# 3GPP_Release-2000

Schedule from MS Project, 1984-10-18 to 2035-12-10, A marks actual dates.

## Calendars

- Standard: Mon-Fri 08:00-12:00, 13:00-17:00; Sat-Sun off. Exceptions (off unless hours are given): 2000-01-15 08:00-12:00, 13:00-17:00, 2009-05-30 08:00-12:00, 13:00-17:00, 2011-08-27 to 2011-08-28 08:00-12:00, 13:00-17:00, 2011-09-24 08:00-12:00, 13:00-17:00, 2012-06-02 08:00-12:00, 13:00-17:00, 2012-09-01 08:00-12:00, 13:00-17:00, 2012-11-18 08:00-12:00, 13:00-17:00, 2012-11-24 08:00-12:00, 13:00-17:00, 2013-02-16 08:00-12:00, 13:00-17:00, 2013-06-02 08:00-12:00, 13:00-17:00, 2013-08-10 to 2013-08-11 08:00-12:00, 13:00-17:00, 2013-09-14 08:00-12:00, 13:00-17:00, 2014-03-01 08:00-12:00, 13:00-17:00, 2014-08-24 08:00-12:00, 13:00-17:00, 2014-09-21 08:00-12:00, 13:00-17:00, 2014-10-05 08:00-12:00, 13:00-17:00, 2016-06-18 08:00-12:00, 13:00-17:00.

## Resources

| Resource |
| --- |
| NP |
| N1 |
| N2 |
| N3 |
| N4 |
| N5 |
| TP |
| T1 |
| T2 |
| T3 |
| RP |
| R1 |
| R2 |
| R3 |
| R4 |
| SP |
| S1 |
| S2 |
| S3 |
| S4 |
| S5 |
| PCG |
| GP |
| No |
| CN4 |
| ? |
| WG G2 |
| G2 |
| G1 |
| G4 |
| G3 |
| All |
| Generic |
| MLST |
| G5 |
| S3, G2 |
| WG T2 |
| GP,G1 |
| G4,G5 |
| OMA |
| GP-G2 |
| Yes |
| GP, |
| N4, |
| GP, N1 |
| CT5 |
| C5 |
| C1 |
| C4 |
| C3 |
| C6 |
| G1, |
| 4 |
| ct |
| c,s,r |
| CT,RAN,SA |
| G2, |
| G1, G3 |
| CT6 |
| CT1 |
| CT1, CT3, CT4 |
| C1, C3, C4 |
| CP |
| R5 |
| C |
| Rel-8 |
| GP, G2 |
| R1,R4 |
| S5,C1 |
| CT,RAN,SA,GERAN |
| S3,C1,C4 |
| 5 |
| S1,C1,C3,C4,S5 |
| S1,C1,C3,C5 |
| S1,C1,C3,C4 |
| S1,S5 |
| S2,S3 |
| RAN,SA |
| RP,S5 |
| S2,CT |
| S1,CT |
| S1,CT,GERAN |
| S1,C5 |
| S3,CT |
| S4,CT |
| C1,SA |
| S1,S2 |
| S1,S4 |
| S2,S2,S3,CT |
| S2,S3,CT |
| S1,CT,GX |
| S1,S4,CT |
| S2,S2,S3,S5,CT |
| S1,S2,CT |
| S1,S2,S3,CT |
| S1,S2,S3,S5CT |
| S1,S2,S3,S5,CT |
| S2,S5,CT |
| S4,S3 |
| S1,C1 |
| CP,C1 |
| C1,C3 |
| C1,C3,C4 |
| S1,S5,CT |
| C4,C3 |
| CP,RAN,SA,GERAN |
| S1,S2,S3,S5,CP |
| S2,S3,CP |
| S2,CP |
| S1,CP,GX |
| S1,CP |
| S1,S4,CP |
| S1,S2,CP |
| S1,S2,S3,CP |
| S2,S5,CP |
| S3,CP |
| S1,S5,CP |
| RAN,SA,GERAN |
| S1,S2,S3,S5,C1,C3,C4,C6 |
| S2,S3,C1,C3,C4 |
| S2,C4 |
| S2,C1,C3,C4 |
| S2,C1,C4 |
| S2,S3,C1,C4 |
| S1,C1,C4,G2 |
| C1,C4 |
| S1,C1,C3 |
| S1,S4,C1,C3,C4 |
| S1,S2,S3,C1,C3,C4 |
| S2,S5,C3 |
| S1,S2,C1,C4 |
| S2,C1 |
| S2,C1,C3 |
| S3,C1,C3,C4 |
| S1,S5,C1,C3,C4 |
| S2,C3,C4 |
| C3,C1 |
| R2,R4 |
| R2,R5 |
| RP,R5 |
| RP,S5,R5 |
| R1,R5 |
| S1,C1,R5 |
| S1,C1,S4,R5 |
| GERAN |
| G3new |
| G1, G3new |
| C4,C1,C3 |
| R1.R4 |
| R1, R4 |
| R2,R3 |
| C3,C4 |
| S4,C3 |
| S4,C3,C1,C4 |
| S1,S2,C1 |
| S1,S2<C1,C3,C4 |
| S1,S2,C1,C3,C4 |
| S5,C1,C3,C4 |
| GP,C4 |
| C4,C1 |
| S2,S1 |
| RP,SP,GP |
| RP,SP,CP,GP |
| CP,GP,RP,SP |
| GP,C4,S4 |
| S1,C1,C4 |
| S1,S2,C3,C1 |
| R2,R4,R3 |
| CP,GP, RP,SP |
| S2,S1,C1,S5 |
| S2,S1,C1 |
| S1,C1,S4 |
| S1,S2,GP,C4,R2 |
| S1,GP,R2 |
| S1,C6 |
| S1,S2,C1,S4 |
| S2,S3,S5,C1,C3,C4 |
| S2,S5,C1 |
| S2,S3,S5 |
| CP,GP, RP,SP,TP |
| S2,C4,C1 |
| S1,C1,C4,S3 |
| S2,S5 |
| S3,C1 |
| S3,C4 |
| S1,C4 |
| S2,S5,C3,C1 |
| S2,S1,S5,C1,C4 |
| S1,R1,C3 |
| S1,C1,R2 |
| S2,S1,C1,C4 |
| S1,C1,C6 |
| GP,S4,C4,C1,C3 |
| C3,C1,C4 |
| S1,C4,C1 |
| S1,S3 |
| S1,S2,S5,C3,C4 |
| R4,G1 |
| G1,R4 |
| RP,GP |
| R4,GP |
| R3,R2 |
| C6,RP,SP |
| R5,C6 |
| CP,RP,SP |
| RP,SP,CP |
| R3,S5 |
| S1,S2,RP |
| S1,S2,S5,RP |
| S2,S1,RP |
| Rel-9 |
| S3,C6 |
| S1,S2,S3,S5,RP |
| S2,S1,S3 |
| S1,S2,S3 |
| S1,S2,S3,S5 |
| C6,R5 |
| S1,S2,RP,GP |
| S1,S2,S4,S5,RP,GP |
| GP,G2 |
| GP,GP, N1 |
| GP,S2,G1,G2 |
| GP,R2,R3,S2,G1,G2 |
| GP,S2,S5,R2,R3,G2,G1 |
| GP,R3 |
| N4,S2 |
| GP,RP |
| GP,S2,RP |
| G5,G4 |
| G4,R3 |
| S2,R2,R4 |
| S1,S2,R2,R4 |
| GP,S5 |
| S1,S2,S5 |
| R4,R5 |
| R4,R2,R3,R5 |
| S2,S5,N4,RP |
| S1,S2,S3,S5,NP |
| S2,S4,S5 |
| T2,S1,S4,S5 |
| SP,RP |
| S2,RP |
| S1,S2,CP,G2 |
| CP,SP |
| S1,G2 |
| SP,CP |
| S1,S2,S5,C3 |
| S1,C1,S3 |
| G1,G3new |
| C4, C3, C1C4 |
| C4,C3,C1 |
| S1,S2,S3,S5,R2,R3,R4 |
| S1,S2,S3,R2 |
| S2,S3,S5,C4,R2 |
| S1,S5,C1 |
| S1,S2,S3,C1,C3,C4,R2 |
| Ggp |
| S3,S2,C1,C4,G2 G3new |
| R1,R2,R3,R4 |
| R4,R1,R2,R3 |
| R4,R2,R3 |
| S1,C1,C4,R2 |
| R4,R2 |
| S2,C4,R2,R4 |
| S2,C4,R2 |
| S2,S3,S5,C3,C4,R2 |
| S1,S2,S4,T2 |
| S1,S2,S4 |
| S1,S2,S4,R5 |
| S3,S2,C1,C4,G2,G3new |
| GP,C1 |
| S1,S5,C4 |
| S1,S2,S3,S5,R2,R3,R4,GP |
| GP,C4,C3,C1 |
| SMG9 |
| SMG1 |
| SMG2 |
| N3,R5 |
| N1, N2, N4, G1, G2, R3, S1, SMG2 |
| S1,SMG1 |
| SMG1,N4 |
| N1,C1,N4,S1,T2,G2,SMG1,SMG2,SMG3,SMG7,SMG9 |
| SMG1,N2 |
| S1,S2,N2,N4 |
| N4,N2 |
| G1,G2 |
| G1,G2,C1 |
| G1,G2,N1 |
| SMG2, SMG1, SMG3, SMG4, SMG7, SMG9, SMG10, G1, G2, G3, N1, N3, T2 |
| SMG2,G1 |
| S1,G1,G2 |
| SMG1,N1,G1,G2 |
| G2,G1 |
| G1,G2,G3,S1,S2,SMG1,SMG2,SMG7,N1,N2,N3,N4,T2 |
| 23.003, 23.008, 29.060 |
| S1, S2, SMG1, SMG2, SMG12, G2, N1, N2, N4 |
| S1,S2,SMG1,SMG2,SMG12,G2,N1,N2,N4 |
| S1,SMG2,N1,N2,N4 |
| SMG1,T2 |
| S1,N1,N2,N4 |
| S1,S2,N5 |
| SMG2,SMG7,G2,T2 |
| S3,N1,N2,N3 |
| S3,N1,N2,N4 |
| SMG9,T3 |
| SMG2,SMG3,SMG7,G2,N2 |
| SMG2,N1,G1,G2 |
| S1,N2 |
| N1,N3 |
| S2,N1 |
| N1,N2,N4 |
| N2,N1,N4 |
| N2,N4 |
| S1,T3 |
| T2,N3 |
| S3,N2 |
| T2,S1 |
| S1,N4 |
| SMG1,SMG2,SMG7 |
| N1,S1,T1 |
| SMG1,SMG3 |
| N4,S2,N1 |
| S1,S2,SMG1,SMG2,SMG7,G1,G2,G3,N1,N2,N3,N4,T2 |
| SMG1,N3 |
| S1,N3 |
| CP,SP,SMG |
| CP,SP,TP,GP,SMG |
| NP,SP,TP,GP,SMG |
| NP,GP, RP,SP,TP |
| SMG2,SMG1,SMG3,SMG4,SMG7,SMG9,SMG10,G1,G2,G3,N1,N3,T2 |
| S1,N2,N4 |
| S1,S2,S3,C1,C3,C4,R2,R3 |
| R2,R3,R1,R4 |
| R2,R3,R4 |
| R2,R1,R3,R4 |
| S2,C4,R2,R3,R4 |
| S2,C4,R2,R1,R3,R4 |
| S2,S3,S5,C3,C4,R2,R3,R4 |
| R1,R2,R4 |
| R3,R1,R4 |
| S2, |
| S2,G2, |
| S1,S2,G2, |
| S1,S2,G2,R2,R3, |
| S1,S2,C4,G2,R2,R3 |
| S1,S2,N4,G2,R2,R3 |
| S1,S2,SMG1,SMG2,SMG12,G2,N1,N2,N4,R2,R3 |
| S1,SMG1,T2 |
| S1,SMG1,S2 |
| S1,N4,N2 |
| T2,N1,N3 |
| S3,N2,N4 |
| SMG1,SMG2,SMG3,SMG7,SMG9,N1,C1,N4,S1,T2,G2 |
| SMG1,N2,N4 |
| S2,T2,N1,N2,N4 |
| S1,T2 |
| S1,S2,C4 |
| S1,S2,N4,RP |
| S2,N4 |
| S1,S2,N3,N4,RP |
| S1,S2,SMG1,SMG2,SMG12,T2,G2,N1,N2,N4,R2,R3 |
| S1,T2,N1,N3 |
| S1,S2,SMG1,SMG2,SMG12,T2,G2,N1,N2,N3,N4,R2,R3 |
| S1,S2,S3,SMG1,SMG2,SMG12,G2,N1,N2,N4,R2,R3 |
| S1,S2,SMG,G1,G2,G3,N1,N2,N3,N4,T2 |
| S1,S2,SMG,T2,G2,N1,N2,N3,N4,R2,R3 |
| S1,S3,SMG,G1,G2,G3,N1,N2,N3,N4,T2 |
| S1,S3,T2,N2,N4 |
| S1,S2,SMG,T2,G1,G2,G3,N1,N2,N3,N4 |
| G2,S2 |
| T1,R5 |
| R5,T1 |
| S1,S2,S4,T1,R5 |
| S1,S2,S4,S5,T1,RP,GP |
| S1,S2,S3,S5,R2,R3,R4,GP,C1 |
| S1,S2,S3,SMG1,SMG2,SMG12,N1,N2,N4,R2,R3 |
| S1,S2,SMG,T2,N1,N2,N3,N4,R2,R3 |
| NP,SP,TP,SMG |
| S1,S2,SMG,T2,N1,N2,N3,N4 |
| SMG,N1 |
| SMG |
| S1,S2,SMG1,SMG2,SMG7,N1,N2,N3,N4,T2 |
| SMG2,SMG1,SMG3,SMG4,SMG7,SMG9,SMG10,N1,N3,T2 |
| S1,SMG |
| SMG2,SMG7,T2 |
| SMG2,S2 |
| N1,N2,N4,R3,S1,SMG |
| SMG2,SMG3,SMG7,N2 |
| SMG1,SMG2,SMG3,SMG7,SMG9,N1,C1,N4,S1,T2 |
| S1,S2,SMG,N3,N4,RP |
| S1,S2,S4,SMG,N3,N4,RP |
| S2,C1,C4,R2,R1,R3,R4 |
| R2,S2,S4 |
| G3new,R5 |
| GP,R4 |
| S2,S4,R2 |
| SP,GP |
| RP,SP |
| S2,S1,S3,S5 |
| S3,S1 |
| N4,N1,N2,S2 |
| S2,G1,G2,R2,R3 |
| S2,G1,G2 |
| G1,G2,R2,R3 |
| N4,T3 |
| S3,S2,N1,N4,T3,OMA |
| T2,S1,S4,S5,OMA |
| S2,N3 |
| S4,S1 |
| N4,N3,S1 |
| R5,G3new |
| R4,R2,R1 |
| S2,R2 |
| C3, C4,C1 |
| S3,C1,C4,C3 |
| C1,C4,C3 |
| S2,C1,C4,C3 |
| R3,R5 |
| S1,S2,C3 |
| R1,R2 |
| S3,C1,C4,G2,G3new |
| R1,R3 |
| GP,N1 |
| R1,R2,R3 |
| R3,R2,R4 |
| R4,R3 |
| S1,S2,R2,R3 |
| S1,S2,S3,C1,C3,C4,R2,R3,R5 |
| S2,S1,S5 |
| C4, C1 |
| C3, C1, C4 |
| S2,S1,S3,S5,C4,C1 |
| S2,C3,C1,C4 |
| S2,S1,S5,C3 |
| GP,S2,C1 |
| GP,S2,C1,G2 |
| G2,S2,C1 |
| v |
| G3new,G1,G2 |
| G1,G2,C1,G3new |
| S2,S1,S5,C1,C3 |
| C1,C3,C4,R5 |
| R2,R1 |
| S1<S2,N1,R2,R5 |
| S1,S2,N1,R2,R5 |
| S2,R5 |
| S1,S2,S5,R5 |
| S2,C1,C4,R2,R1,R3,R4,R5 |
| S1,S2,S3,S5,NP,R5 |
| S1,S2,S4,S5,RP,R5,GP |
| S1,S2,S3,S5,C1,C6,R2,R3,R4 |
| S1,S2,S3,S5,C1,C6,R2,R3,R4,GP |
| S4,R2 |
| S1,S2,C1,C4,G2 |
| S4,C3,C4 |
| S5,C1,C4 |
| S2,C4,C3,C1 |
| C4, C3, C1 |
| S2,S4,R2,C4,C3,C1 |
| GP1,GP2 |
| GP,GP1,GP2 |
| GP,G1,G2 |
| G2,R3 |
| S1,S2,S3,C1,C3,C4,G2 |
| GP,G1,C1 |
| S1,S2,C4,C3,C1 |
| - |
| GP,G1,G2,G3new |
| S1,S2,S3,C1,C3,C4,G2,R2,R3 |
| S1,S2,C1,C3,C4,G2,R2,R3 |
| C1,C6 |
| GP,G2,C4 |
| S2,C3 |
| R5,R4 |
| C4,GP,G2 |
| S1,S2,C1,C4,G2,R2,R3 |
| R1,R2,R4,S3 |
| S2,S5,C3,C1,C4 |
| S2,S4,C4,C3,C1 |
| S2,S4 |
| S3,S1,S2 |
| S1,S2,S3,C1,R2 |
| S3,S1,S2,C1,R2 |
| S2,C3,S5 |
| S1,S2,C1,C4,C3,G2,R2,R3 |
| S5,C4 |
| S2,S1,C3 |
| C1,C4,C3,C6 |
| S1,S2,C1,C4,C3,C6,G2,R2,R3 |
| R1,R2,R4,S3,C4,C6 |
| R4,R1,R4,R1,R2,R3,R3 |
| S2,R3,R2 |
| S1,S2,S5,CP |
| S1,S3,CP |
| C6,C1 |
| R4,R2,R1,R3 |
| R3,R1,R2 |
| R1,R4,R2,R3 |
| S2,C4,C1,C3 |
| R3,R1,R2,R4 |
| C4,S1 |
| S2,S5,R3,GP, |
| S2,S5,R3,GP |
| S1,S2,S3,S5,C1,C3,C4 |
| S2,S3,S5,C1,C3,C4,C6 |
| S5,S1 |
| 03.06.2011 |
| CT1 CT3, CT4 |
| CT3, |
| CT4 |
| CT3 |
| GP,G2,G1 |
| S5,S1,C1 |
| SP,RP,CP |
| SP,CP,GP,RP |
| R1,R2,R4,R3 |
| R4,R2,R5 |
| R2,R4,R5 |
| R1,R2,R4,S2,S3,C4,C6 |
| C1-IETF |
| S4-IETF |
| C1-IETF, C3-IETF, C4-IETF |
| S3-IETF |
| C4-IETF |
| C1-IETF, C3-IETF |
| S2,S4,C1,R2 |
| S2,S4,C3,C4 |
| S2,S4,C1,C3,R2 |
| S1,S2,C1,IETF |
| S4,IETF |
| C1,C4,IETF |
| S2,S4,C1,C3,R2,IETF |
| S3,C1,C4,C3,IETF |
| S3,C4,IETF |
| C1,IETF |
| S1,S2,S3,S5,C1,C3,C4,C6,IETF |
| S2,S3,C1,C4,IETF |
| S1,S2,C1,C3,C4,IETF |
| C1,C3,C4,IETF |
| S1,S5,C1,C3,C4,IETF |
| C1,C3,IETF |
| S2,C1,C3,C4,IETF |
| S2,S4,C3,C4,IETF |
| S5,C1,C4,IETF |
| S5,C1,C3,C4,IETF |
| S2,S3,S5,C1,C3,C4,IETF |
| S2,IETF |
| S3,C1,C3,C4,IETF |
| S2,S3,C1,C3,C4,IETF |
| S3,S2 |
| S3,S2,C1 |
| S3,S1,S2,C1 |
| S2,S5,N3 |
| S1,S2,S3,S5,N1,N3,N4,T3 |
| S5,N4,R3 |
| S1,S2,S5,C1,C4,C3,C6,G2,R2,R3 |
| S2,N1,N4,R3,GP |
| T2,S3 |
| S3,N4,N1 |
| S2,N3,N4 |
| S3,T2 |
| S2,S1,S3,S5,RP,GP |
| S1,S2,S3,S5,R5 |
| S1,S2,S3,S5,NP,T3,T1,R5 |
| S3,T3 |
| GP,S3 |
| S1,S2,S3,S4,S5,RP,R5,GP |
| N1,N4 |
| S1,S2,S3,S4,N1,N3,N4,OMA |
| S2,C1,C3,C4,G2,R2,R3 |
| S1,C4,C3 |
| S2,S1,C1,C4,IETF |
| C1,C3,C4,C6 |
| C4,C1,C6 |
| S1,S2,S3,C1,C3,C4,C6 |
| S2,S1,C1,C3,C4 |
| S1,S2,C1,C3 |
| C1.IETF |
| C1-IETF,C4-IETF |
| G1,C1 |
| G1,S2,C4 |
| G2,S2,C4 |
| R1,R2,R3,R4,R5 |
| R2,R4,R3,R5 |
| R3,R2,R5 |
| R2,R3,C1,C6 |
| S1,S2,S3,C1,C3,C4,C6,R2,R3 |
| R4,R1 |
| S2,S4,C4,C3,C1,IETF |
| S2,C4,C3 |
| S3.C4,C1 |
| G2,C4 |
| R4,G1,G3new |
| C4,G2 |
| S3,C4,C1 |
| R2,R3,R5 |
| R1,R2,R4,R5 |
| S1,S2,S3,S5,C1,C6,R2,R3,R4,R5,GP |
| S1,C1,C4,R2,R5 |
| S2,S3,S5,C3,C4,R2,R3,R4,R5 |
| R2,R1,R3,R4,R5 |
| S3-IETF, C1-IETF |
| S3-IETF,C1-IETF |
| C1-IETF,C3-IETF |
| S2-IETF |
| S2,S1,C1,C3,C4,IETF |
| 25.101, 25.104, 25.141, 25.317 |
| S1,G2,S2,C1 |
| S1,C1,C4,R2,R3,R5 |
| S5,S2 |
| S4,C3,C4,IETF |
| S4,S3,C3,C4,IETF |
| S4,S3,C3,C4 |
| S4,S3,IETF |
| S1,S2,S3,S5,C1,C3,C4,C6,R2,R3 |
| C1,C4,C6 |
| S1,S2,S5,C1,C4,C6,G2,R2,R3 |
| GP,G1,C1,G3new |
| S2,S5,C1,C3 |
| C4,C3,G2 |
| S2,S1,S5,C3,C1,C4 |
| C3,C4,C1 |
| S2,S1,S5,C3,C4,C1 |
| RAN1 |
| RAN2 |
| RAN3 |
| RAN4 |
| R4,R2,R3, |
| Feasibility Study on LTE Device to Device Communications – Radio Aspects |
| SMG1,SMG2,SMG3,SMG7,SMG9,N1,N4,S1,T2 |
| C3-IETF, C4-IETF |
| S3-IETF,C1-IETF,C3-IETF |
| C3-IETF |
| C3,IETF |
| S2,C1,C4,C3,IETF |
| S1,S2,S3,C1,C3,C4,R2,R3,R5,IETF |
| C1-IETF,C3-IETF,C4-IETF |
| C4,C1,C3,IETF |
| S2,C4,C1,C3,IETF |
| C1,C4,C3,IETF |
| S2,S1,T2,N1,N4,R3,R2 |
| S2,S1,S2,S1,N1,N4 |
| S2,S1,N1,N4 |
| S2,R2,G1 |
| S2,S1,S3,S5,N4,R2,R3,GP |
| S1,S2,N4 |
| S2,OMA |
| S2,N4,OMA |
| S2,S5,N4,R2,R4 |
| S2,S5,N4,R2,R4,OMA |
| GP,R2 |
| S1,S2,GP,R2 |
| G1,G3 |
| S1,G2,R2 |
| S2,S5,N4,R2,R4,R5,OMA |
| SR5 |
| S3,C4,C1,R5 |
| S3,S1,C1 |
| S2,C4,C3,G2 |
| SP,CP,RP |
| S3,R5 |
| GP,G2,G3new |
| S1,S2,S3,S4,S5,N1,N3,RP,R5,GP |
| S1,S2,S3,S4,S5,N1,N3,RP,R5,T1,GP |
| S1,S2,S3,S4,S5,N1,N3,RP,R5,T1,GP,G2,G3new |
| S1,S2,S3,S4,S5,N1,N3,R2,R4,R5,T1,GP,G2,G3new |
| S1,S2,S5,C1,C4,C6,G2,R2,R3,G3new |
| SP,CP,RP,GP |
| G2,G1,G3new |
| G2,G1,C1,G3new |
| RAN |
| R |
| S2,S1,S3,S5,R2 |
| S2,S1,S3,S5,R2,R3 |
| S1,S2,S5,C1,C4,C6,G2,R2,R3,R5,G3new |
| C1,C4,R5,IETF |
| C1,R5 |
| R3,R1 |
| R3,GP |
| S3,IETF |
| S1,S2,S5,C1,C3,C4,C6,R2,R3 |
| S3,C4,C1,C3 |
| C1,C4,S1 |
| C1,C4,R3 |
| R2,R1,R3 |
| R1,R4,R2,R3,R5 |
| RAN5 |
| S2,C4,C1,R3 |
| G1,G2,G3new |
| S4,C1 |
| S4,C4,C1,C3 |
| 14/06/2013 08:00 |
| S2,C1,C3,IETF |
| C3, C1 |
| R3,C4 |
| S2,S1,C1,C3 |
| R3,S2,C4 |
| R% |
| G1,C1,G3new |
| R3,S2,C4,G2 |
| S1,S3,N4 |
| S1,OMA |
| S1,S2,S4,OMA |
| S5,S2,N3 |
| S3,C4,C1,C3,IETF |
| S1,S2,S5,C1,C3,C4,C6,R2,R3,R5 |
| S2,S1,S5<c3 |
| S2,C1,C4,C6 |
| S2,S1,S3,C1,C4,C6 |
| S2,S1,S3,C1 |
| R2,R3,R4,G2,G1,G3new |
| C1,C3,R5 |
| ,C4,C6 |
| S2,S1,S3,C1,C4,C6,R2 |
| S2,S1,S3,C1,C4,C6,R2,R3 |
| S2,S1,S3,C1,C3,C4,C6,R2,R3 |
| S1,S2,S3,IETF |
| S1,S2,S3,C1,C3 |
| S1,S2,S3,C4,C1,C3 |
| C1,S1 |
| C34 |
| S1,S2,S3,C1,C4,IETF |
| IETF |
| SMG12 |
| SMG7 |
| SMG3 |
| SMG4 |
| SMG10 |
| C3-IETF,C4-IETF |
| NP,GP,RP,SP,TP |
| S3,G2 |
| R2,S2 |
| R2,S2,C1 |
| R2,C1 |
| S1` |
| R2,S1,C1 |
| C1-IET |
| 18/06/2014 08:00 |
| C4-IET |
| RAN1 (primary) |
| C3.S2 |
| C3-IET |
| S6 |
| ` |
| SA5 |
| Rel-13 |
| Rel-14 |
| 18/06/2015 |
| SA2 |
| S3-IET |
| SA1 |
| SA4-IETF |
| R6 |
| S3LI |
| ITU-R AH |
| Rel-15 |
| CT1-IETF |

## Schedule

| ID | WBS | Task | Type | Duration | Start | Finish | Complete | Remaining | Total slack | Constraint | Resources | Work | Actual work | Release | Acronym | PCG approved | WI rapporteur name | WI rapporteur e-mail | TSG approved | Status Report |
| --- | --- | --- | --- | --- | --- | --- | --- | --- | --- | --- | --- | --- | --- | --- | --- | --- | --- | --- | --- | --- |
| 1 | 1 | Work Plan 3GPP version January 30th 2018 |  | 1d? | 2000-01-03 | 2000-01-03 |  |  | 9394d |  |  |  |  | Rel-16 |  |  |  |  |  |  |
| 2 | 2 | This version includes approval from TSG#78 |  | 1d? | 2000-01-03 | 2000-01-03 |  |  | 5223d |  |  |  |  | Rel-16 |  |  |  |  |  |  |
| 3 | 3 | Next targets: Rel-15: St.3: 06/18; Rel-16 St.1: 12/18 |  | 1d? | 2000-01-03 | 2000-01-03 |  |  | 5223d |  |  |  |  | Rel-16 |  |  |  |  |  |  |
| 4 | 4 | Release 16 Features | milestone | 0d? | 2016-03-15 A | 2016-03-15 A | 100% |  |  | start no earlier than 2016-03-15 |  |  |  | Rel-16 |  |  |  |  |  |  |
| 5 | 5 | **Mobile Communication System for Railways 2** |  | 269d? | 2017-06-05 A | 2018-06-14 | 43% | 154.67d? | 4562d |  | S1 | 6456h | 2743.82h | Rel-16 | MONASTERY2 | 39 | Merkel, Juergen, Nokia | juergen.merkel@nokia.com | 76 |  |
| 6 | 5.1 | Study on MONASTERY2 |  | 269d? | 2017-06-05 A | 2018-06-14 | 50% | 134.5d? | 4562d | finish no earlier than 2018-06-14 | S1 | 2152h | 1076h | Rel-16 | FS_FRMCS2 | 39 | Merkel, Juergen, Nokia | juergen.merkel@nokia.com | 76 |  |
| 7 | 5.2 | Stage 1 of MONASTERY2 |  | 269d? | 2017-06-05 A | 2018-06-14 | 35% | 174.85d? | 4562d | finish no earlier than 2018-06-14 | S1 | 2152h | 753.2h | Rel-16 | MONASTERY2 | 39 | Merkel, Juergen, Nokia | juergen.merkel@nokia.com | 76 |  |
| 8 | 6 | EVS Codec Extension for Immersive Voice and Audio Services |  | 591d? | 2017-09-08 A | 2019-12-13 | 5% | 561.45d? | 4171d | finish no earlier than 2019-12-13 | S4 | 4728h | 236.4h | Rel-16 | IVAS_Codec | 39 | Gibbs, Jon, Huawei Technologies Co Ltd | jon.gibbs@oblisco.com | 77 |  |
| 9 | 7 | Enhancements of Public Warning System |  | 261d? | 2017-12-15 | 2018-12-14 |  |  | 4431d | finish no earlier than 2018-12-14 | S1 | 2088h |  | Rel-16 | ePWS |  | Hyounhee Koo, SyncTechno Inc. | koo at synctechno dot com |  |  |
| 10 | 8 | 5G Voice Service Continuity |  | 59d? | 2017-12-21 | 2018-03-13 |  |  | 4629d | finish no earlier than 2018-03-13 | S1 | 472h |  | Rel-16 | 5GVSC |  | Qun Wei, China Unicom | weiqun5@chinaunico.cn |  |  |
| 11 | 9 | (Small) Technical Enhancements and Improvements for Rel-16 |  | 196d? | 2017-09-11 A | 2018-06-11 A | 100% |  |  | finish no earlier than 2017-12-15 |  |  |  | Rel-16 | TEI16 | 39 |  |  | 77 |  |
| 12 | 10 | Release 16 Studies | milestone | 0d? | 2016-03-15 A | 2016-03-15 A | 100% |  |  | start no earlier than 2016-03-15 |  |  |  | Rel-16 |  |  |  |  |  |  |
| 13 | 11 | Study on Enhancing Topology of SMF and UPF in 5G Networks |  | 266d? | 2017-09-08 | 2018-09-14 |  |  | 4496d | finish no earlier than 2018-09-14 | S2 | 2128h |  | Rel-16 | FS_ETSUN | 39 | Laurent Thiebaut (Nokia) | Laurent.thiebaut@nokia.com | 77 |  |
| 14 | 12 | Study on a Layer for User Centric Identifiers and Authentication |  | 130d? | 2017-12-15 | 2018-06-14 |  |  | 4562d | finish no earlier than 2018-06-14 | S1 | 1040h |  | Rel-16 | FS_LUCIA |  | Bischinger, Kurt; Deutsche Telekom | kurt.bischinger@t-mobile.at |  |  |
| 15 | 13 | Study on Multimedia Priority Service (MPS) Phase 2 |  | 325d? | 2017-12-15 | 2019-03-14 |  |  | 4367d | finish no earlier than 2019-03-14 | S1 | 2600h |  | Rel-16 | FS_MPS2 |  | Singh, Ray P; Vencore Labs | rsingh@vencorelabs.com |  |  |
| 16 | 14 | Study on application layer support for V2X services |  | 196d? | 2017-12-15 | 2018-09-14 |  |  | 4496d | finish no earlier than 2018-09-14 | S6 | 1568h |  | Rel-16 | FS_V2XAPP |  | Niranth Amogh, Huawei Telecommunications India | namogh@huawei.com |  |  |
| 17 | 15 | Study on Enhanced IMS to 5GC Integration |  | 196d? | 2017-12-15 | 2018-09-14 |  |  | 4496d | finish no earlier than 2018-09-14 | S2 | 1568h |  | Rel-16 | FS_eIMS5G |  | Joul, Chris, T-Mobile USA | chris <dot> joul <at> t-mobile <dot> com |  |  |
| 18 | 16 | Study on using Satellite Access in 5G |  | 201d? | 2017-09-08 A | 2018-06-15 | 30% | 140.7d? | 4561d | finish no earlier than 2018-06-15 | S1 | 1608h | 482.4h | Rel-16 | FS_5GSAT | 39 | MICHEL, Cyril | cyril.michel@thalesaleniaspace.com | 77 |  |
| 19 | 17 | Study on 5G message service for MIoT |  | 266d? | 2017-09-08 A | 2018-09-14 | 25% | 199.5d? | 4496d | finish no earlier than 2018-09-14 | S1 | 2128h | 532h | Rel-16 | FS_5GMSG | 39 | Zheng, Jianping, China Mobile | zhengjianping@chinamobile.com | 77 |  |
| 20 | 18 | Study on LAN Support in 5G |  | 204d? | 2017-06-05 A | 2018-03-15 | 65% | 71.4d? | 4627d | finish no earlier than 2018-03-15 | S1 | 1632h | 1060.8h | Rel-16 | FS_5GLAN | 39 | Nasielski, Jack, Qualcomm Incorporated | jackn@qti.qualcomm.com | 76 |  |
| 21 | 19 | Study on the Wireless and Wireline Convergence for the 5G system architecture |  | 269d? | 2017-06-05 A | 2018-06-14 | 15% | 228.65d? | 4562d | finish no earlier than 2018-06-14 | S2 | 2152h | 322.8h | Rel-16 | FS_5WWC | 39 | Marco Spini, Huawei Technologies | m.spini@huawei.com | 76 |  |
| 22 | 20 | Study on positioning use cases |  | 270d? | 2017-06-05 A | 2018-06-15 | 50% | 135d? | 4561d | finish no earlier than 2018-06-15 | S1 | 2160h | 1080h | Rel-16 | FS_5G_HYPOS | 39 | Ries, Lionel, ESA | lionel.ries@esa.int | 76 |  |
| 23 | 21 | Study on Enhancement to the 5GC Location Services |  | 261d? | 2017-12-15 | 2018-12-14 |  |  | 4431d | finish no earlier than 2018-12-14 | S2 | 2088h |  | Rel-16 | FS_eLCS |  | Ming Ai, CATT | aiming@catt.cn |  |  |
| 24 | 22 | Study on Communication for Automation in Vertical Domains |  | 271d? | 2017-03-02 A | 2018-03-15 | 85% | 40.65d? | 4627d | finish no earlier than 2018-03-15 | S1 | 2168h | 1842.8h | Rel-16 | FS_CAV | 38 | Walewski, Joachim, Siemens AG | joachim.walewski@siemens.com | 75 |  |
| 25 | 23 | Study of enablers for Network Automation for 5G |  | 334d? | 2017-06-05 | 2018-09-13 |  |  | 4497d | finish no earlier than 2018-09-13 | S2 | 2672h |  | Rel-16 | FS_eNA | 39 | Xiaobo Wu, Huawei Technologies | wuxiaobo@huawei.com | 76 |  |
| 26 | 24 | Study on integration of ONAP DCAE and 3GPP management architecture |  | 196d? | 2017-12-15 | 2018-09-14 |  |  | 4496d | finish no earlier than 2018-09-14 | S5 | 1568h |  | Rel-16 | FS_ONAPDCAE |  | ORANGE (Jean-Michel Cornily | jeanmichel.cornily@orange.com |  |  |
| 27 | 25 | Study on supporting 256-bit algorithms for 5G |  | 196d? | 2017-12-15 | 2018-09-14 |  |  | 4496d | finish no earlier than 2018-09-14 | S3 | 1568h |  | Rel-16 | FS_256_Algo |  | Evans, Tim, Vodafone Group | tim.evans1@vodafone.com |  |  |
| 28 | 26 | Study on Cellular IoT support and evolution for the 5G System |  | 266d? | 2017-09-08 | 2018-09-14 |  |  | 4496d | finish no earlier than 2018-09-14 | S2 | 2128h |  | Rel-16 | FS_CIoT_5G | 39 | Sebastian Speicher | sspeiche@qti.qualcomm.com | 77 |  |
| 29 | 27 | Study on Enhancement of LTE for Efficient delivery of Streaming Service |  | 336d? | 2016-12-01 A | 2018-03-15 | 75% | 84d? | 4627d | finish no earlier than 2018-03-15 | S1 | 2688h | 2016h | Rel-16 | FS_eLESTR | 38 | China Telecommunications, XIA Xu | xiaxu@ctbri.com.cn | 74 |  |
| 30 | 28 | Study on enhancements to IMS for new real time communication services |  | 71d? | 2017-09-08 A | 2017-12-15 | 75% | 17.75d? | 4691d | start no earlier than 2017-09-08 | S1 | 568h | 426h | Rel-16 | FS_enIMS | 39 | China Mobile, Hui Cai | caihui at chinamobile dot com | 77 |  |
| 31 | 29 | Study on Business Role Models for Network Slicing |  | 266d? | 2017-09-08 A | 2018-09-14 | 10% | 239.4d? | 4496d | start no earlier than 2017-09-08 | S1 | 2128h | 212.8h | Rel-16 | FS_BMNS | 39 | Covell, Betsy, Nokia | betsy.covell@nokia.com | 77 |  |
| 32 | 30 | Study on Access Traffic Steering, Switch and Splitting support in the 5G system architecture |  | 334d? | 2017-06-05 A | 2018-09-13 | 10% | 300.6d? | 4497d | start no earlier than 2017-06-05 | S2 | 2672h | 267.2h | Rel-16 | FS_ATSSS | 39 | So, Tricci, ZTE | tso@ztetx.com | 76 |  |
| 33 | 31 | Study on enhancements of Public Warning System |  | 259d? | 2016-09-19 A | 2017-09-14 A | 100% |  |  | finish no earlier than 2017-09-14 | S1 | 2072h | 2072h | Rel-16 | FS_ePWS | 37 | SyncTechno Inc., Hyounhee Koo | koo at synctechno dot com | 73 |  |
| 34 | 32 | Study on Maritime Communication Services over 3GPP system |  | 455d? | 2016-09-19 A | 2018-06-15 | 55% | 204.75d? | 4561d | finish no earlier than 2018-06-15 | S1 | 3640h | 2002h | Rel-16 | FS_MARCOM | 37 | SyncTechno Inc., Hyounhee Koo | koo at synctechno dot com | 73 |  |
| 35 | 33 | Study on MBMS APIs for Mission Critical Services |  | 204d? | 2017-06-05 A | 2018-03-15 | 20% | 163.2d? | 4627d | finish no earlier than 2018-03-15 | S6 | 1632h | 326.4h | Rel-16 | FS_MBMSAPI_MC | 39 | Ling Zhang, TD Tech Ltd | zhangling@td-tech.com | 76 |  |
| 36 | 34 | Study on encrypted traffic detection and verification |  | 334d? | 2017-06-05 | 2018-09-13 |  |  | 4497d | finish no earlier than 2018-09-13 | S2 | 2672h |  | Rel-16 | FS_ENTRADE | 39 | Yang Xu, China Unicom < | xuyang49@chinaunicom.cn | 76 |  |
| 37 | 35 | Study on architecture enhancements for 3GPP support of advanced V2X services |  | 333d? | 2017-06-05 A | 2018-09-12 | 20% | 266.4d? | 4498d | finish no earlier than 2018-09-12 | S2 | 2664h | 532.8h | Rel-16 | FS_eV2XARC | 39 | LaeYoung Kim, LG Electronics | laeyoung.kim@lge.com | 76 | SP-170412 |
| 38 | 36 | Study on Media Handling Aspects of RAN Delay Budget Reporting in MTSI |  | 196d? | 2017-12-15 | 2018-09-14 |  |  | 4496d | finish no earlier than 2018-09-14 | S4 | 1568h |  | Rel-16 | FS_E2E_DELAY |  | Oyman, Ozgur, Company: Intel, | ozgur.oyman@intel.com |  |  |
| 39 | 37 | Study on EPC support for Mobility with Low Latency Communication |  | 196d? | 2017-12-15 | 2018-09-14 |  |  | 4496d | finish no earlier than 2018-09-14 | S2 | 1568h |  | Rel-16 | FS_LLC_Mob |  | Chris PUDNEY | chris dot pudney at vodafone dot com |  |  |
| 40 | 38 | Study on User Plane Protocol in 5GC |  | 195d? | 2017-12-15 | 2018-09-13 |  |  | 4497d | finish no earlier than 2018-09-13 | C4 | 1560h |  | Rel-16 | FS_UPPS |  | Satoru Matsushima, SoftBank Corp | satoru.matsushima@g.softbank.co.jp |  |  |
| 41 | 39 | Release 15 Features | milestone | 0d? | 2016-03-15 A | 2016-03-15 A | 100% |  |  | finish no earlier than 2016-03-15 |  |  |  | Rel-15 |  |  |  |  |  |  |
| 42 | 40 | Release 15 Features on 5G | milestone | 0d? | 2016-06-09 A | 2016-06-09 A | 100% |  |  | finish no earlier than 2016-06-09 |  |  |  | Rel-15 |  |  |  |  |  |  |

Notes:
- 4: -
- 5: 15/12/17: 10%->35 / Impacted TSs and TRs: New 22.289; 22.280; 22.281; 22.282; 22.179
- 6: 15/12/17: 35%->50 / Impacted TSs and TRs: New 22.889
- 7: Impacted TSs and TRs: New 22.289; 22.280; 22.281; 22.282; 22.179
- 8: 15/12/17: added :26.258; 26.256; 26.255; 26.254; 26.253; 26.251; 26.252; 26.250; 26.997; 15/12/17: 0%->5 / Impacted TSs and TRs: 26.114, new; 26.258; 26.256; 26.255; 26.254; 26.253; 26.251; 26.252; 26.250; 26.997
- 10: Impacted TSs and TRs: 22.261
- 12: -
- 13: 15/12/17: 23.726 added; / Impacted TSs and TRs: New; 23.726
- 17: Impacted TSs and TRs: new
- 18: 15/12/17: 22.822 added;; 15/12/17: 0%->30; 15/12/17: FCD:12/17->06/18 / Impacted TSs and TRs: New; 22.822
- 19: 15/12/17: 22.824 added;; 15/12/17: 0%->25 / Impacted TSs and TRs: New; 22.824
- 20: 11/9/17: 0%->35; 15/12/17: 35%->65 / Impacted TSs and TRs: 22.821;
- 21: 11/9/17: 0%->15; 15/12/17: Changed Rel-15->Rel-16 / Impacted TSs and TRs: 23.7XX
- 22: 11/9/17: 0%->10; 15/12/17: 10%->50; 15/12/17: FCD:03/18->06/18 / Impacted TSs and TRs: 22.872
- 23: Impacted TSs and TRs: new
- 24: 7/6/17: 0%->30; 25/8/17: FCD:12/17->03/18; 11/9/17: 30%->65; 15/12/17: 65%->85 / Impacted TSs and TRs: 22.804
- 25: Impacted TSs and TRs: new
- 27: Impacted TSs and TRs: new
- 28: 11/09/17: rapporteur change; 15/12/17: 23.724 added; / Impacted TSs and TRs: New; 23.724
- 29: 2/3/17: 0%->20; 7/6/17: 20%->50; 11/9/17: 50%->70; 15/12/17: 70%->75; 15/12/17: FCD:09/17->03/18 / Impacted TSs and TRs: 22.833
- 30: 11/9/17: 0%->20; 15/12/17: 22.823 added;; 15/12/17: 20%->75 / Impacted TSs and TRs: New; 22.823
- 31: 15/12/17: 22.830 added;; 15/12/17: 0%->10 / Impacted TSs and TRs: New; 22.830
- 32: 11/9/17: 0%->100; 14/9/17: 100%->10; 15/12/17: Changed Rel-15->Rel-16 / Impacted TSs and TRs: new 23.7xx
- 33: 22.xxx; 1/12/16: 0%->5; 2/3/17: 5%->45; 7/6/17: 45%->75; 30/6/17: 22.869 added;; 25/8/17: 75%->95; 15/12/17: 95%->100 / Impacted TSs and TRs: 22.869
- 34: 22.xxx; 1/12/16: 0%->10; 2/3/17: 10%->15; 2/3/17: WID:SP-160556->SP-170166; 10/3/17: FCD:06/17->06/20; 21/3/17: 22.819 added;; 8/6/17: WID:SP-170166->SP-170453; 25/8/17: 15%->35; 15/12/17: 35%->55 / Impacted TSs and TRs: 22.819
- 35: 12/7/17: WID:SP-170596->SP-170598; 11/9/17: 0%->10; 15/12/17: 10%->20; 15/12/17: Changed Rel-15->Rel-16 / Impacted TSs and TRs: new 23.792
- 36: ; 15/12/17: Changed Rel-15->Rel-16 / Impacted TSs and TRs: new
- 37: 11/9/17: 0%->20; 15/12/17: Changed Rel-15->Rel-16 / Impacted TSs and TRs: 23.car
- 38: Impacted TSs and TRs: new
- 39: Impacted TSs and TRs: new
- 41: -
- 42: -

| ID | WBS | Task | Duration | Start | Finish | Complete | Remaining | Total slack | Constraint | Resources | Work | Actual work | Acronym | PCG approved | WI rapporteur name | WI rapporteur e-mail | Release | TSG approved |
| --- | --- | --- | --- | --- | --- | --- | --- | --- | --- | --- | --- | --- | --- | --- | --- | --- | --- | --- |
| 43 | 41 | **5G System - Phase 1** | 528d? | 2016-06-09 A | 2018-06-15 | 62% | 202.07d? | 4561d |  |  | 43648h | 24242.2h | 5GS_Ph1 | 38 | China Mobile, Tao Sun | suntao@chinamobile.com | Rel-15 | 74 |
| 44 | 41.1 | Study on Charging Aspects of 5G System Architecture Phase 1 | 206d? | 2017-03-03 A | 2017-12-15 A | 100% |  |  | finish no earlier than 2017-12-15 | S5 | 1648h | 1648h | FS_5GS_Ph1_CH | 38 | Chen, Shan, Huawei | chenshan@huawei.com | Rel-15 | 75 |
| 45 | 41.2 | (Stage 1 of 5G) New Services and Markets Technology Enablers | 201d? | 2016-06-09 A | 2017-03-15 A | 100% |  |  | finish no earlier than 2017-03-15 | S1 | 1608h | 1608h | SMARTER | 37 | Li, Alice | alice.li@vodafone.com | Rel-15 | 72 |
| 46 | 41.3 | Stage 2 of 5G System - Phase 1 | 271d? | 2016-12-01 A | 2017-12-14 | 95% | 13.55d? | 4692d | finish no earlier than 2017-12-14 | S2 | 2168h | 2059.6h | 5GS_Ph1 | 38 | China Mobile, Tao Sun | suntao@chinamobile.com | Rel-15 | 74 |
| 47 | 41.4 | Security aspects of 5G System - Phase 1 | 271d? | 2017-03-02 A | 2018-03-15 | 65% | 94.85d? | 4627d | finish no earlier than 2018-03-15 | S3 | 2168h | 1409.2h | 5GS_Ph1-SEC | 38 | NTT DOCOMO, Alf Zugenmaier | alf.zugenmaier@hm.edu | Rel-15 | 75 |
| 48 | 41.5 | **CT aspects of 5G System - Phase 1** | 335d? | 2017-03-03 A | 2018-06-14 | 67% | 110.86d? | 4562d |  | ct | 27400h | 16096.1h | 5GS_Ph1-CT | 38 | Song Yue (China Mobile) | songyue at chinamobile.com | Rel-15 | 75 |
| 49 | 41.5.1 | **Studies on CT1 aspects of 5G System - Phase 1** | 205d? | 2017-03-03 A | 2017-12-14 | 95% | 10.25d? | 4692d |  |  | 11480h | 10906h | 5GS_Ph1-CT | 38 | Herrero Veron, Christian (Huawei) | Christian.Herrero at huawei.com | Rel-15 | 75 |
| 50 | 41.5.1.1 | Study on 5G Network selection | 205d? | 2017-03-03 A | 2017-12-14 | 80% | 41d? | 4692d | finish no earlier than 2017-12-14 | C1 | 1640h | 1312h | 5GS_Ph1-CT | 39 | Herrero Veron, Christian (Huawei) | Christian.Herrero at huawei.com | Rel-15 | 77 |
| 51 | 41.5.1.2 | Study on 5G Mobility management | 205d? | 2017-03-03 A | 2017-12-14 A | 100% |  |  | finish no earlier than 2017-12-14 | C1 | 1640h | 1640h | 5GS_Ph1-CT | 39 | Herrero Veron, Christian (Huawei) | Christian.Herrero at huawei.com | Rel-15 | 77 |
| 52 | 41.5.1.3 | Study on 5G Session management | 205d? | 2017-03-03 A | 2017-12-14 A | 100% |  |  | finish no earlier than 2017-12-14 | C1 | 1640h | 1640h | 5GS_Ph1-CT | 39 | Herrero Veron, Christian (Huawei) | Christian.Herrero at huawei.com | Rel-15 | 77 |
| 53 | 41.5.1.4 | Study on 5G Non-3GPP access networks | 205d? | 2017-03-03 A | 2017-12-14 A | 100% |  |  | finish no earlier than 2017-12-14 | C1 | 1640h | 1640h | 5GS_Ph1-CT | 39 | Herrero Veron, Christian (Huawei) | Christian.Herrero at huawei.com | Rel-15 | 77 |
| 54 | 41.5.1.5 | Study on 5G Interworking with EPC | 205d? | 2017-03-03 A | 2017-12-14 A | 100% |  |  | finish no earlier than 2017-12-14 | C1 | 1640h | 1640h | 5GS_Ph1-CT | 39 | Herrero Veron, Christian (Huawei) | Christian.Herrero at huawei.com | Rel-15 | 77 |
| 55 | 41.5.1.6 | Study on 5G System core network impact on services, network functions and capabilities | 205d? | 2017-03-03 A | 2017-12-14 | 85% | 30.75d? | 4692d | finish no earlier than 2017-12-14 | C1 | 1640h | 1394h | 5GS_Ph1-CT | 39 | Herrero Veron, Christian (Huawei) | Christian.Herrero at huawei.com | Rel-15 | 77 |
| 56 | 41.5.1.7 | Study on 5G Network slicing | 205d? | 2017-03-03 A | 2017-12-14 A | 100% |  |  | finish no earlier than 2017-12-14 | C1 | 1640h | 1640h | 5GS_Ph1-CT | 39 | Herrero Veron, Christian (Huawei) | Christian.Herrero at huawei.com | Rel-15 | 77 |
| 57 | 41.5.2 | **CT1 aspects of 5G System - Phase 1 (normative work)** | 130d? | 2017-12-15 A | 2018-06-14 | 17% | 107.71d? | 4562d |  | C1 | 8320h | 1426.29h | 5GS_Ph1-CT | 38 | Herrero Veron, Christian (Huawei) | Christian.Herrero at huawei.com | Rel-15 | 75 |
| 58 | 41.5.2.1 | 5G Network selection | 130d? | 2017-12-15 | 2018-06-14 |  |  | 4562d | finish no earlier than 2018-06-14 | C1 | 1040h |  | 5GS_Ph1-CT | 39 | Herrero Veron, Christian (Huawei) | Christian.Herrero at huawei.com | Rel-15 | 77 |
| 59 | 41.5.2.2 | 5G Mobility management | 130d? | 2017-12-15 A | 2018-06-14 | 25% | 97.5d? | 4562d | start no earlier than 2017-12-15 | C1 | 1040h | 260h | 5GS_Ph1-CT | 39 | Herrero Veron, Christian (Huawei) | Christian.Herrero at huawei.com | Rel-15 | 77 |
| 60 | 41.5.2.3 | 5G Session management | 130d? | 2017-12-15 A | 2018-06-14 | 35% | 84.5d? | 4562d | start no earlier than 2017-12-15 | C1 | 1040h | 364h | 5GS_Ph1-CT | 39 | Herrero Veron, Christian (Huawei) | Christian.Herrero at huawei.com | Rel-15 | 77 |
| 61 | 41.5.2.4 | 5G Non-3GPP access networks | 130d? | 2017-12-15 A | 2018-06-14 | 20% | 104d? | 4562d | start no earlier than 2017-12-15 | C1 | 1040h | 208h | 5GS_Ph1-CT | 39 | Herrero Veron, Christian (Huawei) | Christian.Herrero at huawei.com | Rel-15 | 77 |
| 62 | 41.5.2.5 | 5G Interworking with EPC | 130d? | 2017-12-15 A | 2018-06-14 | 20% | 104d? | 4562d | start no earlier than 2017-12-15 | C1 | 1040h | 208h | 5GS_Ph1-CT | 39 | Herrero Veron, Christian (Huawei) | Christian.Herrero at huawei.com | Rel-15 | 77 |
| 63 | 41.5.2.6 | 5G System core network impact on services, network functions and capabilities | 130d? | 2017-12-15 A | 2018-06-14 | 10% | 117d? | 4562d | start no earlier than 2017-12-15 | C1 | 1040h | 104h | 5GS_Ph1-CT | 39 | Herrero Veron, Christian (Huawei) | Christian.Herrero at huawei.com | Rel-15 | 77 |
| 64 | 41.5.2.7 | 5G Network slicing | 130d? | 2017-12-15 A | 2018-06-14 | 10% | 117d? | 4562d | start no earlier than 2017-12-15 | C1 | 1040h | 104h | 5GS_Ph1-CT | 39 | Herrero Veron, Christian (Huawei) | Christian.Herrero at huawei.com | Rel-15 | 77 |
| 65 | 41.5.3 | CT3 aspects of 5G System - Phase 1 | 205d? | 2017-03-03 A | 2017-12-14 | 95% | 10.25d? | 4692d | finish no earlier than 2017-12-14 | C3 | 1640h | 1558h | 5GS_Ph1-CT | 38 | Fernandez, Susana (Ericsson) | Susana.Fernandez at ericsson.com | Rel-15 | 75 |
| 66 | 41.5.4 | CT4 aspects of 5G System - Phase 1 | 205d? | 2017-03-03 A | 2017-12-14 | 45% | 112.75d? | 4692d | finish no earlier than 2017-12-14 | C4 | 1640h | 738h | 5GS_Ph1-CT | 38 | Landais, Bruno (Nokia) | Bruno.Landais at nokia.com | Rel-15 | 75 |
| 67 | 41.5.5 | Study on CT6 aspects of 5G System - Phase 1 | 205d? | 2017-03-03 A | 2017-12-14 | 85% | 30.75d? | 4692d | finish no earlier than 2017-12-14 | C6 | 1640h | 1394h | 5GS_Ph1-CT | 38 | micheleb at qti.qualcomm.com | Michele.Berionne at qti.qualcomm.com | Rel-15 | 75 |

Notes:
- 43: 15/12/17: 23.503 added;
- 44: 7/6/17: 0%->15; 11/9/17: 15%->60; 11/9/17: WID:SP-170128->SP-170659; 15/12/17: 60%->100; 21/12/17: WID:SP-170659->SP-170953
- 45: Resulting from FS_SMARTER; 19/9/16: 0%->55; 6/10/16: 22.261 added; 1/12/16: FCD:09/16->03/20; 1/12/16: 55%->75; 2/3/17: 75%->90; 7/6/17: 90%->100 / Impacted TSs and TRs: 22.261
- 46: 3/3/17: 0%->30; 7/6/17: 30%->55; 11/9/17: 55%->75; 21/12/17: 75%->95 / Impacted TSs and TRs: 23.401, 23.167, 23.271, 23.002; 23.228, 23.401, 23.167, 23.271, 23.502, 23.501; 23.503
- 47: 7/6/17: 0%->10; 11/9/17: 10%->30; 15/12/17: 30%->65; 21/12/17: WID:SP-170234->SP-170881 / Impacted TSs and TRs: 33.501
- 48: 5/6/17: WID:CP-170204->CP-171105; 8/9/17: WID:CP-171105->CP-172034. Rapp changed, impacted TS clarified; 15/12/17: added: 24.501 ; 24.502 ; 29.520 added; 29.514; 29.513 ; 29.520a; 29.514a; 15/12/17: 29.519 added;; 15/12/17: 29.516 added;; 15/12/17: 2... / Impacted TSs and TRs: 24.501; 24.502; 29.520; 29.514; 29.513; ; 29.520a; 29.514a; 29.519; 29.516; 29.512; 29.508; 29.507; 29.551
- 49: 18/12/17: WID:CP-172034->CP-173161 / Impacted TSs and TRs: 23.122; 23.040; 23.041; 24.007; 24.301; 24.008; 24.302; 24.011; 24.312; 24.305; 24.368; 27.007
- 50: Task introduced as per CT1's chair e-mail; 11/9/17: 10%->55; 15/12/17: 55%->80
- 51: Task introduced as per CT1's chair e-mail; 11/9/17: 40%->70; 15/12/17: 70%->100
- 52: Task introduced as per CT1's chair e-mail; 11/9/17: 35%->75; 15/12/17: 75%->100
- 53: Task introduced as per CT1's chair e-mail; 11/9/17: 15%->55; 15/12/17: 55%->100
- 54: Task introduced as per CT1's chair e-mail; 11/9/17: 15%->45; 15/12/17: 45%->100
- 55: Task introduced as per CT1's chair e-mail; 11/9/17: 20%->65; 15/12/17: 65%->85
- 56: Task introduced as per CT1's chair e-mail; 11/9/17: 10%->45; 15/12/17: 45%->100
- 57: Impacted TSs and TRs: 23.122; 23.040; 23.041; 24.007; 24.301; 24.008; 24.302; 24.011; 24.312; 24.305; 24.368; 27.007
- 59: 15/12/17: 0%->25
- 60: 15/12/17: 0%->35
- 61: 15/12/17: 0%->20
- 62: 15/12/17: 0%->20
- 63: 15/12/17: 0%->10
- 64: 15/12/17: 0%->10
- 65: 5/6/17: 0%->20; 15/12/17: 20%->95 / Impacted TSs and TRs: 29.213; 29.214; 29.219; 29.122
- 66: 5/6/17: 0%->5; 11/9/17: 5%->25; 15/12/17: 25%->45 / Impacted TSs and TRs: 23.003; 23.008; 23.380; 29.281; 29.272; 29.274; 29.303
- 67: 5/6/17: 0%->10; 11/9/17: 10%->60; 15/12/17: 60%->85

| ID | WBS | Task | Type | Duration | Start | Finish | Complete | Remaining | Total slack | Constraint | Resources | Work | Actual work | Acronym | PCG approved | WI rapporteur name | WI rapporteur e-mail | Release | TSG approved |
| --- | --- | --- | --- | --- | --- | --- | --- | --- | --- | --- | --- | --- | --- | --- | --- | --- | --- | --- | --- |
| 68 | 41.6 | **IMS impact due to 5GS IP-CAN** |  | 205d? | 2017-09-04 A | 2018-06-15 | 22% | 160.58d? | 4561d |  | ct | 6560h | 1421.33h | 5GS_Ph1-IMSo5G | 39 | Song Yue (China Mobile) | songyue (at) chinamobile (dot) com | Rel-15 | 76 |
| 69 | 41.6.1 | CT1 aspects of IMSo5G |  | 205d? | 2017-09-04 A | 2018-06-15 | 65% | 71.75d? | 4561d | finish no earlier than 2018-06-15 | C1 | 1640h | 1066h | 5GS_Ph1-IMSo5G | 39 | Song Yue, China Mobile | songyue@chinamobile.com | Rel-15 | 77 |
| 70 | 41.6.2 | CT3 aspects of IMSo5G |  | 205d? | 2017-09-04 | 2018-06-15 |  |  | 4561d | finish no earlier than 2018-06-15 | C3 | 1640h |  | 5GS_Ph1-IMSo5G | 39 | Herrero Veron, Christian (Huawei) | Christian.Herrero at huawei.com | Rel-15 | 77 |
| 71 | 41.6.3 | CT4 aspects of IMSo5G |  | 205d? | 2017-09-04 | 2018-06-15 |  |  | 4561d | finish no earlier than 2018-06-15 | C4 | 1640h |  | 5GS_Ph1-IMSo5G | 39 | Herrero Veron, Christian (Huawei) | Christian.Herrero at huawei.com | Rel-15 | 77 |
| 72 | 41.7 | Service Based Interface for 5G Charging |  | 131d? | 2017-12-15 | 2018-06-15 |  |  | 4561d | finish no earlier than 2018-06-15 | S5 | 1048h |  | 5GS_Ph1-SBI_CH |  | Chen, Shan, Huawei | chenshan@huawei.com | Rel-15 |  |
| 73 | 41.8 | Data Charging in 5G System Architecture Phase 1 |  | 131d? | 2017-12-15 | 2018-06-15 |  |  | 4561d | start no earlier than 2017-12-15 | S5 | 1048h |  | 5GS_Ph1-DCH |  | Gardella, Maryse, Nokia | maryse.gardella@nokia.com | Rel-15 |  |
| 74 | 42 | **EPC enhancements to support 5G New Radio via Dual Connectivity** |  | 271d? | 2017-03-02 A | 2018-03-15 | 82% | 48.98d? | 4627d |  |  | 8336h | 7030.4h | EDCE5 | 38 | Chris Pudney, Vodafone Group | Chris Pudney, Vodafone Group | Rel-15 | 75 |
| 75 | 42.1 | SA2 aspects of EDCE5 |  | 141d? | 2017-03-02 A | 2017-09-14 A | 100% |  |  | finish no earlier than 2017-09-14 | S2 | 1128h | 1128h | EDCE5 | 38 | Chris Pudney, Vodafone Group |  | Rel-15 | 75 |
| 76 | 42.2 | SA3 aspects of EDCE5 |  | 141d? | 2017-03-02 A | 2017-09-14 A | 100% |  |  | finish no earlier than 2017-09-14 | S3 | 1128h | 1128h | EDCE5 | 38 | Adrian Escott, Qualcomm Incorporated |  | Rel-15 | 75 |
| 77 | 42.3 | **CT aspects of EDCE5** |  | 139d? | 2017-06-05 A | 2017-12-14 A | 100% |  |  |  | ct | 4448h | 4448h | EDCE5-CT | 39 | Jesús de Gregorio, Ericsson | jesus.de.gregorio@ericsson.com | Rel-15 | 76 |
| 78 | 42.3.1 | CT1 aspects of EDCE5 |  | 139d? | 2017-06-05 A | 2017-12-14 A | 100% |  |  | finish no earlier than 2017-12-14 | C1 | 1112h | 1112h | EDCE5-CT | 39 | Jesús de Gregorio, Ericsson | jesus.de.gregorio@ericsson.com | Rel-15 | 76 |
| 79 | 42.3.2 | CT3 aspects of EDCE5 |  | 139d? | 2017-06-05 A | 2017-12-14 A | 100% |  |  | finish no earlier than 2017-12-14 | C3 | 1112h | 1112h | EDCE5-CT | 39 | Jesús de Gregorio, Ericsson | jesus.de.gregorio@ericsson.com | Rel-15 | 76 |
| 80 | 42.3.3 | CT4 aspects of EDCE5 |  | 139d? | 2017-06-05 A | 2017-12-14 A | 100% |  |  | finish no earlier than 2017-12-14 | C4 | 1112h | 1112h | EDCE5-CT | 39 | Jesús de Gregorio, Ericsson | jesus.de.gregorio@ericsson.com | Rel-15 | 76 |
| 81 | 42.4 | Charging aspects of EDCE5: PS Charging enhancements to support 5G New Radio via Dual Connectivity |  | 204d? | 2017-06-05 A | 2018-03-15 | 20% | 163.2d? | 4627d | finish no earlier than 2018-03-15 | S5 | 1632h | 326.4h | EDCE5-CH | 39 | Törnkvist, Robert, Ericsson | robert.tornkvist(at)ericsson.com | Rel-15 | 76 |
| 82 | 43 | **New Radio Access Technology** |  | 458d? | 2017-03-15 A | 2018-12-15 | 29% | 324.22d? | 4431d |  | R1 | 9952h | 2907.05h | NR_newRAT | 38 | NTT DOCOMO |  | Rel-15 | 75 |
| 83 | 43.1 | Core part: New Radio Access Technology |  | 328d? | 2017-03-15 A | 2018-06-15 | 70% | 98.4d? | 4561d | finish no earlier than 2018-06-15 | R1 | 2624h | 1836.8h | NR_newRAT-Core | 38 | NTT DOCOMO |  | Rel-15 | 75 |
| 84 | 43.2 | Perf. part: New Radio Access Technology |  | 458d? | 2017-03-15 | 2018-12-15 |  |  | 4431d | finish no earlier than 2018-12-15 | R4 | 3664h |  | NR_newRAT-Perf | 38 | NTT DOCOMO |  | Rel-15 | 75 |
| 85 | 44 | **LTE connectivity to 5G-CN** |  | 328d? | 2017-03-15 A | 2018-06-15 | 20% | 262.41d? | 4561d |  | R2 | 5248h | 1049.5h | LTE_5GCN_connect | 38 | Huawei |  | Rel-15 | 75 |
| 86 | 44.1 | Core part: LTE connectivity to 5G-CN |  | 328d? | 2017-03-15 A | 2018-06-15 | 20% | 262.4d? | 4561d | finish no earlier than 2018-06-15 | R2 | 2624h | 524.8h | LTE_5GCN_connect-Core | 38 | Huawei |  | Rel-15 | 75 |
| 87 | 45 | UE Conformance Test Aspects - 5G system with NR and LTE |  | 392d? | 2017-06-15 A | 2018-12-15 | 5% | 372.4d? | 4431d | finish no earlier than 2018-12-15 | R5 | 3136h | 156.8h | 5GS_NR_LTE-UEConTest | 39 | Ericsson |  | Rel-15 | 76 |
| 88 | 46 | Release 15 Features on V2X | milestone | 0d? | 2016-06-09 A | 2016-06-09 A | 100% |  |  | finish no earlier than 2016-06-09 |  |  |  |  |  |  |  | Rel-15 |  |
| 89 | 47 | **Enhancement of 3GPP support for V2X scenarios** |  | 206d? | 2016-06-09 A | 2017-03-22 A | 100% |  |  |  |  | 1520h | 1520h | eV2X | 38 | Chun, SungDuck, LG Electronics | sungduck.chun@lge.com | Rel-15 | 75 |
| 90 | 47.1 | Study on Enhancement of 3GPP support for V2X services |  | 137d? | 2016-06-09 A | 2016-12-15 A | 100% |  |  | finish no earlier than 2016-12-15 | S1 | 1096h | 1096h | FS_eV2X | 37 | LG Electronics, SungDuck Chun | sungduck.chun@lge.com | Rel-15 | 72 |
| 91 | 47.2 | Stage 1 of Enhancement of 3GPP support for V2X scenarios |  | 53d? | 2017-01-09 A | 2017-03-22 A | 100% |  |  | finish no earlier than 2017-03-22 | S1 | 424h | 424h | eV2X | 38 | Chun, SungDuck, LG Electronics | sungduck.chun@lge.com | Rel-15 | 75 |

Notes:
- 68: 8/9/17: WID:CP-171103->CP-172033; FCD: 12/17->06/18
- 69: 14/9/17: 0%->10; 15/12/17: 10%->65; rapporteur changed / Impacted TSs and TRs: 24.229; 24.167
- 70: Impacted TSs and TRs: 29.213; 29.214
- 71: Impacted TSs and TRs: 23.008; 29.228; 29.229; 29.328; 29.329; 23.003
- 72: Impacted TSs and TRs: TS 32.240; TS 32.298
- 73: Impacted TSs and TRs: TS 32.240
- 74: 9/6/17: WID:SP-170058->SP-170583
- 75: 7/6/17: 0%->55; 11/9/17: 55%->90; 15/12/17: 90%->100
- 76: 7/6/17: 0%->60; 11/9/17: 60%->70; 15/12/17: 70%->100
- 77: 18/12/17: WID:CP-171045->CP-173038
- 78: 14/9/17: 0%->65; 15/12/17: 65%->100 / Impacted TSs and TRs: 24.301; 27.007
- 79: Impacted TSs and TRs: 29.212; 29.213; 29.214; 29.215; 29.201
- 80: 11/9/17: 0%->50; 15/12/17: 50%->100 / Impacted TSs and TRs: 23.008; 29.272; 29.230; 29.002; 29.305; 29.274
- 81: 15/12/17: 0%->20 / Impacted TSs and TRs: 32.251; 32.298; 32.299
- 82: follow-up WI of REL-14 SI FS_NR_newRAT completed at RAN #75; 30/6/17: 38.425 added;; 14/9/17: WID:RP-170855->RP-171485; 15/12/17: added: 38.305; 38.113; 37.863-04-01; 37.863-03-01; 37.863-02-01; 38.820-04-01; 38.820-03-01; 38.820-02-01; 15/12/17: 37.324 added; / Impacted TSs and TRs: 38.425; 38.424; 38.423; 38.422; 38.421; 38.420; 38.305; 38.113; 37.863-04-01; 37.863-03-01; 37.863-02-01; 38.820-04-01; 38.820-03-01; 38.820-02-01; 37.324
- 83: follow-up WI of REL-14 SI FS_NR_newRAT; 19/6/17: Compl:0%->22%19/6/17: WID: RP-170855->RP-171485; 30/6/17 & 12/6/17: impacted specs added19/9/17: Compl:22%->50%19/9/17: WID: RP-171485->RP-172115; 15/12/17: added: 38.818; 37.865-01-01; 37.834-01-01; 37....; ; ; 8/1/18: Compl:50%->70%; ; ; 8/1/18: WID: RP-172115->RP-172834 / Impacted TSs and TRs: 37.340;37.834-01-01;37.863-05-01;37.864-41-21;37.865-01-01;38.101;38.104;38.12?;38.201/2;38.211/2;38.213to215;38.300;38.304to307;38.321to323;38.331;38.401;38.410to414;38.455;38.470to475;38.815;38.817-01-02;38.818; 38.113
- 84: follow-up WI of REL-14 SI FS_NR_newRAT completed at RAN #75; 19/6/17: WID: RP-170855->RP-171485; 12/7/17: 38.133 added;; 12/7/17: 38.141 added;; 19/9/17: WID: RP-171485->RP-172115; 15/12/17: 38.101-4 added; 8/1/18: WID: RP-172115->RP-172834 / Impacted TSs and TRs: 38.133; 38.141; 38.101-4
- 85: no Perf. part; 14/9/17: WID:RP-170840->RP-171432
- 86: no Perf. Part19/6/17: Compl:0%->5%19/6/17: WID: RP-170840->RP-17143219/9/17: Compl:5%->10%; 8/1/18: Compl:10%->20%; ...
- 87: ; 19/9/17: Compl:0%->2%; ;…; 15/12/17: impacted specs add; 15/12/17: 38.508-2 added;; ... / Impacted TSs and TRs: 38.507-1; 38.533; 38.522; 38.521-1-2-3; 38.508; 38.509; 38.903; 38.905; 38.523-1-2-3; ; 38.508-2
- 88: -
- 90: 19/9/16: 30%->70; 6/10/16: 22.886 added; 1/12/16: 70%->95; 2/3/17: 95%->100 / Impacted TSs and TRs: 22.886
- 91: 7/6/17: 90%->100 / Impacted TSs and TRs: 22.186

| ID | WBS | Task | Type | Duration | Start | Finish | Complete | Remaining | Total slack | Constraint | Resources | Work | Actual work | Acronym | PCG approved | Impacted TSs and TRs | WI rapporteur name | Release | TSG approved | WI rapporteur e-mail |
| --- | --- | --- | --- | --- | --- | --- | --- | --- | --- | --- | --- | --- | --- | --- | --- | --- | --- | --- | --- | --- |
| 92 | 48 | **V2X new band combinations for LTE** |  | 328d? | 2017-03-15 A | 2018-06-15 | 50% | 164d? | 4561d |  | R4 | 5248h | 2624h | LTE_V2X_CA_bands | 38 | 36.787 | LG Electronics | Rel-15 | 75 |  |
| 93 | 48.1 | Core part: V2X new band combinations for LTE |  | 328d? | 2017-03-15 A | 2018-06-15 | 50% | 164d? | 4561d | finish no earlier than 2018-06-15 | R4 | 2624h | 1312h | LTE_V2X_CA_bands-Core | 38 |  | LG Electronics | Rel-15 | 75 |  |
| 94 | 49 | **Enhancements on LTE-based V2X Services** |  | 458d? | 2017-03-15 A | 2018-12-15 | 23% | 352.88d? | 4431d |  | R1 | 9952h | 2284.15h | LTE_eV2X | 38 |  | Huawei | Rel-15 | 75 |  |
| 95 | 49.1 | Core part: V2X phase 2 based on LTE |  | 328d? | 2017-03-15 A | 2018-06-15 | 55% | 147.6d? | 4561d | finish no earlier than 2018-06-15 | R1 | 2624h | 1443.2h | LTE_eV2X-Core | 38 | 36.788 | Huawei | Rel-15 | 75 |  |
| 96 | 49.2 | Perf. Part: V2X phase 2 based on LTE |  | 458d? | 2017-03-15 | 2018-12-15 |  |  | 4431d | finish no earlier than 2018-12-15 | R4 | 3664h |  | LTE_eV2X-Perf | 38 |  | Huawei | Rel-15 | 75 |  |
| 97 | 50 | Study on security aspects for LTE support of V2X services |  | 465d? | 2015-09-07 A | 2017-06-15 | 90% | 46.5d? | 4822d | finish no earlier than 2017-06-15 | S3 | 3720h | 3348h | FS_V2XLTE_ARC | 36 | TR 33.885 | Huawei, Marcus Wong | Rel-15 | 70 | mwong@huawei.com |
| 98 | 51 | Study on V2X Media Handling and Interaction |  | 266d? | 2017-09-08 A | 2018-09-14 | 30% | 186.2d? | 4496d | finish no earlier than 2018-09-14 | S4 | 2128h | 638.4h | FS_mV2X | 39 | New; 26.985 | Jung, Kyunghun, Samsung Electronics Co., Ltd | Rel-15 | 77 | kyunghun.jung@samsung.com |
| 99 | 52 | Release 15 Features on Ultra/Highly Reliable Low Latency Communication | milestone | 0d? | 2016-06-09 A | 2016-06-09 A | 100% |  |  | finish no earlier than 2016-06-09 |  |  |  |  |  |  |  | Rel-15 |  |  |
| 100 | 53 | EPC support for E-UTRAN Ultra Reliable Low Latency Communication |  | 135d? | 2017-09-08 A | 2018-03-15 | 15% | 114.75d? | 4627d | finish no earlier than 2018-03-15 | S2 | 1080h | 162h | EPS_URLLC | 39 | 23.401; 23.214; 23.203 | Chris PUDNEY | Rel-15 | 77 | chris dot pudney at vodafone dot com |
| 101 | 54 | **Highly Reliable Low Latency Communication for LTE** |  | 458d? | 2017-03-15 A | 2018-12-15 | 4% | 438.89d? | 4431d |  | R1 | 9952h | 415.26h | LTE_HRLLC | 38 |  | Ericsson | Rel-15 | 75 |  |
| 102 | 54.1 | Core part: Highly Reliable Low Latency Communication for LTE |  | 328d? | 2017-03-15 A | 2018-06-15 | 10% | 295.2d? | 4561d | finish no earlier than 2018-06-15 | R1 | 2624h | 262.4h | LTE_HRLLC-Core | 38 |  | Ericsson | Rel-15 | 75 |  |
| 103 | 54.2 | Perf. part: Highly Reliable Low Latency Communication for LTE |  | 458d? | 2017-03-15 | 2018-12-15 |  |  | 4431d | finish no earlier than 2018-12-15 | R4 | 3664h |  | LTE_HRLLC-Perf | 38 |  | Ericsson | Rel-15 | 75 |  |
| 104 | 55 | Release 15 Features on improvements of Mission Critical (MC) | milestone | 0d? | 2016-06-09 A | 2016-06-09 A | 100% |  |  | finish no earlier than 2016-06-09 |  |  |  |  |  |  |  | Rel-15 |  |  |
| 105 | 56 | Study on MC system migration and interconnect between MCPTT systems |  | 262d? | 2016-06-13 A | 2017-06-12 A | 100% |  |  | finish no earlier than 2017-06-12 | S6 | 2096h | 2096h | FS_MCSMI | 37 | New TR 23.781 | Chater-Lea, David | Rel-15 | 72 |  |
| 106 | 57 | Study on MC Communication Interworking between LTE and non-LTE Systems |  | 262d? | 2016-06-13 A | 2017-06-12 A | 100% |  |  | finish no earlier than 2017-06-12 | S6 | 2096h | 2096h | FS_MCCI | 37 | New TR 23.782 | Monnes, Peter (Harris Corp.) | Rel-15 | 72 |  |
| 107 | 58 | Study on MC Security Enhancements |  | 456d? | 2016-06-17 A | 2018-03-15 | 90% | 45.6d? | 4627d | finish no earlier than 2018-03-15 | S3 | 3648h | 3283.2h | FS_MC_Sec | 37 | TR 33.xxx; 33.280; 39.880 | Haigh, Peter, CESG | Rel-15 | 72 | peter.haigh@cesg.gsi.gov.uk |
| 108 | 59 | Removal of 'over LTE' limitation from Mission Critical Specifications |  | 23d? | 2017-11-15 A | 2017-12-15 A | 100% |  |  | finish no earlier than 2017-12-15 | S1 | 184h | 184h | MCOver |  | 22.179; 22.280; 22.281; 22.282 | Kees Verweij ;The Police of the Netherlands | Rel-15 |  | KeesdotVerweijatPolitiedotNL |
| 109 | 60 | **Enhancements to MCPTT functional architecture and information flows** |  | 336d? | 2017-03-03 A | 2018-06-15 | 55% | 149.71d? | 4561d |  |  | 3248h | 1800.8h | enhMCPTT | 38 | TS 23.280 + TS 23.379 | Dom Lazara, Motorola Solutions | Rel-15 | 75 | dom.lazara@motorolasolutions.com |
| 110 | 60.1 | Stage 2 of enhMCPTT |  | 205d? | 2017-03-03 A | 2017-12-14 A | 100% |  |  | finish no earlier than 2017-12-14 | S6 | 1640h | 1640h | enhMCPTT | 38 | TS 23.280 + TS 23.379 | Dom Lazara, Motorola Solutions | Rel-15 | 75 | dom.lazara@motorolasolutions.com |
| 111 | 60.2 | Stage 3 of enhMCPTT |  | 201d? | 2017-09-08 A | 2018-06-15 | 10% | 180.9d? | 4561d | finish no earlier than 2018-06-15 | C1 | 1608h | 160.8h | enhMCPTT-CT | 39 | 24.379; 24.380; 24.481; 24.482; 24.483; 24.484 | FREDERICKS, Bob | Rel-15 | 77 | bobfredericks@motorolasolutions.com |
| 112 | 61 | **Enhancements to MC Data Functional architecture and information flows** |  | 336d? | 2017-03-03 A | 2018-06-15 | 50% | 166.34d? | 4561d |  |  | 3248h | 1640h | eMCData | 38 | 23.280 + TS 23.282 | David Freeman, Home Office | Rel-15 | 75 | david@dnf-consulting.co.uk |
| 113 | 61.1 | Stage 2 of eMCData |  | 205d? | 2017-03-03 A | 2017-12-14 A | 100% |  |  | finish no earlier than 2017-12-14 | S6 | 1640h | 1640h | eMCData | 38 | 23.280 + TS 23.282 | David Freeman, Home Office | Rel-15 | 75 | david@dnf-consulting.co.uk |
| 114 | 61.2 | Stage 3 of eMCData |  | 201d? | 2017-09-08 | 2018-06-15 |  |  | 4561d | finish no earlier than 2018-06-15 | C1 | 1608h |  | eMCData-CT | 39 | 24.282; 24.582; 24.481; 24.483; 24.484 | HASON, Baruh | Rel-15 | 77 | Baruh.Hason@motorolasolutions.com |
| 115 | 62 | **Enhancements to MC Video Functional architecture and information flows** |  | 270d? | 2017-06-05 A | 2018-06-15 | 25% | 202.29d? | 4561d |  |  | 6042.8h | 1112h | eMCVideo | 39 | 23.280; 23.281 | Niranth Amogh, Huawei Telecommunications (India | Rel-15 | 76 | namogh@huawei.com |
| 116 | 62.1 | Stage 2 of eMCVideo |  | 139d? | 2017-06-05 A | 2017-12-14 A | 100% |  |  | finish no earlier than 2017-12-14 | S6 | 1112h | 1112h | eMCVideo | 39 | 23.280; 23.281 | Niranth Amogh, Huawei Telecommunications (India | Rel-15 | 76 | namogh@huawei.com |

Notes:
- 92: no Perf. part; 12/7/17: 36.787 added;
- 93: no Perf. part; 19/6/17: Compl:0%->20%; ;...; 19/9/17: Compl:20%->40%; 8/1/18: Compl:40%->50%
- 94: follow-up WI of REL-14 WI LTE_V2X for which the Core part was completed at RAN #75; 14/9/17: WID:RP-170798->RP-171069
- 95: follow-up WI of REL-14 WI LTE_V2X for which the Core part was completed at RAN #75; 19/6/17: Compl:0%->15%; ...; 30/6/17: 36.788 added;; 19/9/17: Compl:15%->30%...; 8/1/18: Compl:30%->55%
- 96: follow-up WI of REL-14 WI LTE_V2X for which the Core part was completed at RAN #7519/6/17: WID: RP-170798->RP-17106919/9/17: WID: RP-171069->RP-171740
- 97: 11/12/15: WID:SP-150715->SP-150743. 28/01/16: typo on name corrected, WD corrected (was SP-150743); 7/3/16: 0%->10; 19/9/16: 10%->65; 1/12/16: 65%->85; 6/3/17: 85%->90; 21/3/17: FCD shifted, moved from Rel-14; 21/3/17: FCD:09/16->06/17
- 98: 15/12/17: 26.985 added;; 15/12/17: 0%->30
- 99: -
- 100: 15/12/17: WID:SP-170797->SP-170811; 15/12/17: 0%->15
- 101: 14/9/17: WID:RP-170796->RP-171489
- 102: ; 19/6/17: WID: RP-170796->RP-171489; 8/1/18: Compl:0%->10%; 8/1/18: WID: RP-171489->RP-172845
- 103: ; 19/6/17: WID: RP-170796->RP-171489; 8/1/18: WID: RP-171489->RP-172845
- 104: -
- 105: 28/7/16: 23.781 added; 19/9/16: WID:SP-160340->SP-160526; FCD: 09/16->12/16; 19/9/16: 0%->40; 1/12/16: WID:SP-160526->SP-160880; 1/12/16: 40%->48; 9/12/16: FCD:12/16->06/17, Rel-14->Rel-15; 3/3/17: 48%->60; 7/6/17: 60%->100
- 106: 28/7/16: 23.782 added; 19/9/16: WID:SP-160341->SP-160527; 19/9/16: 0%->20; 1/12/16: WID:SP-160527->SP-160881; 1/12/16: 20%->22; 9/12/16: FCD:12/16->06/17, Rel-14->Rel-15; 3/3/17: 22%->50; 7/6/17: 50%->90; 11/9/17: 90%->100
- 107: 28/7/16: 33.280 added; 28/7/16: 39.880 added; 19/9/16: WID:SP-160374->SP-160567. FCD: 12/16->03/17; 1/12/16: 0%->35; 6/3/17: FCD:03/17->06/17; 6/3/17: 35%->60; 7/6/17: FCD:06/17->12/17 (Rel-14->Rel-15);60%->65; 8/6/17: WID:SP-160567->SP-170416; 11/9/17...; 15/12/17: FCD:12/17->03/18
- 109: 21/3/17: impacted TS/TR added; 7/6/17: 0%->25
- 110: 21/3/17: impacted TS/TR added; 7/6/17: 0%->25; 11/9/17: 25%->45; 15/12/17: 45%->100
- 111: 15/12/17: 0%->10
- 112: 21/3/17: impacted TS/TR added; 7/6/17: 0%->10; 8/6/17: WID:SP-170249->SP-170462
- 113: 21/3/17: impacted TS/TR added; 7/6/17: 0%->10; 8/6/17: WID:SP-170249->SP-170462; 11/9/17: 10%->15; 15/12/17: 15%->100
- 115: 7/6/17: 0%->10
- 116: 7/6/17: 0%->10; 11/9/17: 10%->60; 15/12/17: 60%->100

| ID | WBS | Task | Type | Duration | Start | Finish | Complete | Remaining | Total slack | Constraint | Resources | Work | Actual work | Acronym | PCG approved | WI rapporteur name | WI rapporteur e-mail | Release | TSG approved | Impacted TSs and TRs |
| --- | --- | --- | --- | --- | --- | --- | --- | --- | --- | --- | --- | --- | --- | --- | --- | --- | --- | --- | --- | --- |
| 117 | 62.2 | **Stage 3 of eMCVideo** |  | 201d? | 2017-09-08 | 2018-06-15 |  |  | 4561d |  | ct | 4930.8h |  | eMCVideo-CT | 39 | AMOGH, Niranth | namogh@huawei.com | Rel-15 | 77 |  |
| 118 | 62.2.1 | CT1 aspects of eMCVideo |  | 138.45d? | 2017-09-08 | 2018-06-15 |  |  | 4561d | finish no earlier than 2018-06-15 | C1 | 1107.6h |  | eMCVideo-CT | 39 | AMOGH, Niranth | namogh@huawei.com | Rel-15 | 77 | 24.281; 24.581; 24.481; 24.483; 24.484 |
| 119 | 62.2.2 | CT3 aspects of eMCVideo |  | 138.45d? | 2017-12-05 | 2018-06-15 |  |  | 4561d | finish no earlier than 2018-06-15 | C3 | 1107.6h |  | eMCVideo-CT | 39 | AMOGH, Niranth | namogh@huawei.com | Rel-15 | 77 | 29.165; 29.213; 29.214 |
| 120 | 62.2.3 | CT6 aspects of eMCVideo |  | 138.45d? | 2017-12-05 | 2018-06-15 |  |  | 4561d | finish no earlier than 2018-06-15 | C6 | 1107.6h |  | eMCVideo-CT | 39 | AMOGH, Niranth | namogh@huawei.com | Rel-15 | 77 | 31.102; 31.103 |
| 121 | 63 | MC Security Enhancements |  | 247d? | 2017-06-05 A | 2018-05-15 | 80% | 49.4d? | 4584d | finish no earlier than 2018-05-15 | S3 | 1976h | 1580.8h | eMCSec | 39 | Haigh, Peter, NCSC |  | Rel-15 | 76 | 33.180 |
| 122 | 64 | MBMS usage for MC communication services |  | 206d? | 2017-03-03 A | 2017-12-15 | 95% | 10.3d? | 4691d | finish no earlier than 2017-12-15 | S6 | 1648h | 1565.6h | MBMS_Mcservices | 38 | Magnus Tränk, Ericsson | magnus.trank@ericsson.com | Rel-15 | 75 | TS 23.280 + TS 23.281 + TS 23.282 + TS 23.379 |
| 123 | 65 | MC system migration and interconnection |  | 139d? | 2017-06-05 A | 2017-12-14 | 80% | 27.8d? | 4692d | start no earlier than 2017-06-05 | S6 | 1112h | 889.6h | MCSMI | 39 | Chater-Lea, David; Motorola Solutions | david.chater-lea@motorolasolutions.com | Rel-15 | 76 | TS 23.280; TS 23.379; TS 23.281; TS 23.282 |
| 124 | 66 | MC Communication Interworking between LTE and non-LTE Systems |  | 139d? | 2017-06-05 A | 2017-12-14 | 87% | 18.07d? | 4692d | start no earlier than 2017-06-05 | S6 | 1112h | 967.44h | MCCI | 39 | Monnes, Peter, Harris Corporation | pmonnes at harris dot com | Rel-15 | 76 | New TS 23.283; TS 23.280; TS 23.379; TS 23.282 |
| 125 | 67 | Protocol enhancements for Mission Critical Services |  | 201d? | 2017-09-08 A | 2018-06-15 | 40% | 120.6d? | 4561d | finish no earlier than 2018-06-15 | C1 | 1608h | 643.2h | MCProtoc15 | 39 | Jörgen Axell |  | Rel-15 | 77 |  |
| 126 | 68 | Release 15 Features on MTC-IoT | milestone | 0d? | 2016-06-09 A | 2016-06-09 A | 100% |  |  | finish no earlier than 2016-06-09 |  |  |  |  |  |  |  | Rel-15 |  |  |
| 127 | 69 | Battery Efficient Security for very low Throughput MTC Devices |  | 389d? | 2016-09-19 A | 2018-03-15 | 95% | 19.45d? | 4627d | finish no earlier than 2018-03-15 | S3 | 3112h | 2956.4h | BEST_MTC_Sec | 37 | Evans, Tim, VODAFONE Group Plc. |  | Rel-15 | 73 | 33.401, 43.020, 33.220; 33.163 |
| 128 | 70 | AT Commands for CIoT-Ext |  | 130d? | 2017-12-15 | 2018-06-14 |  |  | 4562d | finish no earlier than 2018-06-14 | C1 | 1040h |  | AT_CIoT-Ext |  | Bakker, John-Luc (Blackberry) | jbakker@blackberry.com | Rel-15 |  | 27.007 |
| 129 | 71 | **Even further enhanced MTC for LTE** |  | 458d? | 2017-03-15 A | 2018-12-15 | 17% | 381.56d? | 4431d |  | R1 | 9952h | 1661.16h | LTE_eMTC4 | 38 | Ericsson |  | Rel-15 | 75 |  |
| 130 | 71.1 | Core part: Even further enhanced MTC for LTE |  | 328d? | 2017-03-15 A | 2018-06-15 | 40% | 196.8d? | 4561d | finish no earlier than 2018-06-15 | R1 | 2624h | 1049.6h | LTE_eMTC4-Core | 38 | Ericsson |  | Rel-15 | 75 |  |
| 131 | 71.2 | Perf. part: Even further enhanced MTC for LTE |  | 458d? | 2017-03-15 | 2018-12-15 |  |  | 4431d | finish no earlier than 2018-12-15 | R4 | 3664h |  | LTE_eMTC4-Perf | 38 | Ericsson |  | Rel-15 | 75 |  |
| 132 | 72 | **Further NB-IoT enhancements** |  | 458d? | 2017-03-15 A | 2018-12-15 | 26% | 339.57d? | 4431d |  | R1 | 9952h | 2573.34h | NB_IOTenh2 | 38 | Huawei |  | Rel-15 | 75 |  |
| 133 | 72.1 | Core part: Further NB-IoT enhancements |  | 328d? | 2017-03-15 A | 2018-06-15 | 48% | 170.56d? | 4561d | finish no earlier than 2018-06-15 | R1 | 2624h | 1259.52h | NB_IOTenh2-Core | 38 | Huawei |  | Rel-15 | 75 |  |
| 134 | 72.2 | Perf. part: Further NB-IoT enhancements |  | 458d? | 2017-03-15 A | 2018-12-15 | 10% | 412.2d? | 4431d | finish no earlier than 2018-12-15 | R4 | 3664h | 366.4h | NB_IOTenh2-Perf | 38 | Huawei |  | Rel-15 | 75 |  |
| 135 | 73 | Release 15 Features related to WLAN | milestone | 0d? | 2016-06-09 A | 2016-06-09 A | 100% |  |  | finish no earlier than 2016-06-09 |  |  |  |  |  |  |  | Rel-15 |  |  |
| 136 | 74 | **Inclusion of WLAN direct discovery technologies as an alternative for ProSe direct discovery** |  | 348d? | 2016-11-15 A | 2018-03-15 | 91% | 31.42d? | 4627d |  |  | 4528h | 4216h | ProSe_WLAN_DD | 38 | Intel Corporation; Ana Lucia Pinheiro | ana.lucia.a.pinheiro@intel.com | Rel-15 | 74 | 22.278 |
| 137 | 74.1 | Stage 1 of ProSe_WLAN_DD |  | 23d? | 2016-11-15 A | 2016-12-15 A | 100% |  |  | finish no earlier than 2016-12-15 | S1 | 184h | 184h | ProSe_WLAN_DD | 38 | Intel Corporation; Ana Lucia Pinheiro | ana.lucia.a.pinheiro@intel.com | Rel-15 | 74 | 22.278 |
| 138 | 74.2 | Stage 2 of ProSe_WLAN_DD |  | 76d? | 2017-03-02 A | 2017-06-15 A | 100% |  |  | finish no earlier than 2017-06-15 | S2 | 608h | 608h | ProSe_WLAN_DD_Stage2 | 38 | Intel, Sašo Stojanovski | saso.stojanovski@intel.com | Rel-15 | 75 |  |
| 139 | 74.3 | **Stage 3 of ProSe_WLAN_DD** |  | 134d? | 2017-06-02 A | 2017-12-06 A | 100% |  |  |  | ct | 3216h | 3216h | ProSe_WLAN_DD_Stage3 | 39 | Intel, Vivek Gupta | vivek.g.gupta@intel.com | Rel-15 | 76 |  |
| 140 | 74.3.1 | CT1 aspects of ProSe_WLAN_DD |  | 134d? | 2017-06-02 A | 2017-12-06 A | 100% |  |  | finish no earlier than 2017-12-06 | C1 | 1072h | 1072h | ProSe_WLAN_DD_Stage3 | 39 | Intel, Vivek Gupta | vivek.g.gupta@intel.com | Rel-15 | 76 | 24.334 |
| 141 | 74.3.2 | CT4 aspects of ProSe_WLAN_DD |  | 134d? | 2017-06-02 A | 2017-12-06 A | 100% |  |  | finish no earlier than 2017-12-06 | C4 | 1072h | 1072h | ProSe_WLAN_DD_Stage3 | 39 | Intel, Vivek Gupta | vivek.g.gupta@intel.com | Rel-15 | 76 | 29.345; 29.230; 23.008 |
| 142 | 74.4 | Charging of ProSe_WLAN_DD |  | 65d? | 2017-12-15 A | 2018-03-15 | 40% | 39d? | 4627d | finish no earlier than 2018-03-15 | S5 | 520h | 208h | ProSe_WLAN_DD-CH | 38 | Yizhi Yao, Intel Corporation | yizhi.yao@intel.com | Rel-15 | 74 | 32.277; 32.298; 32.299 |

Notes:
- 121: 15/12/17: 0%->80; 15/12/17: FCD:12/17->03/18; 21/12/17: FCD:03/18->05/18. Exception in SP-171056
- 122: 21/3/17: impacted TS/TR added; 7/6/17: 0%->45; 8/9/17: WID:SP-170075->SP-170686; 8/9/17: FCD:09/17->12/17; 11/9/17: 45%->70; 15/12/17: 70%->95
- 123: 12/7/17: WID:SP-170402->SP-170577; 11/9/17: 0%->20; 15/12/17: 20%->80
- 124: 11/9/17: 0%->40; 15/12/17: 40%->87
- 125: 14/9/17: 0%->15; 15/12/17: 15%->40
- 126: -
- 127: 6/10/16: 33.163 added 6/3/17: FCD:12/16->09/17; 6/3/17: 0%->20. Moved from Rel-14.; 7/6/17: 20%->95; 15/12/17: FCD:09/17->03/18
- 129: WI LTE_feMTC-Core got a 3 months exception granted by RAN #75 to complete in REL-14; note: RAN #75 approved WID RP-170732 with working agreement; 14/9/17: WID:RP-170732->RP-171427
- 130: WI LTE_feMTC-Core got a 3 months exception granted by RAN #75 to complete in REL-14; note: RAN #75 approved WID RP-170732 with working agreement; 19/6/17: Compl:0%-...; 19/9/...; 8/1...
- 131: note: RAN #75 approved WID RP-170732 with working agreement19/6/17: WID: RP-170732->RP-171427; 8/1/18: WID: RP-171427->RP-172811
- 132: follow-up WI of REL-14 WI NB_IOTenh which got an exception granted at RAN #75 to complete by RAN #76; note: RAN #75 approved WID RP-170852 with working agreement; 14/9/17: WID:RP-170852->RP-171428
- 133: follow-up WI of REL-14 WI NB_IOTenh which got an exception granted at RAN #75 to complete by RAN #76; note: RAN #75 approved WID RP-170852 with working agreement; ;...1...; 8/1/1...
- 134: follow-up WI of REL-14 WI NB_IOTenh which got an exception granted at RAN #75 to complete by RAN #76; note: RAN #75 approved WID RP-170852 with working agreement; ;...;...; 8/1...
- 135: -
- 136: 1/12/16: 0%->100
- 137: 1/12/16: 0%->100
- 138: 6/3/17: 0%->55; 7/6/17: 55%->100
- 139: 18/12/17: WID:CP-171102->CP-173084
- 140: 14/9/17: 0%->60; 15/12/17: 60%->100
- 141: 15/12/17: 0%->100
- 142: 15/12/17: 0%->40

| ID | WBS | Task | Type | Duration | Start | Finish | Complete | Remaining | Total slack | Constraint | Resources | Work | Actual work | Acronym | PCG approved | Release | TSG approved | Impacted TSs and TRs | WI rapporteur name | WI rapporteur e-mail |
| --- | --- | --- | --- | --- | --- | --- | --- | --- | --- | --- | --- | --- | --- | --- | --- | --- | --- | --- | --- | --- |
| 143 | 75 | **Complementary Features for Voice services over WLAN** |  | 525d? | 2016-06-13 A | 2018-06-14 | 48% | 274.71d? | 4562d |  |  | 10416h | 4656h | VoWLAN | 39 | Rel-15 | 76 |  |  |  |
| 144 | 75.1 | Study on Complementary Features for Voice services over WLAN |  | 199d? | 2016-06-13 A | 2017-03-15 A | 100% |  |  | finish no earlier than 2017-03-15 | S2 | 1592h | 1592h | FS_VoWLAN | 37 | Rel-15 | 72 | 23.751 | Nokia (Nicolas Drevon | nicolas.drevon@nokia.com |
| 145 | 75.2 | Stage 2 of VoWLAN |  | 23d? | 2017-05-09 A | 2017-06-08 A | 100% |  |  | finish no earlier than 2017-06-08 | S2 | 184h | 184h | VoWLAN | 39 | Rel-15 | 76 | 23.402 | Drevon Nicolas, Nokia | nicolas.drevon@nokia.com |
| 146 | 75.3 | **CT aspects of VoWLAN** |  | 270d? | 2017-06-02 A | 2018-06-14 | 33% | 180d? | 4562d |  | ct | 8640h | 2880h | VoWLAN-CT | 39 | Rel-15 | 76 |  | Jennifer Liu (Nokia) | Jennifer.Liu at nokia.com |
| 147 | 75.3.1 | CT1 aspects of VoWLAN |  | 270d? | 2017-06-02 A | 2018-06-14 A | 100% |  |  | finish no earlier than 2018-06-14 | C1 | 2160h | 2160h | VoWLAN-CT | 39 | Rel-15 | 76 | 24.302 ; 24.312 ; 24.244 | Jennifer Liu (Nokia) | Jennifer.Liu at nokia.com |
| 148 | 75.3.2 | CT4 aspects of VoWLAN |  | 270d? | 2017-06-02 | 2018-06-14 |  |  | 4562d | finish no earlier than 2018-06-14 | C4 | 2160h |  | VoWLAN-CT | 39 | Rel-15 | 76 | 29.274 | Jennifer Liu (Nokia) | Jennifer.Liu at nokia.com |
| 149 | 75.3.3 | CT6 aspects of VoWLAN |  | 270d? | 2017-06-02 | 2018-06-14 |  |  | 4562d | finish no earlier than 2018-06-14 | C6 | 2160h |  | VoWLAN-CT | 39 | Rel-15 | 76 | 31.102 | Jennifer Liu (Nokia) | Jennifer.Liu at nokia.com |
| 150 | 76 | Release 15 Features on Virtual Reality (VR) | milestone | 0d? | 2016-03-01 A | 2016-03-01 | 32% | 0d? | 5161d |  |  |  |  |  |  | Rel-15 |  |  |  |  |
| 151 | 77 | Study on Virtual Reality |  | 402d? | 2016-03-01 A | 2017-09-12 A | 100% |  |  | finish no earlier than 2017-09-12 | S4 | 3216h | 3216h | FS_VR | 36 | Rel-15 | 71 | TR 26.918 | Gilles TENIOU, Orange | gilles.teniou@orange.com |
| 152 | 78 | Study on QoE metrics for VR |  | 266d? | 2017-09-08 A | 2018-09-14 | 10% | 239.4d? | 4496d | finish no earlier than 2018-09-14 | S4 | 2128h | 212.8h | FS_QoE_VR | 39 | Rel-15 | 77 | New; 26.929; 26.119 | Li Ji | lily.jili@huawei.com |
| 153 | 79 | Study on 3GPP codecs for VR audio |  | 71d? | 2017-09-08 A | 2017-12-15 A | 100% |  |  | finish no earlier than 2017-12-15 | S4 | 568h | 568h | FS_CODVRA | 39 | Rel-15 | 77 | 26.918 | Toftgård, Tomas, Ericsson | tomas.toftgard@ericsson.com |
| 154 | 80 | Test Methodologies for the Evaluation of Perceived Listening Quality in Immersive Audio Systems |  | 201d? | 2017-09-08 A | 2018-06-15 | 15% | 170.85d? | 4561d | finish no earlier than 2018-06-15 | S4 | 1608h | 241.2h | LiQuImAS | 39 | Rel-15 | 77 | New; 26.861; 26.261; 26.260; 26.259 | Schevciw, Andre – Qualcomm Incorporated | aschevci@qti.qualcomm.com |
| 155 | 81 | Addition of HDR to TV Video Profiles |  | 71d? | 2017-09-08 A | 2017-12-15 A | 100% |  |  | finish no earlier than 2017-12-15 | S4 | 568h | 568h | HDR | 39 | Rel-15 | 77 | TS 26.116; TS 26.346; TS 26.234; TS 26.247; TS 26.244 | Thomas Stockhammer, Qualcomm Incorporated | tsto@qti.qualcomm.com |
| 156 | 82 | Virtual Reality Profiles for Streaming Media |  | 201d? | 2017-09-08 A | 2018-06-15 | 25% | 150.75d? | 4561d | finish no earlier than 2018-06-15 | S4 | 1608h | 402h | VRStream | 39 | Rel-15 | 77 | TS 26.247; TS 26.346; TS 26.234; new TS; 26.118 | Thomas Stockhammer, Qualcomm Incorporated | tsto@qti.qualcomm.com |
| 157 | 83 | Release 15 other Features | milestone | 0d? | 2016-06-09 A | 2016-06-09 | 39% | 0d? | 5089d |  |  |  |  |  |  | Rel-15 |  |  |  |  |
| 158 | 84 | Increasing the number of EPS bearers |  | 131d? | 2017-12-15 | 2018-06-15 |  |  | 4561d | finish no earlier than 2018-06-15 | S2 | 1048h |  | INOBEAR |  | Rel-15 |  | 23.401; 23.167 | Andy.Bennett, Samsung | a <dot> bennett <at> Samsung.com |
| 159 | 85 | **Increased number of E-UTRAN data bearers** |  | 131d? | 2017-12-15 | 2018-06-15 |  |  | 4561d |  | R2 | 2096h |  | INOBEARRAN |  | Rel-15 |  |  | Samsung |  |
| 160 | 85.1 | Core part: Increased number of E-UTRAN data bearers |  | 131d? | 2017-12-15 | 2018-06-15 |  |  | 4561d | finish no earlier than 2018-06-15 | R2 | 1048h |  | INOBEARRAN-Core |  | Rel-15 |  |  | Samsung |  |
| 161 | 86 | **Remote UE access via relay UE** |  | 534d? | 2016-03-01 A | 2018-03-15 | 90% | 54.84d? | 4627d |  | S1 | 8704h | 4592.72h | REAR | 36 | Rel-15 | 71 | 22.278, 22.115 | Huawei, Laurence Meriau | laurence.meriau@huawei.com |
| 162 | 86.1 | Study on architecture enhancements to ProSe UE-to-Network Relay |  | 206d? | 2016-12-01 A | 2017-09-14 A | 100% |  |  | finish no earlier than 2017-09-14 | S2 | 1648h | 1648h | FS_REAR | 38 | Rel-15 | 74 | 23.733 | Dario Serafino Tonesi, Huawei | dario.tonesi@huawei.com |
| 163 | 86.2 | Study on security aspects of enhancements to ProSe UE-to-Network Relay |  | 271d? | 2017-03-02 A | 2018-03-15 | 79% | 56.91d? | 4627d | finish no earlier than 2018-03-15 | S3 | 2168h | 1712.72h | FS_REAR_Sec | 38 | Rel-15 | 75 |  |  | lihe2@huawei.com |
| 164 | 86.3 | Stage 1 for REAR |  | 77d? | 2016-03-01 A | 2016-06-15 A | 100% |  |  | finish no earlier than 2016-06-15 | S1 | 616h | 616h | REAR | 36 | Rel-15 | 71 | 22.278, 22.115 | Huawei, Laurence Meriau | laurence.meriau@huawei.com |
| 165 | 87 | **Enhanced VoLTE performance** |  | 401d? | 2016-12-01 A | 2018-06-14 | 49% | 202.68d? | 4562d |  |  | 5152h | 2548h | eVoLP |  | Rel-15 |  |  |  |  |
| 166 | 87.1 | Stage 2 of eVoLP |  | 47d? | 2017-10-12 A | 2017-12-15 A | 100% |  |  | finish no earlier than 2017-12-15 | S2 | 376h | 376h | eVoLP |  | Rel-15 |  | 23.401; 23.203 | Xiaobo Wu, Huawei | wuxiaobo@ huawei.com |

Notes:
- 144: 28/7/16: 23.751 added; 19/9/16: 0%->10., 7/12/16: moved from Rel-14, according to SP-160806; 6/3/17: 10%->80; 7/6/17: 80%->100
- 145: 15/12/17: 0%->100
- 147: 14/9/17: 0%->70; 15/12/17: 70%->100
- 150: -
- 151: 11/6/16: 0%->10; 19/9/16: 10%->40, FCD: 12/16->03/17; 1/12/16: FCD:03/17->06/17; 1/12/16: 40%->35; 14/12/16: 35%->45; 14/12/16: FCD:06/17->09/17; 6/3/17: 45%->55; 7/6/17: 55%->70; 11/9/17: 70%->100
- 152: 15/12/17: 26.929 added;; 15/12/17: 26.119 added;; 15/12/17: FCD:06/18->09/18; 15/12/17: 0%->10
- 153: 15/12/17: 0%->100; 15/12/17: FCD:09/17->12/17
- 154: 15/12/17: added: 26.861; 26.261; 26.260; 26.259; 15/12/17: 0%->15
- 155: 15/12/17: 0%->100
- 156: 15/12/17: 26.118 added;; 15/12/17: 0%->25
- 157: -
- 161: Previously known as "wearable devices"; 9/6/16: 0%->100; 9/6/16: WID:SP-160231->SP-160371
- 162: 1/12/16: 0%->5. Study on Stage 2 for REAR. When normative work completed, Stage 1 and Stage 2 shall be in the same release; 6/3/17: 5%->30; 7/6/17: 30%->60; 11/9/17: 60%->95; 15/12/17: 95%->100
- 163: 7/6/17: 0%->15; 11/9/17: 15%->50; 15/12/17: 50%->79
- 164: Previously known as "wearable devices"; 9/6/16: 0%->100; 9/6/16: WID:SP-160231->SP-160371; 15/12/17: moved Rel-14->Rel-15

| ID | WBS | Task | Duration | Start | Finish | Complete | Remaining | Total slack | Constraint | Resources | Work | Actual work | Acronym | WI rapporteur name | WI rapporteur e-mail | Release | PCG approved | TSG approved | Status Report |
| --- | --- | --- | --- | --- | --- | --- | --- | --- | --- | --- | --- | --- | --- | --- | --- | --- | --- | --- | --- |
| 167 | 87.2 | **CT aspects on enhanced VoLTE performance** | 130d? | 2017-12-15 | 2018-06-14 |  |  | 4562d |  |  | 2080h |  | eVoLP-CT | Yan, Yali, Huawei | yanyali@huawei.com | Rel-15 |  |  |  |
| 168 | 87.2.1 | CT3 aspects of EvoLP | 130d? | 2017-12-15 | 2018-06-14 |  |  | 4562d | finish no earlier than 2018-06-14 | C3 | 1040h |  | eVoLP-CT | Yan, Yali, Huawei | yanyali@huawei.com | Rel-15 |  |  |  |
| 169 | 87.2.2 | CT4 aspects of EvoLP | 130d? | 2017-12-15 | 2018-06-14 |  |  | 4562d | finish no earlier than 2018-06-14 | C4 | 1040h |  | eVoLP-CT | Yan, Yali, Huawei | yanyali@huawei.com | Rel-15 |  |  |  |
| 170 | 87.3 | **Study on enhanced VoLTE performance** | 336d? | 2016-12-01 A | 2018-03-15 | 81% | 65.31d? | 4627d |  |  | 2696h | 2172h | FS_eVoLP | Fabrice Plante, Intel | fabrice.m.plante@intel.com | Rel-15 | 38 | 74 |  |
| 171 | 87.3.1 | S2 aspects of FS_eVoLP | 206d? | 2016-12-01 A | 2017-09-14 A | 100% |  |  | finish no earlier than 2017-09-14 | S2 | 1648h | 1648h | FS_eVoLP | Xiaobo Wu |  | Rel-15 | 38 | 74 |  |
| 172 | 87.3.2 | S4 aspects of FS_eVoLP | 131d? | 2017-09-14 A | 2018-03-15 | 50% | 65.5d? | 4627d | finish no earlier than 2018-03-15 | S4 | 1048h | 524h | FS_eVoLP | Venkatraman, Atti, Qualcomm Incorporated | vatti@qti.qualcomm.com | Rel-15 | 39 | 77 |  |
| 173 | 88 | **Unlicensed Spectrum Offloading System** | 555d? | 2016-02-01 A | 2018-03-15 | 85% | 81.22d? | 4627d |  | S1 | 7392h | 2608h | USOS | Edward Hall, Qualcomm Incorporated | edhall@qti.qualcomm.com | Rel-15 | 36 | 71 | SP-170526 |
| 174 | 88.1 | Study on unlicensed spectrum offloading system enhancements | 141d? | 2016-12-01 A | 2017-06-15 A | 100% |  |  | finish no earlier than 2017-06-15 | S2 | 1128h | 1128h | FS_USOS | Haris Zisimopoulos, Qualcomm Incorporated | harisz@qti.qualcomm.com | Rel-15 | 38 | 74 |  |
| 175 | 88.2 | Stage 1 of USOS | 22d? | 2016-02-01 A | 2016-03-01 A | 100% |  |  | start no earlier than 2016-02-01 | S1 | 176h | 176h | USOS | Edward Hall, Qualcomm Incorporated | edhall@qti.qualcomm.com | Rel-15 | 36 | 71 | SP-170526 |
| 176 | 88.3 | Stage 2 of USOS | 71d? | 2017-09-08 A | 2017-12-15 A | 100% |  |  | finish no earlier than 2017-12-15 | S2 | 568h | 568h | USOS | Haris Zisimopoulos | harisz@qti.qualcomm.com | Rel-15 | 39 | 77 |  |
| 177 | 88.4 | Stage 3 of USOS | 135d? | 2017-09-08 A | 2018-03-15 | 60% | 54d? | 4627d | finish no earlier than 2018-03-15 | C4 | 1080h | 648h | USOS-CT | Lena Chaponniere, Qualcomm Incorporated | lguellec@qti.qualcomm.com | Rel-15 | 39 | 77 |  |
| 178 | 89 | **Mobile Communication System for Railways** | 398d? | 2016-06-09 A | 2017-12-15 A | 100% |  |  |  |  | 4952h | 4952h | MONASTERY | Merkel, Juergen, Nokia | juergen.merkel@nokia.com | Rel-15 | 38 | 75 |  |
| 179 | 89.1 | Study on Future Railway Mobile Communication System | 267d? | 2016-06-09 A | 2017-06-15 A | 100% |  |  | finish no earlier than 2017-06-15 | S1 | 2136h | 2136h | FS_FRMCS | Merkel, Juergen | Merkel, Juergen - Nokia Networks | Rel-15 | 37 | 72 |  |
| 180 | 89.2 | Study on Application Architecture for the Future Railway Mobile Communication System (stage 2) | 205d? | 2017-03-03 A | 2017-12-14 A | 100% |  |  | finish no earlier than 2017-12-14 | S6 | 1640h | 1640h | FS_FRMCS_ARCH | Oettl, Martin, Nokia | martin(dot)oettl(at)nokia(dot)com | Rel-15 | 38 | 75 |  |
| 181 | 89.3 | Stage 1 of MONASTERY | 76d? | 2017-03-02 A | 2017-06-15 A | 100% |  |  | finish no earlier than 2017-06-15 | S1 | 608h | 608h | MONASTERY | Merkel, Juergen, Nokia | juergen.merkel@nokia.com | Rel-15 | 38 | 75 |  |
| 182 | 89.4 | Stage 2 of MONASTERY | 71d? | 2017-09-08 A | 2017-12-15 A | 100% |  |  | finish no earlier than 2017-12-15 | S6 | 568h | 568h | MONASTERY | Oettl, Martin, Nokia | martin(dot)oettl(at)nokia(dot)com | Rel-15 | 39 | 77 |  |
| 183 | 90 | **PS Data Off Phase 2** | 336d? | 2017-03-02 A | 2018-06-14 | 47% | 178.41d? | 4562d |  |  | 10296h | 4536h | PS_DATA_OFF2 | Murhammer, Leopold, Deutsche Telekom AG | leopold.murhammer@t-mobile.at | Rel-15 | 38 | 75 |  |
| 184 | 90.1 | Stage 2 of PS Data Off Phase 2 | 207d? | 2017-03-02 A | 2017-12-15 A | 100% |  |  | finish no earlier than 2017-12-15 | S2 | 1656h | 1656h | PS_DATA_OFF2 | Murhammer, Leopold, Deutsche Telekom AG | leopold.murhammer@t-mobile.at | Rel-15 | 38 | 75 |  |
| 185 | 90.2 | **Stage 3 of PS Data Off Phase 2** | 270d? | 2017-06-02 A | 2018-06-14 | 33% | 180d? | 4562d |  | ct | 8640h | 2880h | PS_DATA_OFF2-CT | Herrero Veron, Christian (Huawei) | Christian.Herrero at huawei.com | Rel-15 | 39 | 76 |  |
| 186 | 90.2.1 | CT1 aspects of PS Data Off Phase 2 | 270d? | 2017-06-02 | 2018-06-14 |  |  | 4562d | finish no earlier than 2018-06-14 | C1 | 2160h |  | PS_DATA_OFF2-CT | Herrero Veron, Christian (Huawei) | Christian.Herrero at huawei.com | Rel-15 | 39 | 76 |  |
| 187 | 90.2.2 | CT4 aspects of PS Data Off Phase 2 | 270d? | 2017-06-02 A | 2018-06-14 A | 100% |  |  | finish no earlier than 2018-06-14 | C4 | 2160h | 2160h | PS_DATA_OFF2-CT | Herrero Veron, Christian (Huawei) | Christian.Herrero at huawei.com | Rel-15 | 39 | 76 |  |
| 188 | 90.2.3 | CT6 aspects of PS Data Off Phase 2 | 270d? | 2017-06-02 | 2018-06-14 |  |  | 4562d | finish no earlier than 2018-06-14 | C6 | 2160h |  | PS_DATA_OFF2-CT | Herrero Veron, Christian (Huawei) | Christian.Herrero at huawei.com | Rel-15 | 39 | 76 |  |
| 189 | 91 | **Northbound APIs for SCEF – SCS/AS Interworking** | 337d? | 2017-03-02 A | 2018-06-15 | 69% | 104.99d? | 4561d |  |  | 9792h | 6982.4h | NAPS | Vaidya, Maulik, Huawei | Maulik.vaidya@huawei.com | Rel-15 | 38 | 75 |  |
| 190 | 91.1 | Stage 2 of NAPS | 142d? | 2017-03-02 A | 2017-09-15 A | 100% |  |  | start no earlier than 2017-03-02 | S2 | 1136h | 1136h | NAPS | Zhu Fenqin, Huawei | zhufenqin@huawei.com | Rel-15 | 38 | 75 |  |

Notes:
- 168: Impacted TSs and TRs: 29.212; 29.213
- 169: Impacted TSs and TRs: 29.274
- 170: 1/12/16: 0%->5; 6/3/17: 5%->50; 7/6/17: 50%->60; 11/9/17: 60%->100 / Impacted TSs and TRs: 23.759
- 171: 1/12/16: 0%->5; 6/3/17: 5%->50; 7/6/17: 50%->60; 11/9/17: 60%->100; 15/12/17: rapporteur changed / Impacted TSs and TRs: 23.759
- 172: 15/12/17: 26.959 added;; 15/12/17: 0%->50 / Impacted TSs and TRs: 26.959
- 173: 08/09/17: Moved from Rel-14
- 174: 1/12/16: 0%->10; 6/3/17: 10%->30; 7/6/17: 30%->90; 11/9/17: 90%->100 / Impacted TSs and TRs: TR 23.729
- 175: Impacted TSs and TRs: 22.101, 22.115
- 176: 15/12/17: 0%->100 / Impacted TSs and TRs: TS 23.401; TS 23.203
- 177: 15/12/17: acronym corrected to USOS-CT as per the approved WID; 18/12/17: 0%->60 / Impacted TSs and TRs: 23.008; 29.272; 29.230; 29.002; 29.305; 29.274
- 179: 19/9/16: 0%->25; 6/10/16: 22.989 added; 1/12/16: 25%->40; 1/12/16: WID:SP-160371->SP-160903; 9/12/16: FCD:12/16->3/201. WID was in SP-160903; 2/3/17: 40%->80; 2/3/17: FCD:03/17->06/17; 7/6/17: 80%->100 / Impacted TSs and TRs: 22.989
- 180: 21/3/17: added impacted TR; 7/6/17: 0%->10; 11/9/17: 10%->50; 15/12/17: 50%->100 / Impacted TSs and TRs: new TR 23.790
- 181: 7/6/17: 0%->10; 8/9/17: WID:SP-170163->SP-170697; 11/9/17: 10%->100 / Impacted TSs and TRs: 22.280; 22.179
- 182: 14/9/17: SA6 and not SA2; 15/12/17: 0%->100 / Impacted TSs and TRs: 23.280; 23.379
- 184: 7/6/17: 0%->10; 11/9/17: 10%->85; 15/12/17: 85%->100; 15/12/17: FCD:09/17->12/17
- 185: 18/12/17: WID:CP-171104->CP-173162
- 186: Impacted TSs and TRs: 24.008; 24.301; 27.007; 24.229; 24.368; 24.167; 24.173; 24.275; 24.341; 24.390; 24.391
- 187: 15/12/17: 0%->100 / Impacted TSs and TRs: 29.272; 29.274; 29.328; 29.329; 29.228; 29.229; 23.008
- 188: Impacted TSs and TRs: 31.102; 31.103; 31.111
- 189: 6/3/17: 0%->10
- 190: 6/3/17: 0%->10; 7/6/17: 10%->85; 30/6/17: 29.122 added;; 11/9/17: 85%->100; 15/12/17: rapoprteur changed / Impacted TSs and TRs: 29.122

| ID | WBS | Task | Duration | Start | Finish | Complete | Remaining | Total slack | Constraint | Resources | Work | Actual work | Acronym | WI rapporteur name | WI rapporteur e-mail | Release | PCG approved | TSG approved | Status Report |
| --- | --- | --- | --- | --- | --- | --- | --- | --- | --- | --- | --- | --- | --- | --- | --- | --- | --- | --- | --- |
| 191 | 91.2 | **Stage 3 of NAPS** | 270d? | 2017-06-02 A | 2018-06-14 | 80% | 54d? | 4562d |  | C3 | 6480h | 5184h | NAPS-CT | Yan, Yali, Huawei, | yanyali@huawei.com | Rel-15 |  |  |  |
| 192 | 91.2.1 | CT3 aspects of NAPS | 270d? | 2017-06-02 A | 2018-06-14 | 65% | 94.5d? | 4562d | finish no earlier than 2018-06-14 | C3 | 2160h | 1404h | NAPS-CT | Yan, Yali, Huawei, | yanyali@huawei.com | Rel-15 | 39 | 76 |  |
| 193 | 91.2.2 | CT4 aspects of NAPS | 270d? | 2017-06-02 A | 2018-06-14 | 95% | 13.5d? | 4562d | finish no earlier than 2018-06-14 | C4 | 2160h | 2052h | NAPS-CT | Yan, Yali, Huawei, | yanyali@huawei.com | Rel-15 |  |  |  |
| 194 | 91.3 | Security aspects of NAPS | 71d? | 2017-09-08 A | 2017-12-15 | 60% | 28.4d? | 4691d | finish no earlier than 2017-12-15 | S3 | 568h | 340.8h | NAPS-Sec | Zhao, Xuwen, Huawei | zhaoxuwen@huawei.com | Rel-15 | 39 | 77 |  |
| 195 | 91.4 | Carging aspects of NAPS | 201d? | 2017-09-08 A | 2018-06-15 | 20% | 160.8d? | 4561d | finish no earlier than 2018-06-15 | S5 | 1608h | 321.6h | NAPS-CH | Chen, Shan, Huawei | chenshan@huawei.com | Rel-15 | 39 | 76 |  |
| 196 | 92 | **Common API Framework for 3GPP Northbound APIs** | 330d? | 2017-03-10 A | 2018-06-14 | 60% | 131.17d? | 4562d |  |  | 2688h | 1619.6h | CAPIF | Suresh Chitturi, Samsung | s.chitturi@samsung.com | Rel-15 | 39 | 77 |  |
| 197 | 92.1 | Study on CAPIF | 135d? | 2017-03-10 A | 2017-09-14 A | 100% |  |  | finish no earlier than 2017-09-14 | S6 | 1080h | 1080h | FS_CAPIF | Suresh Chitturi, Samsung | s.chitturi@samsung.com | Rel-15 | 38 | 75 |  |
| 198 | 92.2 | Stage 2 of CAPIF | 71d? | 2017-09-08 A | 2017-12-15 | 95% | 3.55d? | 4691d | finish no earlier than 2017-12-15 | S6 | 568h | 539.6h | CAPIF | Suresh Chitturi, Samsung | s.chitturi@samsung.com | Rel-15 | 39 | 77 |  |
| 199 | 92.3 | Security aspects of CAPIF | 130d? | 2017-12-15 | 2018-06-14 |  |  | 4562d | finish no earlier than 2018-06-14 | S3 | 1040h |  | CAPIF-Sec | Rajavelsamy Rajadurai, Samsung | rajvel{@]samsung.com | Rel-15 |  |  |  |
| 200 | 93 | **Management and orchestration of 5G networks and network slicing** | 526d? | 2016-06-13 A | 2018-06-15 | 33% | 352.55d? | 4561d |  | S5 | 20000h | 7146.68h | NETSLICE | Jan Groenendijk, Ericsson | jan<dot>groenendijk<at>ericsson<dot>com | Rel-15 | 39 | 76 |  |
| 201 | 93.1 | General aspects of NETSLICE | 526d? | 2016-06-13 A | 2018-06-15 | 46% | 283.61d? | 4561d |  | S5 | 4208h | 1939.14h | NETSLICE | Jan Groenendijk, Ericsson | jan<dot>groenendijk<at>ericsson<dot>com | Rel-15 | 39 | 76 |  |
| 202 | 93.2 | Study on management and orchestration of network slicing for next generation network | 328d? | 2016-06-13 A | 2017-09-12 A | 100% |  |  | finish no earlier than 2017-09-12 | S5 | 2624h | 2624h | FS_MONETS | Ericsson , Robert Petersen |  | Rel-15 | 37 | 72 |  |
| 203 | 93.3 | Study on security aspect of 5G Network Slicing Provisioning | 201d? | 2017-09-08 A | 2018-06-15 | 20% | 160.8d? | 4561d | finish no earlier than 2018-06-15 | S3 | 1608h | 321.6h | FS_NETSLICE_MGT_Sec | SA3: Huawei | lei.zhongding@huawei.com | Rel-15 | 39 | 77 |  |
| 204 | 93.4 | Provisioning of network slicing for 5G networks and services | 269d? | 2017-06-05 A | 2018-06-14 | 15% | 228.65d? | 4562d | finish no earlier than 2018-06-14 | S5 | 2152h | 322.8h | NETSLICE-PRO_NS | Zhang Kai, Huawei | kai.zhangkai@huawei.com | Rel-15 | 39 | 76 |  |
| 205 | 93.5 | Network Resource Model (NRM) for 5G networks and network slicing | 130d? | 2017-12-15 | 2018-06-14 |  |  | 4562d | finish no earlier than 2018-06-14 | S5 | 1040h |  | NETSLICE-5GNRM | Nokia (Weixing Wang | weixing.wang@nokia-sbell.com | Rel-15 |  |  |  |
| 206 | 93.6 | Assurance data and Performance Management for 5G networks and network slicing | 130d? | 2017-12-15 | 2018-06-14 |  |  | 4562d | finish no earlier than 2018-06-14 | S5 | 1040h |  | NETSLICE-ADPM5G | Yizhi Yao, Intel Corporation | yizhi dot yao at intel dot com | Rel-15 |  |  |  |
| 207 | 93.7 | Management and virtualization aspects of 5G networks | 130d? | 2017-12-15 | 2018-06-14 |  |  | 4562d | start no earlier than 2017-12-15 | S5 | 1040h |  | NETSLICE-MNFV5G | Joey Chou, Intel | joey<dot>chou<at>intel<dot>com | Rel-15 |  |  |  |
| 208 | 93.8 | 5G Trace management | 130d? | 2017-12-15 | 2018-06-14 |  |  | 4562d | start no earlier than 2017-12-15 | S5 | 1040h |  | NETSLICE-5GTRACE | Nokia (Anatoly Andrianov | anatoly.andrianov@nokia.com | Rel-15 |  |  |  |
| 209 | 93.9 | Fault Supervision for 5G networks and network slicing | 130d? | 2017-12-15 | 2018-06-14 |  |  | 4562d | start no earlier than 2017-12-15 | S5 | 1040h |  | NETSLICE-FS5G | Zhu Weihong, ZTE | zhu.weihong@zte.com.cn | Rel-15 |  |  |  |
| 210 | 94 | Framework for Live Uplink Streaming | 269d? | 2017-06-05 A | 2018-06-14 | 85% | 40.35d? | 4562d | finish no earlier than 2018-06-14 | S4 | 2152h | 1829.2h | FLUS | Park, Kyungmo, SK Telecom | kyungmo.park@sk.com | Rel-15 | 39 | 76 |  |
| 211 | 95 | Self-Organizing Networks (SON) for Active Antenna System (AAS) deployment management | 201d? | 2017-09-08 A | 2018-06-15 | 80% | 40.2d? | 4561d | finish no earlier than 2018-06-15 | S5 | 1608h | 1286.4h | OAM_SON_AAS | Nokia (Weixing Wang) | weixing.wang@nokia-sbell.com | Rel-15 | 39 | 77 |  |
| 212 | 96 | Service Interactivity | 200d? | 2017-09-08 A | 2018-06-14 | 10% | 180d? | 4562d | finish no earlier than 2018-06-14 | S4 | 1600h | 160h | SerInter | Lo, Charles, Qualcomm Incorporated | clo@qti.qualcomm.com | Rel-15 | 39 | 77 |  |
| 213 | 97 | Server and Network Assisted DASH for 3GPP Multimedia Services | 206d? | 2016-12-01 A | 2017-09-14 A | 100% |  |  | finish no earlier than 2017-09-14 | S4 | 1648h | 1648h | SAND | Ozgur Oyman, Intel | ozgur.oyman@intel.com | Rel-15 | 38 | 74 | SP-170687 |
| 214 | 98 | SAND for MBMS | 135d? | 2017-09-08 A | 2018-03-15 | 50% | 67.5d? | 4627d | finish no earlier than 2018-03-15 | S4 | 1080h | 540h | SAND4M | Thomas Stockhammer, Qualcomm Incorporated | tsto@qti.qualcomm.com | Rel-15 | 39 | 77 |  |
| 215 | 99 | Management Enhancement for EPC CUPS | 196d? | 2017-12-15 | 2018-09-14 |  |  | 4496d | finish no earlier than 2018-09-14 | S5 | 1568h |  | ME_CUPS | Huawei (ZHU, Lei | lei.zhu@huawei.com | Rel-15 |  |  |  |

Notes:
- 191: 5/6/17: 0%->25; 8/9/17: WID:CP-171143->CP-172057; 11/9/17: 25%->40; 11/9/17: 40%->90. 18/12/17: WID corrected; 18/12/17: WID:CP-171143 ->CP-173112 / Impacted TSs and TRs: 29.336; 29.128; 29.230
- 192: 5/6/17: 0%->25; 8/9/17: WID:CP-171143->CP-172057; 11/9/17: 25%->40; 11/9/17: 40%->90; 15/12/17: 90%->65. 18/12/17: WID corrected / Impacted TSs and TRs: 29.336; 29.128; 29.230
- 194: 15/12/17: 0%->60 / Impacted TSs and TRs: 33.187
- 195: 30/6/17: 32.254 added;; 11/9/17: 0%->10; 15/12/17: 10%->20 / Impacted TSs and TRs: New TS; impact 32.240; 32.298; 32.299; 32.254
- 196: 15/12/17: 23.222 added; / Impacted TSs and TRs: New; 23.222
- 197: 21/3/17: added impacted TR; 7/6/17: 0%->35; 8/6/17: WID:SP-170279->SP-170405; 11/9/17: 35%->70; 15/12/17: 70%->100 / Impacted TSs and TRs: new TR 23.722
- 198: 15/12/17: 0%->95 / Impacted TSs and TRs: New
- 200: 21/12/17: WID:SP-170586->SP-170960. Name changed from "Management of Network Slicing in Mobile Networks, Concepts, Use cases and Requirements" / Impacted TSs and TRs: 32.101; 32.103; new
- 201: 21/12/17: created from the Feature level, since SP-170960 contains its own specs and completions / Impacted TSs and TRs: 32.101; 32.103; 28.530
- 202: 28/7/16: 28.801 added; 19/9/16: 0%->10; 1/12/16: 10%->25; 6/3/17: FCD:03/17->06/17; 6/3/17: 25%->60; 21/3/17: moved from rel-14; 7/6/17: FCD:06/17->09/17; 7/6/17: 60%->90; 11/9/17: 90%->100 / Impacted TSs and TRs: 32.8xx; 28.801
- 203: 11/9/17: 0%->5; 15/12/17: 33.811 added;; 15/12/17: 5%->20. Acronym corrected. / Impacted TSs and TRs: 33.811
- 204: 15/12/17: 0%->15; 21/12/17: WID:SP-170580->SP-170955 / Impacted TSs and TRs: new TS
- 205: Impacted TSs and TRs: 28.657; 28.658; 28.659; 28.707; 28.708; 28.709
- 206: Impacted TSs and TRs: 32.425; 32.426; 32.450; 32.451; 32.455
- 207: Impacted TSs and TRs: 28.500; 28.510; 28.511; 28.512; 28.513; 28.515; 28.516; 28.517; 28.518; 28.520; 28.521; 28.522; 28.523; 28.525; 28.526; 28.527; 28.528
- 208: Impacted TSs and TRs: 32.421; 32.422; 32.423; 32.441; 32.442; 32.446
- 209: Impacted TSs and TRs: 32.111-1; 32.111-2; 32.111-6; 28.515; 28.516; 28.517; 28.518
- 210: 30/6/17: 26.238 added;; 11/9/17: 0%->10; 15/12/17: 10%->85; 15/12/17: FCD:12/17->06/18; 21/12/17: WID:SP-170576->SP-170824 / Impacted TSs and TRs: New TS; 26.238
- 211: 15/12/17: 0%->80 / Impacted TSs and TRs: 28.627; 28.628; 28.629; 28.658; 28.659
- 212: 15/12/17: 0%->10 / Impacted TSs and TRs: TS 26.346; TS 26.247; TS 26.347
- 213: 3/3/17: WID:SP-160779->SP-170031; 6/3/17: 0%->15; 7/6/17: 15%->60; 11/9/17: 60%->100 / Impacted TSs and TRs: TS 26.247, 26.233
- 214: 15/12/17: 0%->50; 15/12/17: FCD:12/17->03/18; 21/12/17: WID:SP-170608->SP-170827 / Impacted TSs and TRs: TS 26.247; TS 26.346; TS 26.347; TR26.946
- 215: ASN.1-type of WID, hence later than St3, indpt of CUPS Rel-14 / Impacted TSs and TRs: 32.426; 32.455; 28.658; 28.707; 28.708; 28.709

| ID | WBS | Task | Duration | Start | Finish | Complete | Remaining | Baseline start | Baseline finish | Baseline duration | Total slack | Constraint | Resources | Work | Actual work | Acronym | PCG approved | WI rapporteur name | WI rapporteur e-mail | Release | TSG approved | MCC resp | Acronym_3GU_Export |
| --- | --- | --- | --- | --- | --- | --- | --- | --- | --- | --- | --- | --- | --- | --- | --- | --- | --- | --- | --- | --- | --- | --- | --- |
| 216 | 100 | **Provision of Access to Restricted Local Operator Services by Unauthenticated UEs** | 270d? | 2016-12-01 A | 2017-12-13 | 53% | 126.85d? |  |  |  | 4693d |  |  | 1880h | 996.8h | PARLOS | 38 | Covell, Betsy Nokia | betsy.covell@nokia.com | Rel-15 | 74 |  |  |
| 217 | 100.1 | Study on Provision of Access to Local Operator Services | 75d? | 2016-12-01 A | 2017-03-15 A | 100% |  |  |  |  |  | finish no earlier than 2017-03-15 | S1 | 600h | 600h | FS_PARLOS | 38 | Covell, Betsy | betsy.covell@nokia.com | Rel-15 | 74 |  |  |
| 218 | 100.2 | Stage 1 for PARLOS | 22d? | 2017-05-10 A | 2017-06-08 A | 100% |  |  |  |  |  | finish no earlier than 2017-06-08 | S1 | 176h | 176h | PARLOS | 39 | Covell, Betsy Nokia | betsy.covell@nokia.com | Rel-15 | 76 |  |  |
| 219 | 100.3 | Study on Stage 2 for PARLOS | 138d? | 2017-06-05 A | 2017-12-13 | 20% | 110.4d? |  |  |  | 4693d | finish no earlier than 2017-12-13 | S2 | 1104h | 220.8h | FS_PARLOS_SA2 | 39 | Nokia (Nicolas Drevon | nicolas.drevon@nokia.com | Rel-15 | 76 |  |  |
| 220 | 101 | Enhanced QoE Reporting for MTSI | 204d? | 2017-06-05 A | 2018-03-15 | 80% | 40.8d? |  |  |  | 4627d | finish no earlier than 2018-03-15 | S4 | 1632h | 1305.6h | EQoE_MTSI | 39 | Gunnar Heikkilä, Ericsson LM | gunnar.heikkila@ericsson.com | Rel-15 | 76 |  |  |
| 221 | 102 | **Enhanced Calling Name Service** | 390d? | 2016-09-15 A | 2018-03-14 | 51% | 193.02d? |  |  |  | 4628d |  |  | 5424h | 2608.82h | eCNAM | 37 | Hala Mowafy, Ericsson |  | Rel-15 | 73 |  |  |
| 222 | 102.1 | Stage 1 of eCNAM | 66d? | 2016-09-15 A | 2016-12-15 A | 100% |  |  |  |  |  | finish no earlier than 2016-12-15 | S1 | 528h | 528h | eCNAM | 37 | Hala Mowafy, Ericsson |  | Rel-15 | 73 |  |  |
| 223 | 102.2 | **CT aspects of eCNAM** | 204d? | 2017-06-02 A | 2018-03-14 | 43% | 117.3d? |  |  |  | 4628d |  | ct | 4896h | 2080.82h | eCNAM-CT | 39 | Mowafy, Hala. Ericsson | hala.mowafy@ericsson.com | Rel-15 | 76 |  |  |
| 224 | 102.2.1 | CT1 aspects of eCNAM | 204d? | 2017-06-02 A | 2018-03-14 | 85% | 30.6d? |  |  |  | 4628d | finish no earlier than 2018-03-14 | C1 | 1632h | 1387.2h | eCNAM-CT | 39 | Mowafy, Hala. Ericsson | hala.mowafy@ericsson.com | Rel-15 | 76 |  |  |
| 225 | 102.2.2 | CT3 aspects of eCNAM | 204d? | 2017-06-02 | 2018-03-14 |  |  |  |  |  | 4628d | finish no earlier than 2018-03-14 | C3 | 1632h |  | eCNAM-CT | 39 | Mowafy, Hala. Ericsson | hala.mowafy@ericsson.com | Rel-15 | 76 |  |  |
| 226 | 103 | Enhancement of background data transfer | 38d? | 2017-01-16 A | 2017-03-08 A | 100% |  |  |  |  |  | finish no earlier than 2017-03-08 | S1 | 304h | 304h | eBT | 38 | Atsushi Minokuchi, NTT DOCOMO | minokuchi at nttdocomo dot com | Rel-15 | 75 |  |  |
| 227 | 104 | **Stage-3 SAE Protocol Development - Phase 6** | 272d? | 2017-06-02 A | 2018-06-18 | 55% | 122.41d? |  |  |  | 4560d |  | C1 | 8704h | 4787.16h | SAES6 | 39 | Interdigital, Aghili, Behrouz | Behrouz.aghili@interdigital.com | Rel-15 | 76 |  |  |
| 228 | 104.1 | SAES6 CS Fallback in EPS | 272d? | 2017-06-02 A | 2018-06-18 | 55% | 122.4d? |  |  |  | 4560d | start no earlier than 2017-06-02 | C1 | 2176h | 1196.8h | SAES6-CSFB | 39 | Interdigital, Aghili, Behrouz | Behrouz.aghili@interdigital.com | Rel-15 | 76 |  |  |
| 229 | 104.2 | SAES6 for support for non-3GPP accesses | 272d? | 2017-06-02 A | 2018-06-18 | 55% | 122.4d? |  |  |  | 4560d | start no earlier than 2017-06-02 | C1 | 2176h | 1196.8h | SAES6-non3GPP | 39 | Interdigital, Aghili, Behrouz | Behrouz.aghili@interdigital.com | Rel-15 | 76 |  |  |
| 230 | 104.3 | SAE Protocol Development (Stage 3) - Phase 6 | 272d? | 2017-06-02 A | 2018-06-18 | 55% | 122.4d? |  |  |  | 4560d | start no earlier than 2017-06-02 | C1 | 2176h | 1196.8h | SAES6 | 37 |  |  | Rel-15 | 72 |  |  |
| 231 | 105 | Security Assurance Specification for eNB network product class | 322d? | 2016-09-19 A | 2017-12-12 A | 100% |  |  |  |  |  | finish no earlier than 2017-12-12 | S3 | 2576h | 2576h | SCAS_eNB | 37 | Marcus Wong, Huawei Technologies | mwong@huawei.com | Rel-15 | 73 |  |  |
| 232 | 106 | Security Assurance Specification for PGW network product class | 389d? | 2016-06-17 A | 2017-12-12 A | 100% |  |  |  |  |  | finish no earlier than 2017-12-12 | S3 | 3112h | 3112h | SCAS_PGW | 37 | Peng Jin, China Mobile | pengjin@chinamobile.com | Rel-15 | 72 |  |  |
| 233 | 107 | **Security Assurance Specification for 3GPP network products** | 924d? | 2013-12-09 A | 2017-06-15 | 95% | 43d? | 2013-12-09 | 2015-03-18 | 334d? | 4822d |  | S3 | 23192h | 15716.5h | SCAS | 32 | NTT DOCOMO | Alf Zugenmaier (alf.zugenmaier@hm.edu) | Rel-15 | 62 | Mirko | SCAS |
| 234 | 107.1 | STOPPED - TR on Pilot development of Security Assurance Specification for MME network product class | 266d? | 2013-12-09 A | 2014-12-12 A | 100% |  | 2013-12-09 | 2014-12-10 | 264d? |  | finish no earlier than 2014-12-12 | S3 | 2120h | 2120h | SCAS-SA3Pil_TR | 32 | NTT DOCOMO | Alf Zugenmaier (alf.zugenmaier@hm.edu) | Rel-14 | 62 | Mirko |  |
| 235 | 107.2 | TR on Security Assurance scheme for 3GPP network products | 791d? | 2013-12-09 A | 2016-12-15 A | 100% |  | 2013-12-09 | 2014-12-10 | 264d? |  | finish no earlier than 2016-12-15 | S3 | 6320h | 6320h | SCAS-SA3TR | 32 | NTT DOCOMO | Alf Zugenmaier (alf.zugenmaier@hm.edu) | Rel-14 | 62 | Mirko |  |
| 236 | 107.3 | Security Assurance Specification for 3GPP network product classes | 920d? | 2013-12-13 A | 2017-06-15 | 90% | 92d? | 2013-12-10 | 2015-03-18 | 333d? | 4822d | finish no earlier than 2017-06-15 | S3 | 7360h | 6624h | SCAS-SA3 | 32 | China Mobile | Judy Zhu (zhuhongru@chinamobile.com) | Rel-15 | 62 | Mirko |  |
| 237 | 108 | HPLMN Radio Access Technology deployment Optimisation in Network Selection | 76d? | 2017-03-02 A | 2017-06-15 A | 100% |  |  |  |  |  | finish no earlier than 2017-06-15 | S1 | 608h | 608h | HORNS | 38 | Eddy Hall, Qualcomm Incorporated | edhall@qti.qualcomm.com | Rel-15 | 75 |  |  |
| 238 | 109 | **IMS Stage-3 IETF Protocol Alignment** | 4832d? | 2017-06-02 A | 2035-12-10 | 3% | 4704.06d? |  |  |  | 0d |  | ct | 158928h | 2884.39h | IMSProtoc9 | 39 | Dr. Belling, Thomas, Nokia | Thomas.Belling@nokia.com | Rel-15 | 76 |  |  |
| 239 | 109.1 | CT1 aspects of IMS Stage-3 IETF Protocol Alignment | 269d? | 2017-06-02 A | 2018-06-13 | 60% | 107.6d? |  |  |  | 4563d | finish no earlier than 2018-06-13 | C1 | 2152h | 1291.2h | IMSProtoc9 | 39 | Dr. Belling, Thomas, Nokia | Thomas.Belling@nokia.com | Rel-15 | 76 |  |  |

Notes:
- 216: 7/6/17: 0%->100 / Impacted TSs and TRs: 22.115; 22.101; 22.228
- 217: 1/12/16: 0%->75; 2/3/17: 75%->100 / Impacted TSs and TRs: 22.xxx
- 218: 7/6/17: 0%->100 / Impacted TSs and TRs: 22.115; 22.101; 22.228
- 219: 11/9/17: 0%->20 / Impacted TSs and TRs: 23.xxx
- 220: 11/9/17: 0%->10; 15/12/17: 10%->80 / Impacted TSs and TRs: TS 26.114
- 221: 1/12/16: 0%->100 / Impacted TSs and TRs: 22.173
- 222: 1/12/16: 0%->100; 30/6/17: 24.196 added; / Impacted TSs and TRs: 22.173; 24.196
- 224: 14/9/17: 0%->40; 15/12/17: 40%->85 / Impacted TSs and TRs: 24.259; 24.604; 24.606; 24.607; 24.608; 24.610; 24.611; 24.615; 24.616; 24.629; 24.642; 24.647; 24.654
- 225: Impacted TSs and TRs: 29.165
- 226: Impacted TSs and TRs: 22.101
- 227: Impacted TSs and TRs: 23.122; 24.008; 24.167; 24.229; 24.301; 24.302; 24.303; 24.304; 24.305; 24.312; 29.018; 29.118; 24.368
- 228: 14/9/17: 0%->20; 15/12/17: 20%->55 / Impacted TSs and TRs: 23.122; 24.008; 24.167; 24.229; 24.301; 24.302; 24.303; 24.304; 24.305; 24.312; 29.018; 29.118; 24.368
- 229: 14/9/17: 0%->20; 15/12/17: 20%->55 / Impacted TSs and TRs: 23.122; 24.008; 24.167; 24.229; 24.301; 24.302; 24.303; 24.304; 24.305; 24.312; 29.018; 29.118; 24.368
- 230: 14/9/17: 0%->20; 15/12/17: 20%->55
- 231: 6/10/16: 33.216 added; 1/12/16: 0%->5; 6/3/17: 5%->25. Moved from Rel-14.; 7/6/17: FCD:06/17->12/17; 7/6/17: 25%->75; 11/9/17: 75%->100 / Impacted TSs and TRs: TS 33.117, TR 33.926; 33.216
- 232: 28/7/16: 33.250 added; 19/9/16: 0%->10; 6/10/16: 33.216 added; 1/12/16: 10%->40. 06/03/17: moved from Rel-14.; 6/3/17: 40%->80; 7/6/17: FCD:06/17->12/17; 7/6/17: 80%->95; 11/9/17: 95%->100 / Impacted TSs and TRs: 33.250; 33.216
- 233: Triggered by Rel-12 TR 33.805 Study on Security Assurance Methodology for 3GPP Network Elements (FS_SECAM); June2015: WID:SP-130718->SP-150292. Aug 15: TR numb added; 28/1/16: 33.926 added; 28/7/16: 33.250 added;06/10/16: moved to Rel-14 as per John/Mir / Impacted TSs and TRs: 33.199; 33.926, 33.117; 33.250
- 234: This TR collects input for the new TS 33.116. Dec.14: 55->70%. 3/3/15: 70->55%. 10/03/15: 55->75%; June2015: Compl:75%->80; 7/12/15: STOPPED AT 80% (marked as 100% here since no more work expected) / Impacted TSs and TRs: New TR 33.806
- 235: This TR contains results of the second WID objective. Dec.14: 75->85%; June2015: Compl:85%->90; 7/12/15: 90%->92; 10/12/15: WID:SP-130718->SP-150716; 19/9/16: 92%->98. FCD set to 12.16 (was 03/16); 6/10/16: 33.216 added; 1/12/16: 81%->100 / Impacted TSs and TRs: New TR 33.916; 33.216
- 236: This TS contains results of the first WID objective; June2015: Compl:0%->5; 7/12/15: 5%->72.; 10/12/15: WID:SP-130718->SP-150716; 7/3/16: 72%->75; 28/7/16: 33.250 added; 19/9/16: 75%->90. FCD set to 12.16 (was 03/16). 6/3/17: moved from Rel-14.; 21/3/17: FCD:12/16->06/17 / Impacted TSs and TRs: New TS 33.116, 33.117; 33.250
- 237: 7/6/17: 75%->100
- 239: 14/9/17: 0%->40; 15/12/17: 40%->60 / Impacted TSs and TRs: 23.218; 24.229; 24.930

| ID | WBS | Task | Type | Duration | Start | Finish | Complete | Remaining | Total slack | Constraint | Resources | Work | Actual work | Acronym | PCG approved | WI rapporteur name | WI rapporteur e-mail | Release | TSG approved | Status Report |
| --- | --- | --- | --- | --- | --- | --- | --- | --- | --- | --- | --- | --- | --- | --- | --- | --- | --- | --- | --- | --- |
| 240 | 109.2 | **(IETF) CT1 aspects of IMS Stage-3 IETF Protocol Alignment** |  | 4832d? | 2017-06-02 A | 2035-12-10 |  | 4831.43d? | 0d |  | C1-IETF | 115968h | 13.78h | IMSProtoc9 | 39 | Dr. Belling, Thomas, Nokia | Thomas.Belling@nokia.com | Rel-15 | 76 |  |
| 241 | 109.2.1 | (IETF) Content-ID header field in SIP (draft-ietf-sipcore-content-id) |  | 4832d? | 2017-06-02 A | 2035-12-10 |  | 4831.1d? | 0d | finish no earlier than 2018-06-13 | C1-IETF | 38656h | 7.2h | IMSProtoc9 |  | Christer Holmberg | christer.holmberg@ericsson.com | Rel-15 |  |  |
| 242 | 109.2.2 | (IETF) P-Visited-Network header updated (draft-jesske-update-p-visited-network ) |  | 4832d? | 2017-06-02 A | 2035-12-10 |  | 4831.75d? | 0d | finish no earlier than 2018-06-13 | C1-IETF | 38656h | 2h | IMSProtoc9 |  | Michael KREIPL, Deutsche Telekom | michael(dot)kreipl(at)telekom(dot)de | Rel-15 |  |  |
| 243 | 109.3 | CT3 aspects of IMS Stage-3 IETF Protocol Alignment |  | 269d? | 2017-06-02 A | 2018-06-13 | 40% | 161.4d? | 4563d | finish no earlier than 2018-06-13 | C3 | 2152h | 860.8h | IMSProtoc9 | 39 | Dr. Belling, Thomas, Nokia | Thomas.Belling@nokia.com | Rel-15 | 76 |  |
| 244 | 110 | **Lawful Interception Rel-15** |  | 467d? | 2017-03-02 A | 2018-12-14 | 10% | 420.31d? | 4431d |  |  | 6424h | 642.4h | LI15 | 38 | Alex Leadbeater, BT | alex.leadbeater@bt.com | Rel-15 | 75 |  |
| 245 | 110.1 | Study on R15 Lawful Interception Service |  | 336d? | 2017-03-02 A | 2018-06-14 | 10% | 302.4d? | 4562d | finish no earlier than 2018-06-14 | S3LI | 2688h | 268.8h | FS_15LIS | 38 | Gerry McQuaid, Vodafone | Gerald.McQuaid@vodafone.com | Rel-15 | 75 |  |
| 246 | 110.2 | Normative work on Lawful Interception Rel-15 |  | 467d? | 2017-03-02 A | 2018-12-14 | 10% | 420.3d? | 4431d | finish no earlier than 2018-12-14 | S3LI | 3736h | 373.6h | LI15 | 38 | Alex Leadbeater, BT | alex.leadbeater@bt.com | Rel-15 | 75 |  |
| 247 | 111 | **DL interference mitigation for UMTS** |  | 67d? | 2017-03-15 A | 2017-06-15 A | 100% |  |  |  | R2 | 1072h | 1072h | UTRA_DL_IM | 38 | Qualcomm |  | Rel-15 | 75 |  |
| 248 | 111.1 | Core part: DL interference mitigation for UMTS |  | 67d? | 2017-03-15 A | 2017-06-15 A | 100% |  |  | finish no earlier than 2017-06-15 | R2 | 536h | 536h | UTRA_DL_IM-Core | 38 | Qualcomm |  | Rel-14 | 75 | RP-171135 |
| 249 | 112 | Control and monitoring of Power, Energy and Environmental (PEE) parameters in Radio Access Networks (RAN) |  | 204d? | 2017-06-05 A | 2018-03-15 | 80% | 40.8d? | 4627d | finish no earlier than 2018-03-15 | S5 | 1632h | 1305.6h | PEE_CMON | 39 | Jean-Michel CORNILY, ORANGE |  | Rel-15 | 76 |  |
| 250 | 113 | Management of QoE measurement collection |  | 269d? | 2017-06-05 A | 2018-06-14 | 15% | 228.65d? | 4562d | finish no earlier than 2018-06-14 | S5 | 2152h | 322.8h | QOED | 39 | Petersen, Robert, Ericsson | robert <dot> petersen <at>ericsson<dot>ericsson | Rel-15 | 76 |  |
| 251 | 114 | **Simplified HS-SCCH for UMTS** |  | 198d? | 2017-03-15 A | 2017-12-15 A | 100% |  |  |  | R6 | 3176h | 3176h | UTRA_simple_HSSCCH | 39 | Ericsson |  | Rel-15 | 76 |  |
| 252 | 114.1 | Study on a simplified HS-SCCH for UMTS |  | 67d? | 2017-03-15 A | 2017-06-15 A | 100% |  |  | start no earlier than 2017-03-15 | R1 | 536h | 536h | FS_UTRA_simple_HSSCCH | 38 | gerardo.agni.medina.acosta@ericsson.com | gerardo.agni.medina.acosta@ericsson.com | Rel-15 | 75 |  |
| 253 | 114.2 | Core part: Simplified HS-SCCH for UMTS |  | 132d? | 2017-06-15 A | 2017-12-15 A | 100% |  |  | finish no earlier than 2017-12-15 | R6 | 1056h | 1056h | UTRA_simple_HSSCCH-Core | 39 | Ericsson |  | Rel-15 | 76 | RP-172306 |
| 254 | 115 | Charging for enhancement to Flexible Mobile Service Steering (eFMSS) |  | 139d? | 2017-06-05 A | 2017-12-14 A | 100% |  |  | finish no earlier than 2017-12-14 | S5 | 1112h | 1112h | eFMSS_CH | 39 | Long,Biao, China Telecom | longb.gd@chinatelecom.cn. | Rel-15 | 76 |  |
| 255 | 116 | Receive acoustic output test in the presence of background noise |  | 65d? | 2017-12-15 | 2018-03-15 |  |  | 4627d | finish no earlier than 2018-03-15 | S4 | 520h |  | RAOT |  | ISBERG, Peter, Sony Mobile Communications | peter.isberg [at] sony.com | Rel-15 |  |  |
| 256 | 117 | Speech quality in the presence of ambient noise for super-wideband and fullband modes |  | 131d? | 2017-12-15 | 2018-06-15 |  |  | 4561d | finish no earlier than 2018-06-15 | S4 | 1048h |  | SPAN |  | Reimes, Jan – HEAD acoustics GmbH | jan.reimes@head-acoustics.de | Rel-15 |  |  |
| 257 | 118 | **REST Solution Sets** |  | 455d? | 2016-09-19 A | 2018-06-15 | 71% | 131.58d? | 4561d |  |  | 3624h | 2576h | REST_SS |  |  |  | Rel-15 |  |  |
| 258 | 118.1 | Study on a RESTful HTTP-based Solution Set |  | 322d? | 2016-09-19 A | 2017-12-12 A | 100% |  |  | finish no earlier than 2017-12-12 | S5 | 2576h | 2576h | FS_OAM_RESTFUL | 37 | Nokia: Pollakowski, Olaf | olaf.pollakowski@nokia.com | Rel-15 | 73 |  |
| 259 | 118.2 | REST Solution Sets (normative work) |  | 131d? | 2017-12-15 | 2018-06-15 |  |  | 4561d | start no earlier than 2017-12-15 | S5 | 1048h |  | REST_SS |  | Pollakowski, Olaf, Nokia | olaf.pollakowski@nokia.com | Rel-15 |  |  |
| 260 | 119 | (Small) Technical Enhancements and Improvements for Rel-15 |  | 196d? | 2017-03-17 A | 2017-12-15 A | 100% |  |  | finish no earlier than 2017-12-15 |  |  |  | TEI15 | 35 |  |  | Rel-15 | 68 |  |
| 261 | 120 | (Small) Test Technical Enhancements and Improvements for Rel-15 |  | 196d? | 2017-03-17 A | 2017-12-15 A | 100% |  |  | finish no earlier than 2017-12-15 |  |  |  | TEI15_Test | 38 |  |  | Rel-15 | 75 |  |
| 262 | 121 | Release 15 Features on LTE improvements | milestone | 0d? | 2000-01-01 | 2000-01-01 |  |  | 9395d |  |  |  |  |  |  |  |  | Rel-15 |  |  |
| 263 | 122 | **UL data compression in LTE** |  | 4768d? | 2000-01-03 A | 2018-03-15 | 70% | 1430.4d? | 4627d |  | R2 | 76288h | 53401.6h | LTE_UDC | 39 | CATT |  | Rel-15 | 77 |  |
| 264 | 122.1 | Core part: UL data compression in LTE |  | 4768d? | 2000-01-03 A | 2018-03-15 | 70% | 1430.4d? | 4627d | finish no earlier than 2018-03-15 | R2 | 38144h | 26700.8h | LTE_UDC-Core | 39 | CATT |  | Rel-15 | 77 |  |

Notes:
- 243: 15/12/17: 0%->40 / Impacted TSs and TRs: 29.163; 29.165; 29.949
- 244: 21/12/17: WID:SP-170039->SP-170839
- 245: 12/7/17: 0%->5; 11/9/17: 5%->10
- 246: 12/7/17: 0%->5; 15/12/17: 5%->10
- 247: no Perf. part
- 248: no Perf. part19/6/17: Compl:0%->100%...
- 249: 30/6/17: 28.306 added;; 30/6/17: 28.305 added;; 30/6/17: 28.304 added;; 11/9/17: 0%->20; 15/12/17: 20%->80 / Impacted TSs and TRs: New TSs, TS 52.402; TS 32.405; TS 32.425; TS 32.101; TS 32.103; 28.306; 28.305; 28.304
- 250: 30/6/17: 28.309 added;; 30/6/17: 28.308 added;; 30/6/17: 28.307 added;; 30/6/17: 28.406 added;; 11/9/17: 0%->5; 15/12/17: 5%->15 / Impacted TSs and TRs: 32.101; 32.103; 6 new TS; 28.309; 28.308; 28.307; 28.406; 28.405; 28.404
- 252: 19/6/17: Compl:0%->100%;...; 30/6/17: 25.709 added; / Impacted TSs and TRs: 25.709
- 253: 11/9/17: 0%->85; 15/12/17: 85%->100; 8/1/18: WID: RP-171443->RP-172720; ...
- 254: 11/9/17: 0%->70; 15/12/17: 70%->100 / Impacted TSs and TRs: TS 32.251; TS 32.298; TS 32.299
- 255: Impacted TSs and TRs: 26.131; 26.132
- 256: Impacted TSs and TRs: 26.131
- 258: 6/10/16: 32.866 added; 1/12/16: 0%->5; 7/6/17: 5%->45; 7/6/17: FCD:06/17->12/17; 11/9/17: 45%->80; 15/12/17: 80%->100 / Impacted TSs and TRs: 32.866
- 259: Impacted TSs and TRs: 32.101
- 261: Created upon demand of RAN5
- 262: -
- 264: ; 8/1/18: Compl:0%->70%; 8/1/18: CD:Mon 03/01/00->Thu 15/03/18; ...

| ID | WBS | Task | Duration | Start | Finish | Complete | Remaining | Total slack | Constraint | Resources | Work | Actual work | Acronym | PCG approved | WI rapporteur name | Release | TSG approved | Impacted TSs and TRs | WI rapporteur e-mail | Status Report |
| --- | --- | --- | --- | --- | --- | --- | --- | --- | --- | --- | --- | --- | --- | --- | --- | --- | --- | --- | --- | --- |
| 265 | 123 | **LTE Advanced inter-band Carrier Aggregation (4DL/4UL) of Band 41C and Band 42C** | 196d? | 2017-09-15 A | 2018-06-15 | 40% | 117.6d? | 4561d |  | R4 | 4704h | 1881.6h | LTE_CA_4DL4UL_B41_B41_B42_B42 | 39 | KDDI | Rel-15 | 77 |  |  |  |
| 266 | 123.1 | Core part:LTE Advanced inter-band Carrier Aggregation (4DL/4UL) of Band 41C and Band 42C | 196d? | 2017-09-15 A | 2018-06-15 | 80% | 39.2d? | 4561d | finish no earlier than 2018-06-15 | R4 | 1568h | 1254.4h | LTE_CA_4DL4UL_B41_B41_B42_B42-Core | 39 | KDDI | Rel-15 | 77 | 36.715-04 |  |  |
| 267 | 123.2 | Perf. part:LTE Advanced inter-band Carrier Aggregation (4DL/4UL) of Band 41C and Band 42C | 196d? | 2017-09-15 | 2018-06-15 |  |  | 4561d | finish no earlier than 2018-06-15 | R4 | 1568h |  | LTE_CA_4DL4UL_B41_B41_B42_B42-Perf | 39 | KDDI | Rel-15 | 77 |  |  |  |
| 268 | 124 | **Additional LTE bands for UE category M1 and/or NB1 in Rel-15** | 196d? | 2017-09-15 A | 2018-06-15 | 37% | 123.29d? | 4561d |  | R4 | 5752h | 2134.03h | LTE_bands_R15_M1_NB1 | 39 | Ericsson | Rel-15 | 77 |  |  |  |
| 269 | 124.1 | Core part: Additional LTE bands for UE category M1 and/or NB1 in Rel-15 | 196d? | 2017-09-15 A | 2018-06-15 | 99% | 1.96d? | 4561d | finish no earlier than 2018-06-15 | R4 | 1568h | 1552.32h | LTE_bands_R15_M1_NB1-Core | 39 | Ericsson | Rel-15 | 77 |  |  |  |
| 270 | 124.2 | Perf. part: Additional LTE bands for UE category M1 and/or NB1 in Rel-15 | 196d? | 2017-09-15 | 2018-06-15 |  |  | 4561d | finish no earlier than 2018-06-15 | R4 | 1568h |  | LTE_bands_R15_M1_NB1-Perf | 39 | Ericsson | Rel-15 | 77 |  |  |  |
| 271 | 124.3 | UE Conformance Test aspects - LTE bands with UE category M1 and/or NB1 in Rel-15 | 131d? | 2017-12-15 | 2018-06-15 |  |  | 4561d | finish no earlier than 2018-06-15 | R5 | 1048h |  | LTE_bands_R15_M1_NB1-UEConTest |  | Ericsson | Rel-15 |  |  |  |  |
| 272 | 125 | **Additional LTE bands for UE category M2 and/or NB2 in Rel-15** | 196d? | 2017-09-15 A | 2018-06-15 | 59% | 79.7d? | 4561d |  | R4 | 4184h | 2482.73h | LTE_bands_R15_M2_NB2 | 39 | Ericsson | Rel-15 | 77 |  |  |  |
| 273 | 125.1 | Core part: Additional LTE bands for UE category M2 and/or NB2 in Rel-15 | 196d? | 2017-09-15 A | 2018-06-15 | 99% | 1.96d? | 4561d | finish no earlier than 2018-06-15 | R4 | 1568h | 1552.32h | LTE_bands_R15_M2_NB2-Core | 39 | Ericsson | Rel-15 | 77 |  |  |  |
| 274 | 125.2 | UE Conformance Test aspects - LTE bands with UE category M2 and/or NB2 in Rel-15 | 131d? | 2017-12-15 | 2018-06-15 |  |  | 4561d | finish no earlier than 2018-06-15 | R5 | 1048h |  | LTE_bands_R15_M2_NB2-UEConTest |  | Ericsson | Rel-15 |  |  |  |  |
| 275 | 126 | **Extended-Band12 new E-UTRA Band** | 130d? | 2017-09-15 A | 2018-03-15 | 13% | 113.75d? | 4627d |  | R4 | 3120h | 390h | Ext_B12_LTE | 39 | Ericsson | Rel-15 | 77 |  |  |  |
| 276 | 126.1 | Core part: Extended-Band12 new E-UTRA Band | 130d? | 2017-09-15 A | 2018-03-15 | 25% | 97.5d? | 4627d | finish no earlier than 2018-03-15 | R4 | 1040h | 260h | Ext_B12_LTE-Core | 39 | Ericsson | Rel-15 | 77 | 37.761 |  |  |
| 277 | 126.2 | Perf. part: Extended-Band12 new E-UTRA Band | 130d? | 2017-09-15 | 2018-03-15 |  |  | 4627d | finish no earlier than 2018-03-15 | R4 | 1040h |  | Ext_B12_LTE-Perf | 39 | Ericsson | Rel-15 | 77 |  |  |  |
| 278 | 127 | **Signalling reduction to enable light connection for LTE** | 590d? | 2016-03-15 A | 2018-06-15 | 66% | 202.96d? | 4561d |  |  | 7648h | 4826.13h | LTE_LIGHT_CON | 36 | Huawei | Rel-15 | 71 |  |  |  |
| 279 | 127.1 | Core part: Signalling reduction to enable light connection for LTE | 590d? | 2016-03-15 A | 2018-06-15 | 79% | 123.9d? | 4561d | finish no earlier than 2018-06-15 | R2 | 4720h | 3728.8h | LTE_LIGHT_CON-Core | 36 | Huawei | Rel-15 | 71 |  |  |  |
| 280 | 127.2 | Study on Stage 2 of LTE_LIGHT_CON | 70d? | 2017-03-10 A | 2017-06-15 | 55% | 31.5d? | 4822d | finish no earlier than 2017-06-15 | S2 | 560h | 308h | FS_LTE_LIGHT_CON | 38 | Sašo Stojanovski , intel | Rel-15 | 75 | 23.723 | saso.stojanovski@intel.com |  |
| 281 | 127.3 | **Stage 3 of LTE_LIGHT_CON** | 74d? | 2016-12-01 A | 2017-03-14 | 33% | 49.33d? | 4889d |  | ct | 2368h | 789.33h | LTE_LIGHT_CON-CT | 38 | Herrero Veron, Christian (Huawei) | Rel-15 | 74 |  | Christian.Herrero at huawei.com |  |
| 282 | 127.3.1 | CT1 aspects of LTE_LIGHT_CON | 74d? | 2016-12-01 | 2017-03-14 |  |  | 4889d | finish no earlier than 2017-03-14 | C1 | 592h |  | LTE_LIGHT_CON-CT | 38 | Herrero Veron, Christian (Huawei) | Rel-15 | 74 | 24.008, 24.301, 29.118, 24.368, 27.007 | Christian.Herrero at huawei.com |  |
| 283 | 127.3.2 | CT4 aspects of LTE_LIGHT_CON | 74d? | 2016-12-01 | 2017-03-14 |  |  | 4889d | finish no earlier than 2017-03-14 | C4 | 592h |  | LTE_LIGHT_CON-CT | 38 | Herrero Veron, Christian (Huawei) | Rel-15 | 74 | 29.274, 29.272 | Christian.Herrero at huawei.com |  |
| 284 | 127.3.3 | CT6 aspects of LTE_LIGHT_CON | 74d? | 2016-12-01 A | 2017-03-14 A | 100% |  |  | finish no earlier than 2017-03-14 | C6 | 592h | 592h | LTE_LIGHT_CON-CT | 38 | Herrero Veron, Christian (Huawei) | Rel-15 | 74 | 31.102 | Christian.Herrero at huawei.com |  |
| 285 | 128 | **Enhancements of Base Station (BS) RF and EMC requirements for Active Antenna System (AAS)** | 590d? | 2016-03-15 A | 2018-06-15 | 55% | 265.22d? | 4561d |  |  | 8400h | 4624h | AASenh_BS_LTE_UTRA | 36 | Huawei | Rel-15 | 71 | 37.843 |  |  |
| 286 | 128.1 | Core part: Enhancements of Base Station (BS) RF and EMC requirements for Active Antenna System (AAS) | 460d? | 2016-03-15 A | 2017-12-15 A | 100% |  |  | finish no earlier than 2017-12-15 | R4 | 3680h | 3680h | AASenh_BS_LTE_UTRA-Core | 36 | Huawei | Rel-15 | 71 |  |  | RP-172345 |
| 287 | 128.2 | Perf. part: Enhancements of Base Station (BS) RF and EMC requirements for Active Antenna System (AAS) | 590d? | 2016-03-15 A | 2018-06-15 | 20% | 472d? | 4561d | finish no earlier than 2018-06-15 | R4 | 4720h | 944h | AASenh_BS_LTE_UTRA-Perf | 36 | Huawei | Rel-15 | 71 |  |  |  |
| 288 | 129 | **Shortened TTI and processing time for LTE** | 524d? | 2016-06-15 A | 2018-06-15 | 53% | 247.19d? | 4561d |  |  | 7856h | 4150.08h | LTE_sTTIandPT | 37 | Ericsson | Rel-15 | 72 |  |  |  |
| 289 | 129.1 | Core part: Shortened TTI and processing time for LTE | 524d? | 2016-06-15 A | 2018-06-15 | 99% | 5.24d? | 4561d | finish no earlier than 2018-06-15 | R1 | 4192h | 4150.08h | LTE_sTTIandPT-Core | 37 | Ericsson | Rel-15 | 72 |  |  | RP-172747 |
| 290 | 129.2 | Perf. part: Shortened TTI and processing time for LTE | 458d? | 2016-09-14 | 2018-06-15 |  |  | 4561d | finish no earlier than 2018-06-15 | R4 | 3664h |  | LTE_sTTIandPT-Perf | 37 | Ericsson | Rel-15 | 72 |  |  |  |

Notes:
- 266: 15/12/17: 36.715-04 added;; 8/1/18: Compl:0%->80%
- 269: ; 8/1/18: Compl:0%->99%
- 271: tested: REL-15 WI LTE_bands_R15_M1_NB1-Core
- 273: ; 8/1/18: Compl:0%->99%
- 274: tested: REL-15 WI LTE_bands_R15_M2_NB2-Core
- 276: 15/12/17: 37.761 added;; 8/1/18: Compl:0%->25%; ...
- 277: ; 8/1/18: WID: RP-172111->RP-172625
- 278: no Perf. part; 14/9/17: WID:RP-160540->RP-160937; 14/9/17: WID:RP-160937->RP-171459
- 279: no Perf. part; 1/7/16: Compl:0%->10%; 1/7/16: CD:Thu 15/12/16->Wed 15/03/17; 1/7/16: WID: RP-160540->RP-16093726/9/16: Compl:10%->30%; 20/12/16: Compl:30%->75%; 20/12/16: Stat Rep: --> 21/3/17: Compl:75%->79% 21/3/17: CD:W...; ;...; ;...
- 280: 21/3/17: 23.723 added;; 7/6/17: 0%->55
- 282: 6/3/17: 0%->25; 11/9/17: 25%->0
- 284: 7/3/17: 0%->100
- 285: follow-up WI of REL-13 WI AAS_BS_LTE_UTRA; 14/9/17: WID:RP-160548->RP-161668
- 286: follow-up WI of REL-13 WI AAS_BS_LTE_UTRA1/7/16: Compl:0%->5%1/7/16: CD:Fri 15/09/17->Wed 15/03/1726/9/16: Compl:5%->10% 20/12/16: Compl:10%->20%21/3/17: Compl:20%->40%...;...; ;...; ;...
- 287: 1/7/16: WID: RP-160548->RP-1609401/7/16: Release: Rel-15->Rel-14; 26/9/16: WID: RP-160940->RP-161668 20/12/16: Stat Rep: -->; 21/3/17: Compl:0%->10%; ;...;...; ;...
- 289: 26/9/16: Compl:0%->5%; 20/12/16: Compl:5%->10%21/3/17: Compl:10%->30%...19/6/17: Compl:30%->65%19/6/17: CD:...; 19/9/17: Compl:65%->75%; 8/1/18: Compl:75%->99%; 8/1/18: CD:Fri 15/12/17->F...
- 290: ; 26/9/16: WID: RP-161299->RP-161922; 20/12/16: WID: RP-161922->RP-16201421/3/17: WID: RP-162014->RP-170113; 19/6/17: CD:Thu 15/03/18->Fri 15/06/18...

| ID | WBS | Task | Duration | Start | Finish | Complete | Remaining | Total slack | Constraint | Resources | Work | Actual work | Acronym | PCG approved | Impacted TSs and TRs | WI rapporteur name | Release | TSG approved |
| --- | --- | --- | --- | --- | --- | --- | --- | --- | --- | --- | --- | --- | --- | --- | --- | --- | --- | --- |
| 291 | 130 | **680073450MHz E-UTRA FDD Band for LTE PPDR and PMR/PAMR in Europe** | 326d? | 2016-12-15 A | 2018-03-15 | 94% | 18.6d? | 4627d |  |  | 4192h | 3952.8h | LTE450_Europe_PPDR | 38 | 36.748 | Airbus | Rel-15 | 74 |
| 292 | 130.1 | Core part: 450MHz E-UTRA FDD Band for LTE PPDR and PMR/PAMR in Europe | 197d? | 2016-12-15 A | 2017-09-15 A | 100% |  |  | finish no earlier than 2017-09-15 | R4 | 1576h | 1576h | LTE450_Europe_PPDR-Core | 38 |  | Airbus | Rel-15 | 74 |
| 293 | 130.2 | Perf. part: 450MHz E-UTRA FDD Band for LTE PPDR and PMR/PAMR in Europe | 197d? | 2016-12-15 A | 2017-09-15 A | 100% |  |  | finish no earlier than 2017-09-15 | R4 | 1576h | 1576h | LTE450_Europe_PPDR-Perf | 38 |  | Airbus | Rel-15 | 74 |
| 294 | 130.3 | UE Conformance Test Aspects - 450MHz E-UTRA FDD Band for LTE PPDR and PMR/PAMR in Europe (Band 72) | 130d? | 2017-09-15 A | 2018-03-15 | 77% | 29.9d? | 4627d | finish no earlier than 2018-03-15 | R5 | 1040h | 800.8h | LTE450_Europe_PPDR-UEConTest | 39 |  | Airbus | Rel-15 | 77 |
| 295 | 131 | **E-UTRA 700MHz in Europe for Broadband-PPDR (Public Protection and Disaster Relief)** | 326d? | 2016-12-15 A | 2018-03-15 | 71% | 92.97d? | 4627d |  |  | 3136h | 2241.6h | LTE700_Europe_PPDR | 38 |  | Airbus | Rel-15 | 74 |
| 296 | 131.1 | Core part: E-UTRA 700MHz in Europe for Broadband-PPDR | 197d? | 2016-12-15 A | 2017-09-15 A | 100% |  |  | finish no earlier than 2017-09-15 | R4 | 1576h | 1576h | LTE700_Europe_PPDR-Core | 38 |  | Airbus | Rel-15 | 74 |
| 297 | 131.2 | Perf. part: E-UTRA 700MHz in Europe for Broadband-PPDR | 65d? | 2016-12-15 | 2017-03-15 |  |  | 4888d | finish no earlier than 2017-03-15 | R4 | 520h |  | LTE700_Europe_PPDR-Perf | 38 |  | Airbus | Rel-15 | 74 |
| 298 | 131.3 | UE Conformance Test Aspects - E-UTRA 700MHz in Europe for Broadband-PPDR | 130d? | 2017-09-15 A | 2018-03-15 | 64% | 46.8d? | 4627d | finish no earlier than 2018-03-15 | R5 | 1040h | 665.6h | LTE700_Europe_PPDR-UEConTest | 39 |  | Airbus | Rel-15 | 77 |
| 299 | 132 | **FDD operating band in the L-band for LTE** | 392d? | 2016-12-15 A | 2018-06-15 | 75% | 97.81d? | 4561d |  |  | 4200h | 3152h | LTE_FDD_L_Band | 38 | 36.751 | NTT DOCOMO | Rel-15 | 74 |
| 300 | 132.1 | Core part: FDD operating band in the L-band for LTE | 197d? | 2016-12-15 A | 2017-09-15 A | 100% |  |  | finish no earlier than 2017-09-15 | R4 | 1576h | 1576h | LTE_FDD_L_Band-Core | 38 |  | NTT DOCOMO | Rel-15 | 74 |
| 301 | 132.2 | Perf. part: FDD operating band in the L-band for LTE | 197d? | 2016-12-15 A | 2017-09-15 A | 100% |  |  | finish no earlier than 2017-09-15 | R4 | 1576h | 1576h | LTE_FDD_L_Band-Perf | 38 |  | NTT DOCOMO | Rel-15 | 74 |
| 302 | 132.3 | UE Conformance Test Aspects - FDD operating band in the L-band for LTE | 131d? | 2017-12-15 | 2018-06-15 |  |  | 4561d | finish no earlier than 2018-06-15 | R5 | 1048h |  | LTE_FDD_L_band-UEConTest |  |  | NTT DOCOMO | Rel-15 |  |
| 303 | 133 | **LTE Extended 1.5 GHz SDL band (1427 – 1518 MHz) and LTE Carrier Aggregation (2DL/1UL) with Band 20** | 197d? | 2016-12-15 A | 2017-09-15 A | 100% |  |  |  |  | 2624h | 2624h | LTE_SDL_1500ext | 38 | 36.934; 36.753 | Qualcomm | Rel-15 | 74 |
| 304 | 133.1 | Core part: LTE Extended 1.5 GHz SDL band (1427 – 1518 MHz) and LTE Carrier Aggregation (2DL/1UL) with Band 20 | 197d? | 2016-12-15 A | 2017-09-15 A | 100% |  |  | finish no earlier than 2017-09-15 | R4 | 1576h | 1576h | LTE_SDL_1500ext-Core | 38 |  | Qualcomm | Rel-15 | 74 |
| 305 | 133.2 | Perf. part: LTE Extended 1.5 GHz SDL band (1427 – 1518 MHz) and LTE Carrier Aggregation (2DL/1UL) with Band 20 | 131d? | 2017-03-17 A | 2017-09-15 A | 100% |  |  | finish no earlier than 2017-09-15 | R4 | 1048h | 1048h | LTE_SDL_1500ext-Perf | 38 |  | Qualcomm | Rel-15 | 74 |
| 306 | 134 | **Add UE Power Class 2 to band 41 intra-band contiguous LTE Carrier Aggregation** | 392d? | 2016-12-15 A | 2018-06-15 | 67% | 130.67d? | 4561d |  |  | 3144h | 2096h | LTE_CA_C_B41_PC2 | 38 |  | Sprint | Rel-15 | 74 |
| 307 | 134.1 | Core part: Add UE Power Class 2 to band 41 intra-band contiguous LTE Carrier Aggregation | 262d? | 2016-12-15 A | 2017-12-15 A | 100% |  |  | finish no earlier than 2017-12-15 | R4 | 2096h | 2096h | LTE_CA_C_B41_PC2-Core | 38 |  | Sprint | Rel-15 | 74 |
| 308 | 134.2 | UE Conformance Test Aspects - Add UE Power Class 2 to band 41 intra-band contiguous LTE Carrier Aggregation | 131d? | 2017-12-15 | 2018-06-15 |  |  | 4561d | finish no earlier than 2018-06-15 | R5 | 1048h |  | LTE_CA_C_B41_PC2-UEConTest |  |  | Sprint | Rel-15 |  |
| 309 | 135 | **Addition of Power Class 1 UE to bands B3/B20/B28 for LTE** | 262d? | 2016-09-15 A | 2017-09-15 A | 100% |  |  |  |  | 2096h | 2096h | LTE_HPUE_B3_B20_B28 | 37 |  | Motorola Solutions | Rel-15 | 73 |
| 310 | 135.1 | Core part: Addition of Power Class 1 UE to bands B3/B20/B28 for LTE | 262d? | 2016-09-15 A | 2017-09-15 A | 100% |  |  | finish no earlier than 2017-09-15 | R4 | 2096h | 2096h | LTE_HPUE_B3_B20_B28-Core | 37 |  | Motorola Solutions | Rel-15 | 73 |
| 311 | 136 | **TDD operating band in the L-band for LTE** | 197d? | 2016-12-15 A | 2017-09-15 A | 100% |  |  |  |  | 2624h | 2624h | LTE_TDD_L_Band | 38 | 36.753 | Huawei | Rel-15 | 74 |
| 312 | 136.1 | Core part: TDD operating band in the L-band for LTE | 197d? | 2016-12-15 A | 2017-09-15 A | 100% |  |  | finish no earlier than 2017-09-15 | R4 | 1576h | 1576h | LTE_TDD_L_Band-Core | 38 |  | Huawei | Rel-15 | 74 |
| 313 | 136.2 | Perf. part: TDD operating band in the L-band for LTE | 131d? | 2017-03-17 A | 2017-09-15 A | 100% |  |  | finish no earlier than 2017-09-15 | R4 | 1048h | 1048h | LTE_TDD_L_Band-Perf | 38 |  | Huawei | Rel-15 | 74 |
| 314 | 137 | **Further enhancements to Coordinated Multi-Point (CoMP) Operation for LTE** | 328d? | 2017-03-15 A | 2018-06-15 | 76% | 78.38d? | 4561d |  | R1 | 7344h | 5216.46h | feCOMP_LTE | 38 |  | Intel | Rel-15 | 75 |
| 315 | 137.1 | Core part: Further enhancements to Coordinated Multi-Point (CoMP) Operation for LTE | 262d? | 2017-03-15 A | 2018-03-15 | 90% | 26.2d? | 4627d | finish no earlier than 2018-03-15 | R1 | 2096h | 1886.4h | feCOMP_LTE-Core | 38 |  | Intel | Rel-15 | 75 |
| 316 | 137.2 | Perf. part: Further enhancements to Coordinated Multi-Point (CoMP) Operation for LTE | 328d? | 2017-03-15 A | 2018-06-15 | 65% | 114.8d? | 4561d | finish no earlier than 2018-06-15 | R4 | 2624h | 1705.6h | feCOMP_LTE-Perf | 38 |  | Intel | Rel-15 | 75 |

Notes:
- 291: 21/3/17: 36.748 added;
- 292: 21/3/17: Compl:0%->10%; 19/6/17: Compl:10%->75%; 19/9/17: Compl:75%->100%
- 293: 19/6/17: Compl:0%->50%19/9/17: Compl:50%->100%
- 294: ; 8/1/18: Compl:0%->77%
- 296: 21/3/17: Compl:0%->25%; ...19/6/17: Compl:25%->80%; 19/9/17: Compl:80%->100%
- 297: 21/3/17: CD:Thu 15/06/17->Wed 15/03/17 ...
- 298: ; 8/1/18: Compl:0%->64%
- 299: 21/3/17: 36.751 added;
- 300: 21/3/17: Compl:0%->50%; 19/6/17: Compl:50%->99%;...; 19/9/17: Compl:99%->100%
- 301: 19/6/17: Compl:0%->99%19/6/17: CD:Thu 15/06/...19/9/17: Compl:99%->100%
- 302: tested: REL-15 WI LTE_FDD_L_Band-Core
- 303: 21/3/17: 36.934 added;; 21/3/17: 36.753 added;
- 304: 21/3/17: Compl:0%->20%19/6/17: Compl:20%->50%; ;...19/9/17: Compl:50%->100%
- 305: ; 19/6/17: CD:Thu 15/06/17->Fri 15/09/17...; 19/9/17: Compl:0%->100%
- 307: 21/3/17: Compl:0%->5%; 19/6/17: Compl:5%->50%; ;...; 19/9/17: Compl:50%->90%; 8/1/18: Compl:90%->100%; ;...
- 308: tested: REL-15 WI LTE_CA_C_B41_PC2-Core
- 310: ; 20/12/16: Compl:0%->15%; 20/12/16: CD:Wed 15/03/17->Thu 15/06/1721/3/17: Compl:15%->70%19/6/17: Compl:70%->99%...19/9/17: Compl:99%->100%; ;...
- 311: 21/3/17: 36.753 added;; 14/9/17: WID:RP-162557->RP-170304
- 312: 21/3/17: Compl:0%->15%; ...19/6/17: Compl:15%->70%; ...; 19/9/17: Compl:70%->100%
- 313: 21/3/17: WID: RP-162557->RP-170304; 19/6/17: CD:Thu 15/06/17->Fri 15/09/17; 19/9/17: Compl:0%->100%
- 314: follow-up WI of REL-14 SI FS_feCOMP_LTE completed at RAN #75; 14/9/17: WID:RP-170750->RP-171031
- 315: follow-up WI of REL-14 SI FS_feCOMP_LTE completed at RAN #75; 19/6/17: Compl:0%->70%; 19/6/17: CD:Fri 15/09/...; 19/9/17: Compl:70%->90%
- 316: follow-up WI of REL-14 SI FS_feCOMP_LTE completed at RAN #7519/6/17: WID: RP-170750->RP-171031; 8/1/18: Compl:0%->65%; 8/1/18: CD:Thu 15/03/18->Fri 15/06/18

| ID | WBS | Task | Duration | Start | Finish | Complete | Remaining | Total slack | Constraint | Resources | Work | Actual work | Acronym | PCG approved | WI rapporteur name | Release | TSG approved | Impacted TSs and TRs | Status Report |
| --- | --- | --- | --- | --- | --- | --- | --- | --- | --- | --- | --- | --- | --- | --- | --- | --- | --- | --- | --- |
| 317 | 138 | **UE Positioning Accuracy Enhancements for LTE** | 328d? | 2017-03-15 A | 2018-06-15 | 35% | 213.2d? | 4561d |  | R2 | 7872h | 2755.19h | LCS_LTE_acc_enh | 38 | Nokia | Rel-15 | 75 |  |  |
| 318 | 138.1 | Core part: UE Positioning Accuracy Enhancements for LTE | 328d? | 2017-03-15 A | 2018-06-15 | 40% | 196.8d? | 4561d | finish no earlier than 2018-06-15 | R2 | 2624h | 1049.6h | LCS_LTE_acc_enh-Core | 38 | Nokia | Rel-15 | 75 |  |  |
| 319 | 138.2 | Perf. part: UE Positioning Accuracy Enhancements for LTE | 328d? | 2017-03-15 A | 2018-06-15 | 30% | 229.6d? | 4561d | finish no earlier than 2018-06-15 | R4 | 2624h | 787.2h | LCS_LTE_acc_enh-Perf | 38 | Nokia | Rel-15 | 75 |  |  |
| 320 | 139 | **Enhancements for high capacity stationary wireless link and introduction of 1024 QAM for LTE DL** | 458d? | 2016-09-14 A | 2018-06-15 | 35% | 295.54d? | 4561d |  | R1 | 8912h | 2497.05h | LTE_1024QAM_DL | 38 | Huawei | Rel-15 | 75 |  |  |
| 321 | 139.1 | Core part: Enhancements for high capacity stationary wireless link and introduction of 1024 QAM for LTE DL | 328d? | 2017-03-15 A | 2018-06-15 | 85% | 49.2d? | 4561d | finish no earlier than 2018-06-15 | R1 | 2624h | 2230.4h | LTE_1024QAM_DL-Core | 38 | Huawei | Rel-15 | 75 | 36.783 |  |
| 322 | 139.2 | Perf. part: Enhancements for high capacity stationary wireless link and introduction of 1024 QAM for LTE DL | 458d? | 2016-09-14 | 2018-06-15 |  |  | 4561d | finish no earlier than 2018-06-15 | R4 | 3664h |  | LTE_1024QAM_DL-Perf | 38 | Huawei | Rel-15 | 75 |  |  |
| 323 | 140 | **Enhancements to LTE operation in unlicensed spectrum** | 458d? | 2017-03-15 A | 2018-12-15 | 36% | 292.5d? | 4431d |  | R1 | 8384h | 1811.4h | LTE_unlic | 38 | Nokia | Rel-15 | 75 |  |  |
| 324 | 140.1 | Core part: Enhancements to LTE operation in unlicensed spectrum | 328d? | 2017-03-15 A | 2018-06-15 | 65% | 114.8d? | 4561d | finish no earlier than 2018-06-15 | R1 | 2624h | 1705.6h | LTE_unlic-Core | 38 | Nokia | Rel-15 | 75 |  |  |
| 325 | 140.2 | Perf. part: Enhancements to LTE operation in unlicensed spectrum | 262d? | 2017-12-14 | 2018-12-15 |  |  | 4431d | finish no earlier than 2018-12-15 | R4 | 2096h |  | LTE_unlic-Perf | 38 | Nokia | Rel-15 | 75 |  |  |
| 326 | 141 | **Further video enhancements for LTE** | 328d? | 2017-03-15 A | 2018-06-15 | 99% | 3.27d? | 4561d |  | R2 | 5248h | 5195.59h | LTE_ViLTE_enh2 | 38 | CMCC | Rel-15 | 75 |  |  |
| 327 | 141.1 | Core part: Further video enhancements for LTE | 328d? | 2017-03-15 A | 2018-06-15 | 99% | 3.28d? | 4561d | finish no earlier than 2018-06-15 | R2 | 2624h | 2597.76h | LTE_ViLTE_enh2-Core | 38 | CMCC | Rel-15 | 75 |  | RP-172381 |
| 328 | 142 | **Quality of Experience (QoE) Measurement Collection for streaming services in E-UTRAN** | 328d? | 2017-03-15 A | 2018-06-15 | 99% | 3.27d? | 4561d |  | R2 | 5248h | 5195.59h | LTE_QMC_Streaming | 38 | China Unicom | Rel-15 | 75 |  |  |
| 329 | 142.1 | Core part:Quality of Experience (QoE) Measurement Collection for streaming services in E-UTRAN | 328d? | 2017-03-15 A | 2018-06-15 | 99% | 3.28d? | 4561d | finish no earlier than 2018-06-15 | R2 | 2624h | 2597.76h | LTE_QMC_Streaming-Core | 38 | China Unicom | Rel-15 | 75 |  | RP-172192 |
| 330 | 143 | **Enhancing LTE CA Utilization** | 328d? | 2017-03-15 A | 2018-06-15 | 15% | 278.62d? | 4561d |  | R2 | 6832h | 1028.65h | LTE_euCA | 38 | Nokia | Rel-15 | 75 |  |  |
| 331 | 143.1 | Core part: Enhancing LTE CA Utilization | 198d? | 2017-03-15 A | 2017-12-15 | 40% | 118.8d? | 4691d | finish no earlier than 2017-12-15 | R2 | 1584h | 633.6h | LTE_euCA-Core | 38 | Nokia | Rel-15 | 75 |  |  |
| 332 | 143.2 | Perf. part: Enhancing LTE CA Utilization | 328d? | 2017-03-15 | 2018-06-15 |  |  | 4561d | finish no earlier than 2018-06-15 | R4 | 2624h |  | LTE_euCA-Perf | 38 | Nokia | Rel-15 | 75 |  |  |
| 333 | 144 | **450 MHz Band for LTE in Region 3** | 198d? | 2017-03-15 A | 2017-12-15 A | 100% |  |  |  | R4 | 4752h | 4752h | LTE450_Reg3 | 38 | China Unicom | Rel-15 | 75 |  |  |
| 334 | 144.1 | Core part: 450 MHz Band for LTE in Region 3 | 198d? | 2017-03-15 A | 2017-12-15 A | 100% |  |  | finish no earlier than 2017-12-15 | R4 | 1584h | 1584h | LTE450_Reg3-Core | 38 | China Unicom | Rel-15 | 75 | 36.759 |  |
| 335 | 144.2 | Perf. part: 450 MHz Band for LTE in Region 3 | 198d? | 2017-03-15 A | 2017-12-15 A | 100% |  |  | finish no earlier than 2017-12-15 | R4 | 1584h | 1584h | LTE450_Reg3-Perf | 38 | China Unicom | Rel-15 | 75 |  |  |
| 336 | 145 | **US 600 MHz Band for LTE** | 198d? | 2017-03-15 A | 2017-12-15 | 99% | 0d? | 0d |  | R4 | 4240h | 3720h | LTE600_US | 38 | Ericsson | Rel-15 | 75 |  |  |
| 337 | 145.1 | Core part: US 600 MHz Band for LTE | 133d? | 2017-03-15 A | 2017-09-15 A | 100% |  |  | finish no earlier than 2017-09-15 | R4 | 1064h | 1064h | LTE600_US-Core | 38 | Ericsson | Rel-15 | 75 | 36.755 |  |
| 338 | 145.2 | Perf. part: US 600 MHz Band for LTE | 133d? | 2017-03-15 A | 2017-09-15 A | 100% |  |  | finish no earlier than 2017-09-15 | R4 | 1064h | 1064h | LTE600_US-Perf | 38 | Ericsson | Rel-15 | 75 |  |  |
| 339 | 145.3 | UE Conformance Test Aspects - US 600 MHz Band for LTE (Band 71) | 66d? | 2017-09-15 A | 2017-12-15 A | 100% |  |  | finish no earlier than 2018-03-15 | R5 | 528h | 528h | LTE600_US-UEConTest | 39 | Dish Network | Rel-15 | 77 |  |  |
| 340 | 146 | **LAA/eLAA for the CBRS 3.5GHz band in the United States** | 198d? | 2017-03-15 A | 2017-12-15 A | 100% |  |  |  | R4 | 4752h | 4752h | LTE_3550_CBRS_US_LAA | 38 | AT&T | Rel-15 | 75 |  |  |
| 341 | 146.1 | Core part: LAA/eLAA for the CBRS 3.5GHz band in the United States | 198d? | 2017-03-15 A | 2017-12-15 A | 100% |  |  | start no earlier than 2017-03-15 | R4 | 1584h | 1584h | LTE_3550_CBRS_US_LAA-Core | 38 | AT&T | Rel-15 | 75 | 36.790 |  |
| 342 | 146.2 | Perf. part: LAA/eLAA for the CBRS 3.5GHz band in the United States | 198d? | 2017-03-15 A | 2017-12-15 A | 100% |  |  | start no earlier than 2017-03-15 | R4 | 1584h | 1584h | LTE_3550_CBRS_US_LAA-Perf | 38 | AT&T | Rel-15 | 75 |  |  |

Notes:
- 317: 14/9/17: WID:RP-170813->RP-171508
- 318: ; 19/6/17: Compl:0%->10%; 19/6/17: CD:Fri 15/12/17->Fri 15/06/18...; 19/9/17: Compl:10%->20%; 8/1/18: Compl:20%->40%; 8/1/18: WID: RP-171508->RP-172313
- 319: ; 19/6/17: WID: RP-170813->RP-171508; 8/1/18: Compl:0%->30%; 8/1/18: WID: RP-171508->RP-172313
- 320: 14/9/17: WID:RP-170838->RP-171067
- 321: ; 19/6/17: Compl:0%->20%; 19/6/17: CD:Sat 15/12/18->Thu 15/03/18...; 19/6/17: FCD:03/18->06/18; 12/7/17: 36.783 added;19/9/17: Compl:20%->40%; ;...; 8/1/18: Compl:40%->85%
- 322: ; 19/6/17: CD:Sat 15/12/18->Fri 15/06/18; 19/6/17: WID: RP-170838->RP-171067...; 19/9/17: WID: RP-171067->RP-171738
- 323: note: The is actually a further LAA enhancement
- 324: note: The is actually a further LAA enhancement; 19/6/17: Compl:0%->15%; 19/6/17: CD:Fri 15...; 19/9/17: Compl:15%->30%; 8/1/18: Compl:30%->65%; ...
- 325: 19/6/17: CD:Thu 15/03/18->Sat 15/12/18; 8/1/18: WID: RP-170848->RP-172841
- 326: no Perf. part; compare REL-14 WI LTE_VoLTE_ViLTE_enh
- 327: no Perf. part; compare REL-14 WI LTE_VoLTE_ViLTE_enh19/6/17: Compl:0%->15%19/6/17: W...; 19/9/17: Compl:15%->35%; 8/1/18: Compl:35%->99%; ...
- 328: compare REL-14 WI UMTS_QMC_Streaming-Core
- 329: compare REL-14 WI UMTS_QMC_Streaming-Core; 19/6/17: Compl:0%->25%; 19/6/17: WID: RP-...; 19/9/17: Compl:25%->45%; 8/1/18: Compl:45%->99%; ...
- 331: 19/9/17: Compl:0%->22%; 8/1/18: Compl:22%->40%
- 333: 14/9/17: WID:RP-170159->RP-170952
- 334: ; 19/6/17: Compl:0%->30%; 19...; 12/7/17: 36.759 added;; 19/9/17: Compl:30%->80%; 8/1/18: Compl:80%->100%
- 335: ; 19/6/17: WID: RP-170159->RP-170952; 8/1/18: Compl:0%->100%
- 337: ; 19/6/17: Compl:0%->95%; 19...; 12/7/17: 36.755 added;19/9/17: Compl:95%->100%
- 338: ; 19/6/17: Compl:0%->95%; 19...; 19/9/17: Compl:95%->100%
- 339: ; 8/1/18: Compl:0%->100%; ...
- 340: compare REL-14 WI LTE_TDD_3550_CBRS_US; related to LTE band 48, intending a new band definition; includes 2DL/2UL CA with B2 Acronym changed, was "LTE_TDD_3550_CBRS_US_LAA"
- 341: compare REL-14 WI LTE_TDD_3550_CBRS_US; related to LTE band 48, intending a new band definition; includes 2DL/2UL CA with B2;19/6/17: Com; Acronym changed, was "LTE_TDD_3550_CBRS_US_LAA-Core"; 12/7/17: 36.790 added;;...; ;...
- 342: compare REL-14 WI LTE_TDD_3550_CBRS_US; related to LTE band 48, intending a new band definition; includes 2DL/2UL CA with B2; 19/6/17: C…; Acronym changed, was "LTE_TDD_3550_CBRS_US_LAA-Perf";...; ;...

| ID | WBS | Task | Duration | Start | Finish | Complete | Remaining | Total slack | Constraint | Resources | Work | Actual work | Acronym | PCG approved | WI rapporteur name | Release | TSG approved | Impacted TSs and TRs |
| --- | --- | --- | --- | --- | --- | --- | --- | --- | --- | --- | --- | --- | --- | --- | --- | --- | --- | --- |
| 343 | 147 | **Introduction new band support for 4Rx antenna ports for LTE for REL-15** | 262d? | 2017-06-15 A | 2018-06-15 | 50% | 132.31d? | 4561d |  | R4 | 6288h | 3112.58h | LTE_4Rx_AP_DL_bands_R15 | 39 | Huawei | Rel-15 | 76 |  |
| 344 | 147.1 | Core part: Introduction new band support for 4Rx antenna ports for LTE for REL-15 | 262d? | 2017-06-15 A | 2018-06-15 | 99% | 2.62d? | 4561d | finish no earlier than 2018-06-15 | R4 | 2096h | 2075.04h | LTE_4Rx_AP_DL_bands_R15-Core | 39 | Huawei | Rel-15 | 76 |  |
| 345 | 147.2 | Perf. part: Introduction new band support for 4Rx antenna ports for LTE for REL-15 | 262d? | 2017-06-15 | 2018-06-15 |  |  | 4561d | finish no earlier than 2018-06-15 | R4 | 2096h |  | LTE_4Rx_AP_DL_bands_R15-Perf | 39 | Huawei | Rel-15 | 76 |  |
| 346 | 148 | **Addition of band 28 and 40 to LTE MTC cat.0** | 67d? | 2017-06-15 A | 2017-09-15 A | 100% |  |  |  | R4 | 1072h | 1072h | LC_MTC_LTE_cat0_B28_B40 | 39 | Huawei | Rel-15 | 76 |  |
| 347 | 148.1 | Core part: Addition of band 28 and 40 to LTE MTC cat.0 | 67d? | 2017-06-15 A | 2017-09-15 A | 100% |  |  | finish no earlier than 2017-09-15 | R4 | 536h | 536h | LC_MTC_LTE_cat0_B28_B40-Core | 39 | Huawei | Rel-15 | 76 |  |
| 348 | 149 | **LTE Advanced high power TDD UE (power class 2) for Rel-15** | 262d? | 2017-06-15 A | 2018-06-15 | 40% | 157.2d? | 4561d |  | R4 | 4192h | 1676.8h | LTE_TDD_HPUE_R15 | 39 | Huawei | Rel-15 | 76 |  |
| 349 | 149.1 | Core part: LTE Advanced high power TDD UE (power class 2) for Rel-15 | 262d? | 2017-06-15 A | 2018-06-15 | 40% | 157.2d? | 4561d | finish no earlier than 2018-06-15 | R4 | 2096h | 838.4h | LTE_TDD_HPUE_R15-Core | 39 | Huawei | Rel-15 | 76 | 36.760 |
| 350 | 150 | **New LTE band for 3.3-3.4 GHz for Africa** | 196d? | 2017-06-15 A | 2018-03-15 | 35% | 127.4d? | 4627d |  | R4 | 4704h | 1646.38h | LTE_TDD_3300_Africa | 39 | Huawei | Rel-15 | 76 |  |
| 351 | 150.1 | Core part: New LTE band for 3.3-3.4 GHz for Africa | 196d? | 2017-06-15 A | 2018-03-15 | 70% | 58.8d? | 4627d | finish no earlier than 2018-03-15 | R4 | 1568h | 1097.6h | LTE_TDD_3300_Africa-Core | 39 | Huawei | Rel-15 | 76 | 36.758 |
| 352 | 150.2 | Perf. part: New LTE band for 3.3-3.4 GHz for Africa | 196d? | 2017-06-15 | 2018-03-15 |  |  | 4627d | finish no earlier than 2018-03-15 | R4 | 1568h |  | LTE_TDD_3300_Africa-Perf | 39 | Huawei | Rel-15 | 76 |  |
| 353 | 151 | **UE requirements for network-based CRS interference mitigation for LTE** | 392d? | 2017-06-15 A | 2018-12-15 | 20% | 313.48d? | 4431d |  | R4 | 8368h | 1676.16h | LTE_NW_CRS_IM | 39 | Ericsson | Rel-15 | 76 |  |
| 354 | 151.1 | Core part: UE requirements for network-based CRS interference mitigation for LTE | 262d? | 2017-06-15 A | 2018-06-15 | 50% | 131d? | 4561d | finish no earlier than 2018-06-15 | R4 | 2096h | 1048h | LTE_NW_CRS_IM-Core | 39 | Ericsson | Rel-15 | 76 |  |
| 355 | 151.2 | Perf. part: UE requirements for network-based CRS interference mitigation for LTE | 392d? | 2017-06-15 | 2018-12-15 |  |  | 4431d | finish no earlier than 2018-12-15 | R4 | 3136h |  | LTE_NW_CRS_IM-Perf | 39 | Ericsson | Rel-15 | 76 |  |
| 356 | 152 | **Bluetooth/WLAN measurement collection in LTE Minimization of Drive Tests (MDT)** | 131d? | 2017-12-15 | 2018-06-15 |  |  | 4561d |  | R2 | 2096h |  | LTE_MDT_BT_WLAN |  | CMCC | Rel-15 |  |  |
| 357 | 152.1 | Core part: Bluetooth/WLAN measurement collection in LTE Minimization of Drive Tests (MDT) | 131d? | 2017-12-15 | 2018-06-15 |  |  | 4561d | finish no earlier than 2018-06-15 | R2 | 1048h |  | LTE_MDT_BT_WLAN-Core |  | CMCC | Rel-15 |  |  |
| 358 | 153 | **Enhanced LTE Support for Aerial Vehicles** | 131d? | 2017-12-15 | 2018-06-15 |  |  | 4561d |  | R2 | 2096h |  | LTE_Aerial |  | Ericsson | Rel-15 |  |  |
| 359 | 153.1 | Core part: Enhanced LTE Support for Aerial Vehicles | 131d? | 2017-12-15 | 2018-06-15 |  |  | 4561d | finish no earlier than 2018-06-15 | R2 | 1048h |  | LTE_Aerial-Core |  | Ericsson | Rel-15 |  |  |
| 360 | 154 | **Separation of CP and UP for Split Option 2 of NR** | 131d? | 2017-12-15 | 2018-06-15 |  |  | 4561d |  | R3 | 2096h |  | NR_CPUP_Split |  | Ericsson | Rel-15 |  |  |
| 361 | 154.1 | Core part: Separation of CP and UP for Split Option 2 of NR | 131d? | 2017-12-15 | 2018-06-15 |  |  | 4561d | finish no earlier than 2018-06-15 | R3 | 1048h |  | NR_CPUP_Split-Core |  | Ericsson | Rel-15 |  |  |
| 362 | 155 | **UE requirements for LTE DL 8Rx antenna ports** | 261d? | 2017-12-15 | 2018-12-15 |  |  | 4431d |  | R4 | 5224h |  | LTE_8Rx_AP_DL |  | Huawei | Rel-15 |  |  |
| 363 | 155.1 | Core part: UE requirements for LTE DL 8Rx antenna ports | 131d? | 2017-12-15 | 2018-06-15 |  |  | 4561d | finish no earlier than 2018-06-15 | R4 | 1048h |  | LTE_8Rx_AP_DL-Core |  | Huawei | Rel-15 |  |  |
| 364 | 155.2 | Perf. part: UE requirements for LTE DL 8Rx antenna ports | 261d? | 2017-12-15 | 2018-12-15 |  |  | 4431d | finish no earlier than 2018-12-15 | R4 | 2088h |  | LTE_8Rx_AP_DL-Perf |  | Huawei | Rel-15 |  |  |
| 365 | 156 | **ProSe Support for Band 72 in LTE** | 1d? | 2017-12-15 | 2017-12-15 |  |  | 4691d |  | R4 | 16h |  | LTE450_B72_Europe_ProSe |  | Airbus | Rel-15 |  |  |
| 366 | 156.1 | Core part: ProSe Support for Band 72 in LTE | 1d? | 2017-12-15 | 2017-12-15 |  |  | 4691d | finish no earlier than 2017-12-15 | R4 | 8h |  | LTE450_B72_Europe_ProSe-Core |  | Airbus | Rel-15 |  |  |

Notes:
- 344: 19/9/17: Compl:0%->99%; 8/1/18: WID: RP-171131->RP-172347
- 345: ; 8/1/18: WID: RP-171131->RP-172347
- 347: 19/9/17: Compl:0%->100%
- 349: 19/9/17: Compl:0%->10%; ...; 15/12/17: 36.760 added;; 8/1/18: Compl:10%->40%
- 351: 12/7/17: 36.758 added;19/9/17: Compl:0%->10%; ...; 8/1/18: Compl:10%->70%
- 352: ; 19/9/17: WID: RP-171506->RP-171759
- 354: ; 19/9/17: Compl:0%->15%; 8/1/18: Compl:15%->50%
- 356: MDT = Minimization of Drive Tests; no Perf. part; may have SA5 impact
- 357: MDT = Minimization of Drive Tests; no Perf. part; may have SA5 impact
- 358: follow-up WI of REL-15 SI FS_LTE_Aerial; no Perf. part
- 359: follow-up WI of REL-15 SI FS_LTE_Aerial; no Perf. part
- 360: follow-up WI of REL-15 SI FS_NR_CPUP_Split; introduction of E1 interface
- 361: follow-up WI of REL-15 SI FS_NR_CPUP_Split; introduction of E1 interface. 30/1/18: acronym updated
- 362: follow-up WI of REL-15 SI FS_LTE_8Rx_AP_DL
- 363: follow-up WI of REL-15 SI FS_LTE_8Rx_AP_DL
- 364: follow-up WI of REL-15 SI FS_LTE_8Rx_AP_DL
- 365: This WI was opened, a RAN4 CR RP-172572 was approved and the WI was completed all at RAN #78; compare REL-15 WI LTE450_Europe_PPDR-Core
- 366: This WI was opened, a RAN4 CR RP-172572 was approved and the WI was completed all at RAN #78; compare REL-15 WI LTE450_Europe_PPDR-Core

| ID | WBS | Task | Duration | Start | Finish | Complete | Remaining | Total slack | Constraint | Resources | Work | Actual work | Acronym | WI rapporteur name | Release | PCG approved | TSG approved | Impacted TSs and TRs |
| --- | --- | --- | --- | --- | --- | --- | --- | --- | --- | --- | --- | --- | --- | --- | --- | --- | --- | --- |
| 367 | 157 | **LTE Advanced inter-band Carrier Aggregation Rel-15 for xDL/1UL with x>5** | 261d? | 2017-12-15 | 2018-12-15 |  |  | 4431d |  | R4 | 5224h |  | LTE_CA_R15_xDL1UL | Qualcomm | Rel-15 |  |  |  |
| 368 | 157.1 | Core part:LTE Advanced inter-band Carrier Aggregation Rel-15 for xDL/1UL with x>5 | 131d? | 2017-12-15 | 2018-06-15 |  |  | 4561d | finish no earlier than 2018-06-15 | R4 | 1048h |  | LTE_CA_R15_xDL1UL-Core | Qualcomm | Rel-15 |  |  |  |
| 369 | 157.2 | Perf. part:LTE Advanced inter-band Carrier Aggregation Rel-15 for xDL/1UL with x>5 | 261d? | 2017-12-15 | 2018-12-15 |  |  | 4431d | finish no earlier than 2018-12-15 | R4 | 2088h |  | LTE_CA_R15_xDL1UL-Perf | Qualcomm | Rel-15 |  |  |  |
| 370 | 158 | **Performance requirements of interference cancellation receiver for LTE BS** | 67d? | 2017-06-15 A | 2017-09-15 A | 100% |  |  |  | R4 | 1072h | 1072h | LTE_IC_BS | China Telecom | Rel-15 | 39 | 76 |  |
| 371 | 158.1 | Perf. part: Performance requirements of interference cancellation receiver for LTE BS | 67d? | 2017-06-15 A | 2017-09-15 A | 100% |  |  | finish no earlier than 2017-09-15 | R4 | 536h | 536h | LTE_IC_BS-Perf | China Telecom | Rel-15 | 39 | 76 |  |
| 372 | 159 | **LTE CRS-Interference Mitigation performance requirements for single RX chain UEs** | 262d? | 2017-06-15 A | 2018-06-15 | 60% | 104.8d? | 4561d |  | R4 | 4192h | 2515.2h | LTE_1RX_CRS_IM | Intel | Rel-15 | 39 | 76 |  |
| 373 | 159.1 | Perf. part: LTE CRS-Interference Mitigation performance requirements for single RX chain UEs | 262d? | 2017-06-15 A | 2018-06-15 | 60% | 104.8d? | 4561d | finish no earlier than 2018-06-15 | R4 | 2096h | 1257.6h | LTE_1RX_CRS_IM-Perf | Intel | Rel-15 | 39 | 76 |  |
| 374 | 160 | **LTE Advanced intra-band Carrier Aggregation Rel-15 for xDL/yUL including contiguous and non-contiguous spectrum** | 262d? | 2017-06-15 A | 2018-06-15 | 70% | 78.59d? | 4561d |  | R4 | 6288h | 3588.4h | LTE_CA_R15_intra | Ericsson | Rel-15 | 39 | 76 |  |
| 375 | 160.1 | Core part: LTE Advanced intra-band Carrier Aggregation Rel-15 for xDL/yUL including contiguous and non-contiguous spectrum | 262d? | 2017-06-15 A | 2018-06-15 | 70% | 78.6d? | 4561d | finish no earlier than 2018-06-15 | R4 | 2096h | 1467.2h | LTE_CA_R15_intra-Core | Ericsson | Rel-15 | 39 | 76 | 36.715-00-00 |
| 376 | 160.2 | Perf. part: LTE Advanced intra-band Carrier Aggregation Rel-15 for xDL/yUL including contiguous and non-contiguous spectrum | 262d? | 2017-06-15 A | 2018-06-15 | 70% | 78.6d? | 4561d | finish no earlier than 2018-06-15 | R4 | 2096h | 1467.2h | LTE_CA_R15_intra-Perf | Ericsson | Rel-15 | 39 | 76 |  |
| 377 | 161 | **LTE Advanced inter-band Carrier Aggregation Rel-15 for 2DL/1UL** | 262d? | 2017-06-15 A | 2018-06-15 | 30% | 183.41d? | 4561d |  | R4 | 6288h | 1886.32h | LTE_CA_R15_2DL1UL | Qualcomm | Rel-15 | 39 | 76 |  |
| 378 | 161.1 | Core part:LTE Advanced inter-band Carrier Aggregation Rel-15 for 2DL/1UL | 262d? | 2017-06-15 A | 2018-06-15 | 30% | 183.4d? | 4561d | finish no earlier than 2018-06-15 | R4 | 2096h | 628.8h | LTE_CA_R15_2DL1UL-Core | Qualcomm | Rel-15 | 39 | 76 | 36.715-02-01 |
| 379 | 161.2 | Perf. part:LTE Advanced inter-band Carrier Aggregation Rel-15 for 2DL/1UL | 262d? | 2017-06-15 A | 2018-06-15 | 30% | 183.4d? | 4561d | finish no earlier than 2018-06-15 | R4 | 2096h | 628.8h | LTE_CA_R15_2DL1UL-Perf | Qualcomm | Rel-15 | 39 | 76 |  |
| 380 | 162 | **LTE Advanced inter-band Carrier Aggregation Rel-15 for 3DL/1UL** | 262d? | 2017-06-15 A | 2018-06-15 | 40% | 157.2d? | 4561d |  | R4 | 6288h | 2515.2h | LTE_CA_R15_3DL1UL | Huawei | Rel-15 | 39 | 76 |  |
| 381 | 162.1 | Core part:LTE Advanced inter-band Carrier Aggregation Rel-15 for 3DL/1UL | 262d? | 2017-06-15 A | 2018-06-15 | 40% | 157.2d? | 4561d | finish no earlier than 2018-06-15 | R4 | 2096h | 838.4h | LTE_CA_R15_3DL1UL-Core | Huawei | Rel-15 | 39 | 76 | 36.715-03-01 |
| 382 | 162.2 | Perf. part:LTE Advanced inter-band Carrier Aggregation Rel-15 for 3DL/1UL | 262d? | 2017-06-15 A | 2018-06-15 | 40% | 157.2d? | 4561d | finish no earlier than 2018-06-15 | R4 | 2096h | 838.4h | LTE_CA_R15_3DL1UL-Perf | Huawei | Rel-15 | 39 | 76 |  |
| 383 | 163 | **LTE Advanced inter-band Carrier Aggregation Rel-15 for 4DL/1UL** | 262d? | 2017-06-15 A | 2018-06-15 | 65% | 91.69d? | 4561d |  | R4 | 6288h | 4137.46h | LTE_CA_R15_4DL1UL | Ericsson | Rel-15 | 39 | 76 |  |
| 384 | 163.1 | Core part:LTE Advanced inter-band Carrier Aggregation Rel-15 for 4DL/1UL | 262d? | 2017-06-15 A | 2018-06-15 | 65% | 91.7d? | 4561d | finish no earlier than 2018-06-15 | R4 | 2096h | 1362.4h | LTE_CA_R15_4DL1UL-Core | Ericsson | Rel-15 | 39 | 76 | 36.715-04-01 |
| 385 | 163.2 | Perf. part:LTE Advanced inter-band Carrier Aggregation Rel-15 for 4DL/1UL | 262d? | 2017-06-15 A | 2018-06-15 | 65% | 91.7d? | 4561d | finish no earlier than 2018-06-15 | R4 | 2096h | 1362.4h | LTE_CA_R15_4DL1UL-Perf | Ericsson | Rel-15 | 39 | 76 |  |
| 386 | 164 | **LTE Advanced inter-band Carrier Aggregation Rel-15 for 5DL/1UL** | 262d? | 2017-06-15 A | 2018-06-15 | 50% | 131d? | 4561d |  | R4 | 6288h | 2619.2h | LTE_CA_R15_5DL1UL | Nokia | Rel-15 | 39 | 76 |  |
| 387 | 164.1 | Core part:LTE Advanced inter-band Carrier Aggregation Rel-15 for 5DL/1UL | 262d? | 2017-06-15 A | 2018-06-15 | 50% | 131d? | 4561d | finish no earlier than 2018-06-15 | R4 | 2096h | 1048h | LTE_CA_R15_5DL1UL-Core | Nokia | Rel-15 | 39 | 76 | 36.715-05-01 |
| 388 | 164.2 | Perf. part:LTE Advanced inter-band Carrier Aggregation Rel-15 for 5DL/1UL | 262d? | 2017-06-15 A | 2018-06-15 | 50% | 131d? | 4561d | finish no earlier than 2018-06-15 | R4 | 2096h | 1048h | LTE_CA_R15_5DL1UL-Perf | Nokia | Rel-15 | 39 | 76 |  |
| 389 | 165 | **LTE Advanced inter-band Carrier Aggregation Rel-15 for 2DL/2UL** | 262d? | 2017-06-15 A | 2018-06-15 | 40% | 157.2d? | 4561d |  | R4 | 6288h | 2515.2h | LTE_CA_R15_2DL2UL | Huawei | Rel-15 | 39 | 76 |  |
| 390 | 165.1 | Core part:LTE Advanced inter-band Carrier Aggregation Rel-15 for 2DL/2UL | 262d? | 2017-06-15 A | 2018-06-15 | 40% | 157.2d? | 4561d | finish no earlier than 2018-06-15 | R4 | 2096h | 838.4h | LTE_CA_R15_2DL2UL-Core | Huawei | Rel-15 | 39 | 76 | 36.715-02-02 |
| 391 | 165.2 | Perf. part:LTE Advanced inter-band Carrier Aggregation Rel-15 for 2DL/2UL | 262d? | 2017-06-15 A | 2018-06-15 | 40% | 157.2d? | 4561d | finish no earlier than 2018-06-15 | R4 | 2096h | 838.4h | LTE_CA_R15_2DL2UL-Perf | Huawei | Rel-15 | 39 | 76 |  |

Notes:
- 367: basket CA WI; TR 36.715-00-01
- 368: basket CA WI; TR 36.715-00-01
- 369: basket CA WI
- 371: ; 19/9/17: Compl:0%->100%
- 373: ; 19/9/17: Compl:0%->20%; 19/9/17: WID: RP-171465->RP-171831; 8/1/18: Compl:20%->60%
- 375: 12/7/17: 36.715-00-00 added;; 19/9/17: Compl:0%->25%...; 8/1/18: Compl:25%->70%; ;...
- 376: 19/9/17: Compl:0%->25%; ...; 8/1/18: Compl:25%->70%; 8/1/18:...
- 378: 12/7/17: 36.715-02-01 added;19/9/17: Compl:0%->20%; ...; 8/1/18: Compl:20%->30%; ;...
- 379: ; 19/9/17: Compl:0%->20%...; 8/1/18: Compl:20%->30%; ;...
- 381: 12/7/17: 36.715-03-01 added;; 19/9/17: Compl:0%->20%; ...; 8/1/18: Compl:20%->40%; ;...
- 382: ; 19/9/17: Compl:0%->20%; ...; 8/1/18: Compl:20%->40%; ;...
- 384: 12/7/17: 36.715-04-01 added;; 19/9/17: Compl:0%->54%...; 8/1/18: Compl:54%->65%; ;...
- 385: 19/9/17: Compl:0%->54%; ...; 8/1/18: Compl:54%->65%; ;...
- 387: 12/7/17: 36.715-05-01 added;19/9/17: Compl:0%->20%; ...; 8/1/18: Compl:20%->50%; ;...
- 388: ; 19/9/17: Compl:0%->20%...; 8/1/18: Compl:20%->50%; ;...
- 390: 12/7/17: 36.715-02-02 added;; 19/9/17: Compl:0%->20%; ...; 8/1/18: Compl:20%->40%; ;...
- 391: ; 19/9/17: Compl:0%->20%; ...; 8/1/18: Compl:20%->40%; ;...

| ID | WBS | Task | Type | Duration | Start | Finish | Complete | Remaining | Baseline start | Baseline finish | Baseline duration | Total slack | Constraint | Resources | Work | Actual work | Acronym | PCG approved | WI rapporteur name | Release | TSG approved | Impacted TSs and TRs | WI rapporteur e-mail | MCC resp | Acronym_3GU_Export | Status Report |
| --- | --- | --- | --- | --- | --- | --- | --- | --- | --- | --- | --- | --- | --- | --- | --- | --- | --- | --- | --- | --- | --- | --- | --- | --- | --- | --- |
| 392 | 166 | **LTE Advanced inter-band Carrier Aggregation Rel-15 for xDL/2UL with x=3,4,5** |  | 262d? | 2017-06-15 A | 2018-06-15 | 50% | 131d? |  |  |  | 4561d |  | R4 | 6288h | 2328.72h | LTE_CA_R15_xDL2UL | 39 | LG Electronics | Rel-15 | 76 |  |  |  |  |  |
| 393 | 166.1 | Core part:LTE Advanced inter-band Carrier Aggregation Rel-15 for xDL/2UL with x=3,4,5 |  | 262d? | 2017-06-15 A | 2018-06-15 | 50% | 131d? |  |  |  | 4561d | finish no earlier than 2018-06-15 | R4 | 2096h | 1048h | LTE_CA_R15_xDL2UL-Core | 39 | LG Electronics | Rel-15 | 76 | 36.715-00-02 |  |  |  |  |
| 394 | 166.2 | Perf. part:LTE Advanced inter-band Carrier Aggregation Rel-15 for xDL/2UL with x=3,4,5 |  | 262d? | 2017-06-15 A | 2018-06-15 | 50% | 131d? |  |  |  | 4561d | finish no earlier than 2018-06-15 | R4 | 2096h | 1048h | LTE_CA_R15_xDL2UL-Perf | 39 | LG Electronics | Rel-15 | 76 |  |  |  |  |  |
| 395 | 167 | UE Conformance Test Aspects – Rel-15 CA configurations |  | 456d? | 2017-09-15 A | 2019-06-15 | 7% | 424.08d? |  |  |  | 4301d | finish no earlier than 2019-06-15 | R5 | 3648h | 255.36h | LTE_CA_R15-UEConTest | 39 | Ericsson | Rel-15 | 77 |  |  |  |  |  |
| 396 | 168 | **LTE UE Total Radiated Power (TRP) and Total Radiated Sensitivity (TRS) and UTRA Hand Phantom related UE TRP and TRS Requirements** |  | 1315d? | 2012-12-15 A | 2017-12-15 | 82% | 237.87d? | 2013-03-15 | 2015-06-12 | 591d? | 4691d |  |  | 17816h | 14593.1h | LTE_UTRA_TRP_TRS | 30 | Nokia | Rel-15 | 58 | UTRA, LTE | petri.j.vasenkari@nokia.com | Issam | LTE_UTRA_TRP_TRS |  |
| 397 | 168.1 | Core part: LTE UE TRP and TRS and UTRA Hand Phantom related UE TRP and TRS Requirements |  | 1244d? | 2012-12-15 A | 2017-12-15 | 85% | 186.6d? | 2013-03-15 | 2014-09-12 | 393d? | 4691d | finish no earlier than 2017-12-15 | R4 | 9952h | 8459.2h | LTE_UTRA_TRP_TRS-Core | 30 | Nokia | Rel-15 | 58 | 25.144, New TS 37.144 | petri.j.vasenkari@nokia.com | Issam | LTE_UTRA_TRP_TRS-Core |  |
| 398 | 168.2 | Test part: LTE UE TRP and TRS and UTRA Hand Phantom |  | 983d? | 2014-03-15 A | 2017-12-15 | 78% | 216.26d? | 2014-03-06 | 2015-06-12 | 332d? | 4691d | finish no earlier than 2017-12-15 | R5 | 7864h | 6133.92h | LTE_UTRA_TRP_TRS-UEConTest | 32 | ZTE | Rel-15 | 63 | New TS 37.544 | TAYLOR Carolyn (carolyn.tayl@zte.com.cn) | Ingbert | LTE_UTRA_TRP_TRS-UEConTest |  |
| 399 | 169 | Release 15 Studies | milestone | 0d? | 2016-06-09 A | 2016-06-09 A | 100% |  |  |  |  |  | finish no earlier than 2016-06-09 |  |  |  |  |  |  | Rel-15 |  |  |  |  |  |  |
| 400 | 170 | Release 15 Studies on 5G | milestone | 0d? | 2016-06-09 A | 2016-06-09 A | 100% |  |  |  |  |  | finish no earlier than 2016-06-09 |  |  |  |  |  |  | Rel-15 |  |  |  |  |  |  |
| 401 | 171 | Study on management aspects of virtualized network functions that are part of the NR |  | 325d? | 2016-09-19 A | 2017-12-15 A | 100% |  |  |  |  |  | finish no earlier than 2017-12-15 | S5 | 2600h | 2600h | FS_MA_RNVNF | 37 | Intel (Joey Chou | Rel-15 | 73 | TR 32.864 | joey.chou@intel.com |  |  |  |
| 402 | 172 | Study on 5G enhanced Mobile Broadband Media Distribution |  | 270d? | 2017-06-05 A | 2018-06-15 | 25% | 202.5d? |  |  |  | 4561d | finish no earlier than 2018-06-15 | S4 | 2160h | 540h | FS_5GMedia_Distribution | 39 | Bouazizi, Imed, Samsung Electronics Co., Ltd., | Rel-15 | 76 | 26.8xx | i (dot) Bouazizi (at) Samsung (dot) com |  |  |  |
| 403 | 173 | Study on Media Handling Aspects of Conversational Services in 5G Systems |  | 204d? | 2017-06-05 A | 2018-03-15 | 35% | 132.6d? |  |  |  | 4627d | start no earlier than 2017-06-05 | S4 | 1632h | 571.2h | FS_5G_MEDIA_MTSI | 39 | Oyman, Ozgur, Company: Intel | Rel-15 | 76 | 26.9xy | ozgur.oyman@intel.com |  |  |  |
| 404 | 174 | Study on CU-DU lower layer split for New Radio |  | 328d? | 2017-03-15 A | 2018-06-15 | 95% | 16.4d? |  |  |  | 4561d | finish no earlier than 2018-06-15 | R3 | 2624h | 2492.8h | FS_NR_CU_DU_LLS | 38 | NTT DOCOMO | Rel-15 | 75 | 38.816 |  |  |  |  |
| 405 | 175 | Study of test methods for New Radio |  | 262d? | 2017-03-15 A | 2018-03-15 | 20% | 209.6d? |  |  |  | 4627d | finish no earlier than 2018-03-15 | R4 | 2096h | 419.2h | FS_NR_test_methods | 38 | Intel | Rel-15 | 75 | 38.810 |  |  |  |  |
| 406 | 176 | Study on NR-based access to unlicensed spectrum |  | 328d? | 2017-03-15 | 2018-06-15 |  |  |  |  |  | 4561d | finish no earlier than 2018-06-15 | R1 | 2624h |  | FS_NR_unlic | 38 | Qualcomm | Rel-15 | 75 | 32.889 |  |  |  |  |
| 407 | 177 | Study on Non-Orthogonal Multiple Access (NOMA) for NR |  | 328d? | 2017-03-15 | 2018-06-15 |  |  |  |  |  | 4561d | finish no earlier than 2018-06-15 | R1 | 2624h |  | FS_NR_NOMA | 38 | ZTE | Rel-15 | 75 | 32.812 |  |  |  |  |
| 408 | 178 | Study on integrated access and backhaul for NR |  | 328d? | 2017-03-15 | 2018-06-15 |  |  |  |  |  | 4561d | finish no earlier than 2018-06-15 | R2 | 2624h |  | FS_NR_IAB | 38 | Qualcomm | Rel-15 | 75 | 38.874 |  |  |  |  |
| 409 | 179 | Study on NR to support non-terrestrial networks |  | 328d? | 2017-03-15 A | 2018-06-15 | 40% | 196.8d? |  |  |  | 4561d | finish no earlier than 2018-06-15 | R1 | 2624h | 1049.6h | FS_NR_nonterr_nw | 38 | Thales | Rel-15 | 75 | 38.811 |  |  |  |  |
| 410 | 180 | STOPPED AT SA#77 - SA3 aspects on Study on Architecture and Security for Next Generation System |  | 467d? | 2016-03-01 A | 2017-12-12 A | 100% |  |  |  |  |  | finish no earlier than 2017-12-12 | S3 | 3736h | 3736h | FS_NSA | 36 | Vesa Torvinen, Ericsson | Rel-15 | 71 | TR 33.899 | vesa.torvinen@ericsson.com |  |  |  |
| 411 | 181 | Study on separation of CP and UP for split option 2 of NR |  | 132d? | 2017-06-15 A | 2017-12-15 A | 100% |  |  |  |  |  | finish no earlier than 2017-12-15 | R3 | 1056h | 1056h | FS_NR_CPUP_Split | 39 | Ericsson | Rel-15 | 76 | 38.806 |  |  |  |  |
| 412 | 182 | Release 15 Studies on 4G/LTE | milestone | 0d? | 2016-06-09 A | 2016-06-09 A | 100% |  |  |  |  |  | finish no earlier than 2016-06-09 |  |  |  |  |  |  | Rel-15 |  |  |  |  |  |  |
| 413 | 183 | Stopped - Study on LTE bandwidth flexibility enhancements |  | 263d? | 2016-03-15 A | 2017-03-15 A | 100% |  |  |  |  |  | finish no earlier than 2017-03-15 | R4 | 2104h | 2104h | FS_LTE_BW_flex | 36 | Huawei | Rel-15 | 71 | 36.740 |  |  |  |  |
| 414 | 184 | Study on interference cancellation receiver for LTE BS |  | 196d? | 2016-09-15 A | 2017-06-15 A | 100% |  |  |  |  |  | finish no earlier than 2017-06-15 | R4 | 1568h | 1568h | FS_LTE_IC_BS | 37 | China Telecom | Rel-15 | 73 | 36.766 |  |  |  |  |
| 415 | 185 | Study on uplink data compression in LTE |  | 197d? | 2016-12-15 A | 2017-09-15 A | 100% |  |  |  |  |  | finish no earlier than 2017-09-15 | R2 | 1576h | 1576h | FS_LTE_UDC | 38 | CATT | Rel-15 | 74 | 36.754 |  |  |  |  |
| 416 | 186 | Study on LTE DL 8Rx antenna ports |  | 132d? | 2017-06-15 A | 2017-12-15 A | 100% |  |  |  |  |  | finish no earlier than 2017-12-15 | R4 | 1056h | 1056h | FS_LTE_8Rx_AP_DL | 39 | Huawei | Rel-15 | 76 | 36.757 |  |  |  |  |
| 417 | 187 | Other Release 15 Studies |  | 136d? | 2017-09-08 A | 2018-03-16 |  | 136d? |  |  |  | 4626d | finish no earlier than 2018-03-16 |  |  |  |  |  |  | Rel-15 |  |  |  |  |  |  |
| 418 | 188 | Study on EVS Float Conformance Non Bit-Exact |  | 134d? | 2017-09-08 A | 2018-03-14 | 50% | 67d? |  |  |  | 4628d | finish no earlier than 2018-03-14 | S4 | 1072h | 536h | FS_EVS_FCNBE | 39 | Fabrice Plante, Intel | Rel-15 | 77 | New; 26.843 | fabrice.m.plante@intel.com |  |  |  |
| 419 | 189 | Study on Update to fixed-point basic operators |  | 135d? | 2017-09-08 A | 2018-03-15 | 80% | 27d? |  |  |  | 4627d | finish no earlier than 2018-03-15 | S4 | 1080h | 864h | FS_BASOP | 39 | Jelinek, Milan, VoiceAge Corporation | Rel-15 | 77 | New; 26.973 | Milan.Jelinek@USherbrooke.ca |  |  |  |
| 420 | 190 | Study on further enhancements to LTE Device to Device (D2D), UE to network relays for IoT (Internet of Things) and wearables |  | 460d? | 2016-03-15 A | 2017-12-15 A | 100% |  |  |  |  |  | finish no earlier than 2017-12-15 | R2 | 3680h | 3680h | FS_feD2D_IoT_relay_wearable | 36 | Qualcomm | Rel-15 | 71 | 36.746 |  |  |  |  |
| 421 | 191 | Study on Energy Efficiency Aspects of 3GPP Standards |  | 327d? | 2016-03-11 A | 2017-06-09 A | 100% |  |  |  |  |  | finish no earlier than 2017-06-09 | SP | 2616h | 2616h | FS_ENEFF | 36 | Orange, Xiaobao Chen | Rel-15 | 71 | TR 21.866 | xiaobao.chen@orange.com |  |  | _SP-170533 |
| 422 | 192 | Study on system and functional aspects of Energy Efficiency in 5G networks |  | 269d? | 2017-06-05 A | 2018-06-14 | 40% | 161.4d? |  |  |  | 4562d | finish no earlier than 2018-06-14 | S5 | 2152h | 860.8h | FS_EE_5G | 39 | CORNILY, Jean-Michel, ORANGE | Rel-15 | 76 | new; 32.872; 32.972 | jeanmichel.cornily@orange.com |  |  |  |
| 423 | 193 | Study on OAM support for assessment of energy efficiency in mobile access networks |  | 421d? | 2015-11-02 A | 2017-06-09 A | 100% |  |  |  |  |  | finish no earlier than 2017-06-09 | S5 | 3368h | 3368h | FS_OAM_EE | 36 | Cornily,Jean-Michel, ORANGE | Rel-15 | 70 | TR 32.856 | jeanmichel.cornily@orange.com |  |  |  |
| 424 | 194 | Study on Long Term Key Update Procedures |  | 204d? | 2017-06-05 A | 2018-03-15 | 70% | 61.2d? |  |  |  | 4627d | finish no earlier than 2018-03-15 | S3 | 1632h | 1142.4h | FS_LTKUP | 39 | Evans, Tim, Vodafone | Rel-15 | 76 | Internal TR | tim.evans1@vodafone.com |  |  |  |
| 425 | 195 | Study on evaluation methodology of new V2X use cases for LTE and NR |  | 262d? | 2017-03-15 A | 2018-03-15 | 10% | 235.8d? |  |  |  | 4627d | finish no earlier than 2018-03-15 | R1 | 2096h | 209.6h | FS_LTE_NR_V2X_eval | 38 | LG Electronics | Rel-15 | 75 | 37.885 |  |  |  |  |
| 426 | 196 | Study on MBMS User Services for IoT |  | 204d? | 2017-06-05 A | 2018-03-15 | 30% | 142.8d? |  |  |  | 4627d | start no earlier than 2017-06-05 | S4 | 1632h | 489.6h | FS_MBMS_IoT | 39 | Cedric thienot, Expway | Rel-15 | 76 | 26.8xx | cedric (dot) thienot (at) expway (dot) com |  |  |  |
| 427 | 197 | Study on FEC for MC Services |  | 204d? | 2017-06-05 A | 2018-03-15 | 60% | 81.6d? |  |  |  | 4627d | finish no earlier than 2018-03-15 | S4 | 1632h | 979.2h | FS_FEC_MCS | 39 | Lambrou, John - Motorola Solutions | Rel-15 | 76 | 26.XXX | john (dot) lambrou (at) motorolasolutions (dot) com |  |  |  |
| 428 | 198 | Study on Enhanced Isolated E-UTRAN Operation for Public Safety |  | 205d? | 2016-03-07 A | 2016-12-15 A | 100% |  |  |  |  |  | finish no earlier than 2016-12-15 | S2 | 1640h | 1640h | FS_IOPS_LB | 36 | Antoine Mouquet, Orange | Rel-15 | 71 | 23.798 | antoine.mouquet@orange.com |  |  |  |
| 429 | 199 | Study on Management Enhancement of CUPS of EPC Nodes |  | 269d? | 2016-12-01 A | 2017-12-12 A | 100% |  |  |  |  |  | finish no earlier than 2017-12-12 | S5 | 2152h | 2152h | FS_MECUPS | 38 | Huawei; Jiang, Junyi | Rel-15 | 74 | 32.867 | jiangjunyi@huawei.com |  |  |  |

Notes:
- 393: 12/7/17: 36.715-00-02 added;; 19/9/17: Compl:0%->20%...; 8/1/18: Compl:20%->50%; ;...
- 394: 19/9/17: CD:Sat 15/09/18->Fri 15/06/18; ...; 8/1/18: Compl:0%->50%; ...
- 395: ; 8/1/18: Compl:0%->7%; ...
- 396: Triggered by Rel-11 TR 37.902 Study on Measurements of radio performances for LTE terminals - TRP and TRS test methodology (FS_LTE_OTA) UID_550022
- 397: ; CD:Wed 18/03/15->Sun 15/03/15; Rel-12->Rel-13; Stat Rep: RP-141158->RP-141973 1st Apr 15: Compl:35%->40% 1st Apr 15: Stat Rep: RP-141973->RP-150104 03/07/15: Stat Rep: RP-150104->RP-150615 29/09/15: Compl:40%->50% 29/09/15: Stat Rep: RP-150615->RP-15...; ; ; ; ; ; ; ; ; ; ; ; ; ; ; ; ; ; ; ; ; ; ; ; ; ; ; ; ; ; ; ; ; ; ; ; ; ; ; ; ; ; ; ; ; ; ; ; ; ; ; ; ; ; ; ; ; ; ; ; ; ; ; ; ; ; ; ; ; ; 8/1/18: CD:Thu 15/03/18->Fri 15/12/17
- 398: Stat Rep: RP-141132->RP-141848; Rel 12->Rel13 1st Apr 15: Compl:15%->20% 1st Apr 15: CD:Mon 15/06/15->Wed 15/06/16 1st Apr 15: WID: RP-140090->RP-150070 1st Apr 15: Stat Rep: RP-141848->RP-150069 03/07/15: Compl:20%->25% 03/07/15: Stat Rep: RP-150069->...; ; ; ; ; ; ; ; ; ; ; ; ; ; ; ; ; ; ; ; ; ; ; ; ; ; ; ; ; ; ; ; ; ; ; ; ; ; ; ; ; ; ; ; ; ; ; ; ; ; ; ; ; ; ; ; ; ; ; ; ; ; ; ; ; ; ; ; ; ; ; ; ; ; ; ; ; ; ; ; ; ; ; ; ; ; ; ; ; ; ; ; ; ; ; ; ; ; ; ; 8/1/18: CD:Fri 15/06/18->Fri 15/12/17
- 399: -
- 400: -
- 401: 6/10/16: Acronym FS_MA_RVNF ->FS_MA_RNVNF ; 6/10/16: 32.864 added; 1/12/16: 0%->5; 6/3/17: 5%->10; 7/6/17: 10%->40; 11/9/17: 40%->70; 15/12/17: 70%->100; 15/12/17: FCD:09/17->12/17
- 402: 11/9/17: 0%->10; 15/12/17: FCD:03/18->06/20; 15/12/17: 10%->25
- 403: 11/9/17: 0%->5; 15/12/17: 5%->35
- 404: CU = central unit, DU = distributed unit; results will be captured in existing TR 38.801; 19/9/17: Compl:0%->30%; 19/9/17: WID: RP-170818->RP-171717; 15/12/17: 38.816 added;; 8/1/18: Compl:30%->95%; 8/1/18: CD:Fr...
- 405: TR 38.8XX; 19/6/17: Compl:0%->10%; 19/6/17: WID: RP-170824->RP-171021; 30/6/17: 38.810 added;19/9/17: Compl:10%->15%19/9/17: WID: RP-171021->RP-171828; 8/1/18: Compl:15%->20%
- 406: TR 38.8XX19/6/17: WID: RP-170828->RP-171416; 30/6/17: 32.889 added;; 19/9/17: WID: RP-171416->RP-172021
- 407: TR 38.8XX; 19/6/17: WID: RP-170829->RP-171043; 30/6/17: 32.812 added;
- 408: TR 38.8XX; 30/6/17: 38.874 added;; 19/9/17: WID: RP-170831->RP-171880; 8/1/18: WID: RP-171880->RP-172290
- 409: TR 38.8XX19/6/17: Compl:0%->25%19/6/17: CD:Fri 15/12/17->Thu 15/03/1819/6/17: WID: RP-170717->RP-171450; 30/6/17: 38.811 added;; 19/9/17: Compl:25%->40%; 8/1/18: CD:Thu 15/03/18->Fri 15/06/18
- 410: 19/9/16: 0%->25; 22/9/16: WID:SP-160227->SP-160727; 22/9/16: FCD:12/16->03/17; 1/12/16: 25%->45; 6/3/17: 45%->60; 7/6/17: FCD:03/17->12/17 so Rel-14->Rel-15; 7/6/17: 60%->65; 11/9/17: 65%->100
- 411: 19/9/17: Compl:0%->45%19/9/17: WID: RP-171421->RP-171905; 15/12/17: 38.806 added;; 8/1/18: Compl:45%->100%
- 412: -
- 413: 1/7/16: Compl:0%->50%; 28/7/16: 36.740 added; 26/9/16: WID: RP-161328->RP-161670; 20/12/16: CD:Thu 15/0;21/3/17: CD:Fri 15...; 12/7/17: 50%->100 since declared as stopped
- 414: 6/10/16: 36.766 added; 20/12/16: Compl:0%->35% 21/3/17: Compl:35%->65%; 19/6/17: Compl:65%->100%
- 415: ; 21/3/17: WID: RP-162541->RP-170403; 21/3/17: 36.754 added;19/6/17: Compl:0%->90%; 19/9/17: Compl:90%->100...
- 416: 12/7/17: 36.757 added;; 19/9/17: Compl:0%->35%; ...; 8/1/18: Compl:35%->100%
- 417: -
- 418: 15/12/17: 26.843 added;; 15/12/17: 0%->50
- 419: 15/12/17: 26.973 added;; 15/12/17: 0%->80
- 420: 1/7/16: Compl:0%->2%;26/9/16: Compl:2%->5%; 6/10/16: 36.746 added; 20/12/16: Compl:5%->15%;21/3/17: Compl:15%->35%…19/6/17:...; ;...; ;...
- 421: 28/7/16: 21.866 added;; 9/6/17: FCD:12/16->9/6/17 (Rel-14->Rel-15); 0%->100
- 422: 30/6/17: 32.872 added;; 11/9/17: 0%->5; 15/12/17: 32.972 added;; 15/12/17: 5%->40
- 423: 13/6/16: WID:SP-150674->SP-160430; 13/6/16: 0%->55; 1/12/16: 55%->80; 6/3/17: FCD:03/17->06/17; 6/3/17: 80%->90; 21/3/17: moved from rel-14; 7/6/17: 90%->100
- 424: 11/9/17: 0%->10; 15/12/17: 10%->70; 15/12/17: FCD:12/17->03/18
- 425: TR 38.8XX19/6/17: WID: RP-170837->RP-171093; 12/7/17: 37.885 added;19/9/17: Compl:0%->5%; 8/1/18: Compl:5%->10%; 8/1/18: CD:Fri 15/12/17->Thu 15/03/18
- 426: 11/9/17: 0%->10; 15/12/17: 10%->30
- 427: 11/9/17: 0%->15; 15/12/17: 15%->60; 15/12/17: FCD:12/17->03/18
- 428: 9/6/16: 0%->6; 28/7/16: 23.798 added; 1/12/16: FCD:09/16->12/16; 1/12/16: 6%->15. 7/12/16: Moved from Rel-14 according to SP-160806.; 6/3/17: 15%->50; 7/6/17: 50%->100
- 429: 6/3/17: 0%->5; 7/6/17: 5%->40; 7/6/17: FCD:09/17->12/17; 11/9/17: 40%->50; 15/12/17: 50%->100

| ID | WBS | Task | Type | Duration | Start | Finish | Complete | Remaining | Baseline start | Baseline finish | Baseline duration | Total slack | Constraint | Resources | Work | Actual work | Acronym | PCG approved | Impacted TSs and TRs | WI rapporteur name | WI rapporteur e-mail | Release | TSG approved | MCC resp | Acronym_3GU_Export |
| --- | --- | --- | --- | --- | --- | --- | --- | --- | --- | --- | --- | --- | --- | --- | --- | --- | --- | --- | --- | --- | --- | --- | --- | --- | --- |
| 430 | 200 | **Study on Policy and Charging for Volume Based Charging** |  | 272d? | 2016-12-01 A | 2017-12-15 A | 100% |  |  |  |  |  |  | C3 | 6528h | 6528h | FS_PC_VBC | 38 | TR 29.827 | Huang, Zhenning, China Mobile | huangzhenning <at> chinamobile <dot> com | Rel-15 | 74 |  |  |
| 431 | 200.1 | Study on Policy and Charging for Volume Based Charging |  | 272d? | 2016-12-01 A | 2017-12-15 A | 100% |  |  |  |  |  | finish no earlier than 2017-12-15 | C3 | 2176h | 2176h | FS_PC_VBC | 38 | TR 29.827 | Huang, Zhenning, China Mobile | huangzhenning <at> chinamobile <dot> com | Rel-15 | 74 |  |  |
| 432 | 200.2 | Study on Policy and Charging for Volume Based Charging |  | 272d? | 2016-12-01 A | 2017-12-15 A | 100% |  |  |  |  |  | finish no earlier than 2017-12-15 | C1 | 2176h | 2176h | FS_PC_VBC | 38 | TR 29.827 | Huang, Zhenning, China Mobile | huangzhenning <at> chinamobile <dot> com | Rel-15 | 74 |  |  |
| 433 | 201 | Study on Technical Requirements for a new secure platform for 3GPP applications |  | 328d? | 2016-06-13 A | 2017-09-12 A | 100% |  |  |  |  |  | finish no earlier than 2017-09-12 | C6 | 2624h | 2624h | FS_NG_SP | 37 | TR 31.801 | Heiko Kruse | heiko.kruse@safrangroup.com | Rel-15 | 72 |  |  |
| 434 | 202 | Study on technical requirements for a new secure platform for 3GPP applications |  | 140d? | 2017-03-03 A | 2017-09-14 A | 100% |  |  |  |  |  | finish no earlier than 2017-09-14 | C6 | 1120h | 1120h | FS_NG_SP2 | 38 | 31.801 | Heiko Kruse | heiko.kruse@safrangroup.com | Rel-15 | 75 |  |  |
| 435 | 203 | Study on scheduling enhancements with carrier aggregation for UMTS |  | 67d? | 2017-03-15 A | 2017-06-15 A | 100% |  |  |  |  |  | finish no earlier than 2017-06-15 | R1 | 536h | 536h | FS_UTRA_CA_sched_enh | 38 | 25.708 | Huawei |  | Rel-15 | 75 |  |  |
| 436 | 204 | Study on enhanced LTE Support for Aerial Vehicles |  | 198d? | 2017-03-15 A | 2017-12-15 A | 100% |  |  |  |  |  | finish no earlier than 2017-12-15 | R2 | 1584h | 1584h | FS_LTE_Aerial | 38 | 36.777 | NTT DOCOMO |  | Rel-15 | 75 |  |  |
| 437 | 205 | Study on Architecture Evolution for E-UTRAN |  | 262d? | 2017-03-15 A | 2018-03-15 | 85% | 39.3d? |  |  |  | 4627d | finish no earlier than 2018-03-15 | R3 | 2096h | 1781.6h | FS_LTE_arch_evo | 38 | 36.756; 37.876 | China Unicom |  | Rel-15 | 75 |  |  |
| 438 | 206 | Study on Enhanced Acoustic Test Specifications |  | 1246d? | 2013-03-18 A | 2017-12-12 A | 100% |  | 2013-03-06 | 2014-09-17 | 401d? |  | finish no earlier than 2017-12-12 | S4 | 9968h | 9968h | FS_SEATS | 30 | 26.931 | Knowles, Intel | Scott Isabelle (Knowles), David Isherwood (Intel) | Rel-15 | 59 | Paolo | FS_SEATS |
| 439 | 207 | Study on User Services Enhancements in 3GPP for TV Services |  | 328d? | 2016-06-13 A | 2017-09-12 A | 100% |  |  |  |  |  | finish no earlier than 2017-09-12 | S4 | 2624h | 2624h | FS_USE_3GPP_4_TV | 37 | TR 26.9xx; 26.917 | Thomas Stockhammer, Qualcomm Incorporated | tsto@qti.qualcomm.com | Rel-15 | 72 |  |  |
| 440 | 208 | Study on Management aspects of selected IoT-related features |  | 322d? | 2016-09-19 A | 2017-12-12 | 45% | 177.1d? |  |  |  | 4694d | finish no earlier than 2017-12-12 | S5 | 2576h | 1159.2h | FS_OAM_IOT | 37 | 32.857 | Cisco Systems / Yanover, Vladimir |  | Rel-15 | 73 |  |  |
| 441 | 209 | Study on Overload Control for Diameter Charging Applications |  | 653d? | 2015-06-18 A | 2017-12-15 A | 100% |  |  |  |  |  | finish no earlier than 2017-12-15 | S5 | 5224h | 5224h | FS_DOCME_CH | 35 | New TR 32.869 | GUO Wenjie, ZTE | guo.wenjie1@zte.com.cn | Rel-15 | 68 |  |  |
| 442 | 210 | Study on forward compatibility for 3GPP Diameter Charging Applications |  | 194d? | 2016-09-19 A | 2017-06-15 A | 100% |  |  |  |  |  | finish no earlier than 2017-06-15 | S5 | 1552h | 1552h | FS_FWDCA | 37 | 32.870 | Nokia, Maryse <dot> Gardella <at> Nokia <dot> com | Nokia, Maryse <dot> Gardella <at> Nokia <dot> com | Rel-15 | 73 |  |  |
| 443 | 211 | Study on OAM aspects of SON for AAS-based deployments |  | 421d? | 2015-11-02 A | 2017-06-09 A | 100% |  |  |  |  |  | finish no earlier than 2017-06-09 | S5 | 3368h | 3368h | FS_OAM_SON_AAS | 36 | TR (new) | Nokia Networks (Yizhi Yao) | Yizhi.yao@nokia.com | Rel-15 | 70 |  |  |
| 444 | 212 | Study on Implementation for the Partitioning of Itf-N |  | 534d? | 2016-03-01 A | 2018-03-15 A | 100% |  |  |  |  |  | finish no earlier than 2018-03-15 | S5 | 4272h | 4272h | FS_IMP_ITFN | 36 | New TR 32.880 | Hu, Yaxi, China Mobile | huyaxi@cmdi.chinamobile.com | Rel-15 | 71 |  |  |
| 445 | 213 | Study on Management Aspects of Next Generation Network architecture and features |  | 393d? | 2016-06-13 A | 2017-12-12 A | 100% |  |  |  |  |  | finish no earlier than 2017-12-12 | S5 | 3144h | 3144h | FS_MAN_NGNAF | 37 | TR (new); 28.802 | Nokia Networks, Yizhi Yao | Yizhi.yao@nokia.com | Rel-15 | 72 |  |  |
| 446 | 214 | Study on Management and Orchestration Architecture of Next Generation Network and Service |  | 393d? | 2016-06-13 A | 2017-12-12 A | 100% |  |  |  |  |  | finish no earlier than 2017-12-12 | S5 | 3144h | 3144h | FS_NGNS_MOA | 37 | TR xy.abc; 28.800 | Huawei Technologies, Zou Lan | zoulan@huawei.com | Rel-15 | 72 |  |  |
| 447 | 215 | Study on SON for eCoMP for LTE |  | 263d? | 2016-06-15 A | 2017-06-15 A | 100% |  |  |  |  |  | finish no earlier than 2017-06-15 | R3 | 2104h | 2104h | FS_LTE_SON_eCOMP | 37 |  | Nokia |  | Rel-15 | 72 |  |  |
| 448 | 216 | Stopped - Study on IMS Enhanced Spoofed Call Prevention and Detection |  | 849d? | 2014-09-19 A | 2017-12-15 A | 100% |  |  |  |  |  | finish no earlier than 2017-12-15 | S3 | 6792h | 6792h | FS_ESCAPADES | 33 | 33.832 | Sprint | Gregory.schumacher@sprint.com | Rel-15 | 64 |  | FS_ESCAPADES |
| 449 | 217 | Study on OAM aspects of LTE and WLAN integration |  | 204d? | 2017-06-05 A | 2018-03-15 | 50% | 102d? |  |  |  | 4627d | finish no earlier than 2018-03-15 | S5 | 1632h | 816h | FS_OAM_LWI | 39 | new; 32.868 | Yizhi Yao, Intel Corporation | yizhi.yao@intel.com | Rel-15 | 76 |  |  |
| 450 | 218 | Study on network policy management for mobile networks based on NFV scenarios |  | 269d? | 2017-06-05 A | 2018-06-14 | 30% | 188.3d? |  |  |  | 4562d | finish no earlier than 2018-06-14 | S5 | 2152h | 645.6h | FS_NETPOL | 39 | new; 32.871 | China Mobile Jinglei Liu | liujinglei@chinamobile.com | Rel-15 | 76 |  |  |
| 451 | 219 | Study on Volume Based Charging Aspects for VoLTE |  | 269d? | 2017-06-05 A | 2018-06-14 | 35% | 174.85d? |  |  |  | 4562d | start no earlier than 2017-06-05 | S5 | 2152h | 753.2h | FS_VBCLTE | 39 | new; 32.848 | Chen, Ai, China Mobile | chenai@chinamobile.com | Rel-15 | 76 |  |  |
| 452 | 220 | STOPPED - Study on UE characteristics and performance for Video |  | 339d? | 2016-03-01 A | 2017-06-15 A | 100% |  |  |  |  |  | finish no earlier than 2017-06-15 | S4 | 2712h | 2712h | FS_UE_VTPerf | 36 | TR 26.932 | Stéphane PROUST, Orange | stephane.proust@orange.com | Rel-15 | 71 |  |  |
| 453 | 221 | Study on self-evaluation towards IMT-2020 submission |  | 393d? | 2016-12-14 A | 2018-06-15 | 15% | 334.05d? |  |  |  | 4561d | finish no earlier than 2018-06-15 | ITU-R AH | 3144h | 471.6h | FS_5G_eval | 38 |  | Huawei |  | Rel-15 | 75 |  |  |
| 454 | 222 | Study on 6 GHz for LTE and NR |  | 131d? | 2017-12-15 | 2018-06-15 |  |  |  |  |  | 4561d | finish no earlier than 2018-06-15 | RP | 1048h |  | FS_6GHz_LTE_NR |  |  | Ericsson |  | Rel-15 |  |  |  |
| 455 | 223 | Study on UE Application Layer Data Throughput Performance Expansion for Carrier Aggregation |  | 131d? | 2017-12-15 | 2018-06-15 |  |  |  |  |  | 4561d | finish no earlier than 2018-06-15 | R5 | 1048h |  | FS_UE_App_Data_Perf_CA |  |  | PCTEST Engineering Lab |  | Rel-15 |  |  |  |
| 456 | 224 | Release 14 Features | milestone | 0d? | 2014-12-12 A | 2014-12-12 A | 100% |  |  |  |  |  | finish no earlier than 2014-12-12 |  |  |  |  |  |  |  |  | Rel-14 |  |  |  |
| 457 | 225 | Release 14 on Mission Critical | milestone | 0d? | 2016-06-09 A | 2016-06-09 A | 100% |  |  |  |  |  | finish no earlier than 2016-06-09 |  |  |  |  |  |  |  |  | Rel-14 |  |  |  |

Notes:
- 430: 6/3/17: 0%->30; 21/3/17: 29.827 added;; 5/6/17: 30%->60; 8/9/17: WID:CP-160822->CP-172058; 11/9/17: FCD:06/17->12/17
- 431: 6/3/17: 0%->30; 21/3/17: 29.827 added;; 5/6/17: 30%->60; 8/9/17: WID:CP-160822->CP-172058; 11/9/17: FCD:06/17->12/17; 15/12/17: 60%->61; 15/12/17: 61%->100
- 432: 15/12/17: 0%->100
- 433: 16/9/16: 0%->15. ; 5/6/17: 15%->70. 5/6/17: moved to Rel-15 (talks with P. Jolivet); 5/6/17: FCD:12/16->09/20; 15/12/17: 70%->100
- 434: 21/3/17: 31.801 added;; 11/9/17: 0%->70; 15/12/17: 70%->100
- 435: TR 25.7XX; 19/6/17: Compl:0%->100%; ...; 12/7/17: 25.708 added;
- 436: TR 36.7XX19/6/17: Compl:0%->15%;...; 30/6/17: 36.777 added;; 19/9/17: Compl:15%->30%; 8/1/18: Compl:30%->100%
- 437: TR 36.8XX; 12/7/17: 36.756 added;19/9/17: Compl:0%->40%; ;...; 15/12/17: 37.876 added;; 8/1/18: Compl:40%->8...
- 438: SP#65 completion 09/14=>12/14. Moved to Rel-13. Dec.14: 30->35%, CD 12/14->03/15. Mar.15: CD: 06/16. 40%; June2015: Compl:40%->45. . 15/4/16: moved from R...; 21/3/17: Moved from Rel-14 (not completed on time); 7/6/17: FCD:06/17->12/17; 11/9/17: 80%->85; 15/12/17: 85%->100
- 439: 19/9/16: 0%->30; 6/10/16: 26.917 added; 1/12/16: 30%->60; 1/12/16: FCD:12/16->03/17; 6/3/17: 60%->75; 6/3/17: FCD:03/17->06/17; 21/3/17: Moved from Rel-14 (not completed on time); 7/6/17: 75%->80; 7/6/17: FCD:06/17->09/17; 11/9/17: 80%->100
- 440: 6/10/16: 32.857 added; 1/12/16: 0%->5; 21/3/17: moved from Rel-14; 7/6/17: FCD:06/17->12/17; 7/6/17: 5%->20; 11/9/17: 20%->30; 15/12/17: 30%->45
- 441: Aug2015: moved to Rel-14 (email CT and EG); 07/09/15: 0%->5; 7/3/16: 5%->10; 13/6/16: FCD:03/16->09/16; 19/9/16: FCD: 09/16->06/17; 6/3/17: FCD:03/17->12/17; 21/3/17: moved from rel-14; 7/6/17: 10%->25; 8/6/17: WID:SP-150310->SP-170481; 11/9/17: 25%->30; 15/12/17: 30%->100
- 442: 6/10/16: 32.870 added; 1/12/16: 0%->10; 21/3/17: moved from rel-14; 11/9/17: 10%->40; 15/12/17: 40%->100
- 443: 13/6/16: 0%->40; 19/9/16: FCD:09/16->12/16; 19/9/16: 40%->60; 1/12/16: FCD:12/16->03/17; 1/12/16: 60%->70; 6/3/17: FCD:03/17->06/17; 21/3/17: moved from rel-14; 7/6/17: 70%->100
- 444: 13/6/16: 0%->10; 19/9/16: 10%->35; 1/12/16: 35%->40; 6/3/17: FCD:03/17->03/18; 21/3/17: moved from rel-14; 7/6/17: 40%->60; 11/9/17: 60%->80; 15/12/17: 80%->100
- 445: 28/7/16: 28.802 added; 19/9/16: 0%->5; 1/12/16: 5%->10; 6/3/17: FCD:03/17->06/17; 6/3/17: 10%->40; 21/3/17: moved from rel-14; 7/6/17: FCD:06/17->12/17; 7/6/17: 40%->60; 11/9/17: 60%->70; 15/12/17: 70%->100
- 446: 28/7/16: 28.800 added; 19/9/16: 0%->10; 6/3/17: FCD:03/17->06/17; 21/3/17: moved from rel-14; 7/6/17: FCD:06/17->12/17; 7/6/17: 10%->25; 11/9/17: 25%->30; 15/12/17: 30%->100
- 447: 26/9/16: Compl:0%->10%. ; 20/12/16: Compl:10%->40%21/3/17: Compl:40%->60%;...; 19/6/17: Compl:60%->100%
- 448: Dec.14: TR number added. 3/3/15: 0->5%; June2015: Compl:5%->25; 9/12/15: 25%->30; 21/3/17: moved from Rel-13; 21/3/17: FCD:09/15->12/17; 7/6/17: Stopped (30%->100%)
- 449: 30/6/17: 32.868 added;; 11/9/17: 0%->10; 15/12/17: 10%->50
- 450: 30/6/17: 32.871 added;; 11/9/17: 0%->20; 15/12/17: 20%->30
- 451: 30/6/17: 32.848 added;; 11/9/17: 0%->5; 15/12/17: 5%->35
- 452: 11/6/16: 0%->10; 19/9/16: 10%->30, FCD: 12/16->06/17; 21/3/17: Moved from Rel-14 (not completed on time); 7/6/17: Stopped, so 30%->100
- 453: TR 38.9XX; 19/6/17: CD:Sat 15/09/18->Fri 15/06/18; 19/6/17: WID: RP-170832->RP-171451; 19/6/17: Release: Rel-16->Rel-15; 8/1/18: Compl:0%->15%
- 454: SI under RAN leadership; TR 37.8XX
- 455: compare REL-11 SI FS_UE_App_Data_Perf; note: SI FS_UE_App_Data_Perf_CA is addressing 2DL/1UL involving also an unlicensed carrier of REL-13 LTE_LAA; instead of a new TR, the TR 37.901 will be updated for REL-15
- 456: -
- 457: -

| ID | WBS | Task | Duration | Start | Finish | Complete | Constraint | Resources | Work | Actual work | Acronym | PCG approved | Release | TSG approved | Impacted TSs and TRs | WI rapporteur name | WI rapporteur e-mail | Status Report |
| --- | --- | --- | --- | --- | --- | --- | --- | --- | --- | --- | --- | --- | --- | --- | --- | --- | --- | --- |
| 458 | 226 | **Mission Critical Improvements** | 569d? | 2015-04-14 A | 2017-06-15 A | 100% |  |  | 27144h | 27144h | MCImp | 36 | Rel-14 | 70 |  |  |  |  |
| 459 | 226.1 | Mission Critical Push to Talk over LTE Realignment | 138d? | 2015-12-07 A | 2016-06-15 A | 100% | finish no earlier than 2016-06-15 | S1 | 1104h | 1104h | MCImp-MCPTTR | 36 | Rel-14 | 70 | 22.179 | Andrew Thiessen | andrew (at) its (dot) bldrdoc (dot) gov | SP-170406 |
| 460 | 226.2 | **Enhancements for Mission Critical Push To Talk** | 264d? | 2016-06-13 A | 2017-06-14 A | 100% |  |  | 5624h | 5624h | MCImp-eMCPTT | 37 | Rel-14 | 72 | TS 23.379, TS 23.280, TS 23.281, TS 23.282; 23.379 | Lazara, Dom | dom.lazara@motorolasolutions.com |  |
| 461 | 226.2.1 | Stage 2 of Enhancements for Mission Critical Push To Talk | 135d? | 2016-06-13 A | 2016-12-15 A | 100% | finish no earlier than 2016-12-15 | S6 | 1080h | 1080h | MCImp-eMCPTT | 37 | Rel-14 | 72 | TS 23.379, TS 23.280, TS 23.281, TS 23.282; 23.379 | Lazara, Dom | dom.lazara@motorolasolutions.com |  |
| 462 | 226.2.2 | **Stage 3 of Enhancements for Mission Critical Push To Talk** | 140d? | 2016-12-01 A | 2017-06-14 A | 100% |  | ct | 4544h | 4544h | MCImp-eMCPTT-CT | 38 | Rel-14 | 74 |  | FREDERICKS, Bob | bobfredericks@motorolasolutions.com |  |
| 463 | 226.2.2.1 | CT1 aspects of Enhancements for Mission Critical Push To Talk | 140d? | 2016-12-01 A | 2017-06-14 A | 100% | finish no earlier than 2017-06-14 | C1 | 1120h | 1120h | MCImp-eMCPTT-CT | 38 | Rel-14 | 74 | 24.379, 24.380, 24.381, 24.382, 24.383, 24.384 | FREDERICKS, Bob | bobfredericks@motorolasolutions.com |  |
| 464 | 226.2.2.2 | CT3 aspects of Enhancements for Mission Critical Push To Talk | 74d? | 2016-12-01 A | 2017-03-14 A | 100% | finish no earlier than 2017-03-14 | C3 | 592h | 592h | MCImp-eMCPTT-CT | 38 | Rel-14 | 74 | 29.165, 29.213, 29.214 | FREDERICKS, Bob | bobfredericks@motorolasolutions.com |  |
| 465 | 226.2.2.3 | CT4 aspects of Enhancements for Mission Critical Push To Talk | 74d? | 2016-12-01 A | 2017-03-14 A | 100% | finish no earlier than 2017-03-14 | C4 | 592h | 592h | MCImp-eMCPTT-CT | 38 | Rel-14 | 74 | 23.003, 29.228, 23.335, 29.283 | FREDERICKS, Bob | bobfredericks@motorolasolutions.com |  |
| 466 | 226.2.2.4 | CT6 aspects of Enhancements for Mission Critical Push To Talk | 140d? | 2016-12-01 A | 2017-06-14 A | 100% | finish no earlier than 2017-06-14 | C6 | 1120h | 1120h | MCImp-eMCPTT-CT | 38 | Rel-14 | 74 | 31.102, 31.103 | FREDERICKS, Bob | bobfredericks@motorolasolutions.com |  |
| 467 | 226.3 | Mission Critical Services Common Requirements | 138d? | 2015-12-07 A | 2016-06-15 A | 100% | finish no earlier than 2016-06-15 | S1 | 1104h | 1104h | MCImp-MCCoRe | 36 | Rel-14 | 70 | New TS 22.280 | Andrew Thiessen | andrew (at) its (dot) bldrdoc (dot) gov | SP-170407 |
| 468 | 226.4 | Common functional architecture to support mission critical services | 135d? | 2016-06-13 A | 2016-12-15 A | 100% | finish no earlier than 2016-12-15 | S6 | 1080h | 1080h | MCImp-MC_ARCH | 37 | Rel-14 | 72 | TS 23.280, TS 23.379, TS 23.281, TS 23.282; 23.280 | Niranth Amogh, Huawei Telecommunications India | namogh@huawei.com |  |
| 469 | 226.5 | **Mission Critical Video over LTE** | 568d? | 2015-04-14 A | 2017-06-14 A | 100% |  |  | 8528h | 8528h | MCImp-MCVideo | 36 | Rel-14 | 70 |  | Emmanuelle Villebrun | Emmanuelle.villebrun@gendarmerie.interieur.gouv.fr |  |
| 470 | 226.5.1 | Study on Mission Critical Video over LTE | 176d? | 2015-04-14 A | 2015-12-15 A | 100% | finish no earlier than 2015-12-15 | S1 | 1408h | 1408h | FS_MCVideo | 34 | Rel-14 | 67 | New TR 22.879 | Villebrun, Emmanuelle (French MoI) | emmanuelle.villebrun@gendarmerie.interieur.gouv.fr |  |
| 471 | 226.5.2 | Stage 1 of MCVideo | 138d? | 2015-12-07 A | 2016-06-15 A | 100% | finish no earlier than 2016-06-15 | S1 | 1104h | 1104h | MCImp-MCVideo | 36 | Rel-14 | 70 | New TR 22.281 | Emmanuelle Villebrun | Emmanuelle.villebrun@gendarmerie.interieur.gouv.fr |  |
| 472 | 226.5.3 | Stage 2 for MCVideo | 135d? | 2016-06-13 A | 2016-12-15 A | 100% | finish no earlier than 2016-12-15 | S6 | 1080h | 1080h | MCImp-MCVideo | 37 | Rel-14 | 72 | TS 23.281, TS 23.280, TS 23.379, TS 23.282; 23.281 | Niranth Amogh, Huawei Telecommunications India | namogh@huawei.com |  |
| 473 | 226.5.4 | MCVideo codecs and media handling | 47d? | 2017-01-11 A | 2017-03-16 A | 100% | finish no earlier than 2017-03-16 | S4 | 376h | 376h | MCImp-MCVideo | 38 | Rel-14 | 75 | 26.281 | John Lambrou (Motorola Solutions) | john (dot) lambrou (at) motorolasolutions (dot) com |  |
| 474 | 226.5.5 | **Stage 3 of MCVideo** | 140d? | 2016-12-01 A | 2017-06-14 A | 100% |  | ct | 4560h | 4560h | MCImp-MCVIDEO-CT | 38 | Rel-14 | 74 | 24.581, 24.281 | PATEL, Milan | milan.patel@huawei.com |  |
| 475 | 226.5.5.1 | CT1 aspects 3 of MCVideo | 140d? | 2016-12-01 A | 2017-06-14 A | 100% | finish no earlier than 2017-06-14 | C1 | 1120h | 1120h | MCImp-MCVIDEO-CT | 38 | Rel-14 | 74 | 24.381, 24.382, 24.383, 24.384 | PATEL, Milan | milan.patel@huawei.com |  |
| 476 | 226.5.5.2 | CT3 aspects 3 of MCVideo | 75d? | 2016-12-01 A | 2017-03-15 A | 100% | finish no earlier than 2017-03-15 | C3 | 600h | 600h | MCImp-MCVIDEO-CT | 38 | Rel-14 | 74 | 29.165, 29.213, 29.214 | PATEL, Milan | milan.patel@huawei.com |  |
| 477 | 226.5.5.3 | CT4 aspects 3 of MCVideo | 75d? | 2016-12-01 A | 2017-03-15 A | 100% | finish no earlier than 2017-03-15 | C4 | 600h | 600h | MCImp-MCVIDEO-CT | 38 | Rel-14 | 74 | 23.003, 23.335, 29.283 | PATEL, Milan | milan.patel@huawei.com |  |
| 478 | 226.5.5.4 | CT6 aspects 3 of MCVideo | 140d? | 2016-12-01 A | 2017-06-14 A | 100% | finish no earlier than 2017-06-14 | C6 | 1120h | 1120h | MCImp-MCVIDEO-CT | 38 | Rel-14 | 74 | 31.102, 31.103 | PATEL, Milan | milan.patel@huawei.com |  |
| 479 | 226.6 | **Mission Critical Data over LTE** | 568d? | 2015-04-14 A | 2017-06-14 A | 100% |  |  | 8152h | 8152h | MCImp-MCData | 36 | Rel-14 | 70 |  | Emmanuelle Villebrun | Emmanuelle.villebrun@gendarmerie.interieur.gouv.fr |  |
| 480 | 226.6.1 | Study on Mission Critical Data Communications | 176d? | 2015-04-14 A | 2015-12-15 A | 100% | finish no earlier than 2015-12-15 | S1 | 1408h | 1408h | FS_MCDATA | 34 | Rel-14 | 67 | New TR 22.880 | Villebrun, Emmanuelle (French MoI) | emmanuelle.villebrun@gendarmerie.interieur.gouv.fr |  |
| 481 | 226.6.2 | Stage 1 of MCData | 138d? | 2015-12-07 A | 2016-06-15 A | 100% | finish no earlier than 2016-06-15 | S1 | 1104h | 1104h | MCImp-MCData | 36 | Rel-14 | 70 | New TR 22.282 | Emmanuelle Villebrun | Emmanuelle.villebrun@gendarmerie.interieur.gouv.fr |  |
| 482 | 226.6.3 | Stage 2 for MCData | 135d? | 2016-06-13 A | 2016-12-15 A | 100% | start no earlier than 2016-06-13 | S6 | 1080h | 1080h | MCImp-MCData | 37 | Rel-14 | 72 | 23.282 | David Freeman (UK Home Office) | david@dnf-consulting.co.uk |  |

Notes:
- 458: Umbrella Feature
- 459: 2/3/16: FCD: 03/16->06/16. ES in SP-160102; 0->75%; 9/6/16: 75%->100
- 460: 28/7/16: 23.379 added; 19/9/16: 0%->35; 1/12/16: 35%->100
- 461: 28/7/16: 23.379 added; 19/9/16: 0%->35; 1/12/16: 35%->100
- 463: 6/3/17: 0%->20; 5/6/17: 20%->95; 14/9/17: 95%->97; 15/12/17: 97%->100
- 464: 5/6/17: 0%->100
- 465: 6/3/17: 0%->100
- 466: 5/6/17: 0%->100. No work identified for CT6.
- 467: 2/3/16: FCD: 03/16->06/16. ES in SP-160104; 0->75%; 9/6/16: 75%->100
- 468: 28/7/16: 23.280 added; 19/9/16: 0%->40; 1/12/16: 40%->95; 3/3/17: 95%->100
- 469: 2/3/16: FCD: 03/16->06/16. ES in SP-160106; 0->80%; 9/6/16: 80%->100
- 470: 1/4/15:TR number added; June2015: Compl:0%->50; 07/09/15: 50%->70; 7/12/15: 70%->100
- 471: 2/3/16: FCD: 03/16->06/16. ES in SP-160106; 0->80%; 9/6/16: 80%->100
- 472: 28/7/16: 23.281 added; 19/9/16: 0%->25; 1/12/16: 25%->95; 3/3/17: 95%->100
- 473: 6/3/17: 0%->100
- 475: 6/3/17: 0%->25; 5/6/17: 25%->90; 14/9/17: 90%->100
- 476: 5/6/17: 0%->100
- 477: 6/3/17: 0%->100
- 478: 5/6/17: 0%->100. No work identified for CT6.
- 479: 2/3/16: FCD: 03/16->06/16. ES in SP-160109; 0->80%; 9/6/16: 80%->100
- 480: 1/4/15:TR number added; June2015: Compl:0%->20; 07/09/15: 20%->90; 7/12/15: 90%->100
- 481: 2/3/16: FCD: 03/16->06/16. ES in SP-160109; 0->80%; 9/6/16: 80%->100
- 482: 28/7/16: 23.282 added; 19/9/16: 0%->10; 1/12/16: 10%->95; 3/3/17: 95%->100

| ID | WBS | Task | Type | Duration | Start | Finish | Complete | Remaining | Total slack | Constraint | Resources | Work | Actual work | Acronym | PCG approved | WI rapporteur name | WI rapporteur e-mail | Release | TSG approved | Status Report |
| --- | --- | --- | --- | --- | --- | --- | --- | --- | --- | --- | --- | --- | --- | --- | --- | --- | --- | --- | --- | --- |
| 483 | 226.6.4 | **Stage 3 of MCData** |  | 140d? | 2016-12-01 A | 2017-06-14 A | 100% |  |  |  | ct | 4560h | 4560h | MCImp-MCDATA-CT | 38 | HASON, Baruh | baruh.hason@motorolasolutions.com | Rel-14 | 74 |  |
| 484 | 226.6.4.1 | CT1 aspects of MCData |  | 140d? | 2016-12-01 A | 2017-06-14 A | 100% |  |  | finish no earlier than 2017-06-14 | C1 | 1120h | 1120h | MCImp-MCDATA-CT | 38 | HASON, Baruh | baruh.hason@motorolasolutions.com | Rel-14 | 74 |  |
| 485 | 226.6.4.2 | CT3 aspects of MCData |  | 75d? | 2016-12-01 A | 2017-03-15 A | 100% |  |  | finish no earlier than 2017-03-15 | C3 | 600h | 600h | MCImp-MCDATA-CT | 38 | HASON, Baruh | baruh.hason@motorolasolutions.com | Rel-14 | 74 |  |
| 486 | 226.6.4.3 | CT4 aspects of MCData |  | 75d? | 2016-12-01 A | 2017-03-15 A | 100% |  |  | finish no earlier than 2017-03-15 | C4 | 600h | 600h | MCImp-MCDATA-CT | 38 | HASON, Baruh | baruh.hason@motorolasolutions.com | Rel-14 | 74 |  |
| 487 | 226.6.4.4 | CT6 aspects of MCData |  | 140d? | 2016-12-01 A | 2017-06-14 A | 100% |  |  | finish no earlier than 2017-06-14 | C6 | 1120h | 1120h | MCImp-MCDATA-CT | 38 | HASON, Baruh | baruh.hason@motorolasolutions.com | Rel-14 | 74 |  |
| 488 | 226.7 | Security of the Mission Critical Service |  | 194d? | 2016-09-19 A | 2017-06-15 A | 100% |  |  | finish no earlier than 2017-06-15 | S3 | 1552h | 1552h | MCSec | 37 | Haigh, Peter, CESG | peter.haigh@cesg.gsi.gov.uk | Rel-14 | 73 |  |
| 489 | 227 | **Protocol enhancements for MCPTT over LTE** |  | 129d? | 2016-09-16 A | 2017-03-15 A | 100% |  |  |  | ct | 5160h | 5160h | MCPTTProtoc1 | 37 | Ricky Kaura | ricky.kaura@samsung.com | Rel-14 | 73 |  |
| 490 | 227.1 | CT1 aspects of MCPTTProtoc1 |  | 129d? | 2016-09-16 A | 2017-03-15 A | 100% |  |  | finish no earlier than 2017-03-15 | C1 | 1032h | 1032h | MCPTTProtoc1 | 37 | Ricky Kaura | ricky.kaura@samsung.com | Rel-14 | 73 |  |
| 491 | 227.2 | CT3 aspects of MCPTTProtoc1 |  | 129d? | 2016-09-16 A | 2017-03-15 A | 100% |  |  | finish no earlier than 2017-03-15 | C3 | 1032h | 1032h | MCPTTProtoc1 | 37 | Ricky Kaura | ricky.kaura@samsung.com | Rel-14 | 73 |  |
| 492 | 227.3 | CT4 aspects of MCPTTProtoc1 |  | 129d? | 2016-09-16 A | 2017-03-15 A | 100% |  |  | finish no earlier than 2017-03-15 | C4 | 1032h | 1032h | MCPTTProtoc1 | 37 | Ricky Kaura | ricky.kaura@samsung.com | Rel-14 | 73 |  |
| 493 | 227.4 | CT6 aspects of MCPTTProtoc1 |  | 129d? | 2016-09-16 A | 2017-03-15 A | 100% |  |  | finish no earlier than 2017-03-15 | C6 | 1032h | 1032h | MCPTTProtoc1 | 37 | Ricky Kaura | ricky.kaura@samsung.com | Rel-14 | 73 |  |
| 494 | 228 | Release 14 on V2X | milestone | 0d? | 2016-06-09 A | 2016-06-09 A | 100% |  |  | finish no earlier than 2016-06-09 |  |  |  |  |  |  |  | Rel-14 |  |  |
| 495 | 229 | **LTE support for V2X services** |  | 876d? | 2015-02-09 A | 2018-06-15 | 93% | 57.54d? | 4561d |  |  | 20176h | 18918.4h | V2XLTE | 35 |  |  | Rel-14 | 68 |  |
| 496 | 229.1 | Stage 1 for LTE support for V2X services |  | 137d? | 2015-09-09 A | 2016-03-17 A | 100% |  |  | finish no earlier than 2016-03-17 | S1 | 1096h | 1096h | V2XLTE | 35 |  |  | Rel-14 | 68 |  |
| 497 | 229.2 | Architecture enhancements for LTE support of V2X services |  | 137d? | 2016-06-09 A | 2016-12-15 A | 100% |  |  | finish no earlier than 2016-12-15 | S2 | 1096h | 1096h | V2XARC | 37 | LG Electronics, LaeYoung Kim | laeyoung.kim@lge.com | Rel-14 | 72 |  |
| 498 | 229.3 | Security aspect of LTE support of V2X services |  | 141d? | 2016-12-01 A | 2017-06-15 A | 100% |  |  | finish no earlier than 2017-06-15 | S3 | 1128h | 1128h | V2XLTE-Sec | 38 | Huawei, Marcus Wong | mwong@huawei.com | Rel-14 | 74 |  |
| 499 | 229.4 | **RAN aspects of LTE-based V2X Services** |  | 524d? | 2016-06-15 A | 2018-06-15 | 80% | 104.53d? | 4561d |  |  | 6304h | 5046.4h | LTE_V2X | 37 | LG Electronics |  | Rel-14 | 72 |  |
| 500 | 229.4.1 | Core part: LTE-based V2X Services |  | 197d? | 2016-06-15 A | 2017-03-15 A | 100% |  |  | finish no earlier than 2017-03-15 | R1 | 1576h | 1576h | LTE_V2X-Core | 37 | LG Electronics |  | Rel-14 | 72 | RP-170237 |
| 501 | 229.4.2 | Perf. part: LTE-based V2X Services |  | 329d? | 2016-06-15 A | 2017-09-15 A | 100% |  |  | finish no earlier than 2017-09-15 | R4 | 2632h | 2632h | LTE_V2X-Perf | 37 | LG Electronics |  | Rel-14 | 72 |  |
| 502 | 229.4.3 | UE Conformance Test Aspects - Support for LTE-based V2X Services |  | 262d? | 2017-06-15 A | 2018-06-15 | 40% | 157.2d? | 4561d | finish no earlier than 2018-06-15 | R5 | 2096h | 838.4h | LTE_V2X-UEConTest | 39 | Huawei |  | Rel-14 | 76 |  |
| 503 | 229.5 | **CT aspects of V2X Services** |  | 129d? | 2016-09-16 A | 2017-03-15 A | 100% |  |  |  | ct | 5160h | 5160h | V2X-CT | 37 | Taehun Kim | taehun78.kim@lge.com | Rel-14 | 73 |  |
| 504 | 229.5.1 | CT1 aspects of V2X Services |  | 129d? | 2016-09-16 A | 2017-03-15 A | 100% |  |  | finish no earlier than 2017-03-15 | C1 | 1032h | 1032h | V2X-CT | 37 | Taehun Kim | taehun78.kim@lge.com | Rel-14 | 73 |  |
| 505 | 229.5.2 | CT3 aspects of V2X Services |  | 129d? | 2016-09-16 A | 2017-03-15 A | 100% |  |  | finish no earlier than 2017-03-15 | C3 | 1032h | 1032h | V2X-CT | 37 | Taehun Kim | taehun78.kim@lge.com | Rel-14 | 73 |  |
| 506 | 229.5.3 | CT4 aspects of V2X Services |  | 129d? | 2016-09-16 A | 2017-03-15 A | 100% |  |  | finish no earlier than 2017-03-15 | C4 | 1032h | 1032h | V2X-CT | 37 | Taehun Kim | taehun78.kim@lge.com | Rel-14 | 73 |  |
| 507 | 229.5.4 | CT6 aspects of V2X Services |  | 129d? | 2016-09-16 A | 2017-03-15 A | 100% |  |  | finish no earlier than 2017-03-15 | C6 | 1032h | 1032h | V2X-CT | 37 | Taehun Kim | taehun78.kim@lge.com | Rel-14 | 73 |  |

Notes:
- 483: Impacted TSs and TRs: 24.582, 24.282
- 484: 6/3/17: 0%->10; 5/6/17: 10%->65; 5/6/17: 65%->90; 14/9/17: 90%->96; 15/12/17: 96%->100 / Impacted TSs and TRs: 24.381, 24.382, 24.383, 24.384
- 485: 5/6/17: 0%->100 / Impacted TSs and TRs: 29.165, 29.213, 29.214
- 486: 6/3/17: 0%->100 / Impacted TSs and TRs: 23.003, 23.335, 29.283
- 487: No work identified. / Impacted TSs and TRs: 31.102, 31.103
- 488: 6/10/16: 33.180 added; 1/12/16: 0%->25; 6/3/17: 25%->60; 7/6/17: 60%->85; 11/9/17: 85%->100 / Impacted TSs and TRs: 33.180
- 489: This Feature is a stage-3 only feature that fixes/enhances MCPTT protocol level (not visible from stage2). Not to be confused with Rel-14 MCPTT Stage 3.
- 490: 6/3/17: 5%->100 / Impacted TSs and TRs: 24.229, 24.379, 24.380, 24.381, 24.382, 24.383, 24.384, 24.980
- 491: 2/12/16: 0%->20; 6/3/17: 20%->100 / Impacted TSs and TRs: 29.165, 29.212, 29.213, 29.214
- 492: 6/3/17: 0%->100 / Impacted TSs and TRs: 23.003, 23.008, 29.283
- 493: 5/6/17: 0%->100. No more work identified. / Impacted TSs and TRs: 31.102
- 494: -
- 495: 7/12/15: 0%->5; 28/1/16: 22.185 added; 2/3/16: 5%->90; 9/6/16: 90%->100 / Impacted TSs and TRs: 22.278; 22.185
- 496: 7/12/15: 0%->5; 28/1/16: 22.185 added; 2/3/16: 5%->90; 9/6/16: 90%->100 / Impacted TSs and TRs: 22.278; 22.185
- 497: 28/7/16: 23.285 added; 19/9/16: 0%->85; 1/12/16: FCD:09/16->12/16; 1/12/16: 85%->100 / Impacted TSs and TRs: 23.285
- 498: 6/3/17: 0%->75; 7/6/17: 75%->100 / Impacted TSs and TRs: 33.185
- 499: follow-up WI of REL-14 SI FS_LTE_V2X
- 500: follow-up WI of REL-14 SI FS_LTE_V2X26/9/16: Compl:0%->15%26/9/16: WID: RP-161298->RP-161894; 6/10/16: 36.786 added; 6/10/16: added; 20/12/16: Compl:15%->75% 21/3/17: Compl:75%->100%... / Impacted TSs and TRs: 36.786;
- 501: ; 26/9/16: WID: RP-161298->RP-161894; 20/12/16: WID: RP-161894->RP-162519; 20/12/16: Stat Rep: ->RP-162519; 19/6/17: Compl:0%->75%; 19/9/17: Compl:75%->100%
- 502: ; 19/9/17: Compl:0%->20%; 8/1/18: Compl:20%->40%; ...
- 504: 6/10/16: 24.385 added; 6/10/16: 24.386 added; 2/12/16: 0%->65; 6/3/17: 65%->100 / Impacted TSs and TRs: 23.122, 24.301, 24.334; 24.385; 24.386
- 505: 6/10/16: 29.387 added; 2/12/16: 0%->40; 6/3/17: 40%->60; 5/6/17: 60%->100 / Impacted TSs and TRs: 29.212, 29.468; 29.387
- 506: 6/10/16: 29.388 added; 6/10/16: 29.389 added; 2/12/16: 0%->80; 6/3/17: 80%->100 / Impacted TSs and TRs: 23.003, 23.007, 23.008, 29.272; 29.388; 29.389
- 507: 7/3/17: 0%->100 / Impacted TSs and TRs: 31.102, 31.111

| ID | WBS | Task | Type | Duration | Start | Finish | Complete | Remaining | Total slack | Constraint | Resources | Work | Actual work | Acronym | PCG approved | WI rapporteur name | WI rapporteur e-mail | Release | TSG approved | Status Report |
| --- | --- | --- | --- | --- | --- | --- | --- | --- | --- | --- | --- | --- | --- | --- | --- | --- | --- | --- | --- | --- |
| 508 | 229.6 | **Study on LTE support for V2X services** |  | 355d? | 2015-02-09 A | 2016-06-17 A | 100% |  |  |  |  | 5392h | 5392h | FS_V2XLTE | 34 | Ki-Dong Lee (LG electronics) | kidong.lee@lge.com | Rel-14 | 67 |  |
| 509 | 229.6.1 | Study on Stage 1 of LTE support for V2X services |  | 1d? | 2015-02-09 A | 2015-02-09 A | 100% |  |  | start no earlier than 2015-09-07 | S1 | 8h | 8h | FS_V2XLTE_S1 | 34 | Ki-Dong Lee (LG electronics) | kidong.lee@lge.com | Rel-14 | 67 |  |
| 510 | 229.6.2 | Study on Stage 2 of LTE support for V2X services |  | 205d? | 2015-09-07 A | 2016-06-17 A | 100% |  |  | finish no earlier than 2016-06-17 | S2 | 1640h | 1640h | FS_V2XARC | 36 | LG Electronics, LaeYoung Kim | laeyoung.kim@lge.com | Rel-14 | 70 |  |
| 511 | 229.6.3 | Study on Security of LTE support for V2X services |  | 205d? | 2015-09-07 A | 2016-06-17 A | 100% |  |  | finish no earlier than 2016-06-17 | S3 | 1640h | 1640h | FS_V2XARC_S3 | 36 |  |  | Rel-14 | 70 |  |
| 512 | 229.6.4 | RAN1 Study on LTE-based V2X Services |  | 263d? | 2015-06-15 A | 2016-06-15 A | 100% |  |  | finish no earlier than 2016-09-15 | R1 | 2104h | 2104h | FS_LTE_V2X | 35 | LG Electronics |  | Rel-14 | 68 |  |
| 513 | 230 | **Support for V2V services based on LTE sidelink** |  | 655d? | 2015-12-15 A | 2018-06-15 | 87% | 85.52d? | 4561d |  |  | 8400h | 7303.2h | LTE_SL_V2V | 36 | LG Electronics |  | Rel-14 | 70 |  |
| 514 | 230.1 | Core part: Support for V2V services based on LTE sidelink |  | 199d? | 2015-12-15 A | 2016-09-15 A | 100% |  |  | finish no earlier than 2016-09-15 | R1 | 1592h | 1592h | LTE_SL_V2V-Core | 36 | LG Electronics |  | Rel-14 | 70 |  |
| 515 | 230.2 | Perf. part: Support for V2V services based on LTE sidelink |  | 394d? | 2015-12-15 A | 2017-06-15 A | 100% |  |  | finish no earlier than 2017-06-15 | R4 | 3152h | 3152h | LTE_SL_V2V-Perf | 36 | LG Electronics |  | Rel-14 | 70 |  |
| 516 | 230.3 | UE Conformance Test Aspects - Support for V2V services based on LTE sidelink |  | 457d? | 2016-09-15 A | 2018-06-15 | 70% | 137.1d? | 4561d | finish no earlier than 2018-06-15 | R5 | 3656h | 2559.2h | LTE_SL_V2V-UEConTest | 37 | Huawei |  | Rel-14 | 73 |  |
| 517 | 231 | Release 14 on CIoT | milestone | 0d? | 2016-06-09 A | 2016-06-09 A | 100% |  |  | finish no earlier than 2016-06-09 |  |  |  |  |  |  |  | Rel-14 |  |  |
| 518 | 232 | **Non-IP for Cellular Internet of Things (CIoT) for 2G/3G-GPRS(EC-EGPRS)** |  | 143d? | 2016-03-02 A | 2016-09-15 A | 100% |  |  |  |  | 4040h | 4040h | NonIP_GPRS | 36 |  |  | Rel-14 | 71 |  |
| 519 | 232.1 | Non-IP for Cellular IoT for EC-EGPRS |  | 76d? | 2016-03-02 A | 2016-06-15 A | 100% |  |  | start no earlier than 2016-03-02 | S2 | 608h | 608h | NonIP_GPRS | 36 | Hans Ronneke, Ericsson | hans . Ronneke (a) ericsson . Com | Rel-14 | 71 |  |
| 520 | 232.2 | **CT aspects for Non-IP for Cellular Internet of Things for EC-EGPRS** |  | 143d? | 2016-03-02 A | 2016-09-15 A | 100% |  |  |  |  | 3432h | 3432h | NonIP_GPRS-CT | 36 | Orange, Youssef CHADLI | youssef.chadli@orange.com | Rel-14 | 71 |  |
| 521 | 232.2.1 | CT1 aspects for Non-IP for Cellular Internet of Things for EC-EGPRS |  | 143d? | 2016-03-02 A | 2016-09-15 A | 100% |  |  | finish no earlier than 2016-09-15 | C1 | 1144h | 1144h | NonIP_GPRS-CT | 36 | Orange, Youssef CHADLI | youssef.chadli@orange.com | Rel-14 | 71 |  |
| 522 | 232.2.2 | CT3 aspects for Non-IP for Cellular Internet of Things for EC-EGPRS |  | 143d? | 2016-03-02 A | 2016-09-15 A | 100% |  |  | finish no earlier than 2016-09-15 | C3 | 1144h | 1144h | NonIP_GPRS-CT | 37 | Orange, Youssef CHADLI | youssef.chadli@orange.com | Rel-14 | 72 |  |
| 523 | 232.2.3 | CT4 aspects for Non-IP for Cellular Internet of Things for EC-EGPRS |  | 143d? | 2016-03-02 A | 2016-09-15 A | 100% |  |  | finish no earlier than 2016-09-15 | C4 | 1144h | 1144h | NonIP_GPRS-CT | 36 | Orange, Youssef CHADLI | youssef.chadli@orange.com | Rel-14 | 71 |  |
| 524 | 233 | **Further enhanced MTC for LTE** |  | 524d? | 2016-06-15 A | 2018-06-15 | 78% | 113.18d? | 4561d |  |  | 6824h | 5350.08h | LTE_feMTC | 37 | Ericsson |  | Rel-14 | 72 |  |
| 525 | 233.1 | Core part: Further enhanced MTC for LTE |  | 263d? | 2016-06-15 A | 2017-06-15 A | 100% |  |  | finish no earlier than 2017-06-15 | R1 | 2104h | 2104h | LTE_feMTC-Core | 37 | Ericsson |  | Rel-14 | 72 | RP-171441 |
| 526 | 233.2 | Perf. part: Further enhanced MTC for LTE |  | 394d? | 2016-06-15 A | 2017-12-15 A | 100% |  |  | finish no earlier than 2017-12-15 | R4 | 3152h | 3152h | LTE_feMTC-Perf | 37 | Ericsson |  | Rel-14 | 72 |  |
| 527 | 233.3 | UE Conformance Test Aspects - Further enhanced MTC for LTE |  | 196d? | 2017-09-15 A | 2018-06-15 | 6% | 184.24d? | 4561d | finish no earlier than 2018-06-15 | R5 | 1568h | 94.08h | LTE_feMTC-UEConTest | 39 | Ericsson |  | Rel-14 | 77 |  |
| 528 | 234 | **Enhancements of NB-IoT** |  | 654d? | 2016-06-15 A | 2018-12-15 | 68% | 206.04d? | 4431d |  |  | 7864h | 5386.4h | NB_IOTenh | 37 | Huawei |  | Rel-14 | 72 |  |
| 529 | 234.1 | Core part: Enhancements of NB-IoT |  | 263d? | 2016-06-15 A | 2017-06-15 A | 100% |  |  | finish no earlier than 2017-06-15 | R1 | 2104h | 2104h | NB_IOTenh-Core | 37 | Huawei |  | Rel-14 | 72 | RP-171061 |
| 530 | 234.2 | Perf. part: Enhancements of NB-IoT |  | 394d? | 2016-06-15 A | 2017-12-15 A | 100% |  |  | finish no earlier than 2017-12-15 | R4 | 3152h | 3152h | NB_IOTenh-Perf | 37 | Huawei |  | Rel-14 | 72 |  |
| 531 | 234.3 | UE Conformance Test Aspects - Enhancements of NB-IoT |  | 326d? | 2017-09-15 A | 2018-12-15 | 5% | 309.7d? | 4431d | finish no earlier than 2018-12-15 | R5 | 2608h | 130.4h | NB_IOTenh-UEConTest | 39 | Huawei |  | Rel-14 | 77 |  |
| 532 | 235 | AT Commands for CIoT |  | 65d? | 2016-09-16 A | 2016-12-15 A | 100% |  |  | finish no earlier than 2016-12-15 | C1 | 520h | 520h | AT_CIoT | 37 | John-Luc Bakker |  | Rel-14 | 73 |  |

Notes:
- 508: 1/4/15:TR number added; June2015: Compl:25%->50; 07/09/15: 50%->75 / Impacted TSs and TRs: New TR 22.885
- 509: 1/4/15:TR number added; June2015: Compl:25%->50; 07/09/15: 50%->75; 7/12/15: 75%->100 / Impacted TSs and TRs: New TR 22.885
- 510: 11/12/15: WID:SP-150625->SP-150743; 7/3/16: 10%->22; 7/3/16: WID:SP-150743->SP-150852; 9/6/16: 22%->80; 19/9/16: 80%->100 / Impacted TSs and TRs: TR 23.785
- 511: Introduced at 100% completion, as per SA3 report to SA#76 / Impacted TSs and TRs: TR 33.885
- 512: 29/09/15: Compl:0%->5% 29/09/15: Stat Rep: -->RP-151311 ; 28/1/16: 33.885 added;22/3/16: Compl:35%->50%22/3/16: CD:Wed 15/06/16->Thu 15/09/1622/3/16: WID: RP-15; / Impacted TSs and TRs: 33.885
- 514: 22/3/16: Compl:0%->15%22/3/16: WID: RP-152293->RP-1606491/7/16: Compl:15%->60%1/7/16: WID: RP-160649->RP-161272; 28/7/16: 36.785 added; 26/9/16: Compl:60%->100%; 26/9/16: WID: RP-161272->RP-161603 / Impacted TSs and TRs: 36.785
- 515: 22/3/16: WID: RP-152293->RP-1606491/7/16: WID: RP-160649->RP-16127226/9/16: WID: RP-161272->RP-161603; 20/12/16: Compl:0%->50% 21/3/17: Compl:50%->80% 21/3/17: CD:Wed 15/03/17->Thu 15/06/1719/6/17: Compl:80%->100%
- 516: ; 20/12/16: Compl:0%->5% 21/3/17: Compl:5%->15%19/9/17: Compl:15%-...; 8/1/18: Com...
- 517: -
- 519: 9/6/16: 0%->50; 19/9/16: 50%->100 / Impacted TSs and TRs: 23.060, 23.682, 23.401?
- 520: 11/6/16: WID:CP-160161->CP-160293
- 521: 11/6/16: 0%->50; 11/6/16: WID:CP-160161->CP-160293; 16/9/16: 50%->65; 2/12/16: 65%->100 / Impacted TSs and TRs: 24.008
- 522: 11/6/16: WID:CP-160161->CP-160293; 13/6/16: 0%->65; 20/9/16: 0%->100 / Impacted TSs and TRs: 29.060, 29.274, 29.002, 29.303, 23.008, 29.128, 29.272, 23.007
- 523: 11/6/16: WID:CP-160161->CP-160293; 13/6/16: 0%->65; 2/12/16: 65%->100 / Impacted TSs and TRs: 29.060, 29.274, 29.002, 29.303, 23.008, 29.128, 29.272, 23.007
- 525: 26/9/16: Compl:0%->12%26/9/16: WID: RP-161321->RP-161464; 20/12/16: Compl:12%->70%; 20/12/16: WID: RP-161464->RP-16252021/3/17: Compl:70%->95% ; 21/3/17: CD...19/6/17: Compl:95%->100%...
- 526: ; 26/9/16: WID: RP-161321->RP-161464; 20/12/16: WID: RP-161464->RP-162520; 20/12/16: Stat Rep: ->RP-16252021/3/17: CD:Fri 15/09/17->Fri 15/12/1721/3/17...; 19/6/17: Compl:0%->35%19/9/17: Compl:35%->60%; 8/1/18: Compl:60%->100%
- 527: ; 8/1/18: Compl:0%->6%
- 529: 26/9/16: Compl:0%->13%26/9/16: WID: RP-161324->RP-161901; 20/12/16: Compl:13%->70%; 21/3/17: Compl:70%->95%; 21/3/17: CD:Wed 15/03/17->Thu 15/06/1719/6/17: Compl:95%->100%...
- 530: 26/9/16: WID: RP-161324->RP-16190121/3/17: CD:Fri 15/09/17->Fri 15/12/17; 19/6/17: Compl:0%->50%; 19/6/17: WID: RP-161901->RP-171060; 19/9/17: Compl:50%->60%; 8/1/18: Compl:60%->100%
- 531: ; 8/1/18: Compl:0%->5%
- 532: 2/12/16: 10%->95; 6/3/17: 95%->100

| ID | WBS | Task | Duration | Start | Finish | Complete | Remaining | Total slack | Constraint | Resources | Work | Actual work | Acronym | PCG approved | WI rapporteur name | WI rapporteur e-mail | Release | TSG approved | Status Report |
| --- | --- | --- | --- | --- | --- | --- | --- | --- | --- | --- | --- | --- | --- | --- | --- | --- | --- | --- | --- |
| 533 | 236 | **Extended architecture support for Cellular Internet of Things** | 194d? | 2016-06-17 A | 2017-03-14 A | 100% |  |  |  |  | 3360h | 3360h | CIoT_Ext | 37 | Intel : Puneet Jain | puneet.jain@intel.com | Rel-14 | 73 |  |
| 534 | 236.1 | Study on extended architecture support for Cellular Internet of Things | 131d? | 2016-06-17 A | 2016-12-15 A | 100% |  |  | finish no earlier than 2016-12-15 | S2 | 1048h | 1048h | FS_CIoT_Ext | 37 | Intel : Puneet Jain | puneet.jain@intel.com | Rel-14 | 72 |  |
| 535 | 236.2 | Stage 2 of Extended architecture support for Cellular Internet of Things | 67d? | 2016-09-15 A | 2016-12-16 A | 100% |  |  | finish no earlier than 2016-12-16 | S2 | 536h | 536h | CIoT_Ext | 37 | Intel : Puneet Jain | puneet.jain@intel.com | Rel-14 | 73 |  |
| 536 | 236.3 | **Stage 3 of extended architecture enhancements for Cellular Internet of Things** | 74d? | 2016-12-01 A | 2017-03-14 A | 100% |  |  |  | ct | 1776h | 1776h | CIoT_Ext-CT | 38 | Intel, Vivek Gupta | vivek.g.gupta@intel.com | Rel-14 | 74 |  |
| 537 | 236.3.1 | CT1 aspects of extended architecture enhancements for Cellular Internet of Things | 74d? | 2016-12-01 A | 2017-03-14 A | 100% |  |  | finish no earlier than 2017-03-14 | C1 | 592h | 592h | CIoT_Ext-CT | 38 | Intel, Vivek Gupta | vivek.g.gupta@intel.com | Rel-14 | 74 |  |
| 538 | 236.3.2 | CT4 aspects of extended architecture enhancements for Cellular Internet of Things | 74d? | 2016-12-01 A | 2017-03-14 A | 100% |  |  | finish no earlier than 2017-03-14 | C4 | 592h | 592h | CIoT_Ext-CT | 38 | Intel, Vivek Gupta | vivek.g.gupta@intel.com | Rel-14 | 74 |  |
| 539 | 237 | **Radio Interface Enhancements for Extended Coverage GSM for support of Cellular Internet of Things** | 196d? | 2016-09-15 A | 2017-06-15 A | 100% |  |  |  | R6 | 4704h | 4704h | CIoT_EC_GSM_radio_enh | 37 | Nokia |  | Rel-14 | 73 |  |
| 540 | 237.1 | Core part: Radio Interface Enhancements for Extended Coverage GSM for support of Cellular Internet of Things | 196d? | 2016-09-15 A | 2017-06-15 A | 100% |  |  | finish no earlier than 2017-06-15 | R6 | 1568h | 1568h | CIoT_EC_GSM_radio_enh-Core | 37 | Nokia |  | Rel-14 | 73 | RP-171321 |
| 541 | 237.2 | Perf. part: Radio Interface Enhancements for Extended Coverage GSM for support of Cellular Internet of Things | 196d? | 2016-09-15 A | 2017-06-15 A | 100% |  |  | finish no earlier than 2017-06-15 | R6 | 1568h | 1568h | CIoT_EC_GSM_radio_enh-Perf | 37 | Nokia |  | Rel-14 | 73 |  |
| 542 | 238 | **New band support for Rel-14 Narrowband Internet of Things (NB-IOT)** | 262d? | 2016-09-15 A | 2017-09-15 | 99% | 0d? | 0d |  | R4 | 6296h | 5229.66h | NB_IOT_R14_bands | 37 | Ericsson |  | Rel-14 | 73 |  |
| 543 | 238.1 | Core part: New band support for Rel-14 Narrowband Internet of Things (NB-IOT) | 196d? | 2016-09-15 A | 2017-06-15 A | 100% |  |  | finish no earlier than 2017-06-15 | R4 | 1568h | 1568h | NB_IOT_R14_bands-Core | 37 | Ericsson |  | Rel-14 | 73 | RP-170970 |
| 544 | 238.2 | Perf. part: New band support for Rel-14 Narrowband Internet of Things (NB-IOT) | 196d? | 2016-09-15 A | 2017-06-15 A | 100% |  |  | finish no earlier than 2017-06-15 | R4 | 1568h | 1568h | NB_IOT_R14_bands-Perf | 37 | Ericsson |  | Rel-14 | 73 |  |
| 545 | 238.3 | UE Conformance Test Aspects - New band support for Rel-14 NB-IoT | 133d? | 2017-03-15 A | 2017-09-15 A | 100% |  |  | finish no earlier than 2017-12-15 | R5 | 1064h | 1064h | NB_IOT_R14_bands-UEConTest | 38 | Ericsson |  | Rel-14 | 75 |  |
| 546 | 239 | **Enhancements of Dedicated Core Networks selection mechanism** | 588d? | 2015-09-17 A | 2017-12-15 | 99% | 0d? | 0d |  |  | 7808h | 6232h | eDecor | 35 | Roland Gustafsson | Roland.Gustafsson@ericsson.com | Rel-14 | 69 | SP-170537 |
| 547 | 239.1 | Study on Enhancements of Dedicated Core Networks selection mechanism | 132d? | 2015-09-17 A | 2016-03-18 A | 100% |  |  | finish no earlier than 2016-03-18 | S2 | 1056h | 1056h | FS_eDecor | 35 | Roland Gustafsson | Roland.Gustafsson@ericsson.com | Rel-14 | 69 |  |
| 548 | 239.2 | Enhancements of Dedicated Core Networks selection mechanism | 72d? | 2016-06-09 A | 2016-09-15 A | 100% |  |  | finish no earlier than 2016-09-15 | S2 | 576h | 576h | eDecor | 37 | Roland Gustafsson | Roland.Gustafsson@ericsson.com | Rel-14 | 72 |  |
| 549 | 239.3 | **CT aspects of eDecor** | 65d? | 2016-09-16 A | 2016-12-15 A | 100% |  |  |  | ct | 2080h | 2080h | eDecor-CT | 37 | Mikael Wass | Mikael.wass@ericsson.com | Rel-14 | 73 |  |
| 550 | 239.3.1 | CT1 aspects of eDecor | 65d? | 2016-09-16 A | 2016-12-15 A | 100% |  |  | finish no earlier than 2016-12-15 | C1 | 520h | 520h | eDecor-CT | 37 | Mikael Wass | Mikael.wass@ericsson.com | Rel-14 | 73 |  |
| 551 | 239.3.2 | CT4 aspects of eDecor | 65d? | 2016-09-16 A | 2016-12-15 A | 100% |  |  | finish no earlier than 2016-12-15 | C4 | 520h | 520h | eDecor-CT | 37 | Mikael Wass | Mikael.wass@ericsson.com | Rel-14 | 73 |  |
| 552 | 239.3.3 | CT6 aspects of eDecor | 65d? | 2016-09-16 A | 2016-12-15 A | 100% |  |  | finish no earlier than 2016-12-15 | C6 | 520h | 520h | eDecor-CT | 37 | Mikael Wass | Mikael.wass@ericsson.com | Rel-14 | 73 |  |
| 553 | 239.4 | **RAN aspects of eDECOR for UMTS and LTE** | 262d? | 2016-12-15 A | 2017-12-15 | 99% | 0d? | 0d |  | R3 | 3672h | 2096h | eDECOR-UTRA_LTE | 38 | Ericsson |  | Rel-14 | 74 |  |
| 554 | 239.4.1 | Core part: RAN aspects of eDECOR for UMTS and LTE | 65d? | 2016-12-15 A | 2017-03-15 A | 100% |  |  | finish no earlier than 2017-03-15 | R3 | 520h | 520h | eDECOR-UTRA_LTE-Core | 38 | Ericsson |  | Rel-14 | 74 | RP-170547 |
| 555 | 239.4.2 | UE Conformance Test Aspects - Enhancements of Dedicated Core Networks for UTRA and LTE | 132d? | 2017-06-15 A | 2017-12-15 A | 100% |  |  | finish no earlier than 2017-12-15 | R5 | 1056h | 1056h | eDECOR-UTRA_LTE-UEConTest | 39 | Ericsson |  | Rel-14 | 76 |  |
| 556 | 239.5 | Deleted - GSM aspects of eDECOR | 53d? | 2017-04-04 A | 2017-06-15 A | 100% |  |  | start no earlier than 2017-04-04 | R6 | 424h | 424h | eDecor | 39 | Ericsson |  | Rel-14 | 76 |  |

Notes:
- 533: Impacted TSs and TRs: 23.401, 23.682, 23.060
- 534: 28/7/16: 23.730 added; 19/9/16: 0%->70; 1/12/16: FCD:03/17->12/16; 1/12/16: 70%->100 / Impacted TSs and TRs: 23.730
- 535: 1/12/16: 0%->100; 1/12/16: WID:SP-160732->SP-160830 / Impacted TSs and TRs: 23.401, 23.682, 23.060, 23.271
- 536: 21/3/17: 24.250 added; / Impacted TSs and TRs: 24.250
- 537: 6/3/17: 0%->50; 5/6/17: 50%->100 / Impacted TSs and TRs: 24.301, 24.008
- 538: 6/3/17: 0%->90; 5/6/17: 90%->100 / Impacted TSs and TRs: 23.008, 29.272, 29.002, 29.336, 29.128, 29.171, 29.172, 29.173
- 540: ; 20/12/16: Compl:0%->50% 21/3/17: Compl:50%->80%...19/6/17: Compl:80%->100%...
- 541: ; 20/12/16: Compl:0%->20% ; 21/3/17: Compl:20%->80%; ...; 19/6/17: Compl:80%->100%
- 543: ; 20/12/16: Compl:0%->99% 21/3/17: CD:Wed 15/03/17->Thu 15/06/17; ;...19/6/17: Compl:99%->100%19/6/17: Stat Rep: ->RP-170970
- 544: ; 20/12/16: Compl:0%->99% 21/3/17: Compl:99%->70% ...; 19/6/17: Compl:70%->100%
- 545: tested: REL-14 NB_IOT_R14_bands-Core (which got an exception at RAN #75 to still complete in REL-14 by RAN #76);...; ;...
- 546: 7/12/15: 0%->70; 7/3/16: 70%->80; 9/6/16: 80%->95 / Impacted TSs and TRs: 23.711
- 547: 7/12/15: 0%->70; 7/3/16: 70%->80; 9/6/16: 80%->95; 19/9/16: 95%->100 / Impacted TSs and TRs: 23.711
- 548: 19/9/16: 70%->100 / Impacted TSs and TRs: 23.401, 23.060, 23.251
- 550: 2/12/16: 0%->80; 6/3/17: 80%->95; 5/6/17: 95%->100 / Impacted TSs and TRs: 24.301, 24.008, 24.368
- 551: 2/12/16: 0%->10; 6/3/17: 10%->100 / Impacted TSs and TRs: 29.303, 23.003, 23.008
- 552: 14/12/16: 0%->15; 7/3/17: 15%->85; 5/6/17: 85%->100 / Impacted TSs and TRs: 31.102, 31.111
- 554: 21/3/17: Compl:0%->100%21/3/17: Stat Rep: ->RP-170547
- 555: ; 19/9/17: Compl:0%->50%; ...; 8/1/18: Compl:50%->100%
- 556: Verbal addition by Paolo U. 21/09/17: verbal deletion by Paolo / Impacted TSs and TRs: 44.060, 44.018, 48.018

| ID | WBS | Task | Type | Duration | Start | Finish | Complete | Constraint | Resources | Work | Actual work | Acronym | PCG approved | WI rapporteur name | Release | TSG approved | Impacted TSs and TRs | WI rapporteur e-mail | Status Report |
| --- | --- | --- | --- | --- | --- | --- | --- | --- | --- | --- | --- | --- | --- | --- | --- | --- | --- | --- | --- |
| 557 | 240 | **Addition of band 25 and 26 to LTE MTC cat.0** |  | 65d? | 2016-12-15 A | 2017-03-15 A | 100% |  | R4 | 1040h | 1040h | LC_MTC_LTE_cat0_B25_B26 | 38 | Sprint | Rel-14 | 74 |  |  |  |
| 558 | 240.1 | Core part: Addition of band 25 and 26 to LTE MTC cat.0 |  | 65d? | 2016-12-15 A | 2017-03-15 A | 100% | finish no earlier than 2017-03-15 | R4 | 520h | 520h | LC_MTC_LTE_cat0_B25_B26-Core | 38 | Sprint | Rel-14 | 74 |  |  |  |
| 559 | 241 | Addition of bands 25 and 40 to LTE MTC cat.1 |  | 65d? | 2016-12-15 A | 2017-03-15 A | 100% | finish no earlier than 2017-03-15 | R4 | 520h | 520h | LTE_MTCe2_L1_cat1_B25_B40-Core | 38 | Sprint | Rel-14 | 74 |  |  |  |
| 560 | 242 | Release 14 on WLAN | milestone | 0d? | 2016-06-09 A | 2016-06-09 A | 100% | finish no earlier than 2016-06-09 |  |  |  |  |  |  | Rel-14 |  |  |  |  |
| 561 | 243 | **EIR check for WLAN access to EPC** |  | 230d? | 2015-11-02 A | 2016-09-15 A | 100% |  |  | 3000h | 3000h | EWE | 36 | Alcatel-Lucent, Nicolas Drevon | Rel-14 | 70 | 23.002, 23.402 | Nicolas.Drevon@alcatel-lucent.com |  |
| 562 | 243.1 | Stage 2 of EWE |  | 165d? | 2015-11-02 A | 2016-06-17 A | 100% | finish no earlier than 2016-06-17 | S2 | 1320h | 1320h | EWE | 36 | Alcatel-Lucent, Nicolas Drevon | Rel-14 | 70 | 23.002, 23.402 | Nicolas.Drevon@alcatel-lucent.com |  |
| 563 | 243.2 | **CT aspects of EWE** |  | 70d? | 2016-06-13 A | 2016-09-15 A | 100% |  | ct | 1680h | 1680h | EWE-CT | 37 | Nokia, Bruno Landais | Rel-14 | 72 |  | bruno.landais@nokia.com |  |
| 564 | 243.2.1 | CT1 aspects of EWE |  | 70d? | 2016-06-13 A | 2016-09-15 A | 100% | finish no earlier than 2016-09-15 | C1 | 560h | 560h | EWE-CT | 37 | Nokia, Bruno Landais | Rel-14 | 72 | 24.302 | bruno.landais@nokia.com |  |
| 565 | 243.2.2 | CT4 aspects of EWE |  | 70d? | 2016-06-13 A | 2016-09-15 A | 100% | finish no earlier than 2016-09-15 | C4 | 560h | 560h | EWE-CT | 37 | Nokia, Bruno Landais | Rel-14 | 72 | 29.273 | bruno.landais@nokia.com |  |
| 566 | 244 | **Support of EAP Re-authentication Protocol for WLAN Interworking** |  | 130d? | 2016-09-16 A | 2017-03-16 A | 100% |  |  | 4152h | 4152h | ERP | 37 | ORANGE, Todor Gamishev | Rel-14 | 73 |  | Todor dot Gamishev at Orange dot com |  |
| 567 | 244.1 | Support of EAP Re-authentication Protocol for WLAN Interworking |  | 129d? | 2016-09-16 A | 2017-03-15 A | 100% | finish no earlier than 2017-03-15 | S3 | 1032h | 1032h | ERP | 37 | ORANGE, Todor Gamishev | Rel-14 | 73 | 33.402 | Todor dot Gamishev at Orange dot com |  |
| 568 | 244.2 | **CT aspects of ERP** |  | 130d? | 2016-09-16 A | 2017-03-16 A | 100% |  | ct | 3120h | 3120h | ERP-CT | 37 | Orange, Julien Bournelle | Rel-14 | 73 |  | Julien.bournelle@orange.com |  |
| 569 | 244.2.1 | CT1 aspects of ERP |  | 130d? | 2016-09-16 A | 2017-03-16 A | 100% | finish no earlier than 2017-03-16 | C1 | 1040h | 1040h | ERP-CT | 37 | Orange, Julien Bournelle | Rel-14 | 73 | 24.302 | Julien.bournelle@orange.com |  |
| 570 | 244.2.2 | CT4 aspects of ERP |  | 130d? | 2016-09-16 A | 2017-03-16 A | 100% | finish no earlier than 2017-03-16 | C4 | 1040h | 1040h | ERP-CT | 37 | Orange, Julien Bournelle | Rel-14 | 73 | 29.273, 23.008, 23.003 | Julien.bournelle@orange.com |  |
| 571 | 245 | **Phase 2 of the Support of Emergency services over WLAN** |  | 403d? | 2015-09-01 A | 2017-03-15 A | 100% |  |  | 5328h | 5328h | SEW2 | 37 | Nicolas Drevon | Rel-14 | 72 | new 23.771, TS 23.402, TS 23.167 | nicolas.drevon@nokia.com |  |
| 572 | 245.1 | Study on Phase 2 of the Support of Emergency services over WLAN |  | 208d? | 2015-09-01 A | 2016-06-16 A | 100% | finish no earlier than 2016-06-16 | S2 | 1664h | 1664h | FS_SEW2 | 34 | Laurent Thiebaut, Alcatel Lucent | Rel-14 | 67 | new 23.771 | Laurent.thiebaut@alcatel-lucent.com |  |
| 573 | 245.2 | Support of Emergency services over WLAN - phase 2 |  | 70d? | 2016-06-13 A | 2016-09-15 A | 100% | finish no earlier than 2016-09-15 | S2 | 560h | 560h | SEW2 | 37 | Nicolas Drevon | Rel-14 | 72 | TS 23.402, TS 23.167 | nicolas.drevon@nokia.com |  |
| 574 | 245.3 | **CT aspects of SEW2** |  | 129d? | 2016-09-16 A | 2017-03-15 A | 100% |  | ct | 3104h | 3104h | SEW2-CT | 37 | Jennifer Liu | Rel-14 | 73 |  | jennifer.liu@nokia.com |  |
| 575 | 245.3.1 | CT1 aspects of SEW2 |  | 129d? | 2016-09-16 A | 2017-03-15 A | 100% | finish no earlier than 2017-03-15 | C1 | 1032h | 1032h | SEW2-CT | 37 | Jennifer Liu | Rel-14 | 73 | 24.302, 24.312, 24.301, 24.244, 24.229, 24.237 | jennifer.liu@nokia.com |  |
| 576 | 245.3.2 | CT4 aspects of SEW2 |  | 129d? | 2016-09-16 A | 2017-03-15 A | 100% | finish no earlier than 2017-03-15 | C4 | 1032h | 1032h | SEW2-CT | 37 | Jennifer Liu | Rel-14 | 73 | 23.003, 29.272, 29.273, 29.274, 29.328 | jennifer.liu@nokia.com |  |
| 577 | 245.3.3 | Deleted - CT6 aspects of SEW2 |  | 1d? | 2016-12-14 A | 2016-12-14 A | 100% | finish no earlier than 2016-12-14 | C6 | 8h | 8h | SEW2-CT | 37 | Jennifer Liu | Rel-14 | 73 | 31.102 | jennifer.liu@nokia.com |  |
| 578 | 246 | T-ADS supporting WLAN Access |  | 134d? | 2016-03-15 A | 2016-09-15 A | 100% | finish no earlier than 2016-09-15 | S2 | 1072h | 1072h | TADS_WLAN | 37 | Jiang Yi | Rel-14 | 72 | TS 23.292, TS 23.221, TS 23.402 | jiangyi (at) chinamobile (dot) com | SP-170519 |
| 579 | 247 | **Enhanced LTE-WLAN Aggregation (LWA)** |  | 263d? | 2016-03-15 A | 2017-03-15 A | 100% |  | R2 | 4208h | 4208h | LTE_WLAN_aggr | 36 | Intel | Rel-14 | 71 |  |  |  |
| 580 | 247.1 | Core part: Enhanced LTE-WLAN Aggregation (LWA) |  | 263d? | 2016-03-15 A | 2017-03-15 A | 100% | finish no earlier than 2017-03-15 | R2 | 2104h | 2104h | LTE_WLAN_aggr-Core | 36 | Intel | Rel-14 | 71 |  |  | RP-170330 |
| 581 | 248 | Release 14 on IMS | milestone | 0d? | 2016-06-09 A | 2016-06-09 A | 100% | finish no earlier than 2016-06-09 |  |  |  |  |  |  | Rel-14 |  |  |  |  |

Notes:
- 558: ; 21/3/17: Compl:0%->100%
- 559: ; 21/3/17: Compl:0%->100%
- 560: -
- 561: 7/3/16: 45%->60; 9/6/16: 60%->100
- 562: 7/3/16: 45%->60; 9/6/16: 60%->100
- 564: 16/9/16: 0%->100
- 565: 2/12/16: 0%->100
- 567: 1/12/16: 0%->90; 6/3/17: 90%->100
- 569: 2/12/16: 0%->80; 6/3/17: 80%->95; 5/6/17: 95%->100
- 570: 2/12/16: 0%->50; 6/3/17: 50%->95; 5/6/17: 95%->100
- 572: June2015: Compl:0%->100, SP-150151->SP-150251; 7/12/15: 0%->30, FCD: 12/15->06/16; 7/3/16: 30%->75; 7/3/16: WID:SP-150251->SP-160173; 9/6/16: 75%->100
- 573: 11/6/16: 0%->45; 19/9/16: 45%->100
- 574: 5/12/16: WID:CP-160476->CP-160694
- 575: 2/12/16: 20%->95; 5/6/17: 95%->100
- 576: 2/12/16: 0%->100
- 577: Deleted at CT6#82
- 578: 19/9/16: 0%->100
- 579: follow-up WI of REL-13 WI LTE_WLAN_radio; no Perf. part
- 580: follow-up WI of REL-13 WI LTE_WLAN_radio; no Perf. part1/7/16: Compl:0%->25%1/7/16: WID: RP-160600->RP-160923; 26/9/16: Compl:25%->45%; 20/12/16: Compl:45%->75%; 20/12/16: Stat Rep: --> ; 21/3/17: Compl:75%->100% ; 21/3/17...
- 581: -

| ID | WBS | Task | Type | Duration | Start | Finish | Complete | Remaining | Baseline start | Baseline finish | Baseline duration | Total slack | Constraint | Resources | Work | Actual work | Acronym | PCG approved | Impacted TSs and TRs | WI rapporteur name | Release | TSG approved | Status Report | WI rapporteur e-mail | MCC resp | Acronym_3GU_Export |
| --- | --- | --- | --- | --- | --- | --- | --- | --- | --- | --- | --- | --- | --- | --- | --- | --- | --- | --- | --- | --- | --- | --- | --- | --- | --- | --- |
| 582 | 249 | **Evolution to and Interworking with eCall in IMS** |  | 745d? | 2015-05-11 A | 2018-03-15 | 95% | 37.14d? |  |  |  | 4627d |  |  | 6288h | 5974.4h | EIEI | 35 | 22.101 | Kurt Bischinger | Rel-14 | 68 | SP-170538 |  |  |  |
| 583 | 249.1 | Stage 1 of Evolution to and Interworking with eCall in IMS |  | 30d? | 2015-05-11 A | 2015-06-19 A | 100% |  |  |  |  |  | start no earlier than 2015-05-11 | S1 | 240h | 240h | EIEI | 35 | 22.101 | Kurt Bischinger | Rel-14 | 68 |  |  |  |  |
| 584 | 249.2 | Stage 2 of Evolution to and Interworking with eCall in IMS |  | 131d? | 2015-12-11 A | 2016-06-10 A | 100% |  |  |  |  |  | finish no earlier than 2016-06-10 | S2 | 1048h | 1048h | EIEI | 35 | 23.167, 23.401 | Haris Zisimopoulos, Qualcomm Incorporated | Rel-14 | 68 |  | harisz@qti.qualcomm.com |  |  |
| 585 | 249.3 | **CT aspects of evolution to and interworking with eCall in IMS** |  | 143d? | 2016-03-02 A | 2016-09-15 A | 100% |  |  |  |  |  |  |  | 3432h | 3432h | EIEI-CT | 36 |  | Lena Chaponniere | Rel-14 | 71 |  | lguellec@qti.qualcomm.com |  |  |
| 586 | 249.3.1 | CT1 aspects of evolution to and interworking with eCall in IMS |  | 143d? | 2016-03-02 A | 2016-09-15 A | 100% |  |  |  |  |  | finish no earlier than 2016-09-15 | C1 | 1144h | 1144h | EIEI-CT | 36 | 24.229, 24.301 | Lena Chaponniere | Rel-14 | 71 |  | lguellec@qti.qualcomm.com |  |  |
| 587 | 249.3.2 | (IETF) Next-Generation Pan-European eCall (draft-ietf-ecrit-ecall) |  | 143d? | 2016-03-02 A | 2016-09-15 A | 100% |  |  |  |  |  | finish no earlier than 2016-09-15 | C1-IETF | 1144h | 1144h | EIEI-CT | 37 | draft-ietf-ecrit-ecall |  | Rel-14 | 72 |  |  |  |  |
| 588 | 249.3.3 | CT6 aspects of evolution to and interworking with eCall in IMS |  | 143d? | 2016-03-02 A | 2016-09-15 A | 100% |  |  |  |  |  | finish no earlier than 2016-09-15 | C6 | 1144h | 1144h | EIEI-CT | 36 | 31.102 | Lena Chaponniere | Rel-14 | 71 |  | lguellec@qti.qualcomm.com |  |  |
| 589 | 249.4 | UE Conformance Test Aspects - Evolution to and Interworking with eCall in IMS (EIEI) |  | 196d? | 2017-06-15 A | 2018-03-15 | 80% | 39.2d? |  |  |  | 4627d | finish no earlier than 2018-03-15 | R5 | 1568h | 1254.4h | EIEI-UEConTest | 39 |  | Qualcomm | Rel-14 | 76 |  |  |  |  |
| 590 | 250 | **Password based service activation for IMS Multimedia Telephony service** |  | 463d? | 2015-03-11 A | 2016-12-15 A | 100% |  |  |  |  |  |  |  | 3264h | 3264h | PWDIMS | 34 | 22.173 | Peter Bleckert (Ericsson) | Rel-14 | 67 | SP-170536 |  |  |  |
| 591 | 250.1 | Stage 1 for PWDIMS |  | 3d? | 2015-03-11 A | 2015-03-13 A | 100% |  |  |  |  |  | finish no earlier than 2015-03-13 | S1 | 24h | 24h | PWDIMS | 34 | 22.173 | Peter Bleckert (Ericsson) | Rel-14 | 67 |  |  |  |  |
| 592 | 250.2 | **CT aspects for PWDIMS** |  | 135d? | 2016-06-13 A | 2016-12-15 A | 100% |  |  |  |  |  |  | ct | 3240h | 3240h | PWDIMS-CT | 37 |  | Axell, Jörgen | Rel-14 | 72 |  |  |  |  |
| 593 | 250.2.1 | CT1 aspects for PWDIMS |  | 135d? | 2016-06-13 A | 2016-12-15 A | 100% |  |  |  |  |  | finish no earlier than 2016-12-15 | C1 | 1080h | 1080h | PWDIMS-CT | 37 | 24.623, 24.611 | Axell, Jörgen | Rel-14 | 72 |  |  |  |  |
| 594 | 250.2.2 | CT3 aspects for PWDIMS |  | 135d? | 2016-06-13 A | 2016-12-15 A | 100% |  |  |  |  |  | finish no earlier than 2016-12-15 | C3 | 1080h | 1080h | PWDIMS-CT | 37 | 29.292 | Axell, Jörgen | Rel-14 | 72 |  |  |  |  |
| 595 | 251 | **IMS Signalling Activated Trace** |  | 531d? | 2014-03-05 A | 2016-03-11 | 75% | 133.29d? | 2014-03-05 | 2014-09-12 | 138d? | 5152d |  |  | 22056h | 16519.4h | ISAT | 32 |  | Vodafone | Rel-14 | 63 |  | peter.dawes @vodafone.com | Frederic | ISAT |
| 596 | 251.1 | CT1 part of IMS Signalling Activated Trace |  | 528d? | 2014-03-10 A | 2016-03-11 A | 100% |  | 2014-03-05 | 2014-09-12 | 138d? |  | finish no earlier than 2016-03-11 | C1 | 4224h | 4224h | ISAT | 32 | 24.229, 24.323 | Vodafone | Rel-14 | 63 |  | peter.dawes @vodafone.com | Frederic |  |
| 597 | 251.2 | (IETF) IMS Signalling Activated Trace (draft-dawes-sipping-debug) |  | 391d? | 2014-09-12 A | 2016-03-11 | 28% | 281.52d? |  |  |  | 5152d | finish no earlier than 2016-03-11 | C1-IETF | 3128h | 875.84h | ISAT | 33 | draft-dawes-sipping-debug | Vodafone | Rel-14 | 65 |  | peter.dawes @vodafone.com |  |  |
| 598 | 251.3 | (IETF) IMS Signalling Activated Trace (draft-dawes-sipping-debug) |  | 391d? | 2014-09-12 A | 2016-03-11 | 25% | 293.25d? |  |  |  | 5152d | finish no earlier than 2016-03-11 | C3-IETF | 3128h | 782h | ISAT | 33 | draft-dawes-sipping-debug | Vodafone | Rel-14 | 65 |  | peter.dawes @vodafone.com |  |  |
| 599 | 251.4 | (IETF) IMS Signalling Activated Trace (draft-dawes-sipping-debug) |  | 391d? | 2014-09-12 A | 2016-03-11 | 70% | 117.3d? |  |  |  | 5152d | finish no earlier than 2016-03-11 | C4-IETF | 3128h | 2189.6h | ISAT | 33 | draft-dawes-sipping-debug | Vodafone | Rel-14 | 65 |  | peter.dawes @vodafone.com |  |  |
| 600 | 251.5 | CT3 part of IMS Signalling Activated Trace |  | 528d? | 2014-03-10 A | 2016-03-11 A | 100% |  | 2014-03-05 | 2014-06-13 | 73d? |  | finish no earlier than 2016-03-11 | C3 | 4224h | 4224h | ISAT | 32 | 29.165 | Vodafone | Rel-14 | 63 |  | peter.dawes @vodafone.com | Adrian |  |
| 601 | 251.6 | CT4 part of IMS Signalling Activated Trace |  | 528d? | 2014-03-05 A | 2016-03-11 A | 100% |  | 2014-03-05 | 2014-09-12 | 138d? |  | finish no earlier than 2016-03-11 | C4 | 4224h | 4224h | ISAT | 32 | 23.008, 29.228, 29.229, 29.328, 29.329 | Vodafone | Rel-14 | 63 |  | peter.dawes @vodafone.com | Kimmo |  |
| 602 | 252 | Other Release 14 | milestone | 0d? | 2016-06-09 A | 2016-06-09 A | 100% |  |  |  |  |  | finish no earlier than 2016-06-09 |  |  |  |  |  |  |  | Rel-14 |  |  |  |  |  |
| 603 | 253 | **User Controlled Spoofed Call Treatment** |  | 474d? | 2016-08-23 A | 2018-06-15 | 27% | 346.87d? |  |  |  | 4561d |  |  | 2856h | 766h | SPECTRE | 37 |  | Greg Schumacher, Sprint | Rel-14 | 73 |  |  |  |  |
| 604 | 253.1 | Stage 1 of User Controlled Spoofed Call Treatment |  | 20d? | 2016-08-23 A | 2016-09-19 A | 100% |  |  |  |  |  | finish no earlier than 2016-09-19 | S1 | 160h | 160h | SPECTRE | 37 | 22.228, 22.173 | Greg Schumacher, Sprint | Rel-14 | 73 |  |  |  |  |
| 605 | 253.2 | Stage 3 of User Controlled Spoofed Call Treatment |  | 74d? | 2016-12-01 A | 2017-03-14 A | 100% |  |  |  |  |  | finish no earlier than 2017-03-14 | C1 | 592h | 592h | SPECTRE-CT | 38 | 24.229, 29.165 | Dolly, Martin | Rel-14 | 74 |  | md3135@att.com |  |  |
| 606 | 253.3 | (IETF) A SIP Response Code for Unwanted Calls (draft-ietf-sipcore-status-unwanted) |  | 1d? | 2017-03-14 A | 2017-03-14 A | 100% |  |  |  |  |  | finish no earlier than 2017-03-14 | C1-IETF | 8h | 8h | SPECTRE-CT_IETF | 38 |  | Ericsson | Rel-14 | 75 |  |  |  |  |
| 607 | 253.4 | (IETF) Authenticated Identity Management in SIP (draft-ietf-stir-rfc4474bis) |  | 262d? | 2017-06-15 A | 2018-06-15 |  | 261.25d? |  |  |  | 4561d | finish no earlier than 2018-06-15 | C1-IETF | 2096h | 6h | SPECTRE-CT_IETF2 |  |  | Christer Holmberg | Rel-14 |  |  | christer.holmberg@ericsson.com |  |  |

Notes:
- 582: 12/15: created by MCC to distinguish Stage 1 from Stage 2
- 584: 7/3/16: 0%->20; 9/6/16: 20%->100. FCD: 03/16->06/16
- 586: 11/6/16: 0%->35; 16/9/16: 35%->85; 2/12/16: 85%->100
- 587: 18/12/17: 30%->100
- 588: 16/9/16: 0%->100
- 589: ; 19/9/17: Compl:0%->45%; 8/1/18: Compl:45%->80%; ...
- 590: 1/4/15: rapporteur added, Impacted TS added. 31/07/15: 100%
- 591: 1/4/15: rapporteur added, Impacted TS added. 31/07/15: 100%
- 593: 2/12/16: 0%->15; 6/3/17: 15%->100
- 594: 5/6/17: 0%->100
- 595: Mar 15: WID: CP-140195->CP-150091. ES in CP-150637. 8/3/16: Moved from Rel-13 at CT#71
- 596: CP66: moved to Rel-13. Mar 15: WID: CP-140195->CP-150091. ES in CP-150728; 5/6/17: 0%->100
- 597: CP66: moved to Rel-13. Mar 15: WID: CP-140195->CP-150091. ES in CP-150637; 13/6/16: 25%->28
- 598: CP66: moved to Rel-13. Mar 15: WID: CP-140195->CP-150091. ES in CP-150637
- 599: CP66: moved to Rel-13. Mar 15: WID: CP-140195->CP-150091. ES in CP-150637; 5/6/17: 25%->70
- 600: CP66: moved to Rel-13. Mar 15: WID: CP-140195->CP-150091. ES in CP-150637; 5/6/17: 0%->100
- 601: CP66: moved to Rel-13. Mar.15: 90%. ES in CP-150615. 7/3/16: Rel-13->Rel-14; 5/6/17: 90%->100
- 602: -
- 603: 1/12/16: moved from Rel-15 to Rel-14; 1/12/16: WID:SP-160729->SP-160898
- 604: 1/12/16: moved from Rel-15 to Rel-14; 1/12/16: WID:SP-160729->SP-160898
- 605: 2/12/16: 0%->25; 6/3/17: 25%->100
- 606: 18/12/17: 20%->100

| ID | WBS | Task | Duration | Start | Finish | Complete | Remaining | Total slack | Constraint | Resources | Work | Actual work | Acronym | PCG approved | WI rapporteur name | WI rapporteur e-mail | Release | TSG approved | Status Report |
| --- | --- | --- | --- | --- | --- | --- | --- | --- | --- | --- | --- | --- | --- | --- | --- | --- | --- | --- | --- |
| 608 | 254 | **Enhancement for TV service** | 565d? | 2015-04-14 A | 2017-06-09 A | 100% |  |  |  |  | 7800h | 7800h | EnTV | 36 | Zhiming Li | Lizhiming@huawei.com | Rel-14 | 70 | SP-170532 |
| 609 | 254.1 | Study on 3GPP Enhancement for TV Video service | 176d? | 2015-04-14 A | 2015-12-15 A | 100% |  |  | finish no earlier than 2015-12-15 | S1 | 1408h | 1408h | FS_EnTV | 34 | Zhiming Li (Huawei) | lizhiming@huawei.com | Rel-14 | 67 |  |
| 610 | 254.2 | **System Architecture Enhancements to eMBMS for TV Video Service** | 201d? | 2016-03-11 A | 2016-12-15 A | 100% |  |  |  |  | 1736h | 1736h | AE_enTV | 36 |  |  | Rel-14 | 71 |  |
| 611 | 254.2.1 | Study on System Architecture Enhancements to eMBMS for TV Video Service | 136d? | 2016-03-11 A | 2016-09-15 A | 100% |  |  | finish no earlier than 2016-09-15 | S2 | 1088h | 1088h | FS_AE_enTV | 36 | Miguel Griot, Qualcomm | mgriot@qti.qualcomm.com | Rel-14 | 71 |  |
| 612 | 254.2.2 | System Architecture Enhancements for TV service | 81d? | 2016-08-25 A | 2016-12-15 A | 100% |  |  | finish no earlier than 2016-12-15 | S2 | 648h | 648h | AE_enTV | 37 | Miguel Griot, Qualcomm | mgriot@qti.qualcomm.com | Rel-14 | 73 |  |
| 613 | 254.3 | Mobile Network Interface for MBMS Delivery of Media and TV services | 80d? | 2016-08-22 A | 2016-12-09 A | 100% |  |  | finish no earlier than 2016-12-09 | S4 | 640h | 640h | AE_enTV-MI_MTV | 37 | Thorsten Lohmar | Thorsten.lohmar@ericsson.com | Rel-14 | 73 |  |
| 614 | 254.4 | Codec aspects for eMBMS Delivery of Media and TV Services | 132d? | 2016-12-08 A | 2017-06-09 A | 100% |  |  | finish no earlier than 2017-06-09 | S4 | 1056h | 1056h | AE_enTV-S4 | 38 | Imed Bouazizi | i.bouazizi@samsung.com | Rel-14 | 74 |  |
| 615 | 254.5 | **Stage 3 of system architecture enhancements for TV service** | 74d? | 2016-12-01 A | 2017-03-14 A | 100% |  |  |  | ct | 2960h | 2960h | AE_enTV-CT | 38 | Catovic, Amer | amerc@qti.qualcomm.com | Rel-14 | 74 |  |
| 616 | 254.5.1 | CT1 aspects of system architecture enhancements for TV service | 74d? | 2016-12-01 A | 2017-03-14 A | 100% |  |  | finish no earlier than 2017-03-14 | C1 | 592h | 592h | AE_enTV-CT | 38 | Catovic, Amer | amerc@qti.qualcomm.com | Rel-14 | 74 |  |
| 617 | 254.5.2 | CT3 aspects of system architecture enhancements for TV service | 74d? | 2016-12-01 A | 2017-03-14 A | 100% |  |  | finish no earlier than 2017-03-14 | C3 | 592h | 592h | AE_enTV-CT | 38 | Catovic, Amer | amerc@qti.qualcomm.com | Rel-14 | 74 |  |
| 618 | 254.5.3 | CT4 aspects of system architecture enhancements for TV service | 74d? | 2016-12-01 A | 2017-03-14 A | 100% |  |  | finish no earlier than 2017-03-14 | C4 | 592h | 592h | AE_enTV-CT | 38 | Catovic, Amer | amerc@qti.qualcomm.com | Rel-14 | 74 |  |
| 619 | 254.5.4 | CT6 aspects of system architecture enhancements for TV service | 74d? | 2016-12-01 A | 2017-03-14 A | 100% |  |  | finish no earlier than 2017-03-14 | C6 | 592h | 592h | AE_enTV-CT | 38 | Catovic, Amer | amerc@qti.qualcomm.com | Rel-14 | 74 |  |
| 620 | 255 | MBMS Transport Protocol and APIs | 330d? | 2015-12-11 A | 2017-03-15 A | 100% |  |  | finish no earlier than 2017-03-15 | S4 | 2640h | 2640h | TRAPI | 36 | Samsung, Imed Bouazizi | i.bouazizi@samsung.com | Rel-14 | 70 |  |
| 621 | 256 | Multimedia Priority Service Modifications | 331d? | 2015-03-11 A | 2016-06-15 A | 100% |  |  | finish no earlier than 2016-06-15 | S1 | 2648h | 2648h | MPS_Mods | 34 | Ray P. Singh (Applied Communications Science) | rsingh@appcomsci.com | Rel-14 | 67 |  |
| 622 | 257 | Lawful Interception Rel-14 | 394d? | 2016-06-15 A | 2017-12-15 A | 100% |  |  | finish no earlier than 2017-12-15 | S3LI | 3152h | 3152h | LI14 | 37 | Koen JASPERS, PIDS |  | Rel-14 | 72 |  |
| 623 | 258 | **SIP Reason header extension** | 455d? | 2016-09-16 A | 2018-06-14 | 75% | 114.41d? | 4562d |  | ct | 7792h | 4136.02h | REAS_EXT | 37 | Mohali, Marianne | marianne.mohali@orange.com | Rel-14 | 73 | CP-171175 |
| 624 | 258.1 | CT1 aspects of SIP Reason header extension | 129d? | 2016-09-16 A | 2017-03-15 A | 100% |  |  | finish no earlier than 2017-03-15 | C1 | 1032h | 1032h | REAS_EXT | 37 | Mohali, Marianne | marianne.mohali@orange.com | Rel-14 | 73 |  |
| 625 | 258.2 | (IETF) ISUP Cause Location Parameter for the SIP Reason Header Field (draft-ietf-sipcore-reason-q850-loc) | 261d? | 2017-06-15 A | 2018-06-14 | 50% | 130.5d? | 4562d | finish no earlier than 2018-06-14 | C1-IETF | 2088h | 1044h | REAS_EXT |  | Michael KREIPL, Deutsche Telekom | michael(dot)kreipl(at)telekom(dot)de | Rel-14 |  |  |
| 626 | 258.3 | CT3 aspects of SIP Reason header extension | 129d? | 2016-09-16 A | 2017-03-15 A | 100% |  |  | finish no earlier than 2017-03-15 | C3 | 1032h | 1032h | REAS_EXT | 37 | Mohali, Marianne | marianne.mohali@orange.com | Rel-14 | 73 |  |
| 627 | 259 | Enhancements to User Location Reporting Support | 73d? | 2015-09-09 A | 2015-12-18 A | 100% |  |  | finish no earlier than 2015-12-18 | S1 | 584h | 584h | eULRS | 35 |  |  | Rel-14 | 68 |  |
| 628 | 260 | **Diameter Load Control Mechanism** | 597d? | 2014-12-03 A | 2017-03-15 | 98% | 10.85d? | 4888d |  | ct | 8032h | 7448.03h | DLoCMe | 37 | Nokia, Ulrich Wiehe | ulrich.wiehe@nokia.com | Rel-14 | 73 | CP-171049 |
| 629 | 260.1 | CT3 aspects of Diameter Load Control Mechanism | 65d? | 2016-09-16 A | 2016-12-15 A | 100% |  |  | finish no earlier than 2016-12-15 | C3 | 520h | 520h | DLoCMe | 37 | Nokia, Ulrich Wiehe | ulrich.wiehe@nokia.com | Rel-14 | 73 |  |
| 630 | 260.2 | CT4 aspects of Diameter Load Control Mechanism | 65d? | 2016-09-16 A | 2016-12-15 A | 100% |  |  | finish no earlier than 2016-12-15 | C4 | 520h | 520h | DLoCMe | 37 | Nokia, Ulrich Wiehe | ulrich.wiehe@nokia.com | Rel-14 | 73 |  |
| 631 | 260.3 | (IETF) Diameter Load Information Conveyance (draft-ietf-dime-load-03) | 74d? | 2016-12-02 A | 2017-03-15 | 90% | 7.4d? | 4888d | finish no earlier than 2017-03-15 | C4-IETF | 592h | 532.8h | DLoCMe | 38 |  |  | Rel-14 | 74 |  |
| 632 | 260.4 | Study on Diameter Load Control Mechanisms | 203d? | 2014-12-03 A | 2015-09-11 A | 100% |  |  | finish no earlier than 2015-09-11 | C4 | 1624h | 1624h | FS_DLoCME | 34 | Alcatel-Lucent |  | Rel-13 | 66 |  |

Notes:
- 608: 2/3/16: 0%->100 / Impacted TSs and TRs: 22.101
- 609: 1/4/15:TR number added; June2015: Compl:0%->20; 07/09/15: 20%->75; 7/12/15: 75%->100 / Impacted TSs and TRs: TR 22.816
- 611: 9/6/16: 0%->70; 28/7/16: 23.746 added; 19/9/16: 70%->100 / Impacted TSs and TRs: TR 23.746
- 612: 19/9/16: 0%->85; 1/12/16: FCD:09/16->12/16; 1/12/16: 85%->100 / Impacted TSs and TRs: TS 23.246
- 613: 06/10/16: Acronym: SA_enTV-MI_MTV -> AE_enTV-MI_MTV; 1/12/16: FCD:09/16->2/16; 1/12/16: 0%->50; 8/12/16: 50%->100 / Impacted TSs and TRs: 26.346
- 614: 6/3/17: 0%->20; 6/3/17: FCD:03/17->06/17; 7/6/17: 20%->100 / Impacted TSs and TRs: 26.347, 26.346
- 615: 21/3/17: 29.116 added; / Impacted TSs and TRs: 24.116, 24.117; 29.116
- 616: 2/12/16: 0%->40; 6/3/17: 40%->75; 5/6/17: 75%->100 / Impacted TSs and TRs: 24.008
- 617: 6/3/17: 0%->80; 6/3/17: 80%->100 / Impacted TSs and TRs: 29.061
- 618: 5/6/17: 0%->100 / Impacted TSs and TRs: 29.274, 23.003
- 619: 7/3/17: 0%->100 / Impacted TSs and TRs: 31.102
- 620: 28/1/16: 26.347 added; 7/3/16: 0%->20; 11/6/16: 20%->35; 19/9/16: 35%->60. FCD: 09/16->03/17; 1/12/16: 60%->70; 6/3/17: 70%->100 / Impacted TSs and TRs: 26.346, 26.852, New TS; 26.347
- 621: 1/4/15: rapporteur added, Impacted TS added. 6/15: 0->25%; 07/09/15: 25%->40; 7/12/15: 40%->70; 2/3/16: 70%->80; 9/6/16: 80%->100 / Impacted TSs and TRs: 22.153
- 622: 1/12/16: 0%->10; 2/3/17: WID:SP-160375->SP-1570038; 3/3/17: 8%->15; 6/3/17: 15%->20; 9/3/17: WID:SP-1570038->SP-170038; 7/6/17: 20%->50; 11/9/17: 50%->80; 15/12/17: 80%->100
- 624: 2/12/16: 0%->50; 6/3/17: 50%->85; 5/6/17: 85%->100 / Impacted TSs and TRs: 24.229
- 626: 5/6/17: 0%->100 / Impacted TSs and TRs: 29.163, 29.292
- 627: 2/3/16: 0%->100
- 628: 5/12/16: WID:CP-160412->CP-160645
- 629: 2/12/16: 0%->100 / Impacted TSs and TRs: 29.272, 29.273, 29.228, 29.229, 29.328, 29.329, 29.336, 29.344, 29.345, 29.128, 29.283
- 630: 2/12/16: 0%->100 / Impacted TSs and TRs: 29.153, 29.154, 29.212, 29.214, 29.215, 29.217, 29.219, 29.213
- 631: 2/12/16: 0%->90
- 632: 0->5%. Mar. 15: 10%; 7/12/15: 10%->40; 13/6/16: 40%->100 / Impacted TSs and TRs: New 29.810

| ID | WBS | Task | Duration | Start | Finish | Complete | Remaining | Total slack | Constraint | Resources | Work | Actual work | Acronym | PCG approved | WI rapporteur e-mail | Release | TSG approved | Status Report | TSG stopped |
| --- | --- | --- | --- | --- | --- | --- | --- | --- | --- | --- | --- | --- | --- | --- | --- | --- | --- | --- | --- |
| 633 | 261 | **Diameter Base Protocol Specification Update** | 74d? | 2016-12-01 A | 2017-03-14 A | 100% |  |  |  |  | 2352h | 2352h | DBPU | 38 | Peter.Schmitt@huawei.com | Rel-14 | 74 |  |  |
| 634 | 261.1 | **CT aspects of Diameter Base Protocol Specification Update** | 74d? | 2016-12-01 A | 2017-03-14 A | 100% |  |  |  | ct | 1776h | 1776h | DBPU | 38 | Peter.Schmitt@huawei.com | Rel-14 | 74 |  |  |
| 635 | 261.1.1 | CT3 aspects of Diameter Base Protocol Specification Update | 74d? | 2016-12-01 A | 2017-03-14 A | 100% |  |  | finish no earlier than 2017-03-14 | C3 | 592h | 592h | DBPU | 38 | Peter.Schmitt@huawei.com | Rel-14 | 74 |  |  |
| 636 | 261.1.2 | CT4 aspects of Diameter Base Protocol Specification Update | 74d? | 2016-12-01 A | 2017-03-14 A | 100% |  |  | finish no earlier than 2017-03-14 | C4 | 592h | 592h | DBPU | 38 | Peter.Schmitt@huawei.com | Rel-14 | 74 |  |  |
| 637 | 261.2 | Charging aspects for Diameter Base Protocol Specification Update | 72d? | 2016-12-01 A | 2017-03-10 A | 100% |  |  | finish no earlier than 2017-03-10 | S5 | 576h | 576h | DBPU-CH | 38 | Nokia, Maryse <dot> Gardella <at> Nokia <dot> com | Rel-14 | 74 |  |  |
| 638 | 262 | **Enhancements to Multi-stream Multiparty Conferencing Media Handling** | 276d? | 2016-03-02 A | 2017-03-21 | 99% | 0.35d? | 4884d |  |  | 10320h | 10091.4h | MMCMH_Enh | 37 | nleung@qti.qualcomm.com | Rel-14 | 72 | SP-170528 |  |
| 639 | 262.1 | Overall aspects of MMCMH_Enh | 196d? | 2016-06-13 A | 2017-03-10 A | 100% |  |  | finish no earlier than 2017-03-10 | S4 | 1568h | 1568h | MMCMH_Enh | 37 | nleung@qti.qualcomm.com | Rel-14 | 72 |  |  |
| 640 | 262.2 | **CT aspects of MMCMH_Enh** | 276d? | 2016-03-02 A | 2017-03-21 | 99% | 0.44d? | 4884d |  | ct | 8752h | 8523.39h | MMCMH_Enh-CT | 37 | nevenka.biondic@ericsson.com | Rel-14 | 72 |  |  |
| 641 | 262.2.1 | CT1 aspects of MMCMH_Enh | 272d? | 2016-03-02 A | 2017-03-15 A | 100% |  |  | finish no earlier than 2017-03-15 | C1 | 2176h | 2176h | MMCMH_Enh-CT | 37 | nevenka.biondic@ericsson.com | Rel-14 | 72 |  |  |
| 642 | 262.2.2 | CT3 aspects of MMCMH_Enh | 272d? | 2016-03-02 A | 2017-03-15 A | 100% |  |  | finish no earlier than 2017-03-15 | C3 | 2176h | 2176h | MMCMH_Enh-CT | 37 | nevenka.biondic@ericsson.com | Rel-14 | 72 |  |  |
| 643 | 262.2.3 | CT4 aspects of MMCMH_Enh | 272d? | 2016-03-02 A | 2017-03-15 A | 100% |  |  | finish no earlier than 2017-03-15 | C4 | 2176h | 2176h | MMCMH_Enh-CT | 37 | nevenka.biondic@ericsson.com | Rel-14 | 72 |  |  |
| 644 | 262.2.4 | (IETF) Using Simulcast in SDP and RTP Sessions (draft-ietf-mmusic-sdp-simulcast) | 1d? | 2017-03-21 A | 2017-03-21 | 50% | 0.5d? | 4884d | start no earlier than 2017-03-21 | C1-IETF | 8h | 4h | MMCMH_Enh-CT | 38 | tomas.frankkila@ericsson.com | Rel-14 | 75 |  |  |
| 645 | 262.2.5 | (IETF) RTP Payload Format Restrictions (draft-ietf-mmusic-rid) | 1d? | 2017-03-21 A | 2017-03-21 | 20% | 0.8d? | 4884d | start no earlier than 2017-03-21 | C1-IETF | 8h | 1.6h | MMCMH_Enh-CT | 38 |  | Rel-14 | 75 |  |  |
| 646 | 263 | **Deleted - CT aspects of (or "Enhancements of") MTSI Extension on Multi-stream** | 143d? | 2016-03-02 A | 2016-09-15 A | 100% |  |  |  | ct | 4576h | 4576h | MMCMH-CT | 36 | nevenka.biondic@ericsson.com | Rel-14 | 71 |  | CP-72 |
| 647 | 263.1 | deleted -CT1 aspects of MTSI Extension on Multi-stream | 143d? | 2016-03-02 A | 2016-09-15 A | 100% |  |  | start no earlier than 2016-03-02 | C1 | 1144h | 1144h | MMCMH-CT | 36 | nevenka.biondic@ericsson.com | Rel-14 | 71 |  | CP-72 |
| 648 | 263.2 | deleted -CT3 aspects of MTSI Extension on Multi-stream | 143d? | 2016-03-02 A | 2016-09-15 A | 100% |  |  | start no earlier than 2016-03-02 | C3 | 1144h | 1144h | MMCMH-CT | 36 | nevenka.biondic@ericsson.com | Rel-14 | 71 |  | CP-72 |
| 649 | 263.3 | deleted -CT4 aspects of MTSI Extension on Multi-stream | 143d? | 2016-03-02 A | 2016-09-15 A | 100% |  |  | start no earlier than 2016-03-02 | C4 | 1144h | 1144h | MMCMH-CT | 36 | nevenka.biondic@ericsson.com | Rel-14 | 71 |  | CP-72 |
| 650 | 264 | **Control and User Plane Separation of EPC nodes** | 391d? | 2015-09-17 A | 2017-03-15 A | 100% |  |  |  |  | 5248h | 5248h | CUPS | 35 | mirko.schramm@huawei.com | Rel-14 | 69 | SP-170520 |  |
| 651 | 264.1 | Study on Control and User Plane Separation of EPC nodes | 197d? | 2015-09-17 A | 2016-06-17 A | 100% |  |  | finish no earlier than 2016-06-17 | S2 | 1576h | 1576h | FS_CUPS | 35 | mirko.schramm@huawei.com | Rel-14 | 69 |  |  |
| 652 | 264.2 | Control and User Plane Separation of EPC nodes | 72d? | 2016-06-09 A | 2016-09-15 A | 100% |  |  | finish no earlier than 2016-09-15 | S2 | 576h | 576h | CUPS | 37 | mirko.schramm@huawei.com | Rel-14 | 72 |  |  |
| 653 | 264.3 | **CT aspects for CUPS** | 129d? | 2016-09-16 A | 2017-03-15 A | 100% |  |  |  | ct | 3096h | 3096h | CUPS-CT | 37 | peter.schmitt@huawei.com | Rel-14 | 73 |  |  |
| 654 | 264.3.1 | CT3 aspects for CUPS | 129d? | 2016-09-16 A | 2017-03-15 A | 100% |  |  | finish no earlier than 2017-03-15 | C3 | 1032h | 1032h | CUPS-CT | 37 | peter.schmitt@huawei.com | Rel-14 | 73 |  |  |
| 655 | 264.3.2 | CT4 aspects for CUPS | 129d? | 2016-09-16 A | 2017-03-15 A | 100% |  |  | finish no earlier than 2017-03-15 | C4 | 1032h | 1032h | CUPS-CT | 37 | peter.schmitt@huawei.com | Rel-14 | 73 |  |  |
| 656 | 265 | **OAM14 Rel-14 Operations, Administration, Maintenance and Provisioning (OAM&P)** | 720d? | 2015-03-12 A | 2017-12-12 A | 100% |  |  |  | S5 | 35193.6h | 35193.6h | OAM14 | 35 |  | Rel-14 | 68 |  |  |
| 657 | 265.1 | **Management of mobile networks that include virtualized network functions** | 653d? | 2015-06-15 A | 2017-12-12 A | 100% |  |  |  | S5 | 23968h | 23968h | OAM14-MAMO_VNF | 35 | liujinglei@chinamobile.com | Rel-14 | 68 |  |  |
| 658 | 265.1.1 | Management concept, architecture and requirements for mobile networks that include virtualized network functions | 395d? | 2015-06-15 A | 2016-12-15 A | 100% |  |  | finish no earlier than 2016-12-15 | S5 | 3160h | 3160h | OAM14-MAMO_VNF-MCAR | 35 | liujinglei@chinamobile.com | Rel-14 | 68 |  |  |
| 659 | 265.1.2 | Configuration Management for mobile networks that include virtualized network functions | 454d? | 2015-09-16 A | 2017-06-09 A | 100% |  |  | finish no earlier than 2017-06-09 | S5 | 3632h | 3632h | OAM14-MAMO_VNF-CM | 35 | zhu.weihong@zte.com.cn | Rel-14 | 69 |  |  |
| 660 | 265.1.3 | Fault Management for mobile networks that include virtualized network functions | 454d? | 2015-09-16 A | 2017-06-09 A | 100% |  |  | finish no earlier than 2017-06-09 | S5 | 3632h | 3632h | OAM14-MAMO_VNF-FM | 35 | kai.zhangkai@huawei.com | Rel-14 | 69 |  |  |
| 661 | 265.1.4 | Performance management for mobile networks that include virtualized network functions | 586d? | 2015-09-16 A | 2017-12-12 A | 100% |  |  | finish no earlier than 2017-12-12 | S5 | 4688h | 4688h | OAM14-MAMO_VNF-PM | 35 | joey.chou@intel.com | Rel-14 | 69 |  |  |
| 662 | 265.1.5 | Lifecycle management for mobile networks that include virtualized network functions | 454d? | 2015-09-16 A | 2017-06-09 A | 100% |  |  | finish no earlier than 2017-06-09 | S5 | 3632h | 3632h | OAM14-MAMO_VNF-LCM | 35 | anatoly.andrianov@nokia.com | Rel-14 | 69 |  |  |
| 663 | 265.2 | Filtering of PM measurements and data volume | 199d? | 2016-03-01 A | 2016-12-01 A | 100% |  |  | start no earlier than 2016-03-01 | S5 | 1592h | 1592h | OAM14-FILMEAS | 36 | robert.petersen@ericsson.com | Rel-14 | 71 |  |  |
| 664 | 265.3 | Study on OAM support for Licensed Shared Access (LSA) | 262d? | 2015-03-12 A | 2016-03-11 A | 100% |  |  | finish no earlier than 2016-03-11 | S5 | 2096h | 2096h | FS_OAM_LSA | 34 | anatoly<dot>andrianov<at>nokia<dot>com | Rel-14 | 67 |  |  |
| 665 | 265.4 | OAM support for Licensed Shared Access (LSA) | 262d? | 2016-06-13 A | 2017-06-12 A | 100% |  |  | start no earlier than 2016-06-13 | S5 | 2096h | 2096h | OAM14-LSA | 37 |  | Rel-14 | 72 |  |  |
| 666 | 266 | Development of super-wideband and fullband P.835 | 524d? | 2015-06-16 A | 2017-06-15 A | 100% |  |  | finish no earlier than 2017-06-15 | S4 | 4192h | 4192h | DESUDAPS | 35 | sisabelle@audience.com | Rel-14 | 68 | SP-170346 |  |
| 667 | 267 | Enhancing Location Capabilities for Indoor and Outdoor Emergency Communications | 200d? | 2015-03-11 A | 2015-12-15 A | 100% |  |  | finish no earlier than 2015-12-15 | S1 | 1600h | 1600h | ELIOT | 34 | Gregory.schumacher@sprint.com | Rel-14 | 67 | SP-170553 |  |
| 668 | 268 | Enhancements to Domain Selection between VoLTE and CDMA CS | 69d? | 2015-03-11 A | 2015-06-15 A | 100% |  |  | finish no earlier than 2015-06-15 | S1 | 552h | 552h | eDSVCC | 34 | zhuhongmei@gsta.com | Rel-14 | 67 |  |  |
| 669 | 269 | Control of Applications when Third party Servers encounter difficulties | 93d? | 2015-05-11 A | 2015-09-16 A | 100% |  |  | finish no earlier than 2015-09-16 | S1 | 744h | 744h | CATS | 35 | er-yoshida (at) kddi (dot) com | Rel-14 | 68 | SP-170338 |  |

Notes:
- 633: WI rapporteur name: Huawei, Peter Schmitt
- 634: WI rapporteur name: Huawei, Peter Schmitt
- 635: 6/3/17: 0%->100 / Impacted TSs and TRs: 29.061, 29.153, 29.154, 29.212, 29.214, 29.215, 29.217, 29.219, 29.368, 29.468, 29.213, 29.155, 29.201 / WI rapporteur name: Huawei, Peter Schmitt
- 636: 2/12/16: 0%->10; 6/3/17: 10%->100 / Impacted TSs and TRs: 29.109, 29.128, 29.172, 29.173, 29.228, 29.229, 29.272, 29.273, 29.283, 29.328, 29.329, 29.336, 29.337, 29.338, 29.343, 29.344, 29.345 / WI rapporteur name: Huawei, Peter Schmitt
- 637: 6/3/17: 0%->100 / Impacted TSs and TRs: 32.240, 32.251, 32.260, 32.270, 32.271, 32.272, 32.273, 32.274, 32.275, 32.278, 32.280, 32.295, 32.296, 32.297, 32.299 / WI rapporteur name: Nokia
- 638: Impacted TSs and TRs: TS 26.114 / WI rapporteur name: Nikolai Leung
- 639: 19/9/16: WID:SP-160272->SP-160785; 19/9/16: 0%->50; 1/12/16: 50%->80; 1/12/16: FCD:12/16->03/17; 6/3/17: 80%->100 / Impacted TSs and TRs: TS 26.114, TR 26.980 / WI rapporteur name: Nikolai Leung
- 640: To be checked at SA4 if a part can stay in Rel-13 (now Stages 1 and 2 by SA4 in UID660050), while the CT aspects are in Rel-14. 06/16: Name changed from "CT aspects of (or "Enhancements of") MTSI Extension on Multi-stream". Acronym changed from "MMCMH- / WI rapporteur name: Ericsson, Nevenka Biondic
- 641: Name changed from "CT1 aspects of MTSI Extension on Multi-stream". Acronym changed from "MMCMH-CT"; 13/6/16: WID:CP-160117->CP-160250. FCD: 09/16->03/17; 13/6/16: WID:CP-160250->CP-160369; 2/12/16: 0%->95; 6/3/17: 95%->100 / Impacted TSs and TRs: 24.229 / WI rapporteur name: Ericsson, Nevenka Biondic
- 642: Acronym changed from "MMCMH-CT"; 13/6/16: WID:CP-160117->CP-160250. FCD: 09/16->03/17; 13/6/16: WID:CP-160250->CP-160369; 6/3/17: 0%->100 / Impacted TSs and TRs: 29.162, 29.213, 29.214, 29.165 / WI rapporteur name: Ericsson, Nevenka Biondic
- 643: 3/6/16: WID:CP-160117->CP-160250. FCD: 09/16->03/17; 13/6/16: WID:CP-160250->CP-160369; 2/12/16: 0%->35; 6/3/17: 35%->75; 5/6/17: 75%->100 / Impacted TSs and TRs: 23.333, 29.333, 23.334, 29.334, 29.238 / WI rapporteur name: Ericsson, Nevenka Biondic
- 644: WI rapporteur name: Ericsson
- 645: WI rapporteur name: Ericsson
- 646: Deleted, "replaced" by MMCMH_Enh-CT / WI rapporteur name: Ericsson, Nevenka Biondic
- 647: Deleted, "replaced" by MMCMH_Enh-CT / Impacted TSs and TRs: 24.229 / WI rapporteur name: Ericsson, Nevenka Biondic
- 648: Deleted, "replaced" by MMCMH_Enh-CT / Impacted TSs and TRs: 29.162, 29.213, 29.214, 29.165 / WI rapporteur name: Ericsson, Nevenka Biondic
- 649: Deleted, "replaced" by MMCMH_Enh-CT / Impacted TSs and TRs: 23.333, 29.333, 23.334, 29.334, 29.238 / WI rapporteur name: Ericsson, Nevenka Biondic
- 650: 7/12/15: 0%->20; 7/3/16: 20%->40; 9/6/16: 40%->100; 28/7/16: 23.214 added; / Impacted TSs and TRs: 23.714; 23.214 / WI rapporteur name: Huawei, Mirko Schramm
- 651: 7/12/15: 0%->20; 7/3/16: 20%->40; 9/6/16: 40%->100 / Impacted TSs and TRs: 23.714 / WI rapporteur name: Huawei, Mirko Schramm
- 652: 19/9/16: 0%->80; 1/12/16: 80%->100 / Impacted TSs and TRs: 23.214, 23.002, 23.203, 23.401, 23.402 / WI rapporteur name: Huawei, Mirko Schramm
- 653: WI rapporteur name: Huawei, Peter Schmitt
- 654: 8/6/17: 0%->100 / Impacted TSs and TRs: 29.212, 29.213 / WI rapporteur name: Huawei, Peter Schmitt
- 655: 2/12/16: 0%->40; 6/3/17: 40%->75; 5/6/17: 75%->100 / Impacted TSs and TRs: 23.007, 29.274, 29.281, 29.303, 23.008 / WI rapporteur name: Huawei, Peter Schmitt
- 657: June2015: WID:SP-150308->SP-150362 / WI rapporteur name: Jinglei Liu, China Mobile
- 658: June2015: WID:SP-150309->SP-150363. Aug2015: FCD: Mar 2016; 07/09/15: 0%->20. 15/09/15: FCD: Mar 16->Dec 16, moved to Rel-14; 7/12/15: 20%->40; 7/3/16: 40%->50; 7/3/16: WID:SP-150363->SP-160023 ( FCD: Dec16->Sep16); 13/6/16: 50%->70; 19/9/16: FCD:09/16; 22/3/17: 90%->100 / Impacted TSs and TRs: 28.xyz, 32.101 / WI rapporteur name: Jinglei Liu, China Mobile (liujinglei@chinamobile.com)
- 659: 5/10/15: 28.513; 28.512; 28.511; 28.510 added; 7/12/15: 0%->15; 7/3/16: 15%->20; 13/6/16: 20%->30; 19/9/16: 30%->50; 1/12/16: 50%->60; 1/12/16: FCD:12/16->03/17; 6/3/17: FCD:03/17->06/17; 6/3/17: 60%->80; 7/6/17: 80%->100 / Impacted TSs and TRs: 28.513; 28.512; 28.511; 28.510; 28.621, 28.622, 28.623, 28.704, 28.707 / WI rapporteur name: ZTE Corporation (Zhu Weihong, zhu.weihong@zte.com.cn)
- 660: 5/10/15: 28.518; 28.517; 28.516; 28.515 added; 7/12/15: 0%->10; 7/3/16: 10%->15; 13/6/16: 15%->50; 13/6/16: WID:SP-150404->SP-160403; 19/9/16: 50%->75; 1/12/16: 75%->80; 1/12/16: 80%->; 1/12/16: FCD:12/16->03/17; 6/3/17: FCD:03/17->06/17; 6/3/17: 80%->90; 7/6/17: 90%->100 / Impacted TSs and TRs: 28.515, 28.516, 28.517, 28.518, 32.111-1, 32.111-2, 32.111-6 / WI rapporteur name: Huawei (Kai ZHANG, kai.zhangkai@huawei.com)
- 661: 5/10/15: 28.523; 28.522; 28.521; 28.520 added; 7/12/15: 0%->10; 7/3/16: 10%->15; 13/6/16: 15%->30; 13/6/16: WID:SP-150401->SP-160402; 19/9/16: 30%->60; 1/12/16: FCD:12/16->03/17; 6/3/17: FCD:03/17->06/17; 6/3/17: 60%->75; 7/6/17: 75%->90; 7/6/17: FCD:0...; 11/9/17: 90%->100 / Impacted TSs and TRs: 28.523; 28.522; 28.521; 28.520; 32.426, 32.409, 32.401 / WI rapporteur name: Intel (Joey Chou, joey.chou@intel.com)
- 662: 5/10/15: 28.528; 28.527; 28.526; 28.525 added; 7/12/15: 0%->10; 7/3/16: 10%->15; 13/6/16: 15%->25; 13/6/16: WID:SP-150403->SP-160427; 19/9/16: 25%->40; 1/12/16: 40%->60; 1/12/16: FCD:12/16->03/17; 6/3/17: FCD:03/17->06/17; 6/3/17: 60%->80; 7/6/17: 80%->100 / Impacted TSs and TRs: 28.525, 28.526, 28.527, 28.528, 28.704, 28.705, 28.706, 28.707, 28.708, 28.709 / WI rapporteur name: Anatoly Andrianov (anatoly.andrianov@nokia.com), Nokia Networks
- 663: 13/6/16: 0%->15; 19/9/16: WID:SP-160022->SP-160610; 19/9/16: 15%->60; 1/12/16: 60%->95; 6/3/17: 95%->100 / Impacted TSs and TRs: New 32.817, 32.425, 32.412, 32.416, 32.130 / WI rapporteur name: Ericsson: Robert Petersen
- 664: June2015: Compl:0%->15; 07/09/15: 15%->70; 7/12/15: 70%->75; 7/3/16: 75%->100. 22/3/16: FCD: 09/15->03/16. Rel-13->Rel-14; 28/7/16: 28.303 added; 28/7/16: 28.302 added; 28/7/16: 28.301 added; 28/7/16: 33.250 added; 28/7/16: added; / Impacted TSs and TRs: 28.303; 28.302; 28.301; / WI rapporteur name: Nokia Networks, Anatoly Andrianov
- 665: 28/7/16: 28.303 added; 28/7/16: 28.302 added; 28/7/16: 28.301 added; 19/9/16: 0%->20; 1/12/16: 20%->30; 6/3/17: 30%->40; 7/6/17: 40%->100 / Impacted TSs and TRs: 32.101; 28.303; 28.302; 28.301 / WI rapporteur name: Nokia: Olaf Pollakowski
- 666: 06/15: FCD corrected to Dec.15; Aug2015: 0%->5; 07/09/15: 5%->20, FCD: 12/15->06.16; 7/12/15: 20%->40, MOVED TO REL-14; 7/3/16: 40%->50. 15/4/16: 6/16->12/16; 11/6/16: 50%->60; 19/9/16: 60%->70, fcd: 12/16->06/17; 1/12/16: 70%->75; 6/3/17: 75%->80; 7/6/17: 80%->100 / Impacted TSs and TRs: 26.131, 26.132 / WI rapporteur name: Scott Isabelle (Knowles, Inc.)
- 667: 1/4/15: rapporteur added, Impacted TS added; June2015: Compl:0%->25; 07/09/15: 25%->80; 2/3/16: 80%->100 / Impacted TSs and TRs: 22.101, 22.071 / WI rapporteur name: Greg Schumacher
- 668: 1/4/15: rapporteur added, Impacted TS added; June2015: Compl:0%->100 / Impacted TSs and TRs: 22.101 / WI rapporteur name: China Telecom, Hongmei Zhu
- 669: 07/09/15: 0%->100 / Impacted TSs and TRs: 22.011 / WI rapporteur name: Eriko Yoshida, KDDI

| ID | WBS | Task | Duration | Start | Finish | Complete | Remaining | Total slack | Constraint | Resources | Work | Actual work | Acronym | PCG approved | WI rapporteur name | WI rapporteur e-mail | Release | TSG approved | Status Report |
| --- | --- | --- | --- | --- | --- | --- | --- | --- | --- | --- | --- | --- | --- | --- | --- | --- | --- | --- | --- |
| 670 | 270 | **PS Data Off Services** | 416d? | 2015-11-09 A | 2017-06-09 A | 100% |  |  |  |  | 5416h | 5416h | PS_Data_Off | 36 | Orange, Bruno Tossou | bruno.tossou@orange.com | Rel-14 | 70 | SP-170708 |
| 671 | 270.1 | PS Data Off Services | 92d? | 2015-11-09 A | 2016-03-15 A | 100% |  |  | finish no earlier than 2016-03-15 | S1 | 736h | 736h | PS_Data_Off | 36 | Orange, Bruno Tossou | bruno.tossou@orange.com | Rel-14 | 70 |  |
| 672 | 270.2 | Study on Stage 2 of PS Data off function | 131d? | 2016-06-17 A | 2016-12-15 A | 100% |  |  | finish no earlier than 2016-12-15 | S2 | 1048h | 1048h | FS_PS_DATA_OFF | 37 | Orange, david <dot> cailliere <at> orange <dot> com | david <dot> cailliere <at> orange <dot> com | Rel-14 | 72 |  |
| 673 | 270.3 | Stage 2 of PS Data Off | 21d? | 2016-11-17 A | 2016-12-15 A | 100% |  |  | finish no earlier than 2016-12-15 | S2 | 168h | 168h | PS_DATA_OFF | 38 | Christophe Petit (Orange) | kris (dot) petit (at) orange (dot) com | Rel-14 | 74 |  |
| 674 | 270.4 | **Stage 3 of PS Data Off** | 74d? | 2016-12-01 A | 2017-03-14 A | 100% |  |  |  | ct | 2368h | 2368h | PS_DATA_OFF-CT | 38 | Herrero Veron, Christian (Huawei) | Christian.Herrero at huawei.com | Rel-14 | 74 |  |
| 675 | 270.4.1 | CT1 aspects of PS Data Off | 74d? | 2016-12-01 A | 2017-03-14 A | 100% |  |  | finish no earlier than 2017-03-14 | C1 | 592h | 592h | PS_DATA_OFF-CT | 38 | Herrero Veron, Christian (Huawei) | Christian.Herrero at huawei.com | Rel-14 | 74 |  |
| 676 | 270.4.2 | CT3 aspects of PS Data Off | 74d? | 2016-12-01 A | 2017-03-14 A | 100% |  |  | finish no earlier than 2017-03-14 | C3 | 592h | 592h | PS_DATA_OFF-CT | 38 | Herrero Veron, Christian (Huawei) | Christian.Herrero at huawei.com | Rel-14 | 74 |  |
| 677 | 270.4.3 | CT6 aspects of PS Data Off | 74d? | 2016-12-01 A | 2017-03-14 A | 100% |  |  | finish no earlier than 2017-03-14 | C6 | 592h | 592h | PS_DATA_OFF-CT | 38 | Herrero Veron, Christian (Huawei) | Christian.Herrero at huawei.com | Rel-14 | 74 |  |
| 678 | 270.5 | Charging Aspect for 3GPP PS Data off Function | 137d? | 2016-12-01 A | 2017-06-09 A | 100% |  |  | finish no earlier than 2017-06-09 | S5 | 1096h | 1096h | PS_DATA_OFF-CH | 38 | Huawei， Chen, Shan | chenshan@huawei.com | Rel-14 | 74 |  |
| 679 | 271 | SCC AS Restoration | 208d? | 2016-03-02 A | 2016-12-15 A | 100% |  |  | finish no earlier than 2016-12-15 | C4 | 1664h | 1664h | SCCAS_RES | 36 | China Mobile, Hao Zhang, | zhanghao@chinamobile.com | Rel-14 | 71 |  |
| 680 | 272 | Paging Policy Enhancements and Procedure | 22d? | 2016-02-01 A | 2016-03-01 A | 100% |  |  | finish no earlier than 2016-03-01 | S1 | 176h | 176h | PPEPO_LTE | 36 | China Unicom, Zhuoyun Zhang | zhangzy910@chinaunicom.cn | Rel-14 | 71 | SP-170549 |
| 681 | 273 | **Enhancement to Flexible Mobile Service Steering** | 355d? | 2015-05-11 A | 2016-09-15 A | 100% |  |  |  |  | 1968h | 1968h | eFMSS | 37 | China Mobile, Lu Lu | lulu@chinamobile.com | Rel-14 | 72 |  |
| 682 | 273.1 | Study on enhancement to FMSS for Rel 14 | 158d? | 2015-05-11 A | 2015-12-16 A | 100% |  |  | finish no earlier than 2015-12-16 | S1 | 1264h | 1264h | FS_eFMSS | 35 | Lu Lu, China Mobile | lulu@chinamobile.com | Rel-14 | 68 |  |
| 683 | 273.2 | Stage 1 of Enhancement to Flexible Mobile Service Steering | 22d? | 2016-02-01 A | 2016-03-01 A | 100% |  |  | start no earlier than 2016-02-01 | S1 | 176h | 176h | eFMSS | 36 | China Mobile, Lu Lu | lulu@chinamobile.com | Rel-14 | 71 |  |
| 684 | 273.3 | Stage 2 of Enhancement to Flexible Mobile Service Steering | 66d? | 2016-06-17 A | 2016-09-15 A | 100% |  |  | finish no earlier than 2016-09-15 | S2 | 528h | 528h | eFMSS | 37 | ZTE, Tricci So |  | Rel-14 | 72 |  |
| 685 | 274 | **Media Handling Extensions of IMS-based Telepresence** | 199d? | 2016-03-01 A | 2016-12-01 | 50% | 99.5d? | 4962d |  |  | 3184h | 1592h | IMS_TELEP_EXT | 36 | Ozgur Oyman, Intel | ozgur.oyman@intel.com | Rel-14 | 71 | SP-170515 |
| 686 | 274.1 | S4 aspects of Media Handling Extensions of IMS-based Telepresence | 199d? | 2016-03-01 A | 2016-12-01 A | 100% |  |  | finish no earlier than 2016-12-01 | S4 | 1592h | 1592h | IMS_TELEP_EXT | 37 | Ozgur Oyman, Intel | ozgur.oyman@intel.com | Rel-14 | 72 |  |
| 687 | 274.2 | (IETF) Other IETF aspects of IMS_TELEP_EXT | 199d? | 2016-03-01 | 2016-12-01 |  |  | 4962d | finish no earlier than 2016-12-01 | S4-IETF | 1592h |  | IMS_TELEP_EXT | 37 |  | ozgur.oyman@intel.com | Rel-14 | 72 |  |
| 688 | 275 | Improved Streaming QoE Reporting in 3GPP | 273d? | 2016-03-01 A | 2017-03-15 A | 100% |  |  | finish no earlier than 2017-03-15 | S4 | 2184h | 2184h | IQoE | 36 | Zhiming Li, Huawei | Lizhiming@huawei.com | Rel-14 | 71 | SP-170521 |
| 689 | 276 | New GPRS algorithms for EASE | 67d? | 2016-03-15 A | 2016-06-15 A | 100% |  |  | start no earlier than 2016-03-15 | S3 | 536h | 536h | EASE_ALGOs_SA3 | 36 | Tim Evans, Vodafone |  | Rel-14 | 71 |  |
| 690 | 277 | **S8 Home Routing Architecture for VoLTE** | 518d? | 2015-06-18 A | 2017-06-09 A | 100% |  |  |  |  | 7832h | 7832h | V8 | 36 |  |  | Rel-14 | 71 | SP-170522 |
| 691 | 277.1 | Study on S8 Home Routing Architecture | 191d? | 2015-06-18 A | 2016-03-10 A | 100% |  |  | finish no earlier than 2016-03-10 | S2 | 1528h | 1528h | FS_V8 | 35 | Motohiro ABE | motohiro(dot)abe(dot)cu(at) nttdocomo (dot) com | Rel-14 | 68 |  |
| 692 | 277.2 | Study on LI in S8 Home Routing Architecture for VoLTE | 197d? | 2015-09-17 A | 2016-06-17 A | 100% |  |  | finish no earlier than 2016-06-17 | S3 | 1576h | 1576h | FS_LIV8 | 35 | Greg Schumacher (SPRINT) Gregory | Schumacher@sprint.com | Rel-14 | 69 |  |
| 693 | 277.3 | S8 Home Routing Architecture for VoLTE | 135d? | 2016-06-13 A | 2016-12-15 A | 100% |  |  | finish no earlier than 2016-12-15 | S2 | 1080h | 1080h | V8 | 37 | Motohiro ABE | motohiro(dot)abe(dot)cu(at) nttdocomo (dot) com | Rel-14 | 72 |  |

Notes:
- 670: 2/3/16: 0%->100 / Impacted TSs and TRs: 22.030
- 671: 2/3/16: 0%->100 / Impacted TSs and TRs: 22.030
- 672: 28/7/16: 23.702 added; 19/9/16: 0%->60; 1/12/16: FCD:09/16->12/16; 1/12/16: 60%->100 / Impacted TSs and TRs: TR 23.702
- 673: 1/12/16: 0%->100 / Impacted TSs and TRs: 23.401, 23.203, 23.060, 23.228, 23.292, 23.221
- 675: 6/3/17: 0%->95; 5/6/17: 95%->100 / Impacted TSs and TRs: 24.008, 24.301, 27.007, 24.229, 24.368, 24.167
- 676: 6/3/17: 0%->60; 8/6/17: 60%->100 / Impacted TSs and TRs: 29.212, 29.213
- 677: 7/3/17: 0%->100 / Impacted TSs and TRs: 31.102, 31.103, 31.111
- 678: 6/3/17: 0%->70; 6/3/17: FCD:03/17->06/17; 7/6/17: 70%->100 / Impacted TSs and TRs: TS 32.251, TS 32.298, TS 32.299
- 679: 13/6/16: 0%->100 / Impacted TSs and TRs: 23.380
- 680: Impacted TSs and TRs: 22.101
- 681: Impacted TSs and TRs: 22.115, 22.101
- 682: 7/12/15: 70%->100 / Impacted TSs and TRs: 22.808
- 683: Impacted TSs and TRs: 22.115, 22.101
- 684: 19/9/16: 0%->100 / Impacted TSs and TRs: 23.203
- 685: 11/6/16: 0%->10 / Impacted TSs and TRs: 26.223
- 686: 11/6/16: 0%->10; 19/9/16: 10%->60; 1/12/16: 60%->100 / Impacted TSs and TRs: 26.223
- 687: Impacted TSs and TRs: draft-ietf-payload-rtp-h265, -flexible-fec-scheme , draft-ietf-clue-framework , -datachannel, -signalling, -data-model-schema, -protocol, -rtp-mapping, draft-ietf-mmusic-sctp-sdp, -data-channel-sdpneg, draft-ietf-tsvwg-sctp-dtls-encaps
- 688: 11/6/16: 0%->10; 19/9/16: 10%->55. FDC: 12/16->03/17; 1/12/16: 55%->65; 6/3/17: 65%->100 / Impacted TSs and TRs: New 26.909, 26.247, 26.346
- 689: Discussion whether it should be Rel-13. To be concluded at SA#72.; 13/6/16: 0%->60; 1/12/16: 60%->70; 6/3/17: 70%->100 / Impacted TSs and TRs: 55.241, 55.242, 55.243, 55.251, 55.252, 55.253
- 690: Umbrella, created by MCC to group SA2 and SA3 activities
- 691: 07/09/15: 0%->10; 07/09/15: 10%->100; 7/12/15: 100%->10% (mistake?) then 10%->70, FCD: 12/15-?03/16; 7/3/16: 70%->80; 9/6/16: 80%->100 / Impacted TSs and TRs: New TR 23.xxx
- 692: 7/12/15: 0%->45; 28/1/16: 33.827 added; 7/3/16: 45%->55; 19/9/16: 55%->65; 15/12/17: 65%->100 / Impacted TSs and TRs: TR 33.827
- 693: 11/6/16: 0%->60; 19/9/16: 60%->95; 1/12/16: FCD:09/16->12/16; 1/12/16: 95%->100 / Impacted TSs and TRs: TS 23.228, TS 23.167, TS 23.203

| ID | WBS | Task | Duration | Start | Finish | Complete | Constraint | Resources | Work | Actual work | Acronym | PCG approved | WI rapporteur name | WI rapporteur e-mail | Release | TSG approved | Status Report |
| --- | --- | --- | --- | --- | --- | --- | --- | --- | --- | --- | --- | --- | --- | --- | --- | --- | --- |
| 694 | 277.4 | **CT Aspects of V8** | 65d? | 2016-09-16 A | 2016-12-15 A | 100% |  | ct | 1560h | 1560h | V8-CT | 37 | Tsuyoshi Takakura (NTT DOCOMO) | tsuyoshi.takakura.ey@s1.nttdocomo.com | Rel-14 | 73 |  |
| 695 | 277.4.1 | CT1 Aspects of V8 | 65d? | 2016-09-16 A | 2016-12-15 A | 100% | finish no earlier than 2016-12-15 | C1 | 520h | 520h | V8-CT | 37 | Tsuyoshi Takakura (NTT DOCOMO) | tsuyoshi.takakura.ey@s1.nttdocomo.com | Rel-14 | 73 |  |
| 696 | 277.4.2 | CT3 Aspects of V8 | 65d? | 2016-09-16 A | 2016-12-15 A | 100% | finish no earlier than 2016-12-15 | C3 | 520h | 520h | V8-CT | 37 | Tsuyoshi Takakura (NTT DOCOMO) | tsuyoshi.takakura.ey@s1.nttdocomo.com | Rel-14 | 73 |  |
| 697 | 277.5 | Charging Aspects of S8 Home Routing Architecture for VoLTE | 261d? | 2016-06-13 A | 2017-06-09 A | 100% | finish no earlier than 2017-06-09 | S5 | 2088h | 2088h | CH14-V8 | 37 | Chen, Ai (China Mobile) | chenai(at) chinamobile (dot) com | Rel-14 | 72 |  |
| 698 | 278 | **Improvements of awareness of user location change** | 453d? | 2015-09-17 A | 2017-06-09 A | 100% |  |  | 5256h | 5256h | AULC | 37 | Yang Xu | xuyang49@chinaunicom.cn | Rel-14 | 72 | SP-170524 |
| 699 | 278.1 | Study on improvement of awareness of user location change | 197d? | 2015-09-17 A | 2016-06-17 A | 100% | finish no earlier than 2016-06-17 | S2 | 1576h | 1576h | FS_AULC | 35 | Yang Xu | xuyang49@chinaunicom.cn | Rel-14 | 69 |  |
| 700 | 278.2 | Improvements of awareness of user location change | 75d? | 2016-06-06 A | 2016-09-15 A | 100% | finish no earlier than 2016-09-15 | S2 | 600h | 600h | AULC | 37 | Yang Xu | xuyang49@chinaunicom.cn | Rel-14 | 72 |  |
| 701 | 278.3 | **CT Aspect of AULC** | 65d? | 2016-09-16 A | 2016-12-15 A | 100% |  | ct | 1560h | 1560h | AULC-CT | 37 | Huawei, Wu Yizhuang | wuyizhuang@huawei.com | Rel-14 | 73 |  |
| 702 | 278.3.1 | CT3 Aspect of AULC | 65d? | 2016-09-16 A | 2016-12-15 A | 100% | finish no earlier than 2016-12-15 | C3 | 520h | 520h | AULC-CT | 37 | Huawei, Wu Yizhuang | wuyizhuang@huawei.com | Rel-14 | 73 |  |
| 703 | 278.3.2 | CT4 Aspect of AULC | 65d? | 2016-09-16 A | 2016-12-15 A | 100% | finish no earlier than 2016-12-15 | C4 | 520h | 520h | AULC-CT | 37 | Huawei, Wu Yizhuang | wuyizhuang@huawei.com | Rel-14 | 73 |  |
| 704 | 278.4 | Charging Aspects of Improvements of AULC | 190d? | 2016-09-19 A | 2017-06-09 A | 100% | finish no earlier than 2017-06-09 | S5 | 1520h | 1520h | AULC-CH | 37 | Huawei， Chen, Shan | chenshan@huawei.com | Rel-14 | 73 |  |
| 705 | 279 | **Service Domain Centralization** | 232d? | 2015-11-02 A | 2016-09-19 A | 100% |  | S2 | 3896h | 3896h | SeDoC | 37 | Chris Joul (T-Mobile USA) | chris (dot) joul (at) t (dash) mobile (dot) com | Rel-14 | 72 |  |
| 706 | 279.1 | Study on Service Domain Centralization | 230d? | 2015-11-02 A | 2016-09-15 A | 100% | finish no earlier than 2016-09-15 | S2 | 1840h | 1840h | FS_SeDoC | 36 | Chris Joul (T-Mobile USA) | chris (dot) joul (at) t (dash) mobile (dot) com | Rel-14 | 70 |  |
| 707 | 279.2 | Service Domain Centralization | 25d? | 2016-08-16 A | 2016-09-19 A | 100% | finish no earlier than 2016-09-19 | S2 | 200h | 200h | SeDoC | 37 | Chris Joul (T-Mobile USA) | chris (dot) joul (at) t (dash) mobile (dot) com | Rel-14 | 73 |  |
| 708 | 280 | **Sponsored data connectivity improvements** | 295d? | 2015-11-02 A | 2016-12-15 A | 100% |  |  | 2880h | 2880h | SDCI | 37 | Yang Xu | xuyang49@chinaunicom.cn | Rel-14 | 72 | SP-170523 |
| 709 | 280.1 | Study on sponsored data connectivity improvements | 160d? | 2015-11-02 A | 2016-06-10 A | 100% | finish no earlier than 2016-06-10 | S2 | 1280h | 1280h | FS_SDCI | 36 | Yang Xu | xuyang49@chinaunicom.cn | Rel-14 | 70 |  |
| 710 | 280.2 | Sponsored data connectivity improvements | 70d? | 2016-06-13 A | 2016-09-15 A | 100% | finish no earlier than 2016-09-15 | S2 | 560h | 560h | SDCI | 37 | Yang Xu | xuyang49@chinaunicom.cn | Rel-14 | 72 |  |
| 711 | 280.3 | **CT Aspects of SDCI** | 65d? | 2016-09-16 A | 2016-12-15 A | 100% |  | ct | 1040h | 1040h | SDCI-CT | 37 | China Unicom, Xu, Yang | xuyang49@chinaunicom.cn | Rel-14 | 73 |  |
| 712 | 280.3.1 | CT3 Aspects of SDCI | 65d? | 2016-09-16 A | 2016-12-15 A | 100% | finish no earlier than 2016-12-15 | C3 | 520h | 520h | SDCI-CT | 37 | China Unicom, Xu, Yang | xuyang49@chinaunicom.cn | Rel-14 | 73 |  |
| 713 | 281 | **Stage-3 SAE Protocol Development - Phase 5** | 272d? | 2016-03-02 A | 2017-03-15 A | 100% |  | C1 | 8704h | 8704h | SAES5 | 36 | Interdigital, Aghili, Behrouz | Behrouz.aghili@interdigital.com | Rel-14 | 71 |  |
| 714 | 281.1 | SAES5 CS Fallback in EPS | 272d? | 2016-03-02 A | 2017-03-15 A | 100% | start no earlier than 2016-03-02 | C1 | 2176h | 2176h | SAES5-CSFB | 36 | Interdigital, Aghili, Behrouz | Behrouz.aghili@interdigital.com | Rel-14 | 71 |  |
| 715 | 281.2 | SAES5 for support for non-3GPP accesses | 272d? | 2016-03-02 A | 2017-03-15 A | 100% | start no earlier than 2016-03-02 | C1 | 2176h | 2176h | SAES5-non3GPP | 36 | Interdigital, Aghili, Behrouz | Behrouz.aghili@interdigital.com | Rel-14 | 71 |  |
| 716 | 281.3 | SAE Protocol Development (Stage 3) - Phase 5 | 272d? | 2016-03-02 A | 2017-03-15 A | 100% | start no earlier than 2016-03-02 | C1 | 2176h | 2176h | SAES5 | 37 |  |  | Rel-14 | 72 |  |
| 717 | 282 | **Group based enhancements in the network capability exposure functions** | 296d? | 2015-11-02 A | 2016-12-16 A | 100% |  | S2 | 4752h | 4752h | GENCEF | 36 | Samsung, Sung Hwan Won | sunghwan.won@samsung.com | Rel-14 | 70 | SP-170517 |
| 718 | 282.1 | Study on group based enhancements in the network capability exposure functions | 160d? | 2015-11-02 A | 2016-06-10 A | 100% | start no earlier than 2015-11-02 | S2 | 1280h | 1280h | FS_GENCEF | 36 | Samsung, Sung Hwan Won | sunghwan.won@samsung.com | Rel-14 | 70 |  |
| 719 | 282.2 | Group based enhancements in the network capability exposure functions | 138d? | 2016-06-09 A | 2016-12-16 A | 100% | finish no earlier than 2016-12-16 | S2 | 1104h | 1104h | GENCEF | 37 | Samsung, Sunghoon Kim | s.hun.kim@samsung.com | Rel-14 | 72 |  |

Notes:
- 695: 2/12/16: 40%->100 / Impacted TSs and TRs: 24.229
- 696: 2/12/16: 40%->100 / Impacted TSs and TRs: 29.212, 29.213, 29.214
- 697: 19/9/16: 0%->15; 1/12/16: FCD:12/16->03/17; 1/12/16: 15%->60; 1/12/16: WID:SP-160429->SP-160838; 6/3/17: FCD:03/17->06/17; 7/6/17: 60%->100 / Impacted TSs and TRs: 32.240, 32.251, 32.260
- 699: 7/12/15: 0%->40; 7/3/16: 40%->70; 9/6/16: 70%->100 / Impacted TSs and TRs: 23.710
- 700: 11/6/16: 0%->10; 19/9/16: 10%->100 / Impacted TSs and TRs: 23.401, 23.203, 23.060
- 702: 2/12/16: 0%->10; 6/3/17: 10%->100 / Impacted TSs and TRs: 29.212, 29.213
- 703: 2/12/16: 0%->95; 6/3/17: 95%->100 / Impacted TSs and TRs: 29.274
- 704: 1/12/16: 0%->40; 6/3/17: 40%->80; 6/3/17: FCD:03/17->06/17; 7/6/17: 80%->100 / Impacted TSs and TRs: TS32.251, TS32.298, TS32.299
- 706: Comes back from previous release; 28/1/16: 23.719 added; 7/3/16: 0%->30; 7/3/16: WID:SP-150626->SP-1601679/6/16: 30%->70; 11/6/16: WID:SP-160167->SP-160306. FCD: 06/16->09/16; 1/12/16: 70%->100 / Impacted TSs and TRs: 23.719
- 707: 19/9/16: 0%->100 / Impacted TSs and TRs: 23.292, 23.167
- 709: 28/1/16: 23.721 added; 7/3/16: 10%->40; 9/6/16: 40%->100 / Impacted TSs and TRs: 23.721
- 710: 19/9/16: 0%->100 / Impacted TSs and TRs: 23.203, 23.682
- 711: 6/10/16: 29.251 added; / Impacted TSs and TRs: 29.251
- 712: 6/10/16: 29.250 added; 2/12/16: 10%->30; 6/3/17: 30%->80; 5/6/17: 80%->100 / Impacted TSs and TRs: 29.212, 29.213, 29.214, 29.201, 29.250
- 713: Impacted TSs and TRs: 23.122, 24.008, 24.167, 24.229, 24.301, 24.302, 24.303, 24.304, 24.305, 24.312, 29.018, 29.118
- 714: 11/6/16: 0%->5; 16/9/16: 5%->20; 2/12/16: 20%->70; 6/3/17: 70%->100 / Impacted TSs and TRs: 23.122, 24.008, 24.167, 24.229, 24.301, 24.302, 24.303, 24.304, 24.305, 24.312, 29.018, 29.118
- 715: 11/6/16: 0%->15; 16/9/16: 15%->20; 2/12/16: 20%->85; 6/3/17: 85%->100 / Impacted TSs and TRs: 23.122, 24.008, 24.167, 24.229, 24.301, 24.302, 24.303, 24.304, 24.305, 24.312, 29.018, 29.118
- 716: Added following CT1's chair e-mail 14/06/16; 16/9/16: 0%->20; 2/12/16: 20%->85; 6/3/17: 85%->100
- 718: 28/1/16: 23.773 added; 28/1/16: 23.742 added; 7/3/16: 0%->10; 9/6/16: 10%->100 / Impacted TSs and TRs: 23.xyz; 23.773; 23.742
- 719: 19/9/16: 0%->90; 1/12/16: FCD:09/16->12/16; 1/12/16: 90%->100 / Impacted TSs and TRs: 23.682

| ID | WBS | Task | Duration | Start | Finish | Complete | Remaining | Total slack | Constraint | Resources | Work | Actual work | Acronym | PCG approved | Release | TSG approved | WI rapporteur name | WI rapporteur e-mail | Status Report |
| --- | --- | --- | --- | --- | --- | --- | --- | --- | --- | --- | --- | --- | --- | --- | --- | --- | --- | --- | --- |
| 720 | 283 | **Robust Call Setup for VoLTE subscriber in LTE** | 620d? | 2015-11-02 A | 2018-03-15 | 90% | 59.35d? | 4627d |  |  | 9680h | 6964.8h | RobVoLTE | 37 | Rel-14 | 72 |  |  |  |
| 721 | 283.1 | Study on Robust Call Setup for VoLTE subscriber in LTE | 160d? | 2015-11-02 A | 2016-06-10 A | 100% |  |  | start no earlier than 2015-11-02 | S2 | 1280h | 1280h | FS_RobVoLTE | 36 | Rel-14 | 70 | Xiaobo Wu, Huawei | wuxiaobo@ huawei.com |  |
| 722 | 283.2 | Robust Call Setup for VoLTE subscriber in LTE | 66d? | 2016-06-17 A | 2016-09-15 A | 100% |  |  | finish no earlier than 2016-09-15 | S2 | 528h | 528h | RobVoLTE |  | Rel-14 | 72 | Xiaobo Wu, Huawei | wuxiaobo@ huawei.com |  |
| 723 | 283.3 | CT Aspects of RobVoLTE | 130d? | 2016-09-16 A | 2017-03-16 A | 100% |  |  | finish no earlier than 2017-03-16 | C1 | 1040h | 1040h | RobVoLTE-CT | 37 | Rel-14 | 73 | PATEL, Milan | Milan.Patel@huawei.com |  |
| 724 | 283.4 | **Voice and Video Enhancement for LTE** | 391d? | 2016-09-15 A | 2018-03-15 | 76% | 94.03d? | 4627d |  | R2 | 5736h | 3020.8h | LTE_VoLTE_ViLTE_enh | 37 | Rel-14 | 73 | CMCC |  |  |
| 725 | 283.4.1 | Core part: Voice and Video Enhancement for LTE | 130d? | 2016-09-15 A | 2017-03-15 A | 100% |  |  | finish no earlier than 2017-03-15 | R2 | 1040h | 1040h | LTE_VoLTE_ViLTE_enh-Core | 37 | Rel-14 | 73 | CMCC |  | RP-170323 |
| 726 | 283.4.2 | UE Conformance Test Aspects –Voice and Video Enhancement for LTE | 196d? | 2017-06-15 A | 2018-03-15 | 60% | 78.4d? | 4627d | finish no earlier than 2018-03-15 | R5 | 1568h | 940.8h | LTE_VoLTE_ViLTE_enh-UEConTest | 39 | Rel-14 | 76 | CATT |  |  |
| 727 | 283.5 | RAN-Assisted Codec Adaptation in MTSI | 137d? | 2016-12-01 A | 2017-06-09 A | 100% |  |  | finish no earlier than 2017-06-09 | S4 | 1096h | 1096h | LTE_VoLTE_ViLTE_enh-S4 | 38 | Rel-14 | 74 | Ozgur Oyman, Intel | ozgur.oyman@intel.com | SP-170516 |
| 728 | 284 | Extension of UE Delay test methods and requirements | 261d? | 2016-06-13 A | 2017-06-09 A | 100% |  |  | finish no earlier than 2017-06-09 | S4 | 2088h | 2088h | EXT_UED | 37 | Rel-14 | 72 | Stéphane Ragot, ORANGE | stephane.ragot@orange.com | SP-170345 |
| 729 | 285 | **Improved operator control using new UE configuration parameters** | 199d? | 2016-06-13 A | 2017-03-15 A | 100% |  |  |  |  | 3184h | 3184h | IOC_UE_conf | 37 | Rel-14 | 72 | Sedlacek, Ivo | ivo.sedlacek@ericsson.com | CP-171176 |
| 730 | 285.1 | CT1 aspects of IOC_UE_conf | 199d? | 2016-06-13 A | 2017-03-15 A | 100% |  |  | finish no earlier than 2017-03-15 | C1 | 1592h | 1592h | IOC_UE_conf | 37 | Rel-14 | 72 | Sedlacek, Ivo | ivo.sedlacek@ericsson.com |  |
| 731 | 285.2 | CT6 aspects of IOC_UE_conf | 199d? | 2016-06-13 A | 2017-03-15 A | 100% |  |  | finish no earlier than 2017-03-15 | C6 | 1592h | 1592h | IOC_UE_conf | 37 | Rel-14 | 72 | Adrian Buckley | abuckley@blackberry.com |  |
| 732 | 286 | Shared Subscription Data Update | 135d? | 2016-06-13 A | 2016-12-15 A | 100% |  |  | finish no earlier than 2016-12-15 | C4 | 1080h | 1080h | eSDU | 37 | Rel-14 | 72 | Nokia, Ulrich Wiehe | ulrich.wiehe@nokia.com | CP-171050 |
| 733 | 287 | **Rel-14 Charging** | 335d? | 2016-03-01 A | 2017-06-09 A | 100% |  |  |  | S5 | 8544h | 8544h | CH14 | 36 | Rel-14 | 71 |  |  |  |
| 734 | 287.1 | Resource Optimization for PS Domain Online | 335d | 2016-03-01 A | 2017-06-09 A | 100% |  |  | finish no earlier than 2017-06-09 | S5 | 2680h | 2680h | CH14-ROPOCH | 36 | Rel-14 | 71 | Shrader, David(Ericsson) | david.shrader@ericsson.com |  |
| 735 | 287.2 | Charging for SMS via T4 | 137d? | 2016-12-01 A | 2017-06-09 A | 100% |  |  | finish no earlier than 2017-06-09 | S5 | 1096h | 1096h | CH14-SMST4 | 38 | Rel-14 | 74 | Nokia | Maryse <dot> Gardella <at> Nokia <dot> com |  |
| 736 | 287.3 | Charging Aspects of Enhanced Proximity-based Services | 261d? | 2016-06-13 A | 2017-06-09 A | 100% |  |  | finish no earlier than 2017-06-09 | S5 | 2088h | 2088h | CH14-ProSe | 37 | Rel-14 | 72 | Chen, Shan | chenshan@huawei.com | SP-170408 |
| 737 | 288 | **Determination of Completeness of Charging Information in IMS** | 261d? | 2016-06-13 A | 2017-06-09 A | 100% |  |  |  | S5 | 5952h | 5952h | CH14-DCCII | 37 | Rel-14 | 72 | Jesske, Roland (Deutsche Telekom) |  |  |
| 738 | 288.1 | Determination of Completeness of Charging Information in IMS | 261d? | 2016-06-13 A | 2017-06-09 A | 100% |  |  | finish no earlier than 2017-06-09 | S5 | 2088h | 2088h | CH14-DCCII | 37 | Rel-14 | 72 | Jesske, Roland (Deutsche Telekom) |  | SP-170344 |
| 739 | 288.2 | **CT Aspects of Determination of Completeness of Charging Information in IMS** | 74d? | 2016-12-01 A | 2017-03-14 A | 100% |  |  |  | ct | 1776h | 1776h | CH14-DCCII-CT | 38 | Rel-14 | 74 | Michael KREIPL, Deutsche Telekom | michael(dot)kreipl(at)telekom(dot)de | CP-171048 |
| 740 | 288.2.1 | CT1 Aspects of Determination of Completeness of Charging Information in IMS | 74d? | 2016-12-01 A | 2017-03-14 A | 100% |  |  | finish no earlier than 2017-03-14 | C1 | 592h | 592h | CH14-DCCII-CT | 38 | Rel-14 | 74 | Michael KREIPL, Deutsche Telekom | michael(dot)kreipl(at)telekom(dot)de |  |
| 741 | 288.2.2 | CT3 Aspects of Determination of Completeness of Charging Information in IMS | 74d? | 2016-12-01 A | 2017-03-14 A | 100% |  |  | finish no earlier than 2017-03-14 | C3 | 592h | 592h | CH14-DCCII-CT | 38 | Rel-14 | 74 | Michael KREIPL, Deutsche Telekom | michael(dot)kreipl(at)telekom(dot)de |  |
| 742 | 289 | **Enhanced LAA for LTE** | 589d? | 2015-12-15 A | 2018-03-15 | 78% | 126.97d? | 4627d |  |  | 9432h | 7398.8h | LTE_eLAA | 36 | Rel-14 | 70 | Ericsson |  |  |
| 743 | 289.1 | Core part: Enhanced LAA for LTE | 328d? | 2015-12-15 A | 2017-03-15 A | 100% |  |  | finish no earlier than 2017-03-15 | R1 | 2624h | 2624h | LTE_eLAA-Core | 36 | Rel-14 | 70 | Ericsson |  | RP-170269 |
| 744 | 289.2 | Perf. part: Enhanced LAA for LTE | 460d? | 2015-12-15 A | 2017-09-15 A | 100% |  |  | finish no earlier than 2017-09-15 | R4 | 3680h | 3680h | LTE_eLAA-Perf | 36 | Rel-14 | 70 | Ericsson |  |  |
| 745 | 289.3 | UE Conformance Test Aspects - Enhanced LAA for LTE | 391d? | 2016-09-15 A | 2018-03-15 | 35% | 254.15d? | 4627d | finish no earlier than 2018-03-15 | R5 | 3128h | 1094.8h | LTE_eLAA-UEConTest | 37 | Rel-14 | 73 | Intel |  |  |

Notes:
- 721: 28/1/16: 23.750 added; 7/3/16: 0%->20; 9/6/16: 20%->100 / Impacted TSs and TRs: 23.8xx; 23.750
- 722: 19/9/16: 0%->100. 1/12/16: UID changed: 720085 -> 720301 (720085 was also used for RP-161181) / Impacted TSs and TRs: 23.228, 23.237
- 723: 2/12/16: 0%->80; 6/3/17: 80%->100 / Impacted TSs and TRs: 24.229, 24.292
- 725: ; 20/12/16: Compl:0%->80%; 21/3/17: Compl:80%->100%; 21/3/17: Stat Rep: ->RP-170323
- 726: ; 19/9/17: Compl:0%->20%; 8/1/18: Compl:20%->60%; ...
- 727: 6/3/17: 0%->65; 6/3/17: FCD:03/17->06/17; 7/6/17: 65%->100
- 728: 19/9/16: WID:SP-160271->SP-160600; 19/9/16: 0%->20; 1/12/16: 20%->30; 14/12/16: 30%->50; 6/3/17: 50%->60; 6/3/17: FCD:03/17->06/17; 7/6/17: 60%->100 / Impacted TSs and TRs: TR 26.954, 26.131, 26.132
- 729: 11/6/16: 0%->10; 17/10/16: WID:CP-160296->CP-160374; 5/12/16: WID:CP-160374->CP-160828 / Impacted TSs and TRs: 24.167, 24.229, 24.301, 24.302, 24.312, 24.341, 24.368, 24.607, 24.623, TS 24.XXX, TS 24.YYY
- 730: 11/6/16: 0%->10; 16/9/16: 10%->20; 17/10/16: WID:CP-160296->CP-160374; 2/12/16: 20%->75; 6/3/17: 75%->100 / Impacted TSs and TRs: 24.167, 24.229, 24.301, 24.302, 24.312, 24.341, 24.368, 24.607, 24.623, 24.275
- 731: 11/6/16: 0%->10; 14/12/16: 0%->15; 7/3/17: 15%->85; 5/6/17: 85%->100 / Impacted TSs and TRs: 31.102, 31.103
- 732: 13/6/16: 0%->25; 2/12/16: 25%->100; 5/12/16: WID:CP-160243->CP-160644 / Impacted TSs and TRs: 29.272, 29.002, 29.305, 29.230
- 733: Umbrella Feature
- 734: 13/6/16: 0%->10. FCD:09/16->03/17; 19/9/16: FCD: 09/16->03/17; 19/9/16: 10%->20; 1/12/16: 20%->50; 6/3/17: 50%->80; 6/3/17: FCD:03/17->06/20; 7/6/17: 80%->100 / Impacted TSs and TRs: 32.251, 32.299
- 735: 6/3/17: 0%->20; 6/3/17: FCD:03/17->06/17; 7/6/17: 20%->100 / Impacted TSs and TRs: TS 32.274, TS 32.250 , TS 32.298, TS 32.299
- 736: 19/9/16: 0%->40; 1/12/16: 40%->60; 6/3/17: FCD:03/17->06/17; 6/3/17: 60%->80; 7/6/17: 80%->100 / Impacted TSs and TRs: 32.240, 32.251, 32.277, 32.298, 32.299
- 737: 19/9/16: 0%->10 / Impacted TSs and TRs: 32.240, 32.260, 32.298, 32.299
- 738: 19/9/16: 0%->10; 6/3/17: FCD:03/17->06/17; 7/6/17: 10%->100 / Impacted TSs and TRs: 32.240, 32.260, 32.298, 32.299
- 740: 2/12/16: 0%->10; 6/3/17: 10%->35; 5/6/17: 35%->100 / Impacted TSs and TRs: 24.229
- 741: 8/6/17: 0%->100 / Impacted TSs and TRs: 29.165
- 743: 22/3/16: Compl:0%->20%22/3/16: WID: RP-152272->RP-1604071/7/16: Compl:20%->60%1/7/16: WID: RP-160407->RP-160881; 26/9/16: Compl:60%->92%; 26/9/16: CD:Thu 15/09/16->Thu 15/12/16; 26/9/16: WID: ; 20/12/16: Compl:92%->97%; 20/12/16:21/3/17: Compl:...
- 744: 22/3/16: WID: RP-152272->RP-160407; 1/7/16: WID: RP-160407->RP-16088126/9/16: CD:Wed 15/03/17->Thu 15/06/1726/9/16: WID: RP-160881->RP-161832; 20/12/16: WID: RP-161832->RP-162235;21/3/17: Compl:0%->33%; 19/6/17: Compl:33%->50%; ...; ;...
- 745: ; 21/3/17: Compl:0%->5% ;...19/6/17: Compl:5%->6%; 19/9/17: Compl...; 8/1/18: C...

| ID | WBS | Task | Duration | Start | Finish | Complete | Remaining | Total slack | Constraint | Resources | Work | Actual work | Acronym | PCG approved | WI rapporteur name | Release | TSG approved | Status Report | Impacted TSs and TRs |
| --- | --- | --- | --- | --- | --- | --- | --- | --- | --- | --- | --- | --- | --- | --- | --- | --- | --- | --- | --- |
| 746 | 290 | **RRC optimization for UMTS** | 199d? | 2015-12-15 A | 2016-09-15 A | 100% |  |  |  | R2 | 3184h | 3184h | UTRA_RRCopt | 36 | Ericsson | Rel-14 | 70 |  |  |
| 747 | 290.1 | Core part: RRC optimization for UMTS | 199d? | 2015-12-15 A | 2016-09-15 A | 100% |  |  | finish no earlier than 2016-09-15 | R2 | 1592h | 1592h | UTRA_RRCopt-Core | 36 | Ericsson | Rel-14 | 70 | RP-172758 |  |
| 748 | 291 | **DTX/DRX enhancements in CELL_FACH** | 264d? | 2015-12-15 A | 2016-12-15 A | 100% |  |  |  | R2 | 4224h | 4224h | FACH_DTXDRX | 36 | Huawei | Rel-14 | 70 |  |  |
| 749 | 291.1 | Core part: DTX/DRX enhancements in CELL_FACH | 264d? | 2015-12-15 A | 2016-12-15 A | 100% |  |  | finish no earlier than 2016-12-15 | R2 | 2112h | 2112h | FACH_DTXDRX-Core | 36 | Huawei | Rel-14 | 70 | RP-162132 |  |
| 750 | 292 | **AWS-3/4 Band for LTE** | 264d? | 2015-12-15 A | 2016-12-15 A | 100% |  |  |  |  | 2640h | 2640h | LTE_AWS_3_4 | 36 | Dish Network | Rel-14 | 70 |  |  |
| 751 | 292.1 | Core part: AWS-3/4 Band for LTE | 132d? | 2015-12-15 A | 2016-06-15 A | 100% |  |  | finish no earlier than 2016-09-15 | R4 | 1056h | 1056h | LTE_AWS_3_4-Core | 36 | Dish Network | Rel-14 | 70 |  | 36.749 |
| 752 | 292.2 | Perf. part: AWS-3/4 Band for LTE | 132d? | 2015-12-15 A | 2016-06-15 A | 100% |  |  | finish no earlier than 2016-09-15 | R4 | 1056h | 1056h | LTE_AWS_3_4-Perf | 36 | Dish Network | Rel-14 | 70 |  |  |
| 753 | 292.3 | UE Conformance Test Aspects – AWS-3/4 Band for LTE (Band 70) | 66d? | 2016-09-15 A | 2016-12-15 A | 100% |  |  | finish no earlier than 2017-03-15 | R5 | 528h | 528h | LTE_AWS_3_4-UEConTest | 37 | Dish Network | Rel-14 | 73 |  |  |
| 754 | 293 | **LTE FDD in the Bands 1980-2010 MHz and 2170-2200MHz for Region 3** | 1d? | 2015-12-15 | 2015-12-15 |  |  | 5215d |  | R4 | 16h |  | LTE_1980_2170_REG3 | 36 | KT Corp. | Rel-14 | 70 |  |  |
| 755 | 293.1 | Core part: LTE FDD in the Bands 1980-2010 MHz and 2170-2200MHz for Region 3 | 1d? | 2015-12-15 | 2015-12-15 |  |  | 5215d | finish no earlier than 2015-12-15 | R4 | 8h |  | LTE_1980_2170_REG3-Core | 36 | KT Corp. | Rel-14 | 70 |  |  |
| 756 | 294 | **Addition of 1.4 and 3 MHz Channel Bandwidth to E-UTRA operating band 65 for CGC (Complementary Ground Component) operations in Region 1** | 197d? | 2016-12-15 A | 2017-09-15 | 99% | 0d? | 0d |  | R4 | 2632h | 1576h | LTE_1980_2170_REG1_addBWs | 38 | Hughes Network Systems | Rel-14 | 74 |  |  |
| 757 | 294.1 | Core part: Addition of 1.4 and 3 MHz Channel Bandwidth to E-UTRA operating band 65 for CGC (Complementary Ground Component) operations in Region 1 | 65d? | 2016-12-15 A | 2017-03-15 A | 100% |  |  | finish no earlier than 2017-03-15 | R4 | 520h | 520h | LTE_1980_2170_REG1_addBWs-Core | 38 | Hughes Network Systems | Rel-14 | 74 |  |  |
| 758 | 294.2 | UE Conformance Test Aspects – Addition of 1.4 and 3 MHz Channel Bandwidth to E-UTRA operating band 65 for CGC (Complementary Ground Component) operations in Region 1 | 67d? | 2017-06-15 A | 2017-09-15 A | 100% |  |  | finish no earlier than 2017-09-15 | R5 | 536h | 536h | LTE_1980_2170_REG1_addBWs-UEConTest | 39 | Dish Network | Rel-14 | 76 |  |  |
| 759 | 295 | **LTE 2.6 GHz FDD Supplemental DL band (2570-2620 MHz) and LTE Carrier Aggregation (2DL/1UL) with Band 3 for region 1** | 525d? | 2015-12-15 A | 2017-12-15 | 99% | 0d? | 0d |  | R4 | 7896h | 4748.02h | LTE_FDD_2600_CA_B3 | 36 | Orange | Rel-14 | 70 |  |  |
| 760 | 295.1 | Core part: LTE 2.6 GHz FDD Supplemental DL band (2570-2620 MHz) and LTE Carrier Aggregation (2DL/1UL) with Band 3 for region 1 | 132d? | 2015-12-15 A | 2016-06-15 A | 100% |  |  | finish no earlier than 2016-09-15 | R4 | 1056h | 1056h | LTE_FDD_2600_CA_B3-Core | 36 | Orange | Rel-14 | 70 |  | 36.858 |
| 761 | 295.2 | Perf. part: LTE 2.6 GHz FDD Supplemental DL band (2570-2620 MHz) and LTE Carrier Aggregation (2DL/1UL) with Band 3 for region 1 | 132d? | 2015-12-15 A | 2016-06-15 A | 100% |  |  | finish no earlier than 2016-09-15 | R4 | 1056h | 1056h | LTE_FDD_2600_CA_B3-Perf | 36 | Orange | Rel-14 | 70 |  |  |
| 762 | 295.3 | UE Conformance Test Aspects - LTE 2.6 GHz FDD SDL band (2570-2620 MHz) and LTE Carrier Aggregation (2DL/1UL) with Band 3 for Region 1 (Band 69) | 198d? | 2017-03-15 A | 2017-12-15 A | 100% |  |  | finish no earlier than 2017-12-15 | R5 | 1584h | 1584h | LTE_FDD_2600_CA_B3-UEConTest |  | Bureau Veritas | Rel-14 |  |  |  |
| 763 | 296 | **Multi-Band Base Station testing with three or more bands** | 264d? | 2015-12-15 A | 2016-12-15 A | 100% |  |  |  | R4 | 6336h | 6336h | MB_BS_test_3B | 36 | Alcatel-Lucent | Rel-14 | 70 |  |  |
| 764 | 296.1 | Core part: Multi-Band Base Station testing with three or more bands | 264d? | 2015-12-15 A | 2016-12-15 A | 100% |  |  | finish no earlier than 2016-12-15 | R4 | 2112h | 2112h | MB_BS_test_3B-Core | 36 | Alcatel-Lucent | Rel-14 | 70 | RP-162032 | 37.871 |
| 765 | 296.2 | Perf. part: Multi-Band Base Station testing with three or more bands | 264d? | 2015-12-15 A | 2016-12-15 A | 100% |  |  | finish no earlier than 2016-12-15 | R4 | 2112h | 2112h | MB_BS_test_3B-Perf | 36 | Alcatel-Lucent | Rel-14 | 70 |  |  |
| 766 | 297 | **Performance enhancements for high speed scenario in LTE** | 655d? | 2015-12-15 A | 2018-06-15 | 83% | 108.95d? | 4561d |  | R4 | 13128h | 9161.83h | LTE_high_speed | 36 | NTT DOCOMO | Rel-14 | 70 |  |  |
| 767 | 297.1 | Core part: Performance enhancements for high speed scenario in LTE | 264d? | 2015-12-15 A | 2016-12-15 A | 100% |  |  | finish no earlier than 2016-12-15 | R4 | 2112h | 2112h | LTE_high_speed-Core | 36 | NTT DOCOMO | Rel-14 | 70 | RP-162222 |  |
| 768 | 297.2 | Perf. part: Performance enhancements for high speed scenario in LTE | 394d? | 2015-12-15 A | 2017-06-15 A | 100% |  |  | finish no earlier than 2017-06-15 | R4 | 3152h | 3152h | LTE_high_speed-Perf | 36 | NTT DOCOMO | Rel-14 | 70 |  |  |
| 769 | 297.3 | UE Conformance Test Aspects - Performance enhancements for high speed scenario in LTE | 328d? | 2017-03-15 A | 2018-06-15 | 50% | 164d? | 4561d | finish no earlier than 2018-06-15 | R5 | 2624h | 1312h | LTE_high_speed-UEConTest | 38 | CMCC | Rel-14 | 75 |  |  |

Notes:
- 747: 22/3/16: Compl:0%->8%; 1/7/16: Compl:8%->70%26/9/16: Compl:70%->100%; 8/1/18: Stat Rep: ->RP-172758
- 749: 22/3/16: Compl:0%->20%; 1/7/16: Compl:20%->50%26/9/16: Compl:50%->65%; 20/12/16: Compl:65%->100%;
- 751: ; 22/3/16: Compl:0%->60%; 1/7/16: Compl:60%->100%; 1/7/16: CD:Th
- 752: 1/7/16: Compl:0%->100%1/7/16: CD:Thu 15/09/16->Wed 15/06
- 753: ; 20/12/16: Compl:0%->100%;
- 757: ; 21/3/17: Compl:0%->100% ; 2...
- 758: ; 19/9/17: Compl:0%->100%
- 760: 28/1/16: 36.858 added;22/3/16: Compl:0%->40%22/3/16: WID: RP-152253->RP-160378; 1/7/16: Compl:40%->100%;
- 761: ; 22/3/16: WID: RP-152253->RP-1603781/7/16: Compl:0%->100%1/7/16
- 762: ; 19/9/17: Compl:43%->96%; ;...; 8/1/18: Compl:96%->100%; ...
- 764: 22/3/16: Compl:0%->50%22/3/16: WID: RP-152205->RP-1600631/7/16: Compl:50%->90%; 26/9/16: Compl:90%->95%; 26/9/16; 20/12/16: Compl:95%->100%;
- 765: 22/3/16: Compl:0%->5%22/3/16: WID: RP-152205->RP-160063; 1/7/16: Compl:5%->30%26/9/16: Compl:30%->60%26/; 20/12/16: Compl:60%->100%;
- 767: 22/3/16: Compl:0%->5%22/3/16: WID: RP-152263->RP-160172; 1/7/16: Compl:5%->25%26/9/16: Compl:25%->45%20/12/16: Compl:45%->100%20/12/16: Stat Rep: ->RP-162222
- 768: 22/3/16: WID: RP-152263->RP-1601721/7/16: Compl:0%->20%; 26/9/16: Compl:20%->25%; 20/12/16: Compl:25%->35% ; 21/3/17: Compl:35%->70%; 19/6/17: Compl:70%->100%; 19/6/17: WID: RP-160172->RP-171039
- 769: tested: REL-14 LTE_high_speed-Core;; 19/6/17: Compl:...; 1...; 8/1/18:...

| ID | WBS | Task | Duration | Start | Finish | Complete | Remaining | Total slack | Constraint | Resources | Work | Actual work | Acronym | PCG approved | WI rapporteur name | Release | TSG approved | Status Report |
| --- | --- | --- | --- | --- | --- | --- | --- | --- | --- | --- | --- | --- | --- | --- | --- | --- | --- | --- |
| 770 | 298 | **Further Indoor Positioning Enhancements for UTRA and LTE** | 460d? | 2016-03-15 A | 2017-12-15 | 99% | 0d? | 0d |  | R2 | 9488h | 6351.77h | UTRA_LTE_iPos_enh2 | 36 | Huawei | Rel-14 | 71 |  |
| 771 | 298.1 | Core part: Further Indoor Positioning Enhancements for UTRA and LTE | 199d? | 2016-03-15 A | 2016-12-15 A | 100% |  |  | finish no earlier than 2016-12-15 | R2 | 1592h | 1592h | UTRA_LTE_iPos_enh2-Core | 36 | Huawei | Rel-14 | 71 | RP-162506 |
| 772 | 298.2 | Perf. part: Further Indoor Positioning Enhancements for UTRA and LTE | 329d? | 2016-03-15 A | 2017-06-15 A | 100% |  |  | finish no earlier than 2017-06-15 | R4 | 2632h | 2632h | UTRA_LTE_iPos_enh2-Perf | 36 | Huawei | Rel-14 | 71 |  |
| 773 | 298.3 | UE Conformance Test Aspects - RAT Independent Further Indoor Positioning Enhancements for LTE | 198d? | 2017-03-15 A | 2017-12-15 A | 100% |  |  | finish no earlier than 2017-12-15 | R5 | 1584h | 1584h | LTE_iPos_enh2_RI-UEConTest | 38 | NextNav | Rel-14 | 75 |  |
| 774 | 299 | **Radiated performance requirements for the verification of multi-antenna reception of UEs in LTE** | 524d? | 2016-03-15 A | 2018-03-15 | 99% | 5.21d? | 4627d |  | R4 | 10480h | 6540.97h | LTE_MIMO_OTA | 36 | Intel | Rel-14 | 71 |  |
| 775 | 299.1 | Core part: Radiated performance requirements for the verification of multi-antenna reception of UEs in LTE | 395d? | 2016-03-15 A | 2017-09-15 A | 100% |  |  | finish no earlier than 2017-09-15 | R4 | 3160h | 3160h | LTE_MIMO_OTA-Core | 36 | Intel | Rel-14 | 71 |  |
| 776 | 299.2 | UE Conformance Test Aspects - Radiated Performance of Multiple-antenna Receivers in the LTE UE | 391d? | 2016-09-15 A | 2018-03-15 | 98% | 7.82d? | 4627d | finish no earlier than 2018-03-15 | R5 | 3128h | 3065.44h | LTE_MIMO_OTA-UEConTest | 37 | Intel | Rel-14 | 73 |  |
| 777 | 300 | **Enhancements on Full-Dimension (FD) MIMO for LTE** | 460d? | 2016-03-15 A | 2017-12-15 | 99% | 0d? | 0d |  | R1 | 9464h | 8374.91h | LTE_eFDMIMO | 36 | Samsung | Rel-14 | 71 |  |
| 778 | 300.1 | Core part: Enhancements on Full-Dimension (FD) MIMO for LTE | 263d? | 2016-03-15 A | 2017-03-15 A | 100% |  |  | finish no earlier than 2017-03-15 | R1 | 2104h | 2104h | LTE_eFDMIMO-Core | 36 | Samsung | Rel-14 | 71 | RP-170173 |
| 779 | 300.2 | Perf. part: Enhancements on Full-Dimension (FD) MIMO for LTE | 460d? | 2016-03-15 A | 2017-12-15 A | 100% |  |  | finish no earlier than 2017-12-15 | R4 | 3680h | 3680h | LTE_eFDMIMO-Perf | 36 | Samsung | Rel-14 | 71 |  |
| 780 | 301 | **Further mobility enhancements in LTE** | 329d? | 2016-03-15 A | 2017-06-15 A | 100% |  |  |  | R2 | 5784h | 5784h | LTE_eMob | 36 | ZTE | Rel-14 | 71 |  |
| 781 | 301.1 | Core part: Further mobility enhancements in LTE | 263d? | 2016-03-15 A | 2017-03-15 A | 100% |  |  | finish no earlier than 2017-03-15 | R2 | 2104h | 2104h | LTE_eMob-Core | 36 | ZTE | Rel-14 | 71 | RP-170369 |
| 782 | 301.2 | Perf. Part: Further mobility enhancements in LTE | 131d? | 2016-12-15 A | 2017-06-15 A | 100% |  |  | finish no earlier than 2017-06-15 | R4 | 1048h | 1048h | LTE_eMob-Perf |  | ZTE | Rel-14 |  |  |
| 783 | 302 | **Uplink Capacity Enhancements for LTE** | 720d? | 2016-03-15 A | 2018-12-15 | 72% | 204.48d? | 4431d |  | R1 | 13112h | 8424h | LTE_UL_CAP_enh | 36 | Ericsson | Rel-14 | 71 |  |
| 784 | 302.1 | Core part: Uplink Capacity Enhancements for LTE | 263d? | 2016-03-15 A | 2017-03-15 A | 100% |  |  | finish no earlier than 2017-03-15 | R1 | 2104h | 2104h | LTE_UL_CAP_enh-Core | 36 | Ericsson | Rel-14 | 71 | RP-170115 |
| 785 | 302.2 | Perf. part: Uplink Capacity Enhancements for LTE | 395d? | 2016-03-15 A | 2017-09-15 A | 100% |  |  | finish no earlier than 2017-09-15 | R4 | 3160h | 3160h | LTE_UL_CAP_enh-Perf | 36 | Ericsson | Rel-14 | 71 |  |
| 786 | 302.3 | UE Conformance Test Aspects - Uplink capacity enhancements for LTE | 261d? | 2017-12-15 | 2018-12-15 |  |  | 4431d | finish no earlier than 2018-12-15 | R5 | 2088h |  | LTE_UL_CAP_enh-UEConTest |  | Ericsson | Rel-14 |  |  |
| 787 | 303 | **L2 latency reduction techniques for LTE** | 590d? | 2016-03-15 A | 2018-06-15 | 51% | 291.66d? | 4561d |  | R2 | 6840h | 2144h | LTE_LATRED_L2 | 36 | Ericsson | Rel-14 | 71 |  |
| 788 | 303.1 | Core part: L2 latency reduction techniques for LTE | 134d? | 2016-03-15 A | 2016-09-15 A | 100% |  |  | finish no earlier than 2016-09-15 | R2 | 1072h | 1072h | LTE_LATRED_L2-Core | 36 | Ericsson | Rel-14 | 71 | RP-172559 |
| 789 | 303.2 | UE Conformance Test Aspects - L2 latency reduction techniques for LTE | 131d? | 2017-12-15 | 2018-06-15 |  |  | 4561d | finish no earlier than 2018-06-15 | R5 | 1048h |  | LTE_LATRED_L2-UEConTest |  | Ericsson | Rel-14 |  |  |
| 790 | 304 | **eMBMS enhancements for LTE** | 395d? | 2016-03-15 A | 2017-09-15 | 99% | 0d? | 0d |  | R1 | 9480h | 6487.64h | MBMS_LTE_enh2 | 36 | Ericsson | Rel-14 | 71 | RP-171628 |
| 791 | 304.1 | Core part: eMBMS enhancements for LTE | 395d? | 2016-03-15 A | 2017-09-15 A | 100% |  |  | finish no earlier than 2017-09-15 | R1 | 3160h | 3160h | MBMS_LTE_enh2-Core | 36 | Ericsson | Rel-14 | 71 |  |
| 792 | 304.2 | Perf. part: eMBMS enhancements for LTE | 395d? | 2016-03-15 A | 2017-09-15 A | 100% |  |  | finish no earlier than 2017-09-15 | R4 | 3160h | 3160h | MBMS_LTE_enh2-Perf | 36 | Ericsson | Rel-14 | 71 |  |
| 793 | 305 | **SRS (sounding reference signal) switching between LTE component carriers** | 524d? | 2016-03-15 A | 2018-03-15 | 72% | 147.71d? | 4627d |  | R1 | 10512h | 5744.1h | LTE_SRS_switch | 36 | Huawei | Rel-14 | 71 |  |
| 794 | 305.1 | Core part: SRS (sounding reference signal) switching between LTE component carriers | 199d? | 2016-03-15 A | 2016-12-15 A | 100% |  |  | finish no earlier than 2016-12-15 | R1 | 1592h | 1592h | LTE_SRS_switch-Core | 36 | Huawei | Rel-14 | 71 | RP-162137 |
| 795 | 305.2 | Perf. part: SRS (sounding reference signal) switching between LTE component carriers | 329d? | 2016-03-15 A | 2017-06-15 A | 100% |  |  | finish no earlier than 2017-06-15 | R4 | 2632h | 2632h | LTE_SRS_switch-Perf | 36 | Huawei | Rel-14 | 71 |  |
| 796 | 305.3 | UE Conformance Test Aspects - SRS (sounding reference signal) switching between LTE component carriers | 262d? | 2017-03-15 A | 2018-03-15 | 15% | 222.7d? | 4627d | finish no earlier than 2018-03-15 | R5 | 2096h | 314.4h | LTE_SRS_switch-UEConTest | 38 | Huawei | Rel-14 | 75 |  |

Notes:
- 770: follow-up WI of REL-13 WI UTRA_LTE_iPos_enh
- 771: follow-up WI of REL-13 WI UTRA_LTE_iPos_enh1/7/16: Compl:0%->30%; 26/9/16: Compl:30%->60%; 26/9/16: WID:; 20/12/16: Compl:60%->100%;
- 772: 26/9/16: CD:Wed 15/03/17->Thu 15/06/1726/9/16: WID: RP-160538->RP-161850; 20/12/16: Compl:0%->30%; 20/12/16: WI21/3/17: Compl:30%->50%19/6/17: Compl:50%->100%
- 773: tested: REL-14 UTRA_LTE_iPos_enh2-Core (but only RAT independent aspects for LTE);; ...; ;...; ;...
- 774: follow-up WI of REL-13 WI UTRA_LTE_MIMO_OTA-Core; no Perf. part
- 775: follow-up WI of REL-13 WI UTRA_LTE_MIMO_OTA-Core; no Perf. part1/7/16: Compl:0%->10%1/7/16: WID: RP-160603->RP-16091426/9/16: Compl:10%->15%; 20/12/16: Compl:15%->25%; 20/12/16: WID: RP-160914->RP-162306;21/3/17: Compl:25%->33%;...1...; ;...
- 776: ; 20/12/16: Compl:0%->5%21/3/17: Compl:5%->20%19/6/17: Compl:20%...; 1...; 8/1/18: C...
- 778: ; 1/7/16: Compl:0%->25%26/9/16: Compl:25%->40%; 20/12/16: Compl:40%->80%; 20/12/16: Stat Rep: -->; 21/3/17: Compl:80%->100%; 21/3/17: Stat Rep: ->RP-170173
- 779: ; 20/12/16: Stat Rep: -->; 19/6/17: Compl:0%->50%19/9/17: Compl:50%->70%19/9/17: CD:Fri 15/09/17->Fri 15/12/17; 8/1/18: Compl:70%->100%
- 780: no Perf. part
- 781: no Perf. part; 1/7/16: Compl:0%->25%; 1/7/16: WID: RP-160636->RP-160921; 26/9/16: Compl:25%->50%; 20/12/16: Compl:50%->90%; 20/12/16: CD:Thu 15/12/16->Wed 15/03/1721/3/17: Compl:90%->100%; 21/3/17: St...
- 784: 1/7/16: Compl:0%->25%26/9/16: Compl:25%->40%; 20/12/16: Compl:40%->85%; 20/12/16: WID: RP-160664->RP-162488; 20/12/16: Stat Rep: -->21/3/17: Compl:85%->100%21/3/17: Stat Rep: ->RP-170115
- 785: ; 20/12/16: WID: RP-160664->RP-162488; 20/12/16: Stat Rep: -->;21/3/17: Compl:0%->20%19/6/17: Compl:20%->75%; 19/9/17: Compl:75%->100%
- 786: tested: REL-14 WI LTE_UL_CAP_enh-Core; related to UL 256 QAM
- 787: no Perf. part; follow-up WI of SI FS_LTE_LATRED
- 788: no Perf. part; follow-up WI of SI FS_LTE_LATRED; 1/7/16: Compl:0%->80%; 26/9/16: Compl:80%->100%8/1/18: Stat Rep: -->RP-172559
- 789: tested: REL-14 WI LTE_LATRED_L2-Core
- 791: 1/7/16: Compl:0%->10%1/7/16: CD:Tue 15/03/16->Wed 15/03/171/7/16: WID: RP-160675->RP-16129726/9/16: Compl:10%->55%; 20/12/16: Compl:55%->80%; 20/12/16: WID: RP-161297->RP-162231 ; 21/3/17: Compl:80%->90% ;...; 19/6/17: Compl:90...; ;...
- 792: ; 1/7/16: CD:Wed 15/06/16->Fri 15/09/17; 1/7/16: WID: RP-160675->RP-161297; 20/12/16: WID: RP-161297->RP-162231; 20/12/16: Stat Rep: --> ; 21/3/17: WID: RP-162231->RP-17019919/6/17: Compl:0%->70%; 19/9/17: Compl:70%->100%
- 794: 1/7/16: Compl:0%->35%1/7/16: WID: RP-160676->RP-160935; 26/9/16: Compl:35%->55%; 20/12/16: Compl:55%->100%; 20/12/16: Stat Rep: -->RP-162137
- 795: 1/7/16: WID: RP-160676->RP-160935; 20/12/16: Stat Rep: --> 21/3/17: Compl:0%->25% 21/3/17: CD:Wed 15/03/17->Thu 15/06/17; 19/6/17: Compl:25%->100%
- 796: tested: REL-14 LTE_SRS_switch-Core;; 19/6/17: Compl:0%->5%; 8/1/18: Compl:...

| ID | WBS | Task | Duration | Start | Finish | Complete | Remaining | Total slack | Constraint | Resources | Work | Actual work | Acronym | PCG approved | WI rapporteur name | Release | TSG approved | Status Report | WI rapporteur e-mail |
| --- | --- | --- | --- | --- | --- | --- | --- | --- | --- | --- | --- | --- | --- | --- | --- | --- | --- | --- | --- |
| 797 | 306 | **Downlink Multiuser Superposition Transmission for LTE** | 329d? | 2016-03-15 A | 2017-06-15 A | 100% |  |  |  | R1 | 6856h | 6856h | LTE_MUST | 36 | MediaTek | Rel-14 | 71 |  |  |
| 798 | 306.1 | Core part: Downlink Multiuser Superposition Transmission for LTE | 199d? | 2016-03-15 A | 2016-12-15 A | 100% |  |  | finish no earlier than 2016-12-15 | R1 | 1592h | 1592h | LTE_MUST-Core | 36 | MediaTek | Rel-14 | 71 | RP-162504 |  |
| 799 | 306.2 | Perf. part: Downlink Multiuser Superposition Transmission for LTE | 329d? | 2016-03-15 A | 2017-06-15 A | 100% |  |  | finish no earlier than 2017-06-15 | R4 | 2632h | 2632h | LTE_MUST-Perf | 36 | MediaTek | Rel-14 | 71 |  |  |
| 800 | 307 | **IMS Stage-3 IETF Protocol Alignment** | 198d? | 2016-06-14 A | 2017-03-15 A | 100% |  |  |  | C1 | 6336h | 6336h | IMSProtoc8 | 37 |  | Rel-14 | 72 |  |  |
| 801 | 307.1 | CT1 aspects of IMS Stage-3 IETF Protocol Alignment | 198d? | 2016-06-14 A | 2017-03-15 A | 100% |  |  | finish no earlier than 2017-03-15 | C1 | 1584h | 1584h | IMSProtoc8 | 37 | Alcatel-Lucent | Rel-14 | 72 |  | Keith Drage |
| 802 | 307.2 | (IETF) CT1 aspects of IMS Stage-3 IETF Protocol Alignment | 198d? | 2016-06-14 A | 2017-03-15 A | 100% |  |  | start no earlier than 2016-06-14 | C1-IETF | 1584h | 1584h | IMSProtoc8 | 37 | Alcatel-Lucent | Rel-14 | 72 |  | Keith Drage |
| 803 | 307.3 | CT3 aspects of IMS Stage-3 IETF Protocol Alignment | 198d? | 2016-06-14 A | 2017-03-15 A | 100% |  |  | start no earlier than 2016-06-14 | C3 | 1584h | 1584h | IMSProtoc8 | 37 | Alcatel-Lucent | Rel-14 | 72 |  | Keith Drage |
| 804 | 308 | **Multi-Carrier Enhancements for UMTS** | 264d? | 2015-12-15 A | 2016-12-15 A | 100% |  |  |  | R2 | 4232h | 4232h | UTRA_MCe | 37 | Huawei, HiSilicon | Rel-14 | 72 |  |  |
| 805 | 308.1 | Study on Multi-Carrier Enhancements for UMTS | 132d? | 2015-12-15 A | 2016-06-15 A | 100% |  |  | finish no earlier than 2016-06-15 | R1 | 1056h | 1056h | FS_UTRA_MCe | 36 | Huawei | Rel-14 | 70 |  |  |
| 806 | 308.2 | Core part: Multi-Carrier Enhancements for UMTS | 133d? | 2016-06-15 A | 2016-12-15 A | 100% |  |  | finish no earlier than 2016-12-15 | R2 | 1064h | 1064h | UTRA_MCe-Core | 37 | Huawei, HiSilicon | Rel-14 | 72 | RP-162129 |  |
| 807 | 309 | **Citizens Broadband Radio Service (CBRS) 3.5GHz band for LTE in the United States** | 263d? | 2016-06-15 A | 2017-06-15 A | 100% |  |  |  | R4 | 5280h | 5280h | LTE_TDD_3550_CBRS_US | 37 | Nokia | Rel-14 | 72 |  |  |
| 808 | 309.1 | Core part: Citizens Broadband Radio Service (CBRS) 3.5GHz band for LTE in the United States | 133d? | 2016-06-15 A | 2016-12-15 A | 100% |  |  | finish no earlier than 2016-12-15 | R4 | 1064h | 1064h | LTE_TDD_3550_CBRS_US-Core | 37 | Nokia | Rel-14 | 72 |  |  |
| 809 | 309.2 | Perf. part: Citizens Broadband Radio Service (CBRS) 3.5GHz band for LTE in the United States | 133d? | 2016-06-15 A | 2016-12-15 A | 100% |  |  | finish no earlier than 2016-12-15 | R4 | 1064h | 1064h | LTE_TDD_3550_CBRS_US-Perf | 37 | Nokia | Rel-14 | 72 |  |  |
| 810 | 309.3 | UE Conformance Test Aspects – Citizens Broadband Radio Service (CBRS) 3.5GHz Band for LTE in the United States (Band 48) | 131d? | 2016-12-15 A | 2017-06-15 A | 100% |  |  | finish no earlier than 2017-06-15 | R5 | 1048h | 1048h | LTE_TDD_3550_CBRS_US-UEConTest | 38 | Nokia | Rel-14 | 74 |  |  |
| 811 | 310 | **LTE Band 41 UE power class 2 operation** | 197d? | 2016-06-15 A | 2017-03-15 A | 100% |  |  |  | R4 | 4744h | 4744h | LTE_B41_UE_PC2 | 37 | Sprint | Rel-14 | 72 |  |  |
| 812 | 310.1 | Core part: LTE Band 41 UE power class 2 operation | 133d? | 2016-06-15 A | 2016-12-15 A | 100% |  |  | finish no earlier than 2016-12-15 | R4 | 1064h | 1064h | LTE_B41_UE_PC2-Core | 37 | Sprint | Rel-14 | 72 |  |  |
| 813 | 310.2 | Perf. part: LTE Band 41 UE power class 2 operation | 133d? | 2016-06-15 A | 2016-12-15 A | 100% |  |  | finish no earlier than 2016-12-15 | R4 | 1064h | 1064h | LTE_B41_UE_PC2-Perf | 37 | Sprint | Rel-14 | 72 |  |  |
| 814 | 310.3 | UE Conformance Test Aspects – LTE Band 41 UE power class 2 operation | 130d? | 2016-09-15 A | 2017-03-15 A | 100% |  |  | finish no earlier than 2017-03-15 | R5 | 1040h | 1040h | LTE_B41_UE_PC2-UEConTest | 37 | Sprint | Rel-14 | 73 |  |  |
| 815 | 311 | **Dedicated Core Networks for GERAN** | 68d? | 2016-06-15 A | 2016-09-15 A | 100% |  |  |  | R6 | 1088h | 1088h | DECOR_GERAN | 37 | Ericsson | Rel-14 | 72 |  |  |
| 816 | 311.1 | Core part: Dedicated Core Networks for GERAN | 68d? | 2016-06-15 A | 2016-09-15 A | 100% |  |  | finish no earlier than 2016-12-15 | R6 | 544h | 544h | DECOR_GERAN-Core | 37 | Ericsson | Rel-14 | 72 | RP-170194 |  |
| 817 | 312 | **Positioning Enhancements for GERAN** | 263d? | 2016-06-15 A | 2017-06-15 A | 100% |  |  |  | R6 | 6312h | 6312h | ePOS_GERAN | 37 | Ericsson | Rel-14 | 72 |  |  |
| 818 | 312.1 | Core part: Positioning Enhancements for GERAN | 263d? | 2016-06-15 A | 2017-06-15 A | 100% |  |  | finish no earlier than 2017-06-15 | R6 | 2104h | 2104h | ePOS_GERAN-Core | 37 | Ericsson | Rel-14 | 72 | RP-170920 |  |
| 819 | 312.2 | Perf. part: Positioning Enhancements for GERAN | 263d? | 2016-06-15 A | 2017-06-15 A | 100% |  |  | finish no earlier than 2017-06-15 | R6 | 2104h | 2104h | ePOS_GERAN-Perf | 37 | Ericsson | Rel-14 | 72 |  |  |
| 820 | 313 | **Quality of Experience (QoE) Measurement Collection for streaming services in UTRAN** | 858d? | 2014-12-03 A | 2018-03-15 | 93% | 62.01d? | 4627d |  | R2 | 12664h | 10156.8h | UMTS_QMC_Streaming | 37 | China Unicom | Rel-14 | 73 |  |  |
| 821 | 313.1 | Study on KQIs for Service Experience | 333d? | 2014-12-03 A | 2016-03-11 A | 100% |  |  | finish no earlier than 2016-03-11 | S5 | 2664h | 2664h | FS_KQISE | 34 | Li, Hui (hui.li(at)huawei.com) | Rel-14 | 66 |  | hui.li(at)huawei.com |
| 822 | 313.2 | Core part:Quality of Experience (QoE) Measurement Collection for streaming services in UTRAN | 130d? | 2016-09-15 A | 2017-03-15 A | 100% |  |  | finish no earlier than 2017-03-15 | R2 | 1040h | 1040h | UMTS_QMC_Streaming-Core | 37 | China Unicom | Rel-14 | 73 | RP-170259 |  |
| 823 | 313.3 | UE Conformance Test Aspects -Quality of Experience (QoE) Measurement Collection for streaming services in UTRAN | 262d? | 2017-03-15 A | 2018-03-15 | 80% | 52.4d? | 4627d | finish no earlier than 2018-03-15 | R5 | 2096h | 1676.8h | UMTS_QMC_Streaming-UEConTest | 38 | Huawei | Rel-14 | 75 |  |  |

Notes:
- 798: ; 1/7/16: Compl:0%->40%; 1/7/16: WID: RP-160680->RP-16101926/9/16: Compl:40%->60%; 20/12/16: Compl:60%->100%; 20/12/16: Stat Rep: -->RP-162504
- 799: 1/7/16: WID: RP-160680->RP-161019; 26/9/16: CD:Fri 15/09/17->Thu 15/06/17; 20/12/16: Stat Rep: --> ; 21/3/17: Compl:0%->25%19/6/17: Compl:25%->100%
- 800: 11/6/16: 0%->15; 5/6/17: 67%->100
- 801: Mar.15: 0->10%; June2015: Compl:10%->30; 07/09/15: 30%->70; 7/12/15: 70%->100; 16/9/16: 0%->30; 2/12/16: 30%->75; 6/3/17: 75%->100
- 802: Impacted TSs and TRs: draft-ietf-mmusic-dtls-sdp, draft-ietf-mmusic-4572-update (became RFC 8122)
- 803: 2/4/15: added, following CT3 chair's info that the WID also has a CT3 part; June2015: Compl:0%->20; 07/09/15: 20%->40; 7/12/15: 40%->100; 20/9/16: 0%->10; 2/12/16: 10%->30; 6/3/17: 30%->100
- 804: no Perf. part; follow-up WI of REL-14 SI FS_UTRA_MCe
- 805: 22/3/16: Compl:0%->20%; 1/7/16: Compl:20%->100%; 28/7/16: 25.707 added; / Impacted TSs and TRs: 25.707
- 806: no Perf. part; follow-up WI of REL-14 SI FS_UTRA_MCe; 26/9/16: Compl:0%->35%; 20/12/16: Compl:35%->100%;
- 808: 26/9/16: Compl:0%->70%; 6/10/16: 36.744 added; 20/12/16: Compl:70%->100%; / Impacted TSs and TRs: 36.744
- 809: ; 20/12/16: Compl:0%->100%;
- 810: 21/3/17: Compl:0%->60% ; ...; 19/6/17: Compl:60%->100%
- 811: follow-up WI of SI FS_LTE_B41_HPUE
- 812: follow-up WI of SI FS_LTE_B41_HPUE; 26/9/16: Compl:0%->80%; 20/12/16: Compl:80%->100%
- 813: 26/9/16: Compl:0%->80%; 20/12/16: Compl:80%->100%
- 814: ; 20/12/16: Compl:0%->65% 21/3/17: Compl:65%->100%
- 815: no Perf. part; DECOR was a REL-13 SA2 feature
- 816: no Perf. part; DECOR was a REL-13 SA2 feature; 26/9/16: Compl:0%->100%21/3/17: Stat Rep: ->RP-170194
- 818: 26/9/16: Compl:0%->30%; 20/12/16: Compl:30%->50% 21/3/17: Compl:50%->80% ; ...19/6/17: Compl:80%->100%;...
- 819: ; 20/12/16: Compl:0%->50% ; 21/3/17: Compl:50%->80%;...; 19/6/17: Compl:80%->100%; ...
- 821: Mar 15: 0->5%; June2015: Compl:0%->40; 07/09/15: 40%->50; 14/09/15: WID:SP-140784->SP-150405; 7/12/15: 50%->75; 7/12/15: WID:SP-150405->SP-150676 ; 7/3/16: 75%->100. 22/3/16: FCD: 09/15->03/16. Rel-13->Rel-14 / Impacted TSs and TRs: TR 32.8xy
- 822: ; 20/12/16: Compl:0%->60% ; 21/3/17: Compl:60%->100%...
- 823: tested: REL-14 UMTS_QMC_Streaming-Core;19/6/17: Comp...; 19/...; 8/1/18:...

| ID | WBS | Task | Duration | Start | Finish | Complete | Remaining | Total slack | Constraint | Resources | Work | Actual work | Acronym | PCG approved | WI rapporteur name | Release | TSG approved | Impacted TSs and TRs | Status Report |
| --- | --- | --- | --- | --- | --- | --- | --- | --- | --- | --- | --- | --- | --- | --- | --- | --- | --- | --- | --- |
| 824 | 314 | **Flexible eNB-ID and Cell-ID in E-UTRAN** | 263d? | 2016-03-15 A | 2017-03-15 A | 100% |  |  |  | R3 | 4216h | 4216h | LTE_FNBID | 37 | China Telecom | Rel-14 | 73 |  |  |
| 825 | 314.1 | Study on flexible eNB-ID and Cell-ID in E-UTRAN | 134d? | 2016-03-15 A | 2016-09-15 A | 100% |  |  | finish no earlier than 2016-09-15 | R3 | 1072h | 1072h | FS_LTE_FNBID | 36 | China Telecom | Rel-14 | 71 | New TR 36.896 |  |
| 826 | 314.2 | Core part: Flexible eNB-ID and Cell-ID in E-UTRAN | 130d? | 2016-09-15 A | 2017-03-15 A | 100% |  |  | finish no earlier than 2017-03-15 | R3 | 1040h | 1040h | LTE_FNBID-Core | 37 | China Telecom | Rel-14 | 73 |  | RP-170478 |
| 827 | 315 | **4 receiver (4Rx) antenna ports with Carrier Aggregation (CA) for LTE downlink (DL)** | 391d? | 2016-09-15 A | 2018-03-15 | 78% | 85.25d? | 4627d |  | R4 | 11504h | 6607.74h | LTE_4Rx_AP_DL_CA | 37 | Ericsson | Rel-14 | 73 |  |  |
| 828 | 315.1 | Core part: 4 receiver (RX) antenna ports with Carrier Aggregation (CA) for LTE downlink (DL) | 66d? | 2016-09-15 A | 2016-12-15 A | 100% |  |  | finish no earlier than 2016-12-15 | R4 | 528h | 528h | LTE_4Rx_AP_DL_CA-Core | 37 | Ericsson | Rel-14 | 73 |  | RP-162059 |
| 829 | 315.2 | Perf. part: 4 receiver (RX) antenna ports with Carrier Aggregation (CA) for LTE downlink (DL) | 262d? | 2016-09-15 A | 2017-09-15 A | 100% |  |  | finish no earlier than 2017-09-15 | R4 | 2096h | 2096h | LTE_4Rx_AP_DL_CA-Perf | 37 | Ericsson | Rel-14 | 73 |  |  |
| 830 | 315.3 | **Introduction of new band support for 4Rx antenna ports for LTE** | 326d? | 2016-12-15 A | 2018-03-15 | 60% | 130.4d? | 4627d |  | R4 | 5752h | 2724.87h | LTE_4Rx_AP_DL_bands | 38 | Huawei | Rel-14 | 74 |  |  |
| 831 | 315.3.1 | Core part: Introduction of new band support for 4Rx antenna ports for LTE | 131d? | 2016-12-15 A | 2017-06-15 A | 100% |  |  | finish no earlier than 2017-06-15 | R4 | 1048h | 1048h | LTE_4Rx_AP_DL_bands-Core | 38 | Huawei | Rel-14 | 74 |  |  |
| 832 | 315.3.2 | UE Conformance Test Aspects - 4 Rx antenna ports with CA for LTE DL | 262d? | 2017-03-15 A | 2018-03-15 | 40% | 157.2d? | 4627d | finish no earlier than 2018-03-15 | R5 | 2096h | 838.4h | LTE_4Rx_AP_DL_CA-UEConTest | 38 | Ericsson | Rel-14 | 75 |  |  |
| 833 | 316 | **Requirements for a new UE category with single receiver based on Category 1 for LTE** | 391d? | 2016-09-15 A | 2018-03-15 | 84% | 64.45d? | 4627d |  | R4 | 8360h | 4995.82h | LTE_UE_cat_1RX | 37 | Qualcomm | Rel-14 | 73 |  |  |
| 834 | 316.1 | Core part: Requirements for a new UE category with single receiver based on Category 1 for LTE | 196d? | 2016-09-15 A | 2017-06-15 A | 100% |  |  | finish no earlier than 2017-06-15 | R4 | 1568h | 1568h | LTE_UE_cat_1RX-Core | 37 | Qualcomm | Rel-14 | 73 |  | RP-171317 |
| 835 | 316.2 | Perf. part: Requirements for a new UE category with single receiver based on Category 1 for LTE | 262d? | 2016-09-15 A | 2017-09-15 A | 100% |  |  | finish no earlier than 2017-09-15 | R4 | 2096h | 2096h | LTE_UE_cat_1RX-Perf | 37 | Qualcomm | Rel-14 | 73 |  |  |
| 836 | 316.3 | UE Conformance Test Aspects – Requirements for a new UE category 1bis with single receiver based on category 1 for LTE | 196d? | 2017-06-15 A | 2018-03-15 | 45% | 107.8d? | 4627d | finish no earlier than 2018-03-15 | R5 | 1568h | 705.6h | LTE_UE_cat_1RX-UEConTest | 39 | Qualcomm | Rel-14 | 76 |  |  |
| 837 | 317 | **Enhanced LTE WLAN Radio Level Integration with IPsec Tunnel (eLWIP)** | 130d? | 2016-09-15 A | 2017-03-15 A | 100% |  |  |  | R3 | 2080h | 2080h | LTE_WLAN_eLWIP | 37 | Nokia | Rel-14 | 73 |  |  |
| 838 | 317.1 | Core part: Enhanced LTE WLAN Radio Level Integration with IPsec Tunnel (eLWIP) | 130d? | 2016-09-15 A | 2017-03-15 A | 100% |  |  | finish no earlier than 2017-03-15 | R3 | 1040h | 1040h | LTE_WLAN_eLWIP-Core | 37 | Nokia | Rel-14 | 73 |  | RP-170706 |
| 839 | 318 | **LTE Measurement Gap Enhancement** | 329d? | 2016-03-15 A | 2017-06-15 A | 100% |  |  |  |  | 5264h | 5264h | LTE_meas_gap_enh | 36 | Intel | Rel-14 | 71 |  |  |
| 840 | 318.1 | Core part: LTE Measurement Gap Enhancement | 329d? | 2016-03-15 A | 2017-06-15 A | 100% |  |  | finish no earlier than 2017-06-15 | R4 | 2632h | 2632h | LTE_meas_gap_enh-Core | 36 | Intel | Rel-14 | 71 |  | RP-171330 |
| 841 | 318.2 | Perf. part: LTE Measurement Gap Enhancement | 329d? | 2016-03-15 A | 2017-06-15 A | 100% |  |  | finish no earlier than 2017-06-15 | R4 | 2632h | 2632h | LTE_meas_gap_enh-Perf | 36 | Intel | Rel-14 | 71 |  |  |
| 842 | 319 | **Enhanced CRS and SU-MIMO Interference Mitigation Performance Requirements for LTE** | 262d? | 2016-09-15 A | 2017-09-15 A | 100% |  |  |  |  | 2096h | 2096h | LTE_eCRSIM_eSUMIMO | 37 | Intel | Rel-14 | 73 | 39.747 |  |
| 843 | 319.1 | Perf. part: Enhanced CRS and SU-MIMO Interference Mitigation Performance Requirements for LTE | 262d? | 2016-09-15 A | 2017-09-15 A | 100% |  |  | finish no earlier than 2017-09-15 | R4 | 2096h | 2096h | LTE_eCRSIM_eSUMIMO-Perf | 37 | Intel | Rel-14 | 73 | 36.176 |  |
| 844 | 320 | **Miscellaneous IETF dependencies** | 197d? | 2017-03-15 A | 2017-12-14 | 44% | 110.46d? | 4692d |  |  | 4216h | 1852h | TEI14_IETF |  |  | Rel-14 |  |  |  |
| 845 | 320.1 | (IETF) SDP Offer/Answer Clarifications for RTP/RTCP Multiplexing [RFC 5761 (was draft-ietf-avtcore-5761-update)] | 133d? | 2017-03-15 A | 2017-09-15 A | 100% |  |  | finish no earlier than 2017-09-15 | CT1-IETF | 1064h | 1064h | TEI14_IETF |  |  | Rel-14 |  |  |  |
| 846 | 320.2 | (IETF) T.140 Text Conversation over Data Channels (draft-schwarz-mmusic-t140-usage-data-channel) | 197d? | 2017-03-15 A | 2017-12-14 | 25% | 147.75d? | 4692d | finish no earlier than 2017-12-14 | CT1-IETF | 1576h | 394h | TEI14_IETF |  |  | Rel-14 |  |  |  |
| 847 | 320.3 | (IETF) BFCP floor control signalling over Data Channels (draft-schwarz-mmusic-bfcp-usage-data-channel) | 197d? | 2017-03-15 A | 2017-12-14 | 25% | 147.75d? | 4692d | finish no earlier than 2017-12-14 | CT1-IETF | 1576h | 394h | TEI14_IETF |  |  | Rel-14 |  |  |  |
| 848 | 321 | (Small) Technical Enhancements and Improvements for Rel-14 | 29d? | 2015-05-11 A | 2015-06-18 A | 100% |  |  | start no earlier than 2015-05-11 | SP; CP; RP; R4 | 928h | 928h | TEI14 | 35 |  | Rel-14 | 68 |  |  |
| 849 | 322 | (Small) Test Technical Enhancements and Improvements for Rel-14 | 593d? | 2016-09-13 A | 2018-12-20 A | 100% |  |  | start no earlier than 2016-09-13 | SP; CP; RP; GP | 18976h | 18976h | TEI14_Test |  |  | Rel-14 |  |  |  |

Notes:
- 825: 1/7/16: Compl:0%->60%26/9/16: Compl:60%->100%
- 826: ; 20/12/16: Compl:0%->80%21/3/17: Compl:80%->100%21/3/17: Stat Rep: ->RP-170478
- 828: ; 20/12/16: Compl:0%->100%; 20/12/16: Stat Rep: ->RP-162059
- 829: ; 20/12/16: Compl:0%->30%;21/3/17: Compl:30%->50%19/6/17: Compl:50%->90%; 19/9/17: Compl:90%->100%
- 830: Pending acronym
- 831: ; 21/3/17: Compl:0%->80% ; 21...19/6/17: Compl:80%->100%
- 832: tested: REL-14 LTE_4Rx_AP_DL_CA-Core; 19/6/17: C...; 1...; 8/1/18: C...
- 834: ; 20/12/16: Compl:0%->70%; 20/12/16: CD:Thu 15/12/16->Wed 15/03/17 ; 21/3/17: Compl:70%->95% 21/3/17: CD:Wed 15/03/17->Thu 15/06/1...; 19/6/17: Compl:95%->100%;...
- 835: ; 20/12/16: Compl:0%->20%; 20/12/16: CD:Thu 15/06/17->Fri 15/09/17 21/3/17: Compl:20%->70% ; 21/3/17: WID: RP-162570->RP-17079119/6/17: Compl:70%->100%;...
- 836: ; 19/9/17: Compl:0%->5%; 8/1/18: Compl:5%->45%
- 838: ; 20/12/16: Compl:0%->60% 21/3/17: Compl:60%->100% 21/3/17: Stat Rep: ->RP-170706
- 840: ; 1/7/16: Compl:0%->10%; 1/7/16: CD:Thu 15/06/17->Wed 15/03/17; 1/7/16: WID: RP-160678->RP-160912; 26/9/16: Compl:10%->25%26/9/16: R; 20/12/16: Compl:25%->60% 21/3/17: Compl:60%->95%...; 19/6/17: Compl:95%->100%...
- 841: 1/7/16: WID: RP-160678->RP-1609121/7/16: Release: Rel-15->Rel-14; 20/12/16: Stat Rep: -->; 20/12/16: Release: Rel-15->Rel-14 21/3/17: Compl:0%->20% 21/3/17: Release: Rel...19/6/17: Compl:20%->100%
- 843: 6/10/16: 36.176 added; 20/12/16: Compl:0%->30%21/3/17: Compl:30%->50% ; 21/3/17: Release: Rel-15->Rel-14; 19/6/17: Compl:50%->85%19/9/17: Compl:85%->100%
- 844: Created upon demand of RAN5
- 849: Created upon demand of RAN5

| ID | WBS | Task | Duration | Start | Finish | Complete | Remaining | Baseline start | Baseline finish | Baseline duration | Total slack | Constraint | Resources | Work | Actual work | Acronym | PCG approved | Release | TSG approved | MCC resp | Special Focus Doc | Acronym_3GU_Export | WI rapporteur name | Impacted TSs and TRs |
| --- | --- | --- | --- | --- | --- | --- | --- | --- | --- | --- | --- | --- | --- | --- | --- | --- | --- | --- | --- | --- | --- | --- | --- | --- |
| 850 | 323 | **Rel-14 LTE Carrier Aggregation** | 131d? | 2015-09-15 A | 2016-03-15 | 90% | 13.09d? | 2014-03-06 | 2015-06-12 | 332d? | 5150d |  | R4 | 9968h | 8897.13h | LTE_CA_Rel14 | 30 | Rel-14 | 58 | Issam | CA | LTE_CA_Rel-13 |  |  |
| 851 | 323.1 | **LTE Advanced 4 Band Carrier Aggregation (4DL/1UL) of Band 4, Band 5, Band 12 and Band 12** | 131d? | 2015-09-15 A | 2016-03-15 | 90% | 13.09d? |  |  |  | 5150d |  | R4 | 3144h | 2829.72h | LTE_CA_B4_B5_B12_B12 | PCG-35 | Rel-14 | RP-69 |  |  |  | US Cellular |  |
| 852 | 323.1.1 | Core part: LTE Advanced 4 Band Carrier Aggregation (4DL/1UL) of Band 4, Band 5, Band 12 and Band 12 | 131d? | 2015-09-15 A | 2016-03-15 | 90% | 13.1d? |  |  |  | 5150d | finish no earlier than 2016-03-15 | R4 | 1048h | 943.2h | LTE_CA_B4_B5_B12_B12-Core | PCG-35 | Rel-14 | RP-69 |  |  |  | US Cellular |  |
| 853 | 323.1.2 | Perf. part: LTE Advanced 4 Band Carrier Aggregation (4DL/1UL) of Band 4, Band 5, Band 12 and Band 12 | 131d? | 2015-09-15 A | 2016-03-15 | 90% | 13.1d? |  |  |  | 5150d | finish no earlier than 2016-03-15 | R4 | 1048h | 943.2h | LTE_CA_B4_B5_B12_B12-Perf | PCG-35 | Rel-14 | RP-69 |  |  |  | US Cellular |  |
| 854 | 323.2 | **LTE Advanced 4 Band Carrier Aggregation (4DL/1UL) of Band 4, Band 4, Band 12 and Band 12** | 131d? | 2015-09-15 A | 2016-03-15 | 90% | 13.09d? |  |  |  | 5150d |  | R4 | 3144h | 2829.72h | LTE_CA_B4_B4_B12_B12 | PCG-35 | Rel-14 | RP-69 |  |  |  | US Cellular |  |
| 855 | 323.2.1 | Core part: LTE Advanced 4 Band Carrier Aggregation (4DL/1UL) of Band 4, Band 4, Band 12 and Band 12 | 131d? | 2015-09-15 A | 2016-03-15 | 90% | 13.1d? |  |  |  | 5150d | finish no earlier than 2016-03-15 | R4 | 1048h | 943.2h | LTE_CA_B4_B4_B12_B12-Core | PCG-35 | Rel-14 | RP-69 |  |  |  | US Cellular |  |
| 856 | 323.2.2 | Perf. part: LTE Advanced 4 Band Carrier Aggregation (4DL/1UL) of Band 4, Band 4, Band 12 and Band 12 | 131d? | 2015-09-15 A | 2016-03-15 | 90% | 13.1d? |  |  |  | 5150d | finish no earlier than 2016-03-15 | R4 | 1048h | 943.2h | LTE_CA_B4_B4_B12_B12-Perf | PCG-35 | Rel-14 | RP-69 |  |  |  | US Cellular |  |
| 857 | 323.3 | **LTE Advanced 4 Band Carrier Aggregation (4DL/1UL) of Band 2, Band 4, Band 12 and Band 12** | 131d? | 2015-09-15 A | 2016-03-15 | 90% | 13.09d? |  |  |  | 5150d |  | R4 | 3144h | 2829.72h | LTE_CA_B2_B4_B12_B12 | PCG-35 | Rel-14 | RP-69 |  |  |  | US Cellular |  |
| 858 | 323.3.1 | Core part: LTE Advanced 4 Band Carrier Aggregation (4DL/1UL) of Band 2, Band 4, Band 12 and Band 12 | 131d? | 2015-09-15 A | 2016-03-15 | 90% | 13.1d? |  |  |  | 5150d | finish no earlier than 2016-03-15 | R4 | 1048h | 943.2h | LTE_CA_B2_B4_B12_B12-Core | PCG-35 | Rel-14 | RP-69 |  |  |  | US Cellular |  |
| 859 | 323.3.2 | Perf. part: LTE Advanced 4 Band Carrier Aggregation (4DL/1UL) of Band 2, Band 4, Band 12 and Band 12 | 131d? | 2015-09-15 A | 2016-03-15 | 90% | 13.1d? |  |  |  | 5150d | finish no earlier than 2016-03-15 | R4 | 1048h | 943.2h | LTE_CA_B2_B4_B12_B12-Perf | PCG-35 | Rel-14 | RP-69 |  |  |  | US Cellular |  |
| 860 | 324 | **Rel-14LTE Advanced inter-band Carrier Aggregation** | 589d? | 2015-12-15 A | 2018-03-15 | 79% | 121.38d? | 2014-03-06 | 2015-06-12 | 332d? | 4627d |  | R4 | 81928h | 59718.1h | LTE_AIBCA_Rel14 | 30 | Rel-14 | 58 | Issam | CA | LTE_CA_Rel-13 |  |  |
| 861 | 324.1 | **LTE Advanced inter-band Carrier Aggregation Rel-14 for 5DL/1UL** | 394d? | 2015-12-15 A | 2017-06-15 | 95% | 19.69d? |  |  |  | 4822d |  | R4 | 9456h | 8416.04h | LTE_CA_R14_5DL1UL | PCG-36 | Rel-14 | RP-70 |  |  |  | Nokia Networks |  |
| 862 | 324.1.1 | Core part: LTE Advanced inter-band Carrier Aggregation Rel-14 for 5DL/1UL | 394d? | 2015-12-15 A | 2017-06-15 | 95% | 19.7d? |  |  |  | 4822d | finish no earlier than 2017-06-15 | R4 | 3152h | 2994.4h | LTE_CA_R14_5DL1UL-Core | PCG-36 | Rel-14 | RP-70 |  |  |  | Nokia Networks | 36.714-05-01 |
| 863 | 324.1.2 | Perf. part: LTE Advanced inter-band Carrier Aggregation Rel-14 for 5DL/1UL | 394d? | 2015-12-15 A | 2017-06-15 | 95% | 19.7d? |  |  |  | 4822d | finish no earlier than 2017-06-15 | R4 | 3152h | 2994.4h | LTE_CA_R14_5DL1UL-Perf | PCG-36 | Rel-14 | RP-70 |  |  |  | Nokia Networks |  |
| 864 | 324.2 | **LTE Advanced inter-band Carrier Aggregation Rel-14 for 2DL/1UL** | 394d? | 2015-12-15 A | 2017-06-15 | 80% | 78.8d? |  |  |  | 4822d |  | R4 | 9456h | 7076.85h | LTE_CA_R14_2DL1UL | PCG-36 | Rel-14 | RP-70 |  |  |  | Qualcomm |  |
| 865 | 324.2.1 | Core part: LTE Advanced inter-band Carrier Aggregation Rel-14 for 2DL/1UL | 394d? | 2015-12-15 A | 2017-06-15 | 80% | 78.8d? |  |  |  | 4822d | finish no earlier than 2017-06-15 | R4 | 3152h | 2521.6h | LTE_CA_R14_2DL1UL-Core | PCG-36 | Rel-14 | RP-70 |  |  |  | Qualcomm | 36.714-02-01 |
| 866 | 324.2.2 | Perf. part: LTE Advanced inter-band Carrier Aggregation Rel-14 for 2DL/1UL | 394d? | 2015-12-15 A | 2017-06-15 | 80% | 78.8d? |  |  |  | 4822d | finish no earlier than 2017-06-15 | R4 | 3152h | 2521.6h | LTE_CA_R14_2DL1UL-Perf | PCG-36 | Rel-14 | RP-70 |  |  |  | Qualcomm |  |
| 867 | 324.3 | **LTE Advanced inter-band Carrier Aggregation Rel-14 for 2DL/2UL** | 394d? | 2015-12-15 A | 2017-06-15 | 90% | 39.4d? |  |  |  | 4822d |  | R4 | 9456h | 7904.07h | LTE_CA_R14_2DL2UL | PCG-36 | Rel-14 | RP-70 |  |  |  | Huawei |  |
| 868 | 324.3.1 | Core part: LTE Advanced inter-band Carrier Aggregation Rel-14 for 2DL/2UL | 394d? | 2015-12-15 A | 2017-06-15 | 90% | 39.4d? |  |  |  | 4822d | finish no earlier than 2017-06-15 | R4 | 3152h | 2836.8h | LTE_CA_R14_2DL2UL-Core | PCG-36 | Rel-14 | RP-70 |  |  |  | Huawei | 36.714-02-02 |
| 869 | 324.3.2 | Perf. part: LTE Advanced inter-band Carrier Aggregation Rel-14 for 2DL/2UL | 394d? | 2015-12-15 A | 2017-06-15 | 90% | 39.4d? |  |  |  | 4822d | finish no earlier than 2017-06-15 | R4 | 3152h | 2836.8h | LTE_CA_R14_2DL2UL-Perf | PCG-36 | Rel-14 | RP-70 |  |  |  | Huawei |  |
| 870 | 324.4 | **LTE Advanced inter-band Carrier Aggregation Rel-14 for 3DL/3UL** | 328d? | 2015-12-15 A | 2017-03-15 A | 100% |  |  |  |  |  |  | R4 | 7872h | 7872h | LTE_CA_R14_3DL3UL | PCG-36 | Rel-14 | RP-70 |  |  |  | Nokia Networks |  |
| 871 | 324.4.1 | Core part: LTE Advanced inter-band Carrier Aggregation Rel-14 for 3DL/3UL | 328d? | 2015-12-15 A | 2017-03-15 A | 100% |  |  |  |  |  | finish no earlier than 2017-03-15 | R4 | 2624h | 2624h | LTE_CA_R14_3DL3UL-Core | PCG-36 | Rel-14 | RP-70 |  |  |  | Nokia Networks | 36.714-03-03 |
| 872 | 324.4.2 | Perf. part: LTE Advanced inter-band Carrier Aggregation Rel-14 for 3DL/3UL | 328d? | 2015-12-15 A | 2017-03-15 A | 100% |  |  |  |  |  | finish no earlier than 2017-03-15 | R4 | 2624h | 2624h | LTE_CA_R14_3DL3UL-Perf | PCG-36 | Rel-14 | RP-70 |  |  |  | Nokia Networks |  |
| 873 | 324.5 | **LTE Advanced inter-band Carrier Aggregation Rel-14 for xDL/2UL with x=3,4,5** | 394d? | 2015-12-15 A | 2017-06-15 | 48% | 206.85d? |  |  |  | 4822d |  | R4 | 9456h | 4240.77h | LTE_CA_R14_xDL2UL | PCG-36 | Rel-14 | RP-70 |  |  |  | LG Electronics |  |
| 874 | 324.5.1 | Core part: LTE Advanced inter-band Carrier Aggregation Rel-14 for xDL/2UL with x=3,4,5 | 394d? | 2015-12-15 A | 2017-06-15 | 95% | 19.7d? |  |  |  | 4822d | finish no earlier than 2017-06-15 | R4 | 3152h | 2994.4h | LTE_CA_R14_xDL2UL-Core | PCG-36 | Rel-14 | RP-70 |  |  |  | LG Electronics | 36.714-00-02 |
| 875 | 324.5.2 | Perf. part: LTE Advanced inter-band Carrier Aggregation Rel-14 for xDL/2UL with x=3,4,5 | 394d? | 2015-12-15 | 2017-06-15 |  |  |  |  |  | 4822d | finish no earlier than 2017-06-15 | R4 | 3152h |  | LTE_CA_R14_xDL2UL-Perf | PCG-36 | Rel-14 | RP-70 |  |  |  | LG Electronics |  |

Notes:
- 850: Acronym changed from "LTE_CA_Rel-13" to "LTE_CA_Rel13"
- 860: Acronym changed from "LTE_CA_Rel-13" to "LTE_CA_Rel13"
- 862: 28/1/16: 36.714-05-01 added; 22/3/16: Compl:0%->15%; 22/3/16: WID: RP-151671->RP-1606151/7/16: Compl:15%->40%; 26/9/16: Compl:40%->60%; 20/12/16: Compl ; 21/3/17...
- 863: 22/3/16: WID: RP-151671->RP-1606151/7/16: WID: RP-160615->RP-16105226/9/16: WID: RP-161052->RP-161496; 20/12/16: Compl:0%->90% ; 21/3/17: Compl:90%->95%;...
- 865: 28/1/16: 36.714-02-01 added; 22/3/16: Compl:0%->20%; 22/3/16: WID: RP-152196->RP-160616; 1/7/16: Compl:20%->30%; 1/7/16: WI26/9/16: Compl:30%->50%; 20/12/16: Com 21/3/17: ...
- 866: 22/3/16: WID: RP-152196->RP-1606161/7/16: Compl:0%->30%1/7/16: WID: RP-160616->RP-161202; 26/9/16: Compl:30%->50% 20/12/16: Compl:50%->75% 21/3/17: Compl:75%->80%; ;...
- 868: 28/1/16: 36.714-02-02 added;22/3/16: Compl:0%->20%22/3/16: WID: RP-152237->RP-160192; 1/7/16: Compl:20%->40%; 26/9/16: Compl:40%->60%; 20/12/16: C ; 21/3/17:...
- 869: ; 22/3/16: WID: RP-152237->RP-1601921/7/16: WID: RP-160192->RP-16094726/9/16: WID: RP-160947->RP-161676; 20/12/16: Compl:0%->80%; 21/3/17: Compl:80%->90...
- 871: 28/1/16: 36.714-03-03 added;22/3/16: Compl:0%->1%1/7/16: Compl:1%->15%; 21/3/17: Compl:15%->100%
- 872: ; 1/7/16: Compl:0%->15%; ; 21/3/17: Compl:15%->100%
- 874: 28/1/16: 36.714-00-02 added; 22/3/16: Compl:0%->10%; 22/3/16: WID: RP-152246->RP-160148; 1/7/16: Compl:10%->40%; 26/9/16: Compl:40%->70%; 20/; 21/3/17: ...
- 875: 22/3/16: WID: RP-152246->RP-1601481/7/16: WID: RP-160148->RP-160748; 26/9/16: WID: RP-160748->RP-161487; 20/12/16: WID: RP-161487->RP-162036; ; 21/3/17:...

| ID | WBS | Task | Type | Duration | Start | Finish | Complete | Remaining | Baseline start | Baseline finish | Baseline duration | Total slack | Constraint | Resources | Work | Actual work | Acronym | PCG approved | WI rapporteur name | Release | TSG approved | Impacted TSs and TRs | WI rapporteur e-mail | MCC resp | Acronym_3GU_Export | Special Focus Doc |
| --- | --- | --- | --- | --- | --- | --- | --- | --- | --- | --- | --- | --- | --- | --- | --- | --- | --- | --- | --- | --- | --- | --- | --- | --- | --- | --- |
| 876 | 324.6 | **LTE Advanced inter-band Carrier Aggregation Rel-14 for 4DL/1UL** |  | 394d? | 2015-12-15 A | 2017-06-15 | 95% | 19.69d? |  |  |  | 4822d |  | R4 | 9456h | 8481.62h | LTE_CA_R14_4DL1UL | PCG-36 | Ericsson | Rel-14 | RP-70 |  |  |  |  |  |
| 877 | 324.6.1 | Core part: LTE Advanced inter-band Carrier Aggregation Rel-14 for 4DL/1UL |  | 394d? | 2015-12-15 A | 2017-06-15 | 95% | 19.7d? |  |  |  | 4822d | finish no earlier than 2017-06-15 | R4 | 3152h | 2994.4h | LTE_CA_R14_4DL1UL-Core | PCG-36 | Ericsson | Rel-14 | RP-70 | 36.714-04-01 |  |  |  |  |
| 878 | 324.6.2 | Perf. part: LTE Advanced inter-band Carrier Aggregation Rel-14 for 4DL/1UL |  | 394d? | 2015-12-15 A | 2017-06-15 | 95% | 19.7d? |  |  |  | 4822d | finish no earlier than 2017-06-15 | R4 | 3152h | 2994.4h | LTE_CA_R14_4DL1UL-Perf | PCG-36 | Ericsson | Rel-14 | RP-70 |  |  |  |  |  |
| 879 | 324.7 | **LTE Advanced intra-band Carrier Aggregation for xDL/yUL including contiguous and non-contiguous spectrum** |  | 394d? | 2015-12-15 A | 2017-06-15 | 82% | 70.92d? |  |  |  | 4822d |  | R4 | 9456h | 7084.9h | LTE_CA_R14_intra | PCG-36 | Ericsson | Rel-14 | RP-70 |  |  |  |  |  |
| 880 | 324.7.1 | Core part: LTE Advanced intra-band Carrier Aggregation for xDL/yUL including contiguous and non-contiguous spectrum |  | 394d? | 2015-12-15 A | 2017-06-15 | 82% | 70.92d? |  |  |  | 4822d | finish no earlier than 2017-06-15 | R4 | 3152h | 2584.64h | LTE_CA_R14_intra-Core | PCG-36 | Ericsson | Rel-14 | RP-70 | 36.714-00-00 |  |  |  |  |
| 881 | 324.7.2 | Perf. part: LTE Advanced intra-band Carrier Aggregation for xDL/yUL including contiguous and non-contiguous spectrum |  | 394d? | 2015-12-15 A | 2017-06-15 | 82% | 70.92d? |  |  |  | 4822d | finish no earlier than 2017-06-15 | R4 | 3152h | 2584.64h | LTE_CA_R14_intra-Perf | PCG-36 | Ericsson | Rel-14 | RP-70 |  |  |  |  |  |
| 882 | 324.8 | **LTE Advanced inter-band Carrier Aggregation Rel-14 for 3DL/1UL** |  | 394d? | 2015-12-15 A | 2017-06-15 | 90% | 39.4d? |  |  |  | 4822d |  | R4 | 9456h | 7904.07h | LTE_CA_R14_3DL1UL | PCG-36 | Huawei | Rel-14 | RP-70 |  |  |  |  |  |
| 883 | 324.8.1 | Core part: LTE Advanced inter-band Carrier Aggregation Rel-14 for 3DL/1UL |  | 394d? | 2015-12-15 A | 2017-06-15 | 90% | 39.4d? |  |  |  | 4822d | finish no earlier than 2017-06-15 | R4 | 3152h | 2836.8h | LTE_CA_R14_3DL1UL-Core | PCG-36 | Huawei | Rel-14 | RP-70 | 36.714-03-01 |  |  |  |  |
| 884 | 324.8.2 | Perf. part: LTE Advanced inter-band Carrier Aggregation Rel-14 for 3DL/1UL |  | 394d? | 2015-12-15 A | 2017-06-15 | 90% | 39.4d? |  |  |  | 4822d | finish no earlier than 2017-06-15 | R4 | 3152h | 2836.8h | LTE_CA_R14_3DL1UL-Perf | PCG-36 | Huawei | Rel-14 | RP-70 |  |  |  |  |  |
| 885 | 324.9 | UE Conformance Test Aspects – Rel-14 CA configurations |  | 458d? | 2016-06-15 A | 2018-03-15 | 9% | 416.78d? |  |  |  | 4627d | finish no earlier than 2018-03-15 | R5 | 3664h | 329.76h | LTE_CA_R14-UEConTest | PCG-37 | Ericsson | Rel-14 | TSG#72 |  |  |  |  |  |
| 886 | 325 | Release 14 Studies |  | 323d? | 2014-09-17 A | 2015-12-11 A | 100% |  |  |  |  |  | finish no earlier than 2015-12-11 | SP; RP; CP; GP | 10336h | 10336h |  |  |  | Rel-14 |  |  |  |  |  |  |
| 887 | 326 | Study on channel model for frequency spectrum above 6 GHz |  | 197d? | 2015-09-15 A | 2016-06-15 A | 100% |  |  |  |  |  | finish no earlier than 2016-06-15 | R1 | 1576h | 1576h | FS_6GHz_CH_model | 35 | Samsung | Rel-14 | 69 | 38.900 |  |  |  |  |
| 888 | 327 | Study on Scenarios and Requirements for Next Generation Access Technologies |  | 264d? | 2015-12-15 A | 2016-12-15 A | 100% |  |  |  |  |  | finish no earlier than 2016-12-15 | RP | 2112h | 2112h | FS_NG_SReq | 36 | CMCC | Rel-14 | 70 | 38.xxx |  |  |  |  |
| 889 | 328 | Study on NB-IoT RF requirement for coexistence with CDMA |  | 133d? | 2016-06-15 A | 2016-12-15 A | 100% |  |  |  |  |  | finish no earlier than 2016-12-15 | R4 | 1064h | 1064h | FS_NB_IOT_CDMA_coex | 37 | China Telecom | Rel-14 | 72 | 36.752 |  |  |  |  |
| 890 | 329 | Study on need for Multiple Access Point Names |  | 464d? | 2013-09-12 A | 2015-06-19 A | 100% |  | 2013-09-12 | 2014-12-10 | 327d? |  | finish no earlier than 2015-06-19 | S1 | 3704h | 3704h | FS_MAPN | 31 | Giesecke & Devrient | Rel-14 | 61 | 22.802 | Ilario.macchi@gi-de.com | Alain | FS_MAPN |  |
| 891 | 330 | Study on Multimedia Broadcast Supplement for Public Warning System |  | 264d? | 2013-12-11 A | 2014-12-12 A | 100% |  | 2013-12-11 | 2014-09-17 | 202d? |  | finish no earlier than 2014-12-12 | S1 | 2104h | 2104h | FS_MBSP | 32 | Qualcomm | Rel-14 | 62 | 22.815 | Eddy Hall (edhall@qti.qualcomm.com) | Alain | FS_MBSP | Public Safety (I-A) |
| 892 | 331 | Study on service aspects for dealing with User Control over spoofed calls |  | 271d? | 2014-03-07 A | 2015-03-20 A | 100% |  | 2014-03-07 | 2014-12-10 | 199d? |  | finish no earlier than 2015-03-20 | S1 | 2168h | 2168h | FS_UC_SPOOF | 32 | Sprint | Rel-14 | 63 | 22.898 | Gregory.schumacher@sprint.com | Alain | FS_UC_SPOOF |  |
| 893 | 332 | Study on User Location Reporting Support enhancements |  | 261d? | 2014-06-19 A | 2015-06-17 A | 100% |  | 2014-06-18 | 2015-06-17 | 261d? |  | finish no earlier than 2015-06-17 | S1 | 2088h | 2088h | FS_eULRS | 33 | China Unicom | Rel-14 | 64 | 22.899 | Zhuoyun Zhang ( zhangzy910@chinaunicom.cn) |  | FS_eULRS |  |
| 894 | 333 | Study on Control of Applications when Third party Servers encounter difficulties |  | 259d? | 2014-06-19 A | 2015-06-15 A | 100% |  | 2014-06-18 | 2014-12-10 | 126d? |  | finish no earlier than 2015-06-15 | S1 | 2072h | 2072h | FS_CATS | 33 | KDDI | Rel-14 | 64 | 22.818 | Eriko Yoshida (er-yoshida@kddi.com) |  | FS_CATS |  |
| 895 | 334 | Study on Paging Policy Enhancements and Procedure Optimizations in LTE |  | 176d? | 2015-04-14 A | 2015-12-15 A | 100% |  |  |  |  |  | finish no earlier than 2015-12-15 | S1 | 1408h | 1408h | FS_PPEPO_LTE | 34 | Zhuoyun Zhang (China Unicom) | Rel-14 | 67 | New TR 22.838 | zhangzy910@chinaunicom.cn |  |  |  |
| 896 | 335 | Study on Latency reduction techniques for LTE |  | 328d? | 2015-03-16 A | 2016-06-15 A | 100% |  |  |  |  |  | finish no earlier than 2016-06-15 | R2 | 2624h | 2624h | FS_LTE_LATRED | 34 | Ericsson | Rel-14 | 67 | 36.881 |  |  |  |  |
| 897 | 336 | Study on High Power LTE UE for Band 41 |  | 263d? | 2015-06-15 A | 2016-06-15 A | 100% |  |  |  |  |  | finish no earlier than 2016-12-15 | R4 | 2104h | 2104h | FS_LTE_B41_HPUE | 35 | Sprint | Rel-14 | 68 | 36.886 |  |  |  |  |
| 898 | 337 | Study on Media and Quality Aspects of SRVCC Enhancements |  | 192d? | 2015-06-18 A | 2016-03-11 A | 100% |  |  |  |  |  | finish no earlier than 2016-03-11 | S4 | 1536h | 1536h | FS_SETA_S4 | 35 | Frédéric Gabin, Ericsson LM | Rel-14 | 68 | New TR 26.916, TS 26.114 | frederic . gabin @ ericsson . com |  |  |  |
| 899 | 338 | Deleted - Study on SON for eCoMP for LTE |  | 3d? | 2016-06-14 A | 2016-06-16 A | 100% |  |  |  |  |  | start no earlier than 2016-06-14 | R3 | 24h | 24h | delFS_LTE_SON_eCOMP | 37 | Nokia | Rel-14 | 72 | 23.228, 23.237 |  |  |  |  |
| 900 | 339 | Study on UICC power optimization for MTC |  | 133d? | 2016-06-15 A | 2016-12-15 A | 100% |  |  |  |  |  |  | C6 | 1064h | 1064h | FS_UICC_MTC_OPT | 36 | Berionne, Michele | Rel-14 | 70 | 31.970 | micheleb [at] qti [dot] qualcomm [dot] com |  |  |  |
| 901 | 340 | Study on Server and Network Assisted DASH for 3GPP |  | 209d? | 2016-03-01 A | 2016-12-15 A | 100% |  |  |  |  |  | finish no earlier than 2016-12-15 | S4 | 1672h | 1672h | FS_SAND | 36 | Ozgur Oyman, Intel | Rel-14 | 71 | TR26.957 | ozgur.oyman@intel.com |  |  |  |
| 902 | 341 | Study on MBMS usage for mission critical communication services | milestone | 0d? | 2016-03-01 A | 1984-10-18 A | 100% |  |  |  |  |  | finish no earlier than 2016-12-15 |  |  |  | FS_MBMS_MCservices | 36 | Magnus Tränk, Ericsson LM | Rel-14 | 71 | TR 23.780 | magnus.trank@ericsson.com |  |  |  |
| 903 | 342 | Study on enhancement of VoLTE |  | 134d? | 2016-03-15 A | 2016-09-15 A | 100% |  |  |  |  |  | finish no earlier than 2016-09-15 | R2 | 1072h | 1072h | FS_LTE_eVoLTE | 36 | CMCC | Rel-14 | 71 | 36.750 |  |  |  |  |
| 904 | 343 | Study on HSPA and LTE Joint Operation |  | 199d? | 2016-03-15 A | 2016-12-15 A | 100% |  |  |  |  |  | finish no earlier than 2016-12-15 | R3 | 1592h | 1592h | FS_UTRA_LTE_JOP | 36 | China Unicom | Rel-14 | 71 | New 37.805 |  |  |  |  |
| 905 | 344 | Study on LTE Advanced Carrier Aggregation of Band 3 and Band 39 |  | 263d? | 2016-03-15 A | 2017-03-15 A | 100% |  |  |  |  |  | finish no earlier than 2017-03-15 | R4 | 2104h | 2104h | FS_LTE_CA_B3_B39 | 36 | ZTE | Rel-14 | 71 |  |  |  |  |  |
| 906 | 345 | Study on Context Aware Service Delivery in RAN for LTE |  | 263d? | 2016-03-15 A | 2017-03-15 A | 100% |  |  |  |  |  | finish no earlier than 2017-03-15 | R3 | 2104h | 2104h | FS_LTE_context | 36 | CMCC | Rel-14 | 71 |  |  |  |  |  |
| 907 | 346 | Study on further enhancements to Coordinated Multi-Point (CoMP) Operation for LTE |  | 263d? | 2016-03-15 A | 2017-03-15 A | 100% |  |  |  |  |  | finish no earlier than 2017-03-15 | R1 | 2104h | 2104h | FS_feCOMP_LTE | 36 | Intel | Rel-14 | 71 |  |  |  |  |  |
| 908 | 347 | Study on Determination of Completeness of Charging Information in IMS |  | 267d? | 2015-03-05 A | 2016-03-11 A | 100% |  |  |  |  |  | finish no earlier than 2016-03-11 | S5 | 2136h | 2136h | FS_DCCHII | 34 | Jesske, Roland | Rel-14 | 67 | 32.xyz | r.jesske@telekom.de |  |  |  |
| 909 | 348 | Study on Interactivity Support for 3GPP-based Streaming and Download Services |  | 587d? | 2014-12-12 A | 2017-03-10 A | 100% |  |  |  |  |  | finish no earlier than 2017-03-10 | S4 | 4696h | 4696h | FS_IS3 | 34 | Lo, Charles, Qualcomm | Rel-14 | 66 | 26.953 | clo@qti.qualcomm.com |  |  |  |
| 910 | 349 | Study on MBMS usage and codecs for MCPTT call and MC Video Service |  | 199d? | 2016-06-13 A | 2017-03-15 A | 100% |  |  |  |  |  | finish no earlier than 2017-03-15 | S4 | 1592h | 1592h | FS_MCP_V | 37 | Zhiming Li, Huawei | Rel-14 | 72 | 26.880 | lizhiming@huawei.com |  |  |  |
| 911 | 350 | Study on MBMS Extensions for Provisioning and Content Ingestion |  | 196d? | 2016-06-13 A | 2017-03-10 A | 100% |  |  |  |  |  | finish no earlier than 2017-03-10 | S4 | 1568h | 1568h | FS_xMBMS | 37 | Kyungmo Park, sk telecom | Rel-14 | 72 | TR 26.981 | kyungmo.park@sk.com |  |  |  |
| 912 | 351 | Study on global application of LTE Band 11 and of LTE Band 21 UEs |  | 133d? | 2016-06-15 A | 2016-12-15 A | 100% |  |  |  |  |  | finish no earlier than 2016-12-15 | R4 | 1064h | 1064h | FS_LTE_B11_B21_global | 37 | SoftBank | Rel-14 | 72 | 36.745 |  |  |  |  |
| 913 | 352 | Study on Downlink MIMO for GERAN |  | 68d? | 2016-06-15 A | 2016-09-15 A | 100% |  |  |  |  |  | finish no earlier than 2016-09-15 | R6 | 544h | 544h | FS_DOMIMO_RAN6 | 37 | Nokia, Alcatel-Lucent Shanghai Bell | Rel-14 | 72 |  |  |  |  |  |
| 914 | 353 | Release 14 studies on 5G MObile Network for Advanced communications |  | 490d? | 2015-02-02 A | 2016-12-15 A | 100% |  |  |  |  |  |  | S1 | 2160h | 2160h |  | 34 | Adrian Neal (Vodafone) | Rel-14 | 67 | New TR 22.891 | adrian.neal@vodafone.com |  |  |  |

Notes:
- 877: 28/1/16: 36.714-04-01 added;22/3/16: Compl:0%->30%22/3/16: WID: RP-152249->RP-1606141/7/16: Compl:30%->38%; 26/9/16: Compl:38%->74%; 20/12/16: Compl:74%->9521/3/1...
- 878: ; 22/3/16: WID: RP-152249->RP-160614; 1/7/16: Compl:0%->38%; 1/7/16: WID: RP-160614->RP-16082126/9/16: Compl:38%->0%; 20/12/16: Compl:0%->95% ; 21/3/17: CD:Wed 1...
- 880: 28/1/16: 36.714-00-00 added;22/3/16: Compl:0%->60%22/3/16: WID: RP-152250->RP-160613; 1/7/16: Compl:60%->50%; 1/7/16: WID: RP-160613; 26/9/16: Compl:50%->44%; 20/12/16:; ; 21/3/1...
- 881: ; 22/3/16: WID: RP-152250->RP-1606131/7/16: Compl:0%->50%1/7/16: WID: RP-160613->RP-16082226/9/16: WID: RP-160822->RP-161473; 20/12/16: Compl:50%->64% 21/3/17: Compl:64%->...
- 883: 28/1/16: 36.714-03-01 added;22/3/16: Compl:0%->15%22/3/16: WID: RP-152278->RP-1605821/7/16: Compl:15%->40%1/7/1626/9/16: Compl:40%->60%; 20/12/16: Compl:60%->80 21/3/1...
- 884: 22/3/16: WID: RP-152278->RP-160582; 1/7/16: WID: RP-160582->RP-160945; 26/9/16: WID: RP-160945->RP-161674; 20/12/16: Compl:0%->80%21/3/17: Compl:80%->90%;...
- 885: testing REL-14 CA basket WIs: LTE_CA_R14_intra-Core, LTE_CA_R14_2DL1UL-Core, LTE_CA_R14_3DL1UL-Core, LTE_CA_R14_4DL1UL-Core, LTE_CA_R14_5DL1UL-Core, LTE_CA_R14_2DL2UL-Core, LTE_CA_R14_xDL2UL-Core, LTE_CA_R14_3DL3UL-Core; ; ...
- 886: -
- 887: will start only in RAN in Q4/15; 28/1/16: 38.900 added; 22/3/16: Compl:10%->20%; 22/3/16: WID: RP-151606->RP-160210; 1/7/16: Compl:20%->100%. 2/12/16: Moved to Rel-15 according JMM email to move all 38.xxx related WIDs to Rel-15; 21/3/17: Stat Rep: -->; 21/3/17: Release: Rel-15->Rel-14
- 888: 22/3/16: Compl:0%->80%1/7/16: WID: RP-152257->RP-160811. 18/9/16: FCD: Sept 16, 80->95%26/9/16: Compl:95%->100%; 14/12/16: FCD:09/16->12/16; 14/12/16: 100%->9820/12/16: Compl:98%->100%20/12/16: CD:Mon 12/12/16->Thu 15/12/1620/12/16: Release: Rel-15->Re
- 889: ; 26/9/16: Compl:0%->35%; 6/10/16: 36.752 added; 20/12/16: Compl:35%->100%
- 890: SP#65 moved to Rel-14. Completion 12/14=>03/15. Triggered by S1-133134 LS on GSMA Connected Living Programme Request for APN Storage in the SIM. Dec.14: 50->70%, CD: 03/15->06/15. Mar.15: 90%; June2015: Compl:90%->100
- 891: SP#65 completion 09/14=>12/14. Moved to Rel-14. TR 22.815v100 for Information. Linked to Rel-9 Feature PWS. Dec.14:70->100%
- 892: SP#65 moved to Rel-14. Linked to SA3 Rel-11 TR 33.838 PUCI and Rel-12 ongoing study TR 33.831 (FS_SPOOF). Dec.14: 70->90, CD: 12/14->03/15. Mar.15: 100%
- 893: SP#65 moved to Rel-14. Linked to Rel-12 SA2 TR 23.843 Study on Core Network Overload solutions (FS_CNO) and Rel-13 Feature Service Exposure and Enablement Support (SEES). Dec.14: 30->70%. Mar.15: 90%; June2015: Compl:90%->100
- 894: SP#65 completion 12/14=>03/15. Moved to Rel-14. Linked to Rel-13 Feature SEES and Rel-13 TR 22.806 (FS_ACDC). Dec.14: 30->60%, WID SP-140246->SP-140758, CD: 12/14->03/15. Mar.15: CD: 03/13->06/15. 60->90%; June2015: Compl:90%->100
- 895: 1/4/15:TR number added; June2015: Compl:0%->40; 07/09/15: 40%->60; 7/12/15: 60%->100
- 896: 03/07/15: Compl:0%->10% 03/07/15: Stat Rep: -->RP-150780 03/07/15: Release: Rel-13->Rel-14 29/09/15: Compl:10%->25% 29/09/15: Stat Rep: RP-150780->RP-151286 22/3/16: Compl:50%->60%;
- 897: 7/9/15: TR added 29/09/15: Compl:0%->1% 29/09/15: Stat Rep: -->RP-151436 ; 22/3/16: Compl:10%->40%; 22/3/16: WID: RP-151104->RP-1600921/7/16: Compl
- 898: Aug2015: 0%->25; 07/09/15: 25%->30; 7/12/15: 30%->80, FCD: 12/15->03/16, MOVED TO REL-14; 7/3/16: 80%->100
- 899: 26/9/16: Compl:0%->10%. 1/12/16: Deleted: 720085 was allocated twice: to FS_LTE_SON-ECOMP (now in 720063) and to ROBVOLTE (now in 720301)
- 900: 7/3/16: 0%->100; 5/6/17: 71%->100
- 901: 11/6/16: 0%->10; 19/9/16: 10%->60; 1/12/16: 60%->100
- 902: 11/6/16: 0%->35. Name corrected; 19/9/16: WID:SP-160201->SP-160525; FCD: 09/16->12/16; 19/9/16: 35%->60; 23/9/16: WID:SP-160525->SP-160728; 1/12/16: 60%->95; 3/3/17: 95%->100
- 903: 1/7/16: Compl:0%->75%1/7/16: WI; 28/7/16: 36.750 added; 26/9/16: Compl:75%->100%
- 904: ; 1/7/16: Compl:0%->30%; 26/9/16: Compl:30%->80%; 20/12/16: Compl:80%->100%;
- 905: intention to capture results in existing TR 36.714-02-01 ; 1/7/16: Compl:0%->30%; 26/9/16: Compl:30%->50%; 20/12/16: Compl ; 21/3/17: Compl:8...
- 906: 1/7/16: Compl:0%->25%1/26/9/16: Compl:25%->40%; 20/12/16: Compl:40%->70% ; 21/3/17: Compl:70%->100%
- 907: ; 1/7/16: Compl:0%->15%; 26/9/16: Compl:15%->30%; 20/12/16: Compl:30%->80%21/3/17: Compl:80%->100%
- 908: 11/03/15: WID changed from FS_DCCII to FS_DCCHII as per SA5 chair request; June2015: Compl:0%->7; 07/09/15: 7%->15; 7/12/15: 15%->60, FCD: 09/15->03/16; 7/3/16: 60%->100. 22/3/16: Rel-13->Rel-14
- 909: TR number added. Mar. 15: 0->5%; June2015: Compl:5%->10; Aug2015: 10%->15; 07/09/15: 15%->30, FCD: 12/15->03/16; 7/3/16: 30%->40. 15/4/16: moved from Rel-13. FCD: 11/3/16->23/9/16; 11/6/16: 40%->50; 19/9/16: 50%->70, FCD:09/16->12/16; 1/12/16: 70%->80;; 6/3/17: 80%->100
- 910: 28/7/16: 26.880 added; 19/9/16: 0%->30, FCD: 12/16->03/17; 1/12/16: 30%->60; 6/3/17: 60%->100
- 911: 28/7/16: 26.981 added; 19/9/16: 0%->30; 1/12/16: 30%->50; 1/12/16: FCD:12/16->03/17; 6/3/17: 50%->100
- 912: 26/9/16: Compl:0%->30%; 6/10/16: 36.745 added; 20/12/16: Compl:30%->100%
- 913: continuation of GERAN SI UID 590034, DOMIMO under RAN626/9/16: Compl:0%->100%
- 914: 11/3: WID: SP-150050->150142; June2015: Compl:0%->20; 07/09/15: 20%->60. 07/12/15: Created by MCC as BB to dissociate SA1 versus SA2 aspects

| ID | WBS | Task | Type | Duration | Start | Finish | Complete | Remaining | Baseline start | Baseline finish | Baseline duration | Total slack | Constraint | Resources | Work | Actual work | Acronym | PCG approved | Impacted TSs and TRs | WI rapporteur name | WI rapporteur e-mail | Release | TSG approved | MCC resp | Special Focus Doc | Acronym_3GU_Export | Status Report | TSG stopped |
| --- | --- | --- | --- | --- | --- | --- | --- | --- | --- | --- | --- | --- | --- | --- | --- | --- | --- | --- | --- | --- | --- | --- | --- | --- | --- | --- | --- | --- |
| 915 | 354 | **Study on Stage 1 for New Services and Markets Technology Enablers** |  | 355d? | 2015-02-02 A | 2016-06-10 A | 100% |  |  |  |  |  |  | S1 | 10120h | 10120h | FS_SMARTER | 34 | New TR 22.891 | Adrian Neal (Vodafone) | adrian.neal@vodafone.com | Rel-14 | 67 |  |  |  |  |  |
| 916 | 354.1 | General aspects of FS_SMARTER SA1 |  | 270d? | 2015-02-02 A | 2016-02-12 A | 100% |  |  |  |  |  | finish no earlier than 2016-02-12 | S1 | 2160h | 2160h | FS_SMARTER | 34 | New TR 22.891 | Adrian Neal (Vodafone) | adrian.neal@vodafone.com | Rel-14 | 67 |  |  |  |  |  |
| 917 | 354.2 | FS_SMARTER – massive Internet of Things |  | 160d? | 2015-11-02 A | 2016-06-10 A | 100% |  |  |  |  |  | finish no earlier than 2016-06-10 | S1 | 1280h | 1280h | FS_SMARTER-mIoT | 36 | New TR 22.861 | Adrian Neal (Vodafone) | adrian.neal@vodafone.com | Rel-14 | 70 |  |  |  |  |  |
| 918 | 354.3 | FS_SMARTER – Critical Communications |  | 160d? | 2015-11-02 A | 2016-06-10 A | 100% |  |  |  |  |  | finish no earlier than 2016-06-10 | S1 | 1280h | 1280h | FS_SMARTER-CRIC | 36 | New TR 22.862 | Kanerva, Mikko | mikko.kanerva@nokia.com | Rel-14 | 70 |  |  |  |  |  |
| 919 | 354.4 | FS_SMARTER – enhanced Mobile Broadband |  | 160d? | 2015-11-02 A | 2016-06-10 A | 100% |  |  |  |  |  | finish no earlier than 2016-06-10 | S1 | 1280h | 1280h | FS_SMARTER-eMBB | 36 | New TR 22.863 | Laurence Meriau | laurence.meriau@huawei.com | Rel-14 | 70 |  |  |  |  |  |
| 920 | 354.5 | FS_SMARTER – Network Operation |  | 160d? | 2015-11-02 A | 2016-06-10 A | 100% |  |  |  |  |  | finish no earlier than 2016-06-10 | S1 | 1280h | 1280h | FS_SMARTER-NEO | 36 | New TR 22.864 | Lu Lu | lulu@chinamobile.com | Rel-14 | 70 |  |  |  |  |  |
| 921 | 355 | SA2 aspects on Study on Architecture and Security for next Generation System |  | 270d? | 2015-12-07 A | 2016-12-15 A | 100% |  |  |  |  |  | finish no earlier than 2016-12-15 | S2 | 2160h | 2160h | FS_NextGen | 36 | TR 23.799 | suntao@chinamobile.com, devaki.chandramouli@nokia.com | suntao@chinamobile.com, devaki.chandramouli@nokia.com | Rel-14 | 70 |  |  |  |  |  |
| 922 | 356 | Study on New Radio (NR) Access Technology |  | 263d? | 2016-03-15 A | 2017-03-15 A | 100% |  |  |  |  |  | finish no earlier than 2017-03-15 | R1 | 2104h | 2104h | FS_NR_newRAT | 36 | TR 38.801, TR 38.912; 38.802; 38.901; 38.805 | NTT DOCOMO |  | Rel-14 | 71 |  |  |  |  |  |
| 923 | 357 | Release 13 Features |  | 253.25d? | 2013-12-11 A | 2014-11-25 A | 100% |  | 2015-04-14 | 2015-12-25 | 183.25d? |  |  | SP; RP; CP; GP | 8104h | 8104h |  |  |  |  |  | Rel-13 |  |  |  |  |  |  |
| 924 | 358 | **Mission Critical Push To Talk over LTE (MCPTT)** |  | 1117d? | 2013-12-11 A | 2018-03-15 | 95% | 58.66d? | 2013-12-11 | 2015-06-17 | 397d? | 4627d |  |  | 38048h | 34769.8h | MCPTT | 32 | Stage 1/2; | NIST | david.cypher@nist.gov | Rel-13 | 62 | Alain | Public Safety (A-A) | MCPTT |  |  |
| 925 | 358.1 | Study on Application Architecture to support MCPTT |  | 326d? | 2014-06-23 A | 2015-09-16 A | 100% |  | 2014-06-18 | 2014-12-10 | 126d? |  | finish no earlier than 2015-09-16 | S6 | 2608h | 2608h | MCPTT | 33 | New TR 23.779 | Yannick Lair | yannick.lair@lge.com | Rel-13 | 64 |  | Public Safety (A-A) |  |  |  |
| 926 | 358.2 | SA2 Study on Architecture Enhancements at the EPS and IMS Level to Support MCPTT |  | 69d? | 2015-03-13 A | 2015-06-17 A | 100% |  |  |  |  |  | finish no earlier than 2015-06-17 | S2 | 552h | 552h | MCPTT | 34 |  | Randy Bloomfield (randy@its.bldrdoc.gov) | Randy Bloomfield (randy@its.bldrdoc.gov) | Rel-13 | 67 |  |  |  |  |  |
| 927 | 358.3 | Study on Security Enhancements for MCPTT |  | 261d? | 2015-03-13 A | 2016-03-11 A | 100% |  |  |  |  |  | finish no earlier than 2016-03-11 | S3 | 2088h | 2088h | MCPTT | 34 | 33.879; 33.280; 39.880 | Peter Haigh (peter.haigh at cesg.gsi.gov.uk) | Peter Haigh (peter.haigh at cesg.gsi.gov.uk) | Rel-13 | 67 |  |  |  |  |  |
| 928 | 358.4 | Study on media, codecs and MBMS enhancements for MCPTT |  | 326d? | 2014-12-12 A | 2016-03-11 | 85% | 48.9d? |  |  |  | 5152d | finish no earlier than 2016-03-11 | S4 | 2608h | 2216.8h | MCPTT | 34 | New TR 26.879 | Zhiming Li (lizhiming@huawei.com) | Zhiming Li (lizhiming@huawei.com) | Rel-13 | 67 |  |  |  |  |  |
| 929 | 358.5 | Stage 1 for MCPTT |  | 263d? | 2013-12-11 A | 2014-12-12 A | 100% |  | 2013-12-11 | 2014-12-10 | 261d? |  | finish no earlier than 2014-12-12 | S1 | 2104h | 2104h | MCPTT | 32 | New TS 22.179 | NIST | david.cypher@nist.gov | Rel-13 | 62 | Alain | Public Safety (A-A) |  | SP-140502 |  |
| 930 | 358.6 | Functional architecture and information flows to support MCPTT |  | 127d? | 2015-06-18 A | 2015-12-11 A | 100% |  | 2014-06-18 | 2014-12-10 | 126d? |  | finish no earlier than 2015-12-11 | S6 | 1016h | 1016h | MCPTT | 33 | New TS 23.179 | Yannick Lair | yannick.lair@lge.com | Rel-13 | 64 |  | Public Safety (A-A) |  |  |  |
| 931 | 358.7 | Security of MCPTT |  | 326d? | 2014-12-12 A | 2016-03-11 A | 100% |  |  |  |  |  | finish no earlier than 2016-03-11 | S3 | 2608h | 2608h | MCPTT | 34 | TS 33.179 | Peter Haigh (peter.haigh at cesg.gsi.gov.uk) | Peter Haigh (peter.haigh at cesg.gsi.gov.uk) | Rel-13 | 66 |  |  |  |  |  |
| 932 | 358.8 | MCPTT Codecs and media handling |  | 267d? | 2015-03-05 A | 2016-03-11 | 85% | 40.05d? |  |  |  | 5152d | finish no earlier than 2016-03-11 | S4 | 2136h | 1815.6h | MCPTT | 34 | 26.346, new TS 26.179 | Zhiming Li (lizhiming@huawei.com) | Zhiming Li (lizhiming@huawei.com) | Rel-13 | 67 |  |  |  |  |  |
| 933 | 358.9 | **MCPTT protocol aspects** |  | 215d? | 2015-09-07 A | 2016-06-30 | 96% | 9.64d? |  |  |  | 5072d |  | ct | 16584h | 14539h | MCPTT-CT | 35 |  | Keith Drage, Alcatel-Lucent |  | Rel-13 | 69 |  |  |  |  |  |
| 934 | 358.9.1 | **CT1 aspects for MCPTT protocol aspects** |  | 135d? | 2015-09-07 A | 2016-03-11 A | 100% |  |  |  |  |  |  | C1 | 10800h | 10800h | MCPTT-CT | 35 | 24.379, 24.380 24.38, 24.382, 24.383, 24.384, 24.229 | Samsung, Ricky Kaura | ricky.kaura@samsung.com | Rel-13 | 69 |  |  |  |  |  |
| 935 | 358.9.1.1 | Call Control – On Network |  | 135d? | 2015-09-07 A | 2016-03-11 A | 100% |  |  |  |  |  | finish no earlier than 2016-03-11 | C1 | 1080h | 1080h | MCPTT-CT | 35 | 24.379 | Samsung, Ricky Kaura | ricky.kaura@samsung.com | Rel-13 | 69 |  |  |  |  |  |
| 936 | 358.9.1.2 | Call Control – Off Network |  | 135d? | 2015-09-07 A | 2016-03-11 A | 100% |  |  |  |  |  | finish no earlier than 2016-03-11 | C1 | 1080h | 1080h | MCPTT-CT | 35 | 24.379 | Samsung, Ricky Kaura | ricky.kaura@samsung.com | Rel-13 | 69 |  |  |  |  |  |
| 937 | 358.9.1.3 | Floor Control – On Network |  | 135d? | 2015-09-07 A | 2016-03-11 A | 100% |  |  |  |  |  | finish no earlier than 2016-03-11 | C1 | 1080h | 1080h | MCPTT-CT | 35 | 24.380 | Samsung, Ricky Kaura | ricky.kaura@samsung.com | Rel-13 | 69 |  |  |  |  |  |
| 938 | 358.9.1.4 | Floor Control – Off Network |  | 135d? | 2015-09-07 A | 2016-03-11 A | 100% |  |  |  |  |  | finish no earlier than 2016-03-11 | C1 | 1080h | 1080h | MCPTT-CT | 35 | 24.380 | Samsung, Ricky Kaura | ricky.kaura@samsung.com | Rel-13 | 69 |  |  |  |  |  |
| 939 | 358.9.1.5 | Broadcast – Call Control and Floor Control |  | 135d? | 2015-09-07 A | 2016-03-11 A | 100% |  |  |  |  |  | finish no earlier than 2016-03-11 | C1 | 1080h | 1080h | MCPTT-CT | 35 | 24.379, 24.380 | Samsung, Ricky Kaura | ricky.kaura@samsung.com | Rel-13 | 69 |  |  |  |  |  |
| 940 | 358.9.1.6 | Group management |  | 135d? | 2015-09-07 A | 2016-03-11 A | 100% |  |  |  |  |  | finish no earlier than 2016-03-11 | C1 | 1080h | 1080h | MCPTT-CT | 35 | 24.381 | Samsung, Ricky Kaura | ricky.kaura@samsung.com | Rel-13 | 69 |  |  |  |  |  |
| 941 | 358.9.1.7 | Identity management |  | 135d? | 2015-09-07 A | 2016-03-11 A | 100% |  |  |  |  |  | finish no earlier than 2016-03-11 | C1 | 1080h | 1080h | MCPTT-CT | 35 | 24.382 | Samsung, Ricky Kaura | ricky.kaura@samsung.com | Rel-13 | 69 |  |  |  |  |  |
| 942 | 358.9.1.8 | Management Object |  | 135d? | 2015-09-07 A | 2016-03-11 A | 100% |  |  |  |  |  | finish no earlier than 2016-03-11 | C1 | 1080h | 1080h | MCPTT-CT | 35 | 24.383 | Samsung, Ricky Kaura | ricky.kaura@samsung.com | Rel-13 | 69 |  |  |  |  |  |
| 943 | 358.9.1.9 | Configuration management |  | 135d? | 2015-09-07 A | 2016-03-11 A | 100% |  |  |  |  |  | start no earlier than 2015-09-07 | C1 | 1080h | 1080h | MCPTT-CT | 36 | 24.384 | Samsung, Ricky Kaura | ricky.kaura@samsung.com | Rel-13 | 71 |  |  |  |  |  |
| 944 | 358.9.2 | CT3 aspects for MCPTT protocol aspects |  | 135d? | 2015-09-07 A | 2016-03-11 A | 100% |  |  |  |  |  | finish no earlier than 2016-03-11 | C3 | 1080h | 1080h | MCPTT-CT | 35 | 29.165 | Alcatel-Lucent, Keith Drage | keith.drage@alcatel-lucent.com | Rel-13 | 69 |  |  |  |  |  |
| 945 | 358.9.3 | CT4 aspects for MCPTT protocol aspects |  | 135d? | 2015-09-07 A | 2016-03-11 A | 100% |  |  |  |  |  | finish no earlier than 2016-03-11 | C4 | 1080h | 1080h | MCPTT-CT | 35 | 23.003, 23.008, 29.283 | Alcatel-Lucent, Keith Drage | keith.drage@alcatel-lucent.com | Rel-13 | 69 |  |  |  |  |  |
| 946 | 358.9.4 | CT6 aspects for MCPTT protocol aspects |  | 135d? | 2015-09-07 A | 2016-03-11 A | 100% |  |  |  |  |  | finish no earlier than 2016-03-11 | C6 | 1080h | 1080h | MCPTT-CT | 36 | 31.102, 31.103 | Alcatel-Lucent, Keith Drage | keith.drage@alcatel-lucent.com | Rel-13 | 70 |  |  |  |  |  |
| 947 | 358.9.5 | (IETF) IANA Registration of New SIP Resource- Priority Namespace for MCPTT |  | 103d? | 2016-02-10 A | 2016-06-30 | 25% | 77.25d? |  |  |  | 5072d | start no earlier than 2016-02-10 | C1-IETF | 824h | 206h | MCPTT-CT | 36 | draft-holmberg-dispatch-mcptt-rp-namespace | Ericsson | christer.holmberg@ericsson.com | Rel-13 | 71 |  |  |  |  |  |
| 948 | 358.10 | IMS Profile to support MCPTT |  | 130d? | 2015-09-14 A | 2016-03-11 A | 100% |  |  |  |  |  | finish no earlier than 2016-03-11 | C1 | 1040h | 1040h | MCPTT-Prof | 35 | 24.980 | Huawei, PATEL Milan | Milan.Patel@huawei.com | Rel-13 | 69 |  |  |  |  |  |
| 949 | 358.11 | UE Conformance Test Aspects - Support for Mission Critical Push To Talk over LTE (MCPTT) |  | 326d? | 2016-12-15 A | 2018-03-15 | 80% | 65.2d? |  |  |  | 4627d | finish no earlier than 2018-03-15 | R5 | 2608h | 2086.4h | MCPTT-ConTest | 38 | 36.579-5 | US Department of Commerce |  | Rel-13 | 74 |  |  |  |  |  |
| 950 | 358.12 | Deleted: SA2 aspects for MCPTT |  | 1d? | 2015-03-13 A | 2015-03-13 A | 100% |  | 2014-06-18 | 2015-06-17 | 261d? |  | finish no earlier than 2015-03-13 | S2 | 8h | 8h | MCPTT | 33 | New TS 23.179 | Randy Bloomfield (randy@its.bldrdoc.gov) | Randy Bloomfield (randy@its.bldrdoc.gov) | Rel-13 | 64 |  | Public Safety (A-A) |  |  | SP-69 |
| 951 | 358.13 | Deleted (duplicated): Application Architecture to support MCPTT | milestone | 0d? | 2015-03-13 A | 2015-03-13 A | 100% |  |  |  |  |  | finish no earlier than 2015-03-13 | S6 |  |  | MCPTT | 34 |  | U.S. Department of Commerce | Randy Bloomfield (randy@its.bldrdoc.gov) | Rel-13 | 67 |  |  |  |  | SP-69 |
| 952 | 358.14 | Deleted (duplicated): SA6 aspects for MCPTT |  | 261d? | 2014-12-12 A | 2015-12-11 A | 100% |  |  |  |  |  | finish no earlier than 2015-12-11 | S6 | 2088h | 2088h | MCPTT | 34 |  | David Cypher (david.cypher at nist.gov) | David Cypher (david.cypher at nist.gov) | Rel-13 | 66 |  |  |  |  | SP-69 |

Notes:
- 916: 7/12/15: 60%->85; 2/3/16: 85%->95; 7/6/17: 95%->100
- 917: 2/3/16: 35%->65; 9/6/16: 65%->100
- 918: 2/3/16: 15%->60; 9/6/16: 60%->95; 7/6/17: 95%->100
- 919: 2/3/16: 40%->75; 9/6/16: 75%->100
- 920: 2/3/16: 30%->60; 19/9/16: 60%->100
- 921: 28/1/16: 23.799 added; Acronym corrected ("NexGen"->"NextGen"); 7/3/16: 5%->15; 10/3/16: WID:SP-150853->SP-160200. Name changed from "Study on Architecture for next Generation System"; 9/6/16: 15%->35; 19/9/16: 35%->64; 22/9/16: WID:SP-160227->SP-16072
- 922: includes RAN TR 38.801; 1/7/16: Compl:0%->10%; 1/7/16: CD:Thu 15/06/17->Wed 15/03/17; 1/7/16: WID: RP-160671->RP-161214; 1/7/16: Release: Rel-15->Rel-14; 28/7/16: 38.802 added; 26/9/16: Compl:10%->20%; 26/9/16: WID: RP-161214->RP-161596. 2/12/16: Moved...; 21/3/17: 38.805 added;
- 923: -
- 924: SP#65 updated WID SP-140276=>SP-140435. Mar 15: WID: SP-140879->SP-150164. 4/15: S4 added. 6/15: WID updated
- 925: SP#65 completion 12/14=>06/15. Updated WID SP-140276=>SP-140435. Dec.14: 2->20%. Mar 15: WID: SP-140879->SP-150095. Mar15: 30%. Transferred to SA6. June 15: FCD shifted to Sept,WID updated; June2015: Compl:24%->50; June2015: Compl:50%->70. 3/8/15: Rapp
- 926: Mar 2015: WID: SP-140879->SP-150164.; June2015: Compl:0%->30, WID updated; 07/09/15: 30%->100, "To be confirmed" deleted, since SA2 has completed it.
- 927: Mar 2015: WID: SP-140879->SP-150164. Name clarified.6/15: WID updated; 7/12/15: 0%->75; 10/12/15: FCD->March, ES in SP-150729; 7/3/16: 75%->80; 28/7/16: 33.280 added; 28/7/16: 39.880 added; 1/12/16: 80%->100
- 928: Mar 2015: WID: SP-140879->SP-150164. Name clarified. 5/5/15: TR number added; June2015: Compl:0%->5, WID updated; Aug2015: 5%->15; 07/09/15: 15%->40; 7/12/15: 40%->80, FCD: 12/15->03/16; 7/3/16: 80%->85
- 929: SP#65 completion 09/14=>12/14. Exception in SP-140502. TS 22.179v100 for Information. Completed. Mar 15: WID: SP-140879->SP-150164. 6/15: WID updated
- 930: June2015: added as per SP-150356; June2015: Compl:0%->15. 31 July: Rapporteur corrected. 3/8/15: name aligned to the WID; 07/09/15: 15%->50; 07/09/15: 50%->85. 15/09/15: FCD: 09/15->12/15; 7/3/16: 85%->100
- 931: Mar 2015: WID: SP-140879->SP-150164. Name clarified. FCD: 03/2016->12/2015; June2015: Compl:5%->15, WID updated. 7/9/15: TS number added; 7/12/15: 15%->60. FCD -> 03/16, ES in SP-150729; 7/3/16: 60%->85; 1/12/16: 85%->98; 6/3/17: 98%->100
- 932: Mar 2015: WID: SP-140879->SP-150164. Name clarified. FCD: 03/2016->12/2015; June2015: Compl:0%->5, WID updated; Aug2015: 5%->15; 07/09/15: 15%->40. ES in SP-150663; 7/3/16: 40%->85
- 933: 7/12/15: WID:CP-150587->CP-150793; 28/1/16: 24.384 added;
- 934: 7/12/15: WID:CP-150587->CP-150793; 7/3/16: WID:CP-150863->CP-160160; 5/12/16: WID:CP-160160->CP-160817
- 935: Proposed by Atle after some talks with several interested parties; 7/12/15: 0%->50; 7/12/15: WID:CP-150587->CP-150863. FCD->03/16, ES in CP-150721; 7/3/16: 50%->100; 7/3/16: WID:CP-150863->CP-160160; 5/12/16: WID:CP-160160->CP-160817
- 936: Proposed by Atle after some talks with several interested parties; 7/12/15: 0%->75; 7/12/15: WID:CP-150587->CP-150863. FCD->03/16, ES in CP-150721; 7/3/16: 75%->100; 7/3/16: WID:CP-150863->CP-160160; 5/12/16: WID:CP-160160->CP-160817
- 937: Proposed by Atle after some talks with several interested parties; 7/12/15: 0%->80; 7/12/15: WID:CP-150587->CP-150863. FCD->03/16, ES in CP-150721; 7/3/16: 80%->100; 7/3/16: WID:CP-150863->CP-160160; 5/12/16: WID:CP-160160->CP-160817
- 938: Proposed by Atle after some talks with several interested parties; 7/12/15: 0%->85; 7/12/15: WID:CP-150587->CP-150863. FCD->03/16, ES in CP-150721; 7/3/16: 85%->100; 7/3/16: WID:CP-150863->CP-160160; 5/12/16: WID:CP-160160->CP-160817
- 939: Proposed by Atle after some talks with several interested parties; 7/12/15: 0%->50; 7/12/15: WID:CP-150587->CP-150863. FCD->03/16, ES in CP-150721; 7/3/16: 50%->100; 7/3/16: WID:CP-150863->CP-160160; 5/12/16: WID:CP-160160->CP-160817
- 940: Proposed by Atle after some talks with several interested parties; 7/12/15: 0%->75; 7/12/15: WID:CP-150587->CP-150863. FCD->03/16, ES in CP-150721; 7/3/16: 75%->100; 7/3/16: WID:CP-150863->CP-160160; 5/12/16: WID:CP-160160->CP-160817
- 941: Proposed by Atle after some talks with several interested parties; 7/12/15: WID:CP-150587->CP-150863. FCD->03/16, ES in CP-150721; 7/3/16: 0%->100; 7/3/16: WID:CP-150863->CP-160160; 5/12/16: WID:CP-160160->CP-160817
- 942: Proposed by Atle after some talks with several interested parties; 7/12/15: 0%->10; 7/12/15: WID:CP-150587->CP-150863. FCD->03/16, ES in CP-150721; 7/3/16: 10%->100. Name changed from "Configuration management"; 7/3/16: WID:CP-150863->CP-160160; 5/12/1
- 943: Introduced from CT1 WP update in 03/16; 7/3/16: WID:CP-150863->CP-160160; 5/12/16: WID:CP-160160->CP-160817
- 944: 7/12/15: 0%->70; 7/12/15: WID:CP-150587->CP-150863. FCD -> 03/16, ES in CP-150643; 7/3/16: 70%->100; 7/3/16: WID:CP-150863->CP-160160; 5/12/16: WID:CP-160160->CP-160817
- 945: 7/12/15: WID:CP-150587->CP-150863. FCD -> 03/16, ES in CP-150864; 7/3/16: 0%->100; 7/3/16: WID:CP-150863->CP-160160; 5/12/16: WID:CP-160160->CP-160817
- 946: 7/12/15: WID:CP-150587->CP-150863. FCD -> 03/16, ES in CP-150866; 7/3/16: 0%->100; 7/3/16: WID:CP-150863->CP-160160; 5/12/16: WID:CP-160160->CP-160817
- 947: 5/12/16: WID:CP-160160->CP-160817
- 948: 12/15: TR # added; 7/12/15: 0%->60; 7/12/15: WID:CP-150500->CP-150794. FCD -> 03/16, ES in CP-150722; 7/3/16: 60%->100
- 949: 6/1/17: acronym changed from "MCPTT-UEConTest" ; 21/3/17: Compl:0%->5%; 21/3/17: 36.579-5 added;...; ;...; ;...
- 950: Mar 2015: transferred to SA6. Was 06/14 to 06/15. 6/15: WID updated
- 951: Mar 2015: WID: SP-140879->SP-150164. Name clarified.6/15: WID updated. 7/15: removed since duplicates 640143 and 660054 (only 640143 is kept)
- 952: Mar 2015: WID: SP-140879->SP-150164. Name clarified. 6/15: WID updated. 31 July: deleted since duplicates 640143 and 670031 (only 640143 is kept)

| ID | WBS | Task | Duration | Start | Finish | Complete | Remaining | Baseline start | Baseline finish | Baseline duration | Total slack | Constraint | Resources | Work | Actual work | Acronym | PCG approved | Impacted TSs and TRs | WI rapporteur name | WI rapporteur e-mail | Release | TSG approved | MCC resp | Status Report | Special Focus Doc | Acronym_3GU_Export |
| --- | --- | --- | --- | --- | --- | --- | --- | --- | --- | --- | --- | --- | --- | --- | --- | --- | --- | --- | --- | --- | --- | --- | --- | --- | --- | --- |
| 953 | 359 | **MBMS Extensions and Profiling** | 202d? | 2015-03-05 A | 2015-12-11 A | 100% |  |  |  |  |  |  | S4 | 4848h | 4848h | MEPRO | 34 | 26.346, new TR 26.852 | Imed Bouazizi, Samsung and Thorsten Lohmar, Ericsson | i.bouazizi@samsung.com, thorsten.lohmar@ericsson.com | Rel-13 | 67 |  |  |  |  |
| 954 | 359.1 | TR on Profiling and Extensions of MBMS | 202d? | 2015-03-05 A | 2015-12-11 A | 100% |  |  |  |  |  | finish no earlier than 2015-12-11 | S4 | 1616h | 1616h | MEPRO | 34 | new TR 26.852 | Imed Bouazizi, Samsung and Thorsten Lohmar, Ericsson | i.bouazizi@samsung.com, thorsten.lohmar@ericsson.com | Rel-13 | 67 |  |  |  |  |
| 955 | 359.2 | Specification of MBMS Extensions and Profiling | 202d? | 2015-03-05 A | 2015-12-11 A | 100% |  |  |  |  |  | start no earlier than 2015-03-05 | S4 | 1616h | 1616h | MEPRO | 34 | 26.346 | Imed Bouazizi, Samsung and Thorsten Lohmar, Ericsson | i.bouazizi@samsung.com, thorsten.lohmar@ericsson.com | Rel-13 | 67 |  |  |  |  |
| 956 | 360 | **Isolated E-UTRAN Operation for Public Safety** | 529d? | 2014-03-07 A | 2016-03-11 A | 100% |  | 2014-03-07 | 2014-09-17 | 139d? |  |  | S1 | 8600h | 8600h | IOPS | 32 | New TS 22.346 | General Dynamics | paul.piggin@gd-broadband.com | Rel-13 | 63 | Alain | S1-143304 | Public Safety (A-A) | IOPS |
| 957 | 360.1 | Stage 1 fo Isolated E-UTRAN Operation for Public Safety | 140d? | 2014-03-07 A | 2014-09-17 A | 100% |  | 2014-03-07 | 2014-09-17 | 139d? |  | finish no earlier than 2014-09-17 | S1 | 1120h | 1120h | IOPS | 32 | New TS 22.346 | General Dynamics | paul.piggin@gd-broadband.com | Rel-13 | 63 | Alain | S1-143304 | Public Safety (A-A) | IOPS |
| 958 | 360.2 | Stage 2 for Isolated E-UTRAN Operation for Public Safety | 140d? | 2015-06-18 A | 2015-12-30 A | 100% |  | 2014-03-07 | 2014-09-17 | 139d? |  | start no earlier than 2015-06-18 | S2 | 1120h | 1120h | IOPS | 32 | 23.401 | Phil Young | phil.young@gd-broadband.com | Rel-13 | 63 | Alain |  | Public Safety (A-A) | IOPS |
| 959 | 360.3 | Security aspects for Isolated E-UTRAN Operation for Public Safety | 76d? | 2015-09-16 A | 2015-12-30 A | 100% |  | 2014-03-07 | 2014-09-17 | 139d? |  | start no earlier than 2015-09-16 | S3 | 608h | 608h | IOPS | 32 | TS 33.401 | General Dynamics | paul.piggin@gd-ms.uk | Rel-13 | 63 | Alain |  | Public Safety (A-A) | IOPS |
| 960 | 360.4 | **CT aspects for IOPS** | 95d? | 2015-11-02 A | 2016-03-11 A | 100% |  |  |  |  |  |  | C6 | 1520h | 1520h | IOPS-CT | 36 |  | Heiko Kruse, Morpho Cards GmbH | heiko.kruse@mrpho.com | Rel-13 | 70 |  |  |  |  |
| 961 | 360.4.1 | CT6 aspects for IOPS | 95d? | 2015-11-02 A | 2016-03-11 A | 100% |  |  |  |  |  | finish no earlier than 2016-03-11 | C6 | 760h | 760h | IOPS-CT | 36 | 31.102 | Heiko Kruse, Morpho Cards GmbH | heiko.kruse@mrpho.com | Rel-13 | 70 |  |  |  |  |
| 962 | 361 | Service Requirements Maintenance for Group Communication System Enablers for LTE | 67d? | 2014-06-18 A | 2014-09-17 A | 100% |  | 2014-06-18 | 2014-09-17 | 66d? |  | finish no earlier than 2014-09-17 | S1 | 536h | 536h | SRM_GCSE_LTE | 33 | 22.468 | Nokia Networks | Juergen.Merkel@nsn.com | Rel-13 | 64 |  | S1-143307 | Public Safety (A-A) | SRM_GCSE_LTE |
| 963 | 362 | Enhanced Calling Information Presentation | 330d? | 2014-09-15 A | 2015-12-16 A | 100% |  | 2013-12-11 | 2014-09-17 | 201d? |  | finish no earlier than 2015-12-16 | S1 | 2640h | 2640h | ECIP | 32 | 22.182 (CAT), 22.183 (CRS) | China Mobile | LI Xiaofan (lixiaofan@chinamobile.com | Rel-13 | 62 | Alain | S1-143311 |  | ECIP |
| 964 | 363 | **Flexible Mobile Service Steering** | 392d? | 2014-09-15 A | 2016-03-11 | 100% | 0d? | 2013-12-11 | 2014-09-17 | 202d? | 0d |  | S1; S2 | 7943.76h | 6367.76h | FMSS | 33 | 22.101 | China Mobile | Lu Lu (lulu@chinamobile.com) | Rel-13 | 65 | Alain | S1-143310 |  | FMSS |
| 965 | 363.1 | Stage 1 for Flexible Mobile Service Steering | 3d? | 2014-09-15 A | 2014-09-17 A | 100% |  | 2013-12-11 | 2014-09-17 | 202d? |  | start no earlier than 2014-09-15 | S1 | 23.85h | 23.85h | FMSS-ST1 | 33 | 22.101 | China Mobile | Lu Lu (lulu@chinamobile.com) | Rel-13 | 65 | Alain | S1-143310 |  | FMSS |
| 966 | 363.2 | Flexible Mobile Service Steering TR Phase | 134d? | 2014-12-12 A | 2015-06-17 A | 100% |  |  |  |  |  | finish no earlier than 2015-06-17 | S2 | 1072h | 1072h | FMSS-SA2TR | 34 | 23.718 | Lu Lu, China Mobile | lulu@chinamobile.com | Rel-13 | 66 |  |  |  |  |
| 967 | 363.3 | Flexible Mobile Service Steering - Stage 2 | 134d? | 2014-12-12 A | 2015-06-17 A | 100% |  |  |  |  |  | start no earlier than 2014-12-12 | S2 | 1072h | 1072h | FMSS-SA2 | 34 |  | Lu Lu, China Mobile | lulu@chinamobile.com | Rel-13 | 66 |  |  |  |  |
| 968 | 363.4 | CT3 Aspect of Flexible Mobile Service Steering | 133d? | 2015-09-09 A | 2016-03-11 A | 100% |  |  |  |  |  | finish no earlier than 2016-03-11 | C3 | 1064h | 1064h | FMSS-CT | 35 | 29.abc, 29.212, 29.213 | ZTE,Zhou Xiaoyun | zhou.xiaoyun@zte.com.cn | Rel-13 | 69 |  |  |  |  |
| 969 | 364 | GERAN UTRAN Sharing Enhancements | 63d? | 2014-09-19 A | 2014-12-12 A | 100% |  |  |  |  |  | finish no earlier than 2014-12-12 | S1 | 504h | 504h | GUSH | 33 | 22.101 | Telefónica | chris.friel@telefonica.com | Rel-13 | 65 |  | SP-140515 |  | GUSH |
| 970 | 365 | **Application specific Congestion control for Data Communication** | 456d? | 2014-06-18 A | 2016-03-11 | 100% | 0d? | 2014-06-18 | 2014-09-17 | 66d? | 0d |  | S1; C1 | 17920h | 14808h | ACDC | 33 | 22.011 | NTT DOCOMO | Atsushi Minokuchi (minokuchi@nttdocomo.co.jp) | Rel-13 | 64 |  | S1-143305 |  | ACDC |
| 971 | 365.1 | Stage 1 for Application specific Congestion control for Data Communication | 67d? | 2014-06-18 A | 2014-09-17 A | 100% |  | 2014-06-18 | 2014-09-17 | 66d? |  | finish no earlier than 2014-09-17 | S1 | 536h | 536h | ACDC-ST1 | 33 | 22.011 | NTT DOCOMO | Atsushi Minokuchi (minokuchi@nttdocomo.co.jp) | Rel-13 | 64 |  | S1-143305 |  | ACDC |
| 972 | 365.2 | **Stage 3 for Application specific Congestion control for Data Communication** | 332d? | 2014-12-04 A | 2016-03-11 A | 100% |  |  |  |  |  |  | C1 | 7472h | 7472h | ACDC-CT | 34 | TS 24.105, 24.301, 24.008, 27.007, 31.102 | Kim, Jaehyun, LGE | jaehyun7.kim@lge.com | Rel-13 | 66 |  |  |  |  |
| 973 | 365.2.1 | CT1 part of Stage 3 for Application specific Congestion control for Data Communication | 270d? | 2014-12-04 A | 2015-12-16 A | 100% |  |  |  |  |  | finish no earlier than 2015-12-16 | C1 | 2160h | 2160h | ACDC-CT | 34 | 24.105, 24.301, 24.008, 27.007, 23.122 | Kim, Jaehyun, LGE | jaehyun7.kim@lge.com | Rel-13 | 66 |  |  |  |  |
| 974 | 365.2.2 | CT6 part of Stage 3 for Application specific Congestion control for Data Communication | 332d? | 2014-12-04 A | 2016-03-11 A | 100% |  |  |  |  |  | finish no earlier than 2016-03-11 | C6 | 2656h | 2656h | ACDC-CT | 34 | 31.102 | Kim, Jaehyun, LGE | jaehyun7.kim@lge.com | Rel-13 | 66 |  |  |  |  |
| 975 | 365.3 | **RAN aspects of Application specific Congestion control for Data Communication** | 197d? | 2015-03-16 A | 2015-12-15 A | 100% |  |  |  |  |  |  | R2 | 3152h | 3152h | ACDC-RAN | 34 |  | LG Electronics |  | Rel-13 | 67 |  |  |  |  |
| 976 | 365.3.1 | Core part: RAN aspects of Application specific Congestion control for Data Communication | 197d? | 2015-03-16 A | 2015-12-15 A | 100% |  |  |  |  |  | finish no earlier than 2015-12-15 | R2 | 1576h | 1576h | ACDC-RAN-Core | 34 |  | LG Electronics |  | Rel-13 | 67 |  | RP-151275 |  |  |

Notes:
- 953: 1/4/15: TS number added; 14/09/15: WID:SP-150099->SP-150439
- 954: 8/4/15: line added; June2015: Compl:0%->10; Aug2015: 10%->15; 07/09/15: 15%->40; 14/09/15: WID:SP-150099->SP-150439; 7/12/15: 40%->100
- 955: 8/4/15: line added; June2015: Compl:0%->10; Aug2015: 10%->15; 07/09/15: 15%->40; 14/09/15: WID:SP-150099->SP-150439; 7/12/15: 40%->100
- 956: SP#65 completed. TS 22.346v100 for 1-step Approval. Triggered by Rel-13 TR 22.897 (FS_IOPS); 14/09/15: WID:SP 150358->SP-150463
- 957: SP#65 completed. TS 22.346v100 for 1-step Approval. Triggered by Rel-13 TR 22.897 (FS_IOPS); 14/09/15: WID:SP 150358->SP-150463
- 958: 07/09/15: 0%->100; 14/09/15: WID:SP 150358->SP-150463
- 959: 07/09/15: 0%->100; 11/12/15: 0%->100
- 961: ES in CP-150837; 7/3/16: 0%->100
- 962: SP#65 completed. Some Rel-12 service reqs have no Stage 2/3 implementation
- 963: SP#65 approved WID & completed. Triggered by Rel-13 TR 22.810. Linked to Multimedia Telephony Service for IMS (UID_7038), Customized Alerting Tone (CAT) UID_370028, Customized Ringing Signal (CRS) UID_380067. 31/07/15: 100%
- 964: SP#65 WID approved & completed. Triggered by Rel-13 TR 22.808 (FS_FMSS)
- 965: SP#65 WID approved & completed. Triggered by Rel-13 TR 22.808 (FS_FMSS). Dec.14: moved from Feature to S1 BB
- 966: 3/3: TR number added.Mar15: 15->20%; June2015: Compl:20%->85; 07/09/15: 85%->100
- 967: 07/09/15: 0%->90; 07/09/15: 90%->100
- 968: 07/09/15: 0%->20; 14/09/15: WID:CP-150488->CP-150577; 7/12/15: 20%->90; 7/12/15: WID:CP-150577->CP-150799. FCD -> 03/16. ES in CP-150646; 7/3/16: 90%->100
- 969: SP#65 exception in SP-140515. Triggered by TR 22.852 (FS_RSE and FS_GUSH). Completed.
- 970: SP#65 completed. Triggered by Rel-13 Study TR 22.806
- 971: Results from MCC Split of the SA1 feature into F+BB for stage 1
- 972: Presented at CT#66. June 2015: FCD: June->Dec 2015, WID: CP-140999-> CP-150282
- 973: Presented at CT#66; June2015: Compl:0%->10. June 2015: FCD: June->Dec 2015, WID: CP-140999-> CP-150282; 07/09/15: 5%->70; 7/12/15: 70%->100
- 974: Presented at CT#66. June 2015: FCD: June->Dec 2015, WID: CP-140999-> CP-150282. 12/15: FCD -> 03/16, ES in CP-150838; 7/3/16: 0%->100
- 976: 03/07/15: Compl:0%->25% 03/07/15: WID: RP-150512->RP-150662 03/07/15: Stat Rep: ->RP-150661 29/09/15: Compl:25%->70% 29/09/15: Stat Rep: RP-150661->RP-151275; 1/1/16: Compl:70%->100%

| ID | WBS | Task | Duration | Start | Finish | Complete | Remaining | Baseline start | Baseline finish | Baseline duration | Total slack | Constraint | Resources | Work | Actual work | Acronym | PCG approved | WI rapporteur name | WI rapporteur e-mail | Release | TSG approved | MCC resp | Acronym_3GU_Export | PCG stopped | TSG stopped | Status Report |
| --- | --- | --- | --- | --- | --- | --- | --- | --- | --- | --- | --- | --- | --- | --- | --- | --- | --- | --- | --- | --- | --- | --- | --- | --- | --- | --- |
| 977 | 366 | **User Plane Congestion management** | 667d? | 2012-09-12 A | 2015-03-18 A | 100% |  | 2012-02-02 | 2015-06-17 | 890d? |  |  | S1; S2; C3; C4 | 39368h | 39368h | UPCON | 29 | KDDI | Eriko Yoshida (er-yoshida@kddi.com) | Rel-13 | 57 | Alain | UPCON |  |  |  |
| 978 | 366.1 | Stage 1 for User Plane Congestion management | 129d? | 2012-09-12 A | 2013-03-06 A | 100% |  | 2012-02-02 | 2013-03-06 | 289d? |  | start no earlier than 2012-09-12 | S1 | 1032h | 1032h | UPCON-ST1 | 29 | KDDI | Eriko Yoshida (er-yoshida@kddi.com) | Rel-13 | 57 | Alain |  |  |  |  |
| 979 | 366.2 | TR on Stage 2 for User Plane Congestion management | 595d? | 2012-12-12 A | 2015-03-18 A | 100% |  | 2012-12-12 | 2014-12-10 | 525d? |  | finish no earlier than 2015-03-18 | S2 | 4760h | 4760h | UPCON-SA2TR | 30 | Allot | Alla Goldner (agoldner@allot.com) | Rel-13 | 58 | Maurice |  |  |  |  |
| 980 | 366.3 | Deleted - Stage 2 for User Plane Congestion management | 261d? | 2012-12-19 A | 2013-12-11 A | 100% |  | 2012-12-19 | 2013-12-11 | 261d? |  | finish no earlier than 2013-12-11 | S2 | 2088h | 2088h | UPCON-SA2Del | 30 | NEC | andreas.maeder@neclab.eu | Rel-13 | 58 | Maurice |  | PCG-32 | SP-62 |  |
| 981 | 366.4 | **BB1: RAN Downlink Traffic Differentiation, Congestion Detection and Reporting** | 269d? | 2014-03-07 A | 2015-03-13 A | 100% |  | 2014-03-07 | 2015-06-17 | 334d? |  |  | S2 | 10048h | 10048h | UPCON-DOTCON | 32 | Allot | Alla Goldner (agoldner@allot.com) | Rel-13 | 63 | Maurice | UPCON-DOTCON |  |  |  |
| 982 | 366.4.1 | Stage 2 for RAN Downlink Traffic Differentiation, Congestion Detection and Reporting | 201d? | 2014-03-07 A | 2014-12-12 A | 100% |  | 2014-03-07 | 2015-06-17 | 334d? |  | finish no earlier than 2014-12-12 | S2 | 1608h | 1608h | UPCON-DOTCON-SA2 | 32 | Allot | Alla Goldner (agoldner@allot.com) | Rel-13 | 63 | Maurice |  |  |  |  |
| 983 | 366.4.2 | **CT aspects of User Plane Congestion Management for BB1** | 262d? | 2014-03-18 A | 2015-03-13 A | 100% |  |  |  |  |  |  | C3 | 6288h | 6288h | UPCON-DOTCON-CT | 33 | Huawei | Xia Haitao (xiahaitao@huawei.com) | Rel-13 | 65 |  | UPCON-DOTCON-CT |  |  |  |
| 984 | 366.4.2.1 | CT3 part of CT aspects of User Plane Congestion Management for BB1 | 262d? | 2014-03-18 A | 2015-03-13 A | 100% |  |  |  |  |  | finish no earlier than 2015-03-13 | C3 | 2096h | 2096h | UPCON-DOTCON-CT | 33 | Huawei | Xia Haitao (xiahaitao@huawei.com) | Rel-13 | 65 |  |  |  |  |  |
| 985 | 366.4.2.2 | CT4 part of CT aspects of User Plane Congestion Management for BB1 | 262d? | 2014-03-18 A | 2015-03-13 A | 100% |  |  |  |  |  | finish no earlier than 2015-03-13 | C4 | 2096h | 2096h | UPCON-DOTCON-CT | 33 | Huawei | Xia Haitao (xiahaitao@huawei.com) | Rel-13 | 65 |  |  |  |  |  |
| 986 | 366.5 | Deleted - BB2: Application and Content Prioritization | 140d? | 2014-03-07 A | 2014-09-17 A | 100% |  | 2014-03-07 | 2015-06-17 | 334d? |  | finish no earlier than 2014-09-17 | S2 | 1120h | 1120h | UPCON-CONDEL | 32 | Allot | Alla Goldner (agoldner@allot.com) | Rel-13 | 63 | Maurice | UPCON-CON | PCG-33 | SP-65 |  |
| 987 | 366.6 | Deleted - BB3: Uplink traffic and attended/unattended traffic | 140d? | 2014-03-07 A | 2014-09-17 A | 100% |  | 2014-03-07 | 2015-06-17 | 334d? |  | finish no earlier than 2014-09-17 | S2 | 1120h | 1120h | UPCON-TRAFDEL | 32 | Allot | Alla Goldner (agoldner@allot.com) | Rel-13 | 63 | Maurice | UPCON-TRAF | PCG-33 | SP-65 |  |
| 988 | 367 | **Media Handling Aspects of IMS-based Telepresence** | 660d? | 2014-09-09 A | 2017-03-15 | 79% | 141.71d? |  |  |  | 4888d |  | S4 | 20696h | 14760.4h | IMS_TELEP_S4 | 33 | Intel | ozgur.oyman@intel.com | Rel-13 | 65 |  | IMS_TELEP_S4 |  |  |  |
| 989 | 367.1 | TR on Media Handling Aspects of IMS-based Telepresence | 269d? | 2014-09-09 A | 2015-09-16 A | 100% |  |  |  |  |  | finish no earlier than 2015-09-16 | S4 | 2152h | 2152h | IMS_TELEP_S4 | 33 | Intel | ozgur.oyman@intel.com | Rel-13 | 65 |  |  |  |  |  |
| 990 | 367.2 | Specification on Media Handling Aspects of IMS-based Telepresence | 334d? | 2014-09-09 A | 2015-12-16 A | 100% |  |  |  |  |  | finish no earlier than 2015-12-16 | S4 | 2672h | 2672h | IMS_TELEP_S4 | 33 | Intel | ozgur.oyman@intel.com | Rel-13 | 65 |  |  |  |  |  |
| 991 | 367.3 | (IETF) CLUE Protocol (draft-ietf-clue-protocol) | 331d? | 2015-12-10 A | 2017-03-15 | 60% | 132.4d? |  |  |  | 4888d | finish no earlier than 2017-03-15 | S4-IETF | 2648h | 1588.8h | IMS_TELEP_S4 | 36 | Intel | ozgur.oyman@intel.com | Rel-13 | 71 |  |  |  |  |  |
| 992 | 367.4 | (IETF) Mapping RTP streams to CLUE media captures (draft-ietf-clue-rtp-mapping) | 331d? | 2015-12-10 A | 2017-03-15 | 60% | 132.4d? |  |  |  | 4888d | finish no earlier than 2017-03-15 | S4-IETF | 2648h | 1588.8h | IMS_TELEP_S4 | 36 | Intel | ozgur.oyman@intel.com | Rel-13 | 71 |  |  |  |  |  |
| 993 | 367.5 | (IETF) DTLS Encapsulation of SCTP Packets (draft-ietf-tsvwg-sctp-dtls-encaps) | 331d? | 2015-12-10 A | 2017-03-15 | 95% | 16.55d? |  |  |  | 4888d | finish no earlier than 2017-03-15 | S4-IETF | 2648h | 2515.6h | IMS_TELEP_S4 | 36 | Intel | ozgur.oyman@intel.com | Rel-13 | 71 |  |  |  |  |  |
| 994 | 367.6 | (IETF) Using Simulcast in SDP and RTP Sessions (draft-ietf-mmusic-sdp-simulcast) | 331d? | 2015-12-10 A | 2017-03-15 | 60% | 132.4d? |  |  |  | 4888d | finish no earlier than 2017-03-15 | S4-IETF | 2648h | 1588.8h | IMS_TELEP_S4 | 36 | Ericsson | tomas.frankkila@ericsson.com | Rel-13 | 71 |  |  |  |  |  |
| 995 | 368 | **RAN Sharing Enhancements** | 657d? | 2013-06-19 A | 2015-12-15 A | 100% |  | 2013-06-19 | 2013-12-11 | 129d? |  |  | S1; R3 | 16824h | 16824h | RSE | 31 | NEC | joerg.swetina@neclab.eu | Rel-13 | 60 | Alain | RSE |  |  |  |
| 996 | 368.1 | Stage 1 for RAN Sharing Enhancements | 129d? | 2013-06-19 A | 2013-12-11 A | 100% |  | 2013-06-19 | 2013-12-11 | 129d? |  |  | S1 | 1032h | 1032h | RSE-SA1 | 31 | NEC | joerg.swetina@neclab.eu | Rel-13 | 60 | Alain |  |  |  |  |
| 997 | 368.2 | **RAN aspects of RAN Sharing Enhancements for LTE** | 330d? | 2014-09-12 A | 2015-12-15 A | 100% |  | 2014-06-13 | 2015-06-12 | 261d? |  |  | R3 | 5280h | 5280h | RSE-RAN_LTE | 33 | NEC | Siva.Vakeesar@emea.nec.com | Rel-13 | 65 |  | RSE-RAN_LTE |  |  |  |
| 998 | 368.2.1 | Core part: RAN aspects of RAN Sharing Enhancements for LTE | 330d? | 2014-09-12 A | 2015-12-15 A | 100% |  | 2014-06-13 | 2015-06-12 | 261d? |  | finish no earlier than 2015-12-15 | R3 | 2640h | 2640h | RSE-RAN_LTE-Core | 33 | NEC | Siva.Vakeesar@emea.nec.com | Rel-13 | 65 |  | RSE-RAN_LTE-Core |  |  | RP-151295 |
| 999 | 369 | **Enhancements to WEBRTC interoperability** | 529d? | 2014-03-07 A | 2016-03-11 | 95% | 24.12d? | 2014-03-07 | 2015-06-17 | 334d? | 5152d |  | S1; S2; S3 | 27336h | 16630.6h | eWebRTCi | 32 | Alcatel-Lucent | betsy.covell@alcatel-lucent.com | Rel-13 | 63 | Alain | eWebRTCi |  |  |  |
| 1000 | 369.1 | Stage 1 for Enhancements to WEBRTC interoperability | 139d? | 2014-03-07 A | 2014-09-17 A | 100% |  | 2014-03-07 | 2014-09-17 | 139d? |  | finish no earlier than 2014-09-17 | S1 | 1112h | 1112h | eWebRTCi | 32 | Alcatel-Lucent | betsy.covell@alcatel-lucent.com | Rel-13 | 63 | Alain |  |  |  | S1-143303 |
| 1001 | 369.2 | TR on Stage 2 for Enhancements to WEBRTC interoperability | 196d? | 2014-06-19 A | 2015-03-18 A | 100% |  | 2014-06-18 | 2015-03-18 | 196d? |  | finish no earlier than 2015-03-18 | S2 | 1568h | 1568h | eWebRTCi | 33 | China Mobile | Yu Qing (yuqing@chinamobile.com) | Rel-13 | 64 |  |  |  |  |  |
| 1002 | 369.3 | Stage 2 for Enhancements to WEBRTC interoperability | 261d? | 2014-06-23 A | 2015-06-17 A | 100% |  | 2014-06-18 | 2015-06-17 | 261d? |  | finish no earlier than 2015-06-17 | S2 | 2088h | 2088h | eWebRTCi | 33 | China Mobile | Yu Qing (yuqing@chinamobile.com) | Rel-13 | 64 |  |  |  |  |  |
| 1003 | 369.4 | TR on Security for Enhancements to WEBRTC interoperability | 273d? | 2014-09-17 A | 2015-09-30 A | 100% |  |  |  |  |  | start no earlier than 2014-09-17 | S3 | 2184h | 2184h | eWebRTCi | 33 | Ericsson | vesa.lehtovirta@ericsson.com | Rel-13 | 65 |  |  |  |  |  |
| 1004 | 369.5 | Security for Enhancements to WEBRTC interoperability | 273d? | 2014-09-17 A | 2015-09-30 A | 100% |  |  |  |  |  | start no earlier than 2014-09-17 | S3 | 2184h | 2184h | eWebRTCi | 33 | Ericsson | vesa.lehtovirta@ericsson.com | Rel-13 | 65 |  |  |  |  |  |
| 1005 | 369.6 | (IETF) Session Traversal Utilities for NAT (STUN) Extension for Third Party Authorization (draft-ietf-tram-turn-third-party-authz) | 198d? | 2014-09-17 A | 2015-08-12 A | 100% |  |  |  |  |  | start no earlier than 2014-09-17 | S3-IET | 1584h | 1584h | eWebRTCi | 35 | Alcatel-Lucent |  | Rel-13 | 69 |  |  |  |  |  |

Notes:
- 977: SP#65 updated WID SP-140153=>SP-140631 (BBII & BBIII stopped). Triggered by Rel-12 TR 22.805 Study on User Plane Congestion management (FS_UPCON) / Impacted TSs and TRs: Stage 1/2/3
- 978: SP#63 moved to Rel-13 updated WID SP-120890=>SP-140153. SP#59 completed. Convert TR 22.805 clause 6 consolidated requirements to normative requirements in 22.101. 3/3/15: start date corrected (was Mar 12) / Impacted TSs and TRs: 22.101
- 979: SP#65 updated WID SP-140153=>SP-140631. TR 23.705v100 for Information. Dec.14: 87->98%. Mar15: 100% / Impacted TSs and TRs: new TR 23.705
- 980: SP#62 stopped at 0% completion / Impacted TSs and TRs: TBD
- 981: SP#65 updated WID SP-140153=>SP-140631. IncludES in CP-150RAN Congestion Detection: , RAN Traffic Differentiation, RAN Congestion Reporting, CN Congestion Mitigation mechanisms, Dynamic Policy Control
- 982: SP#65 updated WID SP-140153=>S2-142850 (added impacted specs). Dec.14: 70->100% only if RAN agrees to standardize the FPI / Impacted TSs and TRs: 23.060, 23.203, 23.401
- 983: Stage 3; WID: CP-140734->CP-140929. June 2015: WID: CP-140929-> CP-150365. / Impacted TSs and TRs: Stage 3
- 984: Dec.14: 0->60; WID: CP-140734->CP-140929. Mar.15: 60->95%; June2015: Compl:95%->100. WID: CP-140929-> CP-150365. / Impacted TSs and TRs: 29.201, 29.212, 29.213, 29.214, 29.215, 29.219, New TS 29.217 (PCC over Np)
- 985: Dec.14: 0->20; WID: CP-140734->CP-140929. Mar. 15: 50%; June2015: Compl:50%->90. WID: CP-140929-> CP-150365.; 07/09/15: 90%->100 / Impacted TSs and TRs: 23.003, 29.303, New TS 29.405 (UPCON over Nq)
- 986: SP#65 updated WID SP-140153=>SP-140631 (BBII & BBIII stopped). IncludES in CP-150Content specific UP prioritization (Video), Application specific UP prioritization / Impacted TSs and TRs: TBD
- 987: SP#65 updated WID SP-140153=>SP-140631 (BBII & BBIII stopped). IncludES in CP-150Uplink Congestion Management, Un/Attended UE Information / Impacted TSs and TRs: TBD
- 988: Can be seen as an "enhancement" of Rel-12 IMS-based Telepresence (IMS_TELEP) UID_530042. Mar. 15: 20%
- 989: Dec.14: 0->10%. 8/4/15: 20%; June2015: Compl:20%->30; Aug2015: 30%->35; 07/09/15: 35%->60; 7/12/15: 60%->100 / Impacted TSs and TRs: New TR 26.9xy
- 990: Dec.14: 0->10%. 8/4/15: 20%; June2015: Compl:20%->30; 07/09/15: 30%->60; 7/12/15: 60%->100 / Impacted TSs and TRs: New TS 26.1xy
- 991: Impacted TSs and TRs: 26.22
- 992: Impacted TSs and TRs: 26.22
- 993: Impacted TSs and TRs: 26.22
- 994: Impacted TSs and TRs: 26.114, 26.223
- 995: Triggered by Rel-12 TR 22.852 Study on RAN Sharing Enhancements (FS_RSE)
- 996: SP#62 completed / Impacted TSs and TRs: 22.101
- 997: Triggered by TR 36.856 Study on RAN aspects of RAN Sharing Enhancements for LTE (FS_RSE-RAN_LTE) & SA1 22.101 Stage 1 / Impacted TSs and TRs: LTE
- 998: ; CD:Mon 15/06/15->Tue 15/09/15; Stat Rep: -->RP-141891 1st Apr 15: Compl:15%->20% 1st Apr 15: Stat Rep: RP-141891->RP-150289 03/07/15: Compl:20%->75% 03/07/15: Stat Rep: RP-150289->RP-150875 29/09/15: Compl:75%->80% 29/09/15: CD:Tue 15/09/15->Tue 15/1 / Impacted TSs and TRs: 36.300, 36.413, 36.423
- 999: SP#65 updated WID SP-14028=>SP-140630 (added SA3 part, SA1 change). Add enhanced interoperability support for WebRTC to Rel-12 Web Real Time Communication (WebRTC) Access to IMS. / Impacted TSs and TRs: Stage 1/2
- 1000: SP#65 completed. Updated WID SP-140286=>SP-140630 / Impacted TSs and TRs: 22.228
- 1001: SP#65 updated WID SP-14028=>SP-140630 (added SA3 part). Dec.14: 9->55%; June2015: Compl:55%->85; 07/09/15: 85%->100 / Impacted TSs and TRs: New TR 23.706
- 1002: SP#65 updated WID SP-14028=>SP-140630 (added SA3 part); June2015: Compl:0%->85; 07/09/15: 85%->100 / Impacted TSs and TRs: 23.228
- 1003: SP#65 updated WID SP-14028=>SP-140630 (added SA3 part). Dec.14: 0->20%, TR number added. 3/3/15: 30%.; June2015: Compl:30%->75; 11/12/15: 54%->100; 11/12/15: 100%->100 / Impacted TSs and TRs: New TR 33.872
- 1004: SP#65 updated WID SP-14028=>SP-140630 (added SA3 part). Dec.14: 0->20%; 11/12/15: 15%->100 / Impacted TSs and TRs: 33.203, 33.328
- 1005: TS 33.203 CR0235draft-ietf-tram-turn-third-party-authz; 7/3/16: 10%->100 / Impacted TSs and TRs: 33.203, RRC 7635 (was draft-ietf-tram-turn-third-party-authz)

| ID | WBS | Task | Type | Duration | Start | Finish | Complete | Remaining | Baseline start | Baseline finish | Baseline duration | Total slack | Constraint | Resources | Work | Actual work | Acronym | PCG approved | WI rapporteur name | WI rapporteur e-mail | Release | TSG approved | Impacted TSs and TRs | MCC resp | Acronym_3GU_Export | Special Focus Doc |
| --- | --- | --- | --- | --- | --- | --- | --- | --- | --- | --- | --- | --- | --- | --- | --- | --- | --- | --- | --- | --- | --- | --- | --- | --- | --- | --- |
| 1006 | 369.7 | **Stage 3 for Enhancements to WebRTC interoperability** |  | 135d? | 2015-09-07 A | 2016-03-11 | 84% | 21.09d? |  |  |  | 5152d |  | ct | 6048h | 4340h | eWebRTCi-CT | 35 | China Mobile, Song Yue | songyue@chinamobile.com | Rel-13 | 69 |  |  |  |  |
| 1007 | 369.7.1 | CT1 aspects 3 for Enhancements to WebRTC interoperability |  | 75d? | 2015-09-07 A | 2015-12-18 A | 100% |  |  |  |  |  | finish no earlier than 2015-12-18 | C1 | 600h | 600h | eWebRTCi-CT | 35 | China Mobile, Song Yue | songyue@chinamobile.com | Rel-13 | 69 | 24.371, 24.229 |  |  |  |
| 1008 | 369.7.2 | CT3 aspects for Enhancements to WebRTC interoperability |  | 135d? | 2015-09-07 A | 2016-03-11 A | 100% |  |  |  |  |  | finish no earlier than 2016-03-11 | C3 | 1080h | 1080h | eWebRTCi-CT | 35 | China Mobile, Song Yue | songyue@chinamobile.com | Rel-13 | 69 | 29.214 |  |  |  |
| 1009 | 369.7.3 | CT4 aspects for Enhancements to WebRTC interoperability |  | 135d? | 2015-09-07 A | 2016-03-11 A | 100% |  |  |  |  |  | finish no earlier than 2016-03-11 | C4 | 1080h | 1080h | eWebRTCi-CT | 35 | China Mobile, Song Yue | songyue@chinamobile.com | Rel-13 | 69 | 29.228, 23.334, 29.334, 23.008 |  |  |  |
| 1010 | 369.7.4 | (IETF) SDP-based Data Channel Negotiation (draft-ietf-mmusic-data-channel-sdpneg) |  | 69d? | 2015-12-08 A | 2016-03-11 | 75% | 17.25d? |  |  |  | 5152d | finish no earlier than 2016-03-11 | C1-IETF; SA4-IETF | 1104h | 828h | eWebRTCi-CT | 36 | Ericsson | christer.holmberg@ericsson.com | Rel-13 | 71 | 24.371, 24.229 |  |  |  |
| 1011 | 369.7.5 | (IETF) MSRP over Data Channels (draft-ietf-mmusic-msrp-usage-data-channel) |  | 69d? | 2015-12-08 A | 2016-03-11 | 75% | 17.25d? |  |  |  | 5152d | start no earlier than 2015-12-08 | C1-IETF | 552h | 414h | eWebRTCi-CT | 36 | Ericsson | christer.holmberg@ericsson.com | Rel-13 | 71 | 24.371, 24.229, 26.223 |  |  |  |
| 1012 | 369.7.6 | (IETF) A Language for Rules Describing JSON Content (draft-newton-json-content-rules) |  | 69d? | 2015-12-08 A | 2016-03-11 | 25% | 51.75d? |  |  |  | 5152d | start no earlier than 2015-12-08 | C3-IETF | 552h | 138h | eWebRTCi-CT | 36 | Ericsson | christer.holmberg@ericsson.com | Rel-13 | 71 | 24.371, 24.229, 26.223 |  |  |  |
| 1013 | 370 | **Improvements to CS/PS coordination in UTRAN/GERAN Shared Networks** |  | 573d? | 2014-03-07 A | 2016-05-12 A | 100% |  | 2014-03-07 | 2014-12-10 | 199d? |  |  | S2 | 9768h | 9768h | CSPS_Coord | 32 | Ericsson | roland.gustafsson@ericsson.com | Rel-13 | 63 | Stage 2 | Maurice | CSPS_Coord |  |
| 1014 | 370.1 | TR on Stage 2 for Improvements to CS/PS coordination in UTRAN/GERAN Shared Networks |  | 140d? | 2014-03-07 A | 2014-09-17 A | 100% |  | 2014-03-07 | 2014-12-10 | 199d? |  | finish no earlier than 2014-09-17 | S2 | 1120h | 1120h | CSPS_Coord-SA2TR | 32 | Ericsson | roland.gustafsson@ericsson.com | Rel-13 | 63 | New TR 23.704 | Maurice |  |  |
| 1015 | 370.2 | Stage 2 for Improvements to CS/PS coordination in UTRAN/GERAN Shared Networks |  | 201d? | 2014-03-12 A | 2014-12-12 A | 100% |  | 2014-03-07 | 2014-12-10 | 199d? |  | finish no earlier than 2014-12-12 | S2 | 1608h | 1608h | CSPS_Coord-SA2 | 32 | Ericsson | roland.gustafsson@ericsson.com | Rel-13 | 63 | 23.216, 23.251, 23.272 | Maurice |  |  |
| 1016 | 370.3 | RAN aspects for improvements to CS/PS coordination in GERAN Shared Networks |  | 307d? | 2015-03-11 A | 2016-05-12 A | 100% |  |  |  |  |  | finish no earlier than 2016-05-12 | G2 | 2456h | 2456h | CSPS_Coord_GERAN |  | Nicklas Johansson, Ericsson LM | Nicklas.Johansson@Ericsson.com | Rel-13 | 65 | 48.008, 48.018 |  |  |  |
| 1017 | 371 | **Enhancements to Proximity-based Services** |  | 788d? | 2013-03-18 A | 2016-03-11 | 100% | 0d? | 2014-06-18 | 2015-06-12 | 258d? | 0d |  | S1; S2; S3 | 30792h | 27152h | eProSe | 33 | Qualcomm | Eddy Hall (edhall@qti.qualcomm.com) | Rel-13 | 64 | Stage 1/2 |  | eProSe | Public Safety (A-A) |
| 1018 | 371.1 | Stage 1 for Enhancements to Proximity-based Services |  | 66d? | 2014-06-19 A | 2014-09-17 A | 100% |  | 2014-06-18 | 2014-09-17 | 66d? |  | finish no earlier than 2014-09-17 | S1 | 528h | 528h | eProSe-SA1 | 33 | Qualcomm | Eddy Hall (edhall@qti.qualcomm.com) | Rel-13 | 64 | 22.115, 22.278 |  |  | Public Safety (A-A) |
| 1019 | 371.2 | Stage 2 for Enhancements to Proximity-based Services - Extensions |  | 326d? | 2014-06-23 A | 2015-09-16 A | 100% |  | 2014-06-18 | 2015-06-12 | 258d? |  | finish no earlier than 2015-09-16 | S2 | 2608h | 2608h | eProSe-Ext-SA2 | 33 | Qualcomm | Haris Zisimopoulos (harisz@qti.qualcomm.com) | Rel-13 | 64 | 23.303, TBD |  | eProSe-Ext | Public Safety (A-A) |
| 1020 | 371.3 | TR on Stage 2 for Enhancements to Proximity-based Services - Extensions |  | 193d? | 2014-06-18 A | 2015-03-13 A | 100% |  | 2014-06-18 | 2015-03-13 | 193d? |  | finish no earlier than 2015-03-13 | S2 | 1544h | 1544h | eProSe-Ext-SA2TR | 33 | Qualcomm | Haris Zisimopoulos (harisz@qti.qualcomm.com) | Rel-13 | 64 | New TR 23.713 |  |  | Public Safety (A-A) |
| 1021 | 371.4 | Security for Enhancements to Proximity-based Services - Extensions |  | 388d? | 2014-09-19 A | 2016-03-11 A | 100% |  |  |  |  |  | finish no earlier than 2016-03-11 | S3 | 3104h | 3104h | eProSe-Ext-SA3 | 33 | Qualcomm | Adrian Escott (aescott@qti.qualcomm.com) | Rel-13 | 65 | 33.303 |  |  | Public Safety (A-A) |
| 1022 | 371.5 | **CT aspects of enhancements to Proximity-based** |  | 195d? | 2015-06-15 A | 2016-03-11 A | 100% |  |  |  |  |  |  | C1 | 7304h | 7304h | eProSe-Ext-CT | 35 | Lena Chaponniere | lguellec@qti.qualcomm.com | Rel-13 | 68 | 23.122, 24.301, 24.333, 24.334 |  |  |  |
| 1023 | 371.5.1 | CT1 aspects of enhancements to Proximity-based |  | 195d? | 2015-06-15 A | 2016-03-11 A | 100% |  |  |  |  |  | finish no earlier than 2016-03-11 | C1 | 1560h | 1560h | eProSe-Ext-CT | 35 | Lena Chaponniere | lguellec@qti.qualcomm.com | Rel-13 | 68 | 29.343 |  |  |  |
| 1024 | 371.5.2 | CT3 aspects of enhancements to Proximity-based |  | 133d? | 2015-06-15 A | 2015-12-16 A | 100% |  |  |  |  |  | start no earlier than 2015-06-15 | C3 | 1064h | 1064h | eProSe-Ext-CT | 35 | Lena Chaponniere | lguellec@qti.qualcomm.com | Rel-13 | 68 | 23.003, 23.008, 29.272, 29.344, 29.345 |  |  |  |
| 1025 | 371.5.3 | CT4 aspects of enhancements to Proximity-based |  | 195d? | 2015-06-15 A | 2016-03-11 A | 100% |  |  |  |  |  | finish no earlier than 2016-03-11 | C4 | 1560h | 1560h | eProSe-Ext-CT | 35 | Lena Chaponniere | lguellec@qti.qualcomm.com | Rel-13 | 68 | 31.102, 31.111 |  |  |  |
| 1026 | 371.5.4 | CT6 aspects of enhancements to Proximity-based |  | 195d? | 2015-06-15 A | 2016-03-11 A | 100% |  |  |  |  |  | finish no earlier than 2016-03-11 | C6 | 1560h | 1560h | eProSe-Ext-CT | 35 | Lena Chaponniere | lguellec@qti.qualcomm.com | Rel-13 | 68 | 31.102, 31.111 |  |  |  |
| 1027 | 371.6 | Study on Security for Proximity-based Services |  | 596d? | 2013-03-18 A | 2015-06-17 A | 100% |  | 2013-03-07 | 2014-09-17 | 401d? |  | finish no earlier than 2015-06-17 | S3 | 4768h | 4768h | FS_ProSe_Sec | 30 | Qualcomm | Adrian Escott (aescott@qti.qualcomm.com) | Rel-13 | 59 | 33.833 | Mirko | FS_ProSe_Sec | Public Safety (A-A) |
| 1028 | 371.7 | Note: Charging Aspects done in Rel-14 under CH14-Prose (UID 720049) | milestone | 0d? | 2015-06-17 A | 2015-06-17 A | 100% |  |  |  |  |  | start no earlier than 2015-06-17 | S5 |  |  | eProSe |  |  |  | Rel-13 |  |  |  |  |  |
| 1029 | 372 | **voice over E-UTRAN Paging Policy Differentiation** |  | 133d? | 2014-06-16 A | 2014-12-12 A | 100% |  | 2014-06-16 | 2014-12-10 | 128d? |  |  | S1; S2; C4; C1; C3 | 9244.75h | 9244.75h | voE_UTRAN_PPD | 33 | Alcatel-Lucent | (betsy.covell@alcatel-lucent.com) | Rel-13 | 64 | Stage 1/2 |  | voE_UTRAN_PPD |  |
| 1030 | 372.1 | Stage 1 for voice over E-UTRAN Paging Policy Differentiation |  | 3d? | 2014-06-16 A | 2014-06-18 A | 100% |  | 2014-06-16 | 2014-06-18 | 3d? |  | finish no earlier than 2014-06-18 | S1 | 24h | 24h | voE_UTRA-N_PPD-SA1 | 33 | Alcatel-Lucent | betsy.covell@alcatel-lucent.com | Rel-13 | 64 | 22.228, 22.278 |  |  |  |
| 1031 | 372.2 | Stage 2 for voice over E-UTRAN Paging Policy Differentiation |  | 128d? | 2014-06-18 A | 2014-12-12 A | 100% |  | 2014-06-18 | 2014-12-10 | 126d? |  | finish no earlier than 2014-12-12 | S2 | 1024h | 1024h | voE_UTRAN_PPD-SA2 | 33 | Alcatel-Lucent | laurent.thiebaut@alcatel-lucent.com | Rel-13 | 64 | 23.228, 23.401 |  |  |  |

Notes:
- 1006: 7/12/15: WID:CP-150498->CP-150790->CP-150767
- 1007: 7/12/15: 0%->100; 7/12/15: WID:CP-150498->CP-150790->CP-150767
- 1008: 7/12/15: WID:CP-150498->CP-150790->CP-150767. ES in CP-150644; 7/3/16: 0%->100
- 1009: 7/12/15: WID:CP-150498->CP-150790->CP-150767. ES in CP-150623; 7/3/16: 0%->100
- 1010: 7/3/16: Introduced by IETF updates
- 1011: 7/3/16: Introduced by IETF updates
- 1012: 7/3/16: Introduced by IETF updates
- 1013: Provide improvements to the solutions for CS/PS coordination in TS 23.251 to ensure that CS/PS coordination can be achieved for all mobility scenarios
- 1014: SP#65 completed. TR 23.704v200 for Approval
- 1015: Dec.14: 0->100%
- 1016: June2015: Compl:0%->35; 07/09/15: 35%->50, FCD:08/15->11/15; 7/12/15: 50%->95, FCD: 12/15->02/16. 02/03/16: FCD: 02/16->05/16; 13/6/16: 95%->100
- 1017: -
- 1018: SP#65 completed. Some Rel-12 ProSe service requirements have not been implemented at Stage 2/3 level. These are taken up in Rel-13 Stage 2/3 and need Stage 1 appropriate service requirements. No new service requirements are introduced.
- 1019: SP#65 updated WID SP-140385=>SP-140573 (added SA3 part). Mar15: WID: SP-140573 ->SP-150028; June2015: Compl:0%->30. FCD: June->Sept. 07/09/15: 24->70%; 07/09/15: 70%->90; 7/12/15: 90%->100
- 1020: SP#65 updated WID SP-140385=>SP-140573 (added SA3 part). Acronym corrected: eProSe-Ex-SA2TRt->eProSe-Ext-SA2TR. Mar15: 60% Mar15: WID: SP-140573 ->SP-150028; June2015: Compl:60%->90; 07/09/15: 90%->95; 07/09/15: 95%->100
- 1021: SP#65 updated WID SP-140385=>SP-140573 (added SA3 part). Acronym corrected: eProSe-Ex-SA3t->eProSe-Ext-SA3. Mar15: WID: SP-140573 ->SP-150028; 7/12/15: 0%->75; 10/12/15: FCD ->03/16, ES in SP-150714; 7/3/16: 75%->100
- 1023: 07/09/15: 0%->40; 7/12/15: 40%->90. FCD -> 03/16, ES in CP-150724; 7/3/16: 90%->100
- 1024: 07/09/15: 0%->60; 8/3/16: 60%->100
- 1025: 07/09/15: 0%->10; 7/12/15: 10%->80. FCD->03/16. ES in CP-150616; 7/3/16: 80%->100
- 1026: 7/12/15: FCD -> 03/16, ES in CP-150839. FCD->03/16. ES in CP-150616; 7/3/16: 0%->95; 8/3/16: 95%->100
- 1027: SP#65 updated WID SP-140300=>SP-140629 (Moved the TR phase to Rel-13 as a stand-alone Study). Completion 09/14=>06/15. SP#64 TR 33.833 v100 for Information. 4/3/15: 95%->70% (more topics to be included); June2015: Compl:70%->75; 7/12/15: 75%->95; 7/3/1
- 1029: -
- 1030: SP#64 approved WID & completed
- 1031: Architectural enhancements allowing a differentiated paging policy for IMS voice calls over E-UTRAN. Dec.14: 25->100%

| ID | WBS | Task | Duration | Start | Finish | Complete | Baseline start | Baseline finish | Baseline duration | Constraint | Resources | Work | Actual work | Acronym | PCG approved | WI rapporteur name | Release | TSG approved | Acronym_3GU_Export |
| --- | --- | --- | --- | --- | --- | --- | --- | --- | --- | --- | --- | --- | --- | --- | --- | --- | --- | --- | --- |
| 1032 | 372.3 | **CT aspects of voice over E-UTRAN Paging Policy Differentiation** | 63d? | 2014-09-16 A | 2014-12-09 A | 100% |  |  |  |  | C4; C1; C3 | 3024h | 3024h | voE_UTRAN_PPD-CT | 33 | Alcatel-Lucent | Rel-13 | 65 |  |
| 1033 | 372.3.1 | CT4 part of CT aspects of voice over E-UTRAN Paging Policy Differentiation | 63d? | 2014-09-16 A | 2014-12-09 A | 100% |  |  |  | finish no earlier than 2014-12-09 | C4 | 504h | 504h | voE_UTRAN_PPD-CT | 33 | Alcatel-Lucent | Rel-13 | 65 |  |
| 1034 | 372.3.2 | CT1 part of CT aspects of voice over E-UTRAN Paging Policy Differentiation | 63d? | 2014-09-16 A | 2014-12-09 A | 100% |  |  |  | finish no earlier than 2014-12-09 | C1 | 504h | 504h | voE_UTRAN_PPD-CT | 33 | Alcatel-Lucent | Rel-13 | 65 |  |
| 1035 | 372.3.3 | CT3 part of CT aspects of voice over E-UTRAN Paging Policy Differentiation | 63d? | 2014-09-16 A | 2014-12-09 A | 100% |  |  |  | finish no earlier than 2014-12-09 | C3 | 504h | 504h | voE_UTRAN_PPD-CT | 33 | Alcatel-Lucent | Rel-13 | 65 |  |
| 1036 | 373 | **IP Flow Mobility support for S2a and S2b Interfaces** | 524d? | 2014-06-18 A | 2016-06-15 A | 100% | 2014-06-18 | 2015-06-17 | 261d? |  | S2 | 15656h | 15656h | NBIFOM | 33 | Tricci So, ZTE | Rel-13 | 64 | NBIFOM |
| 1037 | 373.1 | TR for IP Flow Mobility support for S2a and S2b Interfaces | 193d? | 2014-06-18 A | 2015-03-13 A | 100% | 2014-06-18 | 2015-03-13 | 193d? | finish no earlier than 2015-03-13 | S2 | 1544h | 1544h | NBIFOM-SA2TR | 33 | Tricci So, ZTE | Rel-13 | 64 |  |
| 1038 | 373.2 | Stage 2 for IP Flow Mobility support for S2a and S2b Interfaces | 326d? | 2014-06-23 A | 2015-09-16 A | 100% | 2014-06-18 | 2015-06-17 | 261d? | finish no earlier than 2015-09-16 | S2 | 2608h | 2608h | NBIFOM-SA2 |  | Tricci So, ZTE | Rel-13 | 64 |  |
| 1039 | 373.3 | Charging Aspects of IP Flow Mobility support for S2a and S2b Interfaces (NBIFOM) | 196d? | 2015-09-16 A | 2016-06-15 A | 100% | 2014-06-18 | 2015-06-17 | 261d? | finish no earlier than 2016-06-15 | S5 | 1568h | 1568h | NBIFOM-CH | 35 | GUO Wenjie, ZTE | Rel-13 | 69 |  |
| 1040 | 373.4 | **CT aspects of IP Flow Mobility support for S2a and S2b Interfaces** | 195d? | 2015-06-15 A | 2016-03-11 A | 100% |  |  |  |  | C1 | 5744h | 5744h | NBIFOM-CT | 35 | Xingyue(Joy) Zhou, ZTECorporation | Rel-13 | 68 |  |
| 1041 | 373.4.1 | CT1 aspects of IP Flow Mobility support for S2a and S2b Interfaces | 195d? | 2015-06-15 A | 2016-03-11 A | 100% |  |  |  | finish no earlier than 2016-03-11 | C1 | 1560h | 1560h | NBIFOM-CT | 35 | Xingyue(Joy) Zhou, ZTECorporation. ES in 641 | Rel-13 | 68 |  |
| 1042 | 373.4.2 | CT3 aspects of IP Flow Mobility support for S2a and S2b Interfaces | 195d? | 2015-06-15 A | 2016-03-11 A | 100% |  |  |  | finish no earlier than 2016-03-11 | C3 | 1560h | 1560h | NBIFOM-CT | 35 | 680001Xingyue(Joy) Zhou, ZTECorporation. ES in 641 | Rel-13 | 68 |  |
| 1043 | 373.4.3 | CT4 aspects of IP Flow Mobility support for S2a and S2b Interfaces | 133d? | 2015-06-15 A | 2015-12-16 A | 100% |  |  |  | start no earlier than 2015-06-15 | C4 | 1064h | 1064h | NBIFOM-CT | 35 | Xingyue(Joy) Zhou, ZTECorporation | Rel-13 | 68 |  |
| 1044 | 374 | **Double Resource Reuse for Multiple Media Sessions** | 264d? | 2014-03-14 A | 2015-03-13 A | 100% | 2014-03-14 | 2015-03-13 | 261d? |  | S2 | 5952h | 5952h | DRuMS | 33 | Ericsson | Rel-13 | 64 | DRuMS |
| 1045 | 374.1 | Stage 2 for Double Resource Reuse for Multiple Media Sessions | 264d? | 2014-03-14 A | 2015-03-13 A | 100% | 2014-03-14 | 2015-03-13 | 261d? | finish no earlier than 2015-03-13 | S2 | 2088h | 2088h | DRuMS-SA2 | 33 | Ericsson | Rel-13 | 64 |  |
| 1046 | 374.2 | **CT aspects of Double Resource Reuse for Multiple Media Sessions** | 73d? | 2014-12-03 A | 2015-03-13 A | 100% |  |  |  |  | C3 | 1752h | 1752h | DRuMS-CT | 34 | Ericsson | Rel-13 | 66 |  |
| 1047 | 374.2.1 | CT1 aspects of Double Resource Reuse for Multiple Media Sessions | 73d? | 2014-12-03 A | 2015-03-13 A | 100% |  |  |  | start no earlier than 2014-12-03 | C1 | 584h | 584h | DRuMS-CT | 34 | Ericsson | Rel-13 | 66 |  |
| 1048 | 374.2.2 | CT3 aspects of Double Resource Reuse for Multiple Media Sessions | 73d? | 2014-12-03 A | 2015-03-13 A | 100% |  |  |  | start no earlier than 2014-12-03 | C3 | 584h | 584h | DRuMS-CT | 34 | Ericsson | Rel-13 | 66 |  |
| 1049 | 375 | Lawful Interception in the 3GPP Rel-13 | 656d? | 2014-06-18 A | 2016-12-15 A | 100% | 2014-06-18 | 2015-12-09 | 386d? | finish no earlier than 2016-12-15 | S3 | 5248h | 5248h | LI13 | 33 | PIDS, Alcatel-Lucent | Rel-13 | 64 | LI13 |
| 1050 | 376 | STOPPED - Study on Lawful Interception Service Evolution | 386d? | 2014-06-23 A | 2015-12-09 A | 100% | 2014-06-18 | 2015-12-09 | 386d? | finish no earlier than 2015-12-09 | S3 | 3088h | 3088h | FS_LISE | 33 | Alcatel-Lucent | Rel-13 | 64 | FS_LISE |
| 1051 | 377 | **Video enhancements by Region-Of-Interest information signalling** | 394d? | 2014-06-18 A | 2015-12-16 A | 100% | 2014-06-18 | 2015-06-17 | 261d? |  | S4 | 10016h | 10016h | ROI | 33 | Intel | Rel-13 | 64 | ROI |
| 1052 | 377.1 | SA4 aspects of Video enhancements by Region-Of-Interest information signalling | 329d? | 2014-06-18 A | 2015-09-16 A | 100% |  |  |  | finish no earlier than 2015-09-16 | S4 | 2632h | 2632h | ROI | 33 | Intel | Rel-13 | 64 |  |
| 1053 | 377.2 | **CT Aspects of Video Enhancements by Region-Of-Interest information signalling** | 133d? | 2015-06-15 A | 2015-12-16 A | 100% |  |  |  |  | C4 | 4256h | 4256h | ROI-CT | 35 | Vivek Gupta, Intel | Rel-13 | 68 |  |
| 1054 | 377.2.1 | CT1 Aspects of Video Enhancements by Region-Of-Interest information signalling | 133d? | 2015-06-15 A | 2015-12-16 A | 100% |  |  |  | start no earlier than 2015-06-15 | C1 | 1064h | 1064h | ROI-CT | 35 | Vivek Gupta, Intel | Rel-13 | 68 |  |
| 1055 | 377.2.2 | CT3 Aspects of Video Enhancements by Region-Of-Interest information signalling | 133d? | 2015-06-15 A | 2015-12-16 A | 100% |  |  |  | start no earlier than 2015-06-15 | C3 | 1064h | 1064h | ROI-CT | 35 | Vivek Gupta, Intel | Rel-13 | 68 |  |
| 1056 | 377.2.3 | CT4 Aspects of Video Enhancements by Region-Of-Interest information signalling | 133d? | 2015-06-15 A | 2015-12-16 A | 100% |  |  |  | start no earlier than 2015-06-15 | C4 | 1064h | 1064h | ROI-CT | 35 | Vivek Gupta, Intel | Rel-13 | 68 |  |

Notes:
- 1032: Stage 3 / Impacted TSs and TRs: Stage 3 / WI rapporteur e-mail: bruno.landais@alcatel-lucent.com
- 1033: Mar.15: 0->100% / Impacted TSs and TRs: 29.274, 29.281 / WI rapporteur e-mail: bruno.landais@alcatel-lucent.com
- 1034: Dec.14: 0->50%; 07/09/15: 50%->50; 7/12/15: 50%->100 / Impacted TSs and TRs: 24.229 / WI rapporteur e-mail: bruno.landais@alcatel-lucent.com
- 1035: Mar.15: 0->100% / Impacted TSs and TRs: 29.061 / WI rapporteur e-mail: bruno.landais@alcatel-lucent.com
- 1036: 06/15: WID: SP-140279->SP-150250 / Impacted TSs and TRs: Stage 2 / WI rapporteur e-mail: tso@zte.com.cn
- 1037: Revived the Rel-12 DRAFT TR 23.861 stopped at SP#59 (at 40% completion). Dec.14: 20->60%; June2015: Compl:60%->90, WID: SP-140279->SP-150250 / Impacted TSs and TRs: New TR 23.861 / WI rapporteur e-mail: tso@zte.com.cn
- 1038: June2015: Compl:0%->65, WID: SP-140279->SP-150250; 07/09/15: 52%->100 / Impacted TSs and TRs: 23.402, New TS 23.203 / WI rapporteur e-mail: tso@zte.com.cn
- 1039: 7/12/15: 0%->50. ES in SP-150710 (wrong UID mentioned in the ES); 7/3/16: 50%->85%, FCD:03/16->06/16; 13/6/16: 85%->100 / Impacted TSs and TRs: 32.251, 32.298, 32.299 / WI rapporteur e-mail: guo.wenjie1@zte.com.cn
- 1040: 14/09/15: WID:CP-150285->CP-150497; 7/12/15: WID:CP-150497->CP-150791->874 / Impacted TSs and TRs: 24.161 / WI rapporteur e-mail: zhou.xingyue@zte.com.cn
- 1041: 07/09/15: 0%->25; 14/09/15: WID:CP-150285->CP-150497; 7/12/15: 25%->75; 7/12/15: WID:CP-150497->CP-150791->874. FCD -> 03/16. ES in CP-150725; 7/3/16: 75%->100 / Impacted TSs and TRs: 24.301, 24.302, 24.244, 24.008 / WI rapporteur e-mail: zhou.xingyue@zte.com.cn
- 1042: 07/09/15: 0%->40; 14/09/15: WID:CP-150285->CP-150497; 7/12/15: 40%->95; 7/12/15: WID:CP-150497->CP-150791->874. FCD -> 03/16. ES in CP-150725; 7/3/16: 95%->100 / Impacted TSs and TRs: 29.212, 29.213, 29.214, 29.215 / WI rapporteur e-mail: zhou.xingyue@zte.com.cn
- 1043: 07/09/15: 0%->20; 14/09/15: WID:CP-150285->CP-150497; 7/12/15: 20%->100; 7/12/15: WID:CP-150497->CP-150791->874 / Impacted TSs and TRs: 29.274, 23.008 / WI rapporteur e-mail: zhou.xingyue@zte.com.cn
- 1044: - / Impacted TSs and TRs: Stage 2 / WI rapporteur e-mail: George.Foti@ericsson.com
- 1045: Dec.14: 49->95%. Mar15: 100% / Impacted TSs and TRs: 23.203, 23.228 / WI rapporteur e-mail: George.Foti@ericsson.com
- 1046: Impacted TSs and TRs: 24.229, 24.615, 24.610, 24.605, 29.212, 29.213, 29.214, 29.215
- 1047: 5/5/15: C3 corrected in C1; June2015: Compl:65%->90; 07/09/15: 90%->100 / Impacted TSs and TRs: 24.229, 24.615, 24.610, 24.605
- 1048: Mar.15: 65->95%; June2015: Compl:95%->100 / Impacted TSs and TRs: 29.212, 29.213, 29.214, 29.215 / WI rapporteur e-mail: Jan Holm
- 1049: SP#65 updated WID SP-140400=>SP-140578. 2/4/15: WID SP-140815->SP-150111; June2015: Compl:0%->10. WID: SP-150111->SP-150290; 14/09/15: WID:SP-150290->SP-150460; 7/12/15: 10%->15; 7/3/16: 13%->20; 7/3/16: WID:SP-150460->SP-160043; 19/9/16: 20%->60. FCD / Impacted TSs and TRs: 33.106, 33.107, 33.108 / WI rapporteur e-mail: Koen Jaspers (k.b.jaspers@minjus.nl), terry.jacobson@alcatel-lucent.com
- 1050: Linked to LI13 which defines existing LI service requirements in TS 33.106 as well as existing HI1, HI2 & HI3 reference points. 3/3/15: 0->5%; 7/12/15: 5%->10. Stoppped at 10% in March 2017.; 6/3/17: 10%->100 / Impacted TSs and TRs: 33.826 / WI rapporteur e-mail: terry.jacobson@alcatel-lucent.com
- 1051: Dec.14: 5->20%. Mar.15: 40%; 07/09/15: 43%->100 / Impacted TSs and TRs: 26.114 / WI rapporteur e-mail: ozgur.oyman@intel.com
- 1052: Created by MCC as the structure of the Feature get expanded to include CT aspects; June2015: Compl:40%->90, FCD: 06/15->09/15; Aug2015: Compl:90%->95 / Impacted TSs and TRs: 26.114 / WI rapporteur e-mail: ozgur.oyman@intel.com
- 1053: 14/09/15: WID:CP-150241->CP-150425 / WI rapporteur e-mail: vivek.g.gupta@intel.com
- 1054: 07/09/15: 100%->50; 14/09/15: WID:CP-150241->CP-150425; 7/12/15: 50%->100 / Impacted TSs and TRs: 24.229 / WI rapporteur e-mail: vivek.g.gupta@intel.com
- 1055: 07/09/15: 100%->10; 14/09/15: WID:CP-150241->CP-150425; 7/12/15: 10%->100 / Impacted TSs and TRs: 29.162 / WI rapporteur e-mail: vivek.g.gupta@intel.com
- 1056: 07/09/15: 100%->5; 14/09/15: WID:CP-150241->CP-150425; 7/12/15: 5%->100 / Impacted TSs and TRs: 23.334, 29.334, 29.238 / WI rapporteur e-mail: vivek.g.gupta@intel.com

| ID | WBS | Task | Duration | Start | Finish | Complete | Remaining | Baseline start | Baseline finish | Baseline duration | Total slack | Constraint | Resources | Work | Actual work | Acronym | PCG approved | WI rapporteur name | Release | TSG approved | Acronym_3GU_Export | Status Report | MCC resp |
| --- | --- | --- | --- | --- | --- | --- | --- | --- | --- | --- | --- | --- | --- | --- | --- | --- | --- | --- | --- | --- | --- | --- | --- |
| 1057 | 378 | **TV video profile** | 396d? | 2014-09-09 A | 2016-03-11 A | 100% |  |  |  |  |  |  | S4 | 9504h | 9504h | TVProf | 33 | Orange | Rel-13 | 65 | TVProf |  |  |
| 1058 | 378.1 | TR on TV video profile | 396d? | 2014-09-09 A | 2016-03-11 A | 100% |  |  |  |  |  | finish no earlier than 2016-03-11 | S4 | 3168h | 3168h | TVProf-SA4TR | 33 | Orange | Rel-13 | 65 |  |  |  |
| 1059 | 378.2 | Specification on TV video profile | 396d? | 2014-09-09 A | 2016-03-11 A | 100% |  |  |  |  |  | finish no earlier than 2016-03-11 | S4 | 3168h | 3168h | TVProf-SA4 | 33 | Orange | Rel-13 | 65 |  |  |  |
| 1060 | 379 | Enhanced LTE UE Delay test methods and requirements | 464d? | 2014-09-09 A | 2016-06-15 A | 100% |  |  |  |  |  | finish no earlier than 2016-06-15 | S4 | 3712h | 3712h | E_LTE_UED | 33 | Orange | Rel-13 | 65 | E_LTE_UED |  |  |
| 1061 | 380 | HTML5 Presentation Layer | 334d? | 2014-09-09 A | 2015-12-16 A | 100% |  |  |  |  |  | finish no earlier than 2015-12-16 | S4 | 2672h | 2672h | HTML5 | 33 | Samsung | Rel-13 | 65 | HTML5 |  |  |
| 1062 | 381 | **Support of EVS in 3G Circuit-Switched networks** | 396d? | 2014-09-09 A | 2016-03-11 | 100% | 0d? |  |  |  | 0d |  | S4; C4; C1; C3; R1; R2; R3 | 42757.6h | 24952h | EVSoCS | 33 | Qualcomm | Rel-13 | 65 | EVSoCS |  |  |
| 1063 | 381.1 | SA4 aspects of EVS in 3G Circuit-Switched networks | 396d? | 2014-09-09 A | 2016-03-11 A | 100% |  |  |  |  |  | finish no earlier than 2016-03-11 | S4 | 3168h | 3168h | EVSoCS-S4 | 33 | Qualcomm | Rel-13 | 65 | EVSoCS |  |  |
| 1064 | 381.2 | **CT aspects of EVS in 3G Circuit-Switched Networks** | 268d? | 2015-03-04 A | 2016-03-11 A | 100% |  |  |  |  |  |  | C4; C1; C3 | 12344h | 12344h | EVSoCS-CT | 34 | Qualcomm, Lena Chaponniere | Rel-13 | 67 |  |  |  |
| 1065 | 381.2.1 | CT1 aspects of EVS in 3G Circuit-Switched Networks | 203d? | 2015-03-04 A | 2015-12-11 A | 100% |  |  |  |  |  | finish no earlier than 2015-12-11 | C1 | 1624h | 1624h | EVSoCS-CT | 34 | Qualcomm, Lena Chaponniere | Rel-13 | 67 |  |  |  |
| 1066 | 381.2.2 | CT3 aspects of EVS in 3G Circuit-Switched Networks | 268d? | 2015-03-04 A | 2016-03-11 A | 100% |  |  |  |  |  | finish no earlier than 2016-03-11 | C3 | 2144h | 2144h | EVSoCS-CT | 34 | Qualcomm, Lena Chaponniere | Rel-13 | 67 |  |  |  |
| 1067 | 381.2.3 | CT4 aspects of EVS in 3G Circuit-Switched Networks | 268d? | 2015-03-04 A | 2016-03-11 A | 100% |  |  |  |  |  | finish no earlier than 2016-03-11 | C4 | 2144h | 2144h | EVSoCS-CT | 34 | Qualcomm, Lena Chaponniere | Rel-13 | 67 |  |  |  |
| 1068 | 381.3 | **Support of EVS over UTRAN CS** | 130.67d? | 2015-06-16 A | 2015-12-15 A | 100% |  |  |  |  |  |  | R2; R1; R3 | 6272h | 6272h | EVSoCS_UTRAN | 34 | Qualcomm | Rel-13 | 66 |  |  |  |
| 1069 | 381.3.1 | Core part: Support of EVS over UTRAN CS | 130.67d? | 2015-06-16 A | 2015-12-15 A | 100% |  |  |  |  |  | finish no earlier than 2015-12-15 | R2; R1; R3 | 3136h | 3136h | EVSoCS_UTRAN-Core | 34 | Francesco Pica - Qualcomm Incorporated | Rel-13 | 66 |  | RP-151282 |  |
| 1070 | 382 | Enhanced DASH (Dynamic Adaptive Streaming over HTTP in 3GPP) | 334d? | 2014-09-09 A | 2015-12-16 A | 100% |  |  |  |  |  | finish no earlier than 2015-12-16 | S4 | 2672h | 2672h | eDASH | 33 | Qualcomm, Huawei | Rel-13 | 65 | eDASH |  |  |
| 1071 | 383 | **QoS End-to-end Multimedia Telephony Service for IMS (MTSI) extensions (Stage 3)** | 796d? | 2013-03-06 A | 2016-03-11 A | 100% |  | 2013-03-06 | 2015-03-13 | 533d? |  |  | S4; C3; C1; C4 | 53457.8h | 53457.8h | QOSE2EMTSI | 30 | Ericsson | Rel-13 | 59 | QOSE2EMTSI |  | Paolo |
| 1072 | 383.1 | TR on improved end-to-end QoS handling for MTSI | 589d? | 2013-12-11 A | 2016-03-11 A | 100% |  | 2013-12-11 | 2015-03-13 | 329d? |  | finish no earlier than 2016-03-11 | S4 | 4705.83h | 4705.83h | QOSE2EMTSI | 32 | Ericsson | Rel-13 | 62 |  |  | Paolo |
| 1073 | 383.2 | SA4 part of QoS End-to-end Multimedia Telephony Service for IMS (MTSI) extensions (Stage 3) | 792d? | 2013-03-06 A | 2016-03-11 A | 100% |  | 2013-03-06 | 2015-03-13 | 532d? |  | finish no earlier than 2016-03-11 | S4 | 6336h | 6336h | QOSE2EMTSI | 30 | Ericsson | Rel-13 | 59 |  |  | Paolo |
| 1074 | 383.3 | **CT Aspects of QoS End-to-End MTSI Extensions** | 353d? | 2014-11-05 A | 2016-03-11 A | 100% |  |  |  |  |  |  | C3; C1; C4 | 16944h | 16944h | QOSE2EMTSI-CT | 34 | Ericsson | Rel-13 | 66 |  |  |  |
| 1075 | 383.3.1 | CT3 Aspects of QoS End-to-End MTSI Extensions | 353d? | 2014-11-05 A | 2016-03-11 A | 100% |  |  |  |  |  | finish no earlier than 2016-03-11 | C3 | 2824h | 2824h | QOSE2EMTSI-CT | 34 | Ericsson | Rel-13 | 66 |  |  |  |
| 1076 | 383.3.2 | CT1 Aspects of QoS End-to-End MTSI Extensions | 353d? | 2014-11-05 A | 2016-03-11 A | 100% |  |  |  |  |  | finish no earlier than 2016-03-11 | C1 | 2824h | 2824h | QOSE2EMTSI-CT | 34 | Ericsson | Rel-13 | 66 |  |  |  |
| 1077 | 383.3.3 | CT4 Aspects of QoS End-to-End MTSI Extensions | 353d? | 2014-11-05 A | 2016-03-11 A | 100% |  |  |  |  |  | finish no earlier than 2016-03-11 | C4 | 2824h | 2824h | QOSE2EMTSI-CT | 34 | Ericsson | Rel-13 | 66 |  |  |  |
| 1078 | 384 | **MTSI Extension on Multi-stream Multiparty** | 322d? | 2014-12-12 A | 2016-03-07 | 83% | 53.53d? |  |  |  | 5156d |  | S4 | 5752h | 5216.24h | MMCMH | 34 | Tomas Frankkila, Ericsson LM | Rel-13 | 66 |  |  |  |
| 1079 | 384.1 | Codec aspects for MMCMH | 265d? | 2014-12-12 A | 2015-12-17 A | 100% |  |  |  |  |  | finish no earlier than 2015-12-17 | S4 | 2120h | 2120h | MMCMH | 34 | Tomas Frankkila, Ericsson LM | Rel-13 | 66 |  |  |  |
| 1080 | 384.2 | (IETF) RTP Stream Pause and Resume (RFC 7728) | 66d? | 2015-12-07 A | 2016-03-07 A | 100% |  |  |  |  |  | finish no earlier than 2016-03-07 | S4-IETF | 528h | 528h | MMCMH | 36 | Ericsson | Rel-13 | 71 |  |  |  |
| 1081 | 384.3 | (IETF) draft-ietf-mmusic-sdp-simulcast | 66d? | 2015-12-07 | 2016-03-07 |  |  |  |  |  | 5156d | start no earlier than 2015-12-07 | S4-IETF | 528h |  | MMCMH | 37 |  | Rel-13 | 72 |  |  |  |

Notes:
- 1057: Mar. 15: 5->15% / WI rapporteur e-mail: gilles.teniou@orange.com
- 1058: Dec.14: 0->5%; June2015: Compl:15%->30; Aug2015: 30%->45; 07/09/15: 45%->70; 7/12/15: 70%->85, FCD: 12/15->03/16; 7/3/16: 85%->100 / Impacted TSs and TRs: New TR 26.9xy. ES in SP-150650 / WI rapporteur e-mail: gilles.teniou@orange.com
- 1059: Dec.14: 0->5%; June2015: Compl:15%->30; Aug2015: 30%->45; 07/09/15: 45%->70; 7/12/15: 70%->85, FCD: 12/15->03/16. ES in SP-150650; 7/3/16: 85%->100 / Impacted TSs and TRs: 26.234, 26.244, 26.346, 26.247, New TS 26.xyz. ES in SP-150650 / WI rapporteur e-mail: gilles.teniou@orange.com
- 1060: Mar. 15: 0->5%; June2015: Compl:5%->10; Aug2015: 10%->15; 07/09/15: 15%->50; 7/12/15: 50%->80, FCD: 12/15->03/16. ES in SP-150652; 7/3/16: FCD: 03/16->06/16; 11/6/16: 80%->100 / Impacted TSs and TRs: 26.131, 26.132 / WI rapporteur e-mail: stephane.ragot@orange.com
- 1061: Triggered by Rel-12 TR 26.907 (Study of HTML5 and 3GPP User Services). Dec.14: 0->5%. Mar. 15: 10%; June2015: Compl:10%->20; Aug2015: 20%->40; 07/09/15: 40%->70; 7/12/15: 70%->100 / Impacted TSs and TRs: 26.140, 26.234, 26.247, 26.346, New TS 26.xyz / WI rapporteur e-mail: Imed Bouazizi (i.bouazizi@samsung.com)
- 1062: Provide CS support of EVS to enhance voice quality in CS services over UTRAN (3G WCDMA). Dec.14: 0->5%; 28/1/16: 26.454 added; 28/1/16: 26.453 added; / Impacted TSs and TRs: 26.103, 28.062, New TS 26.454; New TS 26.453 / WI rapporteur e-mail: Imre Varga (ivarga@qti.qualcomm.com)
- 1063: Created by MCC (duplicated from previously single-line Feature) due to the introduction of the CT BB. Mar. 15: 10%; Aug2015: 10%->20; 07/09/15: 20%->40; 7/12/15: 40%->60, FCD:12/15->03/16. ES in SP-150655; 28/1/16: 26.454 added; 28/1/16: 26.453 added; / Impacted TSs and TRs: 26.103, 28.062, New TS 26.454; New TS 26.453 / WI rapporteur e-mail: Imre Varga (ivarga@qti.qualcomm.com)
- 1064: WI rapporteur e-mail: lguellec@qti.qualcomm.com
- 1065: 07/09/15: 0%->90; 7/12/15: 90%->100 / Impacted TSs and TRs: 24.008 / WI rapporteur e-mail: lguellec@qti.qualcomm.com
- 1066: June2015: Compl:0%->10; 07/09/15: 10%->15; 7/12/15: 15%->90. FCD -> 03/16, ES in CP-150638; 7/3/16: 90%->100 / Impacted TSs and TRs: 29.163, 29.414, 29.415 / WI rapporteur e-mail: lguellec@qti.qualcomm.com
- 1067: June2015: Compl:0%->95. FCD -> 03/16, ES in CP-150618; 7/3/16: 95%->100 / Impacted TSs and TRs: 23.153, 23.334, 29.002, 29.231, 29.232, 29.332, 29.334 / WI rapporteur e-mail: lguellec@qti.qualcomm.com
- 1068: WI rapporteur e-mail: Qualcomm
- 1069: Rapporteur details and involved WGs updated 1st Apr 15: Compl:0%->10% 1st Apr 15: Stat Rep: ->RP-150128. 5/5/15: 0->10% 03/07/15: Compl:10%->25% 03/07/15: Stat Rep: RP-150128->RP-150759 29/09/15: Compl:25%->50% 29/09/15: CD:Tue 15/09/15->Tue 15/12/15 2 / WI rapporteur e-mail: fpica@qti.qualcomm.com
- 1070: Triggered by Rel-12 Dec.14: 0->10%. Mar. 15: 15%; June2015: Compl:15%->25. WID updated; Aug2015: 25%->30; 07/09/15: 30%->60; 14/09/15: WID:SP-150211->SP-150448; 7/12/15: 60%->100 / Impacted TSs and TRs: 26.233, 26.234, 26.244, 26.247, 26.938, TS 26.346, TR 26.946 / WI rapporteur e-mail: Thomas Stockhammer (tsto@qti.qualcomm.com), Li Zhiming (lizhiming@huawei.com)
- 1071: SP#65 updated WID SP-130670=>SP-140601 (moved work from Rel-12 incl. new TR to Rel-13). Co-ordinate with SA2, CT1/3/4, IETF MMUSIC. Linked to SA4 Rel-7 Media handling and interaction in MTSI (MTSI-MHI) UID_7040 / WI rapporteur e-mail: tomas.frankkila@ericsson.com
- 1072: SP#65 updated WID SP-130670=>SP-140601 (moved work from Rel12 incl. new TR to Rel-13). Completion 03/15=>06/15. Mar15: 26.924 for info. 8/4/15: 50%; Aug2015: 50%->60; 7/12/15: 75%->90, FCD: 06/15->03/16; 7/3/16: 90%->100 / Impacted TSs and TRs: new TR 26.924 / WI rapporteur e-mail: tomas.frankkila@ericsson.com
- 1073: SP#65: WID SP-130670=>SP-140601 (moved from Rel12 incl. new TR to Rel-13). FCD 03/15=>06/15. St1 in TS 22.173. 12/14: 70->40%, CD: 06/15->09/15. 03/15: 50%. June 15: FCD: 09/15->12/15; 08/15: 60%; 09/15: 75%; 7/12. ES in SP-150658; 7/3/16: 90%->100 / Impacted TSs and TRs: 26.114 / WI rapporteur e-mail: tomas.frankkila@ericsson.com
- 1075: 7/12/15: 0%->70. FCD -> 03/16, ES in CP-150636; 7/3/16: 70%->100 / Impacted TSs and TRs: 29.162, 29.163, 29.213, 29.214
- 1076: FCD -> 03/16, ES in CP-150726; 7/3/16: 0%->100 / Impacted TSs and TRs: 24.229
- 1077: FCD -> 03/16, ES in CP-150620; 7/3/16: 0%->100 / Impacted TSs and TRs: 23.333, 23.334, 29.238, 29.332, 29.333, 29.334
- 1078: Mar. 15: 0->10%. WID: SP-140738->SP-150097; June2015: Compl:10%->30; Aug2015: 30%->50, FCD: sep->Dec 2015; 07/09/15: 50%->60; 7/12/15: 60%->100; 10/12/15: WID:SP-150097->SP-150660. Might be moved to Rel-14 (see note in UID710002) / Impacted TSs and TRs: 26.114, New TR 26.980 / WI rapporteur e-mail: tomas.frankkila@ericsson.com
- 1079: Introduced by MCC to dissociate S4 from IeTF aspects / Impacted TSs and TRs: 26.114, New TR 26.980 / WI rapporteur e-mail: tomas.frankkila@ericsson.com
- 1080: 02/2016: published as RFC 7728 / Impacted TSs and TRs: (IETF) RTP Stream Pause and Resume (RFC 7728) / WI rapporteur e-mail: tomas.frankkila@ericsson.com

| ID | WBS | Task | Duration | Start | Finish | Complete | Remaining | Baseline start | Baseline finish | Baseline duration | Total slack | Constraint | Resources | Work | Actual work | Acronym | PCG approved | Release | TSG approved | MCC resp | Special Focus Doc | Acronym_3GU_Export |
| --- | --- | --- | --- | --- | --- | --- | --- | --- | --- | --- | --- | --- | --- | --- | --- | --- | --- | --- | --- | --- | --- | --- |
| 1082 | 385 | **Video Telephony Robustness Improvements Extensions** | 196d? | 2014-12-12 A | 2015-09-11 | 70% | 58.8d? |  |  |  | 5282d |  | S4 | 6272h | 4390.4h | VTRI_EXT | 34 | Rel-13 | 66 |  |  |  |
| 1083 | 385.1 | TR on Video Telephony Robustness Improvements | 196d? | 2014-12-12 A | 2015-09-11 A | 100% |  |  |  |  |  | finish no earlier than 2015-09-11 | S4 | 1568h | 1568h | VTRI_EXT | 34 | Rel-13 | 66 |  |  |  |
| 1084 | 385.2 | Specification on Video Telephony Robustness Improvements | 196d? | 2014-12-12 A | 2015-09-11 A | 100% |  |  |  |  |  | finish no earlier than 2015-09-11 | S4 | 1568h | 1568h | VTRI_EXT | 34 | Rel-13 | 66 |  |  |  |
| 1085 | 385.3 | (IETF) RTP Payload Format for Non-Interleaved and Interleaved Parity Forward Error Correction (FEC) (draft-ietf-payload-flexible-fec-scheme) | 196d? | 2014-12-12 A | 2015-09-11 | 10% | 176.4d? |  |  |  | 5282d | finish no earlier than 2015-09-11 | S4-IETF | 1568h | 156.8h | VTRI_EXT | 35 | Rel-13 | 69 |  |  |  |
| 1086 | 386 | Acoustic Test methods and Performance Objectives for Speakerphone Performance in Noisy Environments | 326d? | 2014-12-12 A | 2016-03-11 A | 100% |  |  |  |  |  | finish no earlier than 2016-03-11 | S4 | 2608h | 2608h | ATeMPO_SPINE | 34 | Rel-13 | 66 |  |  |  |
| 1087 | 387 | **Rel-13 Operations, Administration, Maintenance and Provisioning (OAM&P)** | 985d? | 2012-06-20 A | 2016-03-11 A | 100% |  | 2014-09-17 | 2015-12-11 | 323d? |  |  | S5 | 57504h | 57504h | OAM13 | 32 | Rel-13 | 63 | Mirko | SON | OAM13 |
| 1088 | 387.1 | Enhanced Network Management (NM) centralized Coverage and Capacity Optimization | 319d? | 2014-09-19 A | 2015-12-11 A | 100% |  | 2014-09-17 | 2015-12-11 | 319d? |  | finish no earlier than 2015-12-11 | S5 | 2552h | 2552h | SON-NM-CCO | 29 | Rel-13 | 56 | Mirko | SON | SON-NM-CCO |
| 1089 | 387.2 | **Compliance of 3GPP SA5 specifications to the NGMN Top Operational Efficiency (OPE) Recommendations** | 728d? | 2012-06-20 A | 2015-03-18 A | 100% |  | 2012-06-20 | 2014-09-17 | 595d? |  |  | S5 | 17368h | 17368h | OAM-NGMN_OPE | 29 | Rel-13 | 56 | Mirko |  | OAM-NGMN_OPE |
| 1090 | 387.2.1 | TR on Compliance of 3GPP SA5 specifications to the NGMN Top Operational Efficiency (OPE) Recommendations | 723d? | 2012-06-20 A | 2015-03-18 A | 100% |  | 2012-06-20 | 2014-09-17 | 593d? |  | finish no earlier than 2015-03-18 | S5 | 5784h | 5784h | OAM-NGMN_OPE | 29 | Rel-13 | 56 | Mirko |  |  |
| 1091 | 387.2.2 | TS work on Compliance of 3GPP SA5 specifications to the NGMN Top Operational Efficiency (OPE) Recommendations | 720d? | 2012-06-25 A | 2015-03-18 A | 100% |  | 2012-06-25 | 2014-09-17 | 590d? |  | finish no earlier than 2015-03-18 | S5 | 5760h | 5760h | OAM-NGMN_OPE | 29 | Rel-13 | 56 | Mirko |  |  |
| 1092 | 387.3 | Converged management Performance Management Interface Definitions | 910d? | 2012-06-20 A | 2015-12-11 A | 100% |  | 2012-06-20 | 2014-09-17 | 588d? |  | finish no earlier than 2015-12-11 | S5 | 7280h | 7280h | OAM-PMID | 29 | Rel-13 | 56 | Mirko |  | OAM-PMID |
| 1093 | 387.4 | **WLAN Management** | 788d? | 2012-06-27 A | 2015-06-17 A | 100% |  | 2012-06-20 | 2014-09-17 | 595d? |  |  | S5 | 18848h | 18848h | WLAN-OAM | 29 | Rel-13 | 56 | Mirko | WLAN | WLAN-OAM |
| 1094 | 387.4.1 | WLAN Network Resource Model for Type-2 interface | 784d? | 2012-06-27 A | 2015-06-17 A | 100% |  | 2012-06-27 | 2014-09-17 | 589d? |  | finish no earlier than 2015-06-17 | S5 | 6272h | 6272h | WLAN-OAM-SA5 | 29 | Rel-13 | 56 | Mirko | WLAN |  |
| 1095 | 387.4.2 | WLAN measurements defined in IEEE and IETF WLAN performance measurements for use on Type-2 interface | 784d? | 2012-06-27 A | 2015-06-17 A | 100% |  | 2012-06-27 | 2014-09-17 | 589d? |  | finish no earlier than 2015-06-17 | S5 | 6272h | 6272h | WLAN-OAM-SA5ietf | 29 | Rel-13 | 56 | Mirko | WLAN |  |
| 1096 | 387.5 | Energy Efficiency related Performance Measurements | 713d? | 2013-06-21 A | 2016-03-11 A | 100% |  | 2013-06-21 | 2014-09-17 | 326d? |  | finish no earlier than 2016-03-11 | S5 | 5704h | 5704h | OAM-PM_EE | 31 | Rel-13 | 60 | Mirko |  | OAM-PM_EE |
| 1097 | 387.6 | Multi-Broadcast Single Frequency Network (MBSFN) Minimization of Drive Tests (MDT) enhancement | 1d? | 2014-12-12 A | 2014-12-12 A | 100% |  |  |  |  |  | start no earlier than 2014-12-12 | S5 | 8h | 8h | MBSFN_MDT | 34 | Rel-13 | 66 |  |  |  |
| 1098 | 388 | **Rel-13 Charging** | 393d? | 2014-06-19 A | 2015-12-16 A | 100% |  | 2014-06-18 | 2015-12-09 | 386d? |  |  | S5 | 16236h | 16236h | CH13 | 33 | Rel-13 | 64 |  |  | CH13 |
| 1099 | 388.1 | **Inter-PLMN PS domain online charging** | 393d? | 2014-06-19 A | 2015-12-16 A | 100% |  | 2014-06-18 | 2015-12-09 | 386d? |  |  | S5 | 8360h | 8360h | iPLMN-PS-OCH | 33 | Rel-13 | 64 |  |  | iPLMN-PS-OCH |
| 1100 | 388.1.1 | TR on Inter-PLMN PS domain online charging | 261d? | 2014-06-19 A | 2015-06-17 A | 100% |  | 2014-06-18 | 2015-06-17 | 261d? |  | finish no earlier than 2015-06-17 | S5 | 2088h | 2088h | iPLMN-PS-OCH | 33 | Rel-13 | 64 |  |  |  |
| 1101 | 388.1.2 | Specification of Inter-PLMN PS domain online charging | 391d? | 2014-06-23 A | 2015-12-16 A | 100% |  | 2014-06-18 | 2015-12-09 | 386d? |  | finish no earlier than 2015-12-16 | S5 | 3128h | 3128h | iPLMN-PS-OCH | 33 | Rel-13 | 64 |  |  |  |
| 1102 | 388.2 | ULI and release causes for charging enhancement for VoLTE | 257d? | 2014-12-12 A | 2015-12-07 A | 100% |  |  |  |  |  | finish no earlier than 2015-12-07 | S5 | 2056h | 2056h | ULRELC-CH | 34 | Rel-13 | 66 |  |  |  |
| 1103 | 388.3 | Charging on enhancements for IMS Service Continuity | 135d? | 2015-03-05 A | 2015-09-09 A | 100% |  |  |  |  |  | finish no earlier than 2015-12-11 | S5 | 1080h | 1080h | CHeISC | 34 | Rel-13 | 67 |  |  |  |
| 1104 | 388.4 | Announcements for IMS Online Charging | 131d? | 2015-06-15 A | 2015-12-14 A | 100% |  |  |  |  |  | start no earlier than 2015-06-14 | S5 | 1048h | 1048h | ANIMO | 35 | Rel-13 | 68 |  |  |  |
| 1105 | 388.5 | Enhanced S2a Mobility Over Trusted WLAN access to EPC - Charging | 68.5d? | 2015-06-15 A | 2015-09-17 A | 100% |  |  |  |  |  | start no earlier than 2015-06-15 | S5 | 548h | 548h | eSaMOG-CH | 35 | Rel-13 | 68 |  |  |  |

Notes:
- 1082: New TR added. 3/3/15: "extensions" added in the title. Mar. 15: 0->10% / Impacted TSs and TRs: 26.922 (new), 26.114 / WI rapporteur name: Muhammed Coban, Qualcomm Incorporated / WI rapporteur e-mail: mcoban@qti.qualcomm.com
- 1083: 3/3/15: created to distinguish TR and TS tasks; June2015: Compl:10%->40; Aug2015: 40%->95; 07/09/15: 95%->100 / Impacted TSs and TRs: 26.922 (new), 26.114 / WI rapporteur name: Muhammed Coban, Qualcomm Incorporated / WI rapporteur e-mail: mcoban@qti.qualcomm.com
- 1084: 3/3/15: created to distinguish TR and TS tasks; June2015: Compl:10%->40; Aug2015: 40%->95; 07/09/15: 95%->100 / Impacted TSs and TRs: 26.922 (new), 26.114 / WI rapporteur name: Muhammed Coban, Qualcomm Incorporated / WI rapporteur e-mail: mcoban@qti.qualcomm.com
- 1085: 26.114, draft-ietf-payload-flexible-fec-scheme. 7/10/15: rapporteur added / Impacted TSs and TRs: 26.114, draft-ietf-payload-flexible-fec-scheme / WI rapporteur name: Muhammed Coban, Qualcomm Incorporated / WI rapporteur e-mail: mcoban@qti.qualcomm.com
- 1086: June2015: Compl:0%->10. Aug: FCD: Jun->Sep15; 07/09/15: 10%->30, FCD:09/15->12/15; 7/12/15: 40%->80, FCD: 12/15->03/16. ES in SP-150642; 7/3/16: 80%->100 / Impacted TSs and TRs: 26.131, 26.132 / WI rapporteur name: Andre Schevciw, Qualcomm Incorporated; Scott Isabelle, Audience Inc. / WI rapporteur e-mail: aschevci@qti.qualcomm.com; sisabelle@audience.com
- 1087: OAM13 is an umbrella Feature for changes that are not part of any other dedicated feature/WI; June2015: WID:-->SP-150305; 5/10/15: 28.683 added; / Impacted TSs and TRs: 28.683
- 1088: SP#64 work not started. Dec.14: 0->20, cd: 06/15->12/15. Mar 15: 20->30%; June2015: Compl:30%->50; 07/09/15: 50%->60; 7/12/15: 60%->100 / Impacted TSs and TRs: 28.627, 28.628, 32.103, 32.422, 32.425, 32.442 / WI rapporteur name: Ericsson / WI rapporteur e-mail: robert.petersen@ericsson.com
- 1089: SP#65 updated WID SP-120349=>SP-140538. Completion 12/14=>03/15. Moved to Rel-13. Source of external requirements: NGMN Top OPE Recommendations 1.0 / WI rapporteur name: Huawei / WI rapporteur e-mail: christian.toche@huawei.com
- 1090: SP#65 updated WID SP-120349=>SP-140538. Completion 12/14=>03/15. Moved to Rel-13.. Dec.14: 72->78. Mar 15: 80%; June2015: Compl:80%->85; 07/09/15: 85%->90; 7/12/15: 90%->100 / Impacted TSs and TRs: New TR 32.838 / WI rapporteur name: Huawei / WI rapporteur e-mail: christian.toche@huawei.com
- 1091: SP#65 updated WID SP-120349=>SP-140538. Completion 12/14=>03/15. Moved to Rel-13; 7/12/15: 50%->100 / Impacted TSs and TRs: 32.101/2/3,32.111-1,32.111-2,32.111-6,32.15x,32.401,32.411,32.412,32.421,32.422,32.423,32.431,32.432,32.436,32.441,32.442,32.446,32.500,32.501,32.502,32.506,32.521,32.522,32.526,32.531,32.532,32.536,32.551,32.691,32.692,32.696,32.762 / WI rapporteur name: Huawei / WI rapporteur e-mail: christian.toche@huawei.com
- 1092: SP#65 updated WID SP-130641=>SP-140613. Completion 09/14=>12/15. Moved to Rel-13. Completion 09/14=>12/15. Dec.14: 20->30; June2015: Compl:30%->60; 07/09/15: 60%->80; 7/12/15: 80%->100; 7/12/15: WID:SP-140613->SP-150678 / Impacted TSs and TRs: new TSs 32.863 / WI rapporteur name: Huawei / WI rapporteur e-mail: christian.toche@huawei.com
- 1093: SP#65 moved to Rel-13. Updated WID SP-130042=>SP-140535 (split into Rel-12 Study & Rel-13 normative WI). TR 32.841 was completed as a Rel-12 Study and has triggered this normative work / WI rapporteur name: Intel / WI rapporteur e-mail: joey.chou@intel.com
- 1094: SP#65 updated WID SP-130042=>SP-140535. Completion 09/14=>06/15. Moved to Rel-13. Dec.14: 10->20; June2015: Compl:20%->70; 07/09/15: 70%->80; 7/12/15: 80%->100 / Impacted TSs and TRs: new TS (28.680, 28.682), 28.681 / WI rapporteur name: Intel / WI rapporteur e-mail: joey.chou@intel.com
- 1095: SP#65 updated WID SP-130042=>SP-140535. Completion 09/14=>06/15. Moved to Rel-13. 22/01:Acronym modified; June2015: Compl:5%->20; 07/09/15: 20%->60; 7/12/15: 60%->100 / Impacted TSs and TRs: new TS 28.403 / WI rapporteur name: Intel / WI rapporteur e-mail: joey.chou@intel.com
- 1096: SP#65 updated WID SP-130263=>SP-140612. Completion 09/14=>06/15. Moved to Rel-13; June2015: Compl:25%->40; 07/09/15: 40%->50. ES in SP-150708; 7/3/16: 50%->100 / Impacted TSs and TRs: 32.425 / WI rapporteur name: Nokia Networks / WI rapporteur e-mail: Yizhi.yao@nsn.com
- 1097: Mar 15: 0->15%; June2015: Compl:15%->100 / Impacted TSs and TRs: 32.421, 32.422, 32.423, 32.441, 32.442, 32.446 / WI rapporteur name: Padma Sudarsan (Alcatel-Lucent) / WI rapporteur e-mail: padma.sudarsan<AT>alcatel-lucent<DOT>com
- 1098: CH13 is an umbrella Feature for changes that are not part of any other dedicated feature/WI; June2015: WID:-->SP-150307
- 1099: Study and specify Gy Reference Point service data flows based online charging for inter-PLMN situations / Impacted TSs and TRs: Stage 2/3 / WI rapporteur name: Alcatel-Lucent / WI rapporteur e-mail: maryse.gardella@alcatel-lucent.com
- 1100: Dec.14: 10->25%. Mar15: 20->60%. 06/15: 100%; 7/12/15: 100%->100 / Impacted TSs and TRs: New TR 32.843 / WI rapporteur name: Alcatel-Lucent / WI rapporteur e-mail: maryse.gardella@alcatel-lucent.com
- 1101: 07/09/15: 0%->80; 7/12/15: 80%->100 / Impacted TSs and TRs: 32.251, 32.299 / WI rapporteur name: Alcatel-Lucent / WI rapporteur e-mail: maryse.gardella@alcatel-lucent.com
- 1102: Acronym changed to ULRELC-CH. Mar15: 0->5%. CD: 12/14->09/15. 06/15: 20%; 07/09/15: 20%->40; 7/12/15: 40%->100, FCD: 09/15->12/15 / Impacted TSs and TRs: 32.251, 32.260, 32.299, 32.298, / WI rapporteur name: Alcatel-Lucent, Maryse Gardella / WI rapporteur e-mail: Alcatel-Lucent, Maryse <dot> Gardella <at> Alcatel-Lucent <dot> com
- 1103: 06/15: 0->50%; 07/09/15: 50%->100. FCD: 12/15->09/15 / Impacted TSs and TRs: 32.260, 32.299, 32.298 / WI rapporteur name: Gerald Goermer / WI rapporteur e-mail: Gerald <dot> Goermer <at> nsn <dot> com
- 1104: 07/09/15: 0%->30; 7/12/15: 30%->100; 7/12/15: WID:SP-150307->SP-150675 / Impacted TSs and TRs: 32.260, 32.275, 32.299, 32.240, 32.281 / WI rapporteur name: Amdocs, Naceur <dot> Lagha <at> Amdocs <dot> com
- 1105: 07/09/15: 0%->30; 7/12/15: 30%->100 / Impacted TSs and TRs: 32.240, 32.251, 32.299, 32.298 / WI rapporteur name: Alcatel-Lucent, Maryse <dot> Gardella <at> Alcatel-Lucent <dot> com

| ID | WBS | Task | Duration | Start | Finish | Complete | Remaining | Baseline start | Baseline finish | Baseline duration | Total slack | Constraint | Resources | Work | Actual work | Acronym | PCG approved | WI rapporteur name | WI rapporteur e-mail | Release | TSG approved | MCC resp | Acronym_3GU_Export | Status Report |
| --- | --- | --- | --- | --- | --- | --- | --- | --- | --- | --- | --- | --- | --- | --- | --- | --- | --- | --- | --- | --- | --- | --- | --- | --- |
| 1106 | 389 | **Support of Real-time Transport Protocol (RTP) / Real-time Transport Control Protocol (RTCP) multiplexing (signalling) in IMS** | 595d? | 2013-09-09 A | 2015-12-11 A | 100% |  | 2013-09-09 | 2014-09-12 | 267d? |  |  | C4; C1; C3 | 28464h | 28464h | RTCP_MUX | 31 | Alcatel-Lucent | Albrecht.Schwarz@alcatel-lucent.com | Rel-13 | 61 | Kimmo | RTCP_MUX |  |
| 1107 | 389.1 | CT4 part of Support of RTP / RTCP multiplexing (signalling) in IMS | 591d? | 2013-09-09 A | 2015-12-11 A | 100% |  | 2013-09-09 | 2014-09-12 | 266d? |  | finish no earlier than 2015-12-11 | C4 | 4728h | 4728h | RTCP_MUX | 31 | Alcatel-Lucent | Albrecht.Schwarz@alcatel-lucent.com | Rel-13 | 61 | Kimmo |  |  |
| 1108 | 389.2 | CT1 part of Support of RTP / RTCP multiplexing (signalling) in IMS | 591d? | 2013-09-13 A | 2015-12-11 A | 100% |  | 2013-09-10 | 2014-09-12 | 266d? |  | finish no earlier than 2015-12-11 | C1 | 4728h | 4728h | RTCP_MUX | 31 | Alcatel-Lucent | Albrecht.Schwarz@alcatel-lucent.com | Rel-13 | 61 | Frederic |  |  |
| 1109 | 389.3 | CT3 part of Support of RTP / RTCP multiplexing (signalling) in IMS | 591d? | 2013-09-13 A | 2015-12-11 A | 100% |  | 2013-09-10 | 2014-06-13 | 201d? |  | finish no earlier than 2015-12-11 | C3 | 4728h | 4728h | RTCP_MUX | 31 | Alcatel-Lucent | Albrecht.Schwarz@alcatel-lucent.com | Rel-13 | 61 | Adrian |  |  |
| 1110 | 390 | **LTE in the 1670-1675 MHz Band for US (on hold till 12/2014)** | 868d? | 2012-03-05 A | 2015-06-12 | 8% | 801.54d? | 2012-03-05 | 2015-06-12 | 865d? | 5347d |  | R4; R2; R3 | 35264h | 2347.6h | LTE_FDD_1670_US | 28 | LightSquared | masoud.olfat@lightsquared.com | Rel-13 | 55 | Issam | LTE_FDD_1670_US |  |
| 1111 | 390.1 | Core part: LTE in the 1670-1675 MHz Band for US (on hold till 12/2014) | 313d? | 2013-08-06 A | 2015-03-13 | 15% | 266.05d? | 2013-08-06 | 2015-03-13 | 313d? | 5412d | finish no earlier than 2015-03-13 | R4; R2; R3 | 7512h | 1126.8h | LTE_FDD_1670_US-Core | 28 | LightSquared | masoud.olfat@lightsquared.com | Rel-13 | 55 | Issam | LTE_FDD_1670_US-Core | RP-141452 |
| 1112 | 390.2 | Perf. Part: LTE in the 1670-1675 MHz Band for US (on hold till 12/2014) | 865d? | 2012-03-05 A | 2015-06-12 | 5% | 821.75d? | 2012-03-05 | 2015-06-12 | 865d? | 5347d | finish no earlier than 2015-06-12 | R4 | 6920h | 346h | LTE_FDD_1670_US-Perf | 28 | LightSquared | masoud.olfat@lightsquared.com | Rel-13 | 55 | Issam | LTE_FDD_1670_US-Perf | RP-141452 |
| 1113 | 391 | **Enhanced Signalling for Inter-eNB Coordinated Multi-Point (CoMP) for LTE** | 328d? | 2014-06-18 A | 2015-09-15 A | 100% |  | 2014-06-13 | 2014-12-05 | 126d? |  |  | R3 | 5248h | 5248h | COMP_LTE_IeNB_sig | 33 | Samsung | sunghwan.won@samsung.com | Rel-13 | 64 |  | COMP_LTE_IeNB_sig |  |
| 1114 | 391.1 | Core part: Enhanced Signalling for Inter-eNB Coordinated Multi-Point (CoMP) for LTE | 328d? | 2014-06-18 A | 2015-09-15 A | 100% |  | 2014-06-13 | 2014-12-05 | 126d? |  | finish no earlier than 2015-09-15 | R3 | 2624h | 2624h | COMP_LTE_IeNB_sig-Core | 33 | Samsung | sunghwan.won@samsung.com | Rel-13 | 64 |  | COMP_LTE_IeNB_sig-Core | RP-151213 |
| 1115 | 392 | **2GHz FDD LTE in Region 1 (1980-2010MHz and 2170-2200MHz Bands)** | 592d? | 2014-06-17 A | 2016-09-15 A | 100% |  | 2014-06-13 | 2015-06-12 | 261d? |  |  | R4 | 12096h | 12096h | LTE_1980_2170_REG1 | 33 | DISH Network | johny.kim@dish.com, mariam.sorond@dish.com | Rel-13 | 64 |  | LTE_1980_2170_REG1 |  |
| 1116 | 392.1 | Core part: 2GHz FDD LTE in Region 1 (1980-2010MHz and 2170-2200MHz Bands) | 393d? | 2014-06-17 A | 2015-12-15 A | 100% |  | 2014-06-13 | 2015-06-12 | 261d? |  | finish no earlier than 2015-12-15 | R4 | 3144h | 3144h | LTE_1980_2170_REG1-Core | 33 | DISH Network | johny.kim@dish.com, mariam.sorond@dish.com | Rel-13 | 64 |  | LTE_1980_2170_REG1-Core | RP-151299 |
| 1117 | 392.2 | Perf. Part: 2GHz FDD LTE in Region 1 (1980-2010MHz and 2170-2200MHz Bands) | 393d? | 2014-06-18 A | 2015-12-15 A | 100% |  | 2014-06-13 | 2015-06-12 | 261d? |  | finish no earlier than 2015-12-15 | R4 | 3144h | 3144h | LTE_1980_2170_REG1-Perf | 33 | DISH Network | johny.kim@dish.com, mariam.sorond@dish.com | Rel-13 | 64 |  | LTE_1980_2170_REG1-Perf | RP-151299 |
| 1118 | 392.3 | UE Conformance Test Aspects - FDD LTE band 1980-2010 MHz and 2170-2200MHz (band 65) in Region1 and Region 3 | 134d? | 2016-03-15 A | 2016-09-15 A | 100% |  |  |  |  |  | finish no earlier than 2016-09-15 | R5 | 1072h | 1072h | LTE_1980_2170_REG1_REG3-UEConTest | 36 | Dish Network |  | Rel-13 | 71 |  |  |  |
| 1119 | 393 | **Self Organizing Networks (SON) for Active Antenna System (AAS) based deployments** | 199d? | 2014-09-12 A | 2015-06-15 A | 100% |  | 2014-06-13 | 2015-06-12 | 261d? |  |  | R3; G2 | 4776h | 4776h | UTRA_LTE_SON_AAS | 33 | Nokia Networks | krzysztof.kordybach@nsn.com | Rel-13 | 65 |  | UTRA_LTE_SON_AAS |  |
| 1120 | 393.1 | Core part: Self Organizing Networks (SON) for Active Antenna System (AAS) based deployments | 199d? | 2014-09-12 A | 2015-06-15 A | 100% |  | 2014-06-13 | 2015-06-12 | 261d? |  | finish no earlier than 2015-06-15 | R3 | 1592h | 1592h | UTRA_LTE_SON_AAS-Core | 33 | Nokia Networks | krzysztof.kordybach@nsn.com | Rel-13 | 65 |  | UTRA_LTE_SON_AAS-Core | RP-150727 |
| 1121 | 394 | **Usage Monitoring Control PCC Extension** | 140d? | 2014-12-03 A | 2015-06-16 A | 100% |  |  |  |  |  |  | S2 | 2824h | 2824h | eUMONC | 34 | CTBRI |  | Rel-13 | 66 |  |  |  |
| 1122 | 394.1 | Stage 2 of Usage Monitoring Control PCC Extension | 140d? | 2014-12-03 A | 2015-06-16 A | 100% |  |  |  |  |  | finish no earlier than 2015-06-16 | S2 | 1120h | 1120h | eUMONC-SA2 | 34 | China Telecom, Jinyan Li | lijy@ctbri.com.cn | Rel-13 | 66 |  |  |  |
| 1123 | 394.2 | CT3 Aspect of Usage Monitoring Control extension | 73d? | 2014-12-03 A | 2015-03-13 A | 100% |  |  |  |  |  | finish no earlier than 2015-03-13 | C3 | 584h | 584h | eUMONC-CT3 | 34 | ZTE |  | Rel-13 | 66 |  |  |  |
| 1124 | 395 | **Enhanced P-CSCF discovery using signalling for access to EPC via WLAN** | 115d? | 2014-10-06 A | 2015-03-13 A | 100% |  |  |  |  |  |  | C1 | 2424h | 2424h | ePCSCF_WLAN | 34 | Ericsson |  | Rel-13 | 66 |  |  |  |
| 1125 | 395.1 | CT1 aspects of Enhanced P-CSCF discovery using signalling for access to EPC via WLAN | 73d? | 2014-12-03 A | 2015-03-13 A | 100% |  |  |  |  |  | finish no earlier than 2015-03-13 | C1 | 584h | 584h | ePCSCF_WLAN | 34 | Ericsson |  | Rel-13 | 66 |  |  |  |
| 1126 | 395.2 | CT4 aspects of Enhanced P-CSCF discovery using signalling for access to EPC via WLAN | 115d? | 2014-10-06 A | 2015-03-13 A | 100% |  |  |  |  |  | finish no earlier than 2015-03-13 | C4 | 920h | 920h | ePCSCF_WLAN | 34 | Ericsson |  | Rel-13 | 66 |  |  |  |
| 1127 | 396 | **P-CSCF Restoration Enhancements with WLAN** | 268.05d? | 2014-12-03 A | 2015-12-14 A | 100% |  |  |  |  |  |  | C4 | 6432.4h | 6432.4h | PCSCF_RES_WLAN | 34 | Jean-Jacques Trottin, Alcatel-Lucent | jean-jacques.trottin@alcatel-lucent.com | Rel-13 | 66 |  |  |  |
| 1128 | 396.1 | CT1 aspects of P-CSCF Restoration Enhancements with WLAN | 268d? | 2014-12-03 A | 2015-12-14 A | 100% |  |  |  |  |  | finish no earlier than 2015-12-11 | C1 | 2144h | 2144h | PCSCF_RES_WLAN | 34 | Jean-Jacques Trottin, Alcatel-Lucent | jean-jacques.trottin@alcatel-lucent.com | Rel-13 | 66 |  |  |  |
| 1129 | 396.2 | CT4 aspects of P-CSCF Restoration Enhancements with WLAN | 268d? | 2014-12-03 A | 2015-12-11 A | 100% |  |  |  |  |  | finish no earlier than 2015-12-11 | C4 | 2144h | 2144h | PCSCF_RES_WLAN | 34 | Jean-Jacques Trottin, Alcatel-Lucent | jean-jacques.trottin@alcatel-lucent.com | Rel-13 | 66 |  |  |  |

Notes:
- 1106: CP#65 moved to Rel-13. Stage 2/3 / Impacted TSs and TRs: Stage 2/3
- 1107: CP#65 moved to Rel-13. Completion 09/14=>12/15. Dec.14: 10->100 / Impacted TSs and TRs: 23.334, 29.334
- 1108: CP#65 moved to Rel-13. Completion 09/14=>12/15; 7/12/15: 0%->100 / Impacted TSs and TRs: 24.229
- 1109: CP#65 moved to Rel-13. Completion 09/14=>12/15; 8/12/15: 0%->100 / Impacted TSs and TRs: 29.213, 29.214
- 1110: RP#65 FS_LTE_FDD_1670_US is extended to 12/14 and this WI (LTE_FDD_1670_US) is on hold till 12/14 / Impacted TSs and TRs: LTE
- 1111: RP#65 completion 03/15=>06/15. On hold till 12/2014 / Impacted TSs and TRs: 25.101, 25.104, 25.113, 25.133, 25.306, 25.307, 25.331, 25.461, 25.466, 34.124, 36.101, 36.104, 36.113, 36.124, 36.133, 36.307, new TR 36.832
- 1112: RP#65 completion 06/15=>09/15. . On hold till 12/2014 / Impacted TSs and TRs: 25.133, 25.306, 25.307, 25.331, 25.461, 25.466, 34.124, 36.113, 36.124, 36.133, 36.141, 36.307
- 1113: Triggered by TR 36.874 Study on Coordinated Multi-Point (CoMP) operation for LTE with Non-Ideal Backhaul (UID_600015) / Impacted TSs and TRs: LTE
- 1114: CD:Thu 11/12/14->Mon 15/06/15; Compl:0%->15%; Stat Rep: -->RP-141805 1st Apr 15: Compl:15%->30% 1st Apr 15: Stat Rep: RP-141805->RP-150162 03/07/15: Compl:30%->90% 03/07/15: CD:Mon 15/06/15->Tue 15/09/15 03/07/15: Stat Rep: RP-150162->RP-150846 29/09/1 / Impacted TSs and TRs: 36.300, 36.423
- 1115: Triggered by TR 37.846 Study on 2GHz FDD for UTRA and LTE in Region 1 (1980-2010MHz and 2170-2200MHz Bands) FS_UTRA_LTE_1980_2170_REG1 / Impacted TSs and TRs: LTE
- 1116: CD:Fri 12/06/15->Mon 15/06/15; Compl:5%->15%; Stat Rep: RP-141627->RP-141795 1st Apr 15: Compl:15%->35% 1st Apr 15: WID: RP-141710->RP-150424 1st Apr 15: Stat Rep: RP-141795->RP-150106 03/07/15: Compl:35%->70% 03/07/15: CD:Mon 15/06/15->Tue 15/12/15 03 / Impacted TSs and TRs: 36.101, 36.104, 36.133, 36.141, 36.307, generic TR 36.853 (3 Band CA with 1UL), New TR 36.862 (Technical Report for 2 GHz Band in Region 1)
- 1117: CD:Fri 12/06/15->Mon 15/06/15; Compl:0%->0%; Stat Rep: RP-141627->RP-141795 1st Apr 15: WID: RP-141710->RP-150424 1st Apr 15: Stat Rep: RP-141795->RP-150106 03/07/15: CD:Mon 15/06/15->Tue 15/12/15 03/07/15: Stat Rep: RP-150106->RP-150705 29/09/15: Stat / Impacted TSs and TRs: 36.101, 36.104, 36.133, 36.141, 36.307, 36.862
- 1118: testing REL-13 LTE_1980_2170_REG1-Core and LTE_1980_2170_REG3-Core;
- 1119: Triggered by TR 37.822 Study on Next-Generation SON for UTRA and LTE (FS_UTRA_LTE_NG_SON) / Impacted TSs and TRs: LTE
- 1120: CD:Tue 16/06/15->Mon 15/06/15; Compl:0%->15%; Stat Rep: -->RP-141854 1st Apr 15: Compl:15%->25% 1st Apr 15: Stat Rep: RP-141854->RP-150110 03/07/15: Compl:25%->100% 03/07/15: Stat Rep: RP-150110->RP-150727 / Impacted TSs and TRs: 36.300, 36.423, 36.413, 25.413
- 1122: June2015: Compl:6%->100. Verbal indication from SA2 chair / Impacted TSs and TRs: 23.203
- 1123: Mar.15: 10->100% / Impacted TSs and TRs: 29.212, 29.215
- 1125: . 12/12:0->100%. 5/5/15: acronym changed from ePCSCF_WLAN-CT1 to ePCSCF_WLAN / Impacted TSs and TRs: 24.229, 24.302
- 1126: Mar.15: 0->100%. 5/5/15: acronym changed from ePCSCF_WLAN-CT1 to ePCSCF_WLAN / Impacted TSs and TRs: 29.274, 29.275
- 1127: WID added, acronym. June 2015: WID: CP-140995-> CP-150275
- 1128: CT4->CT1. 2/4/15: acronym changed to PCSCF_RES_WLAN; June2015: Compl:0%->10. June 2015: WID: CP-140995-> CP-150275; 07/09/15: 10%->70; 7/12/15: 70%->100 / Impacted TSs and TRs: 24.302, 24.229, 24.244, 24.008
- 1129: Dec.14: 0->5%. Mar.15: 5->100%. 2/4/15: acronym changed to PCSCF_RES_WLAN; June2015: Compl:100%->75. June 2015: WID: CP-140995-> CP-150275; 07/09/15: 75%->85; 7/12/15: 85%->100 / Impacted TSs and TRs: New 29.8xy, 23.380, 29.273, 29.274, 29.275, 23.008

| ID | WBS | Task | Duration | Start | Finish | Complete | Remaining | Total slack | Constraint | Resources | Work | Actual work | Acronym | PCG approved | WI rapporteur name | WI rapporteur e-mail | Release | TSG approved |
| --- | --- | --- | --- | --- | --- | --- | --- | --- | --- | --- | --- | --- | --- | --- | --- | --- | --- | --- |
| 1130 | 397 | **Mobile Equipment Identity signalling over WLAN** | 69d? | 2015-06-15 A | 2015-09-17 A | 100% |  |  |  | C4 | 1656h | 1656h | MEI_WLAN | 35 | Bruno Landais, Alcatel-Lucent | bruno.landais@alcatel-lucent.com | Rel-13 | 68 |
| 1131 | 397.1 | CT1 aspects of Mobile Equipment Identity signalling over WLAN | 69d? | 2015-06-15 A | 2015-09-17 A | 100% |  |  | start no earlier than 2015-06-15 | C1 | 552h | 552h | MEI_WLAN | 35 | Bruno Landais, Alcatel-Lucent | bruno.landais@alcatel-lucent.com | Rel-13 | 68 |
| 1132 | 397.2 | CT4 aspects of Mobile Equipment Identity signalling over WLAN | 69d? | 2015-06-15 A | 2015-09-17 A | 100% |  |  | start no earlier than 2015-06-15 | C4 | 552h | 552h | MEI_WLAN | 35 | Bruno Landais, Alcatel-Lucent | bruno.landais@alcatel-lucent.com | Rel-13 | 68 |
| 1133 | 398 | Authentication Signalling Improvements for WLAN | 195d? | 2015-06-15 A | 2016-03-11 A | 100% |  |  | finish no earlier than 2016-03-11 | C1 | 1560h | 1560h | ASI_WLAN | 35 | Youyang Yu | yuyouyang@huawei.com | Rel-13 | 68 |
| 1134 | 399 | **Stage-3 SAE Protocol Development - Phase 4** | 268d? | 2014-12-03 A | 2015-12-11 A | 100% |  |  |  | C1 | 8576h | 8576h | SAES4 | 34 | interdigital |  | Rel-13 | 66 |
| 1135 | 399.1 | SAE Protocol Development (Stage 3) - Phase 4 | 268d? | 2014-12-03 A | 2015-12-11 A | 100% |  |  | start no earlier than 2014-12-03 | C1 | 2144h | 2144h | SAES4 | 34 | interdigital |  | Rel-13 | 66 |
| 1136 | 399.2 | CS Fallback in EPS - Phase 4 | 268d? | 2014-12-03 A | 2015-12-11 A | 100% |  |  | start no earlier than 2014-12-03 | C1 | 2144h | 2144h | SAES4-CSFB | 34 | interdigital |  | Rel-13 | 66 |
| 1137 | 399.3 | SAE for support for non-3GPP accesses - Phase 4 | 268d? | 2014-12-03 A | 2015-12-11 A | 100% |  |  | start no earlier than 2014-12-03 | C1 | 2144h | 2144h | SAES4-non3GPP | 34 | interdigital |  | Rel-13 | 66 |
| 1138 | 400 | **Interworking solution for Called IN number and original called IN number ISUP parameters** | 73d? | 2014-12-03 A | 2015-03-13 | 74% | 19.1d? | 5412d |  | C1; C3 | 2354.5h | 1738.34h | INNB_IW | 34 | Orange |  | Rel-13 | 66 |
| 1139 | 400.1 | Interworking solution for Called IN number and original called IN number ISUP parameters | 73d? | 2014-12-03 A | 2015-03-13 A | 100% |  |  | start no earlier than 2014-12-03 | C1 | 584h | 584h | INNB_IW | 34 | Orange |  | Rel-13 | 66 |
| 1140 | 400.2 | (IETF) CT1 part of Interworking solution for Called IN number and original called IN number ISUP parameters | 51.75d? | 2014-12-03 | 2015-03-10 |  |  | 5415d | finish no earlier than 2015-03-10 | C1-IETF | 414h |  | INNB_IW | 34 | Orange |  | Rel-13 | 66 |
| 1141 | 400.3 | CT3 aspects of Interworking solution for Called IN number and original called IN number ISUP parameters | 73d? | 2014-12-03 A | 2015-03-13 A | 100% |  |  | finish no earlier than 2015-03-13 | C3 | 584h | 584h | INNB_IW | 34 | Orange |  | Rel-13 | 66 |
| 1142 | 401 | **Warning Status Report in EPS** | 204d? | 2014-12-03 A | 2015-09-14 A | 100% |  |  |  | C4 | 4896h | 4896h | WSR_EPS | 34 | one2many |  | Rel-13 | 66 |
| 1143 | 401.1 | CT1 aspects of Warning Status Report in EPS | 204d? | 2014-12-03 A | 2015-09-14 A | 100% |  |  | start no earlier than 2014-12-03 | C1 | 1632h | 1632h | WSR_EPS | 34 | one2many |  | Rel-13 | 66 |
| 1144 | 401.2 | CT4 aspects of Warning Status Report in EPS | 204d? | 2014-12-03 A | 2015-09-14 A | 100% |  |  | finish no earlier than 2015-09-14 | C4 | 1632h | 1632h | WSR_EPS | 34 | one2many |  | Rel-13 | 66 |
| 1145 | 402 | Shared Data Update for Multiple Subscriber | 1d? | 2014-12-03 A | 2014-12-03 A | 100% |  |  | start no earlier than 2014-12-03 | C4 | 8h | 8h | SHARED_SubData_UPD | 34 | Huawei, Susan Shi | susan.shishufeng@huawei.com | Rel-13 | 66 |
| 1146 | 403 | **IMS Stage-3 IETF Protocol Alignment** | 666d? | 2014-12-03 A | 2017-06-20 | 70% | 199.79d? | 4819d |  | C1 | 11760h | 6003.22h | IMSProtoc7 | 34 | Alcatel-Lucent | Keith Drage | Rel-13 | 66 |
| 1147 | 403.1 | CT1 aspects of IMS Stage-3 IETF Protocol Alignment | 268d? | 2014-12-03 A | 2015-12-11 A | 100% |  |  | finish no earlier than 2015-12-11 | C1 | 2144h | 2144h | IMSProtoc7 | 34 | Alcatel-Lucent | Keith Drage | Rel-13 | 66 |
| 1148 | 403.2 | (IETF) CT1 aspects of IMS Stage-3 IETF Protocol Alignment | 268d? | 2016-06-13 A | 2017-06-20 | 10% | 241.2d? | 4819d | finish no earlier than 2015-12-11 | C1 | 2144h | 214.4h | IMSProtoc7 | 34 | Alcatel-Lucent | Keith Drage | Rel-13 | 66 |
| 1149 | 403.3 | CT3 aspects of IMS Stage-3 IETF Protocol Alignment | 268d? | 2014-12-03 A | 2015-12-11 A | 100% |  |  | start no earlier than 2014-12-03 | C3 | 2144h | 2144h | IMSProtoc7 | 34 | Alcatel-Lucent | Keith Drage | Rel-13 | 67 |
| 1150 | 404 | Retry restriction for Improving System Efficiency | 205d? | 2015-03-04 A | 2015-12-15 A | 100% |  |  | finish no earlier than 2015-12-15 | C1 | 1640h | 1640h | RISE | 34 | Huawei, Lin Shu | shulin@huawei.com | Rel-13 | 67 |
| 1151 | 405 | **H.248 Aspects of WebRTC Data Channel on IMS Access Gateway** | 268d? | 2015-03-04 A | 2016-03-11 A | 100% |  |  |  | C4 | 4288h | 4288h | WebRTCH248DC | 34 | China Mobile, Xiaoning Du | duxiaoning@chinamobile.com | Rel-13 | 67 |
| 1152 | 405.1 | CT4 Aspect of H.248 Aspects of WebRTC Data Channel on IMS Access Gateway | 268d? | 2015-03-04 A | 2016-03-11 A | 100% |  |  | finish no earlier than 2016-03-11 | C4 | 2144h | 2144h | WebRTCH248DC | 34 | China Mobile, Xiaoning Du. ES in 639 | duxiaoning@chinamobile.com | Rel-13 | 67 |
| 1153 | 406 | Continuation of the Overload Control for PCC based Diameter applications | 203d? | 2015-03-04 A | 2015-12-11 A | 100% |  |  | finish no earlier than 2015-12-11 | C3 | 1624h | 1624h | cDOCME_PCC | 34 | ZTE, Zhou Xiaoyun | zhou.xiaoyun@zte.com.cn | Rel-13 | 67 |
| 1154 | 407 | Review of dedicated 3GPP UICC features | 200d? | 2015-03-09 A | 2015-12-11 A | 100% |  |  | finish no earlier than 2015-12-11 | C6 | 1600h | 1600h | Red_UCe | 34 | Blackberry, Adrian Buckley | abuckley@blackberry.com | Rel-13 | 67 |

Notes:
- 1130: Impacted TSs and TRs: 24.244, 24.302, 29.273, 29.274, 29.275, 23.008
- 1131: 07/09/15: 0%->80; 7/12/15: 80%->100 / Impacted TSs and TRs: 24.244, 24.302
- 1132: 07/09/15: 0%->90; 7/12/15: 90%->100 / Impacted TSs and TRs: 29.273, 29.274, 29.275, 23.008
- 1133: 07/09/15: 0%->40; 7/12/15: 40%->95. FCD -> 03/16, ES in CP-150727; 7/3/16: 95%->100 / Impacted TSs and TRs: 24.302, 24.244
- 1134: WP Structure created 24/03/15 to avoid confusion in Acronyms / Impacted TSs and TRs: 23.12, 24.008, 24.167, 24.229, 24.301, 24.302, 24.303, 24.304, 24.305, 24.312, 29.018, 29.118
- 1135: WP Structure created 24/03/15 to avoid confusion in Acronyms. 5/5/15: acronym changed from "SAES4-CT1"; June2015: Compl:0%->30; 07/09/15: 30%->70; 7/12/15: 70%->100
- 1136: WP Structure created 24/03/15 to avoid confusion in Acronyms; June2015: Compl:0%->30; 07/09/15: 30%->70; 7/12/15: 70%->100
- 1137: WP Structure created 24/03/15 to avoid confusion in Acronyms; June2015: Compl:0%->30; 07/09/15: 30%->50; 7/12/15: 50%->100
- 1139: 5/5/15: created; June2015: Compl:0%->70; 07/09/15: 70%->100 / Impacted TSs and TRs: 24.229
- 1140: Mar15: resp WG:C1->C1-IETF. WID changed from INNB_IW-CT1 / Impacted TSs and TRs: draft-mohali-dispatch-cause-for-service-number
- 1141: Mar.15: 80->90%. WID changed from INNB_IW-CT3; June2015: Compl:0%->98; 07/09/15: 98%->99; 7/12/15: 99%->100
- 1142: 5/5/15: acronym changed from "WSR_EP"; 7/12/15: WID:CP-140998->CP-150792
- 1143: 2/4/15: acronym changed to WSR_EP. 5/5/15: acronym changed from "WSR_EP"; 07/09/15: 0%->25; 7/12/15: 25%->100; 7/12/15: WID:CP-140998->CP-150792 / Impacted TSs and TRs: New TR 23.712
- 1144: 2/4/15: acronym changed to WSR_EP. 5/5/15: acronym changed from "WSR_EP"; 7/12/15: 0%->100; 7/12/15: WID:CP-140998->CP-150792
- 1145: Mar.15: 0->50%, WID: CP-140804->CP-150013; June2015: Compl:50%->95; 07/09/15: 95%->100 / Impacted TSs and TRs: 29.328, 29.364
- 1146: Mar.15: 0->10% / Impacted TSs and TRs: 23.218, 24.998, 24.930
- 1147: Mar.15: 0->10%; June2015: Compl:10%->30; 07/09/15: 30%->70; 7/12/15: 70%->100
- 1148: Impacted TSs and TRs: draft-ietf-mmusic-dtls-sdp, draft-ietf-mmusic-4572-update
- 1149: 2/4/15: added, following CT3 chair's info that the WID also has a CT3 part; June2015: Compl:0%->20; 07/09/15: 20%->40; 7/12/15: 40%->100
- 1150: Continuation of Rel-12 SINE UID 620006. 5/5/15: acronym changed from "RISE"; June2015: Compl:0%->10; 07/09/15: 10%->70; 14/09/15: WID:CP-150092->CP-150495; 7/12/15: 70%->100
- 1151: Impacted TSs and TRs: 23.334
- 1152: June2015: Compl:0%->10; 07/09/15: 10%->20; 7/12/15: 20%->90; 7/3/16: 90%->100 / Impacted TSs and TRs: 23.334
- 1153: Relates to UID 580026 (Study on Diameter overload control mechanism); June2015: Compl:0%->100 / Impacted TSs and TRs: 29.212, 29.215, 29.219, 29.217
- 1154: Results from the homonymous Study; June2015: Compl:0%->60; 07/09/15: 60%->75; 7/3/16: 75%->100 / Impacted TSs and TRs: 31.102, 31.111, 31.121, 31.124

| ID | WBS | Task | Type | Duration | Start | Finish | Complete | Remaining | Baseline start | Baseline finish | Baseline duration | Total slack | Constraint | Resources | Work | Actual work | Acronym | PCG approved | WI rapporteur name | WI rapporteur e-mail | Release | TSG approved | Status Report | Acronym_3GU_Export | TSG stopped | MCC resp |
| --- | --- | --- | --- | --- | --- | --- | --- | --- | --- | --- | --- | --- | --- | --- | --- | --- | --- | --- | --- | --- | --- | --- | --- | --- | --- | --- |
| 1155 | 408 | **Controlling IMS Media Plane with SDP Capability** |  | 195d? | 2015-06-15 A | 2016-03-11 A | 100% |  |  |  |  |  |  | C4 | 4680h | 4680h | SDPCN_IMS | 35 | Weiwei(Tommy) Yang, Huawei. ES in 640 | tommy@huawei.com | Rel-13 | 68 |  |  |  |  |
| 1156 | 408.1 | CT3 aspects of Controlling IMS Media Plane with SDP Capability |  | 195d? | 2015-06-15 A | 2016-03-11 A | 100% |  |  |  |  |  | finish no earlier than 2016-03-11 | C3 | 1560h | 1560h | SDPCN_IMS | 35 | Weiwei(Tommy) Yang, Huawei. ES in 640 | tommy@huawei.com | Rel-13 | 68 |  |  |  |  |
| 1157 | 408.2 | CT4 aspects of Controlling IMS Media Plane with SDP Capability |  | 195d? | 2015-06-15 A | 2016-03-11 A | 100% |  |  |  |  |  | finish no earlier than 2016-03-11 | C4 | 1560h | 1560h | SDPCN_IMS | 35 | Weiwei(Tommy) Yang, Huawei. ES in 640 | tommy@huawei.com | Rel-13 | 68 |  |  |  |  |
| 1158 | 409 | **(SA66: on hold) Co-ordinated packet data network gateway (P-GW) change for SIPTO** |  | 66d? | 2014-06-18 A | 2014-09-16 A | 100% |  | 2014-06-18 | 2014-09-17 | 66d? |  |  | S1 | 1056h | 1056h | CSIPTO | 33 | Intel | Eric.siow@intel.com | Rel-13 | 64 | S1-143306 | CSIPTO |  |  |
| 1159 | 409.1 | Stage 1 for Co-ordinated packet data network gateway (P-GW) change for SIPTO |  | 66d? | 2014-06-18 A | 2014-09-16 A | 100% |  | 2014-06-18 | 2014-09-17 | 66d? |  | finish no earlier than 2014-09-17 | S1 | 528h | 528h | CSIPTO-ST1 | 33 | Intel | Eric.siow@intel.com | Rel-13 | 64 | S1-143306 | CSIPTO |  |  |
| 1160 | 410 | **Enhanced CS Fallback (CSFB)** |  | 196d? | 2014-06-18 A | 2015-03-13 | 100% | 0d? | 2014-06-18 | 2015-03-18 | 196d? | 0d |  | S2; S3 | 4168h | 2600h | eCSFB | 33 | China Unicom | Yang Xu (xuyang49@chinaunicom.cn) | Rel-13 | 64 |  | eCSFB |  |  |
| 1161 | 410.1 | TR for Enhanced CS Fallback (CSFB) |  | 128d? | 2014-06-18 A | 2014-12-12 A | 100% |  | 2014-06-18 | 2014-12-10 | 126d? |  | finish no earlier than 2014-12-12 | S2 | 1024h | 1024h | eCSFB | 33 | China Unicom | Yang Xu (xuyang49@chinaunicom.cn) | Rel-13 | 64 |  |  |  |  |
| 1162 | 410.2 | Deleted - Stage 2 for Enhanced CS Fallback (CSFB) | milestone | 0d? | 2015-03-13 A | 2015-03-13 A | 100% |  | 2014-06-18 | 2015-03-18 | 196d? |  | start no earlier than 2015-03-13 | S2 |  |  | eCSFB | 33 | China Unicom | Yang Xu (xuyang49@chinaunicom.cn) | Rel-13 | 64 |  |  | SP-69 |  |
| 1163 | 410.3 | Deleted - Security for Enhanced CS Fallback (CSFB) |  | 1d? | 2014-09-18 A | 2014-09-18 A | 100% |  |  |  |  |  | start no earlier than 2014-09-17 | S3 | 8h | 8h | eCSFB | 33 | China Unicom | Feng Gao (gaofeng149@chinaunicom.cn) | Rel-13 | 65 |  |  | SP-69 |  |
| 1164 | 411 | **SRVCC Enhancements for Transcoding Avoidance** |  | 196d? | 2014-09-19 A | 2015-06-17 A | 100% |  |  |  |  |  |  | S2 | 2592h | 2592h | SETA | 33 | Ericsson | George.Foti@ericsson.com | Rel-13 | 65 |  | SETA |  |  |
| 1165 | 411.1 | TR for SRVCC Enhancements for Transcoding Avoidance |  | 128d? | 2014-09-19 A | 2015-03-13 A | 100% |  |  |  |  |  | finish no earlier than 2015-03-13 | S2 | 1024h | 1024h | SETA-SA2TR | 33 | Ericsson | George.Foti@ericsson.com | Rel-13 | 65 |  |  |  |  |
| 1166 | 411.2 | Deleted - Stage 2 for SRVCC Enhancements for Transcoding Avoidance | milestone | 0d? | 2015-06-17 A | 2015-06-17 A | 100% |  |  |  |  |  | start no earlier than 2015-06-17 | S2 |  |  | SETA-SA2 | 33 | Ericsson | George.Foti@ericsson.com | Rel-13 | 65 |  |  | SP-69 |  |
| 1167 | 412 | **Base Station (BS) RF requirements for Active Antenna System (AAS)** |  | 933d? | 2013-03-04 A | 2016-09-15 A | 100% |  | 2013-03-04 | 2014-12-05 | 465d? |  |  | R4 | 21184h | 21184h | AAS_BS_LTE_UTRA | 30 | Huawei | ronnie.zhang@huawei.com | Rel-13 | 59 |  | AAS_BS_LTE_UTRA |  | Issam |
| 1168 | 412.1 | Core part: Base Station (BS) RF requirements for Active Antenna System (AAS) |  | 793d? | 2013-03-04 A | 2016-03-15 A | 100% |  | 2013-03-04 | 2014-09-12 | 401d? |  | finish no earlier than 2016-03-15 | R4 | 6344h | 6344h | AAS_BS_LTE_UTRA-Core | 30 | Huawei | ronnie.zhang@huawei.com | Rel-13 | 59 | RP-151241 | AAS_BS_LTE_UTRA-Core |  | Issam |
| 1169 | 412.2 | Perf. part: Base Station (BS) RF requirements for Active Antenna System (AAS) |  | 922d? | 2013-03-15 A | 2016-09-15 A | 100% |  | 2013-03-07 | 2014-12-05 | 461d? |  | finish no earlier than 2016-09-15 | R4 | 7376h | 7376h | AAS_BS_LTE_UTRA-Perf | 30 | Huawei | ronnie.zhang@huawei.com | Rel-13 | 59 | RP-151241 | AAS_BS_LTE_UTRA-Perf |  | Issam |
| 1170 | 413 | **Enhanced LTE Device to Device Proximity Services** |  | 460d? | 2014-12-15 A | 2016-09-15 A | 100% |  |  |  |  |  |  | R2 | 11016h | 11016h | LTE_eD2D_Prox | 34 | Qualcomm | Qualcomm | Rel-13 | 66 |  |  |  |  |
| 1171 | 413.1 | Core part: Enhanced LTE Device to Device Proximity Services |  | 152.33d? | 2015-08-14 A | 2016-03-15 A | 100% |  |  |  |  |  | finish no earlier than 2016-03-15 | R2; R1; R3 | 3656h | 3656h | LTE_eD2D_Prox-Core | 34 | Qualcomm Incorporated, Shailesh Patil | patil@qti.qualcomm.com | Rel-13 | 66 | RP-151337 |  |  |  |
| 1172 | 413.2 | Perf. part: Enhanced LTE Device to Device Proximity Services |  | 460d? | 2014-12-15 A | 2016-09-15 A | 100% |  |  |  |  |  | finish no earlier than 2016-09-15 | R4 | 3680h | 3680h | LTE_eD2D_Prox-Perf | 34 | Qualcomm | Qualcomm | Rel-13 | 66 | RP-151337 |  |  |  |
| 1173 | 414 | **Radiated requirements for the verification of multi-antenna reception performance of UEs** |  | 327d? | 2014-12-15 A | 2016-03-15 A | 100% |  |  |  |  |  |  | R4 | 5232h | 5232h | UTRA_LTE_MIMO_OTA | 34 | Intel | Intel | Rel-13 | 66 | RP-171826 |  |  |  |
| 1174 | 414.1 | Core part: Radiated requirements for the verification of multi-antenna reception performance of UEs |  | 327d? | 2014-12-15 A | 2016-03-15 A | 100% |  |  |  |  |  | finish no earlier than 2016-03-15 | R4 | 2616h | 2616h | UTRA_LTE_MIMO_OTA-Core | 34 | Intel | Intel | Rel-13 | 66 | RP-151573 |  |  |  |
| 1175 | 415 | **UE core requirements for uplink 64 QAM** |  | 197d? | 2014-12-15 A | 2015-09-15 A | 100% |  |  |  |  |  |  | R4 | 3152h | 3152h | LTE_UL64QAM | 34 | Huawei | Huawei | Rel-13 | 66 |  |  |  |  |
| 1176 | 415.1 | Core part: UE core requirements for uplink 64 QAM |  | 197d? | 2014-12-15 A | 2015-09-15 A | 100% |  |  |  |  |  | finish no earlier than 2015-09-15 | R4 | 1576h | 1576h | LTE_UL64QAM-Core | 34 | Huawei | Huawei | Rel-13 | 66 | RP-151244 |  |  |  |
| 1177 | 416 | UE Conformance Test Aspects - Core Requirements for Uplink 64QAM for E-UTRA |  | 132d? | 2015-06-15 A | 2015-12-15 A | 100% |  |  |  |  |  | finish no earlier than 2015-12-15 | R5 | 1056h | 1056h | LTE_UL64QAM-UEConTest | 35 | CMCC |  | Rel-13 | 68 | RP-151174 |  |  |  |
| 1178 | 417 | **Performance requirements of MMSE-IRC receiver for LTE BS** |  | 393d? | 2014-12-15 A | 2016-06-15 A | 100% |  |  |  |  |  |  | R4 | 6288h | 6288h | LTE_MMSE_IRC_BS | 34 | China Telecom | China Telecom | Rel-13 | 66 |  |  |  |  |
| 1179 | 417.1 | Perf. part: Performance requirements of MMSE-IRC receiver for LTE BS |  | 393d? | 2014-12-15 A | 2016-06-15 A | 100% |  |  |  |  |  | finish no earlier than 2016-06-15 | R4 | 3144h | 3144h | LTE_MMSE_IRC_BS-Perf | 34 | China Telecom | China Telecom | Rel-13 | 66 | RP-151215 |  |  |  |

Notes:
- 1155: Impacted TSs and TRs: 23.334, 29.334, 29.162, 29.238, 23.333, 29.333, 29.163, 29.332, 29.292, 29.232, 29.235
- 1156: 7/12/15: 0%->90. FCD->03/16. ES in CP-150614; 7/3/16: 90%->100 / Impacted TSs and TRs: 29.162, 29.163, 29.292, 29.235
- 1157: 07/09/15: 0%->5; 7/12/15: 5%->70. FCD->03/16. ES in CP-150614; 7/3/16: 70%->100 / Impacted TSs and TRs: 23.334, 29.334, 29.238, 23.333, 29.333, 29.332, 29.232
- 1158: SP#65 completed. Updated WID SP-140235=>SP-140509. Triggered by Rel-13 Study TR 22.828 (FS_CSIPTO) / Impacted TSs and TRs: 22.101
- 1159: SP#65 completed. Updated WID SP-140235=>SP-140509. Triggered by Rel-13 Study TR 22.828 (FS_CSIPTO). Dec.14: former S1-only feature split / Impacted TSs and TRs: 22.101
- 1160: SP#65 updated ID SP-140285=>SP-140579 (added SA3 part). Linked to Rel-8 WIs Single Radio Voice Call Continuity for 3GPP (SAES-SRVCC) and CS Fallback in EPS (SAES-CSFB) / Impacted TSs and TRs: Stage 2
- 1161: SP#65 updated ID SP-140285=>SP-140579 (added SA3 part). Dec.14: 35->85%; 14/09/15: 85%->100. SA#69: decision not to continue the work on this. No normative work. / Impacted TSs and TRs: New TR 23.772
- 1162: SP#65 updated ID SP-140285=>SP-140579 (added SA3 part) / Impacted TSs and TRs: 23.272
- 1163: SP#65 updated ID SP-140285=>SP-140579; 14/09/15: 0%->100. SA#69: deleted, since SA2 has stopped the work.
- 1164: Enhance chances for end-to-end transcoder free operation (TrFo) where possible/ ensure proper CS radio resources are reserved for optimal RAN codec. Address TrFo of EVS codecs during SRVCC that are not covered by Rel-12 / Impacted TSs and TRs: Stage 2
- 1165: Dec.14: 0->70%; 14/09/15: 70%->100. Stopped without conclusion, no intention to continue the study nor to do any mormative work. / Impacted TSs and TRs: New TR 23.7xy
- 1166: SA#69: stop the work on this. / Impacted TSs and TRs: 23.216, 23.237
- 1167: Triggered by Rel-12 TR 37.840 Study of RF and EMC Requirements for Active Antenna Array System BS (FS_AAS_BS_LTE_UTRA) / Impacted TSs and TRs: UTRA, LTE, GERAN
- 1168: ; CD:Thu 11/12/14->Tue 15/12/15; WID: RP-141966->RP-142235; Stat Rep: RP-141249->RP-141908; Release: Rel-12->Rel-13 03/07/15: Stat Rep: RP-141908->RP-150687 29/09/15: Compl:75%->80% 29/09/15: Stat Rep: RP-150687->RP-151241; / Impacted TSs and TRs: New TS 37.142 (AAS BS Tx & Rx), New TR 37.842, 37.114, 37.145-1, 37.145-2
- 1169: ; CD:Sat 18/06/16->Wed 15/06/16; WID: RP-141966->RP-142235; Stat Rep: RP-141249->RP-141908; Release: Rel-12->Rel-13 03/07/15: Stat Rep: RP-141908->RP-150687 29/09/15: Stat Rep: RP-150687->RP-151241 22/3/16: Compl:2 26/9/16: Compl:95%->100% / Impacted TSs and TRs: New TS 37.1xy (AAS BS conformance testing)
- 1171: Rapporteur details and involved WGs updated 1st Apr 15: WID: RP-142311->RP-150441 1st Apr 15: Stat Rep: ->RP-150095 03/07/15: Compl:0%->32% 03/07/15: Stat Rep: RP-150095->RP-150795 29/09/15: Compl:32%->55% 29/09/15: Stat Rep: RP-150795->RP-151337;
- 1172: 1st Apr 15: WID: RP-142311->RP-150441 1st Apr 15: Stat Rep: ->RP-150095 03/07/15: Stat Rep: RP-150095->RP-150795 29/09/15: Stat Rep: RP-150795->RP-151337; 1/1/16: CD; 22/3/16: Compl:0%->10%;26/9/16: Compl:85%->100%
- 1174: 1st Apr 15: Compl:0%->5% 1st Apr 15: WID: RP-142221->RP-150261 1st Apr 15: Stat Rep: ->RP-150260 03/07/15: Compl:5%->15% 03/07/15: Stat Rep: RP-150260->RP-150746 29/09/15: Compl:15%->25% 29/09/15: WID: RP-150261->RP-151574 29/09/15: Stat Rep: RP-15074
- 1176: 1st Apr 15: Compl:0%->10% 1st Apr 15: Stat Rep: ->RP-150232 03/07/15: Compl:10%->90% 03/07/15: WID: RP-142222->RP-150691 03/07/15: Stat Rep: RP-150232->RP-150688 29/09/15: Compl:90%->100% 29/09/15: Stat Rep: RP-150688->RP-151244
- 1177: tested Core part: LTE_UL64QAM-Core which is not yet completed 29/09/15: Compl:0%->5% 29/09/15: Stat Rep: -->RP-151174 1/1/16: Compl:5%->100%
- 1179: 1st Apr 15: Compl:0%->10% 1st Apr 15: WID: RP-142223->RP-150206 1st Apr 15: Stat Rep: ->RP-150204 03/07/15: Compl:10%->35% 03/07/15: Stat Rep: RP-150204->RP-150630 29/09/15: Compl:35%->50% 29/09/15: Stat Rep: RP-150630->RP-151215;

| ID | WBS | Task | Duration | Start | Finish | Complete | Remaining | Total slack | Constraint | Resources | Work | Actual work | Acronym | PCG approved | WI rapporteur name | WI rapporteur e-mail | Release | TSG approved | Status Report |
| --- | --- | --- | --- | --- | --- | --- | --- | --- | --- | --- | --- | --- | --- | --- | --- | --- | --- | --- | --- |
| 1180 | 418 | **CRS Interference Mitigation for LTE Homogenous Deployments** | 327d? | 2014-12-15 A | 2016-03-15 A | 100% |  |  |  | R4 | 5232h | 5232h | LTE_CRSIM | 34 | Ericsson | Ericsson | Rel-13 | 66 |  |
| 1181 | 418.1 | Perf. part: CRS Interference Mitigation for LTE Homogenous Deployments | 327d? | 2014-12-15 A | 2016-03-15 A | 100% |  |  | finish no earlier than 2016-03-15 | R4 | 2616h | 2616h | LTE_CRSIM-Perf | 34 | Ericsson | Ericsson | Rel-13 | 66 | RP-151171 |
| 1182 | 419 | **Dual Connectivity enhancements for LTE** | 328d? | 2015-03-16 A | 2016-06-15 A | 100% |  |  |  | R2 | 6824h | 6824h | LTE_dualC_enh | 34 | NTT DOCOMO |  | Rel-13 | 67 |  |
| 1183 | 419.1 | Core part: Dual Connectivity enhancements for LTE | 197d? | 2015-03-16 A | 2015-12-15 A | 100% |  |  | finish no earlier than 2015-12-15 | R2 | 1576h | 1576h | LTE_dualC_enh-Core | 34 | NTT DOCOMO |  | Rel-13 | 67 | RP-151330 |
| 1184 | 419.2 | Perf. part: Dual Connectivity enhancements for LTE | 328d? | 2015-03-16 A | 2016-06-15 A | 100% |  |  | finish no earlier than 2016-06-15 | R4 | 2624h | 2624h | LTE_dualC_enh-Perf | 34 | NTT DOCOMO |  | Rel-13 | 67 | RP-151330 |
| 1185 | 420 | **Multicarrier Load Distribution of UEs in LTE** | 395d? | 2015-03-16 A | 2016-09-15 A | 100% |  |  |  | R2 | 7896h | 7896h | LTE_MC_load | 34 | ZTE |  | Rel-13 | 67 |  |
| 1186 | 420.1 | Core part: Multicarrier Load Distribution of UEs in LTE | 197d? | 2015-03-16 A | 2015-12-15 A | 100% |  |  | finish no earlier than 2015-12-15 | R2 | 1576h | 1576h | LTE_MC_load-Core | 34 | ZTE |  | Rel-13 | 67 | RP-151190 |
| 1187 | 420.2 | Perf. part: Multicarrier Load Distribution of UEs in LTE | 395d? | 2015-03-16 A | 2016-09-15 A | 100% |  |  | finish no earlier than 2016-09-15 | R4 | 3160h | 3160h | LTE_MC_load-Perf | 34 | ZTE |  | Rel-13 | 67 | RP-151190 |
| 1188 | 421 | **LTE-WLAN Radio Level Integration and Interworking Enhancement** | 785d? | 2015-03-16 A | 2018-03-15 | 73% | 215.87d? | 4627d |  | R2 | 14664h | 6669.4h | LTE_WLAN_radio | 34 | Intel |  | Rel-13 | 67 |  |
| 1189 | 421.1 | Core part: LTE-WLAN Radio Level Integration and Interworking Enhancement | 262d? | 2015-03-16 A | 2016-03-15 A | 100% |  |  | finish no earlier than 2016-03-15 | R2 | 2096h | 2096h | LTE_WLAN_radio-Core | 34 | Intel |  | Rel-13 | 67 | RP-151563 |
| 1190 | 421.2 | Perf. part: LTE-WLAN Radio Level Integration and Interworking Enhancement | 262d? | 2015-03-16 A | 2016-03-15 A | 100% |  |  | finish no earlier than 2016-03-15 | R4 | 2096h | 2096h | LTE_WLAN_radio-Perf | 34 | Intel |  | Rel-13 | 67 | RP-151563 |
| 1191 | 421.3 | UE Conformance Test Aspects - WLAN/3GPP Radio Level Integration and Interworking Enhancement Interworking | 524d? | 2016-03-15 A | 2018-03-15 | 45% | 288.2d? | 4627d | finish no earlier than 2018-03-15 | R5 | 4192h | 1886.4h | LTE_WLAN_radio-UEConTest | 36 | Intel |  | Rel-13 | 71 |  |
| 1192 | 422 | **RAN aspects for improvements to CS/PS coordination in UTRAN Shared Network** | 197d? | 2015-03-16 A | 2015-12-15 A | 100% |  |  |  | R3 | 3152h | 3152h | CSPS_Coord-UTRA | 34 | Ericsson |  | Rel-13 | 67 |  |
| 1193 | 422.1 | Core part: RAN aspects for improvements to CS/PS coordination in UTRAN Shared Network | 197d? | 2015-03-16 A | 2015-12-15 A | 100% |  |  | finish no earlier than 2015-12-15 | R3 | 1576h | 1576h | CSPS_Coord-UTRA-Core | 34 | Ericsson |  | Rel-13 | 67 | RP-151289 |
| 1194 | 423 | **LTE DL 4 Rx antenna ports** | 4639d? | 2000-01-03 A | 2017-09-15 | 99% | 0d? | 0d |  | R4 | 77392h | 46967.7h | LTE_4Rx_AP_DL | 34 | Ericsson |  | Rel-13 | 67 |  |
| 1195 | 423.1 | Core part: LTE DL 4 Rx antenna ports | 197d? | 2015-03-16 A | 2015-12-15 A | 100% |  |  | finish no earlier than 2015-12-15 | R4 | 1576h | 1576h | LTE_4Rx_AP_DL-Core | 34 | Ericsson |  | Rel-13 | 67 | RP-151265 |
| 1196 | 423.2 | Perf. part: LTE DL 4 Rx antenna ports | 4378d? | 2000-01-03 A | 2016-09-15 A | 100% |  |  | finish no earlier than 2016-09-15 | R4 | 35024h | 35024h | LTE_4Rx_AP_DL-Perf | 34 | Ericsson |  | Rel-13 | 67 | RP-151265 |
| 1197 | 423.3 | UE Conformance Test Aspects - LTE DL 4 Rx antenna ports | 460d? | 2015-12-15 A | 2017-09-15 A | 100% |  |  | finish no earlier than 2017-09-15 | R5 | 3680h | 3680h | LTE_4Rx_AP_DL-UEConTest | 36 | Ericsson |  | Rel-13 | 70 |  |
| 1198 | 424 | **AWS-Extension Band for LTE** | 395d? | 2015-03-16 A | 2016-09-15 A | 100% |  |  |  | R4 | 7904h | 7904h | LTE_AWS_EXT | 34 | Ericsson |  | Rel-13 | 67 |  |
| 1199 | 424.1 | Core part: AWS-Extension Band for LTE | 197d? | 2015-03-16 A | 2015-12-15 A | 100% |  |  | finish no earlier than 2015-12-15 | R4 | 1576h | 1576h | LTE_AWS_EXT-Core | 34 | Ericsson |  | Rel-13 | 67 | RP-151343 |
| 1200 | 424.2 | Perf. part: AWS-Extension Band for LTE | 197d? | 2015-03-16 A | 2015-12-15 A | 100% |  |  | finish no earlier than 2015-12-15 | R4 | 1576h | 1576h | LTE_AWS_EXT-Perf | 34 | Ericsson |  | Rel-13 | 67 | RP-151343 |
| 1201 | 424.3 | UE Conformance Test Aspects - AWS-Extension Band for LTE (Band 66) | 199d? | 2015-12-15 A | 2016-09-15 A | 100% |  |  | finish no earlier than 2016-09-15 | R5 | 1592h | 1592h | LTE_AWS_EXT-UEConTest | 36 | Ericsson |  | Rel-13 | 70 |  |
| 1202 | 425 | **Additional bandwidth combination set for LTE Advanced inter-band Carrier Aggregation of Band 5 and Band 7** | 66d? | 2015-03-16 A | 2015-06-15 A | 100% |  |  |  | R4 | 1584h | 1584h | LTE_CA_B5_B7_BWset | 34 | Nokia Networks |  | Rel-13 | 67 |  |
| 1203 | 425.1 | Core part: Additional bandwidth combination set for LTE Advanced inter-band Carrier Aggregation of Band 5 and Band 7 | 66d? | 2015-03-16 A | 2015-06-15 A | 100% |  |  | finish no earlier than 2015-06-15 | R4 | 528h | 528h | LTE_CA_B5_B7_BWset-Core | 34 | Nokia Networks |  | Rel-13 | 67 | RP-150536 |
| 1204 | 425.2 | Perf. part: Additional bandwidth combination set for LTE Advanced inter-band Carrier Aggregation of Band 5 and Band 7 | 66d? | 2015-03-16 A | 2015-06-15 A | 100% |  |  | finish no earlier than 2015-06-15 | R4 | 528h | 528h | LTE_CA_B5_B7_BWset-Perf | 34 | Nokia Networks |  | Rel-13 | 67 | RP-150536 |

Notes:
- 1181: 1st Apr 15: Compl:0%->10% 1st Apr 15: CD:Mon 15/06/15->Tue 15/03/16 1st Apr 15: Stat Rep: ->RP-150061 03/07/15: Compl:10%->20% 03/07/15: Stat Rep: RP-150061->RP-150584 29/09/15: Compl:20%->30% 29/09/15: Stat Rep: RP-150584->RP-151171
- 1183: 03/07/15: Compl:0%->25% 03/07/15: Stat Rep: ->RP-150744 29/09/15: Compl:25%->55% 29/09/15: Stat Rep: RP-150744->RP-151330 1/1/16: Compl:55%->100%
- 1184: 03/07/15: Stat Rep: ->RP-150744 29/09/15: Stat Rep: RP-150744->RP-151330 ; 1/1/16: WID: RP-150490->RP-15173922/3/16: Compl:0%->50%;
- 1186: 03/07/15: Compl:0%->40% 03/07/15: WID: RP-150491->RP-150611 03/07/15: Stat Rep: ->RP-150610 29/09/15: Compl:40%->55% 29/09/15: WID: RP-150611->RP-151206 29/09/15: Stat Rep: RP-150610->RP-151190
- 1187: 03/07/15: WID: RP-150491->RP-150611 03/07/15: Stat Rep: ->RP-150610 29/09/15: WID: RP-150611->RP-151206 29/09/15: Stat Rep: RP-150610->RP-1511901/1/16:22/3/16: Compl:70%->75%; 26/9/16: Compl:90%->100%; 26/9/16: WID: RP-152181
- 1189: 03/07/15: Compl:0%->30% 03/07/15: WID: RP-150510->RP-151114 03/07/15: Stat Rep: ->RP-151081, 07/08/15: impacted TSs added 29/09/15: Compl:30%->35% 29/09/15: Stat Rep: RP-151081->RP-151563; / Impacted TSs and TRs: 36.461, 36.462, 36.463, 36.464, 36.465, 36.622, 36.623, 36.624, 36.625, 36.360
- 1190: 03/07/15: WID: RP-150510->RP-151114 03/07/15: Stat Rep: ->RP-151081 29/09/15: Stat Rep: RP-151081->RP-1515631/1/16: Compl:0%->10% ; 22/3/16: Compl:10%->100%;
- 1191: testing REL-13 LTE_WLAN_radio-Core; 1/7/16: Compl:0%->5%; 20/21/3/17: Compl:20...; ;...; ;...
- 1193: 03/07/15: Compl:0%->45% 03/07/15: Stat Rep: ->RP-150842 29/09/15: Compl:45%->80% 29/09/15: CD:Tue 15/09/15->Tue 15/12/15 29/09/15: Stat Rep: RP-150842->RP-1512891/1/16: Compl:80%->100%
- 1195: 03/07/15: Compl:0%->25% 03/07/15: Stat Rep: ->RP-150803 29/09/15: Compl:25%->50% 29/09/15: Stat Rep: RP-150803->RP-151265; 1/1/16: Compl:50%->100%
- 1196: 03/07/15: Compl:0%->15% 03/07/15: CD:Mon 02/10/00->Wed 15/06/16 03/07/15: Stat Rep: ->RP-150803 29/09/15: Compl:15%->35% 29/09/15: Stat Rep: RP-150803->RP-15126522/3/16: Compl:60%-;26/9/16: Compl:90%->100%
- 1197: ; 22/3/16: Compl:0%->10%; 1/7/16: Compl:10%->25%; 26/9/16: 21/3/17: Compl:60%->70...; ;...; ;...
- 1199: 03/07/15: Compl:0%->20% 03/07/15: WID: RP-150428->RP-150800 03/07/15: Stat Rep: ->RP-150796 29/09/15: Compl:20%->50% 29/09/15: Stat Rep: RP-150796->RP-151343
- 1200: 03/07/15: WID: RP-150428->RP-150800 03/07/15: Stat Rep: ->RP-150796 29/09/15: Stat Rep: RP-150796->RP-151343;
- 1201: ; 22/3/16: Compl:0%->10%1/7/16: Compl:10%->65%26/9/16: Comp
- 1203: 03/07/15: Compl:0%->100% 03/07/15: WID: RP-150171->RP-150602 03/07/15: Stat Rep: ->RP-150536
- 1204: 03/07/15: Compl:0%->100% 03/07/15: WID: RP-150171->RP-150602 03/07/15: Stat Rep: ->RP-150536

| ID | WBS | Task | Duration | Start | Finish | Complete | Constraint | Resources | Work | Actual work | Acronym | PCG approved | WI rapporteur name | Release | TSG approved | Status Report | WI rapporteur e-mail | TSG stopped |
| --- | --- | --- | --- | --- | --- | --- | --- | --- | --- | --- | --- | --- | --- | --- | --- | --- | --- | --- |
| 1205 | 426 | **Additional bandwidth combination set for LTE Advanced inter-band Carrier Aggregation of Band 3 and Band 5** | 66d? | 2015-03-16 A | 2015-06-15 A | 100% |  | R4 | 1584h | 1584h | LTE_CA_B3_B5_BWset | 34 | Samsung | Rel-13 | 67 |  |  |  |
| 1206 | 426.1 | Core part: Additional bandwidth combination set for LTE Advanced inter-band Carrier Aggregation of Band 3 and Band 5 | 66d? | 2015-03-16 A | 2015-06-15 A | 100% | finish no earlier than 2015-06-15 | R4 | 528h | 528h | LTE_CA_B3_B5_BWset-Core | 34 | Samsung | Rel-13 | 67 | RP-150536 |  |  |
| 1207 | 426.2 | Perf. part: Additional bandwidth combination set for LTE Advanced inter-band Carrier Aggregation of Band 3 and Band 5 | 66d? | 2015-03-16 A | 2015-06-15 A | 100% | finish no earlier than 2015-06-15 | R4 | 528h | 528h | LTE_CA_B3_B5_BWset-Perf | 34 | Samsung | Rel-13 | 67 | RP-150536 |  |  |
| 1208 | 427 | **Multiflow Enhancements for UTRA** | 132d? | 2015-03-16 A | 2015-09-15 A | 100% |  | R2 | 2112h | 2112h | HSDPA_MFTX_enh | 34 | Nokia | Rel-13 | 67 |  | alexander.sayenko@nokia.com |  |
| 1209 | 427.1 | Core part: Multiflow Enhancements for UTRA | 132d? | 2015-03-16 A | 2015-09-15 A | 100% | finish no earlier than 2015-09-15 | R2 | 1056h | 1056h | HSDPA_MFTX_enh-Core | 34 | Nokia | Rel-13 | 67 | RP-151302 | alexander.sayenko@nokia.com |  |
| 1210 | 428 | **Message interworking during PS to CS SRVCC** | 68d? | 2015-06-15 A | 2015-09-16 A | 100% |  | C1 | 1632h | 1632h | mSRVCC | 35 | Ivo Sedlacek, Ericsson | Rel-13 | 68 |  | ivo.sedlacek@ericsson.com |  |
| 1211 | 428.1 | CT1 aspects of Message interworking during PS to CS SRVCC | 68d? | 2015-06-15 A | 2015-09-16 A | 100% | start no earlier than 2015-06-15 | C1 | 544h | 544h | mSRVCC | 35 | Ivo Sedlacek, Ericsson | Rel-13 | 68 |  | ivo.sedlacek@ericsson.com |  |
| 1212 | 428.2 | CT3 aspects of Message interworking during PS to CS SRVCC | 68d? | 2015-06-15 A | 2015-09-16 A | 100% | finish no earlier than 2015-09-16 | C3 | 544h | 544h | mSRVCC | 35 | Ivo Sedlacek, Ericsson | Rel-13 | 68 |  | ivo.sedlacek@ericsson.com |  |
| 1213 | 429 | **Support of Emergency services over WLAN – phase 1** | 192d? | 2015-06-18 A | 2016-03-11 A | 100% |  | S2 | 5896h | 5896h | SEW1 | 35 | Laurent thiebaut | Rel-13 | 68 |  | Laurent.thiebaut@alcatel-lucent.com |  |
| 1214 | 429.1 | Stage 2 of Support of Emergency services over WLAN - phase 1 | 65d? | 2015-06-18 A | 2015-09-16 A | 100% | finish no earlier than 2015-09-16 | S2 | 520h | 520h | SEW1 | 35 | Laurent thiebaut | Rel-13 | 68 |  | Laurent.thiebaut@alcatel-lucent.com |  |
| 1215 | 429.2 | **CT aspects of Support of Emergency services over WLAN – phase 1** | 135d? | 2015-09-07 A | 2016-03-11 A | 100% |  | ct | 3840h | 3840h | SEW1-CT | 35 | Alcatel-Lucent, Jennifer Liu (CT1) | Rel-13 | 69 |  | jennifer.liu@alcatel-lucent.com |  |
| 1216 | 429.2.1 | CT1 aspects of Support of Emergency services over WLAN – phase 1 | 135d? | 2015-09-07 A | 2016-03-11 A | 100% | finish no earlier than 2016-03-11 | C1 | 1080h | 1080h | SEW1-CT | 35 | Alcatel-Lucent, Jennifer Liu (CT1) | Rel-13 | 69 |  | jennifer.liu@alcatel-lucent.com |  |
| 1217 | 429.2.2 | CT3 aspects of Support of Emergency services over WLAN – phase 1 | 70d? | 2015-09-07 A | 2015-12-11 A | 100% | finish no earlier than 2015-12-11 | C3 | 560h | 560h | SEW1-CT | 35 | Alcatel-Lucent, Jennifer Liu (CT1) | Rel-13 | 69 |  | jennifer.liu@alcatel-lucent.com |  |
| 1218 | 429.2.3 | CT4 aspects of Support of Emergency services over WLAN – phase 1 | 70d? | 2015-09-07 A | 2015-12-11 A | 100% | finish no earlier than 2015-12-11 | C4 | 560h | 560h | SEW1-CT | 35 | Alcatel-Lucent, Jennifer Liu (CT1) | Rel-13 | 69 |  | jennifer.liu@alcatel-lucent.com |  |
| 1219 | 429.2.4 | CT6 aspects of Support of Emergency services over WLAN – phase 1 | 70d? | 2015-09-07 A | 2015-12-11 A | 100% | finish no earlier than 2015-12-11 | C6 | 560h | 560h | SEW1-CT | 35 | Alcatel-Lucent, Jennifer Liu (CT1) | Rel-13 | 69 |  | jennifer.liu@alcatel-lucent.com |  |
| 1220 | 430 | **MBMS Enhancements** | 264d? | 2014-12-03 A | 2015-12-07 A | 100% |  | S2 | 4320h | 4320h | MBMS_enh | 34 | Nokia Networks, Curt Wong | Rel-13 | 66 |  |  |  |
| 1221 | 430.1 | MBMS Enhancements TR Phase | 204d? | 2014-12-03 A | 2015-09-14 A | 100% | finish no earlier than 2015-09-14 | S2 | 1632h | 1632h | FS_MBMS_enh_TR | 34 | Nokia Networks, Curt Wong | Rel-13 | 66 |  |  |  |
| 1222 | 430.2 | MBMS Enhancements | 28d? | 2015-08-10 A | 2015-09-16 A | 100% | finish no earlier than 2015-09-16 | S2 | 224h | 224h | MBMS_enh_St2 | 35 | Nokia Networks, Curt Wong | Rel-13 | 69 |  |  |  |
| 1223 | 430.3 | **CT aspects of MBMS Enhancements** | 21d? | 2015-11-09 A | 2015-12-07 A | 100% |  | C3 | 344h | 344h | MBMS_enh-CT | 36 | Nokia Networks, Thomas Belling | Rel-13 | 70 |  |  |  |
| 1224 | 430.3.1 | CT3 aspects of MBMS enhancements | 21d? | 2015-11-09 A | 2015-12-07 A | 100% | start no earlier than 2015-11-09 | C3 | 168h | 168h | MBMS_enh-CT | 36 | Nokia Networks, Thomas Belling | Rel-13 | 70 |  |  |  |
| 1225 | 430.3.2 | CT4 aspects of MBMS enhancements | 21d? | 2015-11-09 A | 2015-12-07 A | 100% | finish no earlier than 2015-12-07 | C4 | 168h | 168h | MBMS_enh-CT | 36 | Nokia Networks, Thomas Belling | Rel-13 | 70 |  |  |  |
| 1226 | 430.4 | Deleted (not approved) - MBMS Enhancements - Stage 2 | 1d? | 2015-03-13 A | 2015-03-13 A | 100% | finish no earlier than 2015-03-13 | S2 | 8h | 8h | MBMS_enh_TS | 34 | Rainer Liebhart | Rel-13 | 66 |  |  | SP-69 |
| 1227 | 431 | **EPC Signalling Improvements for race scenarios** | 135d? | 2015-09-07 A | 2016-03-11 A | 100% |  | C4 | 2760h | 2760h | EPC_SIG_RACE | 35 | Huawei, Peter Schmitt | Rel-13 | 69 |  | Huawei, Peter Schmitt, Peter.Schmitt@HUAWEI.COM |  |
| 1228 | 431.1 | CT3 aspects for EPC Signalling Improvements for race scenarios | 135d? | 2015-09-07 A | 2016-03-11 A | 100% | finish no earlier than 2016-03-11 | C3 | 1080h | 1080h | EPC_SIG_RACE | 35 | Huawei, Peter Schmitt | Rel-13 | 69 |  | Huawei, Peter Schmitt, Peter.Schmitt@HUAWEI.COM |  |
| 1229 | 431.2 | CT4 aspects for EPC Signalling Improvements for race scenarios | 75d? | 2015-09-07 A | 2015-12-18 A | 100% | finish no earlier than 2015-12-18 | C4 | 600h | 600h | EPC_SIG_RACE | 35 | Huawei, Peter Schmitt | Rel-13 | 69 |  | Huawei, Peter Schmitt, Peter.Schmitt@HUAWEI.COM |  |

Notes:
- 1206: 03/07/15: Compl:0%->100% 03/07/15: Stat Rep: ->RP-150536
- 1207: 03/07/15: Compl:0%->100% 03/07/15: Stat Rep: ->RP-150536
- 1209: 03/07/15: Compl:0%->80% 03/07/15: WID: RP-150288->RP-151021 03/07/15: Stat Rep: ->RP-150827 29/09/15: Compl:80%->100% 29/09/15: Stat Rep: RP-150827->RP-151302
- 1211: 07/09/15: 0%->25; 7/12/15: 25%->100 / Impacted TSs and TRs: 24.237, 24.292
- 1212: 07/09/15: 0%->70; 7/12/15: 70%->100 / Impacted TSs and TRs: 29.292
- 1213: 07/09/15: 0%->100 / Impacted TSs and TRs: TS 23.402, TS 23.167, TS 23.271, TS 23.203, TS 23.228
- 1214: 07/09/15: 0%->100 / Impacted TSs and TRs: TS 23.402, TS 23.167, TS 23.271, TS 23.203, TS 23.228
- 1216: 7/12/15: 60%->95. FCD -> 03/16, ES in CP-150729; 7/3/16: 95%->100 / Impacted TSs and TRs: 24.302, 24.229
- 1217: 7/12/15: 0%->100 / Impacted TSs and TRs: 29.212, 29.214
- 1218: 7/12/15: 0%->100 / Impacted TSs and TRs: 23.003, 23.008, 29.273, 29.274
- 1219: 7/3/16: 0%->100 / Impacted TSs and TRs: 31.102
- 1220: . 3/3: WID tdoc number updated; 14/09/15: WID:SP-140883->SP-150516
- 1221: Acronym changed from "MBMS_enh-SA2TR". Mar15: 0->10%; June2015: Compl:10%->50; 07/09/15: 50%->70. acronym changed from "MBMS_enh" to "MBMS_enh_TR"; 07/09/15: 70%->100; 14/09/15: WID:SP-140883->SP-150516 / Impacted TSs and TRs: TR 23.8xy
- 1222: SA#69: no normative work, moved as Study only. 14/10/15: corrected: was mentioned as FS_ / Impacted TSs and TRs: TS 23.246, TS 23.468
- 1224: 8/12/15: 0%->100 / Impacted TSs and TRs: 29.061, 29.468
- 1225: Impacted TSs and TRs: 29.274, 23.008, 29.230
- 1226: Commented during RAN#67 that it should have never beeen here. 07/09/15: "undeleted", acronym changed from "MBMS_enh-del" to "MBMS_enh_TS". 14/10/15: SP-140883 was never approved so this line should have never appeared in the WP. / Impacted TSs and TRs: TS 23.246, TS 23.468
- 1228: 7/12/15: FCD -> 03/16, ES in CP-150861; 8/12/15: 0%->100 / Impacted TSs and TRs: 29.212, 29.213
- 1229: 7/12/15: 95%->100 / Impacted TSs and TRs: 29.274, 29.274, 29.275, 29.282, 29.273, 29.230, 23.008, 29.273

| ID | WBS | Task | Duration | Start | Finish | Complete | Remaining | Total slack | Constraint | Resources | Work | Actual work | Acronym | PCG approved | WI rapporteur name | WI rapporteur e-mail | Release | TSG approved | Status Report |
| --- | --- | --- | --- | --- | --- | --- | --- | --- | --- | --- | --- | --- | --- | --- | --- | --- | --- | --- | --- |
| 1230 | 432 | **Diameter Message Priority** | 164d? | 2015-11-02 A | 2016-06-16 A | 100% |  |  |  | C4 | 3736h | 3736h | DiaPri | 36 | Alcatel-Lucent, Jean-Jacques Trottin | jean-jacques.trottin@alcatel-lucent.com | Rel-13 | 70 |  |
| 1231 | 432.1 | CT3 aspects of DiaPri | 95d? | 2015-11-02 A | 2016-03-11 A | 100% |  |  | finish no earlier than 2016-03-11 | C3 | 760h | 760h | DiaPri | 36 | Intel, Vivek Gupta |  | Rel-13 | 70 |  |
| 1232 | 432.2 | CT4 aspects of DiaPri | 95d? | 2015-11-02 A | 2016-03-11 A | 100% |  |  | finish no earlier than 2016-03-11 | C4 | 760h | 760h | DiaPri | 36 | Alcatel-Lucent, Jean-Jacques Trottin | jean-jacques.trottin@alcatel-lucent.com | Rel-13 | 70 |  |
| 1233 | 432.3 | (IETF) Diameter Routing Message Priority (draft-ietf-dime- | 138d? | 2015-12-08 A | 2016-06-16 A | 100% |  |  | finish no earlier than 2016-06-16 | C4-IETF | 1104h | 1104h | DiaPri | 36 | Alcatel-Lucent, Jean-Jacques Trottin | jean-jacques.trottin@alcatel-lucent.com | Rel-13 | 71 |  |
| 1234 | 433 | **Downlink TPC Enhancements for UMTS** | 197d? | 2015-06-15 A | 2016-03-15 A | 100% |  |  |  | R1 | 4208h | 4208h | UTRA_EDL_TPC | 35 | Huawei |  | Rel-13 | 68 |  |
| 1235 | 433.1 | Core part: Downlink TPC Enhancements for UMTS | 44d? | 2015-10-15 A | 2015-12-15 A | 100% |  |  | finish no earlier than 2015-12-15 | R1; R2; R3 | 1056h | 1056h | UTRA_EDL_TPC-Core | 35 | Huawei |  | Rel-13 | 68 | RP-151564 |
| 1236 | 433.2 | Perf. part: Downlink TPC Enhancements for UMTS | 197d? | 2015-06-15 A | 2016-03-15 A | 100% |  |  | finish no earlier than 2016-03-15 | R4 | 1576h | 1576h | UTRA_EDL_TPC-Perf | 35 | Huawei |  | Rel-13 | 68 | RP-151564 |
| 1237 | 434 | **Licensed-Assisted Access using LTE** | 591d? | 2015-06-15 A | 2017-09-15 | 99% | 0d? | 0d |  | R1 | 12624h | 8599.11h | LTE_LAA | 35 | Ericsson |  | Rel-13 | 68 |  |
| 1238 | 434.1 | Core part: Licensed-Assisted Access using LTE | 132d? | 2015-06-15 A | 2015-12-15 A | 100% |  |  | finish no earlier than 2015-12-15 | R1 | 1056h | 1056h | LTE_LAA-Core | 35 | Ericsson |  | Rel-13 | 68 | RP-151390 |
| 1239 | 434.2 | Perf. part: Licensed-Assisted Access using LTE | 395d? | 2015-06-15 A | 2016-12-15 A | 100% |  |  | finish no earlier than 2016-12-15 | R4 | 3160h | 3160h | LTE_LAA-Perf | 35 | Ericsson |  | Rel-13 | 68 |  |
| 1240 | 434.3 | UE Conformance Test Aspects - Licensed-Assisted Access using LTE | 460d? | 2015-12-15 A | 2017-09-15 A | 100% |  |  | finish no earlier than 2017-09-15 | R5 | 3680h | 3680h | LTE_LAA-UEConTest | 36 | Motorola Mobility |  | Rel-13 | 70 |  |
| 1241 | 435 | **Elevation Beamforming/Full-Dimension (FD) MIMO for LTE** | 786d? | 2015-06-15 A | 2018-06-15 | 72% | 222.41d? | 4561d |  | R1 | 11552h | 6414.4h | LTE_EBF_FDMIMO | 35 | Samsung |  | Rel-13 | 68 |  |
| 1242 | 435.1 | Core part: Elevation Beamforming/Full-Dimension (FD) MIMO for LTE | 132d? | 2015-06-15 A | 2015-12-15 A | 100% |  |  | finish no earlier than 2015-12-15 | R1 | 1056h | 1056h | LTE_EBF_FDMIMO-Core | 35 | Samsung |  | Rel-13 | 68 | RP-151565 |
| 1243 | 435.2 | Perf. part: Elevation Beamforming/Full-Dimension (FD) MIMO for LTE | 330d? | 2015-06-15 A | 2016-09-15 A | 100% |  |  | finish no earlier than 2016-09-15 | R4 | 2640h | 2640h | LTE_EBF_FDMIMO-Perf | 35 | Samsung |  | Rel-13 | 68 | RP-151565 |
| 1244 | 435.3 | UE Conformance Test Aspects - Elevation Beamforming/Full-Dimension MIMO for LTE | 196d? | 2017-09-15 A | 2018-06-15 | 5% | 186.2d? | 4561d | finish no earlier than 2018-06-15 | R5 | 1568h | 78.4h | LTE_EBF_FDMIMO-UEConTest | 39 | Ericsson |  | Rel-13 | 77 |  |
| 1245 | 436 | **L2/L3 Downlink enhancements for UMTS** | 132d? | 2015-06-15 A | 2015-12-15 A | 100% |  |  |  | R2 | 2112h | 2112h | UTRA_EDL_L23 | 35 | Huawei |  | Rel-13 | 68 |  |
| 1246 | 436.1 | Core part: L2/L3 Downlink enhancements for UMTS | 132d? | 2015-06-15 A | 2015-12-15 A | 100% |  |  | finish no earlier than 2015-12-15 | R2 | 1056h | 1056h | UTRA_EDL_L23-Core | 35 | Huawei |  | Rel-13 | 68 | RP-151238 |
| 1247 | 437 | **Support of single-cell point-to-multipoint transmission in LTE** | 330d? | 2015-06-15 A | 2016-09-15 A | 100% |  |  |  | R2 | 5824h | 5824h | LTE_SC_PTM | 35 | Huawei |  | Rel-13 | 68 |  |
| 1248 | 437.1 | Core part: Support of single-cell point-to-multipoint transmission in LTE | 132d? | 2015-06-15 A | 2015-12-15 A | 100% |  |  | finish no earlier than 2015-12-15 | R2 | 1056h | 1056h | LTE_SC_PTM-Core | 35 | Huawei |  | Rel-13 | 68 | RP-151237 |
| 1249 | 437.2 | Perf. part: Support of single-cell point-to-multipoint transmission in LTE | 132d? | 2015-06-15 A | 2015-12-15 A | 100% |  |  | finish no earlier than 2016-06-15 | R4 | 1056h | 1056h | LTE_SC_PTM-Perf | 35 | Huawei |  | Rel-13 | 68 | RP-151237 |
| 1250 | 437.3 | UE Conformance Test Aspects - Support of single-cell point-to-multipoint transmission in LTE | 134d? | 2016-03-15 A | 2016-09-15 A | 100% |  |  | finish no earlier than 2016-12-15 | R5 | 1072h | 1072h | LTE_SC_PTM-UEConTest | 36 | Huawei |  | Rel-13 | 71 |  |
| 1251 | 438 | **Extension of Dual Connectivity in E-UTRAN** | 132d? | 2015-06-15 A | 2015-12-15 A | 100% |  |  |  | R3 | 2112h | 2112h | LTE_dualC_ext | 35 | Samsung |  | Rel-13 | 68 |  |
| 1252 | 438.1 | Core part: Extension of Dual Connectivity in E-UTRAN | 132d? | 2015-06-15 A | 2015-12-15 A | 100% |  |  | finish no earlier than 2015-12-15 | R3 | 1056h | 1056h | LTE_dualC_ext-Core | 35 | Samsung |  | Rel-13 | 68 | RP-151214 |
| 1253 | 439 | **RAN sharing enhancements for UMTS** | 132d? | 2015-06-15 A | 2015-12-15 A | 100% |  |  |  | R3 | 2112h | 2112h | RSE_UTRA_GUSH | 35 | Huawei |  | Rel-13 | 68 |  |
| 1254 | 439.1 | Core part: RAN sharing enhancements for UMTS | 132d? | 2015-06-15 A | 2015-12-15 A | 100% |  |  | finish no earlier than 2015-12-15 | R3 | 1056h | 1056h | RSE_UTRA_GUSH-Core | 35 | Huawei |  | Rel-13 | 68 | RP-151239 |

Notes:
- 1231: ES in CP-150645; 7/3/16: 65%->100 / Impacted TSs and TRs: 29.153, 29.154, 29.201, 29.212, 29.213, 29.214, 29.215, 29.217, 29.219
- 1232: ES in CP-150622; 7/3/16: 70%->100 / Impacted TSs and TRs: 29.228, 29.229, 29.272, 29.273, 29.328, 29.329, 29.336, 29.337, 29.338, 29.344, 29.345
- 1233: 02/2016: publication requested; 2/12/16: 85%->100 / Impacted TSs and TRs: 29.227, 29.272, 29.273, 29.229
- 1234: follow-up WI of REL-13 SI FS_UTRA_EDL; TPC = Transmit Power Control
- 1235: follow-up WI of REL-13 SI FS_UTRA_EDL; TPC = Transmit Power Control 29/09/15: Compl:0%->35% 29/09/15: Stat Rep: -->RP-1515641/1/16: Compl:35%->100%1/1/16: WID:
- 1236: follow-up WI of REL-13 SI FS_UTRA_EDL; TPC = Transmit Power Control 29/09/15: Stat Rep: -->RP-151564; 1/1/16: Compl:0%->80%; 1/1/16: WID: RP-151044->RP-151880
- 1237: follow-up WI of REL-13 SI FS_LTE_LAA
- 1238: follow-up WI of REL-13 SI FS_LTE_LAA 29/09/15: Compl:0%->25% 29/09/15: Stat Rep: -->RP-1513901/1/16: Compl:25%->100%
- 1239: follow-up WI of REL-13 SI FS_LTE_LAA 29/09/15: Stat Rep: -->RP-15139022/3/16: Compl:0%->33%; 1/7/16: Compl:3; 26/9/16: Compl:50%->90%; 20/12/16: Compl:90%->100%; 20/12/16: Stat Rep: RP-151390->
- 1240: ; 22/3/16: Compl:0%->5%1/7/16: Compl:5%->8%26/9/16: Compl:8%->15%; 20/21/3/17: Com...; ;...; ;...
- 1241: follow-up WI of REL-13 SI FS_LTE_EBF_FDMIMO
- 1242: follow-up WI of REL-13 SI FS_LTE_EBF_FDMIMO 29/09/15: Compl:0%->25% 29/09/15: Stat Rep: -->RP-151565 1/1/16: Compl:25%->100%
- 1243: follow-up WI of REL-13 SI FS_LTE_EBF_FDMIMO 29/09/15: Stat Rep: -->RP-151565 ; 1/1/16: Compl:0%->5%; 22/3/16: Compl:5%->35%;26/9/16: Compl:70%->100%
- 1244: ; 8/1/18: Compl:0%->5%; ...
- 1245: no Perf. part; follow-up of Rel-13 SI FS_UTRA_EDL
- 1246: no Perf. part; follow-up of Rel-13 SI FS_UTRA_EDL 29/09/15: Compl:0%->35% 29/09/15: WID: RP-151043->RP-151249 29/09/15: Stat Rep: -->RP-1512381/1/16: Compl:35%->100% ;
- 1247: follow-up WI of REL-13 SI FS_LTE_SC_PTM
- 1248: follow-up WI of REL-13 SI FS_LTE_SC_PTM 29/09/15: Compl:0%->30% 29/09/15: Stat Rep: -->RP-151237 1/1/16: Compl:30%->100%
- 1249: follow-up WI of REL-13 SI FS_LTE_SC_PTM 29/09/15: Stat Rep: -->RP-1512371/1/16: Compl:0%->100%
- 1250: testing REL-13 LTE_SC_PTM-Core1/7/16: Compl:0%->40%26/9/16
- 1251: no Perf. part; follow-up WI of REL-13 SI FS_LTE_dualC_ext;
- 1252: no Perf. part; follow-up WI of REL-13 SI FS_LTE_dualC_ext; 29/09/15: Compl:0%->30% 29/09/15: Stat Rep: -->RP-151214; 1/1/16: Compl:3
- 1253: no Perf. part; follow-up WI for Rel-13 SI FS_RSE_UTRA_GUSH; note: GUSH was a REL-13 SA1 WI; there is an ongoing REL-13 WI for LTE: RSE-RAN_LTE;
- 1254: no Perf. part; follow-up WI for Rel-13 SI FS_RSE_UTRA_GUSH; note: GUSH was a REL-13 SA1 WI; there is an ongoing REL-13 WI for LTE: RSE-RAN_LTE; 29/09/15: Compl:0%->30% 29/09/15: WID: RP-151086->RP-151251 29/09/15: Stat Rep: -->RP-151239 ;

| ID | WBS | Task | Duration | Start | Finish | Complete | Remaining | Total slack | Constraint | Resources | Work | Actual work | Acronym | PCG approved | WI rapporteur name | Release | TSG approved | Status Report | Impacted TSs and TRs | WI rapporteur e-mail |
| --- | --- | --- | --- | --- | --- | --- | --- | --- | --- | --- | --- | --- | --- | --- | --- | --- | --- | --- | --- | --- |
| 1255 | 440 | **Interference mitigation for downlink control channels of LTE** | 720d? | 2015-06-15 A | 2018-03-15 | 83% | 122.15d? | 4627d |  | R4 | 9960h | 5591.36h | LTE_IM_DLCCH | 35 | Intel | Rel-13 | 68 |  |  |  |
| 1256 | 440.1 | Perf. part: Interference mitigation for downlink control channels of LTE | 263d? | 2015-06-15 A | 2016-06-15 A | 100% |  |  | finish no earlier than 2016-06-15 | R4 | 2104h | 2104h | LTE_IM_DLCCH-Perf | 35 | Intel | Rel-13 | 68 | RP-151301 |  |  |
| 1257 | 440.2 | UE Conformance Test Aspects - Interference Mitigation for Downlink Control Channels of LTE | 262d? | 2017-03-15 A | 2018-03-15 | 66% | 89.08d? | 4627d | finish no earlier than 2018-03-15 | R5 | 2096h | 1383.36h | LTE_IM_DLCCH-UEConTest | 38 | Intel | Rel-13 | 75 |  |  |  |
| 1258 | 441 | **Network-Assisted Interference Cancellation and Suppression for UMTS** | 66d? | 2015-09-15 A | 2015-12-15 A | 100% |  |  |  | R1 | 1056h | 1056h | UTRA_NAICS | 35 | Huawei | Rel-13 | 69 |  |  |  |
| 1259 | 441.1 | Core part: Network-Assisted Interference Cancellation and Suppression for UMTS | 66d? | 2015-09-15 A | 2015-12-15 A | 100% |  |  | finish no earlier than 2015-12-15 | R1 | 528h | 528h | UTRA_NAICS-Core | 35 | Huawei | Rel-13 | 69 |  |  |  |
| 1260 | 442 | **Dual Carrier HSUPA Enhancements for UTRAN CS** | 66d? | 2015-09-15 A | 2015-12-15 A | 100% |  |  |  | R2 | 1056h | 1056h | DC_HSUPA_CS | 35 | Nokia Networks | Rel-13 | 69 |  |  |  |
| 1261 | 442.1 | Core part: Dual Carrier HSUPA Enhancements for UTRAN CS | 66d? | 2015-09-15 A | 2015-12-15 A | 100% |  |  | finish no earlier than 2015-12-15 | R2 | 528h | 528h | DC_HSUPA_CS-Core | 35 | Nokia Networks | Rel-13 | 69 |  |  |  |
| 1262 | 443 | **Further Enhancements of Minimization of Drive Tests for E-UTRAN** | 524d? | 2015-03-16 A | 2017-03-15 A | 100% |  |  |  | R2 | 6304h | 6304h | LTE_eMDT2 | 35 | CMCC | Rel-13 | 69 |  |  |  |
| 1263 | 443.1 | Study on further Enhancements of Minimization of Drive Tests for E-UTRAN | 132d? | 2015-03-16 A | 2015-09-15 A | 100% |  |  | finish no earlier than 2015-09-15 | R2 | 1056h | 1056h | FS_LTE_eMDT2 | 34 | CMCC | Rel-13 | 67 | RP-151181 | 36.880 |  |
| 1264 | 443.2 | Core part: Further Enhancements of Minimization of Drive Tests for E-UTRAN | 66d? | 2015-09-15 A | 2015-12-15 A | 100% |  |  | finish no earlier than 2015-12-15 | R2 | 528h | 528h | LTE_eMDT2-Core | 35 | CMCC | Rel-13 | 69 |  |  |  |
| 1265 | 443.3 | UE Conformance Test Aspects – Further Enhancements of Minimization of Drive Tests for E-UTRAN | 197d? | 2016-06-15 A | 2017-03-15 A | 100% |  |  | finish no earlier than 2017-03-15 | R5 | 1576h | 1576h | LTE_eMDT2-UEConTest | 37 | Intel | Rel-13 | 72 |  |  |  |
| 1266 | 444 | **LTE-WLAN RAN Level Integration supporting legacy WLAN** | 131d? | 2015-09-15 A | 2016-03-15 A | 100% |  |  |  | R2 | 2096h | 2096h | LTE_WLAN_radio_legacy | 35 | Alcatel-Lucent | Rel-13 | 69 |  |  |  |
| 1267 | 444.1 | Core part: LTE-WLAN RAN Level Integration supporting legacy WLAN | 131d? | 2015-09-15 A | 2016-03-15 A | 100% |  |  | finish no earlier than 2016-03-15 | R2 | 1048h | 1048h | LTE_WLAN_radio_legacy-Core | 35 | Alcatel-Lucent | Rel-13 | 69 |  | 36.361 |  |
| 1268 | 445 | **Indoor Positioning enhancements for UTRA and LTE** | 393d? | 2015-09-15 A | 2017-03-15 A | 100% |  |  |  | R2 | 7152h | 7152h | UTRA_LTE_iPos_enh | 35 | NextNav | Rel-13 | 69 |  |  |  |
| 1269 | 445.1 | Core part: Indoor Positioning enhancements for UTRA and LTE | 66d? | 2015-09-15 A | 2015-12-15 A | 100% |  |  | finish no earlier than 2015-12-15 | R2 | 528h | 528h | UTRA_LTE_iPos_enh-Core | 35 | NextNav | Rel-13 | 69 |  |  |  |
| 1270 | 445.2 | Perf. part: Indoor Positioning enhancements for UTRA and LTE | 197d? | 2015-09-15 A | 2016-06-15 A | 100% |  |  | finish no earlier than 2016-06-15 | R4 | 1576h | 1576h | UTRA_LTE_iPos_enh-Perf | 35 | NextNav | Rel-13 | 69 |  | 37.171; 37.958 |  |
| 1271 | 445.3 | **CT aspects of Indoor Positionning** | 41d? | 2015-10-12 A | 2015-12-07 A | 100% |  |  |  | C4 | 328h | 328h | UTRA_LTE_iPos_enh-CT | 36 | Ericsson, Jesús de Gregorio | Rel-13 | 70 |  | 29.171, 29.172, 29.230, 29.002 | jesus.de.gregorio@ericsson.com |
| 1272 | 445.3.1 | CT4 aspects of Indoor Positionning | 41d? | 2015-10-12 A | 2015-12-07 A | 100% |  |  | finish no earlier than 2015-12-07 | C4 | 328h | 328h | UTRA_LTE_iPos_enh-CT | 36 | Ericsson, Jesús de Gregorio | Rel-13 | 70 |  | 29.171, 29.172, 29.230, 29.002 | jesus.de.gregorio@ericsson.com |
| 1273 | 445.4 | UE Conformance Test Aspects – Indoor Positioning Enhancement Support for LTE and UMTS | 197d? | 2016-06-15 A | 2017-03-15 A | 100% |  |  | finish no earlier than 2017-06-15 | R5 | 1576h | 1576h | UTRA_LTE_iPos_enh-UEConTest | 37 | NextNav | Rel-13 | 72 |  |  |  |
| 1274 | 446 | **Power saving enhancements for UMTS** | 197d? | 2015-06-15 A | 2016-03-15 A | 100% |  |  |  | R2 | 3160h | 3160h | UTRA_SDATA_POWSAV | 35 | Ericsson | Rel-13 | 68 |  |  |  |
| 1275 | 446.1 | Core part: Power saving enhancements for UMTS | 132d? | 2015-06-15 A | 2015-12-15 A | 100% |  |  | finish no earlier than 2015-12-15 | R2 | 1056h | 1056h | UTRA_SDATA_POWSAV-Core | 35 | Ericsson | Rel-13 | 68 | RP-151291 |  |  |
| 1276 | 446.2 | Perf. Part: Power saving enhancements for UMTS | 66d? | 2015-12-15 A | 2016-03-15 A | 100% |  |  | finish no earlier than 2016-03-15 | R4 | 528h | 528h | UTRA_SDATA_POWSAV-Perf | 36 | Ericsson | Rel-13 | 70 |  |  |  |
| 1277 | 447 | **700MHz E-UTRA FDD Band for Arab Region** | 197d? | 2015-06-15 A | 2016-03-15 A | 100% |  |  |  | R4 | 4728h | 4728h | LTE_FDD_700_ARAB | 35 | Etisalat | Rel-13 | 68 |  |  |  |
| 1278 | 447.1 | Core part: 700MHz E-UTRA FDD Band for Arab Region | 197d? | 2015-06-15 A | 2016-03-15 A | 100% |  |  | finish no earlier than 2016-03-15 | R4 | 1576h | 1576h | LTE_FDD_700_ARAB-Core | 35 | Etisalat | Rel-13 | 68 | RP-151207 | 36.893 |  |
| 1279 | 447.2 | Perf. part: 700MHz E-UTRA FDD Band for Arab Region | 197d? | 2015-06-15 A | 2016-03-15 A | 100% |  |  | finish no earlier than 2016-03-15 | R4 | 1576h | 1576h | LTE_FDD_700_ARAB-Perf | 35 | Etisalat | Rel-13 | 68 | RP-151207 |  |  |

Notes:
- 1255: only Perf. part, no Core part;
- 1256: only Perf. part, no Core part; 29/09/15: CD:Tue 15/03/16->Wed 15/06/16 29/09/15: Stat Rep: -->RP-1513011/1/16: Compl:0%->40%22/3/16: Compl:40%->70%
- 1257: tested: REL-13 LTE_IM_DLCCH-Perf (note: WI had no Core part);19/6/17...1...; 8/1/18: C...
- 1258: no Perf. part; follow-up WI REL-13 RAN1 SI FS_UTRA_NAICS
- 1259: no Perf. part; follow-up WI REL-13 RAN1 SI FS_UTRA_NAICS ; 1/1/16: Compl:0%->100% ; 1/1/16: WID: RP-151577->RP-151879
- 1260: no Perf. part; compare REL-13 WI HSUPA_DB_MC
- 1261: no Perf. part; compare REL-13 WI HSUPA_DB_MC 1/1/16: Compl:0%->100% 1/1/16: WID: RP-151607->RP-151780
- 1262: no Perf. part; follow-up WI of REL-13 SI FS_LTE_eMDT2
- 1263: 03/07/15: Compl:0%->70% 03/07/15: Stat Rep: -->RP-150806 29/09/15: Compl:70%->100% 29/09/15: Stat Rep: RP-150806->RP-151181
- 1264: no Perf. part; follow-up WI of REL-13 SI FS_LTE_eMDT2; 1/1/16: Compl:0%->100%
- 1265: tested REL-13 WI: LTE_eMDT2-Core26/9/16: Com;21/3/17: Compl:5%->100%
- 1266: no Perf. part; compare REL-13 WI LTE_WLAN_radio
- 1267: no Perf. part; compare REL-13 WI LTE_WLAN_radio1/1/16: Compl:0%->95% 22/3/16: Compl:95%->100%; 28/7/16: 36.361 added;
- 1268: follow-up WI of REL-13 SI FS_UTRA_LTE_iPos_enh
- 1269: follow-up WI of REL-13 SI FS_UTRA_LTE_iPos_enh1/1/16: Compl:0%->100%1/1/16: WID: RP-151624->RP-15225122/3/16: WID: RP-152251->RP-160332
- 1270: follow-up WI of REL-13 SI FS_UTRA_LTE_iPos_enh 1/1/16: Compl:0%->10% 1/1/16: WID: RP-151624->RP-152251; 22/3/16: Compl:10%->20%; 22/3/16: WID: RP-152251->RP-160332 28/7/16: 37.171 added; 28/7/16: 37.958 added;
- 1272: 8/12/15: 0%->100
- 1273: tested REL-13 WI: UTRA_LTE_iPos_enh-Core; 26/9/1; 20/12/16:21/3/17: Compl:...
- 1274: no Perf. part; follow-up WI of SI FS_UTRA_SDATA
- 1275: no Perf. part; follow-up WI of SI FS_UTRA_SDATA 29/09/15: Compl:0%->25% 29/09/15: CD:Tue 15/03/16->Tue 15/12/15 29/09/15: WID: RP-151092->RP-151292 29/09/15: Stat Rep: -->RP-151291 29/09/15: Release: Rel-14->Rel-13
- 1276: ; 22/3/16: Compl:0%->100%
- 1277: REL-independent from REL-9
- 1278: REL-independent from REL-9. Aug 15: TR numb added 29/09/15: Compl:0%->15% 29/09/15: CD:Tue 15/03/16->Tue 15/12/15 29/09/15: Stat Rep: -->RP-151207 29/09/15: Release: Rel-14->Rel-13;
- 1279: REL-independent from REL-9 29/09/15: CD:Tue 15/03/16->Tue 15/12/15 29/09/15: Stat Rep: -->RP-151207 29/09/15: Release: Rel-14->Rel-13

| ID | WBS | Task | Duration | Start | Finish | Complete | Remaining | Baseline start | Baseline finish | Baseline duration | Total slack | Constraint | Resources | Work | Actual work | Acronym | PCG approved | WI rapporteur name | Release | TSG approved | Status Report | WI rapporteur e-mail | MCC resp | Special Focus Doc | Acronym_3GU_Export |
| --- | --- | --- | --- | --- | --- | --- | --- | --- | --- | --- | --- | --- | --- | --- | --- | --- | --- | --- | --- | --- | --- | --- | --- | --- | --- |
| 1280 | 448 | **European 700 Supplemental Downlink band (738-758 MHz) in E-UTRA and LTE Carrier Aggregation (2DL/1UL) with Band 20** | 132d? | 2015-06-15 A | 2015-12-15 A | 100% |  |  |  |  |  |  | R4 | 3168h | 3168h | LTE_CA_700EU_B20 | 35 | TeliaSonera | Rel-13 | 68 |  |  |  |  |  |
| 1281 | 448.1 | Core part: European 700 Supplemental Downlink band (738-758 MHz) in E-UTRA and LTE Carrier Aggregation (2DL/1UL) with Band 20 | 132d? | 2015-06-15 A | 2015-12-15 A | 100% |  |  |  |  |  | finish no earlier than 2015-12-15 | R4 | 1056h | 1056h | LTE_CA_700EU_B20-Core | 35 | TeliaSonera | Rel-13 | 68 | RP-151232 |  |  |  |  |
| 1282 | 448.2 | Perf. part: European 700 Supplemental Downlink band (738-758 MHz) in E-UTRA and LTE Carrier Aggregation (2DL/1UL) with Band 20 | 132d? | 2015-06-15 A | 2015-12-15 A | 100% |  |  |  |  |  | finish no earlier than 2016-03-15 | R4 | 1056h | 1056h | LTE_CA_700EU_B20-Perf | 35 | TeliaSonera | Rel-13 | 68 | RP-151232 |  |  |  |  |
| 1283 | 449 | Release 13 Features on Internet of Things (IoT) | 438.25d? | 2013-09-12 A | 2015-05-12 A | 100% |  | 2015-04-14 | 2015-12-25 | 183.25d? |  |  | SP; RP; CP; GP | 14024h | 14024h |  |  |  | Rel-13 |  |  |  |  |  |  |
| 1284 | 450 | Service Requirements Maintenance for Machine-Type Communications (MTC) | 194d? | 2015-09-15 A | 2016-06-10 A | 100% |  | 2013-12-12 | 2014-12-10 | 261d? |  |  | S1 | 1552h | 1552h | SRMMTC | 32 | KPN | Rel-13 | 62 |  | toon.norp@tno.nl | Alain | MTC, M2M | SRMMTC |
| 1285 | 451 | **Cellular (Narrowband) Internet of Things** | 590d? | 2015-09-15 A | 2017-12-15 A | 100% |  |  |  |  |  |  |  | 16648h | 16648h | CIoT | 36 |  | Rel-13 | 70 |  |  |  |  |  |
| 1286 | 451.1 | Stage 2 of CIoT | 1d? | 2015-10-05 A | 2015-10-05 A | 100% |  |  |  |  |  | start no earlier than 2015-10-05 | S2 | 8h | 8h | CIoT | 36 | Intel, Puneet Jain | Rel-13 | 70 |  | puneet.jain@intel.com |  |  |  |
| 1287 | 451.2 | Security Aspects of CIoT (aka NB-IoT) | 160d? | 2015-11-02 A | 2016-06-10 A | 100% |  |  |  |  |  | finish no earlier than 2016-06-10 | S3 | 1280h | 1280h | CIoT | 36 | Tim Evans, Vodafone | Rel-13 | 70 |  |  |  |  |  |
| 1288 | 451.3 | **CT aspects of CIoT** | 138d? | 2015-12-07 A | 2016-06-15 A | 100% |  |  |  |  |  |  | C1 | 4976h | 4976h | CIoT-CT | 36 | Intel, Vivek Gupta | Rel-13 | 70 |  | vivek.g.gupta@intel.com |  |  |  |
| 1289 | 451.3.1 | CT1 aspects of CIoT | 70d? | 2015-12-07 A | 2016-03-11 A | 100% |  |  |  |  |  | finish no earlier than 2016-03-11 | C1 | 560h | 560h | CIoT-CT | 36 | Intel, Vivek Gupta | Rel-13 | 70 |  | vivek.g.gupta@intel.com |  |  |  |
| 1290 | 451.3.2 | CT3 aspects of CIoT | 138d? | 2015-12-07 A | 2016-06-15 A | 100% |  |  |  |  |  | finish no earlier than 2016-06-15 | C3 | 1104h | 1104h | CIoT-CT | 36 | Intel, Vivek Gupta | Rel-13 | 70 |  | vivek.g.gupta@intel.com |  |  |  |
| 1291 | 451.3.3 | CT4 aspects of CIoT | 138d? | 2015-12-07 A | 2016-06-15 A | 100% |  |  |  |  |  | finish no earlier than 2016-06-15 | C4 | 1104h | 1104h | CIoT-CT | 36 | Intel, Vivek Gupta | Rel-13 | 70 |  | vivek.g.gupta@intel.com |  |  |  |
| 1292 | 451.3.4 | CT6 aspects of CIoT | 138d? | 2015-12-07 A | 2016-06-15 A | 100% |  |  |  |  |  | finish no earlier than 2016-06-15 | C6 | 1104h | 1104h | CIoT-CT | 36 | Intel, Vivek Gupta | Rel-13 | 70 |  | vivek.g.gupta@intel.com |  |  |  |
| 1293 | 451.4 | Charging Aspects of CIoT | 23d? | 2016-05-12 A | 2016-06-13 A | 100% |  |  |  |  |  | finish no earlier than 2016-06-13 | S5 | 184h | 184h | CIoT-CH | 37 | Gardella, Maryse (Nokia) | Rel-13 | 72 |  | Gardella, Maryse (Nokia) |  |  |  |
| 1294 | 451.5 | **RAN aspects of CIoT aka Narrowband Internet of Things (IOT)** | 329d? | 2015-09-15 A | 2016-12-15 A | 100% |  |  |  |  |  |  | R1 | 6320h | 6320h | NB_IOT | 35 | Vodafone | Rel-13 | 69 |  |  |  |  |  |
| 1295 | 451.5.1 | Core part: Narrowband Internet of Things (IOT) | 197d? | 2015-09-15 A | 2016-06-15 A | 100% |  |  |  |  |  | finish no earlier than 2016-06-15 | R1 | 1576h | 1576h | NB_IOT-Core | 35 | Vodafone | Rel-13 | 69 |  |  |  |  |  |
| 1296 | 451.5.2 | Perf. part: Narrowband Internet of Things (IOT) | 264d? | 2015-12-15 A | 2016-12-15 A | 100% |  |  |  |  |  | finish no earlier than 2016-12-15 | R4 | 2112h | 2112h | NB_IOT-Perf | 36 | Vodafone | Rel-13 | 70 |  |  |  |  |  |
| 1297 | 451.6 | Management for NB-IoT | 25d? | 2016-05-12 A | 2016-06-15 A | 100% |  |  |  |  |  | finish no earlier than 2016-06-15 | S5 | 200h | 200h | NB_IOT-OAM | 37 | Huawei, Kai ZHANG | Rel-13 | 72 |  | kai.zhangkai@huawei.com |  |  |  |
| 1298 | 451.7 | UE Conformance Test Aspects - Narrowband Internet of Things (NB-IOT) | 460d? | 2016-03-15 A | 2017-12-15 A | 100% |  |  |  |  |  | finish no earlier than 2017-12-15 | R5 | 3680h | 3680h | NB_IOT-UEConTest | 36 | CMCC | Rel-13 | 71 |  |  |  |  |  |
| 1299 | 452 | **Extended Coverage GSM (EC-GSM) for support of Cellular Internet of Things** | 255.5d? | 2015-09-25 A | 2016-09-15 | 69% | 77.98d? |  |  |  | 5017d |  | G1; G2 | 8864h | 4044.7h | CIoT_EC_GSM | 35 | Marteen Sunberg, Ericsson | Rel-13 | 69 |  | Marteen.Sunberg@Ericsson.com |  |  |  |
| 1300 | 452.1 | Extended Coverage GSM (EC-GSM) for support of Cellular Internet of Things Core part | 164.5d? | 2015-09-25 A | 2016-05-12 A | 100% |  |  |  |  |  | finish no earlier than 2016-05-12 | G1; G2 | 2632h | 2632h | CIoT_EC_GSM-Core | 36 | Marteen Sunberg, Ericsson | Rel-13 | 70 |  | Marteen.Sunberg@Ericsson.com |  |  |  |
| 1301 | 452.2 | Test for CIoT_EC_GSM | 132d? | 2015-11-11 | 2016-05-12 |  |  |  |  |  | 5108d | start no earlier than 2015-11-11 | G3 | 1056h |  | CIoT_EC_GSM_GERAN3new | 36 | Sierra Wireless S.A | Rel-13 | 70 |  | Marteen.Sunberg@Ericsson.com |  |  |  |
| 1302 | 452.3 | Perf. Part: Extended Coverage GSM (EC-GSM) for support of Cellular Internet of Things | 68d? | 2016-06-15 A | 2016-09-15 A | 100% |  |  |  |  |  | finish no earlier than 2016-09-15 | R6 | 544h | 544h | CIoT_EC_GSM-Perf | 37 | Ericsson | Rel-13 | 72 |  |  |  |  |  |
| 1303 | 452.4 | MS Conformance Test Aspects - Extended Coverage GSM (EC-GSM) for support of Cellular Internet of Things | 68d? | 2016-06-15 A | 2016-09-15 A | 100% |  |  |  |  |  | finish no earlier than 2016-09-15 | R5 | 544h | 544h | CIoT_EC_GSM-MSConTest | 37 | Ericsson | Rel-13 | 72 |  |  |  |  |  |

Notes:
- 1280: introduction of new DL only band and 2DL/1UL CA with it
- 1281: introduction of new DL only band and 2DL/1UL CA with it. Aug 15: TR numb added 29/09/15: Compl:0%->80% 29/09/15: CD:Tue 15/03/16->Tue 15/12/15 29/09/15: WID: RP-150861->RP-151228 29/09/15: Stat Rep: -->RP-151232 29/09/15: Release: Rel-14->Rel-13 / Impacted TSs and TRs: 36.895
- 1282: introduction of new DL only band and 2DL/1UL CA with it 29/09/15: WID: RP-150861->RP-151228 29/09/15: Stat Rep: -->RP-151232 29/09/15: Release: Rel-14->Rel-13
- 1283: -
- 1284: SP#65 completed. Linked to Rel-13 SEES, Rel-12 Support for Interworking with M2M Service Enablement (MTCe-SIMSE), Service Requirement Maintenance (MTCe-SRM). Decide which MTC reqs with no Stage 2 should be removed/maintained in Rel-13. / Impacted TSs and TRs: 22.368
- 1286: 7/3/16: 0%->95 / Impacted TSs and TRs: 23.401, 23.682, 23.251
- 1287: 7/3/16: 0%->39; 19/9/16: 39%->100 / Impacted TSs and TRs: 33.401
- 1288: 11/6/16: WID:CP-150795->CP-160292
- 1289: 7/3/16: 0%->35; 11/6/16: 35%->100; 11/6/16: WID:CP-150795->CP-160292 / Impacted TSs and TRs: 24.301, 24.008, 23.122
- 1290: 7/3/16: 0%->90; 11/6/16: WID:CP-150795->CP-160292; 13/6/16: 90%->100 / Impacted TSs and TRs: 29.061, 29.212
- 1291: 7/3/16: 0%->65; 11/6/16: WID:CP-150795->CP-160292; 13/6/16: 65%->100 / Impacted TSs and TRs: 29.272, 29.274, 23.008, 23.007, 29.128, 29.275, 29.230, 29.336, 29.281, 29.002, 29.303
- 1292: 11/6/16: WID:CP-150795->CP-160292; 13/6/16: 0%->100 / Impacted TSs and TRs: 31.102
- 1293: 32.25x; 13/6/16: 0%->100 / Impacted TSs and TRs: 32.25x, 32.240, 32.251, 32.274, 32.299, 32.298, 32.297
- 1294: no Perf. part; note: WI only stays in REL-13 because of PCG decision
- 1295: no Perf. part; note: WI only stays in REL-13 because of PCG decision1/1/16: Compl:0%->25% 22/3/16: Compl:25%->75%;1/7/16: Com / Impacted TSs and TRs: 36.802
- 1296: 22/3/16: WID: RP-152284->RP-160656; 1/7/16: WID: RP-160656->RP-16093326/9/16: Compl:0%->60%26/9/16: CD:Thu 15/09/16->Thu 15/12/16; 20/12/16: Compl:60%->100%; 20/12/16: WID: RP-160933->RP-162134
- 1297: 13/6/16: 0%->100 / Impacted TSs and TRs: 28.657, 28.658, 28.659, 32.425
- 1298: testing REL-13 NB_IOT-Core1/7/16: Compl:0%->5%; 26/9; 20/12/1; 21/3/17: Compl:...; ;...; ;...; ;...
- 1299: 7/12/15: 0%->60
- 1300: 7/12/15:created by MCC to distinguish core versus test parts. 2/3/16: FCD: 11/15->05/16, 40->90%; 13/6/16: 90%->100
- 1301: 7/12/15: created GERAN. 2/3/16: G1,G2->G3, Acronym: CIoT_EC_GSM-Test->CIoT_EC_GSM_GERAN3new
- 1302: related to GERAN REL-13 WI CIoT_EC_GSM-Core26/9/16: Compl:0%->100%
- 1303: tested REL-13 WI: CIoT_EC_GSM-Core26/9/16: Compl

| ID | WBS | Task | Duration | Start | Finish | Complete | Remaining | Baseline start | Baseline finish | Baseline duration | Total slack | Constraint | Resources | Work | Actual work | Acronym | PCG approved | WI rapporteur name | WI rapporteur e-mail | Release | TSG approved | Status Report | Acronym_3GU_Export |
| --- | --- | --- | --- | --- | --- | --- | --- | --- | --- | --- | --- | --- | --- | --- | --- | --- | --- | --- | --- | --- | --- | --- | --- |
| 1304 | 453 | **Extended DRX cycle for Power Consumption** | 468d? | 2014-12-03 A | 2016-09-15 | 93% | 31.26d? |  |  |  | 5017d |  | S2; R2; G2 | 27696h | 16791.6h | eDRX | 35 | Miguel Griot | mgriot@qti.qualcomm.com | Rel-13 | 68 |  |  |
| 1305 | 453.1 | Study on Extended DRX cycle for Power Consumption Optimization | 268d? | 2014-12-03 A | 2015-12-11 A | 100% |  |  |  |  |  | finish no earlier than 2015-12-11 | S2 | 2144h | 2144h | FS_eDRX | 34 | Miguel Griot, Qualcomm | mgriot@qti.qualcomm.com | Rel-13 | 66 |  |  |
| 1306 | 453.2 | Stage 2 for Extended DRX cycle for Power Consumption | 133d? | 2015-06-15 A | 2015-12-16 A | 100% |  |  |  |  |  | finish no earlier than 2015-12-16 | S2 | 1064h | 1064h | eDRX | 35 | Miguel Griot | mgriot@qti.qualcomm.com | Rel-13 | 68 |  |  |
| 1307 | 453.3 | **CT aspects of extended DRX cycle** | 135d? | 2015-09-07 A | 2016-03-11 A | 100% |  |  |  |  |  |  | ct | 4912h | 4912h | eDRX-CT | 35 | Catovic, Amer, Qualcomm | Catovic, Amer, Qualcomm | Rel-13 | 69 |  |  |
| 1308 | 453.3.1 | CT1 aspects of extended DRX cycle | 135d? | 2015-09-07 A | 2016-03-11 A | 100% |  |  |  |  |  | finish no earlier than 2016-03-11 | C1 | 1080h | 1080h | eDRX-CT | 35 | Catovic, Amer, Qualcomm | Catovic, Amer, Qualcomm | Rel-13 | 69 |  |  |
| 1309 | 453.3.2 | CT3 aspects of extended DRX cycle | 135d? | 2015-09-07 A | 2016-03-11 A | 100% |  |  |  |  |  | finish no earlier than 2016-03-11 | C3 | 1080h | 1080h | eDRX-CT | 35 | Catovic, Amer, Qualcomm | Catovic, Amer, Qualcomm | Rel-13 | 69 |  |  |
| 1310 | 453.3.3 | CT4 aspects of extended DRX cycle | 74d? | 2015-09-07 A | 2015-12-17 A | 100% |  |  |  |  |  | finish no earlier than 2015-12-17 | C4 | 592h | 592h | eDRX-CT | 35 | Catovic, Amer, Qualcomm | Catovic, Amer, Qualcomm | Rel-13 | 69 |  |  |
| 1311 | 453.3.4 | CT6 aspects of extended DRX cycle | 135d? | 2015-09-07 A | 2016-03-11 A | 100% |  |  |  |  |  | finish no earlier than 2016-03-11 | C6 | 1080h | 1080h | eDRX-CT | 36 | Catovic, Amer, Qualcomm | Catovic, Amer, Qualcomm | Rel-13 | 70 |  |  |
| 1312 | 453.4 | **RAN enhancements for extended DRX in LTE** | 262d? | 2015-03-16 A | 2016-03-15 A | 100% |  |  |  |  |  |  | R2 | 4192h | 4192h | LTE_extDRX | 34 | Qualcomm |  | Rel-13 | 67 |  |  |
| 1313 | 453.4.1 | Core part: RAN enhancements for extended DRX in LTE | 262d? | 2015-03-16 A | 2016-03-15 A | 100% |  |  |  |  |  | finish no earlier than 2016-03-15 | R2 | 2096h | 2096h | LTE_extDRX-Core | 34 | Qualcomm |  | Rel-13 | 67 | RP-151338 |  |
| 1314 | 453.5 | UE Conformance Test Aspects - RAN enhancements for extended DRX in LTE | 134d? | 2016-03-15 A | 2016-09-15 A | 100% |  |  |  |  |  | finish no earlier than 2016-12-15 | R5 | 1072h | 1072h | LTE_extDRX-UEConTest | 36 | Qualcomm |  | Rel-13 | 71 |  |  |
| 1315 | 453.6 | **Extended DRX (eDRX) for GSM** | 184.5d? | 2015-08-28 A | 2016-05-12 | 44% | 102.46d? |  |  |  | 5108d |  | G2; G1 | 4832h | 2072.8h | eDRX_GSM | 35 | John Diachina, Ericsson LM | John.Diachina@Ericsson.com | Rel-13 | 69 |  |  |
| 1316 | 453.6.1 | Core Part: Extended DRX (eDRX) for GSM | 60.5d? | 2015-08-28 A | 2015-11-20 A | 100% |  |  |  |  |  | finish no earlier than 2015-11-20 | G2; G1 | 968h | 968h | eDRX_GSM-Core | 36 | John Diachina, Ericsson LM | John.Diachina@Ericsson.com | Rel-13 | 70 |  |  |
| 1317 | 453.6.2 | MS test: Extended DRX (eDRX) for GSM | 114d? | 2015-12-07 A | 2016-05-12 | 15% | 96.9d? |  |  |  | 5108d | start no earlier than 2015-12-07 | G3 | 912h | 136.8h | eDRX_GSM_GERAN3new | 36 | Sierra Wireless S.A | John.Diachina@Ericsson.com | Rel-13 | 70 |  |  |
| 1318 | 454 | **Optimizations to Support High Latency Communications** | 326d? | 2014-09-19 A | 2015-12-16 A | 100% |  |  |  |  |  |  | S2 | 5824h | 5824h | HLcom | 34 | Ericsson, Hans Rönneke | hans.ronneke(at)ericsson.com | Rel-13 | 67 |  |  |
| 1319 | 454.1 | Study on Optimizations to support High Latency communications | 196d? | 2014-09-19 A | 2015-06-17 A | 100% |  |  |  |  |  | finish no earlier than 2015-06-17 | S2 | 1568h | 1568h | FS_HLcom | 33 | Ericsson | hans.ronneke@ericsson.com | Rel-13 | 65 |  | FS_HLcom |
| 1320 | 454.2 | Optimizations to Support High Latency Communications | 73d? | 2015-03-05 A | 2015-06-15 A | 100% |  |  |  |  |  | finish no earlier than 2015-06-15 | S2 | 584h | 584h | HLcom | 34 | Ericsson, Hans Rönneke | hans.ronneke(at)ericsson.com | Rel-13 | 67 |  |  |
| 1321 | 454.3 | CT aspects of Optimizations to Support High Latency | 133d? | 2015-06-15 A | 2015-12-16 A | 100% |  |  |  |  |  | finish no earlier than 2015-12-16 | C4 | 1064h | 1064h | HLcom-CT | 35 | Yong Yang, Ericsson | frank.yong.yang@ericsson.com | Rel-13 | 68 |  |  |
| 1322 | 455 | **Further LTE Physical Layer Enhancements for MTC** | 789d? | 2014-09-12 A | 2017-09-15 | 99% | 0d? | 2014-06-13 | 2015-06-12 | 261d? | 0d |  | R1; R4; R2 | 36320h | 23979.1h | LTE_MTCe2_L1 | 33 | Ericsson | johan.bergman@ericsson.com | Rel-13 | 65 |  | LTE_MTCe2_L1 |
| 1323 | 455.1 | Core part: Further LTE Physical Layer Enhancements for MTC | 395d? | 2014-09-12 A | 2016-03-15 A | 100% |  | 2014-06-13 | 2015-06-12 | 261d? |  | finish no earlier than 2016-03-15 | R1; R2; R4 | 9480h | 9480h | LTE_MTCe2_L1-Core | 33 | Ericsson | johan.bergman@ericsson.com | Rel-13 | 65 | RP-151186 | LTE_MTCe2_L1-Core |
| 1324 | 455.2 | Perf. Part: Further LTE Physical Layer Enhancements for MTC | 593d? | 2014-09-12 A | 2016-12-15 A | 100% |  | 2014-06-13 | 2015-06-12 | 261d? |  | finish no earlier than 2016-12-15 | R4 | 4744h | 4744h | LTE_MTCe2_L1-Perf | 33 | Ericsson | johan.bergman@ericsson.com | Rel-13 | 65 |  | LTE_MTCe2_L1-Perf |
| 1325 | 455.3 | UE Conformance Test Aspects - Further LTE Physical Layer Enhancements for MTC | 395d? | 2016-03-15 A | 2017-09-15 A | 100% |  |  |  |  |  | finish no earlier than 2017-09-15 | R5 | 3160h | 3160h | LTE_MTCe2_L1-UEConTest | 36 | Ericsson |  | Rel-13 | 71 |  |  |
| 1326 | 456 | EGPRS Access Security Enhancements in relation to Cellular IoT | 128d? | 2015-09-16 A | 2016-03-11 A | 100% |  |  |  |  |  | finish no earlier than 2016-03-11 | S3 | 1024h | 1024h | EASE_EC_GSM | 35 | Vesa Torvinen, Ericsson |  | Rel-13 | 69 |  |  |
| 1327 | 457 | **Group based Enhancements** | 394d? | 2014-06-18 A | 2015-12-16 A | 100% |  | 2014-06-18 | 2015-09-16 | 326d? |  |  | S2; S3 | 18676.8h | 18676.8h | GROUPE | 33 | Huawei | ZhangWanqiang@huawei.com | Rel-13 | 64 |  | GROUPE |
| 1328 | 457.1 | TR for Group based Enhancements | 196d? | 2014-06-18 A | 2015-03-18 A | 100% |  | 2014-06-18 | 2015-03-18 | 196d? |  | finish no earlier than 2015-03-18 | S2 | 1568h | 1568h | GROUPE | 33 | Huawei, Wanqiang Zhang | ZhangWanqiang@huawei.com | Rel-13 | 64 |  |  |
| 1329 | 457.2 | Stage 2 for Group based Enhancements | 261d? | 2014-06-23 A | 2015-06-17 A | 100% |  | 2014-06-18 | 2015-06-17 | 261d? |  | finish no earlier than 2015-06-17 | S2 | 2088h | 2088h | GROUPE | 33 | Huawei | ZhangWanqiang@huawei.com | Rel-13 | 64 |  |  |
| 1330 | 457.3 | TR on Security for Group based Enhancements | 231.6d? | 2014-06-18 A | 2015-06-12 A | 100% |  | 2014-06-18 | 2015-06-17 | 231.6d? |  | start no earlier than 2014-06-18 | S3 | 1852.8h | 1852.8h | GROUPE | 33 | Samsung | Rajavelsamy R (rajvel@samsung.com) | Rel-13 | 64 |  |  |
| 1331 | 457.4 | Security for Group based Enhancements | 326d? | 2014-06-23 A | 2015-09-16 A | 100% |  | 2014-06-18 | 2015-09-16 | 326d? |  | finish no earlier than 2015-09-16 | S3 | 2608h | 2608h | GROUPE | 33 | Samsung | Rajavelsamy R (rajvel@samsung.com) | Rel-13 | 64 |  |  |

Notes:
- 1304: June2015: WID:SP-150254->SP-150369 / Impacted TSs and TRs: 23.401, 23.060, 23.682, 23.271, 23.272
- 1305: No Ran aspects yet. GERAN in FS_uPoD.29/1: TS number added Mar15: 0->30%; June2015: Compl:30%->95, Exc S granted in SP-150352; 07/09/15: 95%->100 / Impacted TSs and TRs: 23.770
- 1306: June2015: WID:SP-150254->SP-150369; 07/09/15: 0%->95; 7/12/15: 95%->99 / Impacted TSs and TRs: 23.401, 23.060, 23.682, 23.271, 23.272
- 1307: 14/09/15: WID:CP-150499->CP-150541
- 1308: 14/09/15: WID:CP-150499->CP-150541; 7/12/15: 25%->80. FCD ->03/16. ES in CP-150723; 7/3/16: 80%->100 / Impacted TSs and TRs: 24.301, 24.008, 29.118
- 1309: 14/09/15: WID:CP-150499->CP-150541. FCD ->03/16. ES in CP-150723; 8/12/15: 0%->100 / Impacted TSs and TRs: 29.338, 23.007, 29.274, 29.060, 29.172
- 1310: 14/09/15: WID:CP-150499->CP-150541; 7/12/15: 40%->100; 8/12/15: 100%->95; 8/3/16: 95%->100 / Impacted TSs and TRs: 29.212
- 1311: 7/12/15: Added. FCD ->03/16. ES in CP-150723; 8/3/16: 0%->100
- 1313: 03/07/15: Compl:0%->15% 03/07/15: Stat Rep: ->RP-150798 29/09/15: Compl:15%->35% 29/09/15: WID: RP-150493->RP-151339 29/09/15: Stat Rep: RP-150798->RP-151338 ; 22/3/16: Compl:95%->100%
- 1314: testing REL-13 LTE_extDRX-Core and CT1 feature eDRX-CT;
- 1315: 07/09/15: 0%->40; 7/12/15: 40%->100 / Impacted TSs and TRs: 43.064, 44.018, 44.060, 45.008, 48.018, 43.022
- 1316: 7/12/15: created by MCC to distinguish Core versus test parts / Impacted TSs and TRs: 43.064, 44.018, 44.060, 45.008, 48.018, 43.022
- 1317: 7/12/15: created by GERAN. 2/3/16: G1,G2->G3. Acronym: eDRX_GSM-Test -> eDRX_GSM_GERAN3new (to conform to WID); 0->15%
- 1318: Impacted TSs and TRs: 23.401, 23.060, 23.682
- 1319: Dec.14: 0->30%. Mar15: 70%; June2015: Compl:70%->100 / Impacted TSs and TRs: New TR 23.709
- 1320: June 2015: created by MCC as a result of the split of the one-line Feature into a several-lines Feature (now Stage 2 and Stage 3 aspects); June2015: Compl:0%->100. WID: SP-150030->SP-150252 / Impacted TSs and TRs: 23.401, 23.060, 23.682
- 1321: 07/09/15: 0%->80; 7/12/15: 80%->100 / Impacted TSs and TRs: 29.274, 29.060, 29.281, 23.008, 29.272, 29.230, 29.002, 29.336, 29.xyz
- 1322: Triggered by Rel-12 TR 36.888 Study on Provision of low-cost MTC UEs based on LTE (FS_LC_MTC_LTE) and Low cost & enhanced coverage MTC UE for LTE (LC_MTC_UE) / Impacted TSs and TRs: LTE
- 1323: 3/3/15: WID: RP-141865; Stat Rep: -->RP-141785 1st Apr 15: Compl:10%->25% 1st Apr 15: WID: RP-141865->RP-150492 1st Apr 15: Stat Rep: RP-141785->RP-150495 03/07/15: Compl:25%->45% 03/07/15: Stat Rep: RP-150495->RP-150583 29/09/15: Compl:45%->65% 29/09 / Impacted TSs and TRs: 36.101, 36.104, 36.133, 36.201, 36.211, 36.212, 36.213, 36.214, 36.300, 36.302, 36.306, 36.321, 36.331
- 1324: ; WID: RP-142043->RP-141865; Stat Rep: -->RP-141785 1st Apr 15: WID: RP-141865->RP-150492 1st Apr 15: Stat Rep: RP-141785->RP-150495 03/07/15: Stat Rep: RP-150495->RP-150583 29/09/15: Stat Rep: RP-150583->RP-151186 ;26/9/16: Compl:70%-; / Impacted TSs and TRs: 36.101, 36.104, 36.133
- 1325: testing REL-13 LTE_MTCe2_L1-Core; 1/7/16: Compl:0%->6%; 26/; 2; 21/3/17: Compl:70%...; ;...; ;...
- 1326: 7/12/15: 0%->5; 28/1/16: 33.420 added; 7/3/16: 5%->80; 11/6/16: 80%->98; 19/9/16: 98%->99; 21/3/17: 99%->100->99%; 7/6/17: 99%->100 / Impacted TSs and TRs: New 33.420
- 1327: - / Impacted TSs and TRs: Stage 2
- 1328: Dec.14: 20->70%. Mar15: 90%; June2015: Compl:90%->100 / Impacted TSs and TRs: New TR 23.769
- 1329: Mar15: 0->20%; June2015: Compl:20%->100 / Impacted TSs and TRs: 23.682, TBD
- 1330: TR 33.8xy will capture requirements, solution alternatives, evaluations and conclusions for the AESE, MONTE and GROUPE WIDs. 3/3/15: 5->10%.; June2015: Compl:10%->60; 11/12/15: 60%->100 / Impacted TSs and TRs: New TR 33.889
- 1331: -; 11/12/15: 0%->100 / Impacted TSs and TRs: 33.187

| ID | WBS | Task | Duration | Start | Finish | Complete | Baseline start | Baseline finish | Baseline duration | Constraint | Resources | Work | Actual work | Acronym | PCG approved | WI rapporteur name | WI rapporteur e-mail | Release | TSG approved | Acronym_3GU_Export | Status Report | MCC resp | Special Focus Doc |
| --- | --- | --- | --- | --- | --- | --- | --- | --- | --- | --- | --- | --- | --- | --- | --- | --- | --- | --- | --- | --- | --- | --- | --- |
| 1332 | 457.5 | **CT aspects of Group based Enhancements** | 133d? | 2015-06-15 A | 2015-12-16 A | 100% |  |  |  |  | C4 | 4256h | 4256h | GROUPE-CT | 35 | Peter Schmitt, Huawei | Peter.Schmitt@huawei.com | Rel-13 | 68 |  |  |  |  |
| 1333 | 457.5.1 | CT1 aspects of Group based Enhancements | 133d? | 2015-06-15 A | 2015-12-16 A | 100% |  |  |  | start no earlier than 2015-06-15 | C1 | 1064h | 1064h | GROUPE-CT | 35 | Peter Schmitt, Huawei | Peter.Schmitt@huawei.com | Rel-13 | 68 |  |  |  |  |
| 1334 | 457.5.2 | DELETED: CT3 aspects of Group based Enhancements | 133d? | 2015-06-15 A | 2015-12-16 A | 100% |  |  |  | start no earlier than 2015-06-15 | C3 | 1064h | 1064h | GROUPE-CT | 35 | Peter Schmitt, Huawei | Peter.Schmitt@huawei.com | Rel-13 | 68 |  |  |  |  |
| 1335 | 457.5.3 | CT4 aspects of Group based Enhancements | 133d? | 2015-06-15 A | 2015-12-16 A | 100% |  |  |  | start no earlier than 2015-06-15 | C4 | 1064h | 1064h | GROUPE-CT | 35 | Peter Schmitt, Huawei | Peter.Schmitt@huawei.com | Rel-13 | 68 |  |  |  |  |
| 1336 | 458 | **Monitoring Enhancements** | 456d? | 2014-06-18 A | 2016-03-11 A | 100% | 2014-06-18 | 2015-09-16 | 326d? |  | S2; S3 | 21684.8h | 21684.8h | MONTE | 33 | Intel | puneet.jain@intel.com | Rel-13 | 64 | MONTE |  |  |  |
| 1337 | 458.1 | TR for Monitoring Enhancements | 196d? | 2014-09-17 A | 2015-06-17 A | 100% | 2014-09-17 | 2015-06-17 | 196d? | finish no earlier than 2015-06-17 | S2 | 1568h | 1568h | MONTE | 33 | Intel, Puneet Jain | puneet.jain@intel.com | Rel-13 | 64 |  |  |  |  |
| 1338 | 458.2 | Stage 2 for Monitoring Enhancements | 261d? | 2014-06-23 A | 2015-06-17 A | 100% | 2014-06-18 | 2015-06-17 | 261d? | finish no earlier than 2015-06-17 | S2 | 2088h | 2088h | MONTE | 33 | Intel, Puneet Jain | puneet.jain@intel.com | Rel-13 | 64 |  |  |  |  |
| 1339 | 458.3 | TR on Security for Monitoring Enhancements | 231.6d? | 2014-06-18 A | 2015-06-12 A | 100% | 2014-06-18 | 2015-06-17 | 231.6d? | start no earlier than 2014-06-18 | S3 | 1852.8h | 1852.8h | MONTE | 33 | Samsung | Rajavelsamy R (rajvel@samsung.com) | Rel-13 | 64 |  |  |  |  |
| 1340 | 458.4 | Security for Monitoring Enhancements | 326d? | 2014-06-23 A | 2015-09-16 A | 100% | 2014-06-18 | 2015-09-16 | 326d? | finish no earlier than 2015-09-16 | S3 | 2608h | 2608h | MONTE | 33 | Samsung | Rajavelsamy R (rajvel@samsung.com) | Rel-13 | 64 |  |  |  |  |
| 1341 | 458.5 | Charging aspects of MONTE | 128d? | 2015-09-16 A | 2016-03-11 A | 100% | 2014-06-18 | 2015-09-16 | 326d? | finish no earlier than 2016-03-11 | S5 | 1024h | 1024h | MONTE-CH | 35 | Huawei(Li Li, jasmine.li@huawei.com) | jasmine.li@huawei.com | Rel-13 | 69 |  |  |  |  |
| 1342 | 458.6 | **Monitoring Enhancements CT aspects** | 195d? | 2015-06-15 A | 2016-03-11 A | 100% |  |  |  |  | C4 | 5248h | 5248h | MONTE-CT | 35 | Peter Schmitt, Huawei | peter.schmitt@huawei.com | Rel-13 | 68 |  |  |  |  |
| 1343 | 458.6.1 | CT1 aspects of Monitoring Enhancements | 133d? | 2015-06-15 A | 2015-12-16 A | 100% |  |  |  | start no earlier than 2015-06-15 | C1 | 1064h | 1064h | MONTE-CT | 35 | Peter Schmitt, Huawei | peter.schmitt@huawei.com | Rel-13 | 68 |  |  |  |  |
| 1344 | 458.6.2 | CT3 aspects of Monitoring Enhancements | 133d? | 2015-06-15 A | 2015-12-16 A | 100% |  |  |  | start no earlier than 2015-06-15 | C3 | 1064h | 1064h | MONTE-CT | 35 | Peter Schmitt, Huawei | peter.schmitt@huawei.com | Rel-13 | 68 |  |  |  |  |
| 1345 | 458.6.3 | CT4 aspects of Monitoring Enhancements | 195d? | 2015-06-15 A | 2016-03-11 A | 100% |  |  |  | finish no earlier than 2016-03-11 | C4 | 1560h | 1560h | MONTE-CT | 35 | Peter Schmitt, Huawei | peter.schmitt@huawei.com | Rel-13 | 68 |  |  |  |  |
| 1346 | 459 | **Dedicated Core Networks** | 456d? | 2014-06-18 A | 2016-03-11 A | 100% | 2014-06-18 | 2015-03-18 | 196d? |  | S2 | 11518.4h | 11518.4h | DECOR | 33 | NTT DOCOMO | Daisuke Fujishima (fujishimad@nttdocomo.co.jp) | Rel-13 | 64 | DECOR |  |  |  |
| 1347 | 459.1 | TR for Dedicated Core Networks | 128d? | 2014-06-18 A | 2014-12-12 A | 100% | 2014-06-18 | 2014-12-10 | 126d? | finish no earlier than 2014-12-12 | S2 | 1024h | 1024h | DECOR | 33 | NTT DOCOMO | Daisuke Fujishima (fujishimad@nttdocomo.co.jp) | Rel-13 | 64 |  |  |  |  |
| 1348 | 459.2 | Stage 2 for Dedicated Core Networks | 196d? | 2014-06-23 A | 2015-03-18 A | 100% | 2014-06-18 | 2015-03-18 | 196d? | finish no earlier than 2015-03-18 | S2 | 1568h | 1568h | DECOR | 33 | NTT DOCOMO | Daisuke Fujishima (fujishimad@nttdocomo.co.jp) | Rel-13 | 64 |  |  |  |  |
| 1349 | 459.3 | **CT aspects of Dedicated Core Networks** | 186.8d? | 2015-06-25 A | 2016-03-11 A | 100% |  |  |  |  | ct | 3166.4h | 3166.4h | DECOR-CT | 35 | Huawei, Xiaoyan SHI (Sean.shixiaoyan@huawei.com) | Huawei, Xiaoyan SHI (Sean.shixiaoyan@huawei.com) | Rel-13 | 69 |  |  |  |  |
| 1350 | 459.3.1 | CT1 aspects for Dedicated Core Networks CT aspects | 74d? | 2015-09-07 A | 2015-12-17 A | 100% |  |  |  | finish no earlier than 2015-12-17 | C1 | 592h | 592h | DECOR-CT | 35 | Huawei |  | Rel-13 | 69 |  |  |  |  |
| 1351 | 459.3.2 | CT4 aspects for Dedicated Core Networks CT aspects | 135d? | 2015-06-25 A | 2016-03-11 A | 100% |  |  |  | finish no earlier than 2016-03-11 | C4 | 1080h | 1080h | DECOR-CT | 35 |  |  | Rel-13 | 69 |  |  |  |  |
| 1352 | 459.4 | **Dedicated Core Networks RAN Aspects** | 132d? | 2015-06-15 A | 2015-12-15 A | 100% |  |  |  |  | R3 | 2112h | 2112h | DECOR-UTRA_LTE | 35 | Ericsson |  | Rel-13 | 68 |  |  |  |  |
| 1353 | 459.4.1 | Core part: Dedicated Core Networks | 132d? | 2015-06-15 A | 2015-12-15 A | 100% |  |  |  | finish no earlier than 2015-12-15 | R3 | 1056h | 1056h | DECOR-UTRA_LTE-Core | 35 | Ericsson |  | Rel-13 | 68 |  | RP-151290 |  |  |
| 1354 | 460 | **Service Exposure and Enablement Support** | 268d? | 2013-09-12 A | 2014-09-17 A | 100% | 2013-09-12 | 2014-09-17 | 267d? |  | S1 | 5880h | 5880h | SEES | 31 | KPN | toon.norp@tno.nl | Rel-13 | 61 | SEES | S1-143301 | Alain | MTC, M2M |
| 1355 | 460.1 | TR on Stage 1 for Service Exposure and Enablement Support | 202d? | 2013-09-12 A | 2014-06-18 A | 100% | 2013-09-12 | 2014-06-18 | 202d? | finish no earlier than 2014-06-18 | S1 | 1608h | 1608h | SEES | 31 | KPN | toon.norp@tno.nl | Rel-13 | 61 |  | S1-143301 | Alain | MTC, M2M |
| 1356 | 460.2 | Stage 1 for Service Exposure and Enablement Support | 266d? | 2013-09-12 A | 2014-09-17 A | 100% | 2013-09-12 | 2014-09-17 | 266d? | finish no earlier than 2014-09-17 | S1 | 2128h | 2128h | SEES | 31 | KPN | toon.norp@tno.nl | Rel-13 | 61 |  | S1-143301 | Alain | MTC, M2M |

Notes:
- 1332: 7/12/15: WID:CP-150240->CP-150816 / Impacted TSs and TRs: 24.008, 24.301, 29.468, 29.272, 23.008, 29.336, 29.303, 29.002, 29.230, 29.305, 23.003
- 1333: 07/09/15: 0%->15; 7/12/15: 15%->100; 7/12/15: WID:CP-150240->CP-150816 / Impacted TSs and TRs: 24.008, 24.301
- 1334: 7/12/15: WID:CP-150240->CP-150816. CT3 task removed / Impacted TSs and TRs: 29.468
- 1335: 07/09/15: 0%->80; 7/12/15: 80%->100; 7/12/15: WID:CP-150240->CP-150816 / Impacted TSs and TRs: 29.272, 23.008, 29.336, 29.303, 29.002, 29.230, 29.305, 23.003
- 1336: Linked to Rel-13 Feature Architecture Enhancements for Service Exposure (AESE). Although service requirements (TS 22.368 clause 7.2.8) are motivated by MTC, the solution may apply to normal UEs; 5/10/15: 32.278 added; / Impacted TSs and TRs: 32.278
- 1337: Dec.14: 25->85%. Mar15: 100% / Impacted TSs and TRs: New TR 23.789
- 1338: -; June2015: Compl:0%->100 / Impacted TSs and TRs: 23.682, TBD
- 1339: TR 33.8xy will capture requirements, solution alternatives, evaluations and conclusions for the AESE, MONTE and GROUPE WIDs.3/3/15: 5->10%.; June2015: Compl:10%->15; 11/12/15: 15%->100 / Impacted TSs and TRs: New TR 33.889
- 1340: -; 11/12/15: 0%->100 / Impacted TSs and TRs: 33.187
- 1341: 7/10/15: acronym changed from "MONTE" to "MONTE-CH"; 7/12/15: 0%->50. ES in SP-150709 (wrong UID in the ES); 7/3/16: 25%->100 / Impacted TSs and TRs: 32.27x, 32.240, 32.299, 32.298
- 1342: 14/09/15: WID:CP-150396->CP-150422
- 1343: 07/09/15: 0%->95; 14/09/15: WID:CP-150396->CP-150422; 7/12/15: 95%->100 / Impacted TSs and TRs: 24.301, 24.008
- 1344: 07/09/15: 0%->100; 14/09/15: WID:CP-150396->CP-150422 / Impacted TSs and TRs: 29.214, 29.213, 29.201
- 1345: 61907/09/15: 0%->50; 14/09/15: WID:CP-150396->CP-150422; 7/12/15: 50%->85. FCD -> 03/16, ES in CP-150619; 7/3/16: 85%->100 / Impacted TSs and TRs: New TS 29.128, 29.272, 29.002, 29.336, 29.230, 23.008
- 1346: 06/15: WID: SP-140707-> SP-150249 / Impacted TSs and TRs: Stage 2
- 1347: Dec.14: 30->100%. 06/15: WID: SP-140707-> SP-150249 / Impacted TSs and TRs: New TR 23.707
- 1348: Mar15: 0->70%; June2015: Compl:70%->100, WID: SP-140707-> SP-150249 / Impacted TSs and TRs: 23.060, 23.401, 23.236
- 1350: 7/12/15: 0%->100 / Impacted TSs and TRs: 24.301, 24.008
- 1351: 7/12/15: 70%->90. FCD -> 03/16, ES CP-150617; 7/3/16: 90%->100 / Impacted TSs and TRs: 29.274, 29.060, 23.003, 29.272, 29.002, 29.305, 23.008, 29.230, 29.303, 23.007
- 1352: no Perf. part; note: DECOR is a REL-13 SA2 WI;
- 1353: no Perf. part; note: DECOR is a REL-13 SA2 WI; 29/09/15: Compl:0%->30% 29/09/15: Stat Rep: -->RP-1512901/1/16: Compl:30%->100%
- 1354: SP#62 completion 06/14=>09/14. Linked to Rel-12 Study TR 22.888 (FS_MTCe) and to Features Rel-11 SIMTC & Rel-12 MTCe and MOSAP / Impacted TSs and TRs: Stage 1
- 1355: SP#64 completed. TR 22.853v200 for Approval. External requirements from oneM2M TR0001(oneM2M Use Case collection), TS0002 (M2M Requirements) / Impacted TSs and TRs: New TR 22.853
- 1356: SP#65 completed / Impacted TSs and TRs: 22.101, 22.115, 22.368, TBD

| ID | WBS | Task | Duration | Start | Finish | Complete | Remaining | Baseline start | Baseline finish | Baseline duration | Total slack | Constraint | Resources | Work | Actual work | Acronym | PCG approved | WI rapporteur name | WI rapporteur e-mail | Release | TSG approved | Acronym_3GU_Export | MCC resp | Special Focus Doc | Status Report |
| --- | --- | --- | --- | --- | --- | --- | --- | --- | --- | --- | --- | --- | --- | --- | --- | --- | --- | --- | --- | --- | --- | --- | --- | --- | --- |
| 1357 | 461 | **Architecture Enhancements for Service capability Exposure** | 456d? | 2014-06-18 A | 2016-03-11 | 100% | 0d? | 2014-06-18 | 2015-09-16 | 326d? | 0d |  | S2; S3 | 19675.2h | 16027.2h | AESE | 33 | Intel | puneet.jain@intel.com | Rel-13 | 64 | AESE |  |  |  |
| 1358 | 461.1 | TR for Architecture Enhancements for Service capability Exposure | 196d? | 2014-06-18 A | 2015-03-18 A | 100% |  | 2014-06-18 | 2015-03-18 | 196d? |  | finish no earlier than 2015-03-18 | S2 | 1568h | 1568h | AESE | 33 | Intel, Puneet Jain | puneet.jain@intel.com | Rel-13 | 64 |  |  |  |  |
| 1359 | 461.2 | Stage 2 for Architecture Enhancements for Service capability Exposure | 261d? | 2014-06-23 A | 2015-06-17 A | 100% |  | 2014-06-18 | 2015-06-17 | 261d? |  | finish no earlier than 2015-06-17 | S2 | 2088h | 2088h | AESE | 33 | Intel, Puneet Jain | puneet.jain@intel.com | Rel-13 | 64 |  |  |  |  |
| 1360 | 461.3 | TR on Security for Architecture Enhancements for Service capability Exposure | 241.4d? | 2014-06-23 A | 2015-06-17 A | 100% |  | 2014-06-18 | 2015-06-17 | 241.4d? |  | finish no earlier than 2015-06-17 | S3 | 1931.2h | 1931.2h | AESE | 33 | Samsung | Rajavelsamy R (rajvel@samsung.com) | Rel-13 | 64 |  |  |  |  |
| 1361 | 461.4 | Security for Architecture Enhancements for Service capability Exposure | 326d? | 2014-06-23 A | 2015-09-16 A | 100% |  | 2014-06-18 | 2015-09-16 | 326d? |  | finish no earlier than 2015-09-16 | S3 | 2608h | 2608h | AESE | 33 | Samsung | Rajavelsamy R (rajvel@samsung.com) | Rel-13 | 64 |  |  |  |  |
| 1362 | 461.5 | **CT aspects of Architecture Enhancements for Service capability Exposure** | 195d? | 2015-06-15 A | 2016-03-11 A | 100% |  |  |  |  |  |  | C3 | 4184h | 4184h | AESE-CT | 35 | Yizhuang Wu, Huawei | wuyizhuang@huawei.com | Rel-13 | 68 |  |  |  |  |
| 1363 | 461.5.1 | CT3 aspects of Architecture Enhancements for Service capability Exposure | 195d? | 2015-06-15 A | 2016-03-11 A | 100% |  |  |  |  |  | finish no earlier than 2016-03-11 | C3 | 1560h | 1560h | AESE-CT | 35 | Yizhuang Wu, Huawei. FCD+3, ES in 642 | wuyizhuang@huawei.com | Rel-13 | 68 |  |  |  |  |
| 1364 | 461.5.2 | CT4 aspects of Architecture Enhancements for Service capability Exposure | 133d? | 2015-06-15 A | 2015-12-16 A | 100% |  |  |  |  |  | start no earlier than 2015-06-15 | C4 | 1064h | 1064h | AESE-CT | 35 | Yizhuang Wu, Huawei | wuyizhuang@huawei.com | Rel-13 | 68 |  |  |  |  |
| 1365 | 462 | **Rel-13 LTE Carrier Aggregation** | 1185d? | 2013-12-09 A | 2018-06-15 | 94% | 74.92d? | 2014-03-06 | 2015-06-12 | 332d? | 4561d |  | R4 | 553488h | 508223h | LTE_CA_Rel13 | 30 |  |  | Rel-13 | 58 | LTE_CA_Rel-13 | Issam | CA |  |
| 1366 | 462.1 | **LTE Advanced 4 Band Carrier Aggregation (4DL/1UL) of Band 4, Band 4, Band 5 and Band 12** | 66d? | 2015-09-15 A | 2015-12-15 A | 100% |  |  |  |  |  |  | R4 | 1584h | 1584h | LTE_CA_B4_B4_B5_B12 | 35 | US Cellular |  | Rel-13 | 69 |  |  |  |  |
| 1367 | 462.1.1 | Core part:LTE Advanced 4 Band Carrier Aggregation (4DL/1UL) of Band 4, Band 4, Band 5 and Band 12 | 66d? | 2015-09-15 A | 2015-12-15 A | 100% |  |  |  |  |  | finish no earlier than 2016-03-15 | R4 | 528h | 528h | LTE_CA_B4_B4_B5_B12-Core | 35 | US Cellular |  | Rel-13 | 69 |  |  |  |  |
| 1368 | 462.1.2 | Perf. part:LTE Advanced 4 Band Carrier Aggregation (4DL/1UL) of Band 4, Band 4, Band 5 and Band 12 | 66d? | 2015-09-15 A | 2015-12-15 A | 100% |  |  |  |  |  | finish no earlier than 2016-03-15 | R4 | 528h | 528h | LTE_CA_B4_B4_B5_B12-Perf | 35 | US Cellular |  | Rel-13 | 69 |  |  |  |  |
| 1369 | 462.2 | **LTE Advanced 4 Band Carrier Aggregation (4DL/1UL) of Band 2, Band 4, Band 4 and Band 5** | 66d? | 2015-09-15 A | 2015-12-15 A | 100% |  |  |  |  |  |  | R4 | 1584h | 1584h | LTE_CA_B2_B4_B4_B5 | 35 | US Cellular |  | Rel-13 | 69 |  |  |  |  |
| 1370 | 462.2.1 | Core part:LTE Advanced 4 Band Carrier Aggregation (4DL/1UL) of Band 2, Band 4, Band 4 and Band 5 | 66d? | 2015-09-15 A | 2015-12-15 A | 100% |  |  |  |  |  | finish no earlier than 2016-03-15 | R4 | 528h | 528h | LTE_CA_B2_B4_B4_B5-Core | 35 | US Cellular |  | Rel-13 | 69 |  |  |  |  |
| 1371 | 462.2.2 | Perf. part:LTE Advanced 4 Band Carrier Aggregation (4DL/1UL) of Band 2, Band 4, Band 4 and Band 5 | 66d? | 2015-09-15 A | 2015-12-15 A | 100% |  |  |  |  |  | finish no earlier than 2016-03-15 | R4 | 528h | 528h | LTE_CA_B2_B4_B4_B5-Perf | 35 | US Cellular |  | Rel-13 | 69 |  |  |  |  |
| 1372 | 462.3 | **LTE Advanced inter-band Carrier Aggregation of Band 8 and Band 27** | 531d? | 2013-12-09 A | 2015-12-15 | 30% | 371.7d? | 2013-12-09 | 2014-12-11 | 265d? | 5215d |  | R4 | 12696h | 2643.08h | LTE_CA_B8_B27 | 32 | KT | ilwhan.kim@kt.com | Rel-13 | 62 | LTE_CA_B8_B27 | Issam | CA |  |
| 1373 | 462.3.1 | Core part:LTE Advanced inter-band Carrier Aggregation of Band 8 and Band 27 | 528d? | 2013-12-09 A | 2015-12-15 | 30% | 369.6d? | 2013-12-09 | 2014-12-11 | 265d? | 5215d | finish no earlier than 2015-12-15 | R4 | 4224h | 1267.2h | LTE_CA_B8_B27-Core | 32 | KT | ilwhan.kim@kt.com | Rel-13 | 62 | LTE_CA_B8_B27-Core | Issam | CA | RP-151131 |
| 1374 | 462.3.2 | Perf. part:LTE Advanced inter-band Carrier Aggregation of Band 8 and Band 27 | 528d? | 2013-12-09 A | 2015-12-15 | 30% | 369.6d? | 2013-12-09 | 2014-12-11 | 265d? | 5215d | finish no earlier than 2015-12-15 | R4 | 4224h | 1267.2h | LTE_CA_B8_B27-Perf | 32 | KT | ilwhan.kim@kt.com | Rel-13 | 62 | LTE_CA_B8_B27-Perf | Issam | CA | RP-151131 |
| 1375 | 462.4 | **LTE Advanced 3 band Carrier Aggregation (3DL/1UL) for Band 3, Band 8 and Band 27** | 531d? | 2013-12-09 A | 2015-12-15 | 25% | 398.25d? | 2013-12-09 | 2014-12-05 | 261d? | 5215d |  | R4 | 12696h | 2384h | LTE_CA_B3_B8_B27 | 32 | KT | Chungwoo HWANG (cwhwang@kt.com) | Rel-13 | 62 | LTE_CA_B3_B8_B27 | Issam | CA |  |
| 1376 | 462.4.1 | Core part:LTE Advanced 3 band Carrier Aggregation (3DL/1UL) for Band 3, Band 8 and Band 27 | 528d? | 2013-12-09 A | 2015-12-15 | 25% | 396d? | 2013-12-09 | 2014-12-05 | 261d? | 5215d | finish no earlier than 2015-12-15 | R4 | 4224h | 1056h | LTE_CA_B3_B8_B27-Core | 32 | KT | Chungwoo HWANG (cwhwang@kt.com) | Rel-13 | 62 | LTE_CA_B3_B8_B27-Core | Issam | CA | RP-151131 |
| 1377 | 462.4.2 | Perf. part:LTE Advanced 3 band Carrier Aggregation (3DL/1UL) for Band 3, Band 8 and Band 27 | 528d? | 2013-12-09 A | 2015-12-15 | 25% | 396d? | 2013-12-09 | 2014-12-05 | 261d? | 5215d | finish no earlier than 2015-12-15 | R4 | 4224h | 1056h | LTE_CA_B3_B8_B27-Perf | 32 | KT | Chungwoo HWANG (cwhwang@kt.com) | Rel-13 | 62 | LTE_CA_B3_B8_B27-Perf | Issam | CA | RP-151131 |
| 1378 | 462.5 | **LTE Advanced inter-band Carrier Aggregation of Band 7 and Band 22** | 336d? | 2014-03-06 A | 2015-06-15 A | 100% |  | 2014-03-06 | 2014-12-05 | 197d? |  |  | R4 | 8016h | 8016h | LTE_CA_B7_B22 | 32 | Orange, Ericsson | erika.tejedor@ericsson.com | Rel-13 | 63 | LTE_CA_B7_B22 | Issam | CA |  |
| 1379 | 462.5.1 | Core part:LTE Advanced inter-band Carrier Aggregation of Band 7 and Band 22 | 333d? | 2014-03-06 A | 2015-06-15 A | 100% |  | 2014-03-06 | 2014-12-05 | 197d? |  | finish no earlier than 2015-06-15 | R4 | 2664h | 2664h | LTE_CA_B7_B22-Core | 32 | Orange, Ericsson | erika.tejedor@ericsson.com | Rel-13 | 63 | LTE_CA_B7_B22-Core | Issam | CA | RP-150536 |
| 1380 | 462.5.2 | Perf. part:LTE Advanced inter-band Carrier Aggregation of Band 7 and Band 22 | 333d? | 2014-03-11 A | 2015-06-15 A | 100% |  | 2014-03-06 | 2014-12-05 | 197d? |  | finish no earlier than 2015-06-15 | R4 | 2664h | 2664h | LTE_CA_B7_B22-Perf | 32 | Orange, Ericsson | erika.tejedor@ericsson.com | Rel-13 | 63 | LTE_CA_B7_B22-Perf | Issam | CA | RP-150536 |

Notes:
- 1357: - / Impacted TSs and TRs: Stage 2
- 1358: Dec.14: 30->65%. Mar15: 75%; June2015: Compl:75%->100 / Impacted TSs and TRs: New TR 23.708
- 1359: -; June2015: Compl:0%->100 / Impacted TSs and TRs: TS 23.682, TS 33.187
- 1360: TR 33.8xy will capture requirements, solution alternatives, evaluations and conclusions for the AESE, MONTE and GROUPE WIDs. Dec.14: 0->40%. 3/3/15: 45%.; June2015: Compl:45%->60; 11/12/15: 60%->100 / Impacted TSs and TRs: New TR 33.889
- 1361: -; 11/12/15: 0%->100 / Impacted TSs and TRs: 33.187
- 1362: 14/09/15: WID:CP-150402->CP-150487->CP-150576
- 1363: 07/09/15: 0%->35; 14/09/15: WID:CP-150402->CP-150487->CP-150576; 7/12/15: 35%->90; 7/3/16: 90%->100 / Impacted TSs and TRs: 29.154
- 1364: 07/09/15: 0%->40; 14/09/15: WID:CP-150402->CP-150487->CP-150576; 7/12/15: 40%->100 / Impacted TSs and TRs: 29.201, 29.336, 29.230, 29.272, 23.008
- 1365: Acronym changed from "LTE_CA_Rel-13" to "LTE_CA_Rel13"
- 1366: 13/6/16: moved from Rel-14 to Rel-13 (was a mistake)
- 1367: 13/6/16: moved from Rel-14 to Rel-13 (was a mistake)
- 1368: 13/6/16: moved from Rel-14 to Rel-13 (was a mistake)
- 1369: 13/6/16: moved from Rel-14 to Rel-13 (was a mistake)
- 1370: 13/6/16: moved from Rel-14 to Rel-13 (was a mistake)
- 1371: 13/6/16: moved from Rel-14 to Rel-13 (was a mistake)
- 1372: Inter-band CA 2DL/1UL / Impacted TSs and TRs: LTE
- 1373: CD:Thu 18/06/15->Mon 15/06/15; Compl:10%->10%; Stat Rep: RP-141084->RP-141732 1st Apr 15: Compl:10%->15% 1st Apr 15: Stat Rep: RP-141732->RP-150013 03/07/15: Compl:15%->30% 03/07/15: CD:Mon 15/06/15->Tue 15/12/15 03/07/15: Stat Rep: RP-150013->RP-15053 / Impacted TSs and TRs: 36.101, 36.104, 36.133, generic TR 36.851
- 1374: CD:Thu 18/06/15->Mon 15/06/15; Compl:10%->10%; Stat Rep: RP-141084->RP-141732 1st Apr 15: Compl:10%->15% 1st Apr 15: Stat Rep: RP-141732->RP-150013 03/07/15: Compl:15%->30% 03/07/15: CD:Mon 15/06/15->Tue 15/12/15 03/07/15: Stat Rep: RP-150013->RP-15053 / Impacted TSs and TRs: 36.141, 36.307
- 1375: Inter-band CA 3DL / Impacted TSs and TRs: LTE
- 1376: CD:Thu 18/06/15->Mon 15/06/15; Compl:25%->25%; Stat Rep: RP-141084->RP-141732 1st Apr 15: Compl:25%->30% 1st Apr 15: Stat Rep: RP-141732->RP-150013 03/07/15: Compl:30%->25% 03/07/15: CD:Mon 15/06/15->Tue 15/12/15 03/07/15: Stat Rep: RP-150013->RP-15053 / Impacted TSs and TRs: 36.101, 36.104, 36.133, 36.141, 36.307, new generic TR 36.853 (3 Band CA with 1UL)
- 1377: CD:Thu 18/06/15->Mon 15/06/15; Compl:25%->25%; Stat Rep: RP-141084->RP-141732 1st Apr 15: Compl:25%->30% 1st Apr 15: Stat Rep: RP-141732->RP-150013 03/07/15: Compl:30%->25% 03/07/15: CD:Mon 15/06/15->Tue 15/12/15 03/07/15: Stat Rep: RP-150013->RP-15053 / Impacted TSs and TRs: 36.101, 36.104, 36.133, 36.141, 36.307
- 1378: Inter-band CA 2DL / Impacted TSs and TRs: LTE
- 1379: CD:Thu 11/12/14->Mon 15/06/15; Compl:10%->10%; Stat Rep: RP-141084->RP-141732 03/07/15: Compl:10%->100% 03/07/15: Stat Rep: RP-141732->RP-150536 / Impacted TSs and TRs: 36.101, 36.104, 36.133, generic TR 36.851 (2 Band CA with 1UL),
- 1380: CD:Thu 11/12/14->Mon 15/06/15; Compl:0%->0%; Stat Rep: RP-141084->RP-141732 03/07/15: Compl:0%->100% 03/07/15: Stat Rep: RP-141732->RP-150536 / Impacted TSs and TRs: 36.141, 36.307

| ID | WBS | Task | Duration | Start | Finish | Complete | Baseline start | Baseline finish | Baseline duration | Constraint | Resources | Work | Actual work | Acronym | PCG approved | WI rapporteur name | WI rapporteur e-mail | Release | TSG approved | Special Focus Doc | Acronym_3GU_Export | Status Report |
| --- | --- | --- | --- | --- | --- | --- | --- | --- | --- | --- | --- | --- | --- | --- | --- | --- | --- | --- | --- | --- | --- | --- |
| 1381 | 462.6 | **LTE Advanced 3 Band Carrier Aggregation (3DL/1UL) for Band 2, Band 2 and Band 12** | 262d? | 2014-06-18 A | 2015-06-15 A | 100% | 2014-06-13 | 2015-03-13 | 196d? |  | R4 | 6288h | 6288h | LTE_CA_B2_B2_B12 | 33 | U.S. Cellular | sebastian.thalanany@uscellular.com | Rel-13 | 64 | CA | LTE_CA_B2_B2_B12 |  |
| 1382 | 462.6.1 | Core part:LTE Advanced 3 Band Carrier Aggregation (3DL/1UL) for Band 2, Band 2 and Band 12 | 262d? | 2014-06-18 A | 2015-06-15 A | 100% | 2014-06-13 | 2014-12-05 | 126d? | finish no earlier than 2015-06-15 | R4 | 2096h | 2096h | LTE_CA_B2_B2_B12-Core | 33 | U.S. Cellular | sebastian.thalanany@uscellular.com | Rel-13 | 64 | CA | LTE_CA_B2_B2_B12-Core | RP-150536 |
| 1383 | 462.6.2 | Perf. Part:LTE Advanced 3 Band Carrier Aggregation (3DL/1UL) for Band 2, Band 2 and Band 12 | 262d? | 2014-06-18 A | 2015-06-15 A | 100% | 2014-06-13 | 2015-03-13 | 196d? | finish no earlier than 2015-06-15 | R4 | 2096h | 2096h | LTE_CA_B2_B2_B12-Perf | 33 | U.S. Cellular | sebastian.thalanany@uscellular.com | Rel-13 | 64 | CA | LTE_CA_B2_B2_B12-Perf | RP-150536 |
| 1384 | 462.7 | **LTE Advanced 3 Band Carrier Aggregation (3DL/1UL) of Band 3, Band 3 and Band 8** | 264d? | 2014-06-16 A | 2015-06-15 A | 100% | 2014-06-13 | 2015-06-12 | 261d? |  | R4 | 6304h | 6304h | LTE_CA_B3_B3_B8 | 33 | CHTTL | Po-Han Hsieh (pohanhsieh@cht.com.tw) | Rel-13 | 64 | CA | LTE_CA_B3_B3_B8 |  |
| 1385 | 462.7.1 | Core part:LTE Advanced 3 Band Carrier Aggregation (3DL/1UL) of Band 3, Band 3 and Band 8 | 262d? | 2014-06-16 A | 2015-06-15 A | 100% | 2014-06-13 | 2015-06-12 | 261d? | finish no earlier than 2015-06-15 | R4 | 2096h | 2096h | LTE_CA_B3_B3_B8-Core | 33 | CHTTL | Po-Han Hsieh (pohanhsieh@cht.com.tw) | Rel-13 | 64 | CA | LTE_CA_B3_B3_B8-Core | RP-150536 |
| 1386 | 462.7.2 | Perf. Part:LTE Advanced 3 Band Carrier Aggregation (3DL/1UL) of Band 3, Band 3 and Band 8 | 262d? | 2014-06-18 A | 2015-06-15 A | 100% | 2014-06-13 | 2015-06-12 | 261d? | finish no earlier than 2015-06-15 | R4 | 2096h | 2096h | LTE_CA_B3_B3_B8-Perf | 33 | CHTTL | Po-Han Hsieh (pohanhsieh@cht.com.tw) | Rel-13 | 64 | CA | LTE_CA_B3_B3_B8-Perf | RP-150536 |
| 1387 | 462.8 | **LTE Advanced 3 Band Carrier Aggregation (3DL/1UL) of Band 41, Band 42 and Band 42** | 264d? | 2014-06-16 A | 2015-06-15 A | 100% | 2014-06-13 | 2014-12-05 | 126d? |  | R4 | 6304h | 6304h | LTE_CA_B41_B42_B42 | 33 | Huawei | leo.liuye@huawei.com | Rel-13 | 64 | CA | LTE_CA_B41_B42_B42 |  |
| 1388 | 462.8.1 | Core part:LTE Advanced 3 Band Carrier Aggregation (3DL/1UL) of Band 41, Band 42 and Band 42 | 262d? | 2014-06-16 A | 2015-06-15 A | 100% | 2014-06-13 | 2014-12-05 | 126d? | finish no earlier than 2015-06-15 | R4 | 2096h | 2096h | LTE_CA_B41_B42_B42-Core | 33 | Huawei | leo.liuye@huawei.com | Rel-13 | 64 | CA | LTE_CA_B41_B42_B42-Core | RP-150536 |
| 1389 | 462.8.2 | Perf. Part:LTE Advanced 3 Band Carrier Aggregation (3DL/1UL) of Band 41, Band 42 and Band 42 | 262d? | 2014-06-18 A | 2015-06-15 A | 100% | 2014-06-13 | 2014-12-05 | 126d? | finish no earlier than 2015-06-15 | R4 | 2096h | 2096h | LTE_CA_B41_B42_B42-Perf | 33 | Huawei | leo.liuye@huawei.com | Rel-13 | 64 | CA | LTE_CA_B41_B42_B42-Perf | RP-150536 |
| 1390 | 462.9 | **LTE Advanced inter-band Carrier Aggregation of Band 3 and Band 38** | 198d? | 2014-09-15 A | 2015-06-15 A | 100% | 2014-06-13 | 2015-03-13 | 196d? |  | R4 | 4752h | 4752h | LTE_CA_B3_B38 | 33 | Nokia Networks | iwajlo.angelow@nsn.com | Rel-13 | 65 | CA | LTE_CA_B3_B38 |  |
| 1391 | 462.9.1 | Core part:LTE Advanced inter-band Carrier Aggregation of Band 3 and Band 38 | 198d? | 2014-09-15 A | 2015-06-15 A | 100% | 2014-06-13 | 2015-03-13 | 196d? | finish no earlier than 2015-06-15 | R4 | 1584h | 1584h | LTE_CA_B3_B38-Core | 33 | Nokia Networks | iwajlo.angelow@nsn.com | Rel-13 | 65 | CA | LTE_CA_B3_B38-Core | RP-150536 |
| 1392 | 462.9.2 | Perf. Part:LTE Advanced inter-band Carrier Aggregation of Band 3 and Band 38 | 198d? | 2014-09-15 A | 2015-06-15 A | 100% | 2014-06-13 | 2015-03-13 | 196d? | finish no earlier than 2015-06-15 | R4 | 1584h | 1584h | LTE_CA_B3_B38-Perf | 33 | Nokia Networks | iwajlo.angelow@nsn.com | Rel-13 | 65 | CA | LTE_CA_B3_B38-Perf | RP-150536 |
| 1393 | 462.10 | **LTE Advanced inter-band Carrier Aggregation of Band 2 and Band 28** | 198d? | 2014-09-15 A | 2015-06-15 A | 100% | 2014-06-13 | 2015-03-13 | 196d? |  | R4 | 4752h | 4752h | LTE_CA_B2_B28 | 33 | Huawei | alf.ahlstrom@huawei.com | Rel-13 | 65 | CA | LTE_CA_B2_B28 |  |
| 1394 | 462.10.1 | Core part:LTE Advanced inter-band Carrier Aggregation of Band 2 and Band 28 | 198d? | 2014-09-15 A | 2015-06-15 A | 100% | 2014-06-13 | 2015-03-13 | 196d? | finish no earlier than 2015-06-15 | R4 | 1584h | 1584h | LTE_CA_B2_B28-Core | 33 | Huawei | alf.ahlstrom@huawei.com | Rel-13 | 65 | CA | LTE_CA_B2_B28-Core | RP-150536 |
| 1395 | 462.10.2 | Perf. Part:LTE Advanced inter-band Carrier Aggregation of Band 2 and Band 28 | 198d? | 2014-09-15 A | 2015-06-15 A | 100% | 2014-06-13 | 2015-03-13 | 196d? | finish no earlier than 2015-06-15 | R4 | 1584h | 1584h | LTE_CA_B2_B28-Perf | 33 | Huawei | alf.ahlstrom@huawei.com | Rel-13 | 65 | CA | LTE_CA_B2_B28-Perf | RP-150536 |
| 1396 | 462.11 | **LTE Advanced inter-band Carrier Aggregation of Band 4 and Band 28** | 198d? | 2014-09-15 A | 2015-06-15 A | 100% | 2014-06-13 | 2015-03-13 | 196d? |  | R4 | 4752h | 4752h | LTE_CA_B4_B28 | 33 | Huawei | alf.ahlstrom@huawei.com | Rel-13 | 65 | CA | LTE_CA_B4_B28 |  |
| 1397 | 462.11.1 | Core part:LTE Advanced inter-band Carrier Aggregation of Band 4 and Band 28 | 198d? | 2014-09-15 A | 2015-06-15 A | 100% | 2014-06-13 | 2015-03-13 | 196d? | finish no earlier than 2015-06-15 | R4 | 1584h | 1584h | LTE_CA_B4_B28-Core | 33 | Huawei | alf.ahlstrom@huawei.com | Rel-13 | 65 | CA | LTE_CA_B4_B28-Core | RP-150536 |
| 1398 | 462.11.2 | Perf. Part:LTE Advanced inter-band Carrier Aggregation of Band 4 and Band 28 | 198d? | 2014-09-15 A | 2015-06-15 A | 100% | 2014-06-13 | 2015-03-13 | 196d? | finish no earlier than 2015-06-15 | R4 | 1584h | 1584h | LTE_CA_B4_B28-Perf | 33 | Huawei | alf.ahlstrom@huawei.com | Rel-13 | 65 | CA | LTE_CA_B4_B28-Perf | RP-150536 |
| 1399 | 462.12 | **LTE Advanced inter-band Carrier Aggregation of Band 20 and Band 40** | 330d? | 2014-09-12 A | 2015-12-15 A | 100% | 2014-06-13 | 2015-03-13 | 196d? |  | R4 | 7912h | 7912h | LTE_CA_B20_B40 | 33 | Ericsson | imadur.rahman@ericsson.com | Rel-13 | 65 | CA | LTE_CA_B20_B40 |  |
| 1400 | 462.12.1 | Core part:LTE Advanced inter-band Carrier Aggregation of Band 20 and Band 40 | 330d? | 2014-09-12 A | 2015-12-15 A | 100% | 2014-06-13 | 2015-03-13 | 196d? | finish no earlier than 2015-12-15 | R4 | 2640h | 2640h | LTE_CA_B20_B40-Core | 33 | Ericsson | imadur.rahman@ericsson.com | Rel-13 | 65 | CA | LTE_CA_B20_B40-Core | RP-151131 |
| 1401 | 462.12.2 | Perf. Part:LTE Advanced inter-band Carrier Aggregation of Band 20 and Band 40 | 329d? | 2014-09-15 A | 2015-12-15 A | 100% | 2014-06-13 | 2015-03-13 | 196d? | finish no earlier than 2015-12-15 | R4 | 2632h | 2632h | LTE_CA_B20_B40-Perf | 33 | Ericsson | imadur.rahman@ericsson.com | Rel-13 | 65 | CA | LTE_CA_B20_B40-Perf | RP-151131 |
| 1402 | 462.13 | **LTE Advanced inter-band Carrier Aggregation of Band 1 and Band 40** | 329d? | 2014-09-15 A | 2015-12-15 A | 100% | 2014-06-13 | 2015-03-13 | 196d? |  | R4 | 7896h | 7896h | LTE_CA_B1_B40 | 33 | KT | ilwhan.kim@kt.com | Rel-13 | 65 | CA | LTE_CA_B1_B40 |  |
| 1403 | 462.13.1 | Core part:LTE Advanced inter-band Carrier Aggregation of Band 1 and Band 40 | 329d? | 2014-09-15 A | 2015-12-15 A | 100% | 2014-06-13 | 2015-03-13 | 196d? | finish no earlier than 2015-12-15 | R4 | 2632h | 2632h | LTE_CA_B1_B40-Core | 33 | KT | ilwhan.kim@kt.com | Rel-13 | 65 | CA | LTE_CA_B1_B40-Core | RP-151131 |
| 1404 | 462.13.2 | Perf. Part:LTE Advanced inter-band Carrier Aggregation of Band 1 and Band 40 | 329d? | 2014-09-15 A | 2015-12-15 A | 100% | 2014-06-13 | 2015-03-13 | 196d? | finish no earlier than 2015-12-15 | R4 | 2632h | 2632h | LTE_CA_B1_B40-Perf | 33 | KT | ilwhan.kim@kt.com | Rel-13 | 65 | CA | LTE_CA_B1_B40-Perf | RP-151131 |

Notes:
- 1381: Inter-band CA 3DL/1UL / Impacted TSs and TRs: LTE
- 1382: CD:Thu 12/03/15->Sun 15/03/15; Compl:0%->40%; Stat Rep: RP-141084->RP-141732 1st Apr 15: Compl:40%->99% 1st Apr 15: CD:Sun 15/03/15->Mon 15/06/15 1st Apr 15: Stat Rep: RP-141732->RP-150013 03/07/15: Compl:99%->100% 03/07/15: Stat Rep: RP-150013->RP-150536 / Impacted TSs and TRs: 36.101, 36.104, 36.133, 36.141, 36.307, generic new Rel-13 TR36.8xy [similar to Rel-12 TR 36.853 (3 Band CA with 1UL)]
- 1383: CD:Thu 18/06/15->Mon 15/06/15; Compl:0%->10%; Stat Rep: RP-141084->RP-141732 1st Apr 15: Compl:10%->99% 1st Apr 15: Stat Rep: RP-141732->RP-150013 03/07/15: Compl:99%->100% 03/07/15: Stat Rep: RP-150013->RP-150536 / Impacted TSs and TRs: 36.101, 36.104, 36.133, 36.141, 36.307
- 1384: Inter-band CA 3DL/1UL / Impacted TSs and TRs: LTE
- 1385: ; WID: RP-142043->RP-141832; Stat Rep: RP-141084->RP-141732 1st Apr 15: Compl:60%->99% 1st Apr 15: Stat Rep: RP-141732->RP-150013 03/07/15: Compl:99%->100% 03/07/15: WID: RP-141832->RP-150874 03/07/15: Stat Rep: RP-150013->RP-150536 / Impacted TSs and TRs: 36.101, 36.133, generic TR 36.853 (3 Band CA with 1UL)
- 1386: ; WID: RP-142043->RP-141832; Stat Rep: RP-141084->RP-141732 1st Apr 15: Compl:0%->99% 1st Apr 15: Stat Rep: RP-141732->RP-150013 03/07/15: Compl:99%->100% 03/07/15: WID: RP-141832->RP-150874 03/07/15: Stat Rep: RP-150013->RP-150536 / Impacted TSs and TRs: 36.307
- 1387: Inter-band CA 3DL/1UL / Impacted TSs and TRs: LTE
- 1388: CD:Thu 11/12/14->Sun 15/03/15; Compl:30%->50%; Stat Rep: RP-141084->RP-141732 1st Apr 15: Compl:50%->60% 1st Apr 15: CD:Sun 15/03/15->Mon 15/06/15 1st Apr 15: Stat Rep: RP-141732->RP-150013 03/07/15: Compl:60%->100% 03/07/15: Stat Rep: RP-150013->RP-15 / Impacted TSs and TRs: 36.101, 36.104, 36.133, generic TR 36.853 (3 Band CA with 1UL)
- 1389: CD:Thu 11/12/14->Sun 15/03/15; Compl:0%->0%; Stat Rep: RP-141084->RP-141732 1st Apr 15: Compl:0%->60% 1st Apr 15: CD:Sun 15/03/15->Mon 15/06/15 1st Apr 15: Stat Rep: RP-141732->RP-150013 03/07/15: Compl:60%->100% 03/07/15: Stat Rep: RP-150013->RP-150536 / Impacted TSs and TRs: 36.141, 36.307
- 1390: Inter-band CA 2DL/1UL / Impacted TSs and TRs: LTE
- 1391: CD:Thu 11/12/14->Sun 15/03/15; Compl:0%->90%; Stat Rep: -->RP-141732 1st Apr 15: CD:Sun 15/03/15->Mon 15/06/15 1st Apr 15: Stat Rep: RP-141732->RP-150013 03/07/15: Compl:90%->100% 03/07/15: WID: RP-141129->RP-150717 03/07/15: Stat Rep: RP-150013->RP-15 / Impacted TSs and TRs: 36.101, 36.104, New TR 36.8xx
- 1392: CD:Thu 11/12/14->Sun 15/03/15; Compl:0%->90%; Stat Rep: -->RP-141732 1st Apr 15: CD:Sun 15/03/15->Mon 15/06/15 1st Apr 15: Stat Rep: RP-141732->RP-150013 03/07/15: Compl:90%->100% 03/07/15: WID: RP-141129->RP-150717 03/07/15: Stat Rep: RP-150013->RP-15 / Impacted TSs and TRs: 36.141, 36.307
- 1393: Inter-band CA 2DL/1UL / Impacted TSs and TRs: LTE
- 1394: CD:Fri 11/12/15->Sun 15/03/15; Compl:0%->50%; Stat Rep: -->RP-141732 1st Apr 15: Compl:50%->99% 1st Apr 15: CD:Sun 15/03/15->Mon 15/06/15 1st Apr 15: Stat Rep: RP-141732->RP-150013 03/07/15: Compl:99%->100% 03/07/15: Stat Rep: RP-150013->RP-150536 / Impacted TSs and TRs: 36.101, 36.104, New TR 36.8xx
- 1395: CD:Thu 12/03/15->Sun 15/03/15; Compl:0%->0%; Stat Rep: -->RP-141732 1st Apr 15: Compl:0%->99% 1st Apr 15: CD:Sun 15/03/15->Mon 15/06/15 1st Apr 15: Stat Rep: RP-141732->RP-150013 03/07/15: Compl:99%->100% 03/07/15: Stat Rep: RP-150013->RP-150536 / Impacted TSs and TRs: 36.141, 36.307
- 1396: Inter-band CA 2DL/1UL / Impacted TSs and TRs: LTE
- 1397: CD:Fri 11/12/15->Sun 15/03/15; Compl:0%->35%; Stat Rep: -->RP-141732 1st Apr 15: Compl:35%->99% 1st Apr 15: CD:Sun 15/03/15->Mon 15/06/15 1st Apr 15: Stat Rep: RP-141732->RP-150013 03/07/15: Compl:99%->100% 03/07/15: Stat Rep: RP-150013->RP-150536 / Impacted TSs and TRs: 36.101, 36.104, New TR 36.8xx
- 1398: CD:Thu 12/03/15->Sun 15/03/15; Compl:0%->0%; Stat Rep: -->RP-141732 1st Apr 15: Compl:0%->99% 1st Apr 15: CD:Sun 15/03/15->Mon 15/06/15 1st Apr 15: Stat Rep: RP-141732->RP-150013 03/07/15: Compl:99%->100% 03/07/15: Stat Rep: RP-150013->RP-150536 / Impacted TSs and TRs: 36.141, 36.307
- 1399: Inter-band CA 2DL/1UL / Impacted TSs and TRs: LTE
- 1400: CD:Wed 11/03/15->Sun 15/03/15; Compl:0%->30%; Stat Rep: -->RP-141732 1st Apr 15: Compl:30%->70% 1st Apr 15: CD:Sun 15/03/15->Mon 15/06/15 1st Apr 15: Stat Rep: RP-141732->RP-150013 03/07/15: CD:Mon 15/06/15->Tue 15/09/15 03/07/15: Stat Rep: RP-150013-> / Impacted TSs and TRs: 36.101, 36.104, 36.133, New TR 36.8xx
- 1401: CD:Thu 12/03/15->Sun 15/03/15; Compl:0%->0%; Stat Rep: -->RP-141732 1st Apr 15: CD:Sun 15/03/15->Mon 15/06/15 1st Apr 15: Stat Rep: RP-141732->RP-150013 03/07/15: Compl:0%->70% 03/07/15: CD:Mon 15/06/15->Tue 15/09/15 03/07/15: Stat Rep: RP-150013->RP-1 / Impacted TSs and TRs: 36.141, 36.307
- 1402: Inter-band CA 2DL/1UL / Impacted TSs and TRs: LTE
- 1403: CD:Fri 12/06/15->Mon 15/06/15; Compl:0%->70%; Stat Rep: -->RP-141732 1st Apr 15: Compl:70%->80% 1st Apr 15: Stat Rep: RP-141732->RP-150013 03/07/15: Compl:80%->70% 03/07/15: CD:Mon 15/06/15->Tue 15/12/15 03/07/15: Stat Rep: RP-150013->RP-150536 29/09/1 / Impacted TSs and TRs: 36.101, 36.104, 36.133, New TR 36.8xx
- 1404: CD:Fri 11/12/15->Mon 15/06/15; Compl:0%->70%; Stat Rep: -->RP-141732 1st Apr 15: Compl:70%->80% 1st Apr 15: Stat Rep: RP-141732->RP-150013 03/07/15: Compl:80%->70% 03/07/15: CD:Mon 15/06/15->Tue 15/12/15 03/07/15: Stat Rep: RP-150013->RP-150536 29/09/1 / Impacted TSs and TRs: 36.141, 36.307

| ID | WBS | Task | Duration | Start | Finish | Complete | Baseline start | Baseline finish | Baseline duration | Constraint | Resources | Work | Actual work | Acronym | PCG approved | WI rapporteur name | WI rapporteur e-mail | Release | TSG approved | Special Focus Doc | Acronym_3GU_Export | Status Report |
| --- | --- | --- | --- | --- | --- | --- | --- | --- | --- | --- | --- | --- | --- | --- | --- | --- | --- | --- | --- | --- | --- | --- |
| 1405 | 462.14 | **LTE Advanced inter-band Carrier Aggregation of Band 3 and Band 40** | 198d? | 2014-09-15 A | 2015-06-15 A | 100% | 2014-06-13 | 2015-03-13 | 196d? |  | R4 | 4752h | 4752h | LTE_CA_B3_B40 | 33 | KT | Chungwoo HWANG (cwhwang@kt.com) | Rel-13 | 65 | CA | LTE_CA_B3_B40 |  |
| 1406 | 462.14.1 | Core part:LTE Advanced inter-band Carrier Aggregation of Band 3 and Band 40 | 198d? | 2014-09-15 A | 2015-06-15 A | 100% | 2014-06-13 | 2015-03-13 | 196d? | finish no earlier than 2015-06-15 | R4 | 1584h | 1584h | LTE_CA_B3_B40-Core | 33 | KT | Chungwoo HWANG (cwhwang@kt.com) | Rel-13 | 65 | CA | LTE_CA_B3_B40-Core | RP-150536 |
| 1407 | 462.14.2 | Perf. Part:LTE Advanced inter-band Carrier Aggregation of Band 3 and Band 40 | 198d? | 2014-09-15 A | 2015-06-15 A | 100% | 2014-06-13 | 2015-03-13 | 196d? | finish no earlier than 2015-06-15 | R4 | 1584h | 1584h | LTE_CA_B3_B40-Perf | 33 | KT | Chungwoo HWANG (cwhwang@kt.com) | Rel-13 | 65 | CA | LTE_CA_B3_B40-Perf | RP-150536 |
| 1408 | 462.15 | **LTE Advanced inter-band Carrier Aggregation of Band 20 and Band 31** | 198d? | 2014-09-15 A | 2015-06-15 A | 100% | 2014-06-13 | 2015-03-13 | 196d? |  | R4 | 4752h | 4752h | LTE_CA_B20_B31 | 33 | Huawei | Liu Liehai (liuliehai@huawei.com) | Rel-13 | 65 | CA | LTE_CA_B20_B31 |  |
| 1409 | 462.15.1 | Core part:LTE Advanced inter-band Carrier Aggregation of Band 20 and Band 31 | 198d? | 2014-09-15 A | 2015-06-15 A | 100% | 2014-06-13 | 2015-03-13 | 196d? | finish no earlier than 2015-06-15 | R4 | 1584h | 1584h | LTE_CA_B20_B31-Core | 33 | Huawei | Liu Liehai (liuliehai@huawei.com) | Rel-13 | 65 | CA | LTE_CA_B20_B31-Core | RP-150536 |
| 1410 | 462.15.2 | Perf. Part:LTE Advanced inter-band Carrier Aggregation of Band 20 and Band 31 | 198d? | 2014-09-15 A | 2015-06-15 A | 100% | 2014-06-13 | 2015-03-13 | 196d? | finish no earlier than 2015-06-15 | R4 | 1584h | 1584h | LTE_CA_B20_B31-Perf | 33 | Huawei | Liu Liehai (liuliehai@huawei.com) | Rel-13 | 65 | CA | LTE_CA_B20_B31-Perf | RP-150536 |
| 1411 | 462.16 | **LTE Advanced inter-band Carrier Aggregation of Band 3 and Band 31** | 198d? | 2014-09-15 A | 2015-06-15 A | 100% | 2014-06-13 | 2015-03-13 | 196d? |  | R4 | 4752h | 4752h | LTE_CA_B3_B31 | 33 | Huawei | Liu Liehai (liuliehai@huawei.com) | Rel-13 | 65 | CA | LTE_CA_B3_B31 |  |
| 1412 | 462.16.1 | Core part:LTE Advanced inter-band Carrier Aggregation of Band 3 and Band 31 | 198d? | 2014-09-15 A | 2015-06-15 A | 100% | 2014-06-13 | 2015-03-13 | 196d? | finish no earlier than 2015-06-15 | R4 | 1584h | 1584h | LTE_CA_B3_B31-Core | 33 | Huawei | Liu Liehai (liuliehai@huawei.com) | Rel-13 | 65 | CA | LTE_CA_B3_B31-Core | RP-150536 |
| 1413 | 462.16.2 | Perf. Part:LTE Advanced inter-band Carrier Aggregation of Band 3 and Band 31 | 198d? | 2014-09-15 A | 2015-06-15 A | 100% | 2014-06-13 | 2015-03-13 | 196d? | finish no earlier than 2015-06-15 | R4 | 1584h | 1584h | LTE_CA_B3_B31-Perf | 33 | Huawei | Liu Liehai (liuliehai@huawei.com) | Rel-13 | 65 | CA | LTE_CA_B3_B31-Perf | RP-150536 |
| 1414 | 462.17 | **LTE Advanced inter-band Carrier Aggregation of Band 5 and Band 40** | 199d? | 2014-09-12 A | 2015-06-15 A | 100% | 2014-06-13 | 2015-03-13 | 196d? |  | R4 | 4768h | 4768h | LTE_CA_B5_B40 | 33 | SK Telecom | haesung.park@sk.com | Rel-13 | 65 | CA | LTE_CA_B5_B40 |  |
| 1415 | 462.17.1 | Core part:LTE Advanced inter-band Carrier Aggregation of Band 5 and Band 40 | 199d? | 2014-09-12 A | 2015-06-15 A | 100% | 2014-06-13 | 2015-03-13 | 196d? | finish no earlier than 2015-06-15 | R4 | 1592h | 1592h | LTE_CA_B5_B40-Core | 33 | SK Telecom | haesung.park@sk.com | Rel-13 | 65 | CA | LTE_CA_B5_B40-Core | RP-150536 |
| 1416 | 462.17.2 | Perf. Part:LTE Advanced inter-band Carrier Aggregation of Band 5 and Band 40 | 198d? | 2014-09-15 A | 2015-06-15 A | 100% | 2014-06-13 | 2015-03-13 | 196d? | finish no earlier than 2015-06-15 | R4 | 1584h | 1584h | LTE_CA_B5_B40-Perf | 33 | SK Telecom | haesung.park@sk.com | Rel-13 | 65 | CA | LTE_CA_B5_B40-Perf | RP-150536 |
| 1417 | 462.18 | **LTE Advanced intra-band contiguous Carrier Aggregation in Band 42 for 3DL** | 198d? | 2014-09-15 A | 2015-06-15 A | 100% | 2014-06-13 | 2015-03-13 | 196d? |  | R4 | 4752h | 4752h | LTE_CA_C_B42_3DL | 33 | CATT | Yuexia Song (songyuexia@catt.cn) | Rel-13 | 65 | CA | LTE_CA_C_B42_3DL |  |
| 1418 | 462.18.1 | Core part: LTE Advanced intra-band contiguous Carrier Aggregation in Band 42 for 3DL | 198d? | 2014-09-15 A | 2015-06-15 A | 100% | 2014-06-13 | 2015-03-13 | 196d? | finish no earlier than 2015-06-15 | R4 | 1584h | 1584h | LTE_CA_C_B42_3DL-Core | 33 | CATT | Yuexia Song (songyuexia@catt.cn) | Rel-13 | 65 | CA | LTE_CA_C_B42_3DL-Core | RP-150536 |
| 1419 | 462.18.2 | Perf. Part: LTE Advanced intra-band contiguous Carrier Aggregation in Band 42 for 3DL | 198d? | 2014-09-15 A | 2015-06-15 A | 100% | 2014-06-13 | 2015-03-13 | 196d? | finish no earlier than 2015-06-15 | R4 | 1584h | 1584h | LTE_CA_C_B42_3DL-Perf | 33 | CATT | Yuexia Song (songyuexia@catt.cn) | Rel-13 | 65 | CA | LTE_CA_C_B42_3DL-Perf | RP-150536 |
| 1420 | 462.19 | **LTE Advanced 3 Band Carrier Aggregation (3DL/1UL) of Band 8, Band 41 and Band 41** | 199d? | 2014-09-12 A | 2015-06-15 A | 100% | 2014-06-13 | 2015-03-13 | 196d? |  | R4 | 4768h | 4768h | LTE_CA_B8_B41_B41 | 33 | China Mobile | PAN, Qun (panqun@chinamobile.com) | Rel-13 | 65 | CA | LTE_CA_B8_B41_B41 |  |
| 1421 | 462.19.1 | Core part:LTE Advanced 3 Band Carrier Aggregation (3DL/1UL) of Band 8, Band 41 and Band 41 | 198d? | 2014-09-15 A | 2015-06-15 A | 100% | 2014-06-13 | 2015-03-13 | 196d? | finish no earlier than 2015-06-15 | R4 | 1584h | 1584h | LTE_CA_B8_B41_B41-Core | 33 | China Mobile | PAN, Qun (panqun@chinamobile.com) | Rel-13 | 65 | CA | LTE_CA_B8_B41_B41-Core | RP-150536 |
| 1422 | 462.19.2 | Perf. Part:LTE Advanced 3 Band Carrier Aggregation (3DL/1UL) of Band 8, Band 41 and Band 41 | 199d? | 2014-09-12 A | 2015-06-15 A | 100% | 2014-06-13 | 2015-03-13 | 196d? | finish no earlier than 2015-06-15 | R4 | 1592h | 1592h | LTE_CA_B8_B41_B41-Perf | 33 | China Mobile | PAN, Qun (panqun@chinamobile.com) | Rel-13 | 65 | CA | LTE_CA_B8_B41_B41-Perf | RP-150536 |
| 1423 | 462.20 | **LTE Advanced 3 Band Carrier Aggregation (3DL/1UL) of Band 38, Band 40 and Band 40** | 198d? | 2014-09-15 A | 2015-06-15 A | 100% | 2014-06-13 | 2015-03-13 | 196d? |  | R4 | 4752h | 4752h | LTE_CA_B38_B40_B40 | 33 | Samsung | xutao.zhou@samsung.com | Rel-13 | 65 | CA | LTE_CA_B38_B40_B40 |  |
| 1424 | 462.20.1 | Core part:LTE Advanced 3 Band Carrier Aggregation (3DL/1UL) of Band 38, Band 40 and Band 40 | 198d? | 2014-09-15 A | 2015-06-15 A | 100% | 2014-06-13 | 2015-03-13 | 196d? | finish no earlier than 2015-06-15 | R4 | 1584h | 1584h | LTE_CA_B38_B40_B40-Core | 33 | Samsung | xutao.zhou@samsung.com | Rel-13 | 65 | CA | LTE_CA_B38_B40_B40-Core | RP-150536 |
| 1425 | 462.20.2 | Perf. Part:LTE Advanced 3 Band Carrier Aggregation (3DL/1UL) of Band 38, Band 40 and Band 40 | 198d? | 2014-09-15 A | 2015-06-15 A | 100% | 2014-06-13 | 2015-03-13 | 196d? | finish no earlier than 2015-06-15 | R4 | 1584h | 1584h | LTE_CA_B38_B40_B40-Perf | 33 | Samsung | xutao.zhou@samsung.com | Rel-13 | 65 | CA | LTE_CA_B38_B40_B40-Perf | RP-150536 |
| 1426 | 462.21 | **LTE Advanced 3 Band Carrier Aggregation (3DL/1UL) of Band 2, Band 5 and Band 29** | 198d? | 2014-09-15 A | 2015-06-15 A | 100% | 2014-06-13 | 2015-03-13 | 196d? |  | R4 | 4752h | 4752h | LTE_CA_B2_B5_B29 | 33 | Huawei | SHAN Huiping (shanhuiping@huawei.com) | Rel-13 | 65 | CA | LTE_CA_B2_B5_B29 |  |
| 1427 | 462.21.1 | Core part:LTE Advanced 3 Band Carrier Aggregation (3DL/1UL) of Band 2, Band 5 and Band 29 | 198d? | 2014-09-15 A | 2015-06-15 A | 100% | 2014-06-13 | 2015-03-13 | 196d? | finish no earlier than 2015-06-15 | R4 | 1584h | 1584h | LTE_CA_B2_B5_B29-Core | 33 | Huawei | SHAN Huiping (shanhuiping@huawei.com) | Rel-13 | 65 | CA | LTE_CA_B2_B5_B29-Core | RP-150536 |
| 1428 | 462.21.2 | Perf. Part:LTE Advanced 3 Band Carrier Aggregation (3DL/1UL) of Band 2, Band 5 and Band 29 | 198d? | 2014-09-15 A | 2015-06-15 A | 100% | 2014-06-13 | 2015-03-13 | 196d? | finish no earlier than 2015-06-15 | R4 | 1584h | 1584h | LTE_CA_B2_B5_B29-Perf | 33 | Huawei | SHAN Huiping (shanhuiping@huawei.com) | Rel-13 | 65 | CA | LTE_CA_B2_B5_B29-Perf | RP-150536 |

Notes:
- 1405: Inter-band CA 2DL/1UL / Impacted TSs and TRs: LTE
- 1406: CD:Fri 11/12/15->Mon 15/06/15; Compl:0%->70%; Stat Rep: -->RP-141732 1st Apr 15: Compl:70%->80% 1st Apr 15: Stat Rep: RP-141732->RP-150013 03/07/15: Compl:80%->100% 03/07/15: WID: RP-141674->RP-150832 03/07/15: Stat Rep: RP-150013->RP-150536 / Impacted TSs and TRs: 36.101, 36.104, 36.133, New TR 36.8xx
- 1407: CD:Fri 12/06/15->Mon 15/06/15; Compl:0%->70%; Stat Rep: -->RP-141732 1st Apr 15: Compl:70%->80% 1st Apr 15: Stat Rep: RP-141732->RP-150013 03/07/15: Compl:80%->100% 03/07/15: WID: RP-141674->RP-150832 03/07/15: Stat Rep: RP-150013->RP-150536 / Impacted TSs and TRs: 36.141, 36.307
- 1408: Inter-band CA 2DL/1UL / Impacted TSs and TRs: LTE
- 1409: ; WID: RP-142043->RP-142007; Stat Rep: -->RP-141732 1st Apr 15: Compl:75%->99% 1st Apr 15: CD:Sun 15/03/15->Mon 15/06/15 1st Apr 15: Stat Rep: RP-141732->RP-150013 03/07/15: Compl:99%->100% 03/07/15: Stat Rep: RP-150013->RP-150536 / Impacted TSs and TRs: 36.101, 36.104, New TR 36.8xx
- 1410: ; WID: RP-142043->RP-142007; Stat Rep: -->RP-141732 1st Apr 15: Compl:0%->99% 1st Apr 15: CD:Sun 15/03/15->Mon 15/06/15 1st Apr 15: Stat Rep: RP-141732->RP-150013 03/07/15: Compl:99%->100% 03/07/15: Stat Rep: RP-150013->RP-150536 / Impacted TSs and TRs: 36.141, 36.307
- 1411: Inter-band CA 2DL/1UL / Impacted TSs and TRs: LTE
- 1412: CD:Fri 11/12/15->Sun 15/03/15; Compl:0%->50%; Stat Rep: -->RP-141732 1st Apr 15: Compl:50%->75% 1st Apr 15: CD:Sun 15/03/15->Mon 15/06/15 1st Apr 15: WID: RP-141337->RP-150318 1st Apr 15: Stat Rep: RP-141732->RP-150013 03/07/15: Compl:75%->100% 03/07/1 / Impacted TSs and TRs: 36.101, 36.104, New TR 36.8xx
- 1413: CD:Thu 12/03/15->Sun 15/03/15; Compl:0%->0%; Stat Rep: -->RP-141732 1st Apr 15: CD:Sun 15/03/15->Mon 15/06/15 1st Apr 15: WID: RP-141337->RP-150318 1st Apr 15: Stat Rep: RP-141732->RP-150013 03/07/15: Compl:0%->100% 03/07/15: Stat Rep: RP-150013->RP-15 / Impacted TSs and TRs: 36.141, 36.307
- 1414: Inter-band CA 2DL/1UL / Impacted TSs and TRs: LTE
- 1415: ; WID: RP-142043->RP-141888; Stat Rep: -->RP-141732 1st Apr 15: Compl:0%->80% 1st Apr 15: WID: RP-141888->RP-150285 1st Apr 15: Stat Rep: RP-141732->RP-150013 03/07/15: Compl:80%->100% 03/07/15: Stat Rep: RP-150013->RP-150536 / Impacted TSs and TRs: 36.101, 36.104, New TR 36.8xx
- 1416: ; WID: RP-142043->RP-141888; Stat Rep: -->RP-141732 1st Apr 15: Compl:0%->80% 1st Apr 15: WID: RP-141888->RP-150285 1st Apr 15: Stat Rep: RP-141732->RP-150013 03/07/15: Compl:80%->100% 03/07/15: Stat Rep: RP-150013->RP-150536 / Impacted TSs and TRs: 36.141, 36.307
- 1417: Intra-band contig. CA 3DL / Impacted TSs and TRs: LTE
- 1418: CD:Fri 12/06/15->Mon 15/06/15; Compl:0%->70%; Stat Rep: -->RP-141732 1st Apr 15: Compl:70%->99% 1st Apr 15: WID: RP-141677->RP-150319 1st Apr 15: Stat Rep: RP-141732->RP-150013 03/07/15: Compl:99%->100% 03/07/15: WID: RP-150319->RP-151027 03/07/15: Sta / Impacted TSs and TRs: 36.101, 36.104, 36.133, New TR 36.833-5-42
- 1419: CD:Fri 12/06/15->Mon 15/06/15; Compl:0%->0%; Stat Rep: -->RP-141732 1st Apr 15: Compl:0%->99% 1st Apr 15: WID: RP-141677->RP-150319 1st Apr 15: Stat Rep: RP-141732->RP-150013 03/07/15: Compl:99%->100% 03/07/15: WID: RP-150319->RP-151027 03/07/15: Stat / Impacted TSs and TRs: 36.141, 36.307
- 1420: Inter-band CA 3DL/1UL / Impacted TSs and TRs: LTE
- 1421: ; WID: RP-142043->RP-141845; Stat Rep: -->RP-141732 1st Apr 15: Compl:80%->99% 1st Apr 15: CD:Sun 15/03/15->Mon 15/06/15 1st Apr 15: Stat Rep: RP-141732->RP-150013 03/07/15: Compl:99%->100% 03/07/15: Stat Rep: RP-150013->RP-150536 / Impacted TSs and TRs: 36.101, 36.104, 36.133, New TR 36.8xx
- 1422: ; WID: RP-142043->RP-141845; Stat Rep: -->RP-141732 1st Apr 15: Compl:0%->99% 1st Apr 15: CD:Sun 15/03/15->Mon 15/06/15 1st Apr 15: Stat Rep: RP-141732->RP-150013 03/07/15: Compl:99%->100% 03/07/15: Stat Rep: RP-150013->RP-150536 / Impacted TSs and TRs: 36.141, 36.307
- 1423: Inter-band CA 3DL/1UL / Impacted TSs and TRs: LTE
- 1424: CD:Fri 12/06/15->Mon 15/06/15; Compl:0%->0%; Stat Rep: -->RP-141732 1st Apr 15: Compl:0%->70% 1st Apr 15: Stat Rep: RP-141732->RP-150013 03/07/15: Compl:70%->100% 03/07/15: Stat Rep: RP-150013->RP-150536 / Impacted TSs and TRs: 36.101, 36.104, 36.133, New TR 36.8xx
- 1425: CD:Fri 12/06/15->Mon 15/06/15; Compl:0%->0%; Stat Rep: -->RP-141732 1st Apr 15: Compl:0%->70% 1st Apr 15: Stat Rep: RP-141732->RP-150013 03/07/15: Compl:70%->100% 03/07/15: Stat Rep: RP-150013->RP-150536 / Impacted TSs and TRs: 36.141, 36.307
- 1426: Inter-band CA 3DL/1UL / Impacted TSs and TRs: LTE
- 1427: CD:Fri 11/12/15->Mon 15/06/15; Compl:0%->50%; Stat Rep: -->RP-141732 1st Apr 15: Compl:50%->99% 1st Apr 15: Stat Rep: RP-141732->RP-150013 03/07/15: Compl:99%->100% 03/07/15: Stat Rep: RP-150013->RP-150536 / Impacted TSs and TRs: 36.101, 36.104, 36.133, New TR 36.8xy (inter-band CA 2DL/1UL (introduce CA_B5-B29), New TR 36.8xz (inter-band CA 3DL/1UL)
- 1428: CD:Fri 12/06/15->Mon 15/06/15; Compl:0%->0%; Stat Rep: -->RP-141732 1st Apr 15: Compl:0%->99% 1st Apr 15: Stat Rep: RP-141732->RP-150013 03/07/15: Compl:99%->100% 03/07/15: Stat Rep: RP-150013->RP-150536 / Impacted TSs and TRs: 36.141, 36.307

| ID | WBS | Task | Duration | Start | Finish | Complete | Remaining | Total slack | Constraint | Resources | Work | Actual work | Acronym | PCG approved | WI rapporteur name | WI rapporteur e-mail | Release | TSG approved | Status Report |
| --- | --- | --- | --- | --- | --- | --- | --- | --- | --- | --- | --- | --- | --- | --- | --- | --- | --- | --- | --- |
| 1429 | 462.22 | **LTE Carrier Aggregation Enhancement Beyond 5 Carriers** | 850d? | 2014-12-15 A | 2018-03-15 | 70% | 254.19d? | 4627d |  |  | 8368h | 5865.6h | LTE_CA_enh_b5C | 34 | Nokia Networks | Nokia | Rel-13 | 66 |  |
| 1430 | 462.22.1 | Core part: LTE Carrier Aggregation Enhancement Beyond 5 Carriers | 262d? | 2014-12-15 A | 2015-12-15 A | 100% |  |  | finish no earlier than 2015-12-15 | R1 | 2096h | 2096h | LTE_CA_enh_b5C-Core | 34 | Nokia Networks | Nokia | Rel-13 | 66 | RP-151285 |
| 1431 | 462.22.2 | Perf. part: LTE Carrier Aggregation Enhancement Beyond 5 Carriers | 393d? | 2014-12-15 A | 2016-06-15 A | 100% |  |  | finish no earlier than 2016-06-15 | R4 | 3144h | 3144h | LTE_CA_enh_b5C-Perf | 34 | Nokia Networks | Nokia | Rel-13 | 66 | RP-151285 |
| 1432 | 462.22.3 | UE Conformance Test Aspects - LTE Carrier Aggregation Enhancement Beyond 5 Carriers: PUCCH on Scell | 391d? | 2016-09-15 A | 2018-03-15 | 20% | 312.8d? | 4627d | finish no earlier than 2018-03-15 | R5 | 3128h | 625.6h | LTE_CA_enh_b5C_PUCCH-UEConTest |  | Huawei |  | Rel-13 | 66 |  |
| 1433 | 462.23 | **HSPA Dual-Band UL carrier aggregation** | 327d? | 2014-12-15 A | 2016-03-15 A | 100% |  |  |  | R4 | 7328h | 7328h | HSUPA_DB_MC | 34 | Qualcomm | Qualcomm | Rel-13 | 66 |  |
| 1434 | 462.23.1 | Core part: HSPA Dual-Band UL carrier aggregation | 262d? | 2014-12-15 A | 2015-12-15 A | 100% |  |  | finish no earlier than 2015-12-15 | R4 | 2096h | 2096h | HSUPA_DB_MC-Core | 34 | Qualcomm | Qualcomm | Rel-13 | 66 | RP-151281 |
| 1435 | 462.23.2 | Perf. part: HSPA Dual-Band UL carrier aggregation | 327d? | 2014-12-15 A | 2016-03-15 A | 100% |  |  | finish no earlier than 2016-03-15 | R4 | 2616h | 2616h | HSUPA_DB_MC-Perf | 34 | Qualcomm | Qualcomm | Rel-13 | 66 | RP-151281 |
| 1436 | 462.24 | **LTE Advanced inter-band Carrier Aggregation of Band 25 and Band 26** | 131d? | 2014-12-15 A | 2015-06-15 A | 100% |  |  |  | R4 | 3144h | 3144h | LTE_CA_B25_B26 | 34 | Sprint | Sprint | Rel-13 | 66 |  |
| 1437 | 462.24.1 | Core part:LTE Advanced inter-band Carrier Aggregation of Band 25 and Band 26 | 131d? | 2014-12-15 A | 2015-06-15 A | 100% |  |  | finish no earlier than 2015-06-15 | R4 | 1048h | 1048h | LTE_CA_B25_B26-Core | 34 | Sprint | Sprint | Rel-13 | 66 | RP-150536 |
| 1438 | 462.24.2 | Perf. part:LTE Advanced inter-band Carrier Aggregation of Band 25 and Band 26 | 131d? | 2014-12-15 A | 2015-06-15 A | 100% |  |  | finish no earlier than 2015-06-15 | R4 | 1048h | 1048h | LTE_CA_B25_B26-Perf | 34 | Sprint | Sprint | Rel-13 | 66 | RP-150536 |
| 1439 | 462.25 | **LTE Advanced inter-band Carrier Aggregation of Band 3 and Band 41** | 262d? | 2014-12-15 A | 2015-12-15 A | 100% |  |  |  | R4 | 6288h | 6288h | LTE_CA_B3_B41 | 34 | China Telecom | China Telecom | Rel-13 | 66 |  |
| 1440 | 462.25.1 | Core part:LTE Advanced inter-band Carrier Aggregation of Band 3 and Band 41 | 262d? | 2014-12-15 A | 2015-12-15 A | 100% |  |  | finish no earlier than 2015-12-15 | R4 | 2096h | 2096h | LTE_CA_B3_B41-Core | 34 | China Telecom | China Telecom | Rel-13 | 66 | RP-151131 |
| 1441 | 462.25.2 | Perf. part:LTE Advanced inter-band Carrier Aggregation of Band 3 and Band 41 | 262d? | 2014-12-15 A | 2015-12-15 A | 100% |  |  | finish no earlier than 2015-12-15 | R4 | 2096h | 2096h | LTE_CA_B3_B41-Perf | 34 | China Telecom | China Telecom | Rel-13 | 66 | RP-151131 |
| 1442 | 462.26 | **LTE Advanced 3 band Carrier Aggregation (3DL/1UL) of Band 1, Band 3 and Band 3** | 197d? | 2014-12-15 A | 2015-09-15 A | 100% |  |  |  | R4 | 4728h | 4728h | LTE_CA_B1_B3_B3 | 34 | China Unicom | China Unicom | Rel-13 | 66 |  |
| 1443 | 462.26.1 | Core part:LTE Advanced 3 band Carrier Aggregation (3DL/1UL) of Band 1, Band 3 and Band 3 | 197d? | 2014-12-15 A | 2015-09-15 A | 100% |  |  | finish no earlier than 2015-09-15 | R4 | 1576h | 1576h | LTE_CA_B1_B3_B3-Core | 34 | China Unicom | China Unicom | Rel-13 | 66 | RP-151131 |
| 1444 | 462.26.2 | Perf. part:LTE Advanced 3 band Carrier Aggregation (3DL/1UL) of Band 1, Band 3 and Band 3 | 197d? | 2014-12-15 A | 2015-09-15 A | 100% |  |  | finish no earlier than 2015-09-15 | R4 | 1576h | 1576h | LTE_CA_B1_B3_B3-Perf | 34 | China Unicom | China Unicom | Rel-13 | 66 | RP-151131 |
| 1445 | 462.27 | **LTE Advanced 3 Band Carrier Aggregation (3DL/1UL) of Band 1, Band 19 and Band 28** | 197d? | 2014-12-15 A | 2015-09-15 A | 100% |  |  |  | R4 | 4728h | 4728h | LTE_CA_B1_B19_B28 | 34 | NTT DOCOMO | NTT DOCOMO | Rel-13 | 66 |  |
| 1446 | 462.27.1 | Core part:LTE Advanced 3 Band Carrier Aggregation (3DL/1UL) of Band 1, Band 19 and Band 28 | 197d? | 2014-12-15 A | 2015-09-15 A | 100% |  |  | finish no earlier than 2015-09-15 | R4 | 1576h | 1576h | LTE_CA_B1_B19_B28-Core | 34 | NTT DOCOMO | NTT DOCOMO | Rel-13 | 66 | RP-151131 |
| 1447 | 462.27.2 | Perf. part:LTE Advanced 3 Band Carrier Aggregation (3DL/1UL) of Band 1, Band 19 and Band 28 | 197d? | 2014-12-15 A | 2015-09-15 A | 100% |  |  | finish no earlier than 2015-09-15 | R4 | 1576h | 1576h | LTE_CA_B1_B19_B28-Perf | 34 | NTT DOCOMO | NTT DOCOMO | Rel-13 | 66 | RP-151131 |
| 1448 | 462.28 | **LTE Advanced 3 Band Carrier Aggregation (3DL/1UL) of Band 21, Band 42 and Band 42** | 131d? | 2014-12-15 A | 2015-06-15 A | 100% |  |  |  | R4 | 3144h | 3144h | LTE_CA_B21_B42_B42 | 34 | NTT DOCOMO | NTT DOCOMO | Rel-13 | 66 |  |
| 1449 | 462.28.1 | Core part:LTE Advanced 3 Band Carrier Aggregation (3DL/1UL) of Band 21, Band 42 and Band 42 | 131d? | 2014-12-15 A | 2015-06-15 A | 100% |  |  | finish no earlier than 2015-06-15 | R4 | 1048h | 1048h | LTE_CA_B21_B42_B42-Core | 34 | NTT DOCOMO | NTT DOCOMO | Rel-13 | 66 | RP-150536 |
| 1450 | 462.28.2 | Perf. part:LTE Advanced 3 Band Carrier Aggregation (3DL/1UL) of Band 21, Band 42 and Band 42 | 131d? | 2014-12-15 A | 2015-06-15 A | 100% |  |  | finish no earlier than 2015-06-15 | R4 | 1048h | 1048h | LTE_CA_B21_B42_B42-Perf | 34 | NTT DOCOMO | NTT DOCOMO | Rel-13 | 66 | RP-150536 |
| 1451 | 462.29 | **LTE Advanced 3 Band Carrier Aggregation (3DL/1UL) of Band 7, Band 40 and Band 40** | 197d? | 2014-12-15 A | 2015-09-15 A | 100% |  |  |  | R4 | 4728h | 4728h | LTE_CA_B7_B40_B40 | 34 | ZTE | ZTE | Rel-13 | 66 |  |
| 1452 | 462.29.1 | Core part:LTE Advanced 3 Band Carrier Aggregation (3DL/1UL) of Band 7, Band 40 and Band 40 | 197d? | 2014-12-15 A | 2015-09-15 A | 100% |  |  | finish no earlier than 2015-09-15 | R4 | 1576h | 1576h | LTE_CA_B7_B40_B40-Core | 34 | ZTE | ZTE | Rel-13 | 66 | RP-151131 |
| 1453 | 462.29.2 | Perf. part:LTE Advanced 3 Band Carrier Aggregation (3DL/1UL) of Band 7, Band 40 and Band 40 | 197d? | 2014-12-15 A | 2015-09-15 A | 100% |  |  | finish no earlier than 2015-09-15 | R4 | 1576h | 1576h | LTE_CA_B7_B40_B40-Perf | 34 | ZTE | ZTE | Rel-13 | 66 | RP-151131 |

Notes:
- 1429: FCD: 06/16->12/15, Rel-14?->Rel-13
- 1430: FCD: 06/16->12/15, Rel-14?->Rel-13 1st Apr 15: Compl:0%->10% 1st Apr 15: WID: RP-142286->RP-150277 1st Apr 15: Stat Rep: ->RP-150272 03/07/15: Compl:10%->40% 03/07/15: WID: RP-150277->RP-150771 03/07/15: Stat Rep: RP-150272->RP-150769 29/09/15: Compl:4
- 1431: 1st Apr 15: WID: RP-142286->RP-150277 1st Apr 15: Stat Rep: ->RP-150272 03/07/15: WID: RP-150277->RP-150771 03/07/15: Stat Rep: RP-150272->RP-150769 29/09/15: Stat Rep: RP-150769->RP-151285; 22/3/16: ;
- 1432: ; 20/12/16: Compl:0%->5%19/6/17: Compl:5%->8%; ;...; 19/9/17: Compl:8%->15%; ;...; 8/1/18:...
- 1434: 1st Apr 15: Compl:0%->10% 1st Apr 15: WID: RP-142237->RP-150129 1st Apr 15: Stat Rep: ->RP-150127 03/07/15: Compl:10%->40% 03/07/15: Stat Rep: RP-150127->RP-150761 29/09/15: Compl:40%->50% 29/09/15: Stat Rep: RP-150761->RP-151281;
- 1435: 1st Apr 15: WID: RP-142237->RP-150129 1st Apr 15: Stat Rep: ->RP-150127 03/07/15: Stat Rep: RP-150127->RP-150761 29/09/15: Stat Rep: RP-150761->RP-1512811/1/16: Compl:0%->90% ;
- 1437: 1st Apr 15: Compl:0%->95% 1st Apr 15: CD:Tue 15/12/15->Mon 15/06/15 1st Apr 15: WID: RP-142020->RP-150115 1st Apr 15: Stat Rep: ->RP-150013 03/07/15: Compl:95%->100% 03/07/15: Stat Rep: RP-150013->RP-150536
- 1438: 1st Apr 15: Compl:0%->95% 1st Apr 15: CD:Tue 15/12/15->Mon 15/06/15 1st Apr 15: WID: RP-142020->RP-150115 1st Apr 15: Stat Rep: ->RP-150013 03/07/15: Compl:95%->100% 03/07/15: Stat Rep: RP-150013->RP-150536
- 1440: 1st Apr 15: Compl:0%->20% 1st Apr 15: Stat Rep: ->RP-150013 03/07/15: Compl:20%->65% 03/07/15: Stat Rep: RP-150013->RP-150536 29/09/15: CD:Tue 15/09/15->Tue 15/12/15 29/09/15: WID: RP-142239->RP-151446 29/09/15: Stat Rep: RP-150536->RP-151131; 29/09/1
- 1441: 1st Apr 15: Compl:0%->20% 1st Apr 15: Stat Rep: ->RP-150013 03/07/15: Compl:20%->65% 03/07/15: Stat Rep: RP-150013->RP-150536 29/09/15: CD:Tue 15/09/15->Tue 15/12/15 29/09/15: WID: RP-142239->RP-151446 29/09/15: Stat Rep: RP-150536->RP-151131; 29/09/1
- 1443: 1st Apr 15: Compl:0%->50% 1st Apr 15: Stat Rep: ->RP-150013 03/07/15: Compl:50%->90% 03/07/15: CD:Mon 15/06/15->Tue 15/09/15 03/07/15: Stat Rep: RP-150013->RP-150536 29/09/15: Compl:90%->100% 29/09/15: Stat Rep: RP-150536->RP-151131
- 1444: 03/07/15: Compl:0%->90% 03/07/15: CD:Mon 15/06/15->Tue 15/09/15 03/07/15: Stat Rep: ->RP-150536 29/09/15: Compl:90%->100% 29/09/15: Stat Rep: RP-150536->RP-151131
- 1446: 1st Apr 15: Compl:0%->50% 1st Apr 15: Stat Rep: ->RP-150013 03/07/15: Compl:50%->90% 03/07/15: CD:Mon 15/06/15->Tue 15/09/15 03/07/15: WID: RP-141791->RP-150639 03/07/15: Stat Rep: RP-150013->RP-150536 29/09/15: Compl:90%->100% 29/09/15: Stat Rep: RP-
- 1447: 03/07/15: CD:Mon 15/06/15->Tue 15/09/15 03/07/15: WID: RP-141791->RP-150639 03/07/15: Stat Rep: ->RP-150536 29/09/15: Compl:0%->100% 29/09/15: Stat Rep: RP-150536->RP-151131
- 1449: 1st Apr 15: Compl:0%->90% 1st Apr 15: Stat Rep: ->RP-150013 03/07/15: Compl:90%->100% 03/07/15: WID: RP-141792->RP-150640 03/07/15: Stat Rep: RP-150013->RP-150536
- 1450: 03/07/15: Compl:0%->100% 03/07/15: WID: RP-141792->RP-150640 03/07/15: Stat Rep: ->RP-150536
- 1452: 1st Apr 15: Compl:0%->40% 1st Apr 15: Stat Rep: ->RP-150013 03/07/15: Compl:40%->75% 03/07/15: CD:Mon 15/06/15->Tue 15/09/15 03/07/15: WID: RP-141802->RP-150614 03/07/15: Stat Rep: RP-150013->RP-150536 29/09/15: Compl:75%->100% 29/09/15: Stat Rep: RP-
- 1453: 1st Apr 15: Compl:0%->40% 1st Apr 15: Stat Rep: ->RP-150013 03/07/15: Compl:40%->75% 03/07/15: CD:Mon 15/06/15->Tue 15/09/15 03/07/15: WID: RP-141802->RP-150614 03/07/15: Stat Rep: RP-150013->RP-150536 29/09/15: Compl:75%->100% 29/09/15: Stat Rep: RP-

| ID | WBS | Task | Duration | Start | Finish | Complete | Remaining | Total slack | Constraint | Resources | Work | Actual work | Acronym | PCG approved | WI rapporteur name | WI rapporteur e-mail | Release | TSG approved | Status Report |
| --- | --- | --- | --- | --- | --- | --- | --- | --- | --- | --- | --- | --- | --- | --- | --- | --- | --- | --- | --- |
| 1454 | 462.30 | **LTE Advanced 3 band Carrier Aggregation (3DL/1UL) of Band 1, Band 8 and Band 28** | 327d? | 2014-12-15 A | 2016-03-15 | 40% | 196.2d? | 5150d |  | R4 | 7848h | 2723.2h | LTE_CA_B1_B8_B28 | 34 | Softbank Mobile | Softbank Mobile | Rel-13 | 66 |  |
| 1455 | 462.30.1 | Core part:LTE Advanced 3 band Carrier Aggregation (3DL/1UL) of Band 1, Band 8 and Band 28 | 327d? | 2014-12-15 A | 2016-03-15 | 40% | 196.2d? | 5150d | finish no earlier than 2016-03-15 | R4 | 2616h | 1046.4h | LTE_CA_B1_B8_B28-Core | 34 | Softbank Mobile | Softbank Mobile | Rel-13 | 66 | RP-151131 |
| 1456 | 462.30.2 | Perf. part:LTE Advanced 3 band Carrier Aggregation (3DL/1UL) of Band 1, Band 8 and Band 28 | 327d? | 2014-12-15 A | 2016-03-15 | 40% | 196.2d? | 5150d | finish no earlier than 2016-03-15 | R4 | 2616h | 1046.4h | LTE_CA_B1_B8_B28-Perf | 34 | Softbank Mobile | Softbank Mobile | Rel-13 | 66 | RP-151131 |
| 1457 | 462.31 | **LTE Advanced 3 Band Carrier Aggregation (3DL/1UL) of Band 3, Band 7 and Band 7** | 131d? | 2014-12-15 A | 2015-06-15 A | 100% |  |  |  | R4 | 3144h | 3144h | LTE_CA_B3_B7_B7_Bwset | 34 | Ericsson | Ericsson | Rel-13 | 66 |  |
| 1458 | 462.31.1 | Core part: Additional bandwidth combination set for LTE Advanced 3 Band Carrier Aggregation (3DL/1UL) of Band 3, Band 7 and Band 7 | 131d? | 2014-12-15 A | 2015-06-15 A | 100% |  |  | finish no earlier than 2015-06-15 | R4 | 1048h | 1048h | LTE_CA_B3_B7_B7_Bwset-Core | 34 | Ericsson | Ericsson | Rel-13 | 66 | RP-150536 |
| 1459 | 462.31.2 | Perf. Part: Additional bandwidth combination set for LTE Advanced 3 Band Carrier Aggregation (3DL/1UL) of Band 3, Band 7 and Band 7 | 131d? | 2014-12-15 A | 2015-06-15 A | 100% |  |  | finish no earlier than 2015-06-15 | R4 | 1048h | 1048h | LTE_CA_B3_B7_B7_BWset-Perf | 34 | Ericsson | Ericsson | Rel-13 | 66 | RP-150536 |
| 1460 | 462.32 | **LTE Advanced 3 Band Carrier Aggregation (3DL/1UL) of Band 7, Band 7 and Band 28** | 131d? | 2014-12-15 A | 2015-06-15 A | 100% |  |  |  | R4 | 3144h | 3144h | LTE_CA_B7_B7_B28 | 34 | Ericsson | Ericsson | Rel-13 | 66 |  |
| 1461 | 462.32.1 | Core part:LTE Advanced 3 Band Carrier Aggregation (3DL/1UL) of Band 7, Band 7 and Band 28 | 131d? | 2014-12-15 A | 2015-06-15 A | 100% |  |  | finish no earlier than 2015-06-15 | R4 | 1048h | 1048h | LTE_CA_B7_B7_B28-Core | 34 | Ericsson | Ericsson | Rel-13 | 66 | RP-150536 |
| 1462 | 462.32.2 | Perf. part:LTE Advanced 3 Band Carrier Aggregation (3DL/1UL) of Band 7, Band 7 and Band 28 | 131d? | 2014-12-15 A | 2015-06-15 A | 100% |  |  | finish no earlier than 2015-06-15 | R4 | 1048h | 1048h | LTE_CA_B7_B7_B28-Perf | 34 | Ericsson | Ericsson | Rel-13 | 66 | RP-150536 |
| 1463 | 462.33 | **LTE Advanced 3 band Carrier Aggregation (3DL/1UL) of Band 1, Band 3 and Band 40** | 262d? | 2014-12-15 A | 2015-12-15 A | 100% |  |  |  | R4 | 6288h | 6288h | LTE_CA_B1_B3_B40 | 34 | KT | KT | Rel-13 | 66 |  |
| 1464 | 462.33.1 | Core part:LTE Advanced 3 band Carrier Aggregation (3DL/1UL) of Band 1, Band 3 and Band 40 | 262d? | 2014-12-15 A | 2015-12-15 A | 100% |  |  | finish no earlier than 2015-12-15 | R4 | 2096h | 2096h | LTE_CA_B1_B3_B40-Core | 34 | KT | KT | Rel-13 | 66 | RP-151131 |
| 1465 | 462.33.2 | Perf. part:LTE Advanced 3 band Carrier Aggregation (3DL/1UL) of Band 1, Band 3 and Band 40 | 262d? | 2014-12-15 A | 2015-12-15 A | 100% |  |  | finish no earlier than 2015-12-15 | R4 | 2096h | 2096h | LTE_CA_B1_B3_B40-Perf | 34 | KT | KT | Rel-13 | 66 | RP-151131 |
| 1466 | 462.34 | **LTE Advanced 3 band Carrier Aggregation (3DL/1UL) of Band 1, Band 8 and Band 40** | 262d? | 2014-12-15 A | 2015-12-15 A | 100% |  |  |  | R4 | 6288h | 6288h | LTE_CA_B1_B8_B40 | 34 | KT | KT | Rel-13 | 66 |  |
| 1467 | 462.34.1 | Core part:LTE Advanced 3 band Carrier Aggregation (3DL/1UL) of Band 1, Band 8 and Band 40 | 262d? | 2014-12-15 A | 2015-12-15 A | 100% |  |  | finish no earlier than 2015-12-15 | R4 | 2096h | 2096h | LTE_CA_B1_B8_B40-Core | 34 | KT | KT | Rel-13 | 66 | RP-151131 |
| 1468 | 462.34.2 | Perf. part:LTE Advanced 3 band Carrier Aggregation (3DL/1UL) of Band 1, Band 8 and Band 40 | 262d? | 2014-12-15 A | 2015-12-15 A | 100% |  |  | finish no earlier than 2015-12-15 | R4 | 2096h | 2096h | LTE_CA_B1_B8_B40-Perf | 34 | KT | KT | Rel-13 | 66 | RP-151131 |
| 1469 | 462.35 | **LTE Advanced 3 band Carrier Aggregation (3DL/1UL) of Band 3, Band 8 and Band 40** | 262d? | 2014-12-15 A | 2015-12-15 A | 100% |  |  |  | R4 | 6288h | 6288h | LTE_CA_B3_B8_B40 | 34 | KT | KT | Rel-13 | 66 |  |
| 1470 | 462.35.1 | Core part:LTE Advanced 3 band Carrier Aggregation (3DL/1UL) of Band 3, Band 8 and Band 40 | 262d? | 2014-12-15 A | 2015-12-15 A | 100% |  |  | finish no earlier than 2015-12-15 | R4 | 2096h | 2096h | LTE_CA_B3_B8_B40-Core | 34 | KT | KT | Rel-13 | 66 | RP-151131 |
| 1471 | 462.35.2 | Perf. part:LTE Advanced 3 band Carrier Aggregation (3DL/1UL) of Band 3, Band 8 and Band 40 | 262d? | 2014-12-15 A | 2015-12-15 A | 100% |  |  | finish no earlier than 2015-12-15 | R4 | 2096h | 2096h | LTE_CA_B3_B8_B40-Perf | 34 | KT | KT | Rel-13 | 66 | RP-151131 |
| 1472 | 462.36 | **LTE Advanced 3 Band Carrier Aggregation (3DL) of Band 3, Band 7 and Band 8** | 131d? | 2014-12-15 A | 2015-06-15 A | 100% |  |  |  | R4 | 3144h | 3144h | LTE_CA_B3_B7_B8 | 34 | Ericsson | Ericsson | Rel-13 | 66 |  |
| 1473 | 462.36.1 | Core part:LTE Advanced 3 Band Carrier Aggregation (3DL) of Band 3, Band 7 and Band 8 | 131d? | 2014-12-15 A | 2015-06-15 A | 100% |  |  | finish no earlier than 2015-06-15 | R4 | 1048h | 1048h | LTE_CA_B3_B7_B8-Core | 34 | Ericsson | Ericsson | Rel-13 | 66 | RP-150536 |
| 1474 | 462.36.2 | Perf. part:LTE Advanced 3 Band Carrier Aggregation (3DL) of Band 3, Band 7 and Band 8 | 131d? | 2014-12-15 A | 2015-06-15 A | 100% |  |  | finish no earlier than 2015-06-15 | R4 | 1048h | 1048h | LTE_CA_B3_B7_B8-Perf | 34 | Ericsson | Ericsson | Rel-13 | 66 | RP-150536 |
| 1475 | 462.37 | **LTE Advanced 3 Band Carrier Aggregation (3DL/1UL) of Band 1, Band 3 and Band 28** | 131d? | 2014-12-15 A | 2015-06-15 A | 100% |  |  |  | R4 | 3144h | 3144h | LTE_CA_B1_B3_B28 | 34 | Nokia Networks | Nokia Networks | Rel-13 | 66 |  |
| 1476 | 462.37.1 | Core part:LTE Advanced 3 Band Carrier Aggregation (3DL/1UL) of Band 1, Band 3 and Band 28 | 131d? | 2014-12-15 A | 2015-06-15 A | 100% |  |  | finish no earlier than 2015-06-15 | R4 | 1048h | 1048h | LTE_CA_B1_B3_B28-Core | 34 | Nokia Networks | Nokia Networks | Rel-13 | 66 | RP-150536 |
| 1477 | 462.37.2 | Perf. part:LTE Advanced 3 Band Carrier Aggregation (3DL/1UL) of Band 1, Band 3 and Band 28 | 131d? | 2014-12-15 A | 2015-06-15 A | 100% |  |  | finish no earlier than 2015-06-15 | R4 | 1048h | 1048h | LTE_CA_B1_B3_B28-Perf | 34 | Nokia Networks | Nokia Networks | Rel-13 | 66 | RP-150536 |

Notes:
- 1455: 1st Apr 15: Compl:0%->20% 1st Apr 15: WID: RP-141826->RP-150447 1st Apr 15: Stat Rep: ->RP-150013 03/07/15: Compl:20%->40% 03/07/15: Stat Rep: RP-150013->RP-150536 29/09/15: CD:Tue 15/09/15->Tue 15/12/15 29/09/15: Stat Rep: RP-150536->RP-151131
- 1456: 1st Apr 15: Compl:0%->20% 1st Apr 15: WID: RP-141826->RP-150447 1st Apr 15: Stat Rep: ->RP-150013 03/07/15: Compl:20%->40% 03/07/15: Stat Rep: RP-150013->RP-150536 29/09/15: CD:Tue 15/09/15->Tue 15/12/15 29/09/15: Stat Rep: RP-150536->RP-151131
- 1457: Acronym changed from LTE_CA_B3_B7_B7
- 1458: Acronym changed from LTE_CA_B3_B7_B7-Core 1st Apr 15: Compl:0%->99% 1st Apr 15: CD:Sun 15/03/15->Mon 15/06/15 1st Apr 15: Stat Rep: ->RP-150013 03/07/15: Compl:99%->100% 03/07/15: Stat Rep: RP-150013->RP-150536
- 1459: Acronym changed from LTE_CA_B3_B7_B7-Perf 1st Apr 15: Compl:0%->99% 1st Apr 15: CD:Sun 15/03/15->Mon 15/06/15 1st Apr 15: Stat Rep: ->RP-150013 03/07/15: Compl:99%->100% 03/07/15: Stat Rep: RP-150013->RP-150536
- 1461: 1st Apr 15: Compl:0%->99% 1st Apr 15: CD:Sun 15/03/15->Mon 15/06/15 1st Apr 15: Stat Rep: ->RP-150013 03/07/15: Compl:99%->100% 03/07/15: Stat Rep: RP-150013->RP-150536
- 1462: 1st Apr 15: Compl:0%->99% 1st Apr 15: CD:Sun 15/03/15->Mon 15/06/15 1st Apr 15: Stat Rep: ->RP-150013 03/07/15: Compl:99%->100% 03/07/15: Stat Rep: RP-150013->RP-150536
- 1464: 1st Apr 15: Compl:0%->10% 1st Apr 15: Stat Rep: ->RP-150013 03/07/15: Compl:10%->60% 03/07/15: CD:Tue 15/09/15->Tue 15/12/15 03/07/15: Stat Rep: RP-150013->RP-150536 29/09/15: Compl:60%->80% 29/09/15: WID: RP-141946->RP-151258 29/09/15: Stat Rep: RP-1
- 1465: 1st Apr 15: Compl:0%->10% 1st Apr 15: Stat Rep: ->RP-150013 03/07/15: Compl:10%->60% 03/07/15: CD:Tue 15/09/15->Tue 15/12/15 03/07/15: Stat Rep: RP-150013->RP-150536 29/09/15: Compl:60%->80% 29/09/15: WID: RP-141946->RP-151258 29/09/15: Stat Rep: RP-1
- 1467: 1st Apr 15: Compl:0%->10% 1st Apr 15: Stat Rep: ->RP-150013 03/07/15: Compl:10%->60% 03/07/15: CD:Tue 15/09/15->Tue 15/12/15 03/07/15: Stat Rep: RP-150013->RP-150536 29/09/15: Compl:60%->80% 29/09/15: WID: RP-141947->RP-151259 29/09/15: Stat Rep: RP-1
- 1468: 1st Apr 15: Compl:0%->10% 1st Apr 15: Stat Rep: ->RP-150013 03/07/15: Compl:10%->60% 03/07/15: CD:Tue 15/09/15->Tue 15/12/15 03/07/15: Stat Rep: RP-150013->RP-150536 29/09/15: Compl:60%->80% 29/09/15: WID: RP-141947->RP-151259 29/09/15: Stat Rep: RP-1
- 1470: 1st Apr 15: Compl:0%->10% 1st Apr 15: Stat Rep: ->RP-150013 03/07/15: Compl:10%->60% 03/07/15: CD:Tue 15/09/15->Tue 15/12/15 03/07/15: Stat Rep: RP-150013->RP-150536 29/09/15: Compl:60%->95% 29/09/15: WID: RP-141949->RP-151261 29/09/15: Stat Rep: RP-1
- 1471: 1st Apr 15: Compl:0%->10% 1st Apr 15: Stat Rep: ->RP-150013 03/07/15: Compl:10%->60% 03/07/15: CD:Tue 15/09/15->Tue 15/12/15 03/07/15: Stat Rep: RP-150013->RP-150536 29/09/15: Compl:60%->90% 29/09/15: WID: RP-141949->RP-151261 29/09/15: Stat Rep: RP-1
- 1473: 1st Apr 15: Compl:0%->95% 1st Apr 15: Stat Rep: ->RP-150013 03/07/15: Compl:95%->100% 03/07/15: Stat Rep: RP-150013->RP-150536
- 1474: 1st Apr 15: Compl:0%->99% 1st Apr 15: Stat Rep: ->RP-150013 03/07/15: Compl:99%->100% 03/07/15: Stat Rep: RP-150013->RP-150536
- 1476: 1st Apr 15: Compl:0%->99% 1st Apr 15: CD:Sun 15/03/15->Mon 15/06/15 1st Apr 15: Stat Rep: ->RP-150013 03/07/15: Compl:99%->100% 03/07/15: WID: RP-142038->RP-150719 03/07/15: Stat Rep: RP-150013->RP-150536
- 1477: 1st Apr 15: Compl:0%->99% 1st Apr 15: CD:Sun 15/03/15->Mon 15/06/15 1st Apr 15: Stat Rep: ->RP-150013 03/07/15: Compl:99%->100% 03/07/15: WID: RP-142038->RP-150719 03/07/15: Stat Rep: RP-150013->RP-150536

| ID | WBS | Task | Duration | Start | Finish | Complete | Remaining | Total slack | Constraint | Resources | Work | Actual work | Acronym | PCG approved | WI rapporteur name | WI rapporteur e-mail | Release | TSG approved | Status Report |
| --- | --- | --- | --- | --- | --- | --- | --- | --- | --- | --- | --- | --- | --- | --- | --- | --- | --- | --- | --- |
| 1478 | 462.38 | **LTE Advanced 3 band Carrier Aggregation (3DL/1UL) of Band 3, Band 8 and Band 28** | 327d? | 2014-12-15 A | 2016-03-15 | 40% | 196.2d? | 5150d |  | R4 | 7848h | 2332.07h | LTE_CA_B3_B8_B28 | 34 | Softbank Mobile | Softbank Mobile | Rel-13 | 66 |  |
| 1479 | 462.38.1 | Core part:LTE Advanced 3 band Carrier Aggregation (3DL/1UL) of Band 3, Band 8 and Band 28 | 327d? | 2014-12-15 A | 2016-03-15 | 40% | 196.2d? | 5150d | finish no earlier than 2016-03-15 | R4 | 2616h | 1046.4h | LTE_CA_B3_B8_B28-Core | 34 | Softbank Mobile | Softbank Mobile | Rel-13 | 66 | RP-151131 |
| 1480 | 462.38.2 | Perf. part:LTE Advanced 3 band Carrier Aggregation (3DL/1UL) of Band 3, Band 8 and Band 28 | 327d? | 2014-12-15 A | 2016-03-15 | 40% | 196.2d? | 5150d | finish no earlier than 2016-03-15 | R4 | 2616h | 1046.4h | LTE_CA_B3_B8_B28-Perf | 34 | Softbank Mobile | Softbank Mobile | Rel-13 | 66 | RP-151131 |
| 1481 | 462.39 | **LTE Advanced 3 Band Carrier Aggregation (3DL/1UL) of Band 8, Band 42 and Band 42** | 327d? | 2014-12-15 A | 2016-03-15 A | 100% |  |  |  | R4 | 7848h | 7848h | LTE_CA_B8_B42_B42 | 34 | Softbank Mobile | Softbank Mobile | Rel-13 | 66 |  |
| 1482 | 462.39.1 | Core part:LTE Advanced 3 Band Carrier Aggregation (3DL/1UL) of Band 8, Band 42 and Band 42 | 327d? | 2014-12-15 A | 2016-03-15 A | 100% |  |  | finish no earlier than 2016-03-15 | R4 | 2616h | 2616h | LTE_CA_B8_B42_B42-Core | 34 | Softbank Mobile | Softbank Mobile | Rel-13 | 66 | RP-151131 |
| 1483 | 462.39.2 | Perf. part:LTE Advanced 3 Band Carrier Aggregation (3DL/1UL) of Band 8, Band 42 and Band 42 | 327d? | 2014-12-15 A | 2016-03-15 A | 100% |  |  | finish no earlier than 2016-03-15 | R4 | 2616h | 2616h | LTE_CA_B8_B42_B42-Perf | 34 | Softbank Mobile | Softbank Mobile | Rel-13 | 66 | RP-151131 |
| 1484 | 462.40 | **LTE Advanced 3 Band Carrier Aggregation (3DL/1UL) of Band 28, Band 40 and Band 40** | 262d? | 2014-12-15 A | 2015-12-15 A | 100% |  |  |  | R4 | 6288h | 6288h | LTE_CA_B28_B40_B40 | 34 | Huawei | Huawei | Rel-13 | 66 |  |
| 1485 | 462.40.1 | Core part:LTE Advanced 3 Band Carrier Aggregation (3DL/1UL) of Band 28, Band 40 and Band 40 | 262d? | 2014-12-15 A | 2015-12-15 A | 100% |  |  | finish no earlier than 2015-12-15 | R4 | 2096h | 2096h | LTE_CA_B28_B40_B40-Core | 34 | Huawei | Huawei | Rel-13 | 66 | RP-151131 |
| 1486 | 462.40.2 | Perf. part:LTE Advanced 3 Band Carrier Aggregation (3DL/1UL) of Band 28, Band 40 and Band 40 | 262d? | 2014-12-15 A | 2015-12-15 A | 100% |  |  | finish no earlier than 2015-12-15 | R4 | 2096h | 2096h | LTE_CA_B28_B40_B40-Perf | 34 | Huawei | Huawei | Rel-13 | 66 | RP-151131 |
| 1487 | 462.41 | **LTE Advanced 3 Band Carrier Aggregation (3DL/1UL) of Band 3, Band 40 and Band 40** | 131d? | 2014-12-15 A | 2015-06-15 A | 100% |  |  |  | R4 | 3144h | 3144h | LTE_CA_B3_B40_B40 | 34 | Huawei | Huawei | Rel-13 | 66 |  |
| 1488 | 462.41.1 | Core part:LTE Advanced 3 Band Carrier Aggregation (3DL/1UL) of Band 3, Band 40 and Band 40 | 131d? | 2014-12-15 A | 2015-06-15 A | 100% |  |  | finish no earlier than 2015-06-15 | R4 | 1048h | 1048h | LTE_CA_B3_B40_B40-Core | 34 | Huawei | Huawei | Rel-13 | 66 | RP-150536 |
| 1489 | 462.41.2 | Perf. part:LTE Advanced 3 Band Carrier Aggregation (3DL/1UL) of Band 3, Band 40 and Band 40 | 131d? | 2014-12-15 A | 2015-06-15 A | 100% |  |  | finish no earlier than 2015-06-15 | R4 | 1048h | 1048h | LTE_CA_B3_B40_B40-Perf | 34 | Huawei | Huawei | Rel-13 | 66 | RP-150536 |
| 1490 | 462.42 | **LTE Advanced 3 Band Carrier Aggregation (3DL/1UL) of Band 1, Band 7 and Band 28** | 131d? | 2014-12-15 A | 2015-06-15 A | 100% |  |  |  | R4 | 3144h | 3144h | LTE_CA_B1_B7_B28 | 34 | Huawei | Huawei | Rel-13 | 66 |  |
| 1491 | 462.42.1 | Core part:LTE Advanced 3 Band Carrier Aggregation (3DL/1UL) of Band 1, Band 7 and Band 28 | 131d? | 2014-12-15 A | 2015-06-15 A | 100% |  |  | finish no earlier than 2015-06-15 | R4 | 1048h | 1048h | LTE_CA_B1_B7_B28-Core | 34 | Huawei | Huawei | Rel-13 | 66 | RP-150536 |
| 1492 | 462.42.2 | Perf. part:LTE Advanced 3 Band Carrier Aggregation (3DL/1UL) of Band 1, Band 7 and Band 28 | 131d? | 2014-12-15 A | 2015-06-15 A | 100% |  |  | finish no earlier than 2015-06-15 | R4 | 1048h | 1048h | LTE_CA_B1_B7_B28-Perf | 34 | Huawei | Huawei | Rel-13 | 66 | RP-150536 |
| 1493 | 462.43 | **LTE Advanced 3 Band Carrier Aggregation (3DL/1UL) of Band 1, Band 3 and Band 7** | 262d? | 2014-12-15 A | 2015-12-15 A | 100% |  |  |  | R4 | 6288h | 6288h | LTE_CA_B1_B3_B7 | 34 | Huawei | Huawei | Rel-13 | 66 |  |
| 1494 | 462.43.1 | Core part:LTE Advanced 3 Band Carrier Aggregation (3DL/1UL) of Band 1, Band 3 and Band 7 | 262d? | 2014-12-15 A | 2015-12-15 A | 100% |  |  | finish no earlier than 2015-12-15 | R4 | 2096h | 2096h | LTE_CA_B1_B3_B7-Core | 34 | Huawei | Huawei | Rel-13 | 66 | RP-151131 |
| 1495 | 462.43.2 | Perf. part:LTE Advanced 3 Band Carrier Aggregation (3DL/1UL) of Band 1, Band 3 and Band 7 | 262d? | 2014-12-15 A | 2015-12-15 A | 100% |  |  | finish no earlier than 2015-12-15 | R4 | 2096h | 2096h | LTE_CA_B1_B3_B7-Perf | 34 | Huawei | Huawei | Rel-13 | 66 | RP-151131 |
| 1496 | 462.44 | **LTE Advanced 3 Band Carrier Aggregation (3DL/1UL) of Band 3, Band 3 and Band 5** | 131d? | 2014-12-15 A | 2015-06-15 A | 100% |  |  |  | R4 | 3144h | 3144h | LTE_CA_B3_B3_B5 | 34 | Intel | Intel | Rel-13 | 66 |  |
| 1497 | 462.44.1 | Core part:LTE Advanced 3 Band Carrier Aggregation (3DL/1UL) of Band 3, Band 3 and Band 5 | 131d? | 2014-12-15 A | 2015-06-15 A | 100% |  |  | finish no earlier than 2015-09-15 | R4 | 1048h | 1048h | LTE_CA_B3_B3_B5-Core | 34 | Intel | Intel | Rel-13 | 66 | RP-150536 |
| 1498 | 462.44.2 | Perf. part:LTE Advanced 3 Band Carrier Aggregation (3DL/1UL) of Band 3, Band 3 and Band 5 | 131d? | 2014-12-15 A | 2015-06-15 A | 100% |  |  | finish no earlier than 2015-09-15 | R4 | 1048h | 1048h | LTE_CA_B3_B3_B5-Perf | 34 | Intel | Intel | Rel-13 | 66 | RP-150536 |
| 1499 | 462.45 | **LTE Advanced 3 Band Carrier Aggregation (3DL/1UL) of Band 3, Band 7 and Band 28** | 131d? | 2014-12-15 A | 2015-06-15 A | 100% |  |  |  | R4 | 3144h | 3144h | LTE_CA_B3_B7_B28 | 34 | Ericsson | Ericsson | Rel-13 | 66 |  |
| 1500 | 462.45.1 | Core part:LTE Advanced 3 Band Carrier Aggregation (3DL/1UL) of Band 3, Band 7 and Band 28 | 131d? | 2014-12-15 A | 2015-06-15 A | 100% |  |  | finish no earlier than 2015-06-15 | R4 | 1048h | 1048h | LTE_CA_B3_B7_B28-Core | 34 | Ericsson | Ericsson | Rel-13 | 66 | RP-150536 |
| 1501 | 462.45.2 | Perf. part:LTE Advanced 3 Band Carrier Aggregation (3DL/1UL) of Band 3, Band 7 and Band 28 | 131d? | 2014-12-15 A | 2015-06-15 A | 100% |  |  | finish no earlier than 2015-06-15 | R4 | 1048h | 1048h | LTE_CA_B3_B7_B28-Perf | 34 | Ericsson | Ericsson | Rel-13 | 66 | RP-150536 |

Notes:
- 1479: 1st Apr 15: Compl:0%->20% 1st Apr 15: CD:Tue 15/12/15->Tue 15/09/15 1st Apr 15: Stat Rep: ->RP-150013 03/07/15: Compl:20%->40% 03/07/15: Stat Rep: RP-150013->RP-150536 29/09/15: CD:Tue 15/09/15->Tue 15/12/15 29/09/15: Stat Rep: RP-150536->RP-151131;
- 1480: 1st Apr 15: Compl:0%->20% 1st Apr 15: Stat Rep: ->RP-150013 03/07/15: Compl:20%->40% 03/07/15: Stat Rep: RP-150013->RP-150536 29/09/15: CD:Tue 15/09/15->Tue 15/12/15 29/09/15: Stat Rep: RP-150536->RP-151131
- 1482: 1st Apr 15: Compl:0%->20% 1st Apr 15: CD:Tue 15/12/15->Mon 15/06/15 1st Apr 15: Stat Rep: ->RP-150013 03/07/15: Compl:20%->40% 03/07/15: CD:Mon 15/06/15->Tue 15/09/15 03/07/15: Stat Rep: RP-150013->RP-150536 29/09/15: CD:Tue 15/09/15->Tue 15/12/15 29
- 1483: 1st Apr 15: Compl:0%->20% 1st Apr 15: Stat Rep: ->RP-150013 03/07/15: Compl:20%->40% 03/07/15: CD:Mon 15/06/15->Tue 15/09/15 03/07/15: Stat Rep: RP-150013->RP-150536 29/09/15: CD:Tue 15/09/15->Tue 15/12/15 29/09/15: Stat Rep: RP-150536->RP-151131;
- 1485: 1st Apr 15: Compl:0%->30% 1st Apr 15: CD:Tue 15/12/15->Mon 15/06/15 1st Apr 15: WID: RP-142206->RP-150233 1st Apr 15: Stat Rep: ->RP-150013 03/07/15: Compl:30%->60% 03/07/15: CD:Mon 15/06/15->Tue 15/12/15 03/07/15: WID: RP-150233->RP-150676 03/07/15:
- 1486: 1st Apr 15: WID: RP-142206->RP-150233 1st Apr 15: Stat Rep: ->RP-150013 03/07/15: CD:Mon 15/06/15->Tue 15/12/15 03/07/15: WID: RP-150233->RP-150676 03/07/15: Stat Rep: RP-150013->RP-150536 29/09/15: Stat Rep: RP-150536->RP-151131;
- 1488: 1st Apr 15: Compl:0%->50% 1st Apr 15: CD:Tue 15/12/15->Mon 15/06/15 1st Apr 15: Stat Rep: ->RP-150013 03/07/15: Compl:50%->100% 03/07/15: WID: RP-142207->RP-151071 03/07/15: Stat Rep: RP-150013->RP-150536
- 1489: 03/07/15: Compl:0%->100% 03/07/15: WID: RP-142207->RP-151071 03/07/15: Stat Rep: ->RP-150536
- 1491: 1st Apr 15: Compl:0%->50% 1st Apr 15: CD:Tue 15/12/15->Mon 15/06/15 1st Apr 15: WID: RP-142208->RP-150234 1st Apr 15: Stat Rep: ->RP-150013 03/07/15: Compl:50%->100% 03/07/15: Stat Rep: RP-150013->RP-150536
- 1492: 1st Apr 15: WID: RP-142208->RP-150234 1st Apr 15: Stat Rep: ->RP-150013 03/07/15: Compl:0%->100% 03/07/15: Stat Rep: RP-150013->RP-150536
- 1494: 1st Apr 15: Compl:0%->30% 1st Apr 15: CD:Tue 15/12/15->Mon 15/06/15 1st Apr 15: Stat Rep: ->RP-150013 03/07/15: Compl:30%->40% 03/07/15: CD:Mon 15/06/15->Tue 15/09/15 03/07/15: Stat Rep: RP-150013->RP-150536 29/09/15: Compl:40%->50% 29/09/15: CD:Tue 1
- 1495: 03/07/15: CD:Mon 15/06/15->Tue 15/09/15 03/07/15: Stat Rep: ->RP-150536 29/09/15: CD:Tue 15/09/15->Tue 15/12/15 29/09/15: Stat Rep: RP-150536->RP-151131
- 1497: 1st Apr 15: Compl:0%->10% 1st Apr 15: Stat Rep: ->RP-150013 03/07/15: Compl:10%->100% 03/07/15: CD:Tue 15/09/15->Mon 15/06/15 03/07/15: Stat Rep: RP-150013->RP-150536
- 1498: 03/07/15: Compl:0%->100% 03/07/15: CD:Tue 15/09/15->Mon 15/06/15 03/07/15: Stat Rep: ->RP-150536
- 1500: 1st Apr 15: Compl:0%->99% 1st Apr 15: CD:Sun 15/03/15->Mon 15/06/15 1st Apr 15: Stat Rep: ->RP-150013 03/07/15: Compl:99%->100% 03/07/15: Stat Rep: RP-150013->RP-150536
- 1501: 1st Apr 15: Compl:0%->99% 1st Apr 15: CD:Sun 15/03/15->Mon 15/06/15 1st Apr 15: Stat Rep: ->RP-150013 03/07/15: Compl:99%->100% 03/07/15: Stat Rep: RP-150013->RP-150536

| ID | WBS | Task | Duration | Start | Finish | Complete | Constraint | Resources | Work | Actual work | Acronym | PCG approved | WI rapporteur name | WI rapporteur e-mail | Release | TSG approved | Status Report |
| --- | --- | --- | --- | --- | --- | --- | --- | --- | --- | --- | --- | --- | --- | --- | --- | --- | --- |
| 1502 | 462.46 | **LTE Advanced 4 Band Carrier Aggregation (4DL/1UL) of Band 2, Band 2, Band 12 and Band 30** | 262d? | 2014-12-15 A | 2015-12-15 A | 100% |  | R4 | 6288h | 6288h | LTE_CA_B2_B2_B12_B30 | 34 | AT&T | AT&T | Rel-13 | 66 |  |
| 1503 | 462.46.1 | Core part:LTE Advanced 4 Band Carrier Aggregation (4DL/1UL) of Band 2, Band 2, Band 12 and Band 30 | 262d? | 2014-12-15 A | 2015-12-15 A | 100% | finish no earlier than 2015-12-15 | R4 | 2096h | 2096h | LTE_CA_B2_B2_B12_B30-Core | 34 | AT&T | AT&T | Rel-13 | 66 | RP-151131 |
| 1504 | 462.46.2 | Perf. part:LTE Advanced 4 Band Carrier Aggregation (4DL/1UL) of Band 2, Band 2, Band 12 and Band 30 | 262d? | 2014-12-15 A | 2015-12-15 A | 100% | finish no earlier than 2015-12-15 | R4 | 2096h | 2096h | LTE_CA_B2_B2_B12_B30-Perf | 34 | AT&T | AT&T | Rel-13 | 66 | RP-151131 |
| 1505 | 462.47 | **LTE Advanced 4 Band Carrier Aggregation (4DL/1UL) of Band 2, Band 2, Band 5 and Band 30** | 262d? | 2014-12-15 A | 2015-12-15 A | 100% |  | R4 | 6288h | 6288h | LTE_CA_B2_B2_B5_B30 | 34 | AT&T | AT&T | Rel-13 | 66 |  |
| 1506 | 462.47.1 | Core part:LTE Advanced 4 Band Carrier Aggregation (4DL/1UL) of Band 2, Band 2, Band 5 and Band 30 | 262d? | 2014-12-15 A | 2015-12-15 A | 100% | finish no earlier than 2015-12-15 | R4 | 2096h | 2096h | LTE_CA_B2_B2_B5_B30-Core | 34 | AT&T | AT&T | Rel-13 | 66 | RP-151131 |
| 1507 | 462.47.2 | Perf. part:LTE Advanced 4 Band Carrier Aggregation (4DL/1UL) of Band 2, Band 2, Band 5 and Band 30 | 262d? | 2014-12-15 A | 2015-12-15 A | 100% | finish no earlier than 2015-12-15 | R4 | 2096h | 2096h | LTE_CA_B2_B2_B5_B30-Perf | 34 | AT&T | AT&T | Rel-13 | 66 | RP-151131 |
| 1508 | 462.48 | **LTE Advanced 4 Band Carrier Aggregation (4DL/1UL) of Band 2, Band 2 Band 29 and Band 30** | 262d? | 2014-12-15 A | 2015-12-15 A | 100% |  | R4 | 6288h | 6288h | LTE_CA_B2_B2_B29_B30 | 34 | AT&T | AT&T | Rel-13 | 66 |  |
| 1509 | 462.48.1 | Core part:LTE Advanced 4 Band Carrier Aggregation (4DL/1UL) of Band 2, Band 2 Band 29 and Band 30 | 262d? | 2014-12-15 A | 2015-12-15 A | 100% | finish no earlier than 2015-12-15 | R4 | 2096h | 2096h | LTE_CA_B2_B2_B29_B30-Core | 34 | AT&T | AT&T | Rel-13 | 66 | RP-151131 |
| 1510 | 462.48.2 | Perf. part:LTE Advanced 4 Band Carrier Aggregation (4DL/1UL) of Band 2, Band 2 Band 29 and Band 30 | 262d? | 2014-12-15 A | 2015-12-15 A | 100% | finish no earlier than 2015-12-15 | R4 | 2096h | 2096h | LTE_CA_B2_B2_B29_B30-Perf | 34 | AT&T | AT&T | Rel-13 | 66 | RP-151131 |
| 1511 | 462.49 | **LTE Advanced 4 Band Carrier Aggregation (4DL/1UL) of Band 2, Band 4, Band 12 and Band 30** | 262d? | 2014-12-15 A | 2015-12-15 A | 100% |  | R4 | 6288h | 6288h | LTE_CA_B2_B4_B12_B30 | 34 | AT&T | AT&T | Rel-13 | 66 |  |
| 1512 | 462.49.1 | Core part:LTE Advanced 4 Band Carrier Aggregation (4DL/1UL) of Band 2, Band 4, Band 12 and Band 30 | 262d? | 2014-12-15 A | 2015-12-15 A | 100% | finish no earlier than 2015-12-15 | R4 | 2096h | 2096h | LTE_CA_B2_B4_B12_B30-Core | 34 | AT&T | AT&T | Rel-13 | 66 | RP-151131 |
| 1513 | 462.49.2 | Perf. part:LTE Advanced 4 Band Carrier Aggregation (4DL/1UL) of Band 2, Band 4, Band 12 and Band 30 | 262d? | 2014-12-15 A | 2015-12-15 A | 100% | finish no earlier than 2015-12-15 | R4 | 2096h | 2096h | LTE_CA_B2_B4_B12_B30-Perf | 34 | AT&T | AT&T | Rel-13 | 66 | RP-151131 |
| 1514 | 462.50 | **LTE Advanced 4 Band Carrier Aggregation (4DL/1UL) of Band 2, Band 4, Band 5 and Band 30** | 262d? | 2014-12-15 A | 2015-12-15 A | 100% |  | R4 | 6288h | 6288h | LTE_CA_B2_B4_B5_B30 | 34 | AT&T | AT&T | Rel-13 | 66 |  |
| 1515 | 462.50.1 | Core part:LTE Advanced 4 Band Carrier Aggregation (4DL/1UL) of Band 2, Band 4, Band 5 and Band 30 | 262d? | 2014-12-15 A | 2015-12-15 A | 100% | finish no earlier than 2015-12-15 | R4 | 2096h | 2096h | LTE_CA_B2_B4_B5_B30-Core | 34 | AT&T | AT&T | Rel-13 | 66 | RP-151131 |
| 1516 | 462.50.2 | Perf. part:LTE Advanced 4 Band Carrier Aggregation (4DL/1UL) of Band 2, Band 4, Band 5 and Band 30 | 262d? | 2014-12-15 A | 2015-12-15 A | 100% | finish no earlier than 2015-12-15 | R4 | 2096h | 2096h | LTE_CA_B2_B4_B5_B30-Perf | 34 | AT&T | AT&T | Rel-13 | 66 | RP-151131 |
| 1517 | 462.51 | **LTE Advanced 4 Band Carrier Aggregation (4DL/1UL) of Band 2, Band 4, Band 29 and Band 30** | 262d? | 2014-12-15 A | 2015-12-15 A | 100% |  | R4 | 6288h | 6288h | LTE_CA_B2_B4_B29_B30 | 34 | AT&T | AT&T | Rel-13 | 66 |  |
| 1518 | 462.51.1 | Core part:LTE Advanced 4 Band Carrier Aggregation (4DL/1UL) of Band 2, Band 4, Band 29 and Band 30 | 262d? | 2014-12-15 A | 2015-12-15 A | 100% | finish no earlier than 2015-12-15 | R4 | 2096h | 2096h | LTE_CA_B2_B4_B29_B30-Core | 34 | AT&T | AT&T | Rel-13 | 66 | RP-151131 |
| 1519 | 462.51.2 | Perf. part:LTE Advanced 4 Band Carrier Aggregation (4DL/1UL) of Band 2, Band 4, Band 29 and Band 30 | 262d? | 2014-12-15 A | 2015-12-15 A | 100% | finish no earlier than 2015-12-15 | R4 | 2096h | 2096h | LTE_CA_B2_B4_B29_B30-Perf | 34 | AT&T | AT&T | Rel-13 | 66 | RP-151131 |
| 1520 | 462.52 | **LTE Advanced 4 Band Carrier Aggregation (4DL/1UL) of Band 25, Band 41, Band 41 and Band 41** | 262d? | 2014-12-15 A | 2015-12-15 A | 100% |  | R4 | 6288h | 6288h | LTE_CA_B25_B41_B41_B41 | 34 | Alcatel-Lucent | Alcatel-Lucent | Rel-13 | 66 |  |
| 1521 | 462.52.1 | Core part:LTE Advanced 4 Band Carrier Aggregation (4DL/1UL) of Band 25, Band 41, Band 41 and Band 41 | 262d? | 2014-12-15 A | 2015-12-15 A | 100% | finish no earlier than 2015-12-15 | R4 | 2096h | 2096h | LTE_CA_B25_B41_B41_B41-Core | 34 | Alcatel-Lucent | Alcatel-Lucent | Rel-13 | 66 | RP-151131 |
| 1522 | 462.52.2 | Perf. part:LTE Advanced 4 Band Carrier Aggregation (4DL/1UL) of Band 25, Band 41, Band 41 and Band 41 | 262d? | 2014-12-15 A | 2015-12-15 A | 100% | finish no earlier than 2015-12-15 | R4 | 2096h | 2096h | LTE_CA_B25_B41_B41_B41-Perf | 34 | Alcatel-Lucent | Alcatel-Lucent | Rel-13 | 66 | RP-151131 |
| 1523 | 462.53 | **LTE Advanced dual uplink inter-band Carrier Aggregation Class A1 in REL-13** | 262d? | 2014-12-15 A | 2015-12-15 A | 100% |  | R4 | 6288h | 6288h | LTE_CA_2UL_R13-A1 | 34 | Huawei | Huawei | Rel-13 | 66 |  |
| 1524 | 462.53.1 | Core part:LTE Advanced dual uplink inter-band Carrier Aggregation Class A1 in REL-13 | 262d? | 2014-12-15 A | 2015-12-15 A | 100% | finish no earlier than 2015-12-15 | R4 | 2096h | 2096h | LTE_CA_2UL_R13-A1-Core | 34 | Huawei | Huawei | Rel-13 | 66 | RP-151131 |
| 1525 | 462.53.2 | Perf. part:LTE Advanced dual uplink inter-band Carrier Aggregation Class A1 in REL-13 | 262d? | 2014-12-15 A | 2015-12-15 A | 100% | finish no earlier than 2015-12-15 | R4 | 2096h | 2096h | LTE_CA_2UL_R13-A1-Perf | 34 | Huawei | Huawei | Rel-13 | 66 | RP-151131 |

Notes:
- 1503: 1st Apr 15: Compl:0%->50% 1st Apr 15: WID: RP-142198->RP-150449 1st Apr 15: Stat Rep: ->RP-150013 03/07/15: Compl:50%->95% 03/07/15: Stat Rep: RP-150013->RP-150536 29/09/15: Stat Rep: RP-150536->RP-151131
- 1504: 1st Apr 15: Compl:0%->50% 1st Apr 15: WID: RP-142198->RP-150449 1st Apr 15: Stat Rep: ->RP-150013 03/07/15: Compl:50%->95% 03/07/15: Stat Rep: RP-150013->RP-150536 29/09/15: Stat Rep: RP-150536->RP-151131
- 1506: 1st Apr 15: Compl:0%->50% 1st Apr 15: CD:Tue 15/12/15->Tue 15/09/15 1st Apr 15: WID: RP-142199->RP-150448 1st Apr 15: Stat Rep: ->RP-150013 03/07/15: Compl:50%->95% 03/07/15: CD:Tue 15/09/15->Tue 15/12/15 03/07/15: Stat Rep: RP-150013->RP-150536 29/09
- 1507: 1st Apr 15: Compl:0%->50% 1st Apr 15: WID: RP-142199->RP-150448 1st Apr 15: Stat Rep: ->RP-150013 03/07/15: Compl:50%->95% 03/07/15: Stat Rep: RP-150013->RP-150536 29/09/15: Stat Rep: RP-150536->RP-151131
- 1509: 1st Apr 15: Compl:0%->50% 1st Apr 15: WID: RP-142200->RP-150450 1st Apr 15: Stat Rep: ->RP-150013 03/07/15: Compl:50%->95% 03/07/15: Stat Rep: RP-150013->RP-150536 29/09/15: Stat Rep: RP-150536->RP-151131
- 1510: 1st Apr 15: Compl:0%->50% 1st Apr 15: WID: RP-142200->RP-150450 1st Apr 15: Stat Rep: ->RP-150013 03/07/15: Compl:50%->95% 03/07/15: Stat Rep: RP-150013->RP-150536 29/09/15: Stat Rep: RP-150536->RP-151131
- 1512: 1st Apr 15: Compl:0%->50% 1st Apr 15: WID: RP-142201->RP-150452 1st Apr 15: Stat Rep: ->RP-150013 03/07/15: Compl:50%->95% 03/07/15: Stat Rep: RP-150013->RP-150536 29/09/15: Stat Rep: RP-150536->RP-151131
- 1513: 1st Apr 15: Compl:0%->50% 1st Apr 15: WID: RP-142201->RP-150452 1st Apr 15: Stat Rep: ->RP-150013 03/07/15: Compl:50%->95% 03/07/15: Stat Rep: RP-150013->RP-150536 29/09/15: Stat Rep: RP-150536->RP-151131
- 1515: 1st Apr 15: Compl:0%->50% 1st Apr 15: WID: RP-142202->RP-150451 1st Apr 15: Stat Rep: ->RP-150013 03/07/15: Compl:50%->95% 03/07/15: Stat Rep: RP-150013->RP-150536 29/09/15: Stat Rep: RP-150536->RP-151131
- 1516: 1st Apr 15: Compl:0%->50% 1st Apr 15: WID: RP-142202->RP-150451 1st Apr 15: Stat Rep: ->RP-150013 03/07/15: Compl:50%->95% 03/07/15: Stat Rep: RP-150013->RP-150536 29/09/15: Stat Rep: RP-150536->RP-151131
- 1518: 1st Apr 15: Compl:0%->50% 1st Apr 15: WID: RP-142203->RP-150453 1st Apr 15: Stat Rep: ->RP-150013 03/07/15: Compl:50%->95% 03/07/15: Stat Rep: RP-150013->RP-150536 29/09/15: Stat Rep: RP-150536->RP-151131
- 1519: 1st Apr 15: Compl:0%->50% 1st Apr 15: WID: RP-142203->RP-150453 1st Apr 15: Stat Rep: ->RP-150013 03/07/15: Compl:50%->95% 03/07/15: Stat Rep: RP-150013->RP-150536 29/09/15: Stat Rep: RP-150536->RP-151131
- 1521: 1st Apr 15: Compl:0%->50% 1st Apr 15: Stat Rep: ->RP-150013 03/07/15: Compl:50%->90% 03/07/15: Stat Rep: RP-150013->RP-150536 29/09/15: Compl:90%->95% 29/09/15: CD:Tue 15/09/15->Tue 15/12/15 29/09/15: Stat Rep: RP-150536->RP-151131
- 1522: 1st Apr 15: Compl:0%->25% 1st Apr 15: Stat Rep: ->RP-150013 03/07/15: Compl:25%->75% 03/07/15: Stat Rep: RP-150013->RP-150536 29/09/15: Compl:75%->80% 29/09/15: Stat Rep: RP-150536->RP-151131
- 1524: 1st Apr 15: Compl:0%->40% 1st Apr 15: WID: RP-141935->RP-150411 1st Apr 15: Stat Rep: ->RP-150013 03/07/15: Compl:40%->60% 03/07/15: WID: RP-150411->RP-150678 03/07/15: Stat Rep: RP-150013->RP-150536 29/09/15: Compl:60%->80% 29/09/15: Stat Rep: RP-150
- 1525: 1st Apr 15: Compl:0%->40% 1st Apr 15: WID: RP-141935->RP-150411 1st Apr 15: Stat Rep: ->RP-150013 03/07/15: Compl:40%->60% 03/07/15: WID: RP-150411->RP-150678 03/07/15: Stat Rep: RP-150013->RP-150536 29/09/15: Compl:60%->80% 29/09/15: Stat Rep: RP-150

| ID | WBS | Task | Duration | Start | Finish | Complete | Baseline start | Baseline finish | Baseline duration | Constraint | Resources | Work | Actual work | Acronym | PCG approved | WI rapporteur name | WI rapporteur e-mail | Release | TSG approved | Status Report | Acronym_3GU_Export |
| --- | --- | --- | --- | --- | --- | --- | --- | --- | --- | --- | --- | --- | --- | --- | --- | --- | --- | --- | --- | --- | --- |
| 1526 | 462.54 | **LTE Advanced dual uplink inter-band Carrier Aggregation Class A2 in REL-13** | 262d? | 2014-12-15 A | 2015-12-15 A | 100% |  |  |  |  | R4 | 6288h | 6288h | LTE_CA_2UL_R13-A2 | 34 | Qualcomm | Qualcomm | Rel-13 | 66 |  |  |
| 1527 | 462.54.1 | Core part:LTE Advanced dual uplink inter-band Carrier Aggregation Class A2 in REL-13 | 262d? | 2014-12-15 A | 2015-12-15 A | 100% |  |  |  | finish no earlier than 2015-12-15 | R4 | 2096h | 2096h | LTE_CA_2UL_R13-A2-Core | 34 | Qualcomm | Qualcomm | Rel-13 | 66 | RP-151131 |  |
| 1528 | 462.54.2 | Perf. part:LTE Advanced dual uplink inter-band Carrier Aggregation Class A2 in REL-13 | 262d? | 2014-12-15 A | 2015-12-15 A | 100% |  |  |  | finish no earlier than 2015-12-15 | R4 | 2096h | 2096h | LTE_CA_2UL_R13-A2-Perf | 34 | Qualcomm | Qualcomm | Rel-13 | 66 | RP-151131 |  |
| 1529 | 462.55 | **LTE Advanced dual uplink inter-band Carrier Aggregation Class A3 in REL-13** | 262d? | 2014-12-15 A | 2015-12-15 A | 100% |  |  |  |  | R4 | 6288h | 6288h | LTE_CA_2UL_R13-A3 | 34 | Ericsson | Ericsson | Rel-13 | 66 |  |  |
| 1530 | 462.55.1 | Core part:LTE Advanced dual uplink inter-band Carrier Aggregation Class A3 in REL-13 | 262d? | 2014-12-15 A | 2015-12-15 A | 100% |  |  |  | finish no earlier than 2015-12-15 | R4 | 2096h | 2096h | LTE_CA_2UL_R13-A3-Core | 34 | Ericsson | Ericsson | Rel-13 | 66 | RP-151131 |  |
| 1531 | 462.55.2 | Perf. part:LTE Advanced dual uplink inter-band Carrier Aggregation Class A3 in REL-13 | 262d? | 2014-12-15 A | 2015-12-15 A | 100% |  |  |  | finish no earlier than 2015-12-15 | R4 | 2096h | 2096h | LTE_CA_2UL_R13-A3-Perf | 34 | Ericsson | Ericsson | Rel-13 | 66 | RP-151131 |  |
| 1532 | 462.56 | **LTE Advanced intra-band non-contiguous Carrier Aggregation in Band 41 for 4 DL** | 262d? | 2014-12-15 A | 2015-12-15 A | 100% |  |  |  |  | R4 | 6288h | 6288h | LTE_CA_NC_B41_4DL | 34 | Alcatel-Lucent | Alcatel-Lucent | Rel-13 | 66 |  |  |
| 1533 | 462.56.1 | Core part:LTE Advanced intra-band non-contiguous Carrier Aggregation in Band 41 for 4 DL | 262d? | 2014-12-15 A | 2015-12-15 A | 100% |  |  |  | finish no earlier than 2015-12-15 | R4 | 2096h | 2096h | LTE_CA_NC_B41_4DL-Core | 34 | Alcatel-Lucent | Alcatel-Lucent | Rel-13 | 66 | RP-151131 |  |
| 1534 | 462.56.2 | Perf. part:LTE Advanced intra-band non-contiguous Carrier Aggregation in Band 41 for 4 DL | 262d? | 2014-12-15 A | 2015-12-15 A | 100% | 2013-09-18 | 2015-12-24 | 593d? | finish no earlier than 2015-12-15 | R4 | 2096h | 2096h | LTE_CA_NC_B41_4DL-Perf | 31 | Alcatel-Lucent | Alcatel-Lucent | Rel-13 | 66 | RP-151131 | TEI13 |
| 1535 | 462.57 | **LTE Advanced 3 Band Carrier Aggregation (3DL/1UL) of Band 1, Band 3 and Band 42** | 66d? | 2015-03-16 A | 2015-06-15 A | 100% |  |  |  |  | R4 | 1584h | 1584h | LTE_CA_B1_B3_B42 | 34 | NTT DOCOMO, INC. |  | Rel-13 | 67 |  |  |
| 1536 | 462.57.1 | Core part:LTE Advanced 3 Band Carrier Aggregation (3DL/1UL) of Band 1, Band 3 and Band 42 | 66d? | 2015-03-16 A | 2015-06-15 A | 100% |  |  |  | finish no earlier than 2015-09-15 | R4 | 528h | 528h | LTE_CA_B1_B3_B42-Core | 34 | NTT DOCOMO, INC. |  | Rel-13 | 67 | RP-150536 |  |
| 1537 | 462.57.2 | Perf. part:LTE Advanced 3 Band Carrier Aggregation (3DL/1UL) of Band 1, Band 3 and Band 42 | 66d? | 2015-03-16 A | 2015-06-15 A | 100% |  |  |  | finish no earlier than 2015-09-15 | R4 | 528h | 528h | LTE_CA_B1_B3_B42-Perf | 34 | NTT DOCOMO, INC. |  | Rel-13 | 67 | RP-150536 |  |
| 1538 | 462.58 | **LTE Advanced 3 Band Carrier Aggregation (3DL/1UL) of Band 1, Band 19 and Band 42** | 66d? | 2015-03-16 A | 2015-06-15 A | 100% |  |  |  |  | R4 | 1584h | 1584h | LTE_CA_B1_B19_B42 | 34 | NTT DOCOMO, INC. |  | Rel-13 | 67 |  |  |
| 1539 | 462.58.1 | Core part:LTE Advanced 3 Band Carrier Aggregation (3DL/1UL) of Band 1, Band 19 and Band 42 | 66d? | 2015-03-16 A | 2015-06-15 A | 100% |  |  |  | finish no earlier than 2015-09-15 | R4 | 528h | 528h | LTE_CA_B1_B19_B42-Core | 34 | NTT DOCOMO, INC. |  | Rel-13 | 67 | RP-150536 |  |
| 1540 | 462.58.2 | Perf. part:LTE Advanced 3 Band Carrier Aggregation (3DL/1UL) of Band 1, Band 19 and Band 42 | 66d? | 2015-03-16 A | 2015-06-15 A | 100% |  |  |  | finish no earlier than 2015-09-15 | R4 | 528h | 528h | LTE_CA_B1_B19_B42-Perf | 34 | NTT DOCOMO, INC. |  | Rel-13 | 67 | RP-150536 |  |
| 1541 | 462.59 | **LTE Advanced 3 Band Carrier Aggregation (3DL/1UL) of Band 1, Band 21 and Band 42** | 66d? | 2015-03-16 A | 2015-06-15 A | 100% |  |  |  |  | R4 | 1584h | 1584h | LTE_CA_B1_B21_B42 | 34 | NTT DOCOMO, INC. |  | Rel-13 | 67 |  |  |
| 1542 | 462.59.1 | Core part:LTE Advanced 3 Band Carrier Aggregation (3DL/1UL) of Band 1, Band 21 and Band 42 | 66d? | 2015-03-16 A | 2015-06-15 A | 100% |  |  |  | finish no earlier than 2015-09-15 | R4 | 528h | 528h | LTE_CA_B1_B21_B42-Core | 34 | NTT DOCOMO, INC. |  | Rel-13 | 67 | RP-150536 |  |
| 1543 | 462.59.2 | Perf. part:LTE Advanced 3 Band Carrier Aggregation (3DL/1UL) of Band 1, Band 21 and Band 42 | 66d? | 2015-03-16 A | 2015-06-15 A | 100% |  |  |  | finish no earlier than 2015-09-15 | R4 | 528h | 528h | LTE_CA_B1_B21_B42-Perf | 34 | NTT DOCOMO, INC. |  | Rel-13 | 67 | RP-150536 |  |
| 1544 | 462.60 | **LTE Advanced 3 Band Carrier Aggregation (3DL/1UL) of Band 3, Band 19 and Band 42** | 66d? | 2015-03-16 A | 2015-06-15 A | 100% |  |  |  |  | R4 | 1584h | 1584h | LTE_CA_B3_B19_B42 | 34 | NTT DOCOMO, INC. |  | Rel-13 | 67 |  |  |
| 1545 | 462.60.1 | Core part:LTE Advanced 3 Band Carrier Aggregation (3DL/1UL) of Band 3, Band 19 and Band 42 | 66d? | 2015-03-16 A | 2015-06-15 A | 100% |  |  |  | finish no earlier than 2015-09-15 | R4 | 528h | 528h | LTE_CA_B3_B19_B42-Core | 34 | NTT DOCOMO, INC. |  | Rel-13 | 67 | RP-150536 |  |
| 1546 | 462.60.2 | Perf. part:LTE Advanced 3 Band Carrier Aggregation (3DL/1UL) of Band 3, Band 19 and Band 42 | 66d? | 2015-03-16 A | 2015-06-15 A | 100% |  |  |  | finish no earlier than 2015-09-15 | R4 | 528h | 528h | LTE_CA_B3_B19_B42-Perf | 34 | NTT DOCOMO, INC. |  | Rel-13 | 67 | RP-150536 |  |
| 1547 | 462.61 | **LTE Advanced 3 Band Carrier Aggregation (3DL/1UL) of Band 19, Band 21 and Band 42** | 66d? | 2015-03-16 A | 2015-06-15 A | 100% |  |  |  |  | R4 | 1584h | 1584h | LTE_CA_B19_B21_B42 | 34 | NTT DOCOMO, INC. |  | Rel-13 | 67 |  |  |
| 1548 | 462.61.1 | Core part:LTE Advanced 3 Band Carrier Aggregation (3DL/1UL) of Band 19, Band 21 and Band 42 | 66d? | 2015-03-16 A | 2015-06-15 A | 100% |  |  |  | finish no earlier than 2015-09-15 | R4 | 528h | 528h | LTE_CA_B19_B21_B42-Core | 34 | NTT DOCOMO, INC. |  | Rel-13 | 67 | RP-150536 |  |
| 1549 | 462.61.2 | Perf. part:LTE Advanced 3 Band Carrier Aggregation (3DL/1UL) of Band 19, Band 21 and Band 42 | 66d? | 2015-03-16 A | 2015-06-15 A | 100% |  |  |  | finish no earlier than 2015-09-15 | R4 | 528h | 528h | LTE_CA_B19_B21_B42-Perf | 34 | NTT DOCOMO, INC. |  | Rel-13 | 67 | RP-150536 |  |

Notes:
- 1527: 1st Apr 15: Compl:0%->50% 1st Apr 15: WID: RP-141975->RP-150408 1st Apr 15: Stat Rep: ->RP-150013 03/07/15: Stat Rep: RP-150013->RP-150536 29/09/15: Stat Rep: RP-150536->RP-151131
- 1528: 1st Apr 15: Compl:0%->50% 1st Apr 15: WID: RP-141975->RP-150408 1st Apr 15: Stat Rep: ->RP-150013 03/07/15: Stat Rep: RP-150013->RP-150536 29/09/15: Stat Rep: RP-150536->RP-151131
- 1530: 1st Apr 15: Compl:0%->25% 1st Apr 15: WID: RP-142010->RP-150409 1st Apr 15: Stat Rep: ->RP-150013 03/07/15: Compl:25%->50% 03/07/15: Stat Rep: RP-150013->RP-150536 29/09/15: Compl:50%->75% 29/09/15: Stat Rep: RP-150536->RP-151131;
- 1531: 1st Apr 15: Compl:0%->25% 1st Apr 15: WID: RP-142010->RP-150409 1st Apr 15: Stat Rep: ->RP-150013 03/07/15: Compl:25%->50% 03/07/15: Stat Rep: RP-150013->RP-150536 29/09/15: Compl:50%->75% 29/09/15: Stat Rep: RP-150536->RP-151131;
- 1533: 1st Apr 15: Compl:0%->10% 1st Apr 15: CD:Tue 15/03/16->Tue 15/12/15 1st Apr 15: Stat Rep: ->RP-150013 03/07/15: Compl:10%->50% 03/07/15: Stat Rep: RP-150013->RP-150536 29/09/15: Compl:50%->80% 29/09/15: Stat Rep: RP-150536->RP-151131
- 1534: 1st Apr 15: Compl:0%->10% 1st Apr 15: CD:Tue 18/12/18->Tue 15/12/15 1st Apr 15: Stat Rep: -->RP-150013 03/07/15: Compl:10%->25% 03/07/15: Stat Rep: RP-150013->RP-150536 29/09/15: Compl:25%->50% 29/09/15: Stat Rep: RP-150536->RP-151131 ;
- 1536: 03/07/15: Compl:0%->100% 03/07/15: CD:Tue 15/09/15->Mon 15/06/15 03/07/15: WID: RP-150121->RP-150641 03/07/15: Stat Rep: ->RP-150536
- 1537: 03/07/15: Compl:0%->100% 03/07/15: CD:Tue 15/09/15->Mon 15/06/15 03/07/15: WID: RP-150121->RP-150641 03/07/15: Stat Rep: ->RP-150536
- 1539: 03/07/15: Compl:0%->100% 03/07/15: CD:Tue 15/09/15->Mon 15/06/15 03/07/15: WID: RP-150122->RP-150642 03/07/15: Stat Rep: ->RP-150536
- 1540: 03/07/15: Compl:0%->100% 03/07/15: CD:Tue 15/09/15->Mon 15/06/15 03/07/15: WID: RP-150122->RP-150642 03/07/15: Stat Rep: ->RP-150536
- 1542: 03/07/15: Compl:0%->100% 03/07/15: CD:Tue 15/09/15->Mon 15/06/15 03/07/15: WID: RP-150123->RP-150643 03/07/15: Stat Rep: ->RP-150536
- 1543: 03/07/15: Compl:0%->100% 03/07/15: CD:Tue 15/09/15->Mon 15/06/15 03/07/15: WID: RP-150123->RP-150643 03/07/15: Stat Rep: ->RP-150536
- 1545: 03/07/15: Compl:0%->100% 03/07/15: CD:Tue 15/09/15->Mon 15/06/15 03/07/15: WID: RP-150124->RP-150644 03/07/15: Stat Rep: ->RP-150536
- 1546: 03/07/15: Compl:0%->100% 03/07/15: CD:Tue 15/09/15->Mon 15/06/15 03/07/15: WID: RP-150124->RP-150644 03/07/15: Stat Rep: ->RP-150536
- 1548: 03/07/15: Compl:0%->100% 03/07/15: CD:Tue 15/09/15->Mon 15/06/15 03/07/15: WID: RP-150125->RP-150645 03/07/15: Stat Rep: ->RP-150536
- 1549: 03/07/15: Compl:0%->100% 03/07/15: CD:Tue 15/09/15->Mon 15/06/15 03/07/15: WID: RP-150125->RP-150645 03/07/15: Stat Rep: ->RP-150536

| ID | WBS | Task | Duration | Start | Finish | Complete | Constraint | Resources | Work | Actual work | Acronym | PCG approved | WI rapporteur name | Release | TSG approved | Status Report |
| --- | --- | --- | --- | --- | --- | --- | --- | --- | --- | --- | --- | --- | --- | --- | --- | --- |
| 1550 | 462.62 | **Additional bandwidth combination set for LTE Advanced 3 Band Carrier Aggregation (3DL/1UL) of Band 4, Band 4 and Band 7** | 197d? | 2015-03-16 A | 2015-12-15 A | 100% |  | R4 | 4728h | 4728h | LTE_CA_B4_B4_B7_BWset | 34 | Rogers Communications | Rel-13 | 67 |  |
| 1551 | 462.62.1 | Core part: Additional bandwidth combination set for LTE Advanced 3 Band Carrier Aggregation (3DL/1UL) of Band 4, Band 4 and Band 7 | 197d? | 2015-03-16 A | 2015-12-15 A | 100% | finish no earlier than 2015-12-15 | R4 | 1576h | 1576h | LTE_CA_B4_B4_B7_BWset-Core | 34 | Rogers Communications | Rel-13 | 67 | RP-151131 |
| 1552 | 462.62.2 | Perf. part: Additional bandwidth combination set for LTE Advanced 3 Band Carrier Aggregation (3DL/1UL) of Band 4, Band 4 and Band 7 | 197d? | 2015-03-16 A | 2015-12-15 A | 100% | finish no earlier than 2015-12-15 | R4 | 1576h | 1576h | LTE_CA_B4_B4_B7_BWset-Perf | 34 | Rogers Communications | Rel-13 | 67 | RP-151131 |
| 1553 | 462.63 | **Additional bandwidth combination set for LTE Advanced 3 Band Carrier Aggregation (3DL/1UL) of Band 4, Band 7 and Band 12** | 197d? | 2015-03-16 A | 2015-12-15 A | 100% |  | R4 | 4728h | 4728h | LTE_CA_B4_B7_B12_BWset | 34 | Rogers Communications | Rel-13 | 67 |  |
| 1554 | 462.63.1 | Core part: Additional bandwidth combination set for LTE Advanced 3 Band Carrier Aggregation (3DL/1UL) of Band 4, Band 7 and Band 12 | 197d? | 2015-03-16 A | 2015-12-15 A | 100% | finish no earlier than 2015-12-15 | R4 | 1576h | 1576h | LTE_CA_B4_B7_B12_BWset-Core | 34 | Rogers Communications | Rel-13 | 67 | RP-151131 |
| 1555 | 462.63.2 | Perf. part: Additional bandwidth combination set for LTE Advanced 3 Band Carrier Aggregation (3DL/1UL) of Band 4, Band 7 and Band 12 | 197d? | 2015-03-16 A | 2015-12-15 A | 100% | finish no earlier than 2015-12-15 | R4 | 1576h | 1576h | LTE_CA_B4_B7_B12_BWset-Perf | 34 | Rogers Communications | Rel-13 | 67 | RP-151131 |
| 1556 | 462.64 | **LTE Advanced 3 Band Carrier Aggregation (3DL/1UL) of Band 2, Band 7 and Band 12** | 262d? | 2015-03-16 A | 2016-03-15 A | 100% |  | R4 | 6288h | 6288h | LTE_CA_B2_B7_B12 | 34 | Rogers Communications | Rel-13 | 67 |  |
| 1557 | 462.64.1 | Core part:LTE Advanced 3 Band Carrier Aggregation (3DL/1UL) of Band 2, Band 7 and Band 12 | 262d? | 2015-03-16 A | 2016-03-15 A | 100% | finish no earlier than 2016-03-15 | R4 | 2096h | 2096h | LTE_CA_B2_B7_B12-Core | 34 | Rogers Communications | Rel-13 | 67 | RP-151131 |
| 1558 | 462.64.2 | Perf. part:LTE Advanced 3 Band Carrier Aggregation (3DL/1UL) of Band 2, Band 7 and Band 12 | 262d? | 2015-03-16 A | 2016-03-15 A | 100% | finish no earlier than 2016-03-15 | R4 | 2096h | 2096h | LTE_CA_B2_B7_B12-Perf | 34 | Rogers Communications | Rel-13 | 67 | RP-151131 |
| 1559 | 462.65 | **LTE Advanced 3 Band Carrier Aggregation (3DL/1UL) of Band 2, Band 4 and Band 7** | 262d? | 2015-03-16 A | 2016-03-15 A | 100% |  | R4 | 6288h | 6288h | LTE_CA_B2_B4_B7 | 34 | Rogers Communications | Rel-13 | 67 |  |
| 1560 | 462.65.1 | Core part:LTE Advanced 3 Band Carrier Aggregation (3DL/1UL) of Band 2, Band 4 and Band 7 | 262d? | 2015-03-16 A | 2016-03-15 A | 100% | finish no earlier than 2016-03-15 | R4 | 2096h | 2096h | LTE_CA_B2_B4_B7-Core | 34 | Rogers Communications | Rel-13 | 67 | RP-151131 |
| 1561 | 462.65.2 | Perf. part:LTE Advanced 3 Band Carrier Aggregation (3DL/1UL) of Band 2, Band 4 and Band 7 | 262d? | 2015-03-16 A | 2016-03-15 A | 100% | finish no earlier than 2016-03-15 | R4 | 2096h | 2096h | LTE_CA_B2_B4_B7-Perf | 34 | Rogers Communications | Rel-13 | 67 | RP-151131 |
| 1562 | 462.66 | **LTE Advanced 3 Band Carrier Aggregation (3DL/1UL) of Band 7, Band 20 and Band 38** | 197d? | 2015-03-16 A | 2015-12-15 A | 100% |  | R4 | 4728h | 4728h | LTE_CA_B7_B20_B38 | 34 | Nokia Networks | Rel-13 | 67 |  |
| 1563 | 462.66.1 | Core part:LTE Advanced 3 Band Carrier Aggregation (3DL/1UL) of Band 7, Band 20 and Band 38 | 197d? | 2015-03-16 A | 2015-12-15 A | 100% | finish no earlier than 2015-12-15 | R4 | 1576h | 1576h | LTE_CA_B7_B20_B38-Core | 34 | Nokia Networks | Rel-13 | 67 | RP-151131 |
| 1564 | 462.66.2 | Perf. part:LTE Advanced 3 Band Carrier Aggregation (3DL/1UL) of Band 7, Band 20 and Band 38 | 197d? | 2015-03-16 A | 2015-12-15 A | 100% | finish no earlier than 2015-12-15 | R4 | 1576h | 1576h | LTE_CA_B7_B20_B38-Perf | 34 | Nokia Networks | Rel-13 | 67 | RP-151131 |
| 1565 | 462.67 | **LTE Advanced 4 Band Carrier Aggregation (4DL/1UL) of Band 2, Band 4, Band 4 and Band 12** | 197d? | 2015-03-16 A | 2015-12-15 A | 100% |  | R4 | 4728h | 4728h | LTE_CA_B2_B4_B4_B12 | 34 | Nokia Networks | Rel-13 | 67 |  |
| 1566 | 462.67.1 | Core part:LTE Advanced 4 Band Carrier Aggregation (4DL/1UL) of Band 2, Band 4, Band 4 and Band 12 | 197d? | 2015-03-16 A | 2015-12-15 A | 100% | finish no earlier than 2015-12-15 | R4 | 1576h | 1576h | LTE_CA_B2_B4_B4_B12-Core | 34 | Nokia Networks | Rel-13 | 67 | RP-151131 |
| 1567 | 462.67.2 | Perf. part:LTE Advanced 4 Band Carrier Aggregation (4DL/1UL) of Band 2, Band 4, Band 4 and Band 12 | 197d? | 2015-03-16 A | 2015-12-15 A | 100% | finish no earlier than 2015-12-15 | R4 | 1576h | 1576h | LTE_CA_B2_B4_B4_B12-Perf | 34 | Nokia Networks | Rel-13 | 67 | RP-151131 |
| 1568 | 462.68 | **LTE Advanced 4 Band Carrier Aggregation (4DL/1UL) of Band 2, Band 2, Band 4 and Band 12** | 197d? | 2015-03-16 A | 2015-12-15 A | 100% |  | R4 | 4728h | 4728h | LTE_CA_B2_B2_B4_B12 | 34 | Nokia Networks | Rel-13 | 67 |  |
| 1569 | 462.68.1 | Core part:LTE Advanced 4 Band Carrier Aggregation (4DL/1UL) of Band 2, Band 2, Band 4 and Band 12 | 197d? | 2015-03-16 A | 2015-12-15 A | 100% | finish no earlier than 2015-12-15 | R4 | 1576h | 1576h | LTE_CA_B2_B2_B4_B12-Core | 34 | Nokia Networks | Rel-13 | 67 | RP-151131 |
| 1570 | 462.68.2 | Perf. part:LTE Advanced 4 Band Carrier Aggregation (4DL/1UL) of Band 2, Band 2, Band 4 and Band 12 | 197d? | 2015-03-16 A | 2015-12-15 A | 100% | finish no earlier than 2015-12-15 | R4 | 1576h | 1576h | LTE_CA_B2_B2_B4_B12-Perf | 34 | Nokia Networks | Rel-13 | 67 | RP-151131 |
| 1571 | 462.69 | **LTE Advanced 4 Band Carrier Aggregation (4DL/1UL) of Band 2, Band 2, Band 4 and Band 4** | 197d? | 2015-03-16 A | 2015-12-15 A | 100% |  | R4 | 4728h | 4728h | LTE_CA_B2_B2_B4_B4 | 34 | Nokia Networks | Rel-13 | 67 |  |
| 1572 | 462.69.1 | Core part:LTE Advanced 4 Band Carrier Aggregation (4DL/1UL) of Band 2, Band 2, Band 4 and Band 4 | 197d? | 2015-03-16 A | 2015-12-15 A | 100% | finish no earlier than 2015-12-15 | R4 | 1576h | 1576h | LTE_CA_B2_B2_B4_B4-Core | 34 | Nokia Networks | Rel-13 | 67 | RP-151131 |
| 1573 | 462.69.2 | Perf. part:LTE Advanced 4 Band Carrier Aggregation (4DL/1UL) of Band 2, Band 2, Band 4 and Band 4 | 197d? | 2015-03-16 A | 2015-12-15 A | 100% | finish no earlier than 2015-12-15 | R4 | 1576h | 1576h | LTE_CA_B2_B2_B4_B4-Perf | 34 | Nokia Networks | Rel-13 | 67 | RP-151131 |

Notes:
- 1551: 03/07/15: CD:Tue 15/09/15->Tue 15/12/15 03/07/15: Stat Rep: ->RP-150536 29/09/15: Stat Rep: RP-150536->RP-151131
- 1552: 03/07/15: CD:Tue 15/09/15->Tue 15/12/15 03/07/15: Stat Rep: ->RP-150536 29/09/15: Stat Rep: RP-150536->RP-151131
- 1554: 03/07/15: CD:Tue 15/09/15->Tue 15/12/15 03/07/15: Stat Rep: ->RP-150536 29/09/15: Stat Rep: RP-150536->RP-151131
- 1555: 03/07/15: CD:Tue 15/09/15->Tue 15/12/15 03/07/15: Stat Rep: ->RP-150536 29/09/15: Stat Rep: RP-150536->RP-151131
- 1557: 03/07/15: Stat Rep: ->RP-150536 29/09/15: Stat Rep: RP-150536->RP-151131 ; 1/122/3/16: Compl:0%->100%
- 1558: 03/07/15: Stat Rep: ->RP-150536 29/09/15: Stat Rep: RP-150536->RP-151131 122/3/16: Compl:0%->100%
- 1560: 03/07/15: Stat Rep: ->RP-150536 29/09/15: Stat Rep: RP-150536->RP-1511311/1/16:22/3/16: Compl:0%->100%
- 1561: 03/07/15: Stat Rep: ->RP-150536 29/09/15: Stat Rep: RP-150536->RP-151131 1/1/1; 22/3/16: Compl:0%->100%
- 1563: 03/07/15: Compl:0%->30% 03/07/15: Stat Rep: ->RP-150536 29/09/15: Compl:30%->60% 29/09/15: Stat Rep: RP-150536->RP-151131
- 1564: 03/07/15: Compl:0%->30% 03/07/15: Stat Rep: ->RP-150536 29/09/15: Compl:30%->60% 29/09/15: Stat Rep: RP-150536->RP-151131
- 1566: 03/07/15: Compl:0%->95% 03/07/15: WID: RP-150073->RP-150660 03/07/15: Stat Rep: ->RP-150536 29/09/15: Stat Rep: RP-150536->RP-151131
- 1567: 03/07/15: Compl:0%->95% 03/07/15: WID: RP-150073->RP-150660 03/07/15: Stat Rep: ->RP-150536 29/09/15: Stat Rep: RP-150536->RP-151131
- 1569: 03/07/15: Compl:0%->95% 03/07/15: WID: RP-150074->RP-150659 03/07/15: Stat Rep: ->RP-150536 29/09/15: Stat Rep: RP-150536->RP-151131
- 1570: 03/07/15: Compl:0%->95% 03/07/15: WID: RP-150074->RP-150659 03/07/15: Stat Rep: ->RP-150536 29/09/15: Stat Rep: RP-150536->RP-151131
- 1572: 03/07/15: Compl:0%->95% 03/07/15: WID: RP-150075->RP-150658 03/07/15: Stat Rep: ->RP-150536 29/09/15: Stat Rep: RP-150536->RP-151131
- 1573: 03/07/15: Compl:0%->95% 03/07/15: WID: RP-150075->RP-150658 03/07/15: Stat Rep: ->RP-150536 29/09/15: Stat Rep: RP-150536->RP-151131

| ID | WBS | Task | Duration | Start | Finish | Complete | Constraint | Resources | Work | Actual work | Acronym | PCG approved | WI rapporteur name | Release | TSG approved | Status Report |
| --- | --- | --- | --- | --- | --- | --- | --- | --- | --- | --- | --- | --- | --- | --- | --- | --- |
| 1574 | 462.70 | **LTE Advanced 4 Band Carrier Aggregation (4DL/1UL) of Band 1, Band 3, Band 5 and Band 40** | 197d? | 2015-03-16 A | 2015-12-15 A | 100% |  | R4 | 4728h | 4728h | LTE_CA_B1_B3_B5_B40 | 34 | SK Telecom | Rel-13 | 67 |  |
| 1575 | 462.70.1 | Core part:LTE Advanced 4 Band Carrier Aggregation (4DL/1UL) of Band 1, Band 3, Band 5 and Band 40 | 197d? | 2015-03-16 A | 2015-12-15 A | 100% | finish no earlier than 2015-12-15 | R4 | 1576h | 1576h | LTE_CA_B1_B3_B5_B40-Core | 34 | SK Telecom | Rel-13 | 67 | RP-151131 |
| 1576 | 462.70.2 | Perf. part:LTE Advanced 4 Band Carrier Aggregation (4DL/1UL) of Band 1, Band 3, Band 5 and Band 40 | 197d? | 2015-03-16 A | 2015-12-15 A | 100% | finish no earlier than 2015-12-15 | R4 | 1576h | 1576h | LTE_CA_B1_B3_B5_B40-Perf | 34 | SK Telecom | Rel-13 | 67 | RP-151131 |
| 1577 | 462.71 | **LTE Advanced 4 Band Carrier Aggregation (4DL/1UL) of Band 1, Band 3, Band 7 and Band 8** | 197d? | 2015-03-16 A | 2015-12-15 A | 100% |  | R4 | 4728h | 4728h | LTE_CA_B1_B3_B7_B8 | 34 | Nokia Networks | Rel-13 | 67 |  |
| 1578 | 462.71.1 | Core part:LTE Advanced 4 Band Carrier Aggregation (4DL/1UL) of Band 1, Band 3, Band 7 and Band 8 | 197d? | 2015-03-16 A | 2015-12-15 A | 100% | finish no earlier than 2015-12-15 | R4 | 1576h | 1576h | LTE_CA_B1_B3_B7_B8-Core | 34 | Nokia Networks | Rel-13 | 67 | RP-151131 |
| 1579 | 462.71.2 | Perf. part:LTE Advanced 4 Band Carrier Aggregation (4DL/1UL) of Band 1, Band 3, Band 7 and Band 8 | 197d? | 2015-03-16 A | 2015-12-15 A | 100% | finish no earlier than 2015-12-15 | R4 | 1576h | 1576h | LTE_CA_B1_B3_B7_B8-Perf | 34 | Nokia Networks | Rel-13 | 67 | RP-151131 |
| 1580 | 462.72 | **LTE Advanced 4 Band Carrier Aggregation (4DL/1UL) of Band 2, Band 4, Band 5 and Band 29** | 197d? | 2015-03-16 A | 2015-12-15 A | 100% |  | R4 | 4728h | 4728h | LTE_CA_B2_B4_B5_B29 | 34 | Huawei | Rel-13 | 67 |  |
| 1581 | 462.72.1 | Core part:LTE Advanced 4 Band Carrier Aggregation (4DL/1UL) of Band 2, Band 4, Band 5 and Band 29 | 197d? | 2015-03-16 A | 2015-12-15 A | 100% | finish no earlier than 2015-12-15 | R4 | 1576h | 1576h | LTE_CA_B2_B4_B5_B29-Core | 34 | Huawei | Rel-13 | 67 | RP-151131 |
| 1582 | 462.72.2 | Perf. part:LTE Advanced 4 Band Carrier Aggregation (4DL/1UL) of Band 2, Band 4, Band 5 and Band 29 | 197d? | 2015-03-16 A | 2015-12-15 A | 100% | finish no earlier than 2015-12-15 | R4 | 1576h | 1576h | LTE_CA_B2_B4_B5_B29-Perf | 34 | Huawei | Rel-13 | 67 | RP-151131 |
| 1583 | 462.73 | **LTE Advanced dual uplink inter-band Carrier Aggregation FDD-TDD** | 197d? | 2015-03-16 A | 2015-12-15 A | 100% |  | R4 | 4728h | 4728h | LTE_CA_2UL_FDD_TDD | 34 | KDDI | Rel-13 | 67 |  |
| 1584 | 462.73.1 | Core part:LTE Advanced dual uplink inter-band Carrier Aggregation FDD-TDD | 197d? | 2015-03-16 A | 2015-12-15 A | 100% | finish no earlier than 2015-12-15 | R4 | 1576h | 1576h | LTE_CA_2UL_FDD_TDD-Core | 34 | KDDI | Rel-13 | 67 | RP-151131 |
| 1585 | 462.73.2 | Perf. part:LTE Advanced dual uplink inter-band Carrier Aggregation FDD-TDD | 197d? | 2015-03-16 A | 2015-12-15 A | 100% | finish no earlier than 2015-12-15 | R4 | 1576h | 1576h | LTE_CA_2UL_FDD_TDD-Perf | 34 | KDDI | Rel-13 | 67 | RP-151131 |
| 1586 | 462.74 | **LTE Advanced dual uplink inter-band Carrier Aggregation Class A4** | 197d? | 2015-03-16 A | 2015-12-15 A | 100% |  | R4 | 4728h | 4728h | LTE_CA_2UL_R13-A4 | 34 | Nokia Networks | Rel-13 | 67 |  |
| 1587 | 462.74.1 | Core part:LTE Advanced dual uplink inter-band Carrier Aggregation Class A4 in REL-13 | 197d? | 2015-03-16 A | 2015-12-15 A | 100% | finish no earlier than 2015-12-15 | R4 | 1576h | 1576h | LTE_CA_2UL_R13-A4-Core | 34 | Nokia Networks | Rel-13 | 67 | RP-151131 |
| 1588 | 462.74.2 | Perf. Part:LTE Advanced dual uplink inter-band Carrier Aggregation Class A4 in REL-13 | 197d? | 2015-03-16 A | 2015-12-15 A | 100% | finish no earlier than 2015-12-15 | R4 | 1576h | 1576h | LTE_CA_2UL_R13-A4-Perf | 34 | Nokia Networks | Rel-13 | 67 | RP-151131 |
| 1589 | 462.75 | **LTE Advanced 3DL/2UL inter-band Carrier Aggregation** | 197d? | 2015-03-16 A | 2015-12-15 A | 100% |  | R4 | 4728h | 4728h | LTE_CA_3DL_2UL | 34 | Nokia Corporation | Rel-13 | 67 |  |
| 1590 | 462.75.1 | Core part:LTE Advanced 3DL/2UL inter-band Carrier Aggregation | 197d? | 2015-03-16 A | 2015-12-15 A | 100% | finish no earlier than 2015-12-15 | R4 | 1576h | 1576h | LTE_CA_3DL_2UL-Core | 34 | Nokia Corporation | Rel-13 | 67 | RP-151131 |
| 1591 | 462.75.2 | Perf. part:LTE Advanced 3DL/2UL inter-band Carrier Aggregation | 197d? | 2015-03-16 A | 2015-12-15 A | 100% | finish no earlier than 2015-12-15 | R4 | 1576h | 1576h | LTE_CA_3DL_2UL-Perf | 34 | Nokia Corporation | Rel-13 | 67 | RP-151131 |
| 1592 | 462.76 | **LTE Advanced intra-band non-contiguous Carrier Aggregation in Band 42 for 3DL** | 66d? | 2015-03-16 A | 2015-06-15 A | 100% |  | R4 | 1584h | 1584h | LTE_CA_NC_B42_3DL | 34 | Huawei | Rel-13 | 67 |  |
| 1593 | 462.76.1 | Core part:LTE Advanced intra-band non-contiguous Carrier Aggregation in Band 42 for 3DL | 66d? | 2015-03-16 A | 2015-06-15 A | 100% | finish no earlier than 2015-09-15 | R4 | 528h | 528h | LTE_CA_NC_B42_3DL-Core | 34 | Huawei | Rel-13 | 67 | RP-150536 |
| 1594 | 462.76.2 | Perf. part:LTE Advanced intra-band non-contiguous Carrier Aggregation in Band 42 for 3DL | 66d? | 2015-03-16 A | 2015-06-15 A | 100% | finish no earlier than 2015-09-15 | R4 | 528h | 528h | LTE_CA_NC_B42_3DL-Perf | 34 | Huawei | Rel-13 | 67 | RP-150536 |
| 1595 | 462.77 | **LTE Advanced intra-band contiguous Carrier Aggregation in Band 8** | 197d? | 2015-03-16 A | 2015-12-15 A | 100% |  | R4 | 4728h | 4728h | LTE_CA_C_B8 | 34 | CMCC | Rel-13 | 67 |  |
| 1596 | 462.77.1 | Core part: LTE Advanced intra-band contiguous Carrier Aggregation in Band 8 | 197d? | 2015-03-16 A | 2015-12-15 A | 100% | finish no earlier than 2015-12-15 | R4 | 1576h | 1576h | LTE_CA_C_B8-Core | 34 | CMCC | Rel-13 | 67 | RP-151131 |
| 1597 | 462.77.2 | Perf. part: LTE Advanced intra-band contiguous Carrier Aggregation in Band 8 | 197d? | 2015-03-16 A | 2015-12-15 A | 100% | finish no earlier than 2015-12-15 | R4 | 1576h | 1576h | LTE_CA_C_B8-Perf | 34 | CMCC | Rel-13 | 67 | RP-151131 |

Notes:
- 1575: 03/07/15: Compl:0%->30% 03/07/15: WID: RP-150434->RP-150617 03/07/15: Stat Rep: ->RP-150536 29/09/15: Compl:30%->60% 29/09/15: CD:Tue 15/09/15->Tue 15/12/15 29/09/15: WID: RP-150617->RP-151216 29/09/15: Stat Rep: RP-150536->RP-151131
- 1576: 03/07/15: WID: RP-150434->RP-150617 03/07/15: Stat Rep: ->RP-150536 29/09/15: CD:Tue 15/09/15->Tue 15/12/15 29/09/15: WID: RP-150617->RP-151216 29/09/15: Stat Rep: RP-150536->RP-151131
- 1578: 03/07/15: Compl:0%->40% 03/07/15: Stat Rep: ->RP-150536 29/09/15: Compl:40%->45% 29/09/15: Stat Rep: RP-150536->RP-151131
- 1579: 03/07/15: Stat Rep: ->RP-150536 29/09/15: Stat Rep: RP-150536->RP-151131
- 1581: 03/07/15: Compl:0%->50% 03/07/15: Stat Rep: ->RP-150536 29/09/15: Compl:50%->95% 29/09/15: Stat Rep: RP-150536->RP-151131
- 1582: 03/07/15: Stat Rep: ->RP-150536 29/09/15: Compl:0%->95% 29/09/15: Stat Rep: RP-150536->RP-151131
- 1584: 03/07/15: Compl:0%->70% 03/07/15: Stat Rep: ->RP-150536 29/09/15: Compl:70%->90% 29/09/15: Stat Rep: RP-150536->RP-151131
- 1585: 03/07/15: CD:Tue 15/09/15->Tue 15/12/15 03/07/15: Stat Rep: ->RP-150536 29/09/15: Compl:0%->90% 29/09/15: Stat Rep: RP-150536->RP-151131
- 1587: 03/07/15: Compl:0%->25% 03/07/15: WID: RP-150410->RP-150616 03/07/15: Stat Rep: ->RP-150536 29/09/15: Compl:25%->75% 29/09/15: Stat Rep: RP-150536->RP-151131
- 1588: 03/07/15: Compl:0%->25% 03/07/15: WID: RP-150410->RP-150616 03/07/15: Stat Rep: ->RP-150536 29/09/15: Compl:25%->75% 29/09/15: Stat Rep: RP-150536->RP-151131
- 1590: 03/07/15: Compl:0%->25% 03/07/15: CD:Tue 15/03/16->Tue 15/12/15 03/07/15: Stat Rep: ->RP-150536 29/09/15: Compl:25%->75% 29/09/15: WID: RP-150479->RP-151230 29/09/15: Stat Rep: RP-150536->RP-151131
- 1591: 03/07/15: Compl:0%->25% 03/07/15: Stat Rep: ->RP-150536 29/09/15: Compl:25%->75% 29/09/15: CD:Tue 15/03/16->Tue 15/12/15 29/09/15: WID: RP-150479->RP-151230 29/09/15: Stat Rep: RP-150536->RP-151131
- 1593: 03/07/15: Compl:0%->100% 03/07/15: CD:Tue 15/09/15->Mon 15/06/15 03/07/15: Stat Rep: ->RP-150536
- 1594: 03/07/15: Compl:0%->100% 03/07/15: CD:Tue 15/09/15->Mon 15/06/15 03/07/15: Stat Rep: ->RP-150536
- 1596: 03/07/15: Compl:0%->60% 03/07/15: WID: RP-150437->RP-150809 03/07/15: Stat Rep: ->RP-150536 29/09/15: Compl:60%->90% 29/09/15: CD:Tue 15/09/15->Tue 15/12/15 29/09/15: WID: RP-150809->RP-151177 29/09/15: Stat Rep: RP-150536->RP-151131
- 1597: 03/07/15: WID: RP-150437->RP-150809 03/07/15: Stat Rep: ->RP-150536 29/09/15: Compl:0%->50% 29/09/15: CD:Tue 15/09/15->Tue 15/12/15 29/09/15: WID: RP-150809->RP-151177 29/09/15: Stat Rep: RP-150536->RP-151131;

| ID | WBS | Task | Duration | Start | Finish | Complete | Remaining | Total slack | Constraint | Resources | Work | Actual work | Acronym | PCG approved | WI rapporteur name | Release | TSG approved | Status Report |
| --- | --- | --- | --- | --- | --- | --- | --- | --- | --- | --- | --- | --- | --- | --- | --- | --- | --- | --- |
| 1598 | 462.78 | **LTE Advanced intra-band contiguous Carrier Aggregation in Band 42 for 4DL** | 197d? | 2015-03-16 A | 2015-12-15 A | 100% |  |  |  | R4 | 4728h | 4728h | LTE_CA_C_B42_4DL | 34 | CATT | Rel-13 | 67 |  |
| 1599 | 462.78.1 | Core part: LTE Advanced intra-band contiguous Carrier Aggregation in Band 42 for 4DL | 197d? | 2015-03-16 A | 2015-12-15 A | 100% |  |  | finish no earlier than 2015-12-15 | R4 | 1576h | 1576h | LTE_CA_C_B42_4DL-Core | 34 | CATT | Rel-13 | 67 | RP-151131 |
| 1600 | 462.78.2 | Perf. part: LTE Advanced intra-band contiguous Carrier Aggregation in Band 42 for 4DL | 197d? | 2015-03-16 A | 2015-12-15 A | 100% |  |  | finish no earlier than 2015-12-15 | R4 | 1576h | 1576h | LTE_CA_C_B42_4DL-Perf | 34 | CATT | Rel-13 | 67 | RP-151131 |
| 1601 | 462.79 | **LTE Advanced 3 Band Carrier Aggregation (3DL/1UL) of Band 1, Band 8 and Band 11** | 67d? | 2015-06-15 A | 2015-09-15 A | 100% |  |  |  | R4 | 1608h | 1608h | LTE_CA_B1_B8_B11 | 35 | Softbank Mobile | Rel-13 | 68 |  |
| 1602 | 462.79.1 | Core part:LTE Advanced 3 Band Carrier Aggregation (3DL/1UL) of Band 1, Band 8 and Band 11 | 67d? | 2015-06-15 A | 2015-09-15 A | 100% |  |  | finish no earlier than 2015-09-15 | R4 | 536h | 536h | LTE_CA_B1_B8_B11-Core | 35 | Softbank Mobile | Rel-13 | 68 | RP-151131 |
| 1603 | 462.79.2 | Perf. part:LTE Advanced 3 Band Carrier Aggregation (3DL/1UL) of Band 1, Band 8 and Band 11 | 67d? | 2015-06-15 A | 2015-09-15 A | 100% |  |  | finish no earlier than 2015-09-15 | R4 | 536h | 536h | LTE_CA_B1_B8_B11-Perf | 35 | Softbank Mobile | Rel-13 | 68 | RP-151131 |
| 1604 | 462.80 | **LTE Advanced 3 Band Carrier Aggregation (3DL/1UL) of Band 3, Band 20 and Band 32** | 197d? | 2015-06-15 A | 2016-03-15 | 90% | 19.69d? | 5150d |  | R4 | 4728h | 3364.8h | LTE_CA_B3_B20_B32 | 35 | Ericsson | Rel-13 | 68 |  |
| 1605 | 462.80.1 | Core part:LTE Advanced 3 Band Carrier Aggregation (3DL/1UL) of Band 3, Band 20 and Band 32 | 197d? | 2015-06-15 A | 2016-03-15 | 90% | 19.7d? | 5150d | finish no earlier than 2016-03-15 | R4 | 1576h | 1418.4h | LTE_CA_B3_B20_B32-Core | 35 | Ericsson | Rel-14 | 68 | RP-151131 |
| 1606 | 462.80.2 | Perf. part:LTE Advanced 3 Band Carrier Aggregation (3DL/1UL) of Band 3, Band 20 and Band 32 | 197d? | 2015-06-15 A | 2016-03-15 | 90% | 19.7d? | 5150d | finish no earlier than 2016-03-15 | R4 | 1576h | 1418.4h | LTE_CA_B3_B20_B32-Perf | 35 | Ericsson | Rel-14 | 68 | RP-151131 |
| 1607 | 462.81 | **LTE Advanced 3 Band Carrier Aggregation (3DL/1UL) for Band 7, Band 42 and Band 42** | 132d? | 2015-06-15 A | 2015-12-15 A | 100% |  |  |  | R4 | 3168h | 3168h | LTE_CA_B7_B42_B42 | 35 | Huawei | Rel-13 | 68 |  |
| 1608 | 462.81.1 | Core part:LTE Advanced 3 Band Carrier Aggregation (3DL/1UL) for Band 7, Band 42 and Band 42 | 132d? | 2015-06-15 A | 2015-12-15 A | 100% |  |  | finish no earlier than 2015-12-15 | R4 | 1056h | 1056h | LTE_CA_B7_B42_B42-Core | 35 | Huawei | Rel-13 | 68 | RP-151131 |
| 1609 | 462.81.2 | Perf. part:LTE Advanced 3 Band Carrier Aggregation (3DL/1UL) for Band 7, Band 42 and Band 42 | 132d? | 2015-06-15 A | 2015-12-15 A | 100% |  |  | finish no earlier than 2015-12-15 | R4 | 1056h | 1056h | LTE_CA_B7_B42_B42-Perf | 35 | Huawei | Rel-13 | 68 | RP-151131 |
| 1610 | 462.82 | **LTE Advanced 3 Band Carrier Aggregation (3DL/1UL) for Band 20, Band 42 and Band 42** | 67d? | 2015-06-15 A | 2015-09-15 A | 100% |  |  |  | R4 | 1608h | 1608h | LTE_CA_B20_B42_B42 | 35 | Huawei | Rel-13 | 68 |  |
| 1611 | 462.82.1 | Core part:LTE Advanced 3 Band Carrier Aggregation (3DL/1UL) for Band 20, Band 42 and Band 42 | 67d? | 2015-06-15 A | 2015-09-15 A | 100% |  |  | finish no earlier than 2015-12-15 | R4 | 536h | 536h | LTE_CA_B20_B42_B42-Core | 35 | Huawei | Rel-13 | 68 | RP-151131 |
| 1612 | 462.82.2 | Perf. part:LTE Advanced 3 Band Carrier Aggregation (3DL/1UL) for Band 20, Band 42 and Band 42 | 67d? | 2015-06-15 A | 2015-09-15 A | 100% |  |  | finish no earlier than 2015-12-15 | R4 | 536h | 536h | LTE_CA_B20_B42_B42-Perf | 35 | Huawei | Rel-13 | 68 | RP-151131 |
| 1613 | 462.83 | **LTE Advanced 3 Band Carrier Aggregation (3DL/1UL) for Band 3, Band 7 and Band 38** | 132d? | 2015-06-15 A | 2015-12-15 A | 100% |  |  |  | R4 | 3168h | 3168h | LTE_CA_B3_B7_B38 | 35 | Nokia Networks | Rel-13 | 68 |  |
| 1614 | 462.83.1 | Core part:LTE Advanced 3 Band Carrier Aggregation (3DL/1UL) for Band 3, Band 7 and Band 38 | 132d? | 2015-06-15 A | 2015-12-15 A | 100% |  |  | finish no earlier than 2015-12-15 | R4 | 1056h | 1056h | LTE_CA_B3_B7_B38-Core | 35 | Nokia Networks | Rel-13 | 68 | RP-151131 |
| 1615 | 462.83.2 | Perf. part:LTE Advanced 3 Band Carrier Aggregation (3DL/1UL) for Band 3, Band 7 and Band 38 | 132d? | 2015-06-15 A | 2015-12-15 A | 100% |  |  | finish no earlier than 2015-12-15 | R4 | 1056h | 1056h | LTE_CA_B3_B7_B38-Perf | 35 | Nokia Networks | Rel-13 | 68 | RP-151131 |
| 1616 | 462.84 | **LTE Advanced 3 Band Carrier Aggregation (3DL/1UL) of Band 28, Band 41 and Band 41** | 132d? | 2015-06-15 A | 2015-12-15 A | 100% |  |  |  | R4 | 3168h | 3168h | LTE_CA_B28_B41_B41 | 35 | KDDI | Rel-13 | 68 |  |
| 1617 | 462.84.1 | Core part:LTE Advanced 3 Band Carrier Aggregation (3DL/1UL) of Band 28, Band 41 and Band 41 | 132d? | 2015-06-15 A | 2015-12-15 A | 100% |  |  | finish no earlier than 2015-12-15 | R4 | 1056h | 1056h | LTE_CA_B28_B41_B41-Core | 35 | KDDI | Rel-13 | 68 | RP-151131 |
| 1618 | 462.84.2 | Perf. part:LTE Advanced 3 Band Carrier Aggregation (3DL/1UL) of Band 28, Band 41 and Band 41 | 132d? | 2015-06-15 A | 2015-12-15 A | 100% |  |  | finish no earlier than 2015-12-15 | R4 | 1056h | 1056h | LTE_CA_B28_B41_B41-Perf | 35 | KDDI | Rel-13 | 68 | RP-151131 |
| 1619 | 462.85 | **LTE Advanced 3 Band Carrier Aggregation (3DL/1UL) of Band 28, Band 42 and Band 42** | 132d? | 2015-06-15 A | 2015-12-15 A | 100% |  |  |  | R4 | 3168h | 3168h | LTE_CA_B28_B42_B42 | 35 | KDDI | Rel-13 | 68 |  |
| 1620 | 462.85.1 | Core part:LTE Advanced 3 Band Carrier Aggregation (3DL/1UL) of Band 28, Band 42 and Band 42 | 132d? | 2015-06-15 A | 2015-12-15 A | 100% |  |  | finish no earlier than 2015-12-15 | R4 | 1056h | 1056h | LTE_CA_B28_B42_B42-Core | 35 | KDDI | Rel-13 | 68 | RP-151131 |
| 1621 | 462.85.2 | Perf. part:LTE Advanced 3 Band Carrier Aggregation (3DL/1UL) of Band 28, Band 42 and Band 42 | 132d? | 2015-06-15 A | 2015-12-15 A | 100% |  |  | finish no earlier than 2015-12-15 | R4 | 1056h | 1056h | LTE_CA_B28_B42_B42-Perf | 35 | KDDI | Rel-13 | 68 | RP-151131 |

Notes:
- 1599: 03/07/15: Compl:0%->50% 03/07/15: Stat Rep: ->RP-150536 29/09/15: Compl:50%->80% 29/09/15: Stat Rep: RP-150536->RP-151131
- 1600: 03/07/15: Compl:0%->50% 03/07/15: Stat Rep: ->RP-150536 29/09/15: Compl:50%->80% 29/09/15: Stat Rep: RP-150536->RP-151131
- 1602: 29/09/15: Compl:0%->100% 29/09/15: Stat Rep: -->RP-151131
- 1603: 29/09/15: Compl:0%->100% 29/09/15: Stat Rep: -->RP-151131
- 1605: 29/09/15: Compl:0%->50% 29/09/15: Stat Rep: -->RP-1511311/22/3/16: Compl:50%->90%
- 1606: 29/09/15: Compl:0%->50% 29/09/15: Stat Rep: -->RP-151131 ; 22/3/16: Compl:50%->90%
- 1608: 29/09/15: Compl:0%->70% 29/09/15: Stat Rep: -->RP-151131
- 1609: 29/09/15: Compl:0%->70% 29/09/15: Stat Rep: -->RP-151131
- 1611: 29/09/15: Compl:0%->100% 29/09/15: CD:Tue 15/12/15->Tue 15/09/15 29/09/15: Stat Rep: -->RP-151131
- 1612: 29/09/15: Compl:0%->100% 29/09/15: CD:Tue 15/12/15->Tue 15/09/15 29/09/15: Stat Rep: -->RP-151131
- 1614: 29/09/15: Compl:0%->60% 29/09/15: Stat Rep: -->RP-1511311/1/16: Compl:
- 1615: 29/09/15: Compl:0%->60% 29/09/15: Stat Rep: -->RP-151131; 1/1/16: Comp
- 1617: 29/09/15: Compl:0%->50% 29/09/15: Stat Rep: -->RP-151131
- 1618: 29/09/15: Stat Rep: -->RP-151131
- 1620: 29/09/15: Compl:0%->40% 29/09/15: WID: RP-151112->RP-151158 29/09/15: Stat Rep: -->RP-151131
- 1621: 29/09/15: WID: RP-151112->RP-151158 29/09/15: Stat Rep: -->RP-151131;

| ID | WBS | Task | Duration | Start | Finish | Complete | Constraint | Resources | Work | Actual work | Acronym | PCG approved | WI rapporteur name | Release | TSG approved | Status Report |
| --- | --- | --- | --- | --- | --- | --- | --- | --- | --- | --- | --- | --- | --- | --- | --- | --- |
| 1622 | 462.86 | **LTE Advanced 4 Band Carrier Aggregation (4DL/1UL) of Band 2, Band 4, Band 7 and Band 12** | 197d? | 2015-06-15 A | 2016-03-15 A | 100% |  | R4 | 4728h | 4728h | LTE_CA_B2_B4_B7_B12 | 35 | Rogers Communications | Rel-13 | 68 |  |
| 1623 | 462.86.1 | Core part:LTE Advanced 4 Band Carrier Aggregation (4DL/1UL) of Band 2, Band 4, Band 7 and Band 12 | 197d? | 2015-06-15 A | 2016-03-15 A | 100% | finish no earlier than 2016-03-15 | R4 | 1576h | 1576h | LTE_CA_B2_B4_B7_B12-Core | 35 | Rogers Communications | Rel-13 | 68 | RP-151131 |
| 1624 | 462.86.2 | Perf. part:LTE Advanced 4 Band Carrier Aggregation (4DL/1UL) of Band 2, Band 4, Band 7 and Band 12 | 197d? | 2015-06-15 A | 2016-03-15 A | 100% | finish no earlier than 2016-03-15 | R4 | 1576h | 1576h | LTE_CA_B2_B4_B7_B12-Perf | 35 | Rogers Communications | Rel-13 | 68 | RP-151131 |
| 1625 | 462.87 | **LTE Advanced 4 Band Carrier Aggregation (4DL/1UL) of Band 1, Band 3, Band 19 and Band 42** | 132d? | 2015-06-15 A | 2015-12-15 A | 100% |  | R4 | 3168h | 3168h | LTE_CA_B1_B3_B19_B42 | 35 | NTT DOCOMO, INC. | Rel-13 | 68 |  |
| 1626 | 462.87.1 | Core part:LTE Advanced 4 Band Carrier Aggregation (4DL/1UL) of Band 1, Band 3, Band 19 and Band 42 | 132d? | 2015-06-15 A | 2015-12-15 A | 100% | finish no earlier than 2015-12-15 | R4 | 1056h | 1056h | LTE_CA_B1_B3_B19_B42-Core | 35 | NTT DOCOMO, INC. | Rel-13 | 68 | RP-151131 |
| 1627 | 462.87.2 | Perf. part:LTE Advanced 4 Band Carrier Aggregation (4DL/1UL) of Band 1, Band 3, Band 19 and Band 42 | 132d? | 2015-06-15 A | 2015-12-15 A | 100% | finish no earlier than 2015-12-15 | R4 | 1056h | 1056h | LTE_CA_B1_B3_B19_B42-Perf | 35 | NTT DOCOMO, INC. | Rel-13 | 68 | RP-151131 |
| 1628 | 462.88 | **LTE Advanced 4 Band Carrier Aggregation (4DL/1UL) of Band 1, Band 3, Band 42 and Band 42** | 132d? | 2015-06-15 A | 2015-12-15 A | 100% |  | R4 | 3168h | 3168h | LTE_CA_B1_B3_B42_B42 | 35 | NTT DOCOMO, INC. | Rel-13 | 68 |  |
| 1629 | 462.88.1 | Core part:LTE Advanced 4 Band Carrier Aggregation (4DL/1UL) of Band 1, Band 3, Band 42 and Band 42 | 132d? | 2015-06-15 A | 2015-12-15 A | 100% | finish no earlier than 2015-12-15 | R4 | 1056h | 1056h | LTE_CA_B1_B3_B42_B42-Core | 35 | NTT DOCOMO, INC. | Rel-13 | 68 | RP-151131 |
| 1630 | 462.88.2 | Perf. part:LTE Advanced 4 Band Carrier Aggregation (4DL/1UL) of Band 1, Band 3, Band 42 and Band 42 | 132d? | 2015-06-15 A | 2015-12-15 A | 100% | finish no earlier than 2015-12-15 | R4 | 1056h | 1056h | LTE_CA_B1_B3_B42_B42-Perf | 35 | NTT DOCOMO, INC. | Rel-13 | 68 | RP-151131 |
| 1631 | 462.89 | **LTE Advanced 4 Band Carrier Aggregation (4DL/1UL) of Band 1, Band 19, Band 42 and Band 42** | 132d? | 2015-06-15 A | 2015-12-15 A | 100% |  | R4 | 3168h | 3168h | LTE_CA_B1_B19_B42_B42 | 35 | NTT DOCOMO, INC. | Rel-13 | 68 |  |
| 1632 | 462.89.1 | Core part:LTE Advanced 4 Band Carrier Aggregation (4DL/1UL) of Band 1, Band 19, Band 42 and Band 42 | 132d? | 2015-06-15 A | 2015-12-15 A | 100% | finish no earlier than 2015-12-15 | R4 | 1056h | 1056h | LTE_CA_B1_B19_B42_B42-Core | 35 | NTT DOCOMO, INC. | Rel-13 | 68 | RP-151131 |
| 1633 | 462.89.2 | Perf. part:LTE Advanced 4 Band Carrier Aggregation (4DL/1UL) of Band 1, Band 19, Band 42 and Band 42 | 132d? | 2015-06-15 A | 2015-12-15 A | 100% | finish no earlier than 2015-12-15 | R4 | 1056h | 1056h | LTE_CA_B1_B19_B42_B42-Perf | 35 | NTT DOCOMO, INC. | Rel-13 | 68 | RP-151131 |
| 1634 | 462.90 | **LTE Advanced 4 Band Carrier Aggregation (4DL/1UL) of Band 3, Band 19, Band 42 and Band 42** | 132d? | 2015-06-15 A | 2015-12-15 A | 100% |  | R4 | 3168h | 3168h | LTE_CA_B3_B19_B42_B42 | 35 | NTT DOCOMO, INC. | Rel-13 | 68 |  |
| 1635 | 462.90.1 | Core part:LTE Advanced 4 Band Carrier Aggregation (4DL/1UL) of Band 3, Band 19, Band 42 and Band 42 | 132d? | 2015-06-15 A | 2015-12-15 A | 100% | finish no earlier than 2015-12-15 | R4 | 1056h | 1056h | LTE_CA_B3_B19_B42_B42-Core | 35 | NTT DOCOMO, INC. | Rel-13 | 68 | RP-151131 |
| 1636 | 462.90.2 | Perf. part:LTE Advanced 4 Band Carrier Aggregation (4DL/1UL) of Band 3, Band 19, Band 42 and Band 42 | 132d? | 2015-06-15 A | 2015-12-15 A | 100% | finish no earlier than 2015-12-15 | R4 | 1056h | 1056h | LTE_CA_B3_B19_B42_B42-Perf | 35 | NTT DOCOMO, INC. | Rel-13 | 68 | RP-151131 |
| 1637 | 462.91 | **LTE Advanced 4 Band Carrier Aggregation (4DL/1UL) of Band 1, Band 19, Band 21 and Band 42** | 132d? | 2015-06-15 A | 2015-12-15 A | 100% |  | R4 | 3168h | 3168h | LTE_CA_B1_B19_B21_B42 | 35 | NTT DOCOMO, INC. | Rel-13 | 68 |  |
| 1638 | 462.91.1 | Core part:LTE Advanced 4 Band Carrier Aggregation (4DL/1UL) of Band 1, Band 19, Band 21 and Band 42 | 132d? | 2015-06-15 A | 2015-12-15 A | 100% | finish no earlier than 2015-12-15 | R4 | 1056h | 1056h | LTE_CA_B1_B19_B21_B42-Core | 35 | NTT DOCOMO, INC. | Rel-13 | 68 | RP-151131 |
| 1639 | 462.91.2 | Perf. part:LTE Advanced 4 Band Carrier Aggregation (4DL/1UL) of Band 1, Band 19, Band 21 and Band 42 | 132d? | 2015-06-15 A | 2015-12-15 A | 100% | finish no earlier than 2015-12-15 | R4 | 1056h | 1056h | LTE_CA_B1_B19_B21_B42-Perf | 35 | NTT DOCOMO, INC. | Rel-13 | 68 | RP-151131 |
| 1640 | 462.92 | **LTE Advanced 4 Band Carrier Aggregation (4DL/1UL) of Band 1, Band 21, Band 42 and Band 42** | 132d? | 2015-06-15 A | 2015-12-15 A | 100% |  | R4 | 3168h | 3168h | LTE_CA_B1_B21_B42_B42 | 35 | NTT DOCOMO, INC. | Rel-13 | 68 |  |
| 1641 | 462.92.1 | Core part:LTE Advanced 4 Band Carrier Aggregation (4DL/1UL) of Band 1, Band 21, Band 42 and Band 42 | 132d? | 2015-06-15 A | 2015-12-15 A | 100% | finish no earlier than 2015-12-15 | R4 | 1056h | 1056h | LTE_CA_B1_B21_B42_B42-Core | 35 | NTT DOCOMO, INC. | Rel-13 | 68 | RP-151131 |
| 1642 | 462.92.2 | Perf. part:LTE Advanced 4 Band Carrier Aggregation (4DL/1UL) of Band 1, Band 21, Band 42 and Band 42 | 132d? | 2015-06-15 A | 2015-12-15 A | 100% | finish no earlier than 2015-12-15 | R4 | 1056h | 1056h | LTE_CA_B1_B21_B42_B42-Perf | 35 | NTT DOCOMO, INC. | Rel-13 | 68 | RP-151131 |
| 1643 | 462.93 | **LTE Advanced 4 Band Carrier Aggregation (4DL/1UL) of Band 19, Band 21, Band 42 and Band 42** | 132d? | 2015-06-15 A | 2015-12-15 A | 100% |  | R4 | 3168h | 3168h | LTE_CA_B19_B21_B42_B42 | 35 | NTT DOCOMO, INC. | Rel-13 | 68 |  |
| 1644 | 462.93.1 | Core part:LTE Advanced 4 Band Carrier Aggregation (4DL/1UL) of Band 19, Band 21, Band 42 and Band 42 | 132d? | 2015-06-15 A | 2015-12-15 A | 100% | finish no earlier than 2015-12-15 | R4 | 1056h | 1056h | LTE_CA_B19_B21_B42_B42-Core | 35 | NTT DOCOMO, INC. | Rel-13 | 68 | RP-151131 |
| 1645 | 462.93.2 | Perf. part:LTE Advanced 4 Band Carrier Aggregation (4DL/1UL) of Band 19, Band 21, Band 42 and Band 42 | 132d? | 2015-06-15 A | 2015-12-15 A | 100% | finish no earlier than 2015-12-15 | R4 | 1056h | 1056h | LTE_CA_B19_B21_B42_B42-Perf | 35 | NTT DOCOMO, INC. | Rel-13 | 68 | RP-151131 |

Notes:
- 1623: 29/09/15: Stat Rep: -->RP-151131 22/3/16: Compl:0%->100%
- 1624: 29/09/15: Stat Rep: -->RP-151131 ; 22/3/16: Compl:0%->100%
- 1626: 29/09/15: Compl:0%->95% 29/09/15: CD:Tue 15/09/15->Tue 15/12/15 29/09/15: Stat Rep: -->RP-151131
- 1627: 29/09/15: Compl:0%->95% 29/09/15: CD:Tue 15/09/15->Tue 15/12/15 29/09/15: Stat Rep: -->RP-151131
- 1629: 29/09/15: Compl:0%->95% 29/09/15: CD:Tue 15/09/15->Tue 15/12/15 29/09/15: Stat Rep: -->RP-151131
- 1630: 29/09/15: Compl:0%->95% 29/09/15: CD:Tue 15/09/15->Tue 15/12/15 29/09/15: Stat Rep: -->RP-151131
- 1632: 29/09/15: Compl:0%->95% 29/09/15: CD:Tue 15/09/15->Tue 15/12/15 29/09/15: Stat Rep: -->RP-151131
- 1633: 29/09/15: Compl:0%->95% 29/09/15: CD:Tue 15/09/15->Tue 15/12/15 29/09/15: Stat Rep: -->RP-151131
- 1635: 29/09/15: Compl:0%->95% 29/09/15: CD:Tue 15/09/15->Tue 15/12/15 29/09/15: Stat Rep: -->RP-151131
- 1636: 29/09/15: Compl:0%->95% 29/09/15: CD:Tue 15/09/15->Tue 15/12/15 29/09/15: Stat Rep: -->RP-151131
- 1638: 29/09/15: Compl:0%->95% 29/09/15: CD:Tue 15/09/15->Tue 15/12/15 29/09/15: Stat Rep: -->RP-151131
- 1639: 29/09/15: Compl:0%->95% 29/09/15: CD:Tue 15/09/15->Tue 15/12/15 29/09/15: Stat Rep: -->RP-151131
- 1641: 29/09/15: Compl:0%->95% 29/09/15: CD:Tue 15/09/15->Tue 15/12/15 29/09/15: Stat Rep: -->RP-151131
- 1642: 29/09/15: Compl:0%->95% 29/09/15: CD:Tue 15/09/15->Tue 15/12/15 29/09/15: Stat Rep: -->RP-151131
- 1644: 29/09/15: Compl:0%->95% 29/09/15: CD:Tue 15/09/15->Tue 15/12/15 29/09/15: Stat Rep: -->RP-151131
- 1645: 29/09/15: Compl:0%->95% 29/09/15: CD:Tue 15/09/15->Tue 15/12/15 29/09/15: Stat Rep: -->RP-151131

| ID | WBS | Task | Duration | Start | Finish | Complete | Constraint | Resources | Work | Actual work | Acronym | PCG approved | WI rapporteur name | Release | TSG approved | Status Report |
| --- | --- | --- | --- | --- | --- | --- | --- | --- | --- | --- | --- | --- | --- | --- | --- | --- |
| 1646 | 462.94 | **LTE Advanced 4 Band Carrier Aggregation (4DL/1UL) of Band 2, Band 4, Band 5 and Band 12** | 132d? | 2015-06-15 A | 2015-12-15 A | 100% |  | R4 | 3168h | 3168h | LTE_CA_B2_B4_B5_B12 | 35 | U.S. Cellular | Rel-13 | 68 |  |
| 1647 | 462.94.1 | Core part:LTE Advanced 4 Band Carrier Aggregation (4DL/1UL) of Band 2, Band 4, Band 5 and Band 12 | 132d? | 2015-06-15 A | 2015-12-15 A | 100% | finish no earlier than 2015-12-15 | R4 | 1056h | 1056h | LTE_CA_B2_B4_B5_B12-Core | 35 | U.S. Cellular | Rel-13 | 68 | RP-151131 |
| 1648 | 462.94.2 | Perf. part:LTE Advanced 4 Band Carrier Aggregation (4DL/1UL) of Band 2, Band 4, Band 5 and Band 12 | 132d? | 2015-06-15 A | 2015-12-15 A | 100% | finish no earlier than 2015-12-15 | R4 | 1056h | 1056h | LTE_CA_B2_B4_B5_B12-Perf | 35 | U.S. Cellular | Rel-13 | 68 | RP-151131 |
| 1649 | 462.95 | **LTE Advanced 4 Band Carrier Aggregation (4DL/1UL) of Band 2, Band 2, Band 4 and Band 5** | 132d? | 2015-06-15 A | 2015-12-15 A | 100% |  | R4 | 3168h | 3168h | LTE_CA_B2_B2_B4_B5 | 35 | U.S. Cellular | Rel-13 | 68 |  |
| 1650 | 462.95.1 | Core part:LTE Advanced 4 Band Carrier Aggregation (4DL/1UL) of Band 2, Band 2, Band 4 and Band 5 | 132d? | 2015-06-15 A | 2015-12-15 A | 100% | finish no earlier than 2015-12-15 | R4 | 1056h | 1056h | LTE_CA_B2_B2_B4_B5-Core | 35 | U.S. Cellular | Rel-13 | 68 | RP-151131 |
| 1651 | 462.95.2 | Perf. part:LTE Advanced 4 Band Carrier Aggregation (4DL/1UL) of Band 2, Band 2, Band 4 and Band 5 | 132d? | 2015-06-15 A | 2015-12-15 A | 100% | finish no earlier than 2015-12-15 | R4 | 1056h | 1056h | LTE_CA_B2_B2_B4_B5-Perf | 35 | U.S. Cellular | Rel-13 | 68 | RP-151131 |
| 1652 | 462.96 | **LTE Advanced 4-Band Carrier Aggregation (4DL/1UL) of Band 2, Band 2, Band 12 and Band 12** | 132d? | 2015-06-15 A | 2015-12-15 A | 100% |  | R4 | 3168h | 3168h | LTE_CA_B2_B2_B12_B12 | 35 | U.S. Cellular | Rel-13 | 68 |  |
| 1653 | 462.96.1 | Core part:LTE Advanced 4-Band Carrier Aggregation (4DL/1UL) of Band 2, Band 2, Band 12 and Band 12 | 132d? | 2015-06-15 A | 2015-12-15 A | 100% | finish no earlier than 2015-12-15 | R4 | 1056h | 1056h | LTE_CA_B2_B2_B12_B12-Core | 35 | U.S. Cellular | Rel-13 | 68 | RP-151131 |
| 1654 | 462.96.2 | Perf. part:LTE Advanced 4-Band Carrier Aggregation (4DL/1UL) of Band 2, Band 2, Band 12 and Band 12 | 132d? | 2015-06-15 A | 2015-12-15 A | 100% | finish no earlier than 2015-12-15 | R4 | 1056h | 1056h | LTE_CA_B2_B2_B12_B12-Perf | 35 | U.S. Cellular | Rel-13 | 68 | RP-151131 |
| 1655 | 462.97 | **LTE Advanced 4 Band Carrier Aggregation (4DL/1UL) of Band 4, Band 4, Band 5 and Band 30** | 197d? | 2015-06-15 A | 2016-03-15 A | 100% |  | R4 | 4728h | 4728h | LTE_CA_B4_B4_B5_B30 | 35 | AT&T | Rel-13 | 68 |  |
| 1656 | 462.97.1 | Core part:LTE Advanced 4 Band Carrier Aggregation (4DL/1UL) of Band 4, Band 4, Band 5 and Band 30 | 197d? | 2015-06-15 A | 2016-03-15 A | 100% | finish no earlier than 2016-03-15 | R4 | 1576h | 1576h | LTE_CA_B4_B4_B5_B30-Core | 35 | AT&T | Rel-13 | 68 | RP-151131 |
| 1657 | 462.97.2 | Perf. part:LTE Advanced 4 Band Carrier Aggregation (4DL/1UL) of Band 4, Band 4, Band 5 and Band 30 | 197d? | 2015-06-15 A | 2016-03-15 A | 100% | finish no earlier than 2016-03-15 | R4 | 1576h | 1576h | LTE_CA_B4_B4_B5_B30-Perf | 35 | AT&T | Rel-13 | 68 | RP-151131 |
| 1658 | 462.98 | **LTE Advanced 4 Band Carrier Aggregation (4DL/1UL) of Band 4, Band 4, Band 12 and Band 30** | 197d? | 2015-06-15 A | 2016-03-15 A | 100% |  | R4 | 4728h | 4728h | LTE_CA_B4_B4_B12_B30 | 35 | AT&T | Rel-13 | 68 |  |
| 1659 | 462.98.1 | Core part:LTE Advanced 4 Band Carrier Aggregation (4DL/1UL) of Band 4, Band 4, Band 12 and Band 30 | 197d? | 2015-06-15 A | 2016-03-15 A | 100% | finish no earlier than 2016-03-15 | R4 | 1576h | 1576h | LTE_CA_B4_B4_B12_B30-Core | 35 | AT&T | Rel-13 | 68 | RP-151131 |
| 1660 | 462.98.2 | Perf. part:LTE Advanced 4 Band Carrier Aggregation (4DL/1UL) of Band 4, Band 4, Band 12 and Band 30 | 197d? | 2015-06-15 A | 2016-03-15 A | 100% | finish no earlier than 2016-03-15 | R4 | 1576h | 1576h | LTE_CA_B4_B4_B12_B30-Perf | 35 | AT&T | Rel-13 | 68 | RP-151131 |
| 1661 | 462.99 | **LTE Advanced 4 Band Carrier Aggregation (4DL/1UL) of Band 4, Band 4, Band 29 and Band 30** | 197d? | 2015-06-15 A | 2016-03-15 A | 100% |  | R4 | 4728h | 4728h | LTE_CA_B4_B4_B29_B30 | 35 | AT&T | Rel-13 | 68 |  |
| 1662 | 462.99.1 | Core part:LTE Advanced 4 Band Carrier Aggregation (4DL/1UL) of Band 4, Band 4, Band 29 and Band 30 | 197d? | 2015-06-15 A | 2016-03-15 A | 100% | finish no earlier than 2016-03-15 | R4 | 1576h | 1576h | LTE_CA_B4_B4_B29_B30-Core | 35 | AT&T | Rel-13 | 68 | RP-151131 |
| 1663 | 462.99.2 | Perf. part:LTE Advanced 4 Band Carrier Aggregation (4DL/1UL) of Band 4, Band 4, Band 29 and Band 30 | 197d? | 2015-06-15 A | 2016-03-15 A | 100% | finish no earlier than 2016-03-15 | R4 | 1576h | 1576h | LTE_CA_B4_B4_B29_B30-Perf | 35 | AT&T | Rel-13 | 68 | RP-151131 |
| 1664 | 462.100 | **LTE Advanced 4 Band Carrier Aggregation (4DL/1UL) of Band 2, Band 2, Band 5 and Band 12** | 132d? | 2015-06-15 A | 2015-12-15 A | 100% |  | R4 | 3168h | 3168h | LTE_CA_B2_B2_B5_B12 | 35 | U.S. Cellular | Rel-13 | 68 |  |
| 1665 | 462.100.1 | Core part:LTE Advanced 4 Band Carrier Aggregation (4DL/1UL) of Band 2, Band 2, Band 5 and Band 12 | 132d? | 2015-06-15 A | 2015-12-15 A | 100% | finish no earlier than 2015-12-15 | R4 | 1056h | 1056h | LTE_CA_B2_B2_B5_B12-Core | 35 | U.S. Cellular | Rel-13 | 68 | RP-151131 |
| 1666 | 462.100.2 | Perf. part:LTE Advanced 4 Band Carrier Aggregation (4DL/1UL) of Band 2, Band 2, Band 5 and Band 12 | 132d? | 2015-06-15 A | 2015-12-15 A | 100% | finish no earlier than 2015-12-15 | R4 | 1056h | 1056h | LTE_CA_B2_B2_B5_B12-Perf | 35 | U.S. Cellular | Rel-13 | 68 | RP-151131 |
| 1667 | 462.101 | **LTE Advanced 4 Band Carrier Aggregation (4DL/1UL) of Band 2, Band 5, Band 12 and Band 12** | 132d? | 2015-06-15 A | 2015-12-15 A | 100% |  | R4 | 3168h | 3168h | LTE_CA_B2_B5_B12_B12 | 35 | U.S. Cellular | Rel-13 | 68 |  |
| 1668 | 462.101.1 | Core part:LTE Advanced 4 Band Carrier Aggregation (4DL/1UL) of Band 2, Band 5, Band 12 and Band 12 | 132d? | 2015-06-15 A | 2015-12-15 A | 100% | finish no earlier than 2015-12-15 | R4 | 1056h | 1056h | LTE_CA_B2_B5_B12_B12-Core | 35 | U.S. Cellular | Rel-13 | 68 | RP-151131 |
| 1669 | 462.101.2 | Perf. part:LTE Advanced 4 Band Carrier Aggregation (4DL/1UL) of Band 2, Band 5, Band 12 and Band 12 | 132d? | 2015-06-15 A | 2015-12-15 A | 100% | finish no earlier than 2015-12-15 | R4 | 1056h | 1056h | LTE_CA_B2_B5_B12_B12-Perf | 35 | U.S. Cellular | Rel-13 | 68 | RP-151131 |

Notes:
- 1647: 29/09/15: Compl:0%->40% 29/09/15: Stat Rep: -->RP-151131
- 1648: 29/09/15: Compl:0%->40% 29/09/15: Stat Rep: -->RP-151131
- 1650: 29/09/15: Compl:0%->40% 29/09/15: Stat Rep: -->RP-151131
- 1651: 29/09/15: Compl:0%->40% 29/09/15: Stat Rep: -->RP-151131
- 1653: 29/09/15: Compl:0%->40% 29/09/15: Stat Rep: -->RP-151131
- 1654: 29/09/15: Compl:0%->40% 29/09/15: Stat Rep: -->RP-151131
- 1656: 29/09/15: Stat Rep: -->RP-151131 22/3/16: Compl:50%->100%
- 1657: 29/09/15: Stat Rep: -->RP-151131 ; 22/3/16: Compl:50%->100%
- 1659: 29/09/15: Stat Rep: -->RP-151131 22/3/16: Compl:50%->100%
- 1660: 29/09/15: Stat Rep: -->RP-151131 22/3/16: Compl:50%->100%
- 1662: 29/09/15: Stat Rep: -->RP-151131 ; 22/3/16: Compl:50%->100%
- 1663: 29/09/15: Stat Rep: -->RP-151131 22/3/16: Compl:50%->100%
- 1665: 29/09/15: Compl:0%->40% 29/09/15: Stat Rep: -->RP-151131
- 1666: 29/09/15: Compl:0%->40% 29/09/15: Stat Rep: -->RP-151131
- 1668: 29/09/15: Compl:0%->40% 29/09/15: Stat Rep: -->RP-151131
- 1669: 29/09/15: Compl:0%->40% 29/09/15: Stat Rep: -->RP-151131

| ID | WBS | Task | Duration | Start | Finish | Complete | Constraint | Resources | Work | Actual work | Acronym | PCG approved | WI rapporteur name | Release | TSG approved | Status Report | Impacted TSs and TRs |
| --- | --- | --- | --- | --- | --- | --- | --- | --- | --- | --- | --- | --- | --- | --- | --- | --- | --- |
| 1670 | 462.102 | **LTE Advanced 3DL/2UL mixed intra- and inter-band Carrier Aggregation** | 132d? | 2015-06-15 A | 2015-12-15 A | 100% |  | R4 | 3168h | 3168h | LTE_CA_3DL_2UL_inter_intra | 35 | Nokia Networks | Rel-14 | 68 |  |  |
| 1671 | 462.102.1 | Core part:LTE Advanced 3DL/2UL mixed intra- and inter-band Carrier Aggregation | 132d? | 2015-06-15 A | 2015-12-15 A | 100% | finish no earlier than 2015-12-15 | R4 | 1056h | 1056h | LTE_CA_3DL_2UL_inter_intra-Core | 35 | Nokia Networks | Rel-13 | 68 | RP-151131 |  |
| 1672 | 462.102.2 | Perf. part:LTE Advanced 3DL/2UL mixed intra- and inter-band Carrier Aggregation | 132d? | 2015-06-15 A | 2015-12-15 A | 100% | finish no earlier than 2015-12-15 | R4 | 1056h | 1056h | LTE_CA_3DL_2UL_inter_intra-Perf | 35 | Nokia Networks | Rel-13 | 68 | RP-151131 |  |
| 1673 | 462.103 | **LTE Advanced intra-band contiguous Carrier Aggregation in Band 5** | 132d? | 2015-06-15 A | 2015-12-15 A | 100% |  | R4 | 3168h | 3168h | LTE_CA_C_B5 | 35 | Intel | Rel-13 | 68 |  |  |
| 1674 | 462.103.1 | Core part: LTE Advanced intra-band contiguous Carrier Aggregation in Band 5 | 132d? | 2015-06-15 A | 2015-12-15 A | 100% | finish no earlier than 2015-12-15 | R4 | 1056h | 1056h | LTE_CA_C_B5-Core | 35 | Intel | Rel-13 | 68 | RP-151131 |  |
| 1675 | 462.103.2 | Perf. part: LTE Advanced intra-band contiguous Carrier Aggregation in Band 5 | 132d? | 2015-06-15 A | 2015-12-15 A | 100% | finish no earlier than 2015-12-15 | R4 | 1056h | 1056h | LTE_CA_C_B5-Perf | 35 | Intel | Rel-13 | 68 | RP-151131 |  |
| 1676 | 462.104 | **Additional bandwidth combination set for LTE Advanced intra-band non-contiguous Carrier Aggregation in Band 4** | 67d? | 2015-06-15 A | 2015-09-15 A | 100% |  | R4 | 1608h | 1608h | LTE_CA_NC_B4_BWset | 35 | Nokia Networks | Rel-13 | 68 |  |  |
| 1677 | 462.104.1 | Core part: Additional bandwidth combination set for LTE Advanced intra-band non-contiguous Carrier Aggregation in Band 4 | 67d? | 2015-06-15 A | 2015-09-15 A | 100% | finish no earlier than 2015-09-15 | R4 | 536h | 536h | LTE_CA_NC_B4_BWset-Core | 35 | Nokia Networks | Rel-13 | 68 | RP-151131 |  |
| 1678 | 462.104.2 | Perf. part: Additional bandwidth combination set for LTE Advanced intra-band non-contiguous Carrier Aggregation in Band 4 | 67d? | 2015-06-15 A | 2015-09-15 A | 100% | finish no earlier than 2015-09-15 | R4 | 536h | 536h | LTE_CA_NC_B4_BWset-Perf | 35 | Nokia Networks | Rel-13 | 68 | RP-151131 |  |
| 1679 | 462.105 | **LTE Advanced intra-band non-contiguous Carrier Aggregation in Band 5** | 132d? | 2015-06-15 A | 2015-12-15 A | 100% |  | R4 | 3168h | 3168h | LTE_CA_NC_B5 | 35 | Intel | Rel-13 | 68 |  |  |
| 1680 | 462.105.1 | Core part:LTE Advanced intra-band non-contiguous Carrier Aggregation in Band 5 | 132d? | 2015-06-15 A | 2015-12-15 A | 100% | finish no earlier than 2015-12-15 | R4 | 1056h | 1056h | LTE_CA_NC_B5-Core | 35 | Intel | Rel-13 | 68 | RP-151131 |  |
| 1681 | 462.105.2 | Perf. part:LTE Advanced intra-band non-contiguous Carrier Aggregation in Band 5 | 132d? | 2015-06-15 A | 2015-12-15 A | 100% | finish no earlier than 2015-12-15 | R4 | 1056h | 1056h | LTE_CA_NC_B5-Perf | 35 | Intel | Rel-13 | 68 | RP-151131 |  |
| 1682 | 462.106 | **LTE Advanced intra-band non-contiguous Carrier Aggregation in Band 42 for 4DL** | 132d? | 2015-06-15 A | 2015-12-15 A | 100% |  | R4 | 3168h | 3168h | LTE_CA_NC_B42_4DL | 35 | Huawei | Rel-13 | 68 |  |  |
| 1683 | 462.106.1 | Core part:LTE Advanced intra-band non-contiguous Carrier Aggregation in Band 42 for 4DL | 132d? | 2015-06-15 A | 2015-12-15 A | 100% | finish no earlier than 2015-12-15 | R4 | 1056h | 1056h | LTE_CA_NC_B42_4DL-Core | 35 | Huawei | Rel-13 | 68 | RP-151131 |  |
| 1684 | 462.106.2 | Perf. part:LTE Advanced intra-band non-contiguous Carrier Aggregation in Band 42 for 4DL | 132d? | 2015-06-15 A | 2015-12-15 A | 100% | finish no earlier than 2015-12-15 | R4 | 1056h | 1056h | LTE_CA_NC_B42_4DL-Perf | 35 | Huawei | Rel-13 | 68 | RP-151131 |  |
| 1685 | 462.107 | **Additional bandwidth combination set for LTE Advanced inter-band Carrier Aggregation of Band 2 and Band 12** | 67d? | 2015-06-15 A | 2015-09-15 A | 100% |  | R4 | 1608h | 1608h | LTE_CA_B2_B12_BWset | 35 | Nokia Networks | Rel-13 | 68 |  |  |
| 1686 | 462.107.1 | Core part: Additional bandwidth combination set for LTE Advanced inter-band Carrier Aggregation of Band 2 and Band 12 | 67d? | 2015-06-15 A | 2015-09-15 A | 100% | finish no earlier than 2015-09-15 | R4 | 536h | 536h | LTE_CA_B2_B12_BWset-Core | 35 | Nokia Networks | Rel-13 | 68 | RP-151131 |  |
| 1687 | 462.107.2 | Perf. part: Additional bandwidth combination set for LTE Advanced inter-band Carrier Aggregation of Band 2 and Band 12 | 67d? | 2015-06-15 A | 2015-09-15 A | 100% | finish no earlier than 2015-09-15 | R4 | 536h | 536h | LTE_CA_B2_B12_BWset-Perf | 35 | Nokia Networks | Rel-13 | 68 | RP-151131 |  |
| 1688 | 462.108 | **Additional bandwidth combination set 2 for LTE Advanced inter-band Carrier Aggregation of Band 4 and Band 12** | 67d? | 2015-06-15 A | 2015-09-15 A | 100% |  | R4 | 1608h | 1608h | LTE_CA_B4_B12_BWset2 | 35 | Nokia Networks | Rel-13 | 68 |  |  |
| 1689 | 462.108.1 | Core part: Additional bandwidth combination set 2 for LTE Advanced inter-band Carrier Aggregation of Band 4 and Band 12 | 67d? | 2015-06-15 A | 2015-09-15 A | 100% | finish no earlier than 2015-09-15 | R4 | 536h | 536h | LTE_CA_B4_B12_BWset2-Core | 35 | Nokia Networks | Rel-13 | 68 | RP-151131 |  |
| 1690 | 462.108.2 | Perf. part: Additional bandwidth combination set 2 for LTE Advanced inter-band Carrier Aggregation of Band 4 and Band 12 | 67d? | 2015-06-15 A | 2015-09-15 A | 100% | finish no earlier than 2015-09-15 | R4 | 536h | 536h | LTE_CA_B4_B12_BWset2-Perf | 35 | Nokia Networks | Rel-13 | 68 | RP-151131 |  |
| 1691 | 462.109 | **Introduction of 1447-1467MHz Band for TD-LTE in China** | 330d? | 2015-06-15 A | 2016-09-15 A | 100% |  | R4 | 5824h | 5824h | LTE_TDD_1447MHz_China | 35 | Huawei | Rel-13 | 68 |  |  |
| 1692 | 462.109.1 | Core part: Introduction of 1447-1467MHz Band for TD-LTE in China | 132d? | 2015-06-15 A | 2015-12-15 A | 100% | finish no earlier than 2015-12-15 | R4 | 1056h | 1056h | LTE_TDD_1447MHz_China-Core | 35 | Huawei | Rel-13 | 68 | RP-151242 | 36.892 |
| 1693 | 462.109.2 | Perf. part: Introduction of 1447-1467MHz Band for TD-LTE in China | 132d? | 2015-06-15 A | 2015-12-15 A | 100% | finish no earlier than 2016-03-15 | R4 | 1056h | 1056h | LTE_TDD_1447MHz_China-Perf | 35 | Huawei | Rel-13 | 68 | RP-151242 |  |
| 1694 | 462.109.3 | UE Conformance Test Aspects - Introduction of 1447-1467MHz Band for TD-LTE in China | 134d? | 2016-03-15 A | 2016-09-15 A | 100% | finish no earlier than 2016-09-15 | R5 | 1072h | 1072h | LTE_TDD_1447MHz_China-UEConTest | 36 | Huawei | Rel-13 | 71 |  |  |

Notes:
- 1670: covers combinations of contiguous intra-band CA and inter-band CA or combinations of non-contiguous intra-band CA and inter-band CA for LTE; pure intra-band CA combinations are also covered by this WI; note: There is already a REL-13 WI LTE_CA_3DL_2UL whi
- 1671: covers combinations of contiguous intra-band CA and inter-band CA or combinations of non-contiguous intra-band CA and inter-band CA for LTE; pure intra-band CA combinations are also covered by this WI; note: There is already a REL-13 WI LTE_CA_3DL_2UL
- 1672: covers combinations of contiguous intra-band CA and inter-band CA or combinations of non-contiguous intra-band CA and inter-band CA for LTE; pure intra-band CA combinations are also covered by this WI; note: There is already a REL-13 WI LTE_CA_3DL_2UL
- 1674: 29/09/15: Compl:0%->20% 29/09/15: Stat Rep: -->RP-151131
- 1675: 29/09/15: Compl:0%->20% 29/09/15: Stat Rep: -->RP-151131
- 1676: LTE_CA_NC_B4 was completed in REL-12
- 1677: LTE_CA_NC_B4 was completed in REL-12 29/09/15: Compl:0%->100% 29/09/15: Stat Rep: -->RP-151131
- 1678: LTE_CA_NC_B4 was completed in REL-12 29/09/15: Compl:0%->100% 29/09/15: Stat Rep: -->RP-151131
- 1680: 29/09/15: Compl:0%->20% 29/09/15: Stat Rep: -->RP-151131
- 1681: 29/09/15: Compl:0%->20% 29/09/15: Stat Rep: -->RP-151131
- 1683: 29/09/15: Compl:0%->50% 29/09/15: Stat Rep: -->RP-151131
- 1684: 29/09/15: Stat Rep: -->RP-151131
- 1685: LTE_CA_B2_B12 was completed as REL-12 WI
- 1686: LTE_CA_B2_B12 was completed as REL-12 WI 29/09/15: Compl:0%->100% 29/09/15: Stat Rep: -->RP-151131
- 1687: LTE_CA_B2_B12 was completed as REL-12 WI 29/09/15: Compl:0%->100% 29/09/15: Stat Rep: -->RP-151131
- 1688: LTE_CA_B4_B12 was completed in REL-11 and LTE_CA_B4_B12_BWset was completed in REL-12
- 1689: LTE_CA_B4_B12 was completed in REL-11 and LTE_CA_B4_B12_BWset was completed in REL-12 29/09/15: Compl:0%->100% 29/09/15: Stat Rep: -->RP-151131
- 1690: LTE_CA_B4_B12 was completed in REL-11 and LTE_CA_B4_B12_BWset was completed in REL-12 29/09/15: Compl:0%->100% 29/09/15: Stat Rep: -->RP-151131
- 1691: Aug 15: TR numb added
- 1692: Aug 15: TR numb added 29/09/15: Compl:0%->20% 29/09/15: Stat Rep: -->RP-151242
- 1693: 29/09/15: Stat Rep: -->RP-151242
- 1694: testing REL-13 LTE_TDD_1447MHz_China-Core; 1/7/16: C;

| ID | WBS | Task | Duration | Start | Finish | Complete | Constraint | Resources | Work | Actual work | Acronym | PCG approved | WI rapporteur name | Release | TSG approved | Status Report |
| --- | --- | --- | --- | --- | --- | --- | --- | --- | --- | --- | --- | --- | --- | --- | --- | --- |
| 1695 | 462.110 | **LTE Advanced 4 Band Carrier Aggregation (4DL/1UL) of Band 41, Band 41, Band 42 and Band 42** | 132d? | 2015-06-15 A | 2015-12-15 A | 100% |  | R4 | 3168h | 3168h | LTE_CA_B41_B41_B42_B42 | 35 | ZTE | Rel-13 | 68 |  |
| 1696 | 462.110.1 | Core part:LTE Advanced 4 Band Carrier Aggregation (4DL/1UL) of Band 41, Band 41, Band 42 and Band 42 | 132d? | 2015-06-15 A | 2015-12-15 A | 100% | finish no earlier than 2015-12-15 | R4 | 1056h | 1056h | LTE_CA_B41_B41_B42_B42-Core | 35 | ZTE | Rel-13 | 68 | RP-151131 |
| 1697 | 462.110.2 | Perf. part:LTE Advanced 4 Band Carrier Aggregation (4DL/1UL) of Band 41, Band 41, Band 42 and Band 42 | 132d? | 2015-06-15 A | 2015-12-15 A | 100% | finish no earlier than 2015-12-15 | R4 | 1056h | 1056h | LTE_CA_B41_B41_B42_B42-Perf | 35 | ZTE | Rel-13 | 68 | RP-151131 |
| 1698 | 462.111 | **LTE Advanced inter-band Carrier Aggregation for Band 5 and Band 38** | 66d? | 2015-09-15 A | 2015-12-15 A | 100% |  | R4 | 1584h | 1584h | LTE_CA_B5_B38 | 35 | Huawei | Rel-13 | 69 |  |
| 1699 | 462.111.1 | Core part:LTE Advanced inter-band Carrier Aggregation for Band 5 and Band 38 | 66d? | 2015-09-15 A | 2015-12-15 A | 100% | finish no earlier than 2015-12-15 | R4 | 528h | 528h | LTE_CA_B5_B38-Core | 35 | Huawei | Rel-13 | 69 |  |
| 1700 | 462.111.2 | Perf. part:LTE Advanced inter-band Carrier Aggregation for Band 5 and Band 38 | 66d? | 2015-09-15 A | 2015-12-15 A | 100% | finish no earlier than 2015-12-15 | R4 | 528h | 528h | LTE_CA_B5_B38-Perf | 35 | Huawei | Rel-13 | 69 |  |
| 1701 | 462.112 | **LTE Advanced 3 Band Carrier Aggregation (3DL/1UL) of Band 1, Band 11 and Band 18** | 66d? | 2015-09-15 A | 2015-12-15 A | 100% |  | R4 | 1584h | 1584h | LTE_CA_B1_B11_B18 | 35 | KDDI | Rel-13 | 69 |  |
| 1702 | 462.112.1 | Core part:LTE Advanced 3 Band Carrier Aggregation (3DL/1UL) of Band 1, Band 11 and Band 18 | 66d? | 2015-09-15 A | 2015-12-15 A | 100% | finish no earlier than 2015-12-15 | R4 | 528h | 528h | LTE_CA_B1_B11_B18-Core | 35 | KDDI | Rel-13 | 69 |  |
| 1703 | 462.112.2 | Perf. part:LTE Advanced 3 Band Carrier Aggregation (3DL/1UL) of Band 1, Band 11 and Band 18 | 66d? | 2015-09-15 A | 2015-12-15 A | 100% | finish no earlier than 2015-12-15 | R4 | 528h | 528h | LTE_CA_B1_B11_B18-Perf | 35 | KDDI | Rel-13 | 69 |  |
| 1704 | 462.113 | **LTE Advanced 3 Band Carrier Aggregation (3DL/1UL) of Band 5, Band 40, and Band 40** | 66d? | 2015-09-15 A | 2015-12-15 A | 100% |  | R4 | 1584h | 1584h | LTE_CA_B5_B40_B40 | 35 | ZTE | Rel-13 | 69 |  |
| 1705 | 462.113.1 | Core part:LTE Advanced 3 Band Carrier Aggregation (3DL/1UL) of Band 5, Band 40, and Band 40 | 66d? | 2015-09-15 A | 2015-12-15 A | 100% | finish no earlier than 2015-12-15 | R4 | 528h | 528h | LTE_CA_B5_B40_B40-Core | 35 | ZTE | Rel-13 | 69 |  |
| 1706 | 462.113.2 | Perf. part:LTE Advanced 3 Band Carrier Aggregation (3DL/1UL) of Band 5, Band 40, and Band 40 | 66d? | 2015-09-15 A | 2015-12-15 A | 100% | finish no earlier than 2015-12-15 | R4 | 528h | 528h | LTE_CA_B5_B40_B40-Perf | 35 | ZTE | Rel-13 | 69 |  |
| 1707 | 462.114 | **LTE Advanced 3 Band Carrier Aggregation (3DL/1UL) for Band 3, Band 41 and Band 42** | 66d? | 2015-09-15 A | 2015-12-15 A | 100% |  | R4 | 1584h | 1584h | LTE_CA_B3_B41_B42 | 35 | Huawei | Rel-13 | 69 |  |
| 1708 | 462.114.1 | Core part:LTE Advanced 3 Band Carrier Aggregation (3DL/1UL) for Band 3, Band 41 and Band 42 | 66d? | 2015-09-15 A | 2015-12-15 A | 100% | finish no earlier than 2015-12-15 | R4 | 528h | 528h | LTE_CA_B3_B41_B42-Core | 35 | Huawei | Rel-13 | 69 |  |
| 1709 | 462.114.2 | Perf. part:LTE Advanced 3 Band Carrier Aggregation (3DL/1UL) for Band 3, Band 41 and Band 42 | 66d? | 2015-09-15 A | 2015-12-15 A | 100% | finish no earlier than 2015-12-15 | R4 | 528h | 528h | LTE_CA_B3_B41_B42-Perf | 35 | Huawei | Rel-13 | 69 |  |
| 1710 | 462.115 | **LTE Advanced 3 Band Carrier Aggregation (3DL/1UL) of Band 3, Band 41, and Band 41** | 66d? | 2015-09-15 A | 2015-12-15 A | 100% |  | R4 | 1584h | 1584h | LTE_CA_B3_B41_B41 | 35 | ZTE | Rel-13 | 69 |  |
| 1711 | 462.115.1 | Core part:LTE Advanced 3 Band Carrier Aggregation (3DL/1UL) of Band 3, Band 41, and Band 41 | 66d? | 2015-09-15 A | 2015-12-15 A | 100% | finish no earlier than 2015-12-15 | R4 | 528h | 528h | LTE_CA_B3_B41_B41-Core | 35 | ZTE | Rel-13 | 69 |  |
| 1712 | 462.115.2 | Perf. part:LTE Advanced 3 Band Carrier Aggregation (3DL/1UL) of Band 3, Band 41, and Band 41 | 66d? | 2015-09-15 A | 2015-12-15 A | 100% | finish no earlier than 2015-12-15 | R4 | 528h | 528h | LTE_CA_B3_B41_B41-Perf | 35 | ZTE | Rel-13 | 69 |  |
| 1713 | 462.116 | **LTE Advanced 4 Band Carrier Aggregation (4DL1UL) of Band 39, Band 41, Band 41 and Band 41** | 66d? | 2015-09-15 A | 2015-12-15 A | 100% |  | R4 | 1584h | 1584h | LTE_CA_B39_B41_B41_B41 | 35 | CMCC | Rel-13 | 69 |  |
| 1714 | 462.116.1 | Core part:LTE Advanced 4 Band Carrier Aggregation (4DL1UL) of Band 39, Band 41, Band 41 and Band 41 | 66d? | 2015-09-15 A | 2015-12-15 A | 100% | finish no earlier than 2015-12-15 | R4 | 528h | 528h | LTE_CA_B39_B41_B41_B41-Core | 35 | CMCC | Rel-13 | 69 |  |
| 1715 | 462.116.2 | Perf. part:LTE Advanced 4 Band Carrier Aggregation (4DL1UL) of Band 39, Band 41, Band 41 and Band 41 | 66d? | 2015-09-15 A | 2015-12-15 A | 100% | finish no earlier than 2015-12-15 | R4 | 528h | 528h | LTE_CA_B39_B41_B41_B41-Perf | 35 | CMCC | Rel-13 | 69 |  |
| 1716 | 462.117 | **LTE Advanced 4 Band Carrier Aggregation (4DL1UL) of Band 39, Band 39, Band 41 and Band 41** | 66d? | 2015-09-15 A | 2015-12-15 A | 100% |  | R4 | 1584h | 1584h | LTE_CA_B39_B39_B41_B41 | 35 | CMCC | Rel-13 | 69 |  |
| 1717 | 462.117.1 | Core part:LTE Advanced 4 Band Carrier Aggregation (4DL1UL) of Band 39, Band 39, Band 41 and Band 41 | 66d? | 2015-09-15 A | 2015-12-15 A | 100% | finish no earlier than 2015-12-15 | R4 | 528h | 528h | LTE_CA_B39_B39_B41_B41-Core | 35 | CMCC | Rel-13 | 69 |  |
| 1718 | 462.117.2 | Perf. part:LTE Advanced 4 Band Carrier Aggregation (4DL1UL) of Band 39, Band 39, Band 41 and Band 41 | 66d? | 2015-09-15 A | 2015-12-15 A | 100% | finish no earlier than 2015-12-15 | R4 | 528h | 528h | LTE_CA_B39_B39_B41_B41-Perf | 35 | CMCC | Rel-13 | 69 |  |

Notes:
- 1696: 29/09/15: Compl:0%->40% 29/09/15: WID: RP-150627->RP-151562 29/09/15: Stat Rep: ->RP-151131
- 1697: 29/09/15: Compl:0%->40% 29/09/15: WID: RP-150627->RP-151562 29/09/15: Stat Rep: ->RP-151131
- 1699: 1/1/16: Compl:0%->100%
- 1700: ; 1/1/16: Compl:0%->100%
- 1702: ; 1/1/16: Compl:0%->100%
- 1703: 1/1/16: Compl:0%->100%
- 1705: 1/1/16: Compl:0%->100%
- 1706: 1/1/16: Compl:0%->100%
- 1708: 1/1/16: Compl:0%->100%
- 1709: ; 1/1/16: Compl:0%->100%
- 1711: ; 1/1/16: Compl:0%->100%
- 1712: 1/1/16: Compl:0%->100%

| ID | WBS | Task | Duration | Start | Finish | Complete | Constraint | Resources | Work | Actual work | Acronym | PCG approved | WI rapporteur name | Release | TSG approved | Impacted TSs and TRs |
| --- | --- | --- | --- | --- | --- | --- | --- | --- | --- | --- | --- | --- | --- | --- | --- | --- |
| 1719 | 462.118 | **LTE Advanced 4 Band Carrier Aggregation (4DL/1UL) of Band 1, Band 3, Band 8 and Band 40** | 66d? | 2015-09-15 A | 2015-12-15 A | 100% |  | R4 | 1584h | 1584h | LTE_CA_B1_B3_B8_B40 | 35 | KT | Rel-13 | 69 |  |
| 1720 | 462.118.1 | Core part:LTE Advanced 4 Band Carrier Aggregation (4DL/1UL) of Band 1, Band 3, Band 8 and Band 40 | 66d? | 2015-09-15 A | 2015-12-15 A | 100% | finish no earlier than 2015-12-15 | R4 | 528h | 528h | LTE_CA_B1_B3_B8_B40-Core | 35 | KT | Rel-13 | 69 |  |
| 1721 | 462.118.2 | Perf. part:LTE Advanced 4 Band Carrier Aggregation (4DL/1UL) of Band 1, Band 3, Band 8 and Band 40 | 66d? | 2015-09-15 A | 2015-12-15 A | 100% | finish no earlier than 2015-12-15 | R4 | 528h | 528h | LTE_CA_B1_B3_B8_B40-Perf | 35 | KT | Rel-13 | 69 |  |
| 1722 | 462.119 | **LTE Advanced 4 Band Carrier Aggregation (4DL/1UL) for Band 3, Band 28, Band 40 and Band 40** | 66d? | 2015-09-15 A | 2015-12-15 A | 100% |  | R4 | 1584h | 1584h | LTE_CA_B3_B28_B40_B40 | 35 | Huawei | Rel-13 | 69 |  |
| 1723 | 462.119.1 | Core part:LTE Advanced 4 Band Carrier Aggregation (4DL/1UL) for Band 3, Band 28, Band 40 and Band 40 | 66d? | 2015-09-15 A | 2015-12-15 A | 100% | finish no earlier than 2015-12-15 | R4 | 528h | 528h | LTE_CA_B3_B28_B40_B40-Core | 35 | Huawei | Rel-13 | 69 |  |
| 1724 | 462.119.2 | Perf. part:LTE Advanced 4 Band Carrier Aggregation (4DL/1UL) for Band 3, Band 28, Band 40 and Band 40 | 66d? | 2015-09-15 A | 2015-12-15 A | 100% | finish no earlier than 2015-12-15 | R4 | 528h | 528h | LTE_CA_B3_B28_B40_B40-Perf | 35 | Huawei | Rel-13 | 69 |  |
| 1725 | 462.120 | **LTE Advanced 4 Band Carrier Aggregation (4DL/1UL) for Band 28, Band 40, Band 40 and Band 40** | 66d? | 2015-09-15 A | 2015-12-15 A | 100% |  | R4 | 1584h | 1584h | LTE_CA_B28_B40_B40_B40 | 35 | Huawei | Rel-13 | 69 |  |
| 1726 | 462.120.1 | Core part:LTE Advanced 4 Band Carrier Aggregation (4DL/1UL) for Band 28, Band 40, Band 40 and Band 40 | 66d? | 2015-09-15 A | 2015-12-15 A | 100% | finish no earlier than 2015-12-15 | R4 | 528h | 528h | LTE_CA_B28_B40_B40_B40-Core | 35 | Huawei | Rel-13 | 69 |  |
| 1727 | 462.120.2 | Perf. part:LTE Advanced 4 Band Carrier Aggregation (4DL/1UL) for Band 28, Band 40, Band 40 and Band 40 | 66d? | 2015-09-15 A | 2015-12-15 A | 100% | finish no earlier than 2015-12-15 | R4 | 528h | 528h | LTE_CA_B28_B40_B40_B40-Perf | 35 | Huawei | Rel-13 | 69 |  |
| 1728 | 462.121 | **LTE Advanced 4 Band Carrier Aggregation (4DL/1UL) of Band 3, Band 7, Band 7 and Band 28** | 66d? | 2015-09-15 A | 2015-12-15 A | 100% |  | R4 | 1584h | 1584h | LTE_CA_B3_B7_B7_B28 | 35 | Telstra | Rel-13 | 69 |  |
| 1729 | 462.121.1 | Core part:LTE Advanced 4 Band Carrier Aggregation (4DL/1UL) of Band 3, Band 7, Band 7 and Band 28 | 66d? | 2015-09-15 A | 2015-12-15 A | 100% | finish no earlier than 2015-12-15 | R4 | 528h | 528h | LTE_CA_B3_B7_B7_B28-Core | 35 | Telstra | Rel-13 | 69 |  |
| 1730 | 462.121.2 | Perf. part:LTE Advanced 4 Band Carrier Aggregation (4DL/1UL) of Band 3, Band 7, Band 7 and Band 28 | 66d? | 2015-09-15 A | 2015-12-15 A | 100% | finish no earlier than 2015-12-15 | R4 | 528h | 528h | LTE_CA_B3_B7_B7_B28-Perf | 35 | Telstra | Rel-13 | 69 |  |
| 1731 | 462.122 | **LTE Advanced 5 Band Carrier Aggregation (5DL/1UL) of Band 1, Band 3, Band 19, Band 42 and Band 42** | 66d? | 2015-09-15 A | 2015-12-15 A | 100% |  | R4 | 1584h | 1584h | LTE_CA_B1_B3_B19_B42_B42 | 35 | NTT DOCOMO | Rel-13 | 69 | 36.857-13 |
| 1732 | 462.122.1 | Core part:LTE Advanced 5 Band Carrier Aggregation (5DL/1UL) of Band 1, Band 3, Band 19, Band 42 and Band 42 | 66d? | 2015-09-15 A | 2015-12-15 A | 100% | finish no earlier than 2015-12-15 | R4 | 528h | 528h | LTE_CA_B1_B3_B19_B42_B42-Core | 35 | NTT DOCOMO | Rel-13 | 69 | 36.857-13 |
| 1733 | 462.122.2 | Perf. part:LTE Advanced 5 Band Carrier Aggregation (5DL/1UL) of Band 1, Band 3, Band 19, Band 42 and Band 42 | 66d? | 2015-09-15 A | 2015-12-15 A | 100% | finish no earlier than 2015-12-15 | R4 | 528h | 528h | LTE_CA_B1_B3_B19_B42_B42-Perf | 35 | NTT DOCOMO | Rel-13 | 69 | 36.857-13 |
| 1734 | 462.123 | **LTE Advanced 5 Band Carrier Aggregation (5DL/1UL) of Band 1, Band 19, Band 21, Band 42 and Band 42** | 66d? | 2015-09-15 A | 2015-12-15 A | 100% |  | R4 | 1584h | 1584h | LTE_CA_B1_B19_B21_B42_B42 | 35 | NTT DOCOMO | Rel-13 | 69 |  |
| 1735 | 462.123.1 | Core part:LTE Advanced 5 Band Carrier Aggregation (5DL/1UL) of Band 1, Band 19, Band 21, Band 42 and Band 42 | 66d? | 2015-09-15 A | 2015-12-15 A | 100% | finish no earlier than 2015-12-15 | R4 | 528h | 528h | LTE_CA_B1_B19_B21_B42_B42-Core | 35 | NTT DOCOMO | Rel-13 | 69 |  |
| 1736 | 462.123.2 | Perf. part:LTE Advanced 5 Band Carrier Aggregation (5DL/1UL) of Band 1, Band 19, Band 21, Band 42 and Band 42 | 66d? | 2015-09-15 A | 2015-12-15 A | 100% | finish no earlier than 2015-12-15 | R4 | 528h | 528h | LTE_CA_B1_B19_B21_B42_B42-Perf | 35 | NTT DOCOMO | Rel-13 | 69 |  |
| 1737 | 462.124 | **LTE Advanced 5 Band Carrier Aggregation (5DL/1UL) of Band 1, Band 3, Band 7, Band 7 and Band 28** | 131d? | 2015-09-15 A | 2016-03-15 A | 100% |  | R4 | 3144h | 3144h | LTE_CA_B1_B3_B7_B7_B28 | 35 | Telstra | Rel-13 | 69 |  |
| 1738 | 462.124.1 | Core part:LTE Advanced 5 Band Carrier Aggregation (5DL/1UL) of Band 1, Band 3, Band 7, Band 7 and Band 28 | 131d? | 2015-09-15 A | 2016-03-15 A | 100% | finish no earlier than 2016-03-15 | R4 | 1048h | 1048h | LTE_CA_B1_B3_B7_B7_B28-Core | 35 | Telstra | Rel-13 | 69 |  |
| 1739 | 462.124.2 | Perf. part:LTE Advanced 5 Band Carrier Aggregation (5DL/1UL) of Band 1, Band 3, Band 7, Band 7 and Band 28 | 131d? | 2015-09-15 A | 2016-03-15 A | 100% | finish no earlier than 2016-03-15 | R4 | 1048h | 1048h | LTE_CA_B1_B3_B7_B7_B28-Perf | 35 | Telstra | Rel-13 | 69 |  |
| 1740 | 462.125 | **LTE Advanced 5 Band Carrier Aggregation (5DL/1UL) of Band 3, Band 3, Band 7, Band 7 and Band 28** | 131d? | 2015-09-15 A | 2016-03-15 A | 100% |  | R4 | 3144h | 3144h | LTE_CA_B3_B3_B7_B7_B28 | 35 | Telstra | Rel-13 | 69 |  |
| 1741 | 462.125.1 | Core part:LTE Advanced 5 Band Carrier Aggregation (5DL/1UL) of Band 3, Band 3, Band 7, Band 7 and Band 28 | 131d? | 2015-09-15 A | 2016-03-15 A | 100% | finish no earlier than 2016-03-15 | R4 | 1048h | 1048h | LTE_CA_B3_B3_B7_B7_B28-Core | 35 | Telstra | Rel-13 | 69 |  |
| 1742 | 462.125.2 | Perf. part:LTE Advanced 5 Band Carrier Aggregation (5DL/1UL) of Band 3, Band 3, Band 7, Band 7 and Band 28 | 131d? | 2015-09-15 A | 2016-03-15 A | 100% | finish no earlier than 2016-03-15 | R4 | 1048h | 1048h | LTE_CA_B3_B3_B7_B7_B28-Perf | 35 | Telstra | Rel-13 | 69 |  |

Notes:
- 1720: ; 1/1
- 1721: 1
- 1738: ; 22/3/16: Compl:95%->100%;
- 1739: 22/3/16: Compl:95%->100%;
- 1741: 22/3/16: Compl:95%->100%
- 1742: ; 22/3/16: Compl:95%->100%

| ID | WBS | Task | Duration | Start | Finish | Complete | Remaining | Baseline start | Baseline finish | Baseline duration | Total slack | Constraint | Resources | Work | Actual work | Acronym | PCG approved | WI rapporteur name | Release | TSG approved | Impacted TSs and TRs | Status Report | WI rapporteur e-mail | Acronym_3GU_Export | Special Focus Doc | MCC resp |
| --- | --- | --- | --- | --- | --- | --- | --- | --- | --- | --- | --- | --- | --- | --- | --- | --- | --- | --- | --- | --- | --- | --- | --- | --- | --- | --- |
| 1743 | 462.126 | **LTE Advanced 3 Band Carrier Aggregation (3DL/3UL) of Band 39, Band 41 and Band 41** | 66d? | 2015-09-15 A | 2015-12-15 A | 100% |  |  |  |  |  |  | R4 | 1584h | 1584h | LTE_CA_3DL3UL_B39_B41_B41 | 35 | CATT | Rel-13 | 69 |  |  |  |  |  |  |
| 1744 | 462.126.1 | Core part:LTE Advanced 3 Band Carrier Aggregation (3DL/3UL) of Band 39, Band 41 and Band 41 | 66d? | 2015-09-15 A | 2015-12-15 A | 100% |  |  |  |  |  | finish no earlier than 2015-12-15 | R4 | 528h | 528h | LTE_CA_3DL3UL_B39_B41_B41-Core | 35 | CATT | Rel-13 | 69 |  |  |  |  |  |  |
| 1745 | 462.126.2 | Perf. part:LTE Advanced 3 Band Carrier Aggregation (3DL/3UL) of Band 39, Band 41 and Band 41 | 66d? | 2015-09-15 A | 2015-12-15 A | 100% |  |  |  |  |  | finish no earlier than 2015-12-15 | R4 | 528h | 528h | LTE_CA_3DL3UL_B39_B41_B41-Perf | 35 | CATT | Rel-13 | 69 |  |  |  |  |  |  |
| 1746 | 462.127 | **LTE Advanced 3 Band Carrier Aggregation (3DL/3UL) of Band 39, Band 39 and Band 41** | 66d? | 2015-09-15 A | 2015-12-15 A | 100% |  |  |  |  |  |  | R4 | 1584h | 1584h | LTE_CA_3DL3UL_B39_B39_B41 | 35 | CATT | Rel-13 | 69 | 36.899-13 |  |  |  |  |  |
| 1747 | 462.127.1 | Core part:LTE Advanced 3 Band Carrier Aggregation (3DL/3UL) of Band 39, Band 39 and Band 41 | 66d? | 2015-09-15 A | 2015-12-15 A | 100% |  |  |  |  |  | finish no earlier than 2015-12-15 | R4 | 528h | 528h | LTE_CA_3DL3UL_B39_B39_B41-Core | 35 | CATT | Rel-13 | 69 |  |  |  |  |  |  |
| 1748 | 462.127.2 | Perf. part:LTE Advanced 3 Band Carrier Aggregation (3DL/3UL) of Band 39, Band 39 and Band 41 | 66d? | 2015-09-15 A | 2015-12-15 A | 100% |  |  |  |  |  | finish no earlier than 2015-12-15 | R4 | 528h | 528h | LTE_CA_3DL3UL_B39_B39_B41-Perf | 35 | CATT | Rel-13 | 69 |  |  |  |  |  |  |
| 1749 | 462.128 | **Additional bandwidth combination set for LTE Advanced intra-band non-contiguous Carrier Aggregation in Band 7** | 66d? | 2015-09-15 A | 2015-12-15 A | 100% |  |  |  |  |  |  | R4 | 1584h | 1584h | LTE_CA_NC_B7_BWset | 35 | Huawei | Rel-13 | 69 |  |  |  |  |  |  |
| 1750 | 462.128.1 | Core part: Additional bandwidth combination set for LTE Advanced intra-band non-contiguous Carrier Aggregation in Band 7 | 66d? | 2015-09-15 A | 2015-12-15 A | 100% |  |  |  |  |  | finish no earlier than 2015-12-15 | R4 | 528h | 528h | LTE_CA_NC_B7_BWset-Core | 35 | Huawei | Rel-13 | 69 |  |  |  |  |  |  |
| 1751 | 462.128.2 | Perf. part: Additional bandwidth combination set for LTE Advanced intra-band non-contiguous Carrier Aggregation in Band 7 | 66d? | 2015-09-15 A | 2015-12-15 A | 100% |  |  |  |  |  | finish no earlier than 2015-12-15 | R4 | 528h | 528h | LTE_CA_NC_B7_BWset-Perf | 35 | Huawei | Rel-13 | 69 |  |  |  |  |  |  |
| 1752 | 462.129 | UE Conformance Test Aspects - Rel-13 LTE CA configurations | 655d? | 2015-12-15 A | 2018-06-15 | 65% | 229.25d? |  |  |  | 4561d | finish no earlier than 2018-06-15 | R5 | 5240h | 3406h | LTE_CA_Rel13-UEConTest | 36 | Ericsson | Rel-13 | 70 |  |  |  |  |  |  |
| 1753 | 463 | (Small) Technical Enhancements and Improvements for Rel-13 | 593d? | 2013-09-18 A | 2015-12-21 A | 100% |  |  |  |  |  | finish no earlier than 2015-12-21 | SP; CP; RP; GP | 18976h | 18976h | TEI13 | 31 |  | Rel-13 | 61 |  | PCG-31 |  |  |  |  |
| 1754 | 464 | (Small) Test Technical Enhancements and Improvements for Rel-13 | 593d? | 2013-09-18 A | 2015-12-21 A | 100% |  |  |  |  |  | finish no earlier than 2015-12-21 | SP; CP; RP; GP | 18976h | 18976h | TEI13_Test | 31 |  | Rel-13 | 61 |  | PCG-31 |  |  |  |  |
| 1755 | 465 | Awaiting formal work item | 593d? | 2013-09-18 A | 2015-12-21 A | 100% |  |  |  |  |  | start no earlier than 2013-09-18 | SP; CP; RP; GP | 18976h | 18976h | DUMMY | 35 |  | Rel-13 | 69 |  |  |  |  |  |  |
| 1756 | 466 | (Small) Security Enhancements and Improvements for Rel-13 | 2372d? | 2006-12-12 A | 2015-12-21 A | 100% |  |  |  |  |  | finish no earlier than 2015-12-21 | S3 | 18976h | 18976h | SEC13 | 31 |  | Rel-13 | 61 |  | PCG-31 |  |  |  |  |
| 1757 | 467 | Release 13 IoT related Studies | 602d? | 2013-09-12 A | 2015-12-25 A | 100% |  | 2014-07-31 | 2015-12-25 | 366.5d? |  | start no earlier than 2013-09-12 | SP; R2 | 9632h | 9632h |  |  |  | Rel-13 |  |  |  |  |  |  |  |
| 1758 | 468 | Study on Power saving for Machine-Type Communications (MTC) devices | 266.6d? | 2014-08-12 A | 2015-08-14 A | 100% |  | 2014-06-18 | 2015-02-20 | 160.5d? |  | finish no earlier than 2015-08-14 | G2; G1 | 4000.8h | 4000.8h | FS_uPoD | 32 | China Mobile | Rel-13 | 60 | 43.869 |  | Jing Han (hanjing@chinamobile.com) | FS_uPoD |  |  |
| 1759 | 469 | Study on Cellular system support for ultra Low Complexity and low throughput Internet of Things | 329d? | 2014-05-30 A | 2015-08-28 A | 100% |  | 2015-01-14 | 2015-08-28 | 163d? |  | finish no earlier than 2015-08-28 | G1; G2 | 5264h | 5264h | FS_IoT_LC | 33 | Vodafone | Rel-13 | 66 | 45.8xy |  | chris.pudney@vodafone.com | FS_IoT_LC | MTC, M2M |  |
| 1760 | 470 | Study on architecture enhancements of cellular systems for ultra low complexity and low throughput Internet of Things | 196d? | 2015-03-13 A | 2015-12-11 A | 100% |  |  |  |  |  | finish no earlier than 2015-12-11 | S2 | 1568h | 1568h | FS_AE_CIoT | 34 | puneet.jain@intel.com | Rel-13 | 67 | New TR 23.8xx |  | puneet.jain@intel.com |  |  |  |
| 1761 | 471 | Study on Battery Efficient Security for very low Throughput Machine Type Communication Devices | 196d? | 2015-03-13 A | 2015-12-11 A | 100% |  |  |  |  |  | finish no earlier than 2015-12-11 | S3 | 1568h | 1568h | FS_BEST_MTC_Sec | 34 | Barry, Aguibou, VODAFONE Group Plc | Rel-13 | 67 | 32.863; 33.163 |  | Barry, Aguibou, VODAFONE Group Plc |  |  |  |
| 1762 | 472 | Study on Small data transmission enhancements for UMTS | 197d? | 2014-09-16 A | 2015-06-15 A | 100% |  |  |  |  |  | finish no earlier than 2015-06-15 | R1; R3 | 3152h | 3152h | FS_UTRA_SDATA | 33 | Ericsson | Rel-13 | 65 | 25.705 | RP-150843 | gerardo.agni.medina.acosta@ericsson.com | FS_UTRA_SDATA |  |  |
| 1763 | 473 | Study on Application specific Congestion control for Data Communication | 531.29d? | 2012-09-17 A | 2014-09-17 A | 100% |  | 2012-09-13 | 2014-09-17 | 532d? |  | finish no earlier than 2014-09-17 | S1 | 4250.28h | 4250.28h | FS_ACDC | 29 | NTT DOCOMO | Rel-13 | 57 | 22.806 | S1-143305 | Atsushi Minokuchi (minokuchi@nttdocomo.co.jp) | FS_ACDC |  | Alain |
| 1764 | 474 | Study on enhancements for Infrastructure based data Communication Between Devices | 266d? | 2013-09-14 A | 2014-09-17 A | 100% |  | 2013-09-12 | 2014-09-17 | 266d? |  | finish no earlier than 2014-09-17 | S1 | 2128h | 2128h | FS_eICBD | 31 | KPN | Rel-13 | 61 | 22.807 | S1-143309 | toon.norp@tno.nl | FS_eICBD | MTC, M2M | Alain |
| 1765 | 475 | Release 13 other Studies | 602d? | 2013-09-12 A | 2015-12-25 A | 100% |  | 2014-07-31 | 2015-12-25 | 366.5d? |  | start no earlier than 2013-09-12 | SP; R2 | 9632h | 9632h |  |  |  | Rel-13 |  |  |  |  |  |  |  |
| 1766 | 476 | Study on Isolated E-UTRAN Operation for Public Safety | 261d? | 2013-06-25 A | 2014-06-18 A | 100% |  | 2013-06-21 | 2014-06-18 | 262d? |  | finish no earlier than 2014-06-18 | S1 | 2088h | 2088h | FS_IOPS | 31 | General Dynamics | Rel-13 | 60 | 22.897 |  | paul.piggin@gd-broadband.com | FS_IOPS | Public Safety (A-A) | Alain |
| 1767 | 477 | Study on architecture enhancements for Public Safety | 131d? | 2014-12-12 A | 2015-06-12 A | 100% |  |  |  |  |  | finish no earlier than 2015-06-12 | S2 | 1048h | 1048h | FS_IOPS_St2 | 34 |  | Rel-13 | 66 |  |  | phil.young@gd-broadband.com |  |  |  |
| 1768 | 478 | Study on Security Aspects of Isolated E-UTRAN Operation for Public Safety | 137d? | 2015-03-12 A | 2015-09-18 A | 100% |  |  |  |  |  | finish no earlier than 2015-09-18 | S3 | 1096h | 1096h | FS_IOPS_Sec | 34 | Paul Piggin, General Dynamics UK | Rel-13 | 67 | New TR 33.897 |  | paul.piggin@gd-broadband.com |  |  |  |
| 1769 | 479 | (SA66: on hold) Study on Co-ordinated packet data network gateway (P-GW) change for SIPTO | 201d? | 2013-09-13 A | 2014-06-18 A | 100% |  | 2013-09-12 | 2014-06-18 | 202d? |  | finish no earlier than 2014-06-18 | S1 | 1608h | 1608h | FS_CSIPTO | 31 | Intel | Rel-13 | 61 | 22.828 |  | Eric.siow@intel.com | FS_CSIPTO |  | Alain |
| 1770 | 480 | Study on Flexible Mobile Service Steering | 201d? | 2013-12-13 A | 2014-09-17 A | 100% |  | 2013-12-11 | 2014-09-17 | 202d? |  | finish no earlier than 2014-09-17 | S1 | 1608h | 1608h | FS_FMSS | 32 | China Mobile | Rel-13 | 62 | 22.808 | S1-143310 | Lu Lu (lulu@chinamobile.com) | FS_FMSS |  | Alain |
| 1771 | 481 | Study on Enhanced Calling Information Presentation | 201d? | 2013-12-13 A | 2014-09-17 A | 100% |  | 2013-12-11 | 2014-09-17 | 201d? |  | finish no earlier than 2014-09-17 | S1 | 1608h | 1608h | FS_ECIP | 32 | China Mobile | Rel-13 | 62 | 22.810 | S1-143311 | LI Xiaofan (lixiaofan@chinamobile.com | FS_ECIP |  | Alain |
| 1772 | 482 | Study on RAN Sharing Enhancements on GERAN and UTRAN | 140d? | 2014-03-07 A | 2014-09-17 A | 100% |  | 2014-03-07 | 2014-09-17 | 139d? |  | finish no earlier than 2014-09-17 | S1 | 1120h | 1120h | FS_GUSH | 32 | Telefónica | Rel-13 | 63 | 22.852 updates |  | chris.friel@telefonica.com | FS_GUSH |  | Alain |

Notes:
- 1743: TDD case
- 1744: TDD case
- 1745: TDD case
- 1746: TDD case; 5/10/15: 36.899-13 added;
- 1747: TDD case
- 1748: TDD case
- 1749: LTE_CA_NC_B7 was completed in REL-12
- 1750: LTE_CA_NC_B7 was completed in REL-12 ;
- 1751: LTE_CA_NC_B7 was completed in REL-12 ;
- 1752: ; 22/3/16: Compl:0%->5%;1/7/16: Compl:5%->22%26/9/16: Compl:22%->; 2 21/3/17: Compl:39%...; ...;...; ;...
- 1753: -
- 1754: Created upon demand of RAN5
- 1756: -
- 1757: -
- 1758: GP#65 completion 02/15=>05/15. GP#60 approved WID. Linked to Rel-12 Feature MTCe, Stage 2 BB3: UE Power Consumptions Optimizations (UEPCOP). Dec.14: 30->40%; June2015: Compl:40%->75; 07/09/15: 75%->100
- 1759: GP#62 approved WID. Dec.14: 15->40%; June2015: Compl:40%->75; 07/09/15: 75%->100; 14/09/15: WID:GP-140421->GP-150354
- 1760: 07/09/15: 0%->20; 07/09/15: 20%->65; 7/12/15: 65%->95; 7/3/16: 95%->100
- 1761: TR number added; June2015: Compl:0%->10; 7/12/15: 10%->50; 11/12/15: 50%->75; 7/3/16: 75%->95; 19/9/16: 95%->100; 6/10/16: 33.163 added;
- 1762: 3/3/15: WID: RP-141861; Stat Rep: -->RP-141859. Impacted TR number added. 1st Apr 15: Compl:30%->55% 1st Apr 15: Stat Rep: RP-141859->RP-150196 03/07/15: Compl:55%->100% 03/07/15: Stat Rep: RP-150196->RP-150843
- 1763: SP#65 completed. SP#64 TR 22.806v200 for Approval. ACDC is applicable to UTRAN and E-UTRAN. Possible overlap with RAN2 TR 36.848 Study on smart congestion mitigation in E-UTRAN (prioritising MMTEL voice over other traffic during congestion)
- 1764: SP#65 completed. TR 22.807v200 for Approval
- 1765: -
- 1766: SP#64 completed. TR 22.897v200 for Approval. Linked to Rel-12 TR 22.803 (FS_ProSe) and FeaturES in CP-150ProSe, GCSE_LTE
- 1767: June2015: Compl:0%->100
- 1768: TR added; June2015: Compl:0%->30; 7/12/15: 30%->100
- 1769: SP#64 completed. TR 22.828v200 for Approval. Linked to FeaturES in CP-150Rel-10 LIPA_SIPTO & Rel-12 LIMONET
- 1770: SP#65 completed. TR 22.808v200 for Approval. Study supporting traffic classification and service chain selection capabilities per operators policy in order to realize efficient and flexible mobile service steering in the Gi-LAN network
- 1771: SP#65 completed. TR 22.810v200 for Approval. Linked to Multimedia Telephony Service for IMS (UID_7038), Customized Alerting Tone (CAT) UID_370028, Customized Ringing Signal (CRS) UID_380067
- 1772: SP#65 completed. Update on GERAN and UTRAN of Rel-12 TR 22.852 Study on RAN Sharing Enhancements (FS_RSE)

| ID | WBS | Task | Duration | Start | Finish | Complete | Baseline start | Baseline finish | Baseline duration | Total slack | Constraint | Resources | Work | Actual work | Acronym | PCG approved | WI rapporteur name | Release | TSG approved | MCC resp | Acronym_3GU_Export | PCG stopped | TSG stopped | Special Focus Doc | Status Report |
| --- | --- | --- | --- | --- | --- | --- | --- | --- | --- | --- | --- | --- | --- | --- | --- | --- | --- | --- | --- | --- | --- | --- | --- | --- | --- |
| 1773 | 483 | **Study on Usage Monitoring Enhancements for Service, Application and Subscriber Group** | 934d? | 2011-06-08 A | 2014-12-12 A | 100% | 2011-06-08 | 2014-12-10 | 929d? |  |  | S2 | 13978.1h | 13978.1h | FS_UMONC_sas | 27 | China Telecom | Rel-13 | 52 | Maurice | FS_UMONC_sas |  |  |  |  |
| 1774 | 483.1 | Deleted - SA1 part of Study on Usage Monitoring Control PCC Enhancement | 275d? | 2011-06-08 A | 2012-06-20 A | 100% | 2011-06-08 | 2012-06-20 | 275d? |  | finish no earlier than 2012-06-20 | S1 | 2200h | 2200h |  | 27 | ZTE |  | 52 | Maurice | FS_UMONC | PCG-31 | SP-58 |  |  |
| 1775 | 483.2 | SA2 part of Study on Usage Monitoring Control PCC Enhancement | 397.26d? | 2013-06-14 A | 2014-12-12 A | 100% | 2013-06-02 | 2014-12-10 | 403d? |  | finish no earlier than 2014-12-12 | S2 | 3178.08h | 3178.08h | FS_UMONC_sas | 27 | China Telecom | Rel-13 | 52 | Maurice |  |  |  |  |  |
| 1776 | 483.3 | Deleted - SA5 part of Study on Usage Monitoring Control enhancement | 141d? | 2012-03-02 A | 2012-09-12 A | 100% | 2012-03-02 | 2012-09-12 | 141d? |  | finish no earlier than 2012-09-12 | S5 | 1128h | 1128h |  | 27 | Huawei |  | 52 | Mirko |  | PCG-29 | SP-57 |  |  |
| 1777 | 484 | Study on Security aspects of Integration of Single Sign-On (SSO) frameworks with 3GPP networks | 1180d? | 2010-12-28 A | 2015-06-12 A | 100% | 2010-12-16 | 2014-09-17 | 988d? |  | finish no earlier than 2015-06-12 | S3 | 9440h | 9440h | FS_SSO_Int_Sec | 26 | Ericsson | Rel-13 | 50 | Mirko | FS_SSO_Int_Sec |  |  |  |  |
| 1778 | 485 | Study on Subscriber Privacy Impact in 3GPP | 591d? | 2013-09-17 A | 2015-12-16 A | 100% | 2013-09-12 | 2014-09-17 | 266d? |  | finish no earlier than 2015-12-16 | S3 | 4728h | 4728h | FS_SPI | 31 | China Unicom | Rel-13 | 61 | Mirko | FS_SPI |  |  |  |  |
| 1779 | 486 | Study on Enhancements of OAM aspects of Distributed Mobility Load Balancing (MLB) SON function | 458d? | 2014-09-15 A | 2016-06-13 A | 100% | 2013-09-12 | 2014-12-10 | 326d? |  | finish no earlier than 2016-06-13 | S5 | 3664h | 3664h | FS_D_MLB_SON_OAM | 31 | Cisco | Rel-13 | 61 | Mirko | FS_D_MLB_SON_OAM |  |  | SON |  |
| 1780 | 487 | Study on Application and Partitioning of Itf-N | 458d? | 2013-12-17 A | 2015-09-11 A | 100% | 2013-12-11 | 2014-12-10 | 261d? |  | finish no earlier than 2015-09-11 | S5 | 3664h | 3664h | FS_OAM_AP_Itf-N | 32 | China Mobile | Rel-13 | 62 | Mirko | FS_OAM_AP_Itf-N |  |  |  |  |
| 1781 | 488 | Study on Charging aspects on Roaming End-to-end scenarios with VoLTE IMS and interconnecting networks | 393d? | 2013-12-17 A | 2015-06-12 A | 100% | 2013-12-11 | 2014-12-10 | 261d? |  | finish no earlier than 2015-06-12 | S5 | 3144h | 3144h | FS_REVOLTE_IMS_CH | 32 | Deutsche Telekom | Rel-13 | 62 | Mirko | FS_REVOLTE_IMS_CH |  |  |  |  |
| 1782 | 489 | Study on Network Management of Virtualized Networks | 269d? | 2014-06-11 A | 2015-06-17 A | 100% | 2014-06-06 | 2015-06-17 | 269d? |  | finish no earlier than 2015-06-17 | S5 | 2152h | 2152h | FS_OAM_VIRNET | 33 | China Mobile, Huawei | Rel-13 | 64 |  | FS_OAM_VIRNET |  |  |  |  |
| 1783 | 490 | Study on Review of dedicated 3GPP UICC features | 729d? | 2013-03-13 A | 2015-12-16 A | 100% | 2013-03-04 | 2014-09-12 | 401d? |  | finish no earlier than 2015-12-16 | C6 | 5832h | 5832h | FS_Red_UCe | 30 | BlackBerry | Rel-13 | 59 | Xavier | FS_Red_UCe |  |  |  |  |
| 1784 | 491 | Study on Solutions for GSM/EDGE BTS Energy Saving | 458.8d? | 2011-08-30 A | 2015-11-20 A | 100% | 2009-03-10 | 2014-08-29 | 557d? |  | finish no earlier than 2015-11-20 | G1; G2 | 3670.4h | 3670.4h | FS_Energy_BTS | 25 | Nokia Networks | Rel-13 | 47 | Paolo | FS_Energy_BTS |  |  |  |  |
| 1785 | 492 | Study on Downlink MIMO | 459d? | 2014-08-14 A | 2016-05-12 A | 100% | 2013-08-20 | 2015-02-20 | 396d? |  | finish no earlier than 2016-05-12 | G1; G2 | 4004.8h | 4004.8h | FS_DOMIMO | 30 | Nokia Networks | Rel-13 | 57 | Paolo | FS_DOMIMO |  |  |  |  |
| 1786 | 493 | Study on MIMO OTA antenna test function for LTE | 462d? | 2013-03-18 A | 2014-12-15 A | 100% | 2013-03-15 | 2014-12-05 | 456d? |  | finish no earlier than 2014-12-15 | R4 | 3696h | 3696h | FS_LTE_MIMO_OTA_ATF | 33 | Keysight | Rel-13 | 64 |  | FS_LTE_MIMO_OTA_ATF |  |  |  | RP-142045 |
| 1787 | 494 | Stopped at 20% - Study on UpLink MultiUser Multiple-Input Multiple-Output (UL MU-MIMO) | 481.6d? | 2014-04-17 A | 2016-02-19 A | 100% | 2014-04-17 | 2015-02-20 | 195.5d? |  | finish no earlier than 2016-02-19 | G1; G2 | 5688h | 5688h | FS_UL_MU_MIMO | 32 | Huawei | Rel-13 | 60 |  | FS_UL_MU_MIMO |  | SP#71 |  |  |
| 1788 | 495 | Study on LTE FDD in the bands 1980-2010 MHz and 2170-2200 MHz | 854d? | 2012-09-11 A | 2015-12-15 A | 100% | 2012-09-11 | 2014-09-12 | 527d? |  | finish no earlier than 2015-12-15 | R4 | 6832h | 6832h | FS_LTE_1980_2170_Korea | 29 | KT | Rel-13 | 57 | Issam | FS_LTE_1980_2170_Korea |  |  |  | RP-151274 |
| 1789 | 496 | Study on Positioning enhancements for E-UTRA | 524d? | 2012-05-01 A | 2014-12-15 A | 100% | 2013-04-25 | 2014-12-05 | 256d? |  | finish no earlier than 2014-12-15 | R4 | 4192h | 4192h | FS_LCSenh_LTE | 31 | Huawei | Rel-13 | 60 | Issam | FS_LCSenh_LTE |  |  |  | RP-142224 |
| 1790 | 497 | Study on Multi-RAT joint coordination | 397d? | 2013-12-06 A | 2015-06-15 A | 100% | 2013-12-06 | 2014-12-05 | 261d? |  | finish no earlier than 2015-06-15 | R4 | 3176h | 3176h | FS_MultiRAT_JC | 32 | China Mobile | Rel-13 | 62 | Juha | FS_MultiRAT_JC |  |  | WLAN | RP-150807 |
| 1791 | 498 | Study on Advanced Wireless Services (AWS) - Extension band for LTE | 265d? | 2013-12-16 A | 2014-12-15 A | 100% | 2013-12-09 | 2014-12-05 | 261d? |  | finish no earlier than 2014-12-15 | R4 | 2120h | 2120h | FS_LTE_AWS_EXT | 33 | Qualcomm | Rel-13 | 64 |  | FS_LTE_AWS_EXT |  |  |  | RP-141968 |
| 1792 | 499 | Study on Indoor Positioning Enhancements for UTRA and LTE | 328d? | 2014-06-18 A | 2015-09-15 A | 100% | 2014-06-13 | 2015-09-17 | 330d? |  | finish no earlier than 2015-09-15 | R1; R4 | 5248h | 5248h | FS_UTRA_LTE_iPos_enh | 33 | NextNav | Rel-13 | 64 |  | FS_UTRA_LTE_iPos_enh |  |  |  | RP-151178 |
| 1793 | 500 | Study on Downlink enhancements for UMTS | 199d? | 2014-09-12 A | 2015-06-15 A | 100% |  |  |  |  | finish no earlier than 2015-06-15 | R2; R1 | 3184h | 3184h | FS_UTRA_EDL | 33 | Huawei | Rel-13 | 65 |  | FS_UTRA_EDL |  |  |  | RP-150681 |
| 1794 | 501 | Study on Elevation Beamforming/Full-Dimension (FD) MIMO for LTE | 199d? | 2014-09-12 A | 2015-06-15 A | 100% |  |  |  |  | finish no earlier than 2015-06-15 | R1 | 1592h | 1592h | FS_LTE_EBF_FDMIMO | 33 | Nokia Networks (DL), Samsung (UL) | Rel-13 | 65 |  | FS_LTE_EBF_FDMIMO |  |  |  | RP-150734 |
| 1795 | 502 | Study on Licensed-Assisted Access using LTE | 197d? | 2014-09-16 A | 2015-06-15 A | 100% |  |  |  |  | finish no earlier than 2015-06-15 | R1; R2; R4 | 4728h | 4728h | FS_LTE_LAA | 33 | Ericsson, Huawei | Rel-13 | 65 |  | FS_LTE_LAA |  |  |  | RP-150624 |
| 1796 | 503 | Study on EPC Signalling Improvement for Race Scenarios | 203d? | 2014-12-03 A | 2015-09-11 A | 100% |  |  |  |  | finish no earlier than 2015-09-11 | C4 | 1624h | 1624h | FS_EPC_SIG_RACE | 34 | Huawei | Rel-13 | 66 |  |  |  |  |  |  |
| 1797 | 504 | Study on Video Enhancements in 3GPP Multimedia Services | 261d? | 2014-12-12 A | 2015-12-11 A | 100% |  |  |  |  | finish no earlier than 2015-12-11 | S4 | 2088h | 2088h | FS_VE_3MS | 34 | Ye-Kui Wang, Qualcomm Incorporated | Rel-13 | 66 |  |  |  |  |  |  |
| 1798 | 505 | Study on possible additional configuration for LTE TDD | 197d? | 2014-12-15 A | 2015-09-15 A | 100% |  |  |  |  | finish no earlier than 2015-09-15 | R4 | 1576h | 1576h | FS_LTE_TDD_add_config | 34 | NTT DOCOMO, Hideaki Takahashi | Rel-13 | 66 |  |  |  |  |  | RP-151283 |
| 1799 | 506 | Study on Network-Assisted Interference Cancellation and Suppression for UMTS | 197d? | 2014-12-15 A | 2015-09-15 A | 100% |  |  |  |  | finish no earlier than 2015-09-15 | R1 | 1576h | 1576h | FS_UTRA_NAICS | 34 | Huawei | Rel-13 | 66 |  |  |  |  |  | RP-151235 |
| 1800 | 507 | Study on Enhanced Multiuser Transmissions and Network Assisted Interference Cancellation for LTE | 65d? | 2014-12-15 | 2015-03-15 |  |  |  |  | 5412d | finish no earlier than 2015-03-15 | R1 | 520h |  | FS_LTE_MUTX_NAIC | 34 | MediaTek | Rel-13 | 66 |  |  |  |  |  | RP-150213 |
| 1801 | 508 | Study on Support of single-cell point-to-multipoint transmission in LTE | 131d? | 2014-12-15 A | 2015-06-15 A | 100% |  |  |  |  | finish no earlier than 2015-06-15 | R4 | 1048h | 1048h | FS_LTE_SC_PTM | 34 | Jeff GAO | Rel-13 | 66 |  |  |  |  |  | RP-150695 |
| 1802 | 509 | Study on Extension of Dual Connectivity in E-UTRAN | 131d? | 2014-12-15 A | 2015-06-15 A | 100% |  |  |  |  | finish no earlier than 2015-06-15 | R3 | 1048h | 1048h | FS_LTE_dualC_ext | 34 | Samsung | Rel-13 | 66 |  |  |  |  |  | RP-150849 |
| 1803 | 510 | Study on further enhancements of small cell higher layer aspects for LTE | 197d? | 2014-12-15 A | 2015-09-15 A | 100% |  |  |  |  | finish no earlier than 2015-09-15 | R3 | 1576h | 1576h | FS_LTE_SC_enh2_hilayer | 34 | Huawei | Rel-13 | 66 |  |  |  |  |  | RP-151243 |
| 1804 | 511 | Study on RAN sharing enhancements for UMTS | 131d? | 2014-12-15 A | 2015-06-15 A | 100% |  |  |  |  | finish no earlier than 2015-06-15 | R3 | 1048h | 1048h | FS_RSE_UTRA_GUSH | 34 | Huawei | Rel-13 | 66 |  |  |  |  |  | RP-150684 |
| 1805 | 512 | Study on LTE DL 4 Rx antenna ports | 65d? | 2014-12-15 A | 2015-03-15 A | 100% |  |  |  |  | finish no earlier than 2015-03-15 | R4 | 520h | 520h | FS_LTE_4Rx_AP_DL | 34 | Ericsson | Rel-13 | 66 |  |  |  |  |  | RP-150138 |
| 1806 | 513 | Study on performance enhancements for high speed scenario in LTE | 262d? | 2014-12-15 A | 2015-12-15 A | 100% |  |  |  |  | finish no earlier than 2015-12-15 | R4 | 2096h | 2096h | FS_LTE_high_speed | 34 | NTTDoCoMo | Rel-13 | 66 |  |  |  |  |  | RP-151313 |
| 1807 | 514 | Study on Enhanced Multiuser Transmissions and Network | 261d? | 2014-12-12 | 2015-12-11 |  |  |  |  | 5217d | finish no earlier than 2015-12-11 | R1 | 2088h |  | FS_MUIC_LTE | 34 | Pei-Kai Liao | Rel-13 | 67 |  |  |  |  |  |  |
| 1808 | 515 | Study on regulatory aspects for flexible duplex for E-UTRAN | 133d? | 2016-06-15 A | 2016-12-15 A | 100% |  |  |  |  |  | RP | 1064h | 1064h | FS_LTE_flex_duplex_reg | 34 | LG Electronics Inc. | Rel-13 | 67 |  |  |  |  |  | RP-151307 |
| 1809 | 516 | Study on Downlink Multiuser Superposition Transmission for LTE | 197d? | 2015-03-16 A | 2015-12-15 A | 100% |  |  |  |  | finish no earlier than 2015-12-15 | R1 | 1576h | 1576h | FS_LTE_MUST | 34 | Mediatek | Rel-13 | 67 |  |  |  |  |  | RP-151345 |
| 1810 | 517 | Study on Measurement gap enhancement for LTE | 197d? | 2015-03-16 A | 2015-12-15 A | 100% |  |  |  |  | finish no earlier than 2015-12-15 | R4 | 1576h | 1576h | FS_LTE_meas_gap |  |  | Rel-13 | 67 |  |  |  |  |  | RP-151317 |
| 1811 | 518 | Study on Phase 1 of the Support of Emergency services over WLAN | 71d? | 2015-03-12 A | 2015-06-18 A | 100% |  |  |  |  | finish no earlier than 2015-06-18 | S2 | 568h | 568h | FS_SEW | 34 | Laurent Thiebaut, Alcatel Lucent | Rel-13 | 67 |  |  |  |  |  |  |
| 1812 | 519 | Study on EGPRS Access Security Enhancements with relation to cellular IoT | 197d? | 2015-03-12 A | 2015-12-11 A | 100% |  |  |  |  | finish no earlier than 2015-12-11 | S3 | 1576h | 1576h | FS_EASE_IoT | 34 | Vesa Torvinen, Ericsson | Rel-13 | 67 |  |  |  |  |  |  |
| 1813 | 520 | Study on SCC AS Restoration | 1d? | 2015-06-15 A | 2015-06-15 A | 100% |  |  |  |  | start no earlier than 2015-06-15 | C4 | 8h | 8h | FS_SCCAS_RES | 35 | Hao Zhang,, China Mobile | Rel-13 | 68 |  |  |  |  |  |  |
| 1814 | 521 | Study on S6a/S6d Shared Data Update | 130d? | 2015-06-15 A | 2015-12-11 A | 100% |  |  |  |  | finish no earlier than 2015-12-11 | C4 | 1040h | 1040h | FS_eSDU | 35 | Ulrich Wiehe, Nokia Networks | Rel-13 | 68 |  |  |  |  |  |  |
| 1815 | 522 | Study on Network Assistance for Network Synchronization in LTE | 395d? | 2015-06-15 A | 2016-12-15 A | 100% |  |  |  |  | finish no earlier than 2016-12-15 | R3 | 3160h | 3160h | FS_LTE_NW_SYNC | 35 | Huawei | Rel-14 | 68 |  |  |  |  |  |  |
| 1816 | 523 | Study onLTE Advanced inter-band Carrier Aggregation of Band 20 and Band 28 | 132d? | 2015-06-15 A | 2015-12-15 A | 100% |  |  |  |  | finish no earlier than 2015-12-15 | R4 | 1056h | 1056h | FS_LTE_CA_B20_B28 | 35 | TeliaSonera | Rel-13 | 68 |  |  |  |  |  | RP-151231 |
| 1817 | 524 | Study on Impacts of the Diameter Base Protocol Specification Update | 75d? | 2015-09-07 A | 2015-12-18 A | 100% |  |  |  |  | finish no earlier than 2015-12-18 | C4 | 600h | 600h | FS_DBPU | 35 | Huawei, Peter Schmitt | Rel-13 | 69 |  |  |  |  |  |  |
| 1818 | 525 | Study on new AWS-3/4 Band for LTE | 66d? | 2015-09-15 A | 2015-12-15 A | 100% |  |  |  |  | finish no earlier than 2015-12-15 | R4 | 528h | 528h | FS_LTE_AWS_3_4 | 35 | Dish Network | Rel-13 | 69 |  |  |  |  |  |  |
| 1819 | 526 | Study on multi-node testing for LAA | 263d? | 2016-06-15 A | 2017-06-15 A | 100% |  |  |  |  | finish no earlier than 2017-06-15 | R4 | 2104h | 2104h | FS_LTE_LAA_multinode_test | 37 | Huawei | Rel-13 | 72 |  |  |  |  |  |  |
| 1820 | 527 | Stopped - Study on Compliance of 3GPP SA5 specifications to the NGMN NGCOR | 1442d? | 2012-06-26 A | 2017-12-15 A | 100% | 2012-06-20 | 2015-09-16 | 854d? |  | finish no earlier than 2017-12-15 | S5 | 11536h | 11536h | FS_OAM_NGMN_NGCOR | 29 | Huawei | Rel-13 | 56 | Mirko | FS_OAM_NGMN_NGCOR |  |  |  |  |
| 1821 | 528 | Release 12 Features | 306d? | 2013-10-14 A | 2014-12-12 A | 100% | 2013-10-14 | 2014-12-10 | 304d? |  | finish no earlier than 2014-12-12 | SP; CP; RP; GP | 9792h | 9792h |  |  |  | Rel-12 |  |  |  |  |  |  |  |
| 1822 | 529 | Stage 1 - ONLY Features | 647d? | 2011-09-27 A | 2014-03-05 A | 100% | 2011-09-27 | 2014-03-05 | 647d? |  | start no earlier than 2011-09-27 | SP; CP | 10352h | 10352h |  | 30 |  | Rel-12 | 58 |  |  |  |  |  |  |

Notes:
- 1773: SP#64 revived. Added to the Title "for Service, Application and Subscriber Group", Changed Acronym: FS_UMONC=>FS_UMONC_sas / Impacted TSs and TRs: 23.858 / WI rapporteur e-mail: Jinyan Li (lijy@ctbri.com.cn)
- 1774: SP#56 completed / Impacted TSs and TRs: 23.858 / WI rapporteur e-mail: Li.Mian@zte.com.cn
- 1775: SP#64 revived. Updated WID SP-120554=>SP-140403. Changed Justification/objectives/Rapporteut ZTE=>China Unciom. SP#58 SA2 stopped (at 70% completion). Dec.14: 80->100%. Mar 15: WID SP-140403->SP-150029 / Impacted TSs and TRs: 23.858 / WI rapporteur e-mail: Jinyan Li (lijy@ctbri.com.cn)
- 1776: SP#57 stopped / Impacted TSs and TRs: 32.858 / WI rapporteur e-mail: Hui Cai (Sarah.Cai@huawei.com)
- 1777: SP#65 moved to Rel-13. Updated WID SP-100734=>SP-140576. Completion 09/14=>06/15. Dec.14: 60->65%; June2015: Compl:65%->100; June2015: WID:SP-140576->SP-150368 / Impacted TSs and TRs: 33.895 / WI rapporteur e-mail: vesa.lehtovirta@ericsson.com
- 1778: SP#65 moved to Rel-13. Completion 09/14=>12/15. Related to SA1 TR 22.949 Rel-6 Study on Privacy Capability (PrivCap) UID_31030 studied generalized privacy capability (protection of personal data and non-disclosure of identity). Dec.14: 80->85; June2015 / Impacted TSs and TRs: 33.849 / WI rapporteur e-mail: Feng Gao (gaofeng149@chinaunicom.cn)
- 1779: SP#64 completion 06/14=>12/14. Dec.14: 20->25%, CD: 12/14->06/15; June2015: Compl:25%->30; 7/12/15: 30%->45; 7/3/16: 45%->50; 13/6/16: 50%->100 / Impacted TSs and TRs: 32.860 / WI rapporteur e-mail: Vladimir Yanover (vyanover@cisco.com)
- 1780: -Dec.14: 15->30%, CD: 12/14->09/15; June2015: Compl:30%->60; 07/09/15: 60%->100 / Impacted TSs and TRs: 32.861 / WI rapporteur e-mail: Li Jian (lijian@chinamobile.com), Hu Yaxi (huyaxi@cmdi.chinamobile.com)
- 1781: SP#64 moved to Rel-13. Completion 06/14=>12/14. Dec.14: 35->55, CD: 12/14->06/15. Mar 15: 55->75%; June2015: Compl:75%->100 / Impacted TSs and TRs: 32.849 / WI rapporteur e-mail: Roland Jesske (r.jesske@telekom.de)
- 1782: Dec.14: 10->25%. Mar 15: 25->60%; June2015: Compl:60%->85; 07/09/15: 85%->100 / Impacted TSs and TRs: 32.842 / WI rapporteur e-mail: Liu Jinglei (liujinglei@chinamobile.com), zoulan@huawei.com
- 1783: CP#65 TR 31.901v100 for Information. Moved to Rel-13. Completion 09/14=>12/15. Waiting for feedback from external organizations (PTCRB/PVG). Dec.14: 65->100% / Impacted TSs and TRs: 31.901 / WI rapporteur e-mail: Adrian Buckley (abuckley@blackberry.com)
- 1784: GP#63 moved to Rel-13. Completion 08/14=>11/14. GP#55 TR 45.926v100 for Information. GP#47 approved WID. Dec.14: 90->95%. 3/3/15: start date corrected (was 03/09). 7/9/15: FCD: 8/15->11/15; 7/12/15: 95%->100 / Impacted TSs and TRs: 45.926 / WI rapporteur e-mail: juergen.hofmann@nokia.com
- 1785: GP#62 completion 08/14=>02/15. Moved to Rel-13. GP#57 approved WID. Dec.14: 50->65%, CD: 02/15->05/15. 7/9/15: FCD: 11/15->02/16; 2/3/16: 65%->75, FCD: 02/16->05/16; 11/9/17: 75%->100 / Impacted TSs and TRs: 45.8xy / WI rapporteur e-mail: juergen.hofmann@nokia.com
- 1786: CD:Thu 11/12/14->Mon 15/12/14; Compl:60%->100%; Stat Rep: RP-141124->RP-142045 / Impacted TSs and TRs: 36.509, new TR 37.978 / WI rapporteur e-mail: Moray_Rumney@keysight.com
- 1787: GP#62 completion 11/14=>02/15. GP#60 approved WID. Dec.14: 02/15->05/15. 02/03/16: stopped at 20% / Impacted TSs and TRs: 45.876 / WI rapporteur e-mail: Chao Luo (chluo@huawei.com)
- 1788: CD:Thu 11/12/14->Sun 15/03/15; Compl:85%->90%; Stat Rep: RP-141153->RP-141851 1st Apr 15: CD:Sun 15/03/15->Mon 15/06/15 1st Apr 15: WID: RP-141154->RP-150119 1st Apr 15: Stat Rep: RP-141851->RP-150120 03/07/15: CD:Mon 15/06/15->Tue 15/09/15 03/07/15: S / Impacted TSs and TRs: LTE 36.861 / WI rapporteur e-mail: Chungwoo HWANG (cwhwang@kt.com)
- 1789: WID: RP-140667->RP-130680; Stat Rep: RP-140639->RP-142224. 3/3/15: R1 removed as 2nd responsible WG / Impacted TSs and TRs: LTE 36.855 / WI rapporteur e-mail: Jie Cui (cuijie@huawei.com)
- 1790: ; WID: RP-142043->RP-132086; Stat Rep: RP-141301->RP-141838 1st Apr 15: Compl:55%->85% 1st Apr 15: WID: RP-132086->RP-150417 1st Apr 15: Stat Rep: RP-141838->RP-150187 03/07/15: Compl:85%->100% 03/07/15: Stat Rep: RP-150187->RP-150807 / Impacted TSs and TRs: UTRA, LTE 37.870 / WI rapporteur e-mail: Kimba Dit Adamou, Boubacar (jinba@chinamobile.com)
- 1791: CD:Thu 11/12/14->Mon 15/12/14; Compl:10%->100%; Stat Rep: RP-141429->RP-141968. 5/5/15: 2nd TR number added (to be clarified why two TR for a same topic) / Impacted TSs and TRs: 36.849, 36.869 / WI rapporteur e-mail: Gene Fong (gfong@qti.qualcomm.com)
- 1792: CD:Thu 17/09/15->Tue 15/09/15; Compl:0%->8%; Stat Rep: RP-141101->RP-141818 1st Apr 15: Compl:8%->30% 1st Apr 15: Stat Rep: RP-141818->RP-150080 03/07/15: Compl:30%->75% 03/07/15: Stat Rep: RP-150080->RP-150595 29/09/15: Compl:75%->100% 29/09/15: Stat / Impacted TSs and TRs: UTRA, LTE 37.857 / WI rapporteur e-mail: Vogedes Jerome (jvogedes@NextNav.com)
- 1793: WID: RP-141901; Stat Rep: -->RP-142233 1st Apr 15: Compl:40%->80% 1st Apr 15: WID: RP-141901->RP-150224 1st Apr 15: Stat Rep: RP-142233->RP-150223. 5/5/15: R4 replaced by R1 (correction mistake) 03/07/15: Compl:80%->100% 03/07/15: Stat Rep: RP-150223-> / Impacted TSs and TRs: UTRA TR 25.706 / WI rapporteur e-mail: jun.chen@huawei.com
- 1794: 3/3/15: WID: RP-141831; Stat Rep: -->RP-141822, impacted TR number added. 1st Apr 15: Compl:30%->45% 1st Apr 15: Stat Rep: RP-141822->RP-150346. 5/5/15: "R4" replaced by "R1" (correction mistake) 03/07/15: Compl:45%->100% 03/07/15: WID: RP-141831->RP-1 / Impacted TSs and TRs: 36.897 / WI rapporteur e-mail: bishwarup.mondal@nsn.com, hyoungju.ji@samsung.com
- 1795: 3/3/15: WID: RP-141817; Stat Rep: -->RP-141816. Impacted TR number added. 1st Apr 15: Compl:30%->40% 1st Apr 15: Stat Rep: RP-141816->RP-150414 03/07/15: Compl:40%->100% 03/07/15: Stat Rep: RP-150414->RP-150624 / Impacted TSs and TRs: 36.889 / WI rapporteur e-mail: havish.koorapaty@ericsson.com, david.mazzarese@huawei.com
- 1796: Mar15: 0->20%; June2015: Compl:20%->80; 07/09/15: 80%->95; 7/12/15: 95%->100 / Impacted TSs and TRs: New TR 29.811
- 1797: Mar. 15: 0->20%; June2015: Compl:20%->40; 07/09/15: 40%->80; 7/12/15: 80%->100 / WI rapporteur e-mail: yekuiw@qti.qualcomm.com
- 1798: TR 36.825 rapporteur: CATT. TR number added. 1st Apr 15: Compl:0%->5% 1st Apr 15: Stat Rep: ->RP-150151 03/07/15: Compl:5%->35% 03/07/15: WID: RP-142248->RP-150652 03/07/15: Stat Rep: RP-150151->RP-150805 29/09/15: Compl:35%->100% 29/09/15: Stat Rep: R / Impacted TSs and TRs: 36.825 / WI rapporteur e-mail: NTT DOCOMO
- 1799: TS number added 1st Apr 15: Compl:0%->20% 1st Apr 15: WID: RP-142250->RP-150174 1st Apr 15: Stat Rep: ->RP-150175. 5/5/15: "R4" replaced by "R1" (correction mistake) 03/07/15: Compl:20%->65% 03/07/15: Stat Rep: RP-150175->RP-150679 29/09/15: Compl:65%- / Impacted TSs and TRs: 25.766 / WI rapporteur e-mail: Huawei
- 1800: 1st Apr 15: CD:Tue 15/12/15->Sun 15/03/15 1st Apr 15: Stat Rep: ->RP-150213. 5/5/15: "R4" replaced by "R1" (correction mistake) / WI rapporteur e-mail: MediaTek
- 1801: deleted 660062 (duplicated). 29/1: TR number added 1st Apr 15: Compl:0%->25% 1st Apr 15: WID: RP-142205->RP-150177 1st Apr 15: Stat Rep: ->RP-150176 03/07/15: Compl:25%->100% 03/07/15: Stat Rep: RP-150176->RP-150695 / Impacted TSs and TRs: TR 36.890 / WI rapporteur e-mail: gaoyongqiang@huawei.com
- 1802: 1st Apr 15: WID: RP-142257->RP-150170 1st Apr 15: Stat Rep: ->RP-150163 03/07/15: Compl:85%->100% 03/07/15: Stat Rep: RP-150163->RP-150849. 7/10/15: responsible group corrected (R4->R3) / Impacted TSs and TRs: 36.875 / WI rapporteur e-mail: Samsung
- 1803: 03/07/15: Compl:10%->30% 03/07/15: Stat Rep: RP-150226->RP-150683 29/09/15: Compl:30%->100% 29/09/15: Stat Rep: RP-150683->RP-151243. 7/10/15: responsible group corrected (R4->R3) and TS (37.876->36.876) / Impacted TSs and TRs: 36.876 / WI rapporteur e-mail: Huawei
- 1804: 03/07/15: Compl:10%->100% 03/07/15: WID: RP-142284->RP-150686 03/07/15: Stat Rep: RP-150227->RP-150684. 7/10/15: responsible group corrected (R4->R3) / Impacted TSs and TRs: 25.756 / WI rapporteur e-mail: Huawei
- 1805: 1st Apr 15: Compl:0%->100% 1st Apr 15: WID: RP-142299->RP-150457 1st Apr 15: Stat Rep: ->RP-150138 / WI rapporteur e-mail: Ericsson
- 1806: TR Rapporteur is Huawei 1st Apr 15: Compl:0%->5% 1st Apr 15: WID: RP-142307->RP-150159 1st Apr 15: Stat Rep: ->RP-150517 03/07/15: Compl:5%->40% 03/07/15: Stat Rep: RP-150517->RP-150793 29/09/15: Compl:40%->80% 29/09/15: CD:Tue 15/09/15->Tue 15/12/15 2 / WI rapporteur e-mail: NTTDoCoMo
- 1807: TR added / Impacted TSs and TRs: 36.891 / WI rapporteur e-mail: pk.liao@mediatek.com
- 1808: TR added 03/07/15: Compl:0%->5% 03/07/15: Stat Rep: -->RP-150770 29/09/15: Compl:5%->100% 29/09/15: Stat Rep: RP-150770->RP-151307 / Impacted TSs and TRs: 36.882
- 1809: TR added 03/07/15: Compl:0%->30% 03/07/15: WID: RP-150496->RP-151100 03/07/15: Stat Rep: -->RP-150857 29/09/15: Compl:30%->50% 29/09/15: Stat Rep: RP-150857->RP-151345 / Impacted TSs and TRs: 36.859
- 1810: 03/07/15: Compl:0%->15% 03/07/15: CD:Thu 10/12/15->Tue 15/12/15 03/07/15: Stat Rep: ->RP-150754 03/07/15: Release: REL-13->Rel-13. Aug 15: TR numb added 29/09/15: Compl:15%->65% 29/09/15: Stat Rep: RP-150754->RP-151317 / Impacted TSs and TRs: 36.894
- 1811: June2015: Compl:0%->100, SP-150151->SP-150251 / Impacted TSs and TRs: new 23.771 / WI rapporteur e-mail: Laurent.thiebaut@alcatel-lucent.com
- 1812: TR added; June2015: Compl:0%->25; 7/12/15: 25%->70; 28/1/16: 33.420 added; 7/3/16: 70%->100 / Impacted TSs and TRs: New 33.860; 33.420
- 1813: 07/09/15: 5%->20; 7/12/15: 20%->100 / Impacted TSs and TRs: New 29.812 / WI rapporteur e-mail: zhanghao@chinamobile.com
- 1814: 07/09/15: 0%->20; 7/12/15: 20%->100 / Impacted TSs and TRs: New 29.813 / WI rapporteur e-mail: ulrich.wiehe@nokia.com
- 1815: Aug 15: TR numb added 29/09/15: Compl:0%->15% 29/09/15: WID: RP-151084->RP-151252 29/09/15: Stat Rep: -->RP-151240 22/3/16: Compl:60%->80%; 22/3/16: CD:Tue 15/03/16->Wed 15/06/16; ; / Impacted TSs and TRs: New 36.898
- 1816: 29/09/15: Compl:0%->20% 29/09/15: WID: RP-151101->RP-151515 29/09/15: Stat Rep: -->RP-151231
- 1817: 7/3/16: 0%->79; 13/6/16: 79%->99; 2/12/16: 99%->100 / Impacted TSs and TRs: 29.274, 29.060, 23.003, 29.272, 29.002, 29.305, 23.008, 29.230, 29.303, 23.007, 24.301, 24.008
- 1818: Impacted TSs and TRs: 36.870
- 1819: coexistence testing for REL-13 WI LTE_LAA26/9/16: Compl:0%->10%26/9/16: WID: RP-161197->RP-161672; 20/12/16: Compl:10%->30%; 20/12/16: CD:Thu 15/12/16->Wed 15/03/17; 20/12/16: WID: RP-161672->RP-162144; 21/3/17: CD:Wed 15/03/17->Thu 15/06/17; ;...
- 1820: SP#65 updated WID SP-140349=>SP-140539. Dec.14: 35->45, 12/14: 28.821 added. Mar 15: 45->50%; June2015: Compl:50%->60. 07/09/15: FCD: 09/15->12/15; 7/12/15: FCD:12/15->03/16; 21/3/17:marked as stopped, was 60% / Impacted TSs and TRs: TR 32.837, TR 28.821 / WI rapporteur e-mail: zoulan@huawei.com
- 1821: -
- 1822: -

| ID | WBS | Task | Duration | Start | Finish | Complete | Baseline start | Baseline finish | Baseline duration | Constraint | Resources | Work | Actual work | Acronym | PCG approved | Impacted TSs and TRs | WI rapporteur name | WI rapporteur e-mail | Release | TSG approved | MCC resp | Special Focus Doc | Acronym_3GU_Export | PCG stopped | TSG stopped |
| --- | --- | --- | --- | --- | --- | --- | --- | --- | --- | --- | --- | --- | --- | --- | --- | --- | --- | --- | --- | --- | --- | --- | --- | --- | --- |
| 1823 | 530 | **SIPTO Service Continuity of IP Data Session** | 262d? | 2010-09-23 A | 2011-09-21 A | 100% | 2010-09-23 | 2011-09-21 | 262d? |  | S1 | 4176h | 4176h | SIPTO_SC | 25 | Stage 1 | Vodafone | mona.mustapha@vodafone.com | Rel-12 | 49 | Alain | HNB | SIPTO_SC |  |  |
| 1824 | 530.1 | Stage 1 for SIPTO Service Continuity of IP Data Session | 262d? | 2010-09-23 A | 2011-09-21 A | 100% | 2010-09-23 | 2011-09-21 | 262d? | finish no earlier than 2011-09-21 | S1 | 2080h | 2080h | SIPTO_SC-SA1 | 25 | 22.101, 22.220 | Vodafone | mona.mustapha@vodafone.com | Rel-12 | 49 | Alain | HNB |  |  |  |
| 1825 | 531 | **Interworking between Mobile Operators using the Evolved Packet System and Data Application Providers** | 792d? | 2010-12-16 A | 2013-12-11 A | 100% | 2010-12-16 | 2013-12-11 | 792d? |  | S1; S2 | 22794.7h | 22794.7h | MOSAP | 26 | Stage 1 | Cisco | Vojislav Vucetic (vvucetic@cisco.com) | Rel-12 | 50 | Alain |  | MOSAP |  |  |
| 1826 | 531.1 | Stage 1 for MOSAP | 202d? | 2010-12-16 A | 2011-09-21 A | 100% | 2010-12-16 | 2011-09-21 | 202d? | finish no earlier than 2011-09-21 | S1 | 1600h | 1600h | MOSAP-SA1 | 26 | 22.278 | Cisco | Vojislav Vucetic (vvucetic@cisco.com) | Rel-12 | 50 | Alain |  |  |  |  |
| 1827 | 531.2 | TR on Stage 2 for MOSAP | 669d? | 2011-06-06 A | 2013-12-11 A | 100% | 2011-06-06 | 2013-12-11 | 669d? | finish no earlier than 2012-12-12 | S2 | 5338.74h | 5338.74h | MOSAP-SA2TR | 27 | new TR 23.862 | Intel | chang.hong.shan@intel.com | Rel-12 | 52 | Maurice |  |  |  |  |
| 1828 | 531.3 | Deleted - Stage 2 for MOSAP | 399d? | 2011-06-14 A | 2012-12-12 A | 100% | 2011-06-14 | 2012-12-12 | 399d? | finish no earlier than 2012-12-12 | S2 | 3184h | 3184h | MOSAP-SA2Del | 27 | TBD | Intel | chang.hong.shan@intel.com | Rel-12 | 52 | Maurice |  |  | PCG-30 | SP-58 |
| 1829 | 532 | **IMS Network-Independent Public User Identities** | 275d? | 2011-06-08 A | 2012-06-20 A | 100% | 2011-06-08 | 2012-06-20 | 275d? |  | S1 | 4390.4h | 4390.4h | INIPUI | 27 | Stage 1 | Vodafone | mona.mustapha@vodafone.com | Rel-12 | 52 | Alain |  | INIPUI |  |  |
| 1830 | 532.1 | Stage 1 for IMS Network-Independent Public User Identities | 275d? | 2011-06-08 A | 2012-06-20 A | 100% | 2011-06-08 | 2012-06-20 | 275d? | finish no earlier than 2012-06-20 | S1 | 2190.4h | 2190.4h | INIPUI-SA1 | 27 | 22.115, 22.228 | Vodafone | mona.mustapha@vodafone.com | Rel-12 | 52 | Alain |  |  |  |  |
| 1831 | 533 | **Service and Media Reachability for Users over Restrictive Firewalls** | 198d? | 2011-09-21 A | 2012-06-20 A | 100% | 2011-09-21 | 2012-06-20 | 198d? |  | S1 | 3161.67h | 3161.67h | SMURFs | 27 | Stage 1 | Vodafone | mona.mustapha@vodafone.com | Rel-12 | 53 | Alain |  | SMURFs |  |  |
| 1832 | 533.1 | Stage 1 for Service and Media Reachability for Users over Restrictive Firewalls | 198d? | 2011-09-21 A | 2012-06-20 A | 100% | 2011-09-21 | 2012-06-20 | 198d? | finish no earlier than 2012-06-08 | S1 | 1577.67h | 1577.67h | SMURFs-SA1 | 27 | 22.278 | Vodafone | mona.mustapha@vodafone.com | Rel-12 | 53 | Alain |  |  |  |  |
| 1833 | 534 | **Advanced IP Interconnection of Services (IPXS) for national interconnect** | 139d? | 2012-03-06 A | 2012-09-12 A | 100% | 2012-03-06 | 2012-09-12 | 139d? |  | S1 | 2208h | 2208h | IPXSNAT | 28 | Stage 1 | KPN | toon.norp@tno.nl | Rel-12 | 55 | Alain |  | IPXSNAT |  |  |
| 1834 | 534.1 | Stage 1 for Advanced IP Interconnection of Services (IPXS) for national interconnect | 139d? | 2012-03-06 A | 2012-09-12 A | 100% | 2012-03-06 | 2012-09-12 | 139d? | finish no earlier than 2012-09-12 | S1 | 1096h | 1096h | IPXSNAT-SA1 | 28 | 22.228 CR#0161 | KPN | toon.norp@tno.nl | Rel-12 | 55 | Alain |  |  |  |  |
| 1835 | 535 | **Integration of Single Sign-On (SSO) frameworks with 3GPP networks** | 137d? | 2012-03-08 A | 2012-09-12 A | 100% | 2012-03-08 | 2012-09-12 | 137d? |  | S1 | 2184h | 2184h | SSO_Int | 28 | Stage 1 | InterDigital | christopher.wallace@interdigital.com | Rel-12 | 55 | Alain |  | SSO_Int |  |  |
| 1836 | 535.1 | Stage 1 for Integration of Single Sign-On (SSO) frameworks with 3GPP networks | 137d? | 2012-03-08 A | 2012-09-12 A | 100% | 2012-03-08 | 2012-09-12 | 137d? | finish no earlier than 2012-09-12 | S1 | 1088h | 1088h | SSO_Int-SA1 | 28 | 22.101 | InterDigital | christopher.wallace@interdigital.com | Rel-12 | 55 | Alain |  |  |  |  |
| 1837 | 536 | **Explicit Communication Transfer Blind (ECT Blind) service interactions** | 3d? | 2012-06-18 A | 2012-06-20 A | 100% | 2012-06-18 | 2012-06-20 | 3d? |  | S1 | 48h | 48h | ECTB | 29 | Stage 1 | Orange | philippe.lottin@orange.com | Rel-12 | 56 | Alain |  | ECTB |  |  |
| 1838 | 536.1 | Stage 1 for Explicit Communication Transfer Blind (ECT Blind) service interactions | 3d? | 2012-06-18 A | 2012-06-20 A | 100% | 2012-06-18 | 2012-06-20 | 3d? | finish no earlier than 2012-06-20 | S1 | 24h | 24h | ECTB-SA1 | 29 | 22.173 | Orange | philippe.lottin@orange.com | Rel-12 | 56 | Alain |  |  |  |  |
| 1839 | 537 | **IMS access via Digital Video Broadcast - Return Channel via Satellite (DVB-RCS2)** | 162d? | 2012-02-02 A | 2012-09-12 A | 100% | 2012-02-02 | 2012-09-12 | 162d? |  | S1 | 2584h | 2584h | IMSSat | 29 | Stage 1 | KPN | toon.norp@tno.nl | Rel-12 | 57 | Alain |  | IMSSat |  |  |
| 1840 | 537.1 | Stage 1 for IMS access via DVB-RCS2 | 162d? | 2012-02-02 A | 2012-09-12 A | 100% | 2012-02-02 | 2012-09-12 | 162d? | finish no earlier than 2012-09-12 | S1 | 1288h | 1288h | IMSSat-SA1 | 29 | 22.228 | KPN | toon.norp@tno.nl | Rel-12 | 57 | Alain |  |  |  |  |
| 1841 | 538 | **Sequential Flexible Alerting** | 3d? | 2012-12-10 A | 2012-12-12 A | 100% | 2012-12-10 | 2012-12-12 | 3d? |  | S1 | 48h | 48h | SEQ_FA | 30 | Stage 1 | Orange | bruno.tossou@orange-ftgroup.com | Rel-12 | 58 | Alain |  | IMSSat |  |  |
| 1842 | 538.1 | Stage 1 for Sequential Flexible Alerting | 3d? | 2012-12-10 A | 2012-12-12 A | 100% | 2012-12-10 | 2012-12-12 | 3d? | finish no earlier than 2012-12-12 | S1 | 24h | 24h | SEQ_FA | 30 | 22.173 | Orange | bruno.tossou@orange-ftgroup.com | Rel-12 | 58 | Alain |  |  |  |  |
| 1843 | 539 | **Language and Modality Information for communications** | 63d? | 2012-12-11 A | 2013-03-06 A | 100% | 2012-12-11 | 2013-03-06 | 63d? |  | S1 | 1008h | 1008h | LangInfo | 30 | Stage 1 | Orange | philippe.lottin@orange.com | Rel-12 | 58 | Alain |  | LangInfo |  |  |
| 1844 | 539.1 | Stage 1 for Language and Modality Information for communications | 63d? | 2012-12-11 A | 2013-03-06 A | 100% | 2012-12-11 | 2013-03-06 | 63d? | finish no earlier than 2013-03-06 | S1 | 504h | 504h | LangInfo-SA1 | 30 | 22.228 | Orange | philippe.lottin@orange.com | Rel-12 | 58 | Alain |  |  |  |  |
| 1845 | 540 | **Emergency Session Identification** | 3d? | 2013-03-04 A | 2013-03-06 A | 100% | 2013-03-04 | 2013-03-06 | 3d? |  | S1 | 48h | 48h | ESID | 30 | Stage 1 | Telecom Italia | carmen.catalano@telecomitalia.it | Rel-12 | 59 | Alain |  | ESID |  |  |
| 1846 | 540.1 | Stage 1 for Emergency Session Identification | 3d? | 2013-03-04 A | 2013-03-06 A | 100% | 2013-03-04 | 2013-03-06 | 3d? | finish no earlier than 2013-03-06 | S1 | 24h | 24h | ESID-SA1 | 30 | 22.101 | Telecom Italia | carmen.catalano@telecomitalia.it | Rel-12 | 59 | Alain |  |  |  |  |

Notes:
- 1823: SP#57 moved to Rel-12 (Reason: Stage 2 for requirements in TS 22.101 clause 4.3.5 have not been implemented in Rel-11). Linked to Rel-10 Local IP Access and Selected Internet IP Traffic Offload (LIPA_SIPTO)
- 1824: SP#57 moved to Rel-12. SP#53 completed
- 1825: SP#58 Stage 2 stopped (TR only, no normative work done)
- 1826: SP#53 completed
- 1827: SP#62 completed. TR 23.862v200 for Approval. SP#58 frozen as v100.
- 1828: SP#58 stopped (no normative work done)
- 1829: Triggered by Rel-11 TR 22.894 (FS_INIPUI)
- 1830: SP#56 re-completed. Updated WID SP-110381=>SP-120425 (Re-opened & moved to Rel-12 by adding new reqs & removing reqs from Rel-11). SP#53 Rel-11 Stage 1 completed
- 1831: SP#56 Stage 1 completed
- 1832: SP#56 completed
- 1833: SP#57 Stage 1 completed. Linked to Rel-11 Feature Advanced IP Interconnection of Services (IPXS) UID_470051.
- 1834: SP#57 completed
- 1835: SP#57 Stage 1 completed. Triggered by Rel-12 TR 22.895. Linked to SA3 33.8xy (Study on Security aspects of SSO_Int), 33.914 (SSO application security for common IMS based on SIP Digest), 33.924 (i/w GBA and OpenID), 33.980 (i/w GBA and Liberty Alliance)
- 1836: SP#57 completed
- 1837: SP#56 WID approved & Stage 1 completed
- 1838: SP#56 new WID approved & work completed. Clarify the service interactions between ECT Blind and other MMTEL Supplementary Services
- 1839: SP#57 Stage 1 completed. Integrate Satcom access with IMS. Specify DVB-RCS2 as an IP Connectivity Access Network for IMS
- 1840: SP#57 completed. Definition of DVB-RCS2 as a non-3GPP IP Connectivity Access Network for IMS
- 1841: SP#58 approved WID & Stage 1 completed. Currently Flexible Alerting (FA) group members are simultaneously alerted by the incoming call. Add the possibility to alert FA group members sequentially. 22/01: acronym modified
- 1842: SP#58 approved WID & Stage 1 completed
- 1843: SP#59 Stage 1 completed. Triggered by Rel-11 Study on Non Voice Emergency Services (FS_NOVES) TR 22.871 use case 10
- 1844: SP#59 completed. Updated WID SP-120937=>SP-130108
- 1845: SP#59 Stage 1 completed.
- 1846: SP#59 completed (22.101 CR#0445)

| ID | WBS | Task | Duration | Start | Finish | Complete | Baseline start | Baseline finish | Baseline duration | Constraint | Resources | Work | Actual work | Acronym | PCG approved | WI rapporteur name | WI rapporteur e-mail | Release | TSG approved | MCC resp | PCG stopped | TSG stopped | Acronym_3GU_Export | Special Focus Doc | Status Report |
| --- | --- | --- | --- | --- | --- | --- | --- | --- | --- | --- | --- | --- | --- | --- | --- | --- | --- | --- | --- | --- | --- | --- | --- | --- | --- |
| 1847 | 541 | **Deleted - Application and Service Access Control** | 77d? | 2013-03-06 A | 2013-06-19 A | 100% | 2013-03-06 | 2013-06-19 | 77d? |  | S1 | 1224h | 1224h | ASAC | 30 | NTT DOCOMO | Atsushi Minokuchi (minokuchi@nttdocomo.co.jp) | Rel-12 | 59 | Alain | PCG-31 | SP-60 | ASAC |  |  |
| 1848 | 541.1 | Deleted - Stage 1 for Application and Service Access Control | 77d? | 2013-03-06 A | 2013-06-19 A | 100% | 2013-03-06 | 2013-06-19 | 77d? | finish no earlier than 2013-06-19 | S1 | 608h | 608h | ASAC-SA1del | 30 | NTT DOCOMO | Atsushi Minokuchi (minokuchi@nttdocomo.co.jp) | Rel-12 | 59 | Alain | PCG-31 | SP-60 |  |  |  |
| 1849 | 542 | **Prevention of Mobile-Originating signalling and/or data traffic of UE in Connected mode** | 3d? | 2013-03-04 A | 2013-03-06 A | 100% | 2013-03-04 | 2013-03-06 | 3d? |  | S1 | 48h | 48h | PMOC | 30 | NTT DOCOMO | Atsushi Minokuchi (minokuchi@nttdocomo.co.jp) | Rel-12 | 59 | Alain |  |  | PMOC |  |  |
| 1850 | 542.1 | Stage 1 for Prevention of Mobile-Originating signalling and/or data traffic of UE in Connected mode | 3d? | 2013-03-04 A | 2013-03-06 A | 100% | 2013-03-04 | 2013-03-06 | 3d? | finish no earlier than 2013-03-06 | S1 | 24h | 24h | PMOC-SA1 | 30 | NTT DOCOMO | Atsushi Minokuchi (minokuchi@nttdocomo.co.jp) | Rel-12 | 59 | Alain |  |  |  |  |  |
| 1851 | 543 | SA1/SA2 Features | 216d? | 2013-05-17 A | 2014-03-07 A | 100% | 2013-05-17 | 2014-03-07 | 216d? | finish no earlier than 2014-03-07 | SP; CP; RP | 5184h | 5184h |  | 30 |  |  | Rel-12 | 58 |  |  |  |  |  |  |
| 1852 | 544 | **LIPA Mobility and SIPTO at the Local Network** | 898d? | 2010-10-15 A | 2014-03-06 A | 100% | 2010-10-15 | 2014-03-06 | 898d? |  | S2; C4; C1; R3 | 87994h | 87994h | LIMONET | 26 | Huawei | zhufenqin@huawei.com | Rel-12 | 50 | Maurice |  |  | LIMONET | HNB |  |
| 1853 | 544.1 | TR on Stage 2 for LIPA Mobility and SIPTO at the Local Network | 580.85d? | 2010-10-15 A | 2013-03-06 A | 100% | 2010-10-15 | 2013-03-06 | 580.85d? | finish no earlier than 2013-03-06 | S2 | 4646.8h | 4646.8h | LIMONET-SA3 | 26 | Huawei | zhufenqin@huawei.com | Rel-12 | 50 | Maurice |  |  |  | HNB |  |
| 1854 | 544.2 | **BB1: SIPTO at the Local Network** | 892d? | 2010-10-22 A | 2014-03-05 A | 100% | 2010-10-22 | 2014-03-05 | 892d? |  | S2 | 31685.6h | 31685.6h | LIMONET-SIPTO | 26 | Huawei | zhufenqin@huawei.com | Rel-12 | 50 | Maurice |  |  | LIMONET-SIPTO | HNB |  |
| 1855 | 544.2.1 | Stage 2 for SIPTO at the Local Network | 655.85d? | 2010-10-22 A | 2013-06-19 A | 100% | 2010-10-22 | 2013-06-19 | 655.85d? | finish no earlier than 2013-06-19 | S2 | 5246.8h | 5246.8h | LIMONET-SIPTO-SA2 | 26 | Huawei | zhufenqin@huawei.com | Rel-12 | 50 | Maurice |  |  |  | HNB |  |
| 1856 | 544.2.2 | **Stage 3 CN aspects of SIPTO at the Local Network** | 649d? | 2011-09-24 A | 2014-03-05 A | 100% | 2011-09-24 | 2014-03-05 | 649d? |  | C4; C1 | 19680h | 19680h | LIMONET-SIPTO | 27 | Huawei | peter.schmitt@huawei.com | Rel-12 | 53 | Kimmo |  |  |  | HNB |  |
| 1857 | 544.2.2.1 | CT4 part of Stage 3 CN aspects of SIPTO at the Local Network | 518d? | 2011-09-24 A | 2013-09-06 A | 100% | 2011-09-24 | 2013-09-06 | 518d? | finish no earlier than 2013-09-06 | C4 | 4136h | 4136h | LIMONET-SIPTO-CT4 | 27 | Huawei | peter.schmitt@huawei.com | Rel-12 | 53 | Kimmo |  |  |  | HNB |  |
| 1858 | 544.2.2.2 | CT1 part of Stage 3 CN aspects of SIPTO at the Local Network | 646d? | 2011-09-24 A | 2014-03-05 A | 100% | 2011-09-24 | 2014-03-05 | 646d? | finish no earlier than 2014-01-29 | C1 | 5160h | 5160h | LIMONET-SIPTO-CT1 | 27 | Huawei | peter.schmitt@huawei.com | Rel-12 | 53 | Frederic |  |  |  | HNB |  |
| 1859 | 544.3 | **RAN aspects for SIPTO at the Local Network** | 269d? | 2013-03-04 A | 2014-03-06 A | 100% | 2013-03-04 | 2014-03-06 | 269d? |  | R3 | 4272h | 4272h | LIMONET-RAN | 30 | Huawei | zheng.zhou@huawei.com | Rel-12 | 59 | Juha |  |  | LIMONET-RAN | HNB |  |
| 1860 | 544.3.1 | Core part: RAN aspects for SIPTO at the Local Network | 266d? | 2013-03-04 A | 2014-03-06 A | 100% | 2013-03-04 | 2014-03-06 | 266d? | finish no earlier than 2014-03-06 | R3 | 2120h | 2120h | LIMONET-RAN-Core | 30 | Huawei | zheng.zhou@huawei.com | Rel-12 | 59 | Juha |  |  | LIMONET-RAN-Core | HNB | RP-131512 |
| 1861 | 544.4 | **Deleted - BB2: Stand-alone L-GW and associated Mobility for LIPA and SIPTO at the Local Network** | 566d? | 2010-10-22 A | 2012-12-12 A | 100% | 2010-10-22 | 2012-12-12 | 566d? |  | S2 | 18653.6h | 18653.6h | LIMONET-LIPA | 26 | Huawei | zhufenqin@huawei.com | Rel-12 | 50 | Maurice | PCG-30 | SP-58 | LIMONET-LIPA | HNB |  |
| 1862 | 544.4.1 | Deleted - Stage 2 for stand-alone L-GW and associated Mobility for LIPA and SIPTO at the Local Network | 519.85d? | 2010-10-22 A | 2012-12-12 A | 100% | 2010-10-22 | 2012-12-12 | 519.85d? | finish no earlier than 2012-12-12 | S2 | 4158.8h | 4158.8h | LIMONET-LIPA-del1 | 26 | Huawei | zhufenqin@huawei.com | Rel-12 | 50 | Maurice | PCG-30 | SP-58 |  | HNB |  |
| 1863 | 544.4.2 | **Deleted - Stage 3 CN aspects of LIPA Mobility** | 323d? | 2011-09-24 A | 2012-12-12 A | 100% | 2011-09-24 | 2012-12-12 | 323d? |  | C1; C4 | 10336h | 10336h | LIMONET-LIPA-del2 | 27 | Huawei | christian.herrero@huawei.com | Rel-12 | 53 | Frederic | PCG-30 | SP-58 |  | HNB |  |
| 1864 | 544.4.2.1 | Deleted - CT1 part of CN aspects of LIPA Mobility | 323d? | 2011-09-24 A | 2012-12-12 A | 100% | 2011-09-24 | 2012-12-12 | 323d? | finish no earlier than 2012-12-12 | C1 | 2584h | 2584h | LIMONET-LIPA-del3 | 27 | Huawei | christian.herrero@huawei.com | Rel-12 | 53 | Frederic | PCG-30 | SP-58 |  | HNB |  |
| 1865 | 544.4.2.2 | Deleted - CT4 part of CN aspects of LIPA Mobility | 323d? | 2011-09-24 A | 2012-12-12 A | 100% | 2011-09-24 | 2012-12-12 | 323d? | finish no earlier than 2012-12-12 | C4 | 2584h | 2584h | LIMONET-LIPA-del4 | 27 | Huawei | christian.herrero@huawei.com | Rel-12 | 53 | Kimmo | PCG-30 | SP-58 |  | HNB |  |
| 1866 | 545 | **Operator Policies for IP Interface Selection** | 720d? | 2011-03-23 A | 2013-12-06 A | 100% | 2011-03-23 | 2013-12-06 | 720d? |  | S2; C1 | 20256h | 20256h | OPIIS | 26 | LG Electronics | taehyeon.kim@lge.com | Rel-12 | 51 | Maurice |  |  | OPIIS |  |  |
| 1867 | 545.1 | TR on Stage 2 for Operator Policies for IP Interface Selection | 457d? | 2011-03-23 A | 2012-12-12 A | 100% | 2011-03-23 | 2012-12-12 | 457d? | finish no earlier than 2012-12-12 | S2 | 3640h | 3640h | OPIIS | 26 | LG Electronics | taehyeon.kim@lge.com | Rel-12 | 51 | Maurice |  |  |  |  |  |
| 1868 | 545.2 | Stage 2 for Operator Policies for IP Interface Selection | 511d? | 2011-04-04 A | 2013-03-06 A | 100% | 2011-04-04 | 2013-03-06 | 511d? | finish no earlier than 2013-03-06 | S2 | 4088h | 4088h | OPIIS | 26 | LG Electronics | taehyeon.kim@lge.com | Rel-12 | 51 | Maurice |  |  |  |  |  |
| 1869 | 545.3 | Stage 3 for Operator Policies for IP Interface Selection | 126d? | 2013-06-14 A | 2013-12-06 A | 100% | 2013-06-14 | 2013-12-06 | 126d? | finish no earlier than 2013-12-06 | C1 | 1008h | 1008h | OPIIS-CT | 31 | LG Electronics | Jaehyun Kim (jaehyun7.kim@lge.com) | Rel-12 | 60 | Frederic |  |  | OPIIS-CT |  |  |
| 1870 | 546 | **Short Message Service (SMS) submit and delivery without MSISDN in IMS** | 665d? | 2011-06-08 A | 2013-12-06 A | 100% | 2011-06-08 | 2013-12-06 | 665d? |  | S2; C1; C4 | 28336.3h | 28336.3h | SMSMI | 27 | Nokia Siemens Networks | curt.wong@nsn.com | Rel-12 | 52 | Maurice |  |  | SMSMI |  |  |
| 1871 | 546.1 | TR on Stage 2 for SMS submit and delivery without MSISDN in IMS | 402d? | 2011-06-08 A | 2012-12-12 A | 100% | 2011-06-08 | 2012-12-12 | 402d? | finish no earlier than 2012-12-12 | S2 | 3192.32h | 3192.32h | SMSMI-SA2TR | 27 | Nokia Siemens Networks | curt.wong@nsn.com | Rel-12 | 52 | Maurice |  |  |  |  |  |
| 1872 | 546.2 | Stage 2 for SMS submit and delivery without MSISDN in IMS | 400d? | 2011-06-13 A | 2012-12-12 A | 100% | 2011-06-13 | 2012-12-12 | 400d? | finish no earlier than 2012-12-12 | S2 | 3192h | 3192h | SMSMI-SA2 | 27 | Nokia Siemens Networks | curt.wong@nsn.com | Rel-12 | 52 | Maurice |  |  |  |  |  |

Notes:
- 1847: SP#60 stopped and Rel-13 FS_ACDC continues. Triggered by TR 22.806 Study on Application specific Congestion control for Data Communication (FS_ACDC) UID_570034 / Impacted TSs and TRs: Stage 1
- 1848: SP#60 stopped and Rel-13 FS_ACDC contd. Allow/prohibit for E-UTRAN idle mode UE initiation of particular applications defined by operator and subject to regional regulations. Prevent/mitigate overload of AN/CN defined by operator (congestion or disaster) / Impacted TSs and TRs: 22.011
- 1849: SP#59 Stage 1 completed / Impacted TSs and TRs: Stage 1
- 1850: SP#59 completed / Impacted TSs and TRs: 22.011
- 1851: -
- 1852: CP#63 completed. SP#58 updated WID SP-120256=>SP-120926 (stopped BB2 LIMONET-LIPA on Mobility). Linked to UID_450035 Local IP Access and Selected IP Traffic Offload (LIPA_SIPTO) / Impacted TSs and TRs: Stage 2/3
- 1853: SP#59 completed. TR 23.859 v100 for Information and Approval / Impacted TSs and TRs: new TR 23.859
- 1854: SP#60 completed / Impacted TSs and TRs: 23.060, 23.401
- 1855: SP#60 completed / Impacted TSs and TRs: 23.060, 23.401
- 1856: CP#63 completed / Impacted TSs and TRs: Stage 3
- 1857: CP#61 completed / Impacted TSs and TRs: 23.003, 23.008, 29.002, 29.060, 29.230, 29.272, 29.274, 29.303
- 1858: CP#63 completed / Impacted TSs and TRs: 24.008, 24.301
- 1859: - / Impacted TSs and TRs: UTRA, LTE
- 1860: RP#62 completed / Impacted TSs and TRs: 25.401, 25.413, 25.423, 25.467, 25.469, 36.300, 36.413, 36.423
- 1861: SP#58 updated WID SP-120256=>SP-120926 (stopped BB2 LIMONET-LIPA on Mobility) / Impacted TSs and TRs: 23.060, 23.401
- 1862: SP#58 updated WID SP-120256=>SP-120926 (stopped BB2 LIMONET-LIPA on Mobility) / Impacted TSs and TRs: 23.060, 23.401
- 1863: SP#58 CT Stage 3 part stopped because of SA stopping Stage 2 for BB2 LIMONET-LIPA on Mobility) / Impacted TSs and TRs: Stage 3
- 1864: SP#58 CT Stage 3 part stopped because of SA stopping Stage 2 for BB2 LIMONET-LIPA on Mobility) / Impacted TSs and TRs: 24.008, 24.301
- 1865: SP#58 CT Stage 3 part stopped because of SA stopping Stage 2 for BB2 LIMONET-LIPA on Mobility) / Impacted TSs and TRs: 29.060, 29.274, 29.281, 29.303, 29.002, 29.272, 29.275, 29.282, 29.305
- 1866: Linked to Rel-10 IFOM IP Flow Mobility and seamless WLAN offload (non-seamless WLAN offload aspects) & Rel-11 LIMONET (support traffic offload at local network) / Impacted TSs and TRs: Stage 2/3
- 1867: SP#58 completed / Impacted TSs and TRs: new TR 23.853
- 1868: SP#59 completed (23.402 CR#152: Introduction of Inter-APN Routing Policies) / Impacted TSs and TRs: 23.402
- 1869: CP#62 completed. Specify Inter-APN Routing Policies for selecting an IP interface to route IP flows among a choice of available interfacES in CP-150both 3GPP and non-3GPP accesses / Impacted TSs and TRs: 24.302, 24.312
- 1870: Linked to Rel-7 SMSIP (Support of SMS over generic 3GPP IP access), Rel-11 SIMTC, Rel-12 TR 22.988 SA1 Study on alternatives to E.164 for MTC / Impacted TSs and TRs: Stage 2/3
- 1871: SP#58 completed / Impacted TSs and TRs: new TR 23.863
- 1872: SP#58 completed / Impacted TSs and TRs: 23.204, 23.682

| ID | WBS | Task | Duration | Start | Finish | Complete | Remaining | Baseline start | Baseline finish | Baseline duration | Total slack | Constraint | Resources | Work | Actual work | Acronym | PCG approved | Impacted TSs and TRs | WI rapporteur name | WI rapporteur e-mail | Release | TSG approved | MCC resp | Acronym_3GU_Export | Status Report | Special Focus Doc |
| --- | --- | --- | --- | --- | --- | --- | --- | --- | --- | --- | --- | --- | --- | --- | --- | --- | --- | --- | --- | --- | --- | --- | --- | --- | --- | --- |
| 1873 | 546.3 | **Stage 3 for SMS submit and delivery without MSISDN in IMS** | 205d? | 2013-03-01 A | 2013-12-06 A | 100% |  | 2013-03-01 | 2013-12-06 | 205d? |  |  | C1; C4 | 5992h | 5992h | SMSMI-CT | 30 | Stage 3 | NSN | peter.leis@nsn.com | Rel-12 | 59 | Frederic | SMSMI-CT |  |  |
| 1874 | 546.3.1 | CT1 part of Stage 3 for SMS submit and delivery without MSISDN in IMS | 205d? | 2013-03-01 A | 2013-12-06 A | 100% |  | 2013-03-01 | 2013-12-06 | 205d? |  | finish no earlier than 2013-12-06 | C1 | 1608h | 1608h | SMSMI-CT | 30 | 23.040, 24.341 | NSN | peter.leis@nsn.com | Rel-12 | 59 | Frederic |  |  |  |
| 1875 | 546.3.2 | CT4 part of Stage 3 for SMS submit and delivery without MSISDN in IMS | 139d? | 2013-03-01 A | 2013-09-06 A | 100% |  | 2013-03-01 | 2013-09-06 | 139d? |  | finish no earlier than 2013-09-06 | C4 | 1104h | 1104h | SMSMI-CT | 30 | 23.008, 29.002, 29.305, 29.328, 29.338 | NSN | peter.leis@nsn.com | Rel-12 | 59 | Kimmo |  |  |  |
| 1876 | 547 | **IMS-based Telepresence** | 1247.5d? | 2010-03-22 A | 2014-12-09 | 66% | 430.02d? | 2010-03-19 | 2014-12-05 | 1243.5d? | 5480d |  | S1; C1; C3; C4; IETF | 122882h | 38645.9h | IMS_TELEP | 27 | Stage 1/2/3 | Orange | bruno.tossou@orange-ftgroup.com | Rel-12 | 53 | Alain | IMS_TELEP |  |  |
| 1877 | 547.1 | Stage 1 for IMS-based Telepresence | 197d? | 2011-09-22 A | 2012-06-20 A | 100% |  | 2011-09-22 | 2012-06-20 | 197d? |  | finish no earlier than 2012-06-08 | S1 | 1569.86h | 1569.86h | IMS_TELEP | 27 | 22.228 | Orange | bruno.tossou@orange-ftgroup.com | Rel-12 | 53 | Alain |  |  |  |
| 1878 | 547.2 | **CT part for IMS Telepresence (Stage 2/3)** | 1247.5d? | 2010-03-22 A | 2014-12-09 | 64% | 444.19d? | 2010-03-19 | 2014-12-05 | 1243.5d? | 5480d |  | C1; C3; C4; IETF | 87712h | 30772h | IMS_TELEP | 30 | Stage 2/3 | Huawei | Weiwei(Tommy) Yang (tommy@huawei.com) | Rel-12 | 58 | Frederic |  |  |  |
| 1879 | 547.2.1 | TR on CT part of IMS Telepresence (Stage 2/3) | 399d? | 2012-12-07 A | 2014-06-13 A | 100% |  | 2012-12-07 | 2014-06-13 | 399d? |  | finish no earlier than 2014-06-13 | C1 | 3184h | 3184h | IMS_TELEP | 30 | New TR 24.803 | Huawei | Weiwei(Tommy) Yang (tommy@huawei.com) | Rel-12 | 58 | Frederic |  |  |  |
| 1880 | 547.2.2 | CT1 part of IMS Telepresence (Stage 3) | 526d? | 2012-12-07 A | 2014-12-09 A | 100% |  | 2012-12-07 | 2014-09-12 | 464d? |  | finish no earlier than 2014-12-09 | C1 | 4208h | 4208h | IMS_TELEP | 30 | 24.147, 24.166, 24.229, New TS 24.103 | Huawei | Weiwei(Tommy) Yang (tommy@huawei.com) | Rel-12 | 58 | Frederic |  | CP-140616 |  |
| 1881 | 547.2.3 | (IETF) CT1 part of IMS Telepresence (mmusic-sctp-sdp) | 851d? | 2010-03-22 A | 2014-12-09 | 50% | 425.5d? | 2010-03-19 | 2014-12-05 | 849d? | 5480d | finish no earlier than 2014-12-09 | C1-IETF | 6808h | 3404h | IMS_TELEP | 33 | draft-ietf-mmusic-sctp-sdp | christer.holmberg@ericsson.com | christer.holmberg@ericsson.com | Rel-12 | 64 |  |  |  |  |
| 1882 | 547.2.4 | (IETF) CT1 part of IMS Telepresence (clue-framework ) | 851d? | 2010-03-22 A | 2014-12-09 | 50% | 425.5d? | 2010-03-19 | 2014-12-05 | 849d? | 5480d | finish no earlier than 2014-12-09 | C1-IETF | 6808h | 3404h | IMS_TELEP | 33 | draft-ietf-clue-framework | christer.holmberg@ericsson.com | christer.holmberg@ericsson.com | Rel-12 | 64 |  |  |  |  |
| 1883 | 547.2.5 | (IETF) CT1 part of IMS Telepresence (clue-datachannel) | 851d? | 2010-03-22 A | 2014-12-09 | 50% | 425.5d? | 2010-03-19 | 2014-12-05 | 849d? | 5480d | finish no earlier than 2014-12-09 | C1-IETF | 6808h | 3404h | IMS_TELEP | 33 | draft-ietf-clue-datachannel | christer.holmberg@ericsson.com | christer.holmberg@ericsson.com | Rel-12 | 64 |  |  |  |  |
| 1884 | 547.2.6 | (IETF) CT1 part of IMS Telepresence (clue-signaling) | 851d? | 2010-03-22 A | 2014-12-09 | 50% | 425.5d? | 2010-03-19 | 2014-12-05 | 849d? | 5480d | finish no earlier than 2014-12-09 | C1-IETF | 6808h | 3404h | IMS_TELEP | 33 | draft-ietf-clue-signaling | christer.holmberg@ericsson.com | christer.holmberg@ericsson.com | Rel-12 | 64 |  |  |  |  |
| 1885 | 547.2.7 | (IETF) CT1 part of IMS Telepresence (clue-data-model-schema) | 851d? | 2010-03-22 A | 2014-12-09 | 50% | 425.5d? | 2010-03-19 | 2014-12-05 | 849d? | 5480d | finish no earlier than 2014-12-09 | C1-IETF | 6808h | 3404h | IMS_TELEP | 33 | draft-ietf-clue-data-model-schema | christer.holmberg@ericsson.com | christer.holmberg@ericsson.com | Rel-12 | 64 |  |  |  |  |
| 1886 | 547.2.8 | CT3 part of IMS Telepresence (Stage 3) | 467d? | 2012-12-07 A | 2014-09-11 A | 100% |  | 2012-12-07 | 2014-09-12 | 467d? |  | finish no earlier than 2014-09-12 | C3 | 3736h | 3736h | IMS_TELEP | 30 | 29.165 | Huawei | Weiwei(Tommy) Yang (tommy@huawei.com) | Rel-12 | 58 | Adrian |  |  |  |
| 1887 | 547.2.9 | CT4 part of IMS Telepresence (Stage 2/3) | 328d? | 2013-09-13 A | 2014-12-09 A | 100% |  | 2013-09-10 | 2014-09-12 | 266d? |  | finish no earlier than 2014-12-09 | C4 | 2624h | 2624h | IMS_TELEP | 31 | 23.333, 29.333 | Huawei | Weiwei(Tommy) Yang (tommy@huawei.com) | Rel-12 | 61 | Kimmo |  | CP-140477 |  |
| 1888 | 548 | **Group Communication System Enablers for LTE** | 727d? | 2012-06-18 A | 2015-03-15 | 99% | 0d? | 2012-06-18 | 2014-09-17 | 597d? | 0d |  | S1; S2; S3; C3; C4; R3; C1 | 59744h | 58696h | GCSE_LTE | 29 | Stage 1/2/3 | Nokia Networks | Juergen.Merkel@nsn.com | Rel-12 | 56 | Alain | GCSE_LTE |  | Public Safety (A-A) |
| 1889 | 548.1 | Stage 1 for Group Communication System Enablers for LTE | 267d? | 2012-06-18 A | 2013-06-19 A | 100% |  | 2012-06-18 | 2013-06-19 | 267d? |  | finish no earlier than 2013-06-19 | S1 | 2128h | 2128h | GCSE_LTE | 29 | New TS 22.468 | Nokia Networks | Juergen.Merkel@nsn.com | Rel-12 | 56 | Alain |  |  | Public Safety (A-A) |
| 1890 | 548.2 | TR on Architecture enhancements to support Group Communication System Enablers for LTE | 267d? | 2013-03-07 A | 2014-03-07 A | 100% |  | 2013-03-07 | 2014-03-07 | 267d? |  | finish no earlier than 2014-03-07 | S2 | 2128h | 2128h | GCSE_LTE | 30 | New TR 23.768 | Nokia Networks | rainer.liebhart@nsn.com | Rel-12 | 59 | Maurice |  |  | Public Safety (A-A) |
| 1891 | 548.3 | Stage 2 for Group Communication System Enablers for LTE | 402d? | 2013-03-12 A | 2014-09-16 A | 100% |  | 2013-03-12 | 2014-09-17 | 402d? |  | finish no earlier than 2014-09-17 | S2 | 3208h | 3208h | GCSE_LTE | 30 | New TS 23.468 | Nokia Networks | rainer.liebhart@nsn.com | Rel-12 | 59 | Maurice |  |  | Public Safety (A-A) |
| 1892 | 548.4 | TR on Security for Group Communication System Enablers for LTE (Stage 2) | 201d? | 2013-09-12 A | 2014-06-18 A | 100% |  | 2013-09-12 | 2014-06-18 | 201d? |  | finish no earlier than 2014-06-18 | S3 | 1608h | 1608h | GCSE_LTE | 31 | New TR 33.888 | Nokia Networks | anja.jerichow@nsn.com | Rel-12 | 61 | Mirko |  |  | Public Safety (A-A) |
| 1893 | 548.5 | Security for Group Communication System Enablers for LTE (Stage 2) | 201d? | 2013-09-13 A | 2014-06-18 A | 100% |  | 2013-09-13 | 2014-06-18 | 201d? |  | finish no earlier than 2014-06-18 | S3 | 1608h | 1608h | GCSE_LTE | 31 | 33.246 | Nokia Networks | anja.jerichow@nsn.com | Rel-12 | 61 | Mirko |  |  | Public Safety (A-A) |
| 1894 | 548.6 | **CT aspects of Group Communication System Enablers for LTE** | 131d? | 2014-06-13 A | 2014-12-09 | 100% | 0d? | 2014-06-13 | 2014-09-12 | 66d? | 0d |  | C3; C4; C1 | 5200h | 4152h | GCSE_LTE-CT | 33 | Stage 3 | Nokia Networks | thomas.belling@nsn.com | Rel-12 | 64 |  | GCSE_LTE-CT |  | Public Safety (A-A) |
| 1895 | 548.6.1 | CT3 part of Group Communication System Enablers for LTE | 66d? | 2014-06-13 A | 2014-09-11 A | 100% |  | 2014-06-13 | 2014-09-12 | 66d? |  | finish no earlier than 2014-09-12 | C3 | 528h | 528h | GCSE_LTE-CT | 33 | 29.212, 29.213, 29.214, 29.274, New TS 29.468 | Nokia Networks | thomas.belling@nsn.com | Rel-12 | 64 |  |  |  | Public Safety (A-A) |
| 1896 | 548.6.2 | CT4 part of Group Communication System Enablers for LTE | 128d? | 2014-06-13 A | 2014-12-09 A | 100% |  | 2014-06-13 | 2014-09-12 | 66d? |  | finish no earlier than 2014-12-09 | C4 | 1024h | 1024h | GCSE_LTE-CT | 33 | 23.007, 23.008 | Nokia Networks | thomas.belling@nsn.com | Rel-12 | 64 |  |  | CP-140725 | Public Safety (A-A) |
| 1897 | 548.6.3 | CT1 part of Group Communication System Enablers for LTE | 63d? | 2014-09-12 A | 2014-12-09 A | 100% |  |  |  |  |  | finish no earlier than 2014-12-09 | C1 | 504h | 504h | GCSE_LTE-CT | 33 | 24.301 | Nokia Networks | thomas.belling@nsn.com | Rel-12 | 65 |  |  | CP-140614 | Public Safety (A-A) |

Notes:
- 1873: CP#62 completed. Address scenario IMS client to IMS client SMS (comprises SMS receive and send SMS without requiring an MSISDN associated as part of their subscription record in HSS
- 1874: CP#62 completed
- 1875: CP#61 completed
- 1876: This feature does not introduce any changes to the IMS architecture, and no stage 2 impacts are identified
- 1877: SP#56 completed. 2/4/15: acronym changed to IMS_TELEP
- 1878: CP#65 updated WID CP-140196=>CP-140624. 2/4/15: acronym changed to IMS_TELEP
- 1879: CP#64 completed. 2/4/15: acronym changed to IMS_TELEP
- 1880: CP#65 TS 24.103v100 for Information. Updated WID CP-140196=>CP-140624. Completion 09/14=>12/14. Exception in CP-140616. Dec.14: 90->100%. 2/4/15: acronym changed to IMS_TELEP
- 1881: work in progress. 2/4/15: acronym changed to IMS_TELEP
- 1882: work in progress. 2/4/15: acronym changed to IMS_TELEP
- 1883: work in progress. 2/4/15: acronym changed to IMS_TELEP
- 1884: work in progress. 2/4/15: acronym changed to IMS_TELEP
- 1885: work in progress. 2/4/15: acronym changed to IMS_TELEP
- 1886: CP#65 completed. 2/4/15: acronym changed to IMS_TELEP
- 1887: CP#65 updated WID CP-140196=>CP-140624. Completion 09/14=>12/14. Exception in CP-140477. Mar.15: 0->100%. 2/4/15: acronym changed to IMS_TELEP
- 1888: Linked to Rel-12 FS_ProSe TR 22.803 Study on Proximity-based Services. External requirements: NIST, MESA, APCO Global Alliance, TCCA. Specify 3GPP system enablers to support group communication over LTE for Public Safety
- 1889: SP#60 completed. TS 22.468 v100 for 1-step Approval
- 1890: SP#63 completed. TR 23.768v200 for Approval
- 1891: SP#65 completed. Updated WID SP-140113=>SP-140433. SP#63 TS 23.468v100 for 1-step Approval
- 1892: SP#64 completed. TR 33.888v100 for 1-step Approval
- 1893: SP#64 completed
- 1894: CP#65 updated WID CP-140452=>C3-143199 (added CT1 part)
- 1895: CP#65 completed. TS 29.468v200 for Approval
- 1896: CP#65 completion 09/14=>12/14. Exception in CP-140725. Dec.14: 35->100
- 1897: CP#65 updated WID CP-140452=>CP-140559 (added CT1 part). Exception in CP-140614. Dec.14: 90->100%

| ID | WBS | Task | Duration | Start | Finish | Complete | Remaining | Baseline start | Baseline finish | Baseline duration | Total slack | Constraint | Resources | Work | Actual work | Acronym | PCG approved | Impacted TSs and TRs | WI rapporteur name | WI rapporteur e-mail | Release | TSG approved | Special Focus Doc | Acronym_3GU_Export | Status Report | MCC resp | PCG stopped | TSG stopped |
| --- | --- | --- | --- | --- | --- | --- | --- | --- | --- | --- | --- | --- | --- | --- | --- | --- | --- | --- | --- | --- | --- | --- | --- | --- | --- | --- | --- | --- |
| 1898 | 548.7 | **Group Call eMBMS congestion management for LTE** | 198d? | 2014-06-16 A | 2015-03-15 A | 100% |  | 2014-06-13 | 2014-09-12 | 66d? |  |  | R3 | 3152h | 3152h | GCSE_LTE-MBMS_CM | 33 | LTE | Alcatel-Lucent | hakon.helmers@alcatel-lucent.com | Rel-12 | 64 | Public Safety (A-A) | GCSE_LTE-MBMS_CM |  |  |  |  |
| 1899 | 548.7.1 | Core part: Group Call eMBMS congestion management for LTE | 196d? | 2014-06-16 A | 2015-03-15 A | 100% |  | 2014-06-13 | 2014-09-12 | 66d? |  | finish no earlier than 2015-03-15 | R3 | 1568h | 1568h | GCSE_LTE-MBMS_CM-Core | 33 | 36.413 | Alcatel-Lucent | hakon.helmers@alcatel-lucent.com | Rel-12 | 64 | Public Safety (A-A) | GCSE_LTE-MBMS_CM-Core | RP-150081 |  |  |  |
| 1900 | 549 | **Machine-Type and other mobile data applications Communications enhancements** | 1692d? | 2009-12-10 A | 2016-05-12 | 98% | 40.3d? | 2009-12-10 | 2014-09-12 | 1255d? | 5108d |  |  | 58859h | 57908.6h | MTCe | 29 | Stage 1/2/3 | Intel | puneet.jain@intel.com | Rel-12 | 56 | MTC, M2M | MTCe |  | Maurice |  |  |
| 1901 | 549.1 | Stage 1 for Support for Interworking with M2M Service Enablement | 189d? | 2012-06-18 A | 2013-03-06 A | 100% |  | 2012-06-18 | 2013-03-06 | 189d? |  | finish no earlier than 2013-03-06 | S1 | 1504h | 1504h | MTCe-SIMSE | 29 | 22.368 | KPN | toon.norp@tno.nl | Rel-12 | 56 | MTC, M2M | MTCe-SIMSE |  | Alain |  |  |
| 1902 | 549.2 | Stage 1 for Machine-Type and other mobile data applications Communications – Service Requirement Maintenance | 127d? | 2012-09-13 A | 2013-03-06 A | 100% |  | 2012-09-13 | 2013-03-06 | 127d? |  | finish no earlier than 2013-03-06 | S1 | 1008h | 1008h | MTCe-SRM | 29 | 22.101, 22.368 | KPN | toon.norp@tno.nl | Rel-12 | 57 | MTC, M2M | MTCe-SRM |  | Alain |  |  |
| 1903 | 549.3 | TR on Security aspects of Machine-Type Communications | 1113d? | 2009-12-10 A | 2014-03-07 A | 100% |  | 2009-12-10 | 2014-03-07 | 1113d? |  | finish no earlier than 2014-03-07 | S3 | 8896h | 8896h | MTCe-SA3TR | 29 | New TR 33.868 | Samsung | Rajavelsamy R (rajvel@samsung.com) | Rel-12 | 56 | MTC, M2M |  |  | Mirko |  |  |
| 1904 | 549.4 | Security and Privacy aspects for Machine-Type and other mobile data applications Communications enhancements (Stage 2) | 452d? | 2012-06-22 A | 2014-03-07 A | 100% |  | 2012-06-22 | 2014-03-07 | 452d? |  | finish no earlier than 2014-03-07 | S3 | 3608h | 3608h | MTCe-SA3 | 29 | New TS 33.187 | Samsung | Rajavelsamy R (rajvel@samsung.com) | Rel-12 | 56 | MTC, M2M |  |  | Mirko |  |  |
| 1905 | 549.5 | **BB1: Small Data and Device Triggering Enhancements (SDDTE)** | 594d? | 2012-06-18 A | 2014-09-11 A | 100% |  | 2012-06-18 | 2014-09-12 | 594d? |  |  | S2; C4; C3 | 24400h | 24400h | MTCe-SDDTE | 29 |  | Intel | puneet.jain@intel.com | Rel-12 | 56 | MTC, M2M | MTCe-SDDTE |  | Maurice |  |  |
| 1906 | 549.5.1 | TR on Stage 2 BB1: Small Data and Device Triggering Enhancements | 394d? | 2012-06-18 A | 2013-12-11 A | 100% |  | 2012-06-18 | 2013-12-11 | 394d? |  | finish no earlier than 2013-12-11 | S2 | 3128h | 3128h | MTCe-SDDTE | 29 | New TR 23.887 | Intel | puneet.jain@intel.com | Rel-12 | 56 | MTC, M2M |  |  | Maurice |  |  |
| 1907 | 549.5.2 | Stage 2 for BB1: Small Data and Device Triggering Enhancements | 390d? | 2012-06-26 A | 2013-12-11 A | 100% |  | 2012-06-26 | 2013-12-11 | 390d? |  | finish no earlier than 2013-12-11 | S2 | 3120h | 3120h | MTCe-SDDTE | 29 | 23.682 | Intel | puneet.jain@intel.com | Rel-12 | 56 | MTC, M2M |  |  | Maurice |  |  |
| 1908 | 549.5.3 | **Stage 3 for BB1: Small Data and Device Triggering Enhancements** | 138d? | 2014-03-05 A | 2014-09-11 A | 100% |  | 2014-03-05 | 2014-09-12 | 138d? |  |  | C4; C3 | 3896h | 3896h | MTCe-SDDTE-CT | 32 | Stage 3 | Huawei | peter.schmitt@huawei.com | Rel-12 | 63 | MTC, M2M | MTCe-SDDTE-CT |  | Kimmo |  |  |
| 1909 | 549.5.3.1 | CT4 part of Stage 3 for BB1: Small Data and Device Triggering Enhancement | 138d? | 2014-03-05 A | 2014-09-11 A | 100% |  | 2014-03-05 | 2014-09-12 | 138d? |  | finish no earlier than 2014-09-12 | C4 | 1104h | 1104h | MTCe-SDDTE-CT | 32 | 29.002, 29.336, 23.008, 29.337, 29.338, 29.230 | Huawei | peter.schmitt@huawei.com | Rel-12 | 63 | MTC, M2M |  |  | Kimmo |  |  |
| 1910 | 549.5.3.2 | CT3 part of Stage 3 for BB1: Small Data and Device Triggering Enhancement | 73d? | 2014-03-05 A | 2014-06-13 A | 100% |  | 2014-03-05 | 2014-06-13 | 73d? |  | finish no earlier than 2014-06-13 | C3 | 584h | 584h | MTCe-SDDTE-CT | 32 | 29.368 | Huawei | peter.schmitt@huawei.com | Rel-12 | 63 | MTC, M2M |  |  | Adrian |  |  |
| 1911 | 549.6 | Deleted - BB2: Monitoring Enhancements (MONTE) | 131d? | 2012-06-18 A | 2012-12-12 A | 100% |  | 2012-06-18 | 2012-12-12 | 131d? |  | finish no earlier than 2012-12-12 | S2 | 1048h | 1048h | MTCe-MONTE | 29 | 23.682 | Intel | puneet.jain@intel.com | Rel-12 | 56 | MTC, M2M | MTCe-MONTE |  | Maurice | PCG-30 | SP-58 |
| 1912 | 549.7 | **BB3: UE Power Consumptions Optimizations (UEPCOP)** | 1031d? | 2012-06-18 A | 2016-05-12 | 93% | 71.29d? | 2012-06-18 | 2014-09-12 | 594d? | 5108d |  |  | 13712h | 12761.6h | MTCe-UEPCOP | 29 |  | Ericsson | peter.hedman@ericsson.com | Rel-12 | 56 | MTC, M2M | MTCe-UEPCOP |  | Maurice |  |  |
| 1913 | 549.7.1 | TR on Stage 2 BB3: UE Power Consumptions Optimizations (UEPCOP) | 394d? | 2012-06-18 A | 2013-12-11 A | 100% |  | 2012-06-18 | 2013-12-11 | 394d? |  | finish no earlier than 2013-12-11 | S2 | 3128h | 3128h | MTCe-UEPCOP | 29 | New TR 23.887 | Ericsson | peter.hedman@ericsson.com | Rel-12 | 56 | MTC, M2M |  |  | Maurice |  |  |
| 1914 | 549.7.2 | Stage 2 for BB3: UE Power Consumptions Optimizations (UEPCOP) | 390d? | 2012-06-26 A | 2013-12-11 A | 100% |  | 2012-06-26 | 2013-12-11 | 390d? |  | finish no earlier than 2013-12-11 | S2 | 3120h | 3120h | MTCe-UEPCOP | 29 | 23.060, 23.401, 23.682 | Ericsson | peter.hedman@ericsson.com | Rel-12 | 56 | MTC, M2M |  |  | Maurice |  |  |
| 1915 | 549.7.3 | **Stage 3 for BB3: UE Power Consumptions Optimizations (UEPCOP)** | 597d? | 2013-12-06 A | 2016-03-15 A | 100% |  | 2013-12-06 | 2014-09-12 | 202d? |  |  |  | 6368h | 6368h | MTCe-UEPCOP-CT | 32 | Stage 3 | Ericsson | mikael.wass@ericsson.com | Rel-12 | 62 | MTC, M2M | MTCe-UEPCOP-CT |  | Frederic |  |  |
| 1916 | 549.7.3.1 | CT1 part of Stage 3 for BB3: UE Power Consumptions Optimizations (UEPCOP) | 202d? | 2013-12-06 A | 2014-09-11 A | 100% |  | 2013-12-06 | 2014-09-12 | 202d? |  | finish no earlier than 2014-09-12 | C1 | 1608h | 1608h | MTCe-UEPCOP-CT1 | 32 | 24.008, 24.301 | Ericsson | mikael.wass@ericsson.com | Rel-12 | 62 | MTC, M2M |  |  | Frederic |  |  |
| 1917 | 549.7.3.2 | Deleted - CT4 part of Stage 3 for BB3: UE Power Consumptions Optimizations (UEPCOP) | 201d? | 2013-12-09 A | 2014-09-11 A | 100% |  | 2013-12-09 | 2014-09-12 | 201d? |  | finish no earlier than 2014-09-12 | C4 | 1608h | 1608h | MTCe-UEPCOP-CT4 | 32 | 29.274, 29.060, 23.008 | Ericsson | mikael.wass@ericsson.com | Rel-12 | 62 | MTC, M2M |  |  | Kimmo | PCG-33 | CP-65 |
| 1918 | 549.7.3.3 | CT6 part of Stage 3 for BB3: UE Power Consumptions Optimizations (UEPCOP) | 263d? | 2013-12-09 A | 2014-12-09 A | 100% |  | 2013-12-09 | 2014-09-12 | 201d? |  | finish no earlier than 2014-12-09 | C6 | 2104h | 2104h | MTCe-UEPCOP-CT6 | 32 | 31.101, 31.102, 31.111 | Ericsson | mikael.wass@ericsson.com | Rel-12 | 62 | MTC, M2M |  | CP-140697 | Xavier |  |  |
| 1919 | 549.7.3.4 | UE Conformance Test Aspects - UE Power Consumptions Optimizations (UEPCOP) | 131d? | 2015-09-15 A | 2016-03-15 A | 100% |  |  |  |  |  | finish no earlier than 2016-03-15 | R5 | 1048h | 1048h | MTCe-UEPCOP-UEConTest | 35 |  | Ericsson |  | Rel-12 | 69 |  |  |  |  |  |  |
| 1920 | 549.7.4 | Support of Power Saving Mode in GERAN | 5d? | 2014-08-25 A | 2014-08-29 A | 100% |  |  |  |  |  | finish no earlier than 2014-08-29 | G1 | 40h | 40h | MTCe-UEPCOP-GERAN | 33 | 43.022 | Ericsson | sajal.kumar.das@ericsson.com | Rel-12 | 63 |  | MTCe-UEPCOP-GERAN |  |  |  |  |
| 1921 | 549.7.5 | Testing of Support of Power Saving Mode in GERAN | 132d? | 2015-11-11 A | 2016-05-12 | 10% | 118.8d? |  |  |  | 5108d | finish no earlier than 2016-05-12 | G3 | 1056h | 105.6h | MTCe-UEPCOP_GERAN3new | 36 |  | Ericsson | sajal.kumar.das@ericsson.com | Rel-12 | 70 |  | MTCe-UEPCOP-GERAN |  |  |  |  |
| 1922 | 549.8 | Deleted - BB4: Group based MTC feature (GROUP) | 129d? | 2012-06-20 A | 2012-12-12 A | 100% |  | 2012-06-20 | 2012-12-12 | 129d? |  | finish no earlier than 2012-12-12 | S2 | 1032h | 1032h | MTCe-GROUP | 29 | 23.682 | KPN | Annemieke Kips | Rel-12 | 56 | MTC, M2M | MTCe-GROUP |  | Maurice | PCG-30 | SP-58 |

Notes:
- 1898: -
- 1899: CD:Thu 11/12/14->Sun 15/03/15; Compl:25%->80%; Stat Rep: RP-141327->RP-141863 1st Apr 15: Compl:80%->100% 1st Apr 15: Stat Rep: RP-141863->RP-150081
- 1900: -
- 1901: SP#59 completed. Define requirements for interworking with M2M service enablement layer specified by ETSI TC M2M in TS 102 689 ( specification for Service Enablement layer)
- 1902: SP#59 completed. Updated WID SP-120541=>SP-130105
- 1903: SP#63 completed. TR 33.868v100 for 1-step Approval. Was Rel-10 UID_460023 (Security for NIMTC). Was Rel-11 UID_490028 (TR on Security aspects of MTC). SP#56 activity transferred to Rel-12 Feature MTCe
- 1904: SP#63 completed. TS 33.187v100 for 1-step Approval
- 1905: -
- 1906: SP#62 completed. TR 23.887v200 for Approval
- 1907: SP#62 completed
- 1908: CP#65 updated WID CP-140272=>CP-140489
- 1909: CP#65 completed. Updated WID CP-140272=>CP-140489
- 1910: CP#64 completed
- 1911: SP#58 stopped (at 20% completion)
- 1912: -
- 1913: SP#62 completed. TR 23.887v200 for Approval
- 1914: SP#62 completed
- 1915: -
- 1916: CP#65 completed
- 1917: CP#65 stopped (no inpact on CT4)
- 1918: CP#65 completion 09/14=>12/14. Exception in CP-140697; June2015: Compl:90%->100
- 1919: tested: MTCe-UEPCOP was a REL-12 SA2 WI; NAS over LTE and UTRA;1/1/16: Compl:0%->25%22/3/16: C
- 1920: GP#63 approved WID and completed
- 1921: 7/12/15: created.02/3/16: acronym: MTCe-UEPCOP-GERAN_test->MTCe-UEPCOP_GERAN3new; 2/3/16: 0%->10
- 1922: SP#58 stopped (at 25% completion)

| ID | WBS | Task | Duration | Start | Finish | Complete | Baseline start | Baseline finish | Baseline duration | Constraint | Resources | Work | Actual work | Acronym | PCG approved | WI rapporteur name | WI rapporteur e-mail | Release | TSG approved | MCC resp | Special Focus Doc | Acronym_3GU_Export | Status Report | PCG stopped | TSG stopped |
| --- | --- | --- | --- | --- | --- | --- | --- | --- | --- | --- | --- | --- | --- | --- | --- | --- | --- | --- | --- | --- | --- | --- | --- | --- | --- |
| 1923 | 549.9 | **RAN enhancements for Machine-Type and other mobile data applications Communications** | 161.2d? | 2014-02-03 A | 2014-09-12 A | 100% | 2014-02-03 | 2014-09-12 | 160.2d? |  | R2; R3 | 3651h | 3651h | MTCe-RAN | 32 | ZTE | sergio.parolari@zte.com.cn | Rel-12 | 62 | Yong-Jun | MTC, M2M | MTCe-RAN |  |  |  |
| 1924 | 549.9.1 | Core part: RAN enhancements for Machine-Type and other mobile data applications Communications | 133d? | 2014-02-03 A | 2014-09-12 A | 100% | 2014-02-03 | 2014-09-12 | 133d? | finish no earlier than 2014-09-12 | R2; R3 | 2128h | 2128h | MTCe-RAN-Core | 32 | ZTE | sergio.parolari@zte.com.cn | Rel-12 | 62 | Yong-Jun | MTC, M2M | MTCe-RAN-Core | RP-141096 |  |  |
| 1925 | 550 | **Low cost & enhanced coverage MTC UE for LTE** | 922d? | 2013-06-15 A | 2016-12-15 A | 100% | 2013-06-20 | 2015-03-13 | 456d? |  | R1; R2; R4 | 34104h | 34104h | LC_MTC_LTE | 31 | Vodafone | eric.bouton@vodafone.com | Rel-12 | 60 | Patrick | MTC, M2M | LC_MTC_LTE |  |  |  |
| 1926 | 550.1 | Core part: Low cost & enhanced coverage MTC UE for LTE | 174.67d? | 2013-06-15 A | 2014-12-15 A | 100% | 2013-10-15 | 2014-09-12 | 108.67d? | finish no earlier than 2014-12-15 | R1; R2; R4 | 4192h | 4192h | LC_MTC_LTE-Core | 31 | Vodafone | eric.bouton@vodafone.com | Rel-12 | 60 | Patrick | MTC, M2M | LC_MTC_LTE-Core | RP-142024 |  |  |
| 1927 | 550.2 | Perf. part: Low cost & enhanced coverage MTC UE for LTE | 522d? | 2013-06-15 A | 2015-06-15 A | 100% | 2013-06-20 | 2015-03-13 | 456d? | finish no earlier than 2015-06-15 | R4 | 4176h | 4176h | LC_MTC_LTE-Perf | 31 | Vodafone | eric.bouton@vodafone.com | Rel-12 | 60 | Issam | MTC, M2M | LC_MTC_LTE-Perf | RP-150915 |  |  |
| 1928 | 550.3 | UE Conformance Test Aspects - Low cost & enhanced coverage MTC UE for LTE | 460d? | 2015-03-16 A | 2016-12-15 A | 100% |  |  |  | finish no earlier than 2016-12-15 | R5 | 3680h | 3680h | LC_MTC_LTE-UEConTest | 34 | Ericsson |  | Rel-12 | 67 |  |  |  |  |  |  |
| 1929 | 551 | **Policy and Charging Control for supporting fixed broadband access networks** | 660d? | 2012-06-20 A | 2014-12-12 A | 100% | 2012-06-20 | 2014-09-17 | 595d? |  | S2; S1; S5; C3; C1; C4 | 84075.4h | 84075.4h | P4C | 29 | Huawei | marco.spini@huawei.com | Rel-12 | 56 | Maurice |  | P4C |  |  |  |
| 1930 | 551.1 | Stage 1 for Policy and Charging Support for Fixed Mobile Convergence | 3d? | 2012-09-10 A | 2012-09-12 A | 100% | 2012-09-10 | 2012-09-12 | 3d? | finish no earlier than 2012-09-12 | S1 | 24h | 24h | P4C-FMC | 29 | Huawei | amar.deol@huawei.com | Rel-12 | 57 | Alain |  | P4C-FMC |  |  |  |
| 1931 | 551.2 | **BB1: Policy and Charging Control for supporting traffic from fixed terminals and NSWO (Non Seamless WLAN Offload) traffic from 3GPP UEs in fixed broadband access networks (P4C-F)** | 660d? | 2012-06-20 A | 2014-12-12 A | 100% | 2012-06-20 | 2014-09-17 | 595d? |  | S2; S5; C3; C1; C4 | 45657.3h | 45657.3h | P4C-F | 29 | Huawei | marco.spini@huawei.com | Rel-12 | 56 | Maurice | WLAN | P4C-F |  |  |  |
| 1932 | 551.2.1 | TR on Stage 2 for BB1: Policy and Charging Control for supporting traffic from fixed terminals and NSWO traffic from 3GPP UEs in fixed broadband access networks (P4C-F) | 539.9d? | 2012-06-20 A | 2014-12-12 A | 100% | 2012-06-20 | 2014-09-17 | 476.9d? | finish no earlier than 2014-12-12 | S2 | 4290.1h | 4290.1h | P4C-F-SA2TR | 29 | Huawei | marco.spini@huawei.com | Rel-12 | 56 | Maurice | WLAN |  |  |  |  |
| 1933 | 551.2.2 | Stage 2 for BB1: Policy and Charging Control for supporting traffic from fixed terminals and NSWO traffic from 3GPP UEs in fixed broadband access networks (P4C-F) | 272.9d? | 2012-06-20 A | 2013-12-11 A | 100% | 2012-06-20 | 2013-12-11 | 272.9d? | finish no earlier than 2013-12-11 | S2 | 2183.2h | 2183.2h | P4C-F-SA2 | 29 | Huawei | marco.spini@huawei.com | Rel-12 | 56 | Maurice | WLAN |  |  |  |  |
| 1934 | 551.2.3 | **Stage 3 for BB1: Policy and Charging Control for supporting traffic from fixed terminals and NSWO traffic from 3GPP UEs in fixed broadband access networks** | 203d? | 2013-09-06 A | 2014-06-13 A | 100% | 2013-09-06 | 2014-06-13 | 203d? |  | C3; C1; C4 | 8088h | 8088h | P4C-F-CT3 | 31 | Huawei | Xia Haitao (xiahaitao@huawei.com) | Rel-12 | 61 | Adrian | WLAN | P4C-F-CT3 |  |  |  |
| 1935 | 551.2.3.1 | CT3 part of Stage 3 for BB1: Policy and Charging Control for supporting traffic from fixed terminals and NSWO traffic from 3GPP UEs in fixed broadband access networks | 203d? | 2013-09-06 A | 2014-06-13 A | 100% | 2013-09-06 | 2014-06-13 | 203d? | finish no earlier than 2014-06-13 | C3 | 1608h | 1608h | P4C-F-CT3 | 31 | Huawei | Xia Haitao (xiahaitao@huawei.com) | Rel-12 | 61 | Adrian | WLAN |  |  |  |  |
| 1936 | 551.2.3.2 | CT1 part of Stage 3 for BB1: Policy and Charging Control for supporting traffic from fixed terminals and NSWO traffic from 3GPP UEs in fixed broadband access networks | 65d? | 2013-12-06 A | 2014-03-05 A | 100% | 2013-12-06 | 2014-03-05 | 65d? | finish no earlier than 2014-03-05 | C1 | 512h | 512h | P4C-F-CT3 | 32 | Huawei | Xia Haitao (xiahaitao@huawei.com) | Rel-12 | 62 | Frederic | WLAN |  |  |  |  |
| 1937 | 551.2.3.3 | CT4 part of Stage 3 for BB1: Policy and Charging Control for supporting traffic from fixed terminals and NSWO traffic from 3GPP UEs in fixed broadband access networks | 137d? | 2013-12-06 A | 2014-06-13 A | 100% | 2013-12-06 | 2014-06-13 | 137d? | finish no earlier than 2014-06-13 | C4 | 1096h | 1096h | P4C-F-CT3 | 32 | Huawei | Xia Haitao (xiahaitao@huawei.com) | Rel-12 | 62 | Kimmo | WLAN |  |  |  |  |
| 1938 | 551.2.4 | Policy and Charging Enforcement Function (PCEF) based Charging for traffic from fixed terminals and NSWO traffic from 3GPP UEs in fixed broadband access networks (Stage 2/3) | 326d? | 2013-06-21 A | 2014-09-17 A | 100% | 2013-06-21 | 2014-09-17 | 326d? | finish no earlier than 2014-09-17 | S5 | 2608h | 2608h | P4C-F-CH_P | 31 | Alcatel-Lucent | maryse.gardella@alcatel-lucent.com | Rel-12 | 60 | Mirko | WLAN | P4C-F-CH_P |  |  |  |
| 1939 | 551.2.5 | Traffic Detection Function (TDF) based Charging for traffic from fixed terminals and NSWO traffic from 3GPP UEs in fixed broadband access networks (Stage 2/3) | 261d? | 2013-06-24 A | 2014-06-18 A | 100% | 2013-06-24 | 2014-06-18 | 261d? | finish no earlier than 2014-06-18 | S5 | 2088h | 2088h | P4C-F-CH_T | 31 | Openet Telecom | alan.mcnamee@openet.com | Rel-12 | 60 | Mirko | WLAN | P4C-F-CH_T |  |  |  |
| 1940 | 551.3 | **BB2: Policy and Charging Control for 3GPP UEs connected to BroadBand Forum access network as Trusted network in Interworking scenario (P4C-TI)** | 266d? | 2012-06-20 A | 2013-06-19 A | 100% | 2012-06-20 | 2013-06-19 | 266d? |  | S2 | 2610.07h | 2610.07h | P4C-TI | 29 | Alcatel-Lucent | konstantin.livanos@alcatel-lucent.com | Rel-12 | 56 | Maurice |  | P4C-TI |  |  |  |
| 1941 | 551.3.1 | TR on Stage 2 for BB2: Policy and Charging Control for 3GPP UEs connected to BroadBand Forum access network as Trusted network in Interworking scenario (P4C-TI) | 109.2d? | 2012-06-20 A | 2013-06-19 A | 100% | 2012-06-20 | 2013-06-19 | 109.2d? | finish no earlier than 2013-06-06 | S2 | 862.87h | 862.87h | P4C-TI-SA2TR | 29 | Alcatel-Lucent | konstantin.livanos@alcatel-lucent.com | Rel-12 | 56 | Maurice |  |  |  |  |  |
| 1942 | 551.3.2 | Stage 2 for BB2: Policy and Charging Control for 3GPP UEs connected to BroadBand Forum access network as Trusted network in Interworking scenario (P4C-TI) | 109.2d? | 2012-06-20 A | 2013-06-19 A | 100% | 2012-06-20 | 2013-06-19 | 109.2d? | finish no earlier than 2013-06-19 | S2 | 873.6h | 873.6h | P4C-TI-SA2 | 29 | Alcatel-Lucent | konstantin.livanos@alcatel-lucent.com | Rel-12 | 56 | Maurice |  |  |  |  |  |
| 1943 | 551.4 | Deleted - BB3: Policy and Charging Control for 3GPP UEs connected to fixed broadband access network via S2b and S2c reference points for EPC routed traffic (P4C-S2bc) | 128d? | 2012-06-21 A | 2012-12-12 A | 100% | 2012-06-21 | 2012-12-12 | 128d? | finish no earlier than 2012-12-12 | S2 | 1024h | 1024h | P4C-S2bc | 29 | ZTE | Tricci So (tso@zteusa.com) | Rel-12 | 56 | Maurice |  | P4C-S2bc |  | PCG-30 | SP-58 |
| 1944 | 551.5 | Deleted - BB4: Policy and Charging Control for EPC routed traffic over fixed broadband access networks of 3GPP UEs connected via H(e)NB in convergent scenarios (P4C-HeNB) | 128d? | 2012-06-21 A | 2012-12-12 A | 100% | 2012-06-21 | 2012-12-12 | 128d? | finish no earlier than 2012-12-12 | S2 | 1024h | 1024h | P4C-HeNB | 29 | NEC | Stefan.Schmid@neclab.eu | Rel-12 | 56 | Maurice |  | P4C-HeNB |  | PCG-30 | SP-58 |
| 1945 | 551.6 | Deleted - BB5: Policy and Charging Control for supporting Layer 2 traffic in fixed broadband access network (P4C-FL2) | 128d? | 2012-06-21 A | 2012-12-12 A | 100% | 2012-06-21 | 2012-12-12 | 128d? | finish no earlier than 2012-12-12 | S2 | 1024h | 1024h | P4C-FL2 | 29 | Huawei | marco.spini@huawei.com | Rel-12 | 56 | Maurice |  | P4C-FL2 |  | PCG-30 | SP-58 |
| 1946 | 551.7 | Deleted - BB6: Policy and Charging Control for 3GPP UEs connected to fixed broadband access networks via S2a reference point for EPC routed traffic in convergence (P4C-TC) | 129d? | 2012-06-20 A | 2012-12-12 A | 100% | 2012-06-20 | 2012-12-12 | 129d? | finish no earlier than 2012-12-12 | S2 | 1032h | 1032h | P4C-TC | 29 | ZTE | Tricci So (tso@zteusa.com) | Rel-12 | 56 | Maurice |  | P4C-TC |  | PCG-30 | SP-58 |

Notes:
- 1923: Triggered by TR 23.887 Machine Type and other mobile data applications Communications Enhancements (MTCe), TR 37.869 Study on Enhancements MTC and other Mobile Data Applications; RAN aspects (FS_MTCe_RAN), Rel-11 TR 23.888 SIMTC / Impacted TSs and TRs: UTRA, LTE
- 1924: RP#65 completed / Impacted TSs and TRs: 25.300, 25.304, 25.413, 36.300, 36.304, 36.413, 36.423
- 1925: Triggered by Rel-11 TR 36.888 (FS_LC_MTC_UE) / Impacted TSs and TRs: LTE
- 1926: ; CD:Thu 18/06/15->Mon 15/06/15; WID: RP-130848->RP-140522; Stat Rep: RP-141221->RP-142024 / Impacted TSs and TRs: 36.101, 36.104, 36.133, 36.201, 36.211, 36.212, 36.213, 36.300, 36.302, 36.306, 36.321, 36.331
- 1927: ; CD:Thu 18/06/15->Mon 15/06/15; WID: RP-130848->RP-140522; Stat Rep: RP-141221->RP-142024 1st Apr 15: Compl:65%->90% 1st Apr 15: CD:Sun 15/03/15->Mon 15/06/15 1st Apr 15: Stat Rep: RP-142024->RP-150149 03/07/15: Compl:90%->100% 03/07/15: WID: RP-14052 / Impacted TSs and TRs: 36.101, 36.104, 36.133
- 1928: 03/07/15: Compl:0%->13% 03/07/15: WID: RP-150135->RP-150838 03/07/15: Stat Rep: ->RP-150833 29/09/15: Compl:13%->25% 29/09/15: Stat Rep: RP-150833->RP-151165 ; 1/1/16: Compl:25%->70% ; 1/1/16: CD:Tue 15/12/15->Tue 15/03/16
- 1929: Linked to BBF, IETF work. SP#58 stopped BB3 to BB6. Split BB1 and BB2 into TR and Stage 2 work / Impacted TSs and TRs: Stage 1/2/3
- 1930: SP#57 completed / Impacted TSs and TRs: 22.278
- 1931: -
- 1932: SP#64 TR 23.896 was never sent for approval due to incomplete P4C BBs. SP#61 TR 23.896v100 for Information. Dec.14: 90->100%. Mar15: 23.896 for approval. / Impacted TSs and TRs: new TR 23.896
- 1933: SP#62 completed / Impacted TSs and TRs: 23.139, 23.203
- 1934: - / Impacted TSs and TRs: Stage 3
- 1935: CP#64 completed / Impacted TSs and TRs: 29.212, 29.213, 29.215, 29.219
- 1936: CP#63 completed / Impacted TSs and TRs: 24.302
- 1937: CP#64 completed / Impacted TSs and TRs: 29.273
- 1938: SP#65 completed. Introduce Charging Characteristics in Convergent scenario, Include missing fixed user location information for NSWO / Impacted TSs and TRs: Stage 2 (32.240, 32.251), Stage 3 (32.298, 32.299)
- 1939: SP#64 completed / Impacted TSs and TRs: Stage 2 (32.240, 32.251), Stage 3 (32.298, 32.299)
- 1940: -
- 1941: SP#60 completed / Impacted TSs and TRs: new TR 23.839
- 1942: SP#60 completed / Impacted TSs and TRs: 23.139, 23.203
- 1943: SP#58 stopped (at 0% completion) / Impacted TSs and TRs: 23.139, 23.203, new TR 23.896
- 1944: SP#58 stopped (at 0% completion) / Impacted TSs and TRs: 23.139, 23.203, new TR 23.896
- 1945: SP#58 stopped (at 0% completion) / Impacted TSs and TRs: 23.139, 23.203, new TR 23.896
- 1946: SP#58 stopped (at 30% completion) / Impacted TSs and TRs: 23.139, 23.203, new TR 23.896

| ID | WBS | Task | Duration | Start | Finish | Complete | Baseline start | Baseline finish | Baseline duration | Constraint | Resources | Work | Actual work | Acronym | PCG approved | Impacted TSs and TRs | WI rapporteur name | WI rapporteur e-mail | Release | TSG approved | MCC resp | Acronym_3GU_Export | Status Report | Special Focus Doc | PCG stopped | TSG stopped |
| --- | --- | --- | --- | --- | --- | --- | --- | --- | --- | --- | --- | --- | --- | --- | --- | --- | --- | --- | --- | --- | --- | --- | --- | --- | --- | --- |
| 1947 | 552 | **IMS Business Trunking for IP-PBX in Static Mode of Operation** | 847.1d? | 2011-09-28 A | 2014-12-09 A | 100% | 2011-09-28 | 2014-09-12 | 782.1d? |  | S2; S1; C1; C3 | 43555.2h | 43555.2h | BusTI | 29 | Stage 1/2/3 | Deutsche Telekom | michele.zarri@telekom.com | Rel-12 | 56 | Maurice | BusTI |  |  |  |  |
| 1948 | 552.1 | Stage 1 for IMS Business Trunking for IP-PBX in Static Mode of Operation | 64d? | 2011-09-28 A | 2012-09-12 A | 100% | 2011-09-28 | 2012-09-12 | 64d? | finish no earlier than 2012-08-30 | S1 | 504h | 504h | BusTI-SA1 | 29 | 22.228 | Deutsche Telekom | kurt.bischinger@t-mobile.at | Rel-12 | 56 | Alain |  |  |  |  |  |
| 1949 | 552.2 | TR on IMS Business Trunking for IP-PBX in Static Mode of Operation | 268d? | 2012-06-18 A | 2013-06-19 A | 100% | 2012-06-18 | 2013-06-19 | 268d? | finish no earlier than 2013-06-19 | S2; S1 | 4288h | 4288h | BusTI-SATR | 29 | new TR 23.897 | Deutsche Telekom | michele.zarri@telekom.com | Rel-12 | 56 | Maurice |  |  |  |  |  |
| 1950 | 552.3 | Stage 2 for IMS Business Trunking for IP-PBX in Static Mode of Operation | 263d? | 2012-06-25 A | 2013-06-19 A | 100% | 2012-06-25 | 2013-06-19 | 263d? | finish no earlier than 2013-06-19 | S2 | 2104h | 2104h | BusTI-SA2 | 29 | 23.228 | Deutsche Telekom | michele.zarri@telekom.com | Rel-12 | 56 | Maurice |  |  |  |  |  |
| 1951 | 552.4 | **CT aspects of IMS Business Trunking for IP-PBX in Static Mode of Operation (Stage 3)** | 333d? | 2013-09-06 A | 2014-12-09 A | 100% | 2013-09-06 | 2014-09-12 | 268d? |  | C1; C3 | 9552h | 9552h | BusTI-CT | 31 | Stage 3 | Deutsche Telekom | michael.kreipl@telekom.de | Rel-12 | 61 | Frederic | BusTI-CT |  |  |  |  |
| 1952 | 552.4.1 | CT1 part of CT aspects of IMS Business Trunking for IP-PBX in Static Mode of Operation (Stage 3) | 329d? | 2013-09-06 A | 2014-12-09 A | 100% | 2013-09-06 | 2014-09-12 | 267d? | finish no earlier than 2014-12-09 | C1 | 2632h | 2632h | BusTI-CT | 31 | 23.218, 24.229, 24.525 (transfer of ETSI TS 182 025) | Deutsche Telekom | michael.kreipl@telekom.de | Rel-12 | 61 | Frederic |  | CP-140607 |  |  |  |
| 1953 | 552.4.2 | CT3 part of CT aspects of IMS Business Trunking for IP-PBX in Static Mode of Operation (Stage 3) | 201d? | 2013-09-06 A | 2014-06-11 A | 100% | 2013-09-06 | 2014-06-13 | 201d? | finish no earlier than 2014-06-13 | C3 | 1608h | 1608h | BusTI-CT | 31 | 29.165 | Deutsche Telekom | michael.kreipl@telekom.de | Rel-12 | 61 | Adrian |  |  |  |  |  |
| 1954 | 553 | **WLAN Network Selection for 3GPP Terminals** | 659d? | 2012-06-18 A | 2014-12-09 A | 100% | 2012-06-18 | 2014-09-12 | 594d? |  | S2; S1; S3; C1 | 35272h | 35272h | WLAN_NS | 29 | Stage 1/2/3 | Intel | vivek.g.gupta@intel.com | Rel-12 | 56 | Maurice | WLAN_NS |  | WLAN |  |  |
| 1955 | 553.1 | TR on Stage 2 for WLAN Network Selection for 3GPP Terminals | 396d? | 2012-06-18 A | 2013-12-11 A | 100% | 2012-06-18 | 2013-12-11 | 396d? | finish no earlier than 2013-12-11 | S2; S1 | 6336h | 6336h | WLAN_NS-SATR | 29 | New TR 23.865 | Intel | vivek.g.gupta@intel.com | Rel-12 | 56 | Maurice |  |  | WLAN |  |  |
| 1956 | 553.2 | Stage 2 for WLAN Network Selection for 3GPP Terminals | 392d? | 2012-06-22 A | 2013-12-11 A | 100% | 2012-06-22 | 2013-12-11 | 392d? | finish no earlier than 2013-12-11 | S2 | 3136h | 3136h | WLAN_NS-SA2 | 29 | 23.402, 23.865 | Intel | vivek.g.gupta@intel.com | Rel-12 | 56 | Maurice |  |  | WLAN |  |  |
| 1957 | 553.3 | Deleted - TR on Security Aspects of WLAN Network Selection for 3GPP Terminals | 326d? | 2012-12-13 A | 2014-03-07 A | 100% | 2012-12-13 | 2014-03-07 | 326d? | finish no earlier than 2014-03-07 | S3 | 2608h | 2608h | WLAN_Nsdel | 30 | New TR 33.865 | Huawei | Lydia Xu (xuyixian@huawei.com) | Rel-12 | 58 | Mirko |  |  | WLAN | PCG-32 | CP-63 |
| 1958 | 553.4 | CT aspects of WLAN Network Selection for 3GPP Terminals (Stage 3) | 263d? | 2013-12-06 A | 2014-12-09 A | 100% | 2013-12-06 | 2014-09-12 | 201d? | finish no earlier than 2014-12-09 | C1 | 2104h | 2104h | WLAN_NS-CT | 32 | 24.302, 24.312 | Qualcomm | Amer Catovic, amerc@qualcomm.com | Rel-12 | 62 | Frederic | WLAN_NS-CT | CP-140622 | WLAN |  |  |
| 1959 | 554 | **Deleted - IMS Registration Control** | 496d? | 2012-01-31 A | 2013-12-11 A | 100% | 2012-01-31 | 2013-12-11 | 496d? |  | S1; S2; C1; C4 | 23400h | 23400h | IMS_RegCon | 29 | Stage 1/2/3 | China Mobile | lulu@chinamobile.com | Rel-12 | 57 | Alain | IMS_RegCon |  |  | PCG-32 | SP-62 |
| 1960 | 554.1 | Deleted - Stage 1 for IMS Registration Control | 164d? | 2012-01-31 A | 2012-09-12 A | 100% | 2012-01-31 | 2012-09-12 | 164d? | finish no earlier than 2012-09-12 | S1 | 1304h | 1304h | IMS_RegCon-del1 | 29 | 22.228 | China Mobile | lulu@chinamobile.com | Rel-12 | 57 | Alain |  |  |  | PCG-32 | SP-62 |
| 1961 | 554.2 | Deleted - Stage 2 for IMS Registration Control | 262d? | 2012-12-13 A | 2013-12-11 A | 100% | 2012-12-13 | 2013-12-11 | 262d? | finish no earlier than 2013-12-11 | S2 | 2096h | 2096h | IMS_RegCon-del2 | 30 | 23.228 | China Mobile | Jiang Yi (jiangyi@chinamobile.com) | Rel-12 | 58 | Maurice |  |  |  | PCG-32 | SP-62 |
| 1962 | 554.3 | **Deleted - CT aspects of IMS registration control** | 129d? | 2013-06-19 A | 2013-12-11 A | 100% | 2013-06-19 | 2013-12-11 | 129d? |  | C1; C4 | 4128h | 4128h | IMS_RegCon-CT | 31 | Stage 2/3 | China Mobile | Jiang Yi (jiangyi@chinamobile.com) | Rel-12 | 60 | Frederic | IMS_RegCon-CT |  |  | PCG-32 | SP-62 |
| 1963 | 554.3.1 | Deleted - CT1 aspects of CT aspects of IMS registration control (Stage 2/3) | 129d? | 2013-06-19 A | 2013-12-11 A | 100% | 2013-06-19 | 2013-12-11 | 129d? | finish no earlier than 2013-12-11 | C1 | 1032h | 1032h | IMS_RegCon-CT1 | 31 | 23.218, 24.229 | China Mobile | Jiang Yi (jiangyi@chinamobile.com) | Rel-12 | 60 | Frederic |  |  |  | PCG-32 | SP-62 |
| 1964 | 554.3.2 | Deleted - CT4 aspects of CT aspects of IMS registration control (Stage 3) | 129d? | 2013-06-19 A | 2013-12-11 A | 100% | 2013-06-19 | 2013-12-11 | 129d? | finish no earlier than 2013-12-11 | C4 | 1032h | 1032h | IMS_RegCon-CT4 | 31 | 29.228, 29.229, 23.008 | China Mobile | Jiang Yi (jiangyi@chinamobile.com) | Rel-12 | 60 | Kimmo |  |  |  | PCG-32 | SP-62 |
| 1965 | 555 | **Proximity-based Services** | 1186d? | 2012-12-13 A | 2017-06-15 A | 100% | 2012-12-13 | 2015-03-13 | 593d? |  |  | 36376.8h | 36376.8h | ProSe | 30 | Stage 1/2 | Qualcomm | Rich Hovey (rhovey@qualcomm.com) | Rel-12 | 58 | Alain | ProSe |  | Public Safety (A-A) |  |  |
| 1966 | 555.1 | Stage 1 for Proximity-based Services | 137d? | 2012-12-13 A | 2013-06-19 A | 100% | 2012-12-13 | 2013-06-19 | 137d? | finish no earlier than 2013-06-19 | S1 | 1088h | 1088h | ProSe-SA1 | 30 | 22.115, 22.278 | Qualcomm | Rich Hovey (rhovey@qualcomm.com) | Rel-12 | 58 | Alain |  |  | Public Safety (A-A) |  |  |
| 1967 | 555.2 | TR on Stage 2 for Proximity-based Services | 327d? | 2012-12-13 A | 2014-03-07 A | 100% | 2012-12-13 | 2014-03-07 | 327d? | finish no earlier than 2014-03-07 | S2 | 2608h | 2608h | ProSe-SA2TR | 30 | New TR 23.703 | Qualcomm | Haris Zisimopoulos (harisz@qti.qualcomm.com) | Rel-12 | 58 | Maurice |  |  | Public Safety (A-A) |  |  |
| 1968 | 555.3 | Stage 2 for Proximity-based Services | 397d? | 2012-12-19 A | 2014-06-18 A | 100% | 2012-12-19 | 2014-06-18 | 397d? | finish no earlier than 2014-06-18 | S2 | 3168.8h | 3168.8h | ProSe-SA2 | 30 | New TS 23.303 | Qualcomm | Haris Zisimopoulos (harisz@qti.qualcomm.com) | Rel-12 | 58 | Maurice |  |  | Public Safety (A-A) |  |  |
| 1969 | 555.4 | Security for Proximity-based Services | 464d? | 2013-03-13 A | 2014-12-12 A | 100% | 2013-03-13 | 2014-06-18 | 336d? | finish no earlier than 2014-12-12 | S3 | 3712h | 3712h | ProSe-SA3 | 30 | 33.220, New TS 33.303 | Qualcomm | Adrian Escott (aescott@qti.qualcomm.com) | Rel-12 | 59 | Mirko |  | SP-140584 | Public Safety (A-A) |  |  |
| 1970 | 555.5 | (IETF) Security for Proximity-based Services (ietf-avtcore-srtp-aes-gcm) | 63d? | 2014-09-12 A | 2014-12-09 A | 100% |  |  |  | finish no earlier than 2014-12-09 | S3-IETF | 504h | 504h | ProSe | 33 | RFC 7714 (was ietf-avtcore-srtp-aes-gcm) | Atle Monrad | atle.monrad@ericsson.com | Rel-12 | 65 |  |  |  | Public Safety (A-A) |  |  |

Notes:
- 1947: Linked to Rel-11 IPXS Feature UID_470051 Advanced IP Interconnection of Services. This WI defines a generic framework for interconnecting with any type of IMS based network including IP-PBXs.
- 1948: SP#57 completed. 22.228CR#0171
- 1949: SP#60 completed
- 1950: SP#60 completed
- 1951: -
- 1952: CP#65 completion 09/14=>12/14. Exception in CP-140607. Dec.14: 85->100%
- 1953: CP#64 completed
- 1954: Evaluate and if needed enhance existing 3GPP solutions for WLAN network selection taking into account WFA Hotspot 2.0 solutions
- 1955: SP#62 completed
- 1956: SP#62 completed
- 1957: SP#63 stopped (84% complete)
- 1958: CP#65 completion 09/14=>12/14. CP#65 exception CP-140622. Dec.14: 95->100%
- 1959: SP#62 stopped. Specify for fixed line the requirement of controlling user registration to IMS based on network information related to user location (e.g. IP address, DSLAM information)
- 1960: SP#57 completed
- 1961: SP#62 stopped at 50% completion
- 1962: SP#62 no CT/Stage 3 work is needed (stopped at 0% completion)
- 1963: SP#62 no CT/Stage 3 work is needed (stopped at 0% completion)
- 1964: SP#62 no CT/Stage 3 work is needed (stopped at 0% completion)
- 1965: SP#65 SA3 updated the SA-wide WID SP-140300=>SP-140574 (Moved the TR phase to Rel-13 as a stand-alone Study). Triggered by Rel-12 TR 22.803 Study on Proximity-based Services (FS_ProSe) UID_530044
- 1966: SP#60 completed
- 1967: SP#63 completed. TR 23.703v200 for Approval
- 1968: SP#64 completed open issue/alignment to RAN/SA3 decisions. SP#63 TS 23.303v100 for 1-step Approval
- 1969: SP#65 re-opened. Completion 06/14=>12/14. Exception in SP-140584. Updated WID SP-140300=>SP-140574 (Moved the TR phase to Rel-13 as a stand-alone Study). SP#64 completed. TS 33.303 v100 for 1-step Approval; Aug2015: 90%->100
- 1970: Submitted to IESG for publication; 7/3/16: 75%->100

| ID | WBS | Task | Duration | Start | Finish | Complete | Remaining | Baseline start | Baseline finish | Baseline duration | Total slack | Constraint | Resources | Work | Actual work | Acronym | PCG approved | WI rapporteur name | WI rapporteur e-mail | Release | TSG approved | Status Report | Special Focus Doc | Acronym_3GU_Export | MCC resp |
| --- | --- | --- | --- | --- | --- | --- | --- | --- | --- | --- | --- | --- | --- | --- | --- | --- | --- | --- | --- | --- | --- | --- | --- | --- | --- |
| 1971 | 555.6 | **Charging Aspects of Proximity-based Services** | 195d? | 2014-06-19 A | 2015-03-13 A | 100% |  | 2014-06-18 | 2014-09-17 | 66d? |  |  | S5 | 4160h | 4160h | ProSe-CH | 33 | Qualcomm | Cheng Hong (hongc@qti.qualcomm.com) | Rel-12 | 64 | SP-140543 | Public Safety (A-A) | ProSe-CH |  |
| 1972 | 555.6.1 | Study on Charging support for ProSe one-to-many Direct Communication for Public Safety use | 130d? | 2014-06-19 A | 2014-12-12 A | 100% |  | 2014-06-18 | 2014-09-17 | 66d? |  | finish no earlier than 2014-12-12 | S5 | 1040h | 1040h | ProSe-CH-SA5TR | 33 | Qualcomm | Cheng Hong (hongc@qti.qualcomm.com) | Rel-12 | 64 | SP-140543 | Public Safety (A-A) |  |  |
| 1973 | 555.6.2 | Specification of Charging Aspects of Proximity-based Services | 195d? | 2014-06-19 A | 2015-03-13 A | 100% |  | 2014-06-18 | 2014-09-17 | 66d? |  | finish no earlier than 2015-03-13 | S5 | 1560h | 1560h | ProSe-CH-SA5 | 33 | Qualcomm | Cheng Hong (hongc@qti.qualcomm.com) | Rel-12 | 64 | SP-140543 | Public Safety (A-A) |  |  |
| 1974 | 555.7 | **CT aspects of Proximity-based Services (Stage 3)** | 203d? | 2014-03-05 A | 2014-12-09 A | 100% |  | 2014-03-05 | 2014-09-12 | 138d? |  |  |  | 6392h | 6392h | ProSe-CT | 32 | Qualcomm | Lena Chaponniere (lguellec@qti.qualcomm.com) | Rel-12 | 63 |  | Public Safety (A-A) | ProSe-CT | Frederic |
| 1975 | 555.7.1 | CT1 part of CT aspects of Proximity-based Services | 200d? | 2014-03-05 A | 2014-12-09 A | 100% |  | 2014-03-05 | 2014-09-12 | 138d? |  | finish no earlier than 2014-12-09 | C1 | 1600h | 1600h | ProSe-CT | 32 | Qualcomm | Lena Chaponniere (lguellec@qti.qualcomm.com) | Rel-12 | 63 | CP-140615 | Public Safety (A-A) |  | Frederic |
| 1976 | 555.7.2 | CT3 part of CT aspects of Proximity-based Services | 200d? | 2014-03-05 A | 2014-12-09 A | 100% |  | 2014-03-05 | 2014-09-12 | 138d? |  | finish no earlier than 2014-12-09 | C3 | 1600h | 1600h | ProSe-CT | 32 | Qualcomm | Lena Chaponniere (lguellec@qti.qualcomm.com) | Rel-12 | 63 | CP-140568 | Public Safety (A-A) |  | Adrian |
| 1977 | 555.7.3 | CT4 part of CT aspects of Proximity-based Services | 200d? | 2014-03-05 A | 2014-12-09 A | 100% |  | 2014-03-05 | 2014-09-12 | 138d? |  | finish no earlier than 2014-12-09 | C4 | 1600h | 1600h | ProSe-CT | 32 | Qualcomm | Lena Chaponniere (lguellec@qti.qualcomm.com) | Rel-12 | 63 | CP-140484 | Public Safety (A-A) |  | Kimmo |
| 1978 | 555.7.4 | CT6 part of CT aspects of Proximity-based Services | 199d? | 2014-03-06 A | 2014-12-09 A | 100% |  | 2014-03-06 | 2014-09-12 | 137d? |  | finish no earlier than 2014-12-09 | C6 | 1592h | 1592h | ProSe-CT | 32 | Qualcomm | Lena Chaponniere (lguellec@qti.qualcomm.com) | Rel-12 | 63 | CP-140695 | Public Safety (A-A) |  | Xavier |
| 1979 | 555.8 | **LTE Device to Device Proximity Services** | 857d? | 2014-03-11 A | 2017-06-15 A | 100% |  | 2014-03-06 | 2015-03-13 | 267d? |  |  |  | 14744h | 14744h | LTE_D2D_Prox | 32 | Qualcomm | Shailesh Patil (patil@qti.qualcomm.com) | Rel-12 | 63 |  | Public Safety (A-A) | LTE_D2D_Prox | Patrick |
| 1980 | 555.8.1 | Core part: LTE Device to Device Proximity Services | 263d? | 2014-03-15 A | 2015-03-15 A | 100% |  | 2014-07-11 | 2014-09-12 | 45.67d? |  | finish no earlier than 2015-03-15 | R1; R2; R4 | 6312h | 6312h | LTE_D2D_Prox-Core | 32 | Qualcomm | Shailesh Patil (patil@qti.qualcomm.com) | Rel-12 | 63 | RP-150094 | Public Safety (A-A) | LTE_D2D_Prox-Core | Patrick |
| 1981 | 555.8.2 | Perf. part: LTE Device to Device Proximity Services | 464d? | 2014-03-11 A | 2015-12-15 A | 100% |  | 2014-03-06 | 2015-03-13 | 267d? |  | finish no earlier than 2015-12-15 | R4 | 3712h | 3712h | LTE_D2D_Prox-Perf | 32 | Qualcomm | Shailesh Patil (patil@qti.qualcomm.com) | Rel-12 | 63 | RP-151276 | Public Safety (A-A) | LTE_D2D_Prox-Perf | Issam |
| 1982 | 555.8.3 | UE Conformance Test Aspects – LTE Device-to-Device Proximity Services | 590d? | 2015-03-16 A | 2017-06-15 A | 100% |  |  |  |  |  | finish no earlier than 2017-06-15 | R5 | 4720h | 4720h | LTE_D2D_Prox-UEConTest | 34 | Qualcomm | svora@qti.qualcomm.com | Rel-12 | 67 |  |  |  |  |
| 1983 | 556 | **Web Real Time Communication access to IMS** | 530d? | 2012-12-14 A | 2014-12-12 | 88% | 63.97d? | 2012-12-14 | 2014-12-10 | 525d? | 5477d |  | S1; S2; S3 | 34985.8h | 22067h | IMS_WebRTC | 30 | China Mobile | lulu@chinamobile.com | Rel-12 | 58 |  |  | IMS_WebRTC | Alain |
| 1984 | 556.1 | Stage 1 for Web Real Time Communication access to IMS | 136d? | 2012-12-14 A | 2013-06-19 A | 100% |  | 2012-12-14 | 2013-06-19 | 136d? |  | finish no earlier than 2013-06-19 | S1 | 1088h | 1088h | IMS_WebRTC | 30 | China Mobile | lulu@chinamobile.com | Rel-12 | 58 |  |  |  | Alain |
| 1985 | 556.2 | TR on Stage 2 for Web Real Time Communication access to IMS | 126d? | 2013-06-19 A | 2013-12-11 A | 100% |  | 2013-06-19 | 2013-12-11 | 126d? |  | finish no earlier than 2013-12-11 | S2 | 1008h | 1008h | IMS_WebRTC | 31 | China Mobile | Yu Qing (yuqing@chinamobile.com) | Rel-12 | 60 |  |  |  | Maurice |
| 1986 | 556.3 | Stage 2 for Web Real Time Communication access to IMS | 192d? | 2013-06-19 A | 2014-03-07 A | 100% |  | 2013-06-19 | 2014-03-07 | 192d? |  | finish no earlier than 2014-03-07 | S2 | 1528h | 1528h | IMS_WebRTC | 31 | China Mobile | Yu Qing (yuqing@chinamobile.com) | Rel-12 | 60 |  |  |  | Maurice |
| 1987 | 556.4 | (IETF) Web Real Time Communication access to IMS (rtcweb-overview) | 391d? | 2013-06-25 A | 2014-12-12 | 50% | 195.5d? | 2013-06-19 | 2014-12-10 | 389d? | 5477d | finish no earlier than 2014-12-12 | C1-IETF | 3128h | 1564h | IMS_WebRTC | 32 | Uwe Rauschenbach | Uwe Rauschenbach | Rel-12 | 63 |  |  |  |  |
| 1988 | 556.5 | TR on Security for Web Real Time Communication access to IMS | 202d? | 2013-12-11 A | 2014-09-17 A | 100% |  | 2013-12-11 | 2014-09-17 | 202d? |  | finish no earlier than 2014-09-17 | S3 | 1608h | 1608h | IMS_WebRTC | 32 | Ericsson | oscar.ohlsson@ericsson.com | Rel-12 | 62 |  |  |  | Mirko |
| 1989 | 556.6 | Security for Web Real Time Communication access to IMS | 202d? | 2013-09-12 A | 2014-06-18 A | 100% |  | 2013-09-12 | 2014-06-18 | 202d? |  | finish no earlier than 2014-06-18 | S3 | 1609.85h | 1609.85h | IMS_WebRTC | 31 | Ericsson | oscar.ohlsson@ericsson.com | Rel-12 | 61 |  |  |  | Mirko |
| 1990 | 556.7 | **CT aspects of Web Real Time Communication (WebRTC) Access to IMS** | 203d? | 2014-03-05 A | 2014-12-09 | 93% | 14.71d? | 2014-03-05 | 2014-12-05 | 198d? | 5480d |  | C1; C4; IETF | 12296h | 10397.2h | IMS_WebRTC-CT | 32 | China Mobile | Jiang Yi (jiangyi@chinamobile.com) | Rel-12 | 63 |  |  | IMS_WebRTC-CT | Frederic |
| 1991 | 556.7.1 | CT1 part of CT aspects of Web Real Time Communication (WebRTC) Access to IMS | 200d? | 2014-03-05 A | 2014-12-09 A | 100% |  | 2014-03-05 | 2014-09-12 | 138d? |  | finish no earlier than 2014-12-09 | C1 | 1600h | 1600h | IMS_WebRTC-CT1 | 32 | China Mobile | Jiang Yi (jiangyi@chinamobile.com) | Rel-12 | 63 | CP-140621 |  |  | Frederic |
| 1992 | 556.7.2 | (IETF) Web Real Time Communication access to IMS (rtcweb-data-channel) | 200d? | 2014-03-06 A | 2014-12-09 | 90% | 20d? | 2014-03-05 | 2014-12-05 | 198d? | 5480d | finish no earlier than 2014-12-09 | C1-IETF | 1600h | 1440h | IMS_WebRTC-data | 33 | christer.holmberg@ericsson.com | christer.holmberg@ericsson.com | Rel-12 | 64 |  |  |  |  |
| 1993 | 556.7.3 | (IETF) Web Real Time Communication access to IMS (rtcweb-stun-consent-freshness) | 200d? | 2014-03-06 A | 2014-12-09 A | 100% |  | 2014-03-05 | 2014-12-05 | 198d? |  | finish no earlier than 2014-12-09 | C1-IETF | 1600h | 1600h | IMS_WebRTC-stun | 33 | christer.holmberg@ericsson.com | christer.holmberg@ericsson.com | Rel-12 | 64 |  |  |  |  |
| 1994 | 556.7.4 | (IETF) Web Real Time Communication access to IMS (draft-yusef-sipcore-sip-oauth) | 63d? | 2014-09-12 A | 2014-12-09 | 25% | 47.25d? |  |  |  | 5480d | finish no earlier than 2014-12-09 | C1-IETF | 504h | 126h | IMS_WebRTC-yusef | 33 | christer.holmberg@ericsson.com | christer.holmberg@ericsson.com | Rel-12 | 65 |  |  |  |  |
| 1995 | 556.7.5 | Deleted - (IETF) Web Real Time Communication access to IMS (draft-holmberg-sipcore-auth-id) | 65d? | 2014-09-12 A | 2014-12-09 A | 100% |  |  |  |  |  | start no earlier than 2014-09-12 | C1-IETF | 520h | 520h | IMS_WebRTC-holmb | 34 | christer.holmberg@ericsson.com |  | Rel-12 | 66 |  |  |  |  |
| 1996 | 556.7.6 | CT4 part of CT aspects of Web Real Time Communication (WebRTC) Access to IMS | 200d? | 2014-03-05 A | 2014-12-09 A | 100% |  | 2014-03-05 | 2014-09-19 | 143d? |  | finish no earlier than 2014-12-09 | C4 | 1600h | 1600h | IMS_WebRTC-CT4 | 32 | China Mobile | Jiang Yi (jiangyi@chinamobile.com) | Rel-12 | 63 | CP-140732 |  |  | Kimmo |

Notes:
- 1971: SP#65 exception in SP-140543. Mar15: 85->100% / Impacted TSs and TRs: Stage 2/3
- 1972: SP#65 completion 09/14=>12/14. Exception in SP-140543. TR 32.844v100 for Information. Dec.14: CD: 09/14->12/14, 60->100% / Impacted TSs and TRs: New TR 32.844
- 1973: SP#65 completion 09/14=>12/14. Exception in SP-140543. SP#65 TR 32.277v100 for Information. Dec.14: CD: 09/14->03/15, 40->75%. Mar15: 75->100% / Impacted TSs and TRs: 32.240, 32.297, 32.298, 32.299, New TS 32.277
- 1974: CP#64 updated WID CP-140194=>CP-140290 / Impacted TSs and TRs: Stage 3
- 1975: CP#65 completion 09/14=>12/14. Exception in CP-140615. TS 24.333/4v200 for Approval. Dec.14: 90->100% / Impacted TSs and TRs: 24.301, 23.122, New TSs (24.333, 24.334)
- 1976: CP#65 completion 09/14=>12/14. TS 29.343v100 for 1-step Approval. Exception in CP-140568. Dec.14: 90->100 / Impacted TSs and TRs: New TS 29.343
- 1977: CP#65 completion 09/14=>12/14. TS 29.344/5v100 for 1-step Approval. Exception in CP-140484. Dec.14: 90->100 / Impacted TSs and TRs: 29.272, 23.008, 23.003, New TSs (29.344, 29.345)
- 1978: CP#65 completion 09/14=>12/14. Exception in CP-140695. Dec.14: 60->100% / Impacted TSs and TRs: 31.102
- 1979: follow-up of TR 36.843 FS_LTE_D2D_Prox / Impacted TSs and TRs: LTE
- 1980: ; CD:Sat 15/03/14->Sun 15/03/15Compl:0%->95%; CD:Fri 13/03/15->Sun 15/03/15; Stat Rep: RP-141244->RP-141894 1st Apr 15: Compl:95%->100% 1st Apr 15: Stat Rep: RP-141894->RP-150094 / Impacted TSs and TRs: 36.101, 36.133, 36.211, 36.212, 36.213, 36.214, 36.300, 36.304, 36.306, 36.321, 36.322, 36.323, 36.331, 36.413, 36.423, New TR 36.877
- 1981: ; CD:Sat 15/03/14->Sun 15/03/15; Stat Rep: RP-141244->RP-141894 1st Apr 15: Compl:10%->25% 1st Apr 15: Stat Rep: RP-141894->RP-150094 03/07/15: Compl:25%->70% 03/07/15: Stat Rep: RP-150094->RP-150760 29/09/15: Compl:70%->95% 29/09/15: CD:Tue 15/09/15-> / Impacted TSs and TRs: 36.101, 36.133
- 1982: rapporteur e-mail added 03/07/15: Compl:0%->10% 03/07/15: Stat Rep: ->RP-150765 29/09/15: Compl:10%->30% 29/09/15: CD:Tue 15/12/15->Wed 15/06/16 29/09/15: Stat Rep: RP-150765->RP-151280 1/1/16: Compl:30%->45% 1/1/16: WID: RP-1; ...; ;...
- 1983: IETF RTCWEB and W3C WEBRTC groups are specifying a browser-based client to support communication services. Interoperability for WebRTC clients to access 3GPP IMS is needed. / Impacted TSs and TRs: Stage 1/2
- 1984: SP#60 completed / Impacted TSs and TRs: 22.101, 22.228
- 1985: SP#62 completed. TR 23.701v100 for Information & Approval / Impacted TSs and TRs: New TR 23.701
- 1986: SP#63 completed / Impacted TSs and TRs: 23.228
- 1987: In WGLC. Mar15: responsible WG changed from S2-IETF / Impacted TSs and TRs: draft-ietf-rtcweb-overview
- 1988: SP#65 completed. TR 33.871v200 for Approval / Impacted TSs and TRs: New TR 33.871
- 1989: SP#64 completed / Impacted TSs and TRs: 33.203, 33.328
- 1990: - / Impacted TSs and TRs: Stage 3
- 1991: CP#65 TS 24.371v100 for Information. Completion 09/14=>12/14. Exception in CP-140621. Dec.14: 70->90%. 3/3/15: 100% cpltd. / Impacted TSs and TRs: 24.229, New TS 24.371
- 1992: Submitted to IESG for publication. Mar15: In RFC-Editors queue / Impacted TSs and TRs: draft-ietf-rtcweb-data-channel
- 1993: Mar15: Publication requested; 7/3/16: 50%->100 / Impacted TSs and TRs: draft-ietf-rtcweb-stun-consent-freshness
- 1994: work in progress / Impacted TSs and TRs: draft-yusef-sipcore-sip-oaut
- 1995: 7/3/16: 25%->100 since deleted (draft no longer needed). / Impacted TSs and TRs: draft-holmberg-sipcore-auth-id
- 1996: CP#65 completion 09/14=>12/14. Exception in CP-140732. Dec.14: 30->80%. Mar. 15: 100% / Impacted TSs and TRs: 23.334, 29.334

| ID | WBS | Task | Duration | Start | Finish | Complete | Baseline start | Baseline finish | Baseline duration | Constraint | Resources | Work | Actual work | Acronym | PCG approved | WI rapporteur name | WI rapporteur e-mail | Release | TSG approved | MCC resp | Acronym_3GU_Export | Special Focus Doc | Status Report |
| --- | --- | --- | --- | --- | --- | --- | --- | --- | --- | --- | --- | --- | --- | --- | --- | --- | --- | --- | --- | --- | --- | --- | --- |
| 1997 | 557 | **Usage Monitoring Control PCC enhancement** | 196d? | 2012-12-13 A | 2013-09-06 A | 100% | 2012-12-13 | 2013-09-06 | 196d? |  | S2; C3 | 4112h | 4112h | UMONC | 30 | ZTE | bi.yifeng@zte.com.cn | Rel-12 | 58 | Maurice | UMONC |  |  |
| 1998 | 557.1 | Stage 2 for Usage Monitoring Control PCC enhancement | 61d? | 2012-12-13 A | 2013-03-06 A | 100% | 2012-12-13 | 2013-03-06 | 61d? | finish no earlier than 2013-03-06 | S2 | 488h | 488h | UMONC | 30 | ZTE | bi.yifeng@zte.com.cn | Rel-12 | 58 | Maurice |  |  |  |
| 1999 | 557.2 | CT3 aspects of Usage Monitoring Control PCC enhancement (Stage 3) | 63d? | 2013-06-14 A | 2013-09-06 A | 100% | 2013-06-14 | 2013-09-06 | 63d? | finish no earlier than 2013-09-06 | C3 | 488h | 488h | UMONC-CT3 | 31 | ZTE | zhou.xiaoyun@zte.com.cn | Rel-12 | 60 | Adrian | UMONC-CT3 |  |  |
| 2000 | 558 | **Application Based Charging** | 340d? | 2013-03-07 A | 2014-06-18 A | 100% | 2013-03-07 | 2014-06-18 | 340d? |  | S2; S5; C3 | 11612h | 11612h | ABC | 30 | Allot | Alla Goldner (agoldner@allot.com) | Rel-12 | 59 | Maurice | ABC |  |  |
| 2001 | 558.1 | Stage 2 for Application Based Charging | 76d? | 2013-03-07 A | 2013-06-19 A | 100% | 2013-03-07 | 2013-06-19 | 76d? | finish no earlier than 2013-12-11 | S2 | 608h | 608h | ABC-SA2 | 30 | Allot | Alla Goldner (agoldner@allot.com) | Rel-12 | 59 | Maurice |  |  |  |
| 2002 | 558.2 | Charging for Application Based Charging | 232.5d? | 2013-06-19 A | 2014-06-18 A | 100% | 2013-06-19 | 2014-06-18 | 232.5d? | finish no earlier than 2014-06-18 | S5 | 1836h | 1836h | ABC-CT5 | 31 | Openet Telecom | alan.mcnamee@openet.com | Rel-12 | 60 | Mirko |  |  |  |
| 2003 | 558.3 | CT3 aspects of Application Based Charging (Stage 3) | 127d? | 2013-06-14 A | 2013-12-06 A | 100% | 2013-06-14 | 2013-12-06 | 127d? | finish no earlier than 2013-12-06 | C3 | 1008h | 1008h | ABC-CT3 | 31 | Allot | Alla Goldner (agoldner@allot.com) | Rel-12 | 60 | Adrian | ABC-CT3 |  |  |
| 2004 | 559 | **Enhanced S2a Mobility Over trusted WLAN access to EPC** | 332d? | 2013-09-09 A | 2014-12-09 A | 100% | 2013-09-09 | 2014-09-12 | 267d? |  | S2; C1; C4 | 19024h | 19024h | eSaMOG | 31 | ZTE | Tricci So (tso@zteusa.com) | Rel-12 | 61 | Maurice | eSaMOG | WLAN |  |
| 2005 | 559.1 | Stage 2 for Enhanced S2a Mobility Over trusted WLAN access to EPC | 130d? | 2013-09-11 A | 2014-03-07 A | 100% | 2013-09-11 | 2014-03-07 | 130d? | finish no earlier than 2014-03-07 | S2 | 1032h | 1032h | eSaMOG-SA2 | 31 | ZTE | Tricci So (tso@zteusa.com) | Rel-12 | 61 | Maurice |  | WLAN |  |
| 2006 | 559.2 | **Stage 3 for Enhanced S2a Mobility Over trusted WLAN access to EPC** | 332d? | 2013-09-09 A | 2014-12-09 A | 100% | 2013-09-09 | 2014-09-12 | 267d? |  | C1; C4 | 10048h | 10048h | eSaMOG-St3 | 31 | ZTE | Joy Zhou (zhou.xingyue@zte.com.cn) | Rel-12 | 61 | Frederic | eSaMOG-St3 | WLAN |  |
| 2007 | 559.2.1 | CT1 part of Stage 3 for Enhanced S2a Mobility Over trusted WLAN access to EPC | 329d? | 2013-09-09 A | 2014-12-09 A | 100% | 2013-09-09 | 2014-09-12 | 267d? | finish no earlier than 2014-12-09 | C1 | 2624h | 2624h | eSaMOG-St3 | 31 | ZTE | Joy Zhou (zhou.xingyue@zte.com.cn) | Rel-12 | 61 | Frederic |  | WLAN | CP-140608 |
| 2008 | 559.2.2 | CT4 part of Stage 3 for Enhanced S2a Mobility Over trusted WLAN access to EPC | 266d? | 2013-09-09 A | 2014-09-11 A | 100% | 2013-09-09 | 2014-09-12 | 266d? | finish no earlier than 2014-09-12 | C4 | 2128h | 2128h | eSaMOG-St3 | 31 | ZTE | Joy Zhou (zhou.xingyue@zte.com.cn) | Rel-12 | 61 | Kimmo |  | WLAN |  |
| 2009 | 560 | **Optimized Offloading to WLAN in 3GPP-RAT Mobility** | 199d? | 2013-09-12 A | 2014-06-13 A | 100% | 2013-09-12 | 2014-06-13 | 199d? |  | S2; C1 | 4800h | 4800h | WORM | 31 | BlackBerry | Steve Barrett (sbarrett@blackberry.com) | Rel-12 | 61 | Maurice | WORM | WLAN |  |
| 2010 | 560.1 | Stage 2 for Optimized Offloading to WLAN in 3GPP-RAT Mobility | 66d? | 2013-09-12 A | 2013-12-11 A | 100% | 2013-09-12 | 2013-12-11 | 66d? | finish no earlier than 2013-12-11 | S2 | 528h | 528h | WORM-SA2 | 31 | BlackBerry | Steve Barrett (sbarrett@blackberry.com) | Rel-12 | 61 | Maurice |  | WLAN |  |
| 2011 | 560.2 | CT aspects of Optimized Offloading to WLAN in 3GPP-RAT Mobility (Stage 3) | 136d? | 2013-12-06 A | 2014-06-13 A | 100% | 2013-12-06 | 2014-06-13 | 136d? | finish no earlier than 2014-06-13 | C1 | 1088h | 1088h | WORM-CT | 32 | Intel | Chen-ho Chin (chen-hox.chin@intel.com) | Rel-12 | 62 | Frederic | WORM-CT | WLAN |  |
| 2012 | 561 | **Network-provided Location information for IMS Trusted WLAN Access Network (TWAN) case** | 264d? | 2013-09-12 A | 2014-09-11 A | 100% | 2013-09-12 | 2014-09-12 | 264d? |  | S2; C3; C1; C4 | 18624h | 18624h | NETLOC_TWAN | 31 | Alcatel-Lucent | Laurent.thiebaut@alcatel-lucent.com | Rel-12 | 61 | Maurice | NETLOC_TWAN | WLAN |  |
| 2013 | 561.1 | Stage 2 for Network-provided Location information for IMS Trusted WLAN Access Network (TWAN) case | 129d? | 2013-09-12 A | 2014-03-07 A | 100% | 2013-09-12 | 2014-03-07 | 129d? | finish no earlier than 2014-03-07 | S2 | 1024h | 1024h | NETLOC_TWAN-SA2 | 31 | Alcatel-Lucent | Laurent.thiebaut@alcatel-lucent.com | Rel-12 | 61 | Maurice |  |  |  |
| 2014 | 561.2 | **CT aspects of Network-provided Location information for IMS Trusted WLAN Access Network (TWAN) case (Stage 3)** | 202d? | 2013-12-06 A | 2014-09-11 A | 100% | 2013-12-06 | 2014-09-12 | 202d? |  | C3; C1; C4 | 9152h | 9152h | NETLOC_TWAN-CT | 32 | China Telecom | Xia Xu (xiaxu@ctbri.com.cn) | Rel-12 | 62 | Adrian | NETLOC_TWAN-CT |  |  |
| 2015 | 561.2.1 | CT3 part of Network-provided Location information for IMS Trusted WLAN Access Network (TWAN) case | 137d? | 2013-12-06 A | 2014-06-13 A | 100% | 2013-12-06 | 2014-06-13 | 137d? | finish no earlier than 2014-06-13 | C3 | 1088h | 1088h | NETLOC_TWAN-CT | 32 | China Telecom | Xia Xu (xiaxu@ctbri.com.cn) | Rel-12 | 62 | Adrian |  |  |  |
| 2016 | 561.2.2 | CT1 part of Network-provided Location information for IMS Trusted WLAN Access Network (TWAN) case | 201d? | 2013-12-09 A | 2014-09-11 A | 100% | 2013-12-09 | 2014-09-12 | 201d? | finish no earlier than 2014-09-12 | C1 | 1608h | 1608h | NETLOC_TWAN-CT | 32 | China Telecom | Xia Xu (xiaxu@ctbri.com.cn) | Rel-12 | 62 | Frederic |  |  |  |
| 2017 | 561.2.3 | CT4 part of Network-provided Location information for IMS Trusted WLAN Access Network (TWAN) case | 201d? | 2013-12-06 A | 2014-09-11 A | 100% | 2013-12-06 | 2014-09-12 | 201d? | finish no earlier than 2014-09-12 | C4 | 1608h | 1608h | NETLOC_TWAN-CT | 32 | China Telecom | Xia Xu (xiaxu@ctbri.com.cn) | Rel-12 | 62 | Kimmo |  |  |  |
| 2018 | 562 | **Core Network Overload - User Location Information reporting improvement** | 203d? | 2013-12-11 A | 2014-09-17 A | 100% | 2013-12-11 | 2014-09-12 | 199d? |  | S2; C3; C4; S5 | 10920h | 10920h | CNO_ULI | 32 | Alcatel-Lucent | nicolas.drevon@alcatel-lucent.com | Rel-12 | 62 | Maurice | CNO_ULI |  |  |
| 2019 | 562.1 | Stage 2 for Core Network Overload - User Location Information reporting improvement | 64d? | 2013-12-11 A | 2014-03-07 A | 100% | 2013-12-11 | 2014-03-07 | 64d? | finish no earlier than 2014-03-07 | S2 | 504h | 504h | CNO_ULI-SA2 | 32 | Alcatel-Lucent | nicolas.drevon@alcatel-lucent.com | Rel-12 | 62 | Maurice |  |  |  |
| 2020 | 562.2 | Charging aspects of Core Network Overload – User Location Information reporting improvements | 3d? | 2014-09-15 A | 2014-09-17 A | 100% |  |  |  | finish no earlier than 2014-09-17 | S5 | 24h | 24h | CNO_ULI-CH | 33 | Alcatel-Lucent | maryse.gardella@alcatel-lucent.com | Rel-12 | 65 |  | CNO_ULI-CH |  |  |

Notes:
- 1997: SP#59 Stage 2 completed. Triggered by Rel-12 TR 23.858 Study on Usage Monitoring Control enhancement (UID_520035) / Impacted TSs and TRs: Stage 2/3
- 1998: SP#59 completed. 23.203 CR#0782 (Time Based Usage Monitoring), CR#0784 (Usage Monitoring via Online Charging System) / Impacted TSs and TRs: 23.203
- 1999: CP#61 completed. 2/4/15: acronym changed to "UMONC-CT3" / Impacted TSs and TRs: 29.212, 29.214, 29.215
- 2000: Triggered by TR 23.800 Study on Application Based Charging (FS_ABC) UID_560038 / Impacted TSs and TRs: Stage 2/3
- 2001: SP#60 completed / Impacted TSs and TRs: 23.203
- 2002: SP#64 completed / Impacted TSs and TRs: 32.240, 32.251, 32.296, 32.298, 32.299
- 2003: CP#62 completed / Impacted TSs and TRs: 29.212, 29.213, 29.214, 29.215, 29.219
- 2004: - / Impacted TSs and TRs: Stage 2/3
- 2005: SP#63 completed / Impacted TSs and TRs: 23.402
- 2006: CP#62 updated WID CP-130580=>CP-130715 / Impacted TSs and TRs: Stage 3
- 2007: CP#65 completion 09/14=>12/14. Exception in CP-140608. TS 24.244 v200 for Approval. Dec.14: 95->100% / Impacted TSs and TRs: 24.302, New TS 24.244 (WLAN control plane protocol for trusted WLAN access to EPC)
- 2008: CP#65 completed / Impacted TSs and TRs: 29.273, 29.274, 29.275
- 2009: Linked to TR 23.890 Study on Optimized Offloading to WLAN in 3GPP-RAT mobility (FS_WORM), SAE for support for non-3GPP accesses, Multi-Access PDN Connectivity (MAPCON), IP Flow Mobility and Seamless WLAN Offload (IFOM), CS Fallback in EPS (SAES-CSFB) / Impacted TSs and TRs: Stage 2/3
- 2010: SP#62 completed / Impacted TSs and TRs: 23.272, 23.401, 23.402
- 2011: CP#64 completed. Stage 3 enabling differentiation/prioritization of 3GPP RATs relative to WLAN for traffic flow routing based on Inter-System Routing Policies / Impacted TSs and TRs: 24.302, 24.312
- 2012: Rel-11 Network Provided Location Information for IMS (NWK-PL2IMS) covers the case where UE is served by a 3GPP RAN. This WI covers the case where the UE is served by a TWAN / Impacted TSs and TRs: Stage 2/3
- 2013: SP#63 completed / Impacted TSs and TRs: 23.203, 23.228, 23.402
- 2014: - / Impacted TSs and TRs: Stage 3
- 2015: CP#64 completed / Impacted TSs and TRs: 29.212, 29.214
- 2016: CP#65 completed / Impacted TSs and TRs: 24.229
- 2017: CP#65 completed / Impacted TSs and TRs: 29.273, 29.274, 29.275, 29.328, 29.329
- 2018: - / Impacted TSs and TRs: Stage 2/3
- 2019: SP#63 completed / Impacted TSs and TRs: 23.060, 23.203, 23.401
- 2020: SP#65 New WID approved & completed. Introduction of Presence Reporting Areas for Charging / Impacted TSs and TRs: 32.251, 32.298, 32.299

| ID | WBS | Task | Duration | Start | Finish | Complete | Baseline start | Baseline finish | Baseline duration | Constraint | Resources | Work | Actual work | Acronym | PCG approved | Impacted TSs and TRs | WI rapporteur name | Release | TSG approved | MCC resp | Acronym_3GU_Export | Special Focus Doc | PCG stopped | TSG stopped | Status Report |
| --- | --- | --- | --- | --- | --- | --- | --- | --- | --- | --- | --- | --- | --- | --- | --- | --- | --- | --- | --- | --- | --- | --- | --- | --- | --- |
| 2021 | 562.3 | **CT aspects of Core Network Overload – User Location Information reporting improvements** | 138d? | 2014-03-05 A | 2014-09-11 A | 100% | 2014-03-05 | 2014-09-12 | 138d? |  | C3; C4 | 3896h | 3896h | CNO_ULI-CT | 32 | Stage 3 | Alcatel-Lucent | Rel-12 | 63 | Adrian | CNO_ULI-CT |  |  |  |  |
| 2022 | 562.3.1 | CT3 part of CT aspects of Core Network Overload – User Location Information reporting improvements | 73d? | 2014-03-05 A | 2014-06-13 A | 100% | 2014-03-05 | 2014-06-13 | 73d? | finish no earlier than 2014-06-13 | C3 | 584h | 584h | CNO_ULI-CT | 32 | 29.212, 29.213 | Alcatel-Lucent | Rel-12 | 63 | Adrian |  |  |  |  |  |
| 2023 | 562.3.2 | CT4 part of CT aspects of Core Network Overload – User Location Information reporting improvements | 138d? | 2014-03-05 A | 2014-09-11 A | 100% | 2014-03-05 | 2014-09-12 | 138d? | finish no earlier than 2014-09-12 | C4 | 1104h | 1104h | CNO_ULI-CT | 32 | 23.008, 29.060, 29.274 | Alcatel-Lucent | Rel-12 | 63 | Kimmo |  |  |  |  |  |
| 2024 | 563 | Rel-12 Security small Enhancements | 923d? | 2011-03-23 A | 2014-09-17 A | 100% | 2011-03-23 | 2014-06-18 | 859d? | finish no earlier than 2014-09-17 | S3 | 7384h | 7384h | SEC12 | 29 | Stage 2/3 |  | Rel-12 | 56 | Mirko | SEC12 |  |  |  |  |
| 2025 | 564 | **Security aspects of Public Warning System** | 925d? | 2011-03-23 A | 2014-09-17 A | 100% | 2011-03-23 | 2014-09-17 | 924d? |  | S3; S1 | 36832h | 36832h | PWS_Sec | 26 |  | ST-Ericsson | Rel-12 | 51 | Mirko | PWS_Sec | Public Safety (I-A) |  |  |  |
| 2026 | 564.1 | Stage 1 for Protection against false PWS Warning Notifications | 65d? | 2012-06-15 A | 2012-09-12 A | 100% | 2012-06-15 | 2012-09-12 | 65d? | finish no earlier than 2012-09-12 | S1 | 512h | 512h | PWS_Sec-SA1 | 29 | 22.268 | Vodafone | Rel-12 | 56 | Alain |  | Public Safety (I-A) |  |  |  |
| 2027 | 564.2 | TR on SA3 part for Security aspects of Public Warning System | 921d? | 2011-03-23 A | 2014-09-17 A | 100% | 2011-03-23 | 2014-09-17 | 921d? | finish no earlier than 2014-09-17 | S3 | 7360h | 7360h | PWS_Sec-SA3TR | 26 | New TR 33.869 changed to 33.969 | ST-Ericsson | Rel-12 | 51 | Mirko |  | Public Safety (I-A) |  |  |  |
| 2028 | 564.3 | Deleted - SA3 part for Security aspects of Public Warning System | 852d? | 2011-03-30 A | 2014-06-18 A | 100% | 2011-03-30 | 2014-06-18 | 852d? | finish no earlier than 2014-06-18 | S3 | 6808h | 6808h | PWS_Sec-del1 | 26 | New TS 33.269 | ST-Ericsson | Rel-12 | 51 | Mirko |  | Public Safety (I-A) | PCG-33 | SP-64 |  |
| 2029 | 564.4 | Deleted - Stage 1 for Security aspects of Public Warning System | 330d? | 2011-03-23 A | 2012-06-20 A | 100% | 2011-03-23 | 2012-06-20 | 330d? | start no earlier than 2011-03-23 | S1 | 2640h | 2640h | PWS_Sec-del2 | 26 | 22.268 | ST-Ericsson | Rel-12 | 51 | Alain |  | Public Safety (I-A) | PCG-29 | SP-56 |  |
| 2030 | 564.5 | Deleted - Stage 2 for Security aspects of Public Warning System | 133d? | 2011-03-23 A | 2011-09-21 A | 100% | 2011-03-23 | 2011-09-21 | 133d? | start no earlier than 2011-03-23 | S2 | 1064h | 1064h | PWS_Sec-del3 | 26 | 23.401 | ST-Ericsson | Rel-12 | 51 | Maurice |  | Public Safety (I-A) | PCG-27 | SP-53 |  |
| 2031 | 564.6 | Deleted - CT1 part for Security aspects of Public Warning System | 328d? | 2011-03-25 A | 2012-06-20 A | 100% | 2011-03-25 | 2012-06-20 | 328d? | finish no earlier than 2012-06-20 | C1 | 2624h | 2624h | PWS_Sec-del4 | 26 | 23.041 | ST-Ericsson | Rel-12 | 51 | Frederic |  | Public Safety (I-A) | PCG-29 | SP-56 |  |
| 2032 | 564.7 | Deleted - RAN2 part for Security aspects of Public Warning System | 128d? | 2011-03-25 A | 2011-09-16 A | 100% | 2011-03-25 | 2011-09-16 | 128d? | start no earlier than 2011-03-25 | R2 | 1024h | 1024h | PWS_Sec-del5 | 26 | 36.331 | ST-Ericsson | Rel-12 | 51 | Yong-Jun |  | Public Safety (I-A) | PCG-27 | RP-53 |  |
| 2033 | 565 | Security enhancements for usage of Generic Bootstrapping Architecture (GBA) from the browser (Stage 2) | 536d? | 2011-06-08 A | 2013-06-20 A | 100% | 2011-06-08 | 2013-06-19 | 536d? | finish no earlier than 2013-06-19 | S3 | 4256h | 4256h | Web_GBA | 27 | 33.220, 33.222, New TR 33.823 | Nokia | Rel-12 | 52 | Mirko | Web_GBA |  |  |  |  |
| 2034 | 566 | **Extended IMS media plane security features** | 657d? | 2012-06-20 A | 2014-12-09 A | 100% | 2012-06-20 | 2014-12-10 | 655d? |  | S3; C4; C1; C3; IETF | 73585.2h | 73585.2h | eMEDIASEC | 29 | Stage 2/3 | Vodafone | Rel-12 | 56 | Mirko | eMEDIASEC |  |  |  |  |
| 2035 | 566.1 | SA3 part of Extended IMS media plane security features (Stage 2) | 530d? | 2012-06-20 A | 2014-06-18 A | 100% | 2012-06-20 | 2014-06-18 | 530d? | finish no earlier than 2014-06-18 | S3 | 4185.2h | 4185.2h | eMEDIASEC-SA3 | 29 | 33.328 | Vodafone | Rel-12 | 56 | Mirko |  |  |  |  |  |
| 2036 | 566.2 | (IETF) SA3 part of Extended IMS media plane security features (RFC 7345) | 591d? | 2012-06-20 A | 2014-09-12 A | 100% | 2012-06-20 | 2014-12-10 | 654d? | finish no earlier than 2014-09-12 | S3-IETF | 4728h | 4728h | eMEDIASECSA3IETF | 31 | RFC 7345 (was draft-ietf-mmusic-udptl-dtls) | christer.holmberg@ericsson.com | Rel-12 | 61 |  |  |  |  |  |  |
| 2037 | 566.3 | **CT aspects of Extended IMS media plane security features (Stage 2/3)** | 528d? | 2012-12-13 A | 2014-12-09 A | 100% | 2012-12-13 | 2014-12-05 | 523d? |  | C4; C1; C3; IETF | 38392h | 38392h | eMEDIASEC-CT | 30 | Stage 2/3 | Alcatel-Lucent | Rel-12 | 58 | Kimmo | eMEDIASEC-CT |  |  |  |  |
| 2038 | 566.3.1 | TR on Extended IMS media plane security features and TCP related NAT traversal support; IMS H.248 profiles aspects | 461d? | 2012-12-13 A | 2014-09-11 A | 100% | 2012-12-13 | 2014-09-12 | 461d? | finish no earlier than 2014-09-12 | C4 | 3688h | 3688h | eMEDIASEC-CT | 30 | New TR 29.828 | Alcatel-Lucent | Rel-12 | 58 | Kimmo |  |  |  |  |  |
| 2039 | 566.3.2 | CT4 part of CT aspects of Extended IMS media plane security features | 520d? | 2012-12-19 A | 2014-12-09 A | 100% | 2012-12-19 | 2014-09-12 | 458d? | finish no earlier than 2014-12-09 | C4 | 4160h | 4160h | eMEDIASEC-CT | 30 | 23.334, 29.334, 29.238, 23.333, 29.333 | Alcatel-Lucent | Rel-12 | 58 | Kimmo |  |  |  |  | CP-140479 |
| 2040 | 566.3.3 | (IETF) CT4 part of Extended IMS media plane security features (RFC 7345) | 457d? | 2012-12-18 A | 2014-09-11 A | 100% | 2012-12-18 | 2014-12-05 | 519d? | finish no earlier than 2014-09-11 | C4-IETF | 3656h | 3656h | eMEDIASEC-CT | 32 | RFC 7345 (was draft-ietf-mmusic-udptl-dtls) | christer.holmberg@ericsson.com | Rel-12 | 62 |  |  |  |  |  |  |
| 2041 | 566.3.4 | (IETF) CT4 part of Extended IMS media plane security features (draft-schwarz-mmusic-sdp-for-gw) | 129d? | 2014-06-12 A | 2014-12-09 A | 100% | 2014-06-12 | 2014-12-05 | 127d? | finish no earlier than 2014-12-09 | C4-IETF | 1032h | 1032h | eMEDIASEC-CT | 33 | draft-schwarz-mmusic-sdp-for-gw | christer.holmberg@ericsson.com | Rel-12 | 64 |  |  |  |  |  |  |
| 2042 | 566.3.5 | CT1 part of CT aspects of Extended IMS media plane security features | 463d? | 2012-12-13 A | 2014-09-11 A | 100% | 2012-12-13 | 2014-09-12 | 463d? | finish no earlier than 2014-09-12 | C1 | 3696h | 3696h | eMEDIASEC-CT | 30 | 23.218, 24.147, 24.229, 24.247 | Alcatel-Lucent | Rel-12 | 58 | Frederic |  |  |  |  |  |
| 2043 | 566.3.6 | (IETF) CT1 part of Extended IMS media plane security features (RFC 7345) | 137d? | 2014-03-06 A | 2014-09-11 A | 100% | 2014-03-06 | 2014-12-05 | 197d? | finish no earlier than 2014-09-11 | C1-IETF | 1096h | 1096h | eMEDIASEC-CT | 32 | RFC 7345 (was draft-ietf-mmusic-udptl-dtls) | christer.holmberg@ericsson.com | Rel-12 | 62 |  |  |  |  |  |  |
| 2044 | 566.3.7 | CT3 part of CT aspects of Extended IMS media plane security features | 521d? | 2012-12-19 A | 2014-12-09 A | 100% | 2012-12-19 | 2014-06-13 | 394d? | finish no earlier than 2014-12-09 | C3 | 4168h | 4168h | eMEDIASEC-CT | 30 | 29.162 | Alcatel-Lucent | Rel-12 | 58 | Adrian |  |  |  |  | CP-140569 |
| 2045 | 567 | Lawful Interception in the 3GPP Rel-12 | 592d? | 2012-09-17 A | 2014-12-12 A | 100% | 2012-09-17 | 2014-09-12 | 526d? | finish no earlier than 2014-12-12 | S3 | 4736h | 4736h | LI12 | 29 | 33.106, 33.107, 33.108 | PIDS, Alcatel-Lucent | Rel-12 | 57 | Mirko | LI12 |  |  |  |  |

Notes:
- 2021: Specify Stage 3 procedures to support the ULI signalling optimizations / WI rapporteur e-mail: horst.brinkmann@alcatel-lucent.com
- 2022: CP#64 completed / WI rapporteur e-mail: horst.brinkmann@alcatel-lucent.com
- 2023: CP#65 completed / WI rapporteur e-mail: horst.brinkmann@alcatel-lucent.com
- 2024: SEC12 is an umbrella Feature for Security related TEI12 type of changes that are not part of any other dedicated feature
- 2025: - / WI rapporteur e-mail: john.mattsson@ericsson.com
- 2026: SP#57 completed. Specify reqs to protect against false PWS Warning Notifications (Optional as not all regions/countries require this functionality). WID covers all objectivES in CP-150SA3 PWS_Sec Feature-level WID replacing the original Stage 1 UID_510154 / WI rapporteur e-mail: adrian.neal@vodafone.com
- 2027: SP#65 completed. TR 33.969v100 for 1-step Approval. Former TR 33.869 changed to 33.969. / WI rapporteur e-mail: john.mattsson@ericsson.com
- 2028: SP#64 stopped / WI rapporteur e-mail: john.mattsson@ericsson.com
- 2029: Completed in Rel-9 under PWS. SP#55 stopped, Stage 1 requirements removed from Rel-9 onwards (SP-120172). AP 55/1: SA1 to align Stage 1 PWS security for Rel-12. SA1 new WID PWS Security UID_560029. / WI rapporteur e-mail: john.mattsson@ericsson.com
- 2030: SP#53 work stopped as already done in previous releases / WI rapporteur e-mail: john.mattsson@ericsson.com
- 2031: TSG#56 work stopped. SP#56 updated WID SP-110223=>SP-120334 (removed all but SA3 impacted specs) / WI rapporteur e-mail: mikael.wass@ericsson.com
- 2032: RP#53 work stopped as no WI in RAN / WI rapporteur e-mail: john.mattsson@ericsson.com
- 2033: SP#60 completed / WI rapporteur e-mail: Silke.Holtmanns@nokia.com
- 2034: Triggered by Rel-11 TR 33.829 Study on Extended IMS media plane security features (FS_eMEDIASEC) / WI rapporteur e-mail: Aguibou.Barry@vodafone.com
- 2035: SP#64 completed / WI rapporteur e-mail: Aguibou.Barry@vodafone.com
- 2036: SP#65 completed / WI rapporteur e-mail: christer.holmberg@ericsson.com
- 2037: - / WI rapporteur e-mail: bruno.landais@alcatel-lucent.com
- 2038: CP#65 completed. TR 29.828v200 for Approval. 2/4/15: acronym changed to eMEDIASEC-CT / WI rapporteur e-mail: bruno.landais@alcatel-lucent.com
- 2039: CP#65 completion 09/14=>12/14. Exception in CP-140479. Dec.14: 90->100. 2/4/15: acronym changed to eMEDIASEC-CT / WI rapporteur e-mail: bruno.landais@alcatel-lucent.com
- 2040: CP#65 completed. 2/4/15: acronym changed to eMEDIASEC-CT / WI rapporteur e-mail: christer.holmberg@ericsson.com
- 2041: Work in progress. 2/4/15: acronym changed to eMEDIASEC-CT / WI rapporteur e-mail: christer.holmberg@ericsson.com
- 2042: CP#65 completed. 2/4/15: acronym changed to eMEDIASEC-CT / WI rapporteur e-mail: bruno.landais@alcatel-lucent.com
- 2043: CP#65 completed. 2/4/15: acronym changed to eMEDIASEC-CT / WI rapporteur e-mail: christer.holmberg@ericsson.com
- 2044: CP#65 completion 06/14=>12/14. Level 100%=>80%. Exception in CP-140569. CP#64 completed. Dec.14: 80->100. 2/4/15: acronym changed to eMEDIASEC-CT / WI rapporteur e-mail: bruno.landais@alcatel-lucent.com
- 2045: 3/3/15: 75->100% / WI rapporteur e-mail: Koen Jaspers (k.b.jaspers@minjus.nl), terry.jacobson@alcatel-lucent.com

| ID | WBS | Task | Duration | Start | Finish | Complete | Baseline start | Baseline finish | Baseline duration | Constraint | Resources | Work | Actual work | Acronym | PCG approved | WI rapporteur name | WI rapporteur e-mail | Release | TSG approved | MCC resp | Acronym_3GU_Export | Status Report |
| --- | --- | --- | --- | --- | --- | --- | --- | --- | --- | --- | --- | --- | --- | --- | --- | --- | --- | --- | --- | --- | --- | --- |
| 2046 | 568 | **Tunneling of UE Services over Restrictive Access Networks (Stage 2/3)** | 401d? | 2012-12-13 A | 2014-06-18 A | 100% | 2012-12-13 | 2014-06-18 | 401d? |  | S3; C1 | 11662.5h | 11662.5h | TURAN | 30 | Acme Packet | Prashant Kumar (PKumar@acmepacket.com) | Rel-12 | 58 | Mirko | TURAN |  |
| 2047 | 568.1 | SA3 part of Tunneling of UE Services over Restrictive Access Networks (Stage 2/3) | 400d? | 2012-12-13 A | 2014-06-18 A | 100% | 2012-12-13 | 2014-06-18 | 400d? | finish no earlier than 2014-06-18 | S3 | 3168h | 3168h | TURAN-SA3 | 30 | Acme Packet | Prashant Kumar (PKumar@acmepacket.com) | Rel-12 | 58 | Mirko |  |  |
| 2048 | 568.2 | CT aspects of Tunneling of UE Services over Restrictive Access Networks (Stage 3) | 264d? | 2013-06-14 A | 2014-06-13 A | 100% | 2013-06-14 | 2014-06-13 | 264d? | finish no earlier than 2014-06-13 | C1 | 2094.45h | 2094.45h | TURAN-CT | 31 | Huawei | Haitao Wei (weihaitao@huawei.com) | Rel-12 | 60 | Frederic | TURAN-CT |  |
| 2049 | 569 | Specification of the TUAK Algorithm Set | 139d? | 2013-12-09 A | 2014-06-18 A | 100% | 2013-12-09 | 2014-06-18 | 139d? | finish no earlier than 2014-06-18 | S3 | 1112h | 1112h | STAS | 32 | Vodafone | aguibou.barry@vodafone.com | Rel-12 | 62 | Mirko | STAS |  |
| 2050 | 570 | **Codec for Enhanced Voice Services** | 1575d? | 2010-03-25 A | 2016-03-15 A | 100% | 2010-03-25 | 2014-12-12 | 1245d? |  | S4; S1; C4; C1; C3 | 87912h | 87912h | EVS_codec | 24 | Huawei | lei.miao@huawei.com | Rel-12 | 47 | Paolo | EVS_codec |  |
| 2051 | 570.1 | Stage 1 for Codec for Enhanced Voice Services | 1d? | 2010-03-25 A | 2010-03-25 A | 100% | 2010-03-25 | 2010-03-25 | 1d? | start no earlier than 2010-03-25 | S1 | 8h | 8h | EVS_codec-SA1 | 24 | Huawei | lei.miao@huawei.com | Rel-12 | 47 | Paolo |  |  |
| 2052 | 570.2 | Stage 2/3 for Codec for Enhanced Voice Services | 1240d? | 2010-03-25 A | 2014-12-12 A | 100% | 2010-03-25 | 2014-09-17 | 1178d? | finish no earlier than 2014-12-12 | S4 | 9896h | 9896h | EVS_codec-SA4 | 24 | Huawei | lei.miao@huawei.com | Rel-12 | 47 | Paolo |  | SP-140467 |
| 2053 | 570.3 | TR on Performance characterization of Codec for Enhanced Voice Services | 1239d? | 2010-03-25 A | 2014-12-12 A | 100% | 2010-03-25 | 2014-12-12 | 1239d? | finish no earlier than 2014-12-12 | S4 | 9888h | 9888h | EVS_codec-SA4TR | 24 | Huawei | lei.miao@huawei.com | Rel-12 | 47 | Paolo |  | SP-140467 |
| 2054 | 570.4 | **CT impacts of codec for Enhanced Voice Services** | 63d? | 2014-09-16 A | 2014-12-09 A | 100% |  |  |  |  | C4; C1; C3 | 3024h | 3024h | EVS_codec-CT | 33 | Nokia Networks | Jan.Kall@nsn.com | Rel-12 | 65 |  | EVS_codec-CT |  |
| 2055 | 570.4.1 | CT4 part of CT impacts of codec for Enhanced Voice Services | 63d? | 2014-09-16 A | 2014-12-09 A | 100% |  |  |  | finish no earlier than 2014-12-09 | C4 | 504h | 504h | EVS_codec-CT | 33 | Nokia Networks | Jan.Kall@nsn.com | Rel-12 | 65 |  |  | CP-140478 |
| 2056 | 570.4.2 | CT1 part of CT impacts of codec for Enhanced Voice Services | 63d? | 2014-09-16 A | 2014-12-09 A | 100% |  |  |  | finish no earlier than 2014-12-09 | C1 | 504h | 504h | EVS_codec-CT | 33 | Nokia Networks | Jan.Kall@nsn.com | Rel-12 | 65 |  |  | CP-140618 |
| 2057 | 570.4.3 | CT3 part of CT impacts of codec for Enhanced Voice Services | 63d? | 2014-09-16 A | 2014-12-09 A | 100% |  |  |  | finish no earlier than 2014-12-09 | C3 | 504h | 504h | EVS_codec-CT | 33 | Nokia Networks | Jan.Kall@nsn.com | Rel-12 | 65 |  |  | CP-140560 |
| 2058 | 570.5 | UE Conformance Test Aspects - Codec for Enhanced Voice Services (EVS) | 262d? | 2015-03-16 A | 2016-03-15 A | 100% |  |  |  | finish no earlier than 2016-03-15 | R5 | 2096h | 2096h | EVS_codec-UEConTest | 34 | Ericsson |  | Rel-12 | 67 |  |  | RP-151164 |
| 2059 | 571 | **Coordination of Video Orientation** | 400d? | 2012-06-07 A | 2013-12-06 A | 100% | 2012-06-07 | 2013-12-06 | 400d? |  | S4; C4; C1; C3 | 20496.8h | 20496.8h | CVO | 29 | Ericsson | frederic.gabin@ericsson.com | Rel-12 | 56 | Paolo | CVO |  |
| 2060 | 571.1 | SA4 part of Coordination of Video Orientation | 196d? | 2012-06-07 A | 2013-03-06 A | 100% | 2012-06-07 | 2013-03-06 | 196d? | finish no earlier than 2013-03-06 | S4 | 1560h | 1560h | CVO-SA4 | 29 | Ericsson | frederic.gabin@ericsson.com | Rel-12 | 56 | Paolo |  |  |
| 2061 | 571.2 | **CT aspects of Coordination of Video Orientation** | 129d? | 2013-06-14 A | 2013-12-06 A | 100% | 2013-06-14 | 2013-12-06 | 129d? |  | C4; C1; C3 | 6136.8h | 6136.8h | CVO-CT | 31 | Ericsson | nevenka.biondic@ericsson.com | Rel-12 | 60 | Kimmo | CVO-CT |  |
| 2062 | 571.2.1 | CT4 part of CT aspects of Coordination of Video Orientation | 128.05d? | 2013-06-14 A | 2013-12-06 A | 100% | 2013-06-14 | 2013-12-06 | 128.05d? | finish no earlier than 2013-12-06 | C4 | 1008.4h | 1008.4h | CVO-CT | 31 | Ericsson | nevenka.biondic@ericsson.com | Rel-12 | 60 | Kimmo |  |  |
| 2063 | 571.2.2 | CT1 part of CT aspects of Coordination of Video Orientation | 129d? | 2013-06-14 A | 2013-12-06 A | 100% | 2013-06-14 | 2013-12-06 | 129d? | finish no earlier than 2013-12-06 | C1 | 1016h | 1016h | CVO-CT | 31 | Ericsson | nevenka.biondic@ericsson.com | Rel-12 | 60 | Frederic |  |  |
| 2064 | 571.2.3 | CT3 part of CT aspects of Coordination of Video Orientation | 127.05d? | 2013-06-14 A | 2013-12-06 A | 100% | 2013-06-14 | 2013-12-06 | 127.05d? | finish no earlier than 2013-12-06 | C3 | 1016.4h | 1016.4h | CVO-CT | 31 | Ericsson | nevenka.biondic@ericsson.com | Rel-12 | 60 | Adrian |  |  |
| 2065 | 572 | **High Efficiency Video Coding** | 594d? | 2012-09-12 A | 2014-12-05 A | 100% | 2012-09-12 | 2014-12-05 | 591d? |  | S4; IETF | 21576h | 21576h | HEVC | 29 | Qualcomm | Ye-Kui Wang (yekuiw@qti.qualcomm.com) | Rel-12 | 57 | Paolo | HEVC |  |
| 2066 | 572.1 | TR on Evaluation of High Efficiency Video Coding for 3GPP Services | 464d? | 2012-09-12 A | 2014-06-19 A | 100% | 2012-09-12 | 2014-06-19 | 464d? | finish no earlier than 2014-06-18 | S4 | 3704h | 3704h | HEVC-SA4TR | 29 | Qualcomm | Ye-Kui Wang (yekuiw@qti.qualcomm.com) | Rel-12 | 57 | Paolo |  |  |
| 2067 | 572.2 | High Efficiency Video Coding in 3GPP services PSS, MBMS, DASH, MMS, MTSI, IMS Messaging and Presence | 462d? | 2012-09-17 A | 2014-06-18 A | 100% | 2012-09-17 | 2014-06-18 | 462d? | finish no earlier than 2014-06-18 | S4 | 3688h | 3688h | HEVC-SA4 | 29 | Qualcomm | Ye-Kui Wang (yekuiw@qti.qualcomm.com) | Rel-12 | 57 | Paolo |  |  |
| 2068 | 572.3 | (IETF) High Efficiency Video Coding | 587d? | 2012-09-17 A | 2014-12-05 A | 100% | 2012-09-17 | 2014-12-05 | 587d? | finish no earlier than 2014-12-05 | S4-IETF | 4696h | 4696h | HEVC-SA4IETF | 32 | Thomas Stockhammer, Qualcomm Incorporated | tsto@qti.qualcomm.com | Rel-12 | 63 |  |  |  |
| 2069 | 573 | Mobile stereoscopic 3D services extensions | 200d? | 2012-12-12 A | 2013-09-11 A | 100% | 2012-12-12 | 2013-09-11 | 200d? | finish no earlier than 2013-09-11 | S4 | 1568h | 1568h | M3DV_Ext | 30 | Huawei | lukasz.kondrad@huawei.com | Rel-12 | 58 | Paolo | M3DV_Ext |  |

Notes:
- 2046: Linked to Rel-12 SMURFs. Related to TS 22.278 (EPS) cl.7.1.8 Service Reachability (Firewall traversal for IP based services for non-3GPP access), TS 22.228 (IMS) cl.5 (support Firewall traversal), TR 33.830 (Study on Firewall traversal) / Impacted TSs and TRs: Stage 2/3
- 2047: SP#64 completed / Impacted TSs and TRs: 33.203, 33.402
- 2048: CP#64 completed. Stage 3 for 2 new SA3 solutions for firewall traversal: 1) UE access to PLMN IP-based services via restrictive non-3GPP Ans, 2) UE access to IMS services via restrictive ANs / Impacted TSs and TRs: 24.229, 24.302, New TS 24.322
- 2049: SP#64 completed. Triggered by SP-130602 LS from ETSI SAGE (TUAK as alternative to Milenage). 12/14: new TS added / Impacted TSs and TRs: New TSs: 35.231, 35.232, 35.233, TR 35.9nn, TR 35.9nn, TR 35.9nn
- 2050: Triggered by UID_370045 Study on enhanced voice service requirements for EPS (TR 22.813)
- 2051: SP#47 completed / Impacted TSs and TRs: 22.173
- 2052: SP#65 completion 09/14=>12/14. Exception in SP-140467. TS 26.441v200 for Approval. TSs 26.442/44/45/46/47/48/49/50/51v100 for 1-step Approval. Ongoing TS 26.443 EVS Codec ANSI C code (floating point). Dec.14: 90->95 / Impacted TSs and TRs: 26.114, New TS (26.441, 26.442, 26.443, 26.444, 26.445, 26.446, 26.447, 26.448, 26.449, 26.450, 26.451)
- 2053: SP#65 completion 09/14=>12/14. Ongoing TR 26.952 EVS Codec Performance Characterization. Exception in SP-140467 / Impacted TSs and TRs: New TR 26.952
- 2054: Stage 3; WID: CP-140492-> CP-140800
- 2055: CP#65 exception in CP-140478. Dec.14: 0->100; WID: CP-140492-> CP-140800 / Impacted TSs and TRs: 23.334, 29.232, 29.238, 29.332, 29.333, 29.334
- 2056: CP#65 exception in CP-140618. Dec.14: 0->100%; WID: CP-140492-> CP-140800 / Impacted TSs and TRs: 24.229
- 2057: CP#65 exception in CP-140560. Dec.14: 20->100; WID: CP-140492-> CP-140800 / Impacted TSs and TRs: 29.163, 29.292
- 2058: 03/07/15: Compl:0%->25% 03/07/15: WID: RP-150137->RP-150836 03/07/15: Stat Rep: ->RP-150831 29/09/15: Compl:25%->75% 29/09/15: Stat Rep: RP-150831->RP-1511641/1/16: Compl:75%->95%1/1/16: CD:Tue 15/12/15->Tue 15/03/16;
- 2059: CP#62 completed. Resolve backward compatible video orientation mis-alignment in MTSI real-time video communication via interaction between MTSI video clients at call setup & during mid-call of the video orientation for correct local rendering
- 2060: SP#59 completed. Resolve backward compatible video orientation mis-alignment in MTSI real-time video communication via interaction between MTSI video clients at call setup & during mid-call of the video orientation for correct local rendering / Impacted TSs and TRs: 26.114, 26.141, 26.234, 26.346
- 2061: Complete CVO support (both, basic 2 bit orientation and additional option for extra 6 bit granularity) within CN protocols/procedures for IMS nodes, e.g. IMS ALG/AGW,IBCF/TrGW,MRFC/MRFP & add support of CVO-related SDP attributes to be negotiated by UE / Impacted TSs and TRs: Stage 2/3
- 2062: CP#62 completed / Impacted TSs and TRs: 23.333, 23.334, 29.238, 29.332, 29.333, 29.334
- 2063: CP#62 completed / Impacted TSs and TRs: 24.229
- 2064: CP#62 completed / Impacted TSs and TRs: 29.162, 29.163
- 2065: Specify the support of HEVC in 3GPP services (PSS, DASH, MTSI, MMS, MBMS, IMS Messaging and Presence)
- 2066: SP#64 completed. TR 26.906v200 for Approval / Impacted TSs and TRs: New TR 26.906
- 2067: SP#64 completed / Impacted TSs and TRs: 26.114, 26.140, 26.141, 26.234, 26.244, 26.247, 26.346
- 2068: Submitted to IESG for publication. 7/10/15: Rapporteur added; 7/3/16: 50%->95; 13/6/16: 95%->100 / Impacted TSs and TRs: draft-ietf-payload-rtp-h265
- 2069: SP#61 completed. Related to Rel-11 Study On Mobile 3D Video Coding (FS_M3DVC) TR 26.905 and Rel-11 Mobile 3D Video Coding (M3DVC) / Impacted TSs and TRs: 26.114, 26.245, 26.247, 26.430

| ID | WBS | Task | Duration | Start | Finish | Complete | Baseline start | Baseline finish | Baseline duration | Constraint | Resources | Work | Actual work | Acronym | PCG approved | WI rapporteur name | WI rapporteur e-mail | Release | TSG approved | MCC resp | Acronym_3GU_Export | Impacted TSs and TRs | Status Report | Special Focus Doc |
| --- | --- | --- | --- | --- | --- | --- | --- | --- | --- | --- | --- | --- | --- | --- | --- | --- | --- | --- | --- | --- | --- | --- | --- | --- |
| 2070 | 574 | **IMS-based Streaming and Download Delivery Enhancements** | 329d? | 2012-12-12 A | 2014-03-07 A | 100% | 2012-12-12 | 2014-03-07 | 329d? |  | S4 | 7800h | 7800h | IMS_SDE | 30 | Intel | ozgur.oyman@intel.com | Rel-12 | 58 | Paolo | IMS_SDE |  |  |  |
| 2071 | 574.1 | TR on IMS-based Streaming and Download Delivery Enhancements | 326d? | 2012-12-12 A | 2014-03-07 A | 100% | 2012-12-12 | 2014-03-07 | 326d? | finish no earlier than 2014-03-07 | S4 | 2584h | 2584h | IMS_SDE-SA4TR | 30 | Intel | ozgur.oyman@intel.com | Rel-12 | 58 | Paolo |  | new TR 26.827 |  |  |
| 2072 | 574.2 | Specification on IMS-based Streaming and Download Delivery Enhancements | 327d? | 2012-12-13 A | 2014-03-07 A | 100% | 2012-12-13 | 2014-03-07 | 327d? | finish no earlier than 2014-03-07 | S4 | 2584h | 2584h | IMS_SDE-SA4 | 30 | Intel | ozgur.oyman@intel.com | Rel-12 | 58 | Paolo |  | 26.237 |  |  |
| 2073 | 575 | **Acoustic Requirements and Test methods for IMS-based conversational speech services over LTE** | 532d? | 2012-12-12 A | 2014-12-12 A | 100% | 2012-12-12 | 2014-09-17 | 467d? |  | S4 | 14224h | 14224h | ART_LTE | 30 | Qualcomm | Andre Schevciw (aschevci@qualcomm.com) | Rel-12 | 58 | Paolo | ART_LTE | Stage 3 |  |  |
| 2074 | 575.1 | Acoustic Requirements and Test methods for IMS-based conversational speech services over LTE - NarrowBand and WideBand aspects | 265d? | 2012-12-12 A | 2013-12-11 A | 100% | 2012-12-12 | 2013-12-11 | 265d? | finish no earlier than 2013-12-11 | S4 | 2088h | 2088h | ART_LTE-NBWB | 30 | Sony Mobile Communications | Peter.Isberg@sony.com | Rel-12 | 58 | Paolo | ART_LTE-NBWB | 26.131, 26.132 |  |  |
| 2075 | 575.2 | Acoustic Requirements and Test methods for IMS-based conversational speech services over LTE - UE Delay aspects | 462d? | 2012-12-12 A | 2014-09-17 A | 100% | 2012-12-12 | 2014-09-17 | 461d? | finish no earlier than 2014-09-17 | S4 | 3696h | 3696h | ART_LTE-UED | 30 | AT&T, Orange | luisa.marchetto@att.com, stephane.ragot@orange.com | Rel-12 | 58 | Paolo | ART_LTE-UED | 26.131, 26.132 |  |  |
| 2076 | 575.3 | Acoustic Requirements and Test methods for IMS-based conversational speech services over LTE - Super wideband and fullband aspects | 523d? | 2012-12-12 A | 2014-12-12 A | 100% | 2012-12-12 | 2014-09-17 | 461d? | finish no earlier than 2014-12-12 | S4 | 4184h | 4184h | ART_LTE-SUPER | 30 | Sony Mobile Communications | peter.isberg@sonymobile.com | Rel-12 | 58 | Paolo | ART_LTE-SUPER | 26.131, 26.132 | SP-140470 |  |
| 2077 | 576 | **MBMS Improvements** | 471d? | 2013-03-06 A | 2014-12-12 A | 100% | 2013-03-06 | 2014-09-17 | 406d? |  | S4 | 18584h | 18584h | MI | 30 | Ericsson | eric.turcotte@ericsson.com | Rel-12 | 59 | Paolo | MI |  | SP-140471 |  |
| 2078 | 576.1 | TR on Enhanced MBMS Operation | 463d? | 2013-03-06 A | 2014-12-12 A | 100% | 2013-03-06 | 2014-09-17 | 401d? | finish no earlier than 2014-12-12 | S4 | 3704h | 3704h | MI-EMOTR | 30 | Huawei | Zhiming Li (lizhiming@huawei.com) | Rel-12 | 59 | Paolo |  | New TR 26.848 | SP-140471 |  |
| 2079 | 576.2 | Enhanced MBMS Operation | 463d? | 2013-03-06 A | 2014-12-12 A | 100% | 2013-03-06 | 2014-09-17 | 401d? | finish no earlier than 2014-12-12 | S4 | 3704h | 3704h | MI-EMO | 30 | Huawei | Zhiming Li (lizhiming@huawei.com) | Rel-12 | 59 | Paolo | MI-EMO | 26.247, 26.346 | SP-140471 |  |
| 2080 | 576.3 | TR on MBMS operation on Demand | 463d? | 2013-03-06 A | 2014-12-12 A | 100% | 2013-03-06 | 2014-09-17 | 401d? | finish no earlier than 2014-12-12 | S4 | 3704h | 3704h | MI-MooDTR | 30 | Qualcomm | Charles Lo (clo@qti.qualcomm.com) | Rel-12 | 59 | Paolo |  | New TR 26.849 | SP-140471 |  |
| 2081 | 576.4 | MBMS operation on Demand | 463d? | 2013-03-06 A | 2014-12-12 A | 100% | 2013-03-06 | 2014-09-17 | 401d? | finish no earlier than 2014-12-12 | S4 | 3704h | 3704h | MI-MooD | 30 | Qualcomm | Charles Lo (clo@qti.qualcomm.com) | Rel-12 | 59 | Paolo | MI-MooD | 26.346 | SP-140471 |  |
| 2082 | 577 | **End-to-End Multimedia Telephony Service for IMS (MTSI) extensions** | 667d? | 2013-03-06 A | 2015-09-14 A | 100% | 2013-03-06 | 2015-03-13 | 533d? |  | S4 | 32648h | 32648h | E2EMTSI | 30 | Ericsson | tomas.frankkila@ericsson.com | Rel-12 | 59 | Paolo | E2EMTSI | 26.114 |  |  |
| 2083 | 577.1 | S4 aspects of End-to-End Multimedia Telephony Service for IMS (MTSI) extensions | 406d? | 2013-03-06 A | 2014-09-16 A | 100% | 2013-03-06 | 2015-03-13 | 533d? | finish no earlier than 2014-09-17 | S4 | 3248h | 3248h | E2EMTSI | 30 | Ericsson | tomas.frankkila@ericsson.com | Rel-12 | 59 | Paolo | E2EMTSI | 26.114 |  |  |
| 2084 | 577.2 | **CT aspects of End-to-End Multimedia Telephony Service for IMS (MTSI) extensions** | 589d? | 2013-06-21 A | 2015-09-14 A | 100% | 2013-06-20 | 2014-09-12 | 326d? |  | C3; C1; C4 | 24064h | 24064h | E2EMTSI-CT | 31 | Ericsson | susana.fernandez@ericsson.com | Rel-12 | 60 | Adrian |  | Stage 2/3 |  |  |
| 2085 | 577.2.1 | CT3 part of CT aspects of End-to-End Multimedia Telephony Service for IMS (MTSI) extensions | 589d? | 2013-06-21 A | 2015-09-14 A | 100% | 2013-06-20 | 2014-09-12 | 326d? | finish no earlier than 2015-09-14 | C3 | 4712h | 4712h | E2EMTSI-CT | 31 | Ericsson | susana.fernandez@ericsson.com | Rel-12 | 60 | Adrian |  | 29.162, 29.163, 29.213, 29.214 |  |  |
| 2086 | 577.2.2 | CT1 part of CT aspects of End-to-End Multimedia Telephony Service for IMS (MTSI) extensions | 326d? | 2013-06-21 A | 2014-09-12 A | 100% | 2013-06-20 | 2014-09-12 | 326d? | finish no earlier than 2014-09-12 | C1 | 2608h | 2608h | E2EMTSI-CT | 31 | Ericsson | susana.fernandez@ericsson.com | Rel-12 | 60 | Frederic |  | 24.229 |  |  |
| 2087 | 577.2.3 | CT4 part of CT aspects of End-to-End Multimedia Telephony Service for IMS (MTSI) extensions | 326d? | 2013-06-21 A | 2014-09-12 A | 100% | 2013-06-20 | 2014-09-12 | 326d? | finish no earlier than 2014-09-12 | C4 | 2608h | 2608h | E2EMTSI-CT | 31 | Ericsson | susana.fernandez@ericsson.com | Rel-12 | 60 | Kimmo |  | 23.333, 23.334, 29.238, 29.332, 29.333, 29.334 |  |  |
| 2088 | 578 | Video Coding Enhancements in IMS Messaging and Presence | 64d? | 2013-12-11 A | 2014-03-07 A | 100% | 2013-12-11 | 2014-03-07 | 64d? | finish no earlier than 2014-03-07 | S4 | 504h | 504h | VCEIMP | 32 | Ericsson | frederic.gabin@ericsson.com | Rel-12 | 62 | Paolo | VCEIMP | 26.141 |  |  |
| 2089 | 579 | Video Telephony Robustness Improvements | 66d? | 2014-06-18 A | 2014-09-16 A | 100% | 2014-06-18 | 2014-09-17 | 66d? | finish no earlier than 2014-09-17 | S4 | 528h | 528h | VTRI | 33 | Qualcomm | Muhammed Coban (mcoban@qti.qualcomm.com) | Rel-12 | 64 |  | VTRI | 26.114 |  |  |
| 2090 | 580 | **Rel-12 Operations, Administration, Maintenance and Provisioning (OAM&P)** | 857d? | 2011-09-21 A | 2014-12-12 A | 100% | 2011-09-21 | 2014-09-17 | 792d? |  | S5 | 58352.5h | 58352.5h | OAM12 | 29 |  |  | Rel-12 | 56 | Mirko | OAM12 |  |  |  |
| 2091 | 580.1 | **Rel-12 Self-Organizing Networks (SON) - OAM aspects** | 591d? | 2011-09-21 A | 2013-12-11 A | 100% | 2011-09-21 | 2013-12-11 | 591d? |  | S5 | 9408h | 9408h | OAM12-SON | 29 |  |  | Rel-12 | 56 | Mirko | OAM12-SON |  |  | HNB, SON |
| 2092 | 580.1.1 | Multi-vendor Plug and Play eNB connection to the network | 586d? | 2011-09-21 A | 2013-12-11 A | 100% | 2011-09-21 | 2013-12-11 | 586d? | finish no earlier than 2013-12-11 | S5 | 4680h | 4680h | SON-NM-MUPPET | 29 | NSN | anatoly.andrianov@nsn.com | Rel-12 | 56 | Mirko | SON-NM-MUPPET | 32.501, New TSs (32.508, 32.509) |  | HNB, SON |
| 2093 | 580.2 | **Compliance of 3GPP SA5 specifications to the NGMN Next Generation Converged Operations Requirements (NGCOR)** | 596d? | 2012-06-20 A | 2014-09-17 A | 100% | 2012-06-20 | 2014-09-17 | 595d? |  | S5 | 11616.5h | 11616.5h | OAM-NGMN_NGCOR | 29 | Huawei | christian.toche@huawei.com | Rel-12 | 56 | Mirko | OAM-NGMN_NGCOR |  |  |  |
| 2094 | 580.2.1 | Converged Management Model Alignment (Phase 2) | 593d? | 2012-06-20 A | 2014-09-17 A | 100% | 2012-06-20 | 2014-09-17 | 593d? | finish no earlier than 2014-09-17 | S5 | 4744h | 4744h | OAM-MODAL | 29 | NSN | olaf.pollakowski@nsn.com | Rel-12 | 56 | Mirko | OAM-MODAL | 32.156, new TR 28.820 |  |  |
| 2095 | 580.2.2 | 3GPP Fault Management Solution Profile for NGMN NGCOR | 266d? | 2012-06-20 A | 2013-06-19 A | 100% | 2012-06-20 | 2013-06-19 | 266d? | finish no earlier than 2013-06-19 | S5 | 2104.53h | 2104.53h | OAM-FMSP | 29 | Ericsson | thomas.tovinger@ericsson.com | Rel-12 | 56 | Mirko | OAM-FMSP | new TS 28.390 |  |  |

Notes:
- 2070: Provide an extension of IMS based PSS and MBMS user services
- 2071: SP#63 completed. Identify use cases and requirements based on Rel-10/11 PSS and MBMS functionality to be addressed for IMS-based streaming and download enhancements
- 2072: SP#63 completed. Develop procedures towards enabling the IMS-based extensions of the identified use casES in CP-150TS 26.237. Refine existing MBMS download procedures to enable IMS-based MBMS file repair with the use of conventional HTTP web servers.
- 2073: Triggered by Rel-12 Feature Codec for Enhanced Voice Services (EVS_codec) UID_470030. Need for super wideband acoustic requirements and test methods
- 2074: SP#62 completed
- 2075: SP#65 completed
- 2076: SP#65 completion 09/14=>12/14. Exception in SP-140470. Dec.14: 65->100
- 2077: Stage 3 based on existing Stage 2 in TS 23.246 MBMS Architecture and functional description
- 2078: SP#65 completion 09/14=>12/14. Exception in SP-140471. SP#63 TR 26.848v100 for Information. Dec.14: 85->100.
- 2079: SP#65 completion 09/14=>12/14. Exception in SP-140471. Dec.14: 85->100
- 2080: SP#65 completion 09/14=>12/14. Exception in SP-140471. SP#63 TR 26.849v100 for Information. Dec.14: 75->100
- 2081: SP#65 completion 09/14=>12/14. Exception in SP-140471. Dec.14: 75->100
- 2082: SP#65 completed. Updated WID SP-130670=>SP-140594. Reduced Scope & Objectives. Moved work on new TR 26.924, etc. to Rel-13. Co-ordinate with CT1/3/4. Linked to SA4 Rel-7 Media handling and interaction in MTSI (MTSI-MHI) UID_7040
- 2083: SP#65 completed. Updated WID SP-130670=>SP-140594. Reduced Scope & Objectives. Moved work on new TR 26.924, etc. to Rel-13. Co-ordinate with CT1/3/4. Linked to SA4 Rel-7 Media handling and interaction in MTSI (MTSI-MHI) UID_7040
- 2084: Stage 2/3. 5/5/15: corrected to be Rel-12. Nothing to be done in the end (covered by Rel-13 QOSE2EMTSI-CT), so 100%
- 2085: Dec.14: CD: 09/14->09/15. 5/5/15: corrected to be Rel-12. Nothing to be done in the end (covered by Rel-13 QOSE2EMTSI-CT), so 100%
- 2086: CP#64 completion 06/14=>09/14. 5/5/15: corrected to be Rel-12. Nothing to be done in the end (covered by Rel-13 QOSE2EMTSI-CT), so 100%
- 2087: CP#64 completion 06/14=>09/14. 5/5/15: corrected to be Rel-12. Nothing to be done in the end (covered by Rel-13 QOSE2EMTSI-CT), so 100%
- 2088: SP#63 completed. Linked to Rel-6 Media Codecs and Formats for IMS Messaging and Presence (PRESNC-COFIMP) UID_34025. Work item which gave rise to TS 26.141
- 2089: SP#65 completed. Linked to E2EMTSI (End-to-End Multimedia Telephony Service for IMS extensions). Add Reqs&guidelines for video telephony robustness to improve service perf. for PLI, Generic NACK, and FIR messages within overall bitrate limit
- 2090: OAM12 is an umbrella Feature for changes that are not part of any other dedicated feature/WI
- 2091: OAM12-SON is an umbrella BB also for SON related TEI12 type of changes that are not part of any other dedicated feature/WI
- 2092: SP#62 completed. TS 32.508v200 for Approval, TS 32.509v100 for 1-step Approval
- 2093: SP#65 moved to Rel-13 OAM-PMID (Converged management Performance Management Interface Definition) UID_560235
- 2094: SP#65 completed. TR 28.280v100 for 1-step Approval
- 2095: SP#60 completed. TS 28.390v200 for Approval

| ID | WBS | Task | Duration | Start | Finish | Complete | Baseline start | Baseline finish | Baseline duration | Constraint | Resources | Work | Actual work | Acronym | PCG approved | WI rapporteur name | WI rapporteur e-mail | Release | TSG approved | MCC resp | Special Focus Doc | Acronym_3GU_Export | Status Report | TSG stopped |
| --- | --- | --- | --- | --- | --- | --- | --- | --- | --- | --- | --- | --- | --- | --- | --- | --- | --- | --- | --- | --- | --- | --- | --- | --- |
| 2096 | 580.3 | **Network Management for 3GPP Interworking WLAN** | 793d? | 2011-09-21 A | 2014-09-17 A | 100% | 2011-09-21 | 2014-06-18 | 727d? |  | S5 | 17232h | 17232h | OAM-IWLAN | 27 | China Mobile | Chengang@chinamobile.com, lijian@chinamobile.com | Rel-12 | 53 | Mirko | WLAN | OAM-IWLAN |  |  |
| 2097 | 580.3.1 | Performance measurements part Network Management for 3GPP Interworking WLAN | 785d? | 2011-09-22 A | 2014-09-17 A | 100% | 2011-09-22 | 2014-06-18 | 720d? | finish no earlier than 2014-09-17 | S5 | 6272h | 6272h | OAM-IWLAN-SA5P | 27 | China Mobile | Chengang@chinamobile.com, lijian@chinamobile.com | Rel-12 | 53 | Mirko | WLAN |  |  |  |
| 2098 | 580.3.2 | NIM part Network Management for 3GPP Interworking WLAN | 585d? | 2011-09-21 A | 2013-12-11 A | 100% | 2011-09-21 | 2013-12-11 | 585d? | finish no earlier than 2013-12-11 | S5 | 4672h | 4672h | OAM-IWLAN-SA5NM | 27 | China Mobile | Chengang@chinamobile.com, lijian@chinamobile.com | Rel-12 | 53 | Mirko | WLAN |  |  |  |
| 2099 | 580.4 | **Rel-12 Network Infrastructure Management** | 267d? | 2013-12-11 A | 2014-12-12 A | 100% | 2013-12-11 | 2014-09-17 | 202d? |  | S5 | 5848h | 5848h | OAM12-NIM | 30 |  |  | Rel-12 | 58 | Mirko |  | OAM12-NIM |  |  |
| 2100 | 580.4.1 | Alarm quality improvements | 263d? | 2013-12-11 A | 2014-12-12 A | 100% | 2013-12-11 | 2014-09-17 | 201d? | finish no earlier than 2014-12-12 | S5 | 2104h | 2104h | OAM-AMI-SA5 | 32 | TeliaSonera | tommy.berggren@teliasonera.com | Rel-12 | 62 | Mirko |  | OAM-AMI | SP-140544 |  |
| 2101 | 580.4.2 | Radio Planning Tool (RPT) interface | 201d? | 2014-03-07 A | 2014-12-12 A | 100% | 2014-03-07 | 2014-09-17 | 139d? | finish no earlier than 2014-12-12 | S5 | 1608h | 1608h | OAM-RPTi-SA5 | 32 | Nokia Networks | olaf.pollakowski@nsn.com | Rel-12 | 63 | Mirko |  | OAM-RPTi | SP-140546 |  |
| 2102 | 580.5 | Deleted - Rel-12 Performance Management | 328d? | 2013-06-21 A | 2014-09-16 A | 100% | 2013-06-21 | 2014-09-17 | 328d? |  | S5 | 2624h | 2624h | OAM12-PM | 30 |  |  | Rel-12 | 58 | Mirko |  | OAM12-PM |  | SP-69 |
| 2103 | 580.6 | **OAM aspects of Network Sharing** | 267d? | 2013-12-11 A | 2014-12-12 A | 100% | 2013-12-11 | 2014-09-17 | 202d? |  | S5 | 6344h | 6344h | OAM-SHARE | 32 | Orange | jeanmichel.cornily@orange.com | Rel-12 | 62 | Mirko |  | OAM-SHARE | SP-140545 |  |
| 2104 | 580.6.1 | OAM aspects of Network Sharing - Concepts and high-level requirements | 263d? | 2013-12-11 A | 2014-12-12 A | 100% | 2013-12-11 | 2014-09-17 | 201d? | finish no earlier than 2014-12-12 | S5 | 2104h | 2104h | OAM-SHARE-SA5c | 32 | Orange | jeanmichel.cornily@orange.com | Rel-12 | 62 | Mirko |  |  | SP-140545 |  |
| 2105 | 580.6.2 | OAM aspects of Network Sharing - Impacts on existing specifications | 263d? | 2013-12-12 A | 2014-12-12 A | 100% | 2013-12-12 | 2014-09-17 | 201d? | finish no earlier than 2014-12-12 | S5 | 2104h | 2104h | OAM-SHARE-SA5imp | 32 | Orange | jeanmichel.cornily@orange.com | Rel-12 | 62 | Mirko |  |  | SP-140545 |  |
| 2106 | 581 | **Rel-12 Charging** | 402d? | 2012-12-12 A | 2014-06-18 A | 100% | 2012-12-12 | 2014-06-18 | 402d? |  | S5 | 10112h | 10112h | CH12 | 29 |  |  | Rel-12 | 57 | Mirko |  | CH12 |  |  |
| 2107 | 581.1 | Short Message Service - Service Center (SMS-SC) Offline Charging | 325d? | 2012-12-12 A | 2014-03-10 A | 100% | 2012-12-12 | 2014-03-07 | 325d? | finish no earlier than 2014-03-07 | S5 | 2592h | 2592h | SMS-SC-CH | 30 | Alcatel-Lucent | maryse.gardella@alcatel-lucent.com | Rel-12 | 58 | Mirko |  | SMS-SC-CH |  |  |
| 2108 | 581.2 | Charging per IP - Connectivity Access Network (IP-CAN) Session (Stage 2/3) | 201d? | 2013-09-12 A | 2014-06-18 A | 100% | 2013-09-12 | 2014-06-18 | 201d? | finish no earlier than 2014-06-18 | S5 | 1608h | 1608h | CHIPS | 31 | Ericsson | david.shrader@ericsson.com | Rel-12 | 61 | Mirko |  | CHIPS |  |  |
| 2109 | 581.3 | Charging using an Alternative Roaming Provider (Stage 2/3) | 202d? | 2013-09-12 A | 2014-06-18 A | 100% | 2013-09-12 | 2014-06-18 | 202d? | finish no earlier than 2014-06-18 | S5 | 1608h | 1608h | CHARP | 31 | Ericsson | david.shrader@ericsson.com | Rel-12 | 61 | Mirko |  | CHARP |  |  |
| 2110 | 581.4 | Charging for IMS centralized service (ICS) control (Stage 2/3) | 137d? | 2013-12-11 A | 2014-06-18 A | 100% | 2013-12-11 | 2014-06-18 | 137d? | finish no earlier than 2014-06-18 | S5 | 1088h | 1088h | CHICS | 32 | NSN | Gerald.Goermer@nsn.com | Rel-12 | 62 | Mirko |  | CHICS |  |  |
| 2111 | 582 | **IMS Emergency PSAP Callback (Stage 3)** | 724d? | 2011-09-21 A | 2014-06-13 A | 100% | 2011-09-21 | 2014-06-13 | 724d? |  | C1; C3; IETF | 38848h | 38848h | EMC_PC | 27 | Ericsson | christer.holmberg@ericsson.com | Rel-12 | 53 | Frederic | Public Safety (I-A) | EMC_PC |  |  |
| 2112 | 582.1 | CT1 part of IMS Emergency PSAP Callback | 721d? | 2011-09-22 A | 2014-06-13 A | 100% | 2011-09-22 | 2014-06-13 | 721d? | finish no earlier than 2014-06-13 | C1 | 5760h | 5760h | EMC_PC | 27 | Ericsson | christer.holmberg@ericsson.com | Rel-12 | 53 | Frederic | Public Safety (I-A) |  |  |  |
| 2113 | 582.2 | (IETF) CT1 part of IMS Emergency PSAP Callback (RFC 7090) | 723d? | 2011-09-21 A | 2014-06-13 A | 100% | 2011-09-21 | 2014-06-13 | 723d? | finish no earlier than 2014-06-13 | C1-IETF | 5776h | 5776h | EMC_PC | 27 | christer.holmberg@ericsson.com | christer.holmberg@ericsson.com | Rel-12 | 53 | Frederic | Public Safety (I-A) |  |  |  |
| 2114 | 582.3 | CT3 part of IMS Emergency PSAP Callback | 519d? | 2011-09-24 A | 2013-09-06 A | 100% | 2011-09-24 | 2013-09-06 | 519d? | finish no earlier than 2013-09-06 | C3 | 4152h | 4152h | EMC_PC | 27 | Ericsson | christer.holmberg@ericsson.com | Rel-12 | 53 | Adrian | Public Safety (I-A) |  |  |  |
| 2115 | 582.4 | (IETF) CT3 part of IMS Emergency PSAP Callback (RFC 7090) | 724d? | 2011-09-21 A | 2014-06-13 A | 100% | 2011-09-21 | 2014-06-13 | 724d? | finish no earlier than 2014-06-13 | C3-IETF | 5784h | 5784h | EMC_PC | 31 | christer.holmberg@ericsson.com | christer.holmberg@ericsson.com | Rel-12 | 60 | Adrian | Public Safety (I-A) |  |  |  |
| 2116 | 583 | Interworking between a PLMN with WLAN to access the EPC and a PDN (Stage 3) | 265d? | 2012-09-10 A | 2013-09-06 A | 100% | 2012-09-10 | 2013-09-06 | 265d? | finish no earlier than 2013-08-12 | C3 | 2091.72h | 2091.72h | SAES_WLAN_EPC_intwk | 29 | Huawei | Christian.Herrero@huawei.com | Rel-12 | 57 | Adrian | WLAN | SAES_WLAN_EPC_intwk |  |  |
| 2117 | 584 | **Reporting Enhancements in Warning Message Delivery (Stage 2/3)** | 402d? | 2012-12-07 A | 2014-06-13 A | 100% | 2012-12-07 | 2014-06-13 | 402d? |  | C1; C4; R3 | 20832.2h | 20832.2h | REP_WMD | 30 | one2many | peter.sanders@one2many.eu | Rel-12 | 58 | Frederic | Public Safety (I-A) | REP_WMD |  |  |
| 2118 | 584.1 | CT1 part of Reporting Enhancements in Warning Message Delivery (Stage 2) | 329d? | 2012-12-07 A | 2014-03-04 A | 100% | 2012-12-07 | 2014-03-04 | 329d? | finish no earlier than 2014-03-06 | C1 | 2592.18h | 2592.18h | REP_WMD-CT1 | 30 | one2many | peter.sanders@one2many.eu | Rel-12 | 58 | Frederic | Public Safety (I-A) |  |  |  |
| 2119 | 584.2 | CT4 part of Reporting Enhancements in Warning Message Delivery (Stage 2/3) | 400d? | 2012-12-10 A | 2014-06-13 A | 100% | 2012-12-10 | 2014-06-13 | 400d? | finish no earlier than 2014-06-13 | C4 | 3168h | 3168h | REP_WMD-CT4 | 30 | one2many | peter.sanders@one2many.eu | Rel-12 | 58 | Kimmo | Public Safety (I-A) |  |  |  |

Notes:
- 2096: SP#65 updated WID SP-120779=>SP-140542 (removed parts on CN and non-3GPP access). Discontinue I-WLAN spec.
- 2097: SP#65 completed. TS 28.402v100 for 1-step Approval, withdraw New TS 28.401 (CN and non-3GPP access i/w PMs). Moved PMs for EPC and non-3GPP access i/w from 28.401=>28.402 / Impacted TSs and TRs: new TS 28.401, withdrawn new TS 28.402
- 2098: SP#65 discontinue I-WLAN specs: Move parts (e.g. IOCs) applicable for EPC and non-3GPP access interworking NRMs from 28.601/2/6 to 28.611/2/6. Withdraw 28.601/2/6 (CN and non-3GPP access i/w NRMs). SP#62 completed. TSs 28.601/2/6/11/12/16 for Approval / Impacted TSs and TRs: 32.632, 32.636, 32.752, 32.756, new TS (28.611, 28.612, 28.616, withdrawn 28.601, 28.602, 28.606)
- 2099: -
- 2100: SP#65 completion 09/14=>12/14. Exception in SP-140544. Triggered by Rel-12 TR 32.859 Study on Alarm Management (FS_OAM_AM) . Dec.14: 50->100 / Impacted TSs and TRs: 32.111-1, 32.111-2, 32.111-6
- 2101: SP#65 completion 09/14=>12/14. Exception in SP-140546. SP#65 v100 TS 28.667/8 for Information. Dec.14: 60->100 / Impacted TSs and TRs: 32.101, New TSs (28.667, 28.668, 28.669)
- 2102: OAM12-PM is an umbrella BB also for PM related TEI12 type of changes that are not part of any other dedicated feature/WI
- 2103: SP#65 completion 09/14=>12/14. Exception in SP-140545. Triggered by Rel-12 TR 32.851 Study on OAM aspects of Network Sharing (FS_OAM_SHARE), Rel-6 Network Sharing (NTShar) UID_31018 / Impacted TSs and TRs: Stage 1/2/3
- 2104: SP#65 completion 09/14=>12/14. Exception in SP-140545. LM 80->100 / Impacted TSs and TRs: new TS 32.130
- 2105: SP#65 completion 09/14=>12/14. Exception in SP-140545. Dec.14: 60->100 / Impacted TSs and TRs: 28.401,28.621/2/3,28.651/2/3,28.654/5/6,28.657/8/9,28.701/2/3,28.731/2/3,28.734/5/6,32.101/2,32.111-1/2/3/6,32.121/2/6,32.155,32.171/2/6,32.300/1/2/6,32.311/2/6,32.321/2/6,32.331/2/6,32.341/2/6,32.351/352/6,32.361/2/6,32.381/2/6,32.405/6/7/8/9/10/11/12/41
- 2106: CH12 is an umbrella Feature for changes that are not part of any other dedicated feature/WI
- 2107: Stage 2/3. SP#63 completed. Updated WID SP-120775=>SP-140027 / Impacted TSs and TRs: 32.240, 32.274, 32.297, 32.298, 32.299
- 2108: SP#64 completed. 12/15: Acronym reverted back from CHIPCAN to CHIPS / Impacted TSs and TRs: 32.251, 32.298, 32.299
- 2109: SP#64 completed. TS 32.276v200 for Approval, 32.293v100 for 1-step Approval / Impacted TSs and TRs: 32.240, 32.299, New TSs [32.276 (Voice Call Service Charging), 32.293 (Proxy Function)]
- 2110: SP#64 completed. Align SA5 Charging specifications with Rel-8 Feature IMS Centralized Service control (ICSRA) and subsequent enhancements under TEIx (SA2 23.292 ICSRA Stage 2, CT3 29.292, CT1 24.607, 24.611) / Impacted TSs and TRs: 32.250, 32.298
- 2111: Dep. IETF ECRIT on PSAP call back. Fulfill SA1/2 Rel-7 EMC1 reqs UID_32045 PS domain and IMS impacts for supporting IMS Emergency calls (related to BB UID_1653 Emergency Call Enhancements for IP& PS Based Calls / Impacted TSs and TRs: Stage 3
- 2112: CP#64 completed. 2/4/15: acronym changed to EMC_PC / Impacted TSs and TRs: 24.229, tied to completion of IETF dependencies: 24.604, 24.605, 24.610, 24.611, 24.629
- 2113: CP#64 completed. 2/4/15: acronym changed to EMC_PC / Impacted TSs and TRs: RFC 7090 (was draft-ietf-ecrit-psap-callback
- 2114: CP#61 completed. 2/4/15: acronym changed to EMC_PC / Impacted TSs and TRs: 29.163, 29.165
- 2115: CP#64 completed. 2/4/15: acronym changed to EMC_PC / Impacted TSs and TRs: RFC 7090 (was draft-ietf-ecrit-psap-callback)
- 2116: CP#61 completed. Linked to Rel-8 Feature SAES in CP-150System Architecture Evolution specification - Evolved Packet System (non RAN aspects) UID_320005 / Impacted TSs and TRs: 29.061
- 2117: Stage 1 for Cell Broadcast does not exist. This WID enhances the reporting capabilities of Warning Message Delivery. Introduce LTE functionality requested by regulators, equivalent to existing 2G/3G functionality. / Impacted TSs and TRs: Stage 2/3
- 2118: CP#63 completed / Impacted TSs and TRs: 23.041
- 2119: CP#64 completed / Impacted TSs and TRs: 23.007, 29.168

| ID | WBS | Task | Duration | Start | Finish | Complete | Remaining | Baseline start | Baseline finish | Baseline duration | Total slack | Constraint | Resources | Work | Actual work | Acronym | PCG approved | WI rapporteur name | Release | TSG approved | MCC resp | Special Focus Doc | Acronym_3GU_Export | Status Report |
| --- | --- | --- | --- | --- | --- | --- | --- | --- | --- | --- | --- | --- | --- | --- | --- | --- | --- | --- | --- | --- | --- | --- | --- | --- |
| 2120 | 584.3 | **Public Warning System - Reset/Failure/Restart in Warning Message Delivery in LTE** | 340d? | 2013-03-04 A | 2014-06-13 A | 100% |  | 2013-03-04 | 2014-06-13 | 340d? |  |  | R3 | 5424h | 5424h | REP_WMD-RFR_PWS | 30 | one2many, Huawei | Rel-12 | 59 | Juha | Public Safety (I-A) | REP_WMD-RFR_PWS |  |
| 2121 | 584.3.1 | Core part: PWS - Reset/Failure/Restart in Warning Message Delivery in LTE | 338d? | 2013-03-04 A | 2014-06-13 A | 100% |  | 2013-03-04 | 2014-06-13 | 338d? |  | finish no earlier than 2014-06-13 | R3 | 2704h | 2704h | REP_WMD-RFR_PWS-Core | 30 | one2many, Huawei | Rel-12 | 59 | Juha | Public Safety (I-A) | REP_WMD-RFR_PWS-Core | RP-140637 |
| 2122 | 585 | **Single Radio Voice Call Continuity (SRVCC) before ringing (Stage 3)** | 331d? | 2012-12-07 A | 2014-03-06 A | 100% |  | 2012-12-07 | 2014-03-06 | 331d? |  |  | C1; C3; R5 | 9584h | 9584h | bSRVCC | 30 | NTT DOCOMO | Rel-12 | 58 | Frederic |  | bSRVCC |  |
| 2123 | 585.1 | CT1 part of Single Radio Voice Call Continuity (SRVCC) before ringing | 138d? | 2012-12-07 A | 2013-06-14 A | 100% |  | 2012-12-07 | 2013-06-14 | 138d? |  | finish no earlier than 2013-06-14 | C1 | 1096h | 1096h | bSRVCC | 30 | NTT DOCOMO | Rel-12 | 58 | Frederic |  |  |  |
| 2124 | 585.2 | CT3 part of Single Radio Voice Call Continuity (SRVCC) before ringing | 3d? | 2013-06-12 A | 2013-06-14 A | 100% |  | 2013-06-12 | 2013-06-14 | 3d? |  | finish no earlier than 2013-06-14 | C3 | 24h | 24h | bSRVCC | 31 | NTT DOCOMO | Rel-12 | 60 | Adrian |  |  |  |
| 2125 | 585.3 | Test part: Single Radio Voice Call Continuity (SRVCC) before ringing | 65d? | 2013-12-06 A | 2014-03-06 A | 100% |  | 2013-12-06 | 2014-03-06 | 65d? |  | finish no earlier than 2014-03-06 | R5 | 520h | 520h | bSRVCC-UEConTest | 32 | NTT DOCOMO | Rel-12 | 62 | Ingbert |  | bSRVCC-UEConTest | RP-140422 |
| 2126 | 586 | **IMS Stage 3 IETF Protocol Alignment - phase 6** | 532d? | 2012-12-07 A | 2014-12-09 | 97% | 17.95d? | 2012-12-07 | 2014-12-05 | 527d? | 5480d |  | C1; C3; IETF | 20640.6h | 17961.5h | IMSProtoc6 | 30 | Alcatel-Lucent | Rel-12 | 58 | Frederic |  | IMSProtoc6 |  |
| 2127 | 586.1 | CT1 part of IMS Stage 3 IETF Protocol Alignment - phase 6 | 464d? | 2012-12-07 A | 2014-09-11 A | 100% |  | 2012-12-07 | 2014-09-12 | 464d? |  | finish no earlier than 2014-09-12 | C1 | 3712h | 3712h | IMSProtoc6 | 30 | Alcatel-Lucent | Rel-12 | 58 | Frederic |  |  |  |
| 2128 | 586.2 | (IETF) CT1 part of IMS Stage 3 IETF Protocol Alignment - phase 6 (holmberg-sipcore-received-realm) | 410d? | 2013-05-21 A | 2014-12-09 A | 100% |  | 2013-05-21 | 2014-12-05 | 408d? |  | finish no earlier than 2014-12-09 | C1-IETF | 3256.25h | 3256.25h | IMSProtoc6 | 31 | christer.holmberg@ericsson.com | Rel-12 | 60 | Frederic |  |  |  |
| 2129 | 586.3 | (IETF) CT1 part of IMS Stage 3 IETF Protocol Alignment - phase 6 (allen-sipcore-sip-tree-cap-indicators) | 63d? | 2014-09-12 A | 2014-12-09 | 25% | 47.25d? |  |  |  | 5480d | finish no earlier than 2014-12-09 | C1-IETF | 504h | 126h | IMSProtoc6 | 33 | christer.holmberg@ericsson.com | Rel-12 | 65 |  |  |  |  |
| 2130 | 586.4 | (IETF) CT1 part of IMS Stage 3 IETF Protocol Alignment - phase 6 (draft-ietf-insipid-session-id) | 65d? | 2014-09-12 A | 2014-12-09 A | 100% |  |  |  |  |  | start no earlier than 2014-09-12 | C1-IETF | 520h | 520h | IMSProtoc6 | 34 | christer.holmberg@ericsson.com | Rel-12 | 65 |  |  |  |  |
| 2131 | 586.5 | CT3 part of IMS Stage 3 IETF Protocol Alignment - phase 6 | 71d? | 2014-06-06 A | 2014-09-11 A | 100% |  | 2014-06-06 | 2014-09-12 | 71d? |  | finish no earlier than 2014-09-12 | C3 | 568h | 568h | IMSProtoc6 | 30 | Alcatel-Lucent | Rel-12 | 58 | Adrian |  |  |  |
| 2132 | 586.6 | (IETF) CT3 part of IMS Stage 3 IETF Protocol Alignment - phase 6 (holmberg-sipcore-received-realm) | 327d? | 2013-09-06 A | 2014-12-05 A | 100% |  | 2013-09-06 | 2014-12-05 | 327d? |  | finish no earlier than 2014-12-05 | C3-IETF | 2608h | 2608h | IMSProtoc6 | 31 | christer.holmberg@ericsson.com | Rel-12 | 61 |  |  |  |  |
| 2133 | 587 | **SAE Protocol Development - Phase 3** | 467d? | 2012-12-07 A | 2014-09-11 A | 100% |  | 2012-12-07 | 2014-09-12 | 467d? |  |  | C1 | 14920h | 14920h | SAES3 | 30 | InterDigital | Rel-12 | 58 | Frederic |  | SAES3 |  |
| 2134 | 587.1 | SAE Protocol Development (Stage 3) - Phase 3 | 466d? | 2012-12-07 A | 2014-09-11 A | 100% |  | 2012-12-07 | 2014-09-12 | 466d? |  | finish no earlier than 2014-09-12 | C1 | 3728h | 3728h | SAES3-CT1 | 30 | InterDigital | Rel-12 | 58 | Frederic |  |  |  |
| 2135 | 587.2 | CS Fallback in EPS - Phase 3 | 466d? | 2012-12-07 A | 2014-09-11 A | 100% |  | 2012-12-07 | 2014-09-12 | 466d? |  | finish no earlier than 2014-09-12 | C1 | 3728h | 3728h | SAES3-CSFB | 30 | InterDigital | Rel-12 | 58 | Frederic |  | SAES3-CSFB |  |
| 2136 | 587.3 | SAE for support for non-3GPP accesses - Phase 3 | 466d? | 2012-12-07 A | 2014-09-11 A | 100% |  | 2012-12-07 | 2014-09-12 | 466d? |  | finish no earlier than 2014-09-12 | C1 | 3728h | 3728h | SAES3-non3GPP | 30 | InterDigital | Rel-12 | 58 | Frederic |  | SAES3-non3GPP |  |
| 2137 | 588 | **IM-SSF Application Server Service Data Descriptions (Stage 2/3)** | 138d? | 2012-12-07 A | 2013-06-14 A | 100% |  | 2012-12-07 | 2013-06-14 | 138d? |  |  | C4; C1 | 3780h | 3780h | IMS_SSFDD | 30 | Huawei | Rel-12 | 58 | Kimmo |  | IMS_SSFDD |  |
| 2138 | 588.1 | Stage 2 for IM-SSF Application Server Service Data Descriptions | 62d? | 2012-12-07 A | 2013-03-01 A | 100% |  | 2012-12-07 | 2013-03-01 | 62d? |  | finish no earlier than 2013-06-14 | C1 | 488h | 488h | IMS_SSFDD | 30 | Huawei | Rel-12 | 58 | Frederic |  |  |  |
| 2139 | 588.2 | Stage 3 for IM-SSF Application Server Service Data Descriptions | 136.5d? | 2012-12-10 A | 2013-06-14 A | 100% |  | 2012-12-10 | 2013-06-14 | 136.5d? |  | finish no earlier than 2013-06-14 | C4 | 1084h | 1084h | IMS_SSFDD | 30 | Huawei | Rel-12 | 58 | Kimmo |  |  |  |
| 2140 | 589 | **Diameter based interface between SGSN and SMS central functions (Stage 2/3)** | 265d? | 2012-12-10 A | 2013-12-06 A | 100% |  | 2012-12-10 | 2013-12-06 | 265d? |  |  | C4; C1 | 7952h | 7952h | Dia_SGSN_SMS | 30 | Alcatel-Lucent | Rel-12 | 58 | Kimmo |  | Dia_SGSN_SMS |  |
| 2141 | 589.1 | Stage 2 for Diameter based interface between SGSN and SMS central functions | 201d? | 2013-03-07 A | 2013-12-06 A | 100% |  | 2013-03-07 | 2013-12-06 | 201d? |  | finish no earlier than 2013-12-06 | C1 | 1608h | 1608h | Dia_SGSN_SMS | 30 | Alcatel-Lucent | Rel-12 | 59 | Frederic |  |  |  |
| 2142 | 589.2 | Stage 3 for Diameter based interface between SGSN and SMS central functions | 265d? | 2012-12-10 A | 2013-12-06 A | 100% |  | 2012-12-10 | 2013-12-06 | 265d? |  | finish no earlier than 2013-12-06 | C4 | 2104h | 2104h | Dia_SGSN_SMS | 30 | Alcatel-Lucent | Rel-12 | 58 | Kimmo |  |  |  |
| 2143 | 590 | Diameter based interface between SGSN-GMLC (Stage 3) | 265d? | 2012-12-10 A | 2013-12-06 A | 100% |  | 2012-12-10 | 2013-12-06 | 265d? |  | finish no earlier than 2013-12-06 | C4 | 2096h | 2096h | Dia_SGSN_GMLC | 30 | Cisco | Rel-12 | 58 | Kimmo |  | Dia_SGSN_GMLC |  |
| 2144 | 591 | IMS impacts on UICC Application Aspects (Stage 3) | 465d? | 2013-03-04 A | 2014-12-09 A | 100% |  | 2013-03-04 | 2014-09-12 | 403d? |  | finish no earlier than 2014-12-09 | C6 | 3720h | 3720h | IMS_UApAs | 30 | Giesecke & Devrient | Rel-12 | 59 | Xavier |  | IMS_UApAs | CP-140696 |

Notes:
- 2120: - / Impacted TSs and TRs: LTE / WI rapporteur e-mail: peter.sanders@one2many.eu, Dai Mingzeng (daimingzeng@huawei.com)
- 2121: RP#64 completed / Impacted TSs and TRs: 36.413 / WI rapporteur e-mail: peter.sanders@one2many.eu, Dai Mingzeng (daimingzeng@huawei.com)
- 2122: Linked to Rel-8 Feature IMS Service Continuity (IMS-Cont) UID_390056. TS 23.237 Rel-12 CR#0444 under TEI12 / Impacted TSs and TRs: GERAN, UTRA, LTE / WI rapporteur e-mail: keisuke.sasada.kx@nttdocomo.com
- 2123: CP#60 completed. 2/4/15: acronym changed to bSRVCC / Impacted TSs and TRs: 24.008, 24.237 / WI rapporteur e-mail: keisuke.sasada.kx@nttdocomo.com
- 2124: CP#60 completedbSRVCC / Impacted TSs and TRs: 29.165 / WI rapporteur e-mail: keisuke.sasada.kx@nttdocomo.com
- 2125: RP#63 completed. Testing for CT1 TS 24.237 (IMS service continuity Stage 3) / Impacted TSs and TRs: 34.229-1, 34.229-2, 36.523-1, 36.523-2 / WI rapporteur e-mail: Masahiro.Tamaoki.eu@nttdocomo.com
- 2126: - / Impacted TSs and TRs: Stage 3 / WI rapporteur e-mail: keith.drage@alcatel-lucent.com
- 2127: CP#65 completed. 4/2/15: acronym changed to IMSProtoc6 / Impacted TSs and TRs: 23.218, 24.229, 24.930 / WI rapporteur e-mail: keith.drage@alcatel-lucent.com
- 2128: Not completed internet-draft. 4/2/15: acronym changed to IMSProtoc6; 21/3/17: 50%->100 / Impacted TSs and TRs: draft-holmberg-sipcore-received-realm / WI rapporteur e-mail: christer.holmberg@ericsson.com
- 2129: Not completed internet-draft. 4/2/15: acronym changed to IMSProtoc6 / Impacted TSs and TRs: draft-allen-sipcore-sip-tree-cap-indicators / WI rapporteur e-mail: christer.holmberg@ericsson.com
- 2130: work in progress. 4/2/15: acronym changed to IMSProtoc6; 21/3/17: 25%->100 / Impacted TSs and TRs: draft-ietf-insipid-session-id
- 2131: CP#65 completed. 4/2/15: acronym changed to IMSProtoc6 / Impacted TSs and TRs: 29.163, 29.165 / WI rapporteur e-mail: keith.drage@alcatel-lucent.com
- 2132: Not completed internet-draft. 4/2/15: acronym changed to IMSProtoc6; 21/3/17: 50%->100 / Impacted TSs and TRs: draft-holmberg-sipcore-received-realm / WI rapporteur e-mail: christer.holmberg@ericsson.com
- 2133: Stage 3 continuation of Rel-8 Feature SAES (3GPP System Architecture Evolution Specification - Evolved Packet System) UID_320005 / Impacted TSs and TRs: Stage 2/3 / WI rapporteur e-mail: behrouz.aghili@interdigital.com
- 2134: CP#65 completed / Impacted TSs and TRs: 23.122, 24.008, 24.167, 24.229, 24.301, 24.302, 24.303, 24.304, 24.305, 24.312, 29.018, 29.118 / WI rapporteur e-mail: behrouz.aghili@interdigital.com
- 2135: CP#65 completed / Impacted TSs and TRs: 23.122, 24.008, 24.167, 24.229, 24.301, 24.302, 24.303, 24.304, 24.305, 24.312, 29.018, 29.118 / WI rapporteur e-mail: behrouz.aghili@interdigital.com
- 2136: CP#65 completed / Impacted TSs and TRs: 23.122, 24.008, 24.167, 24.229, 24.301, 24.302, 24.303, 24.304, 24.305, 24.312, 29.018, 29.118 / WI rapporteur e-mail: behrouz.aghili@interdigital.com
- 2137: CP#60 completed / Impacted TSs and TRs: Stage 2/3 / WI rapporteur e-mail: susan.shishufeng@huawei.com
- 2138: CP#59 completed / Impacted TSs and TRs: 23.218 / WI rapporteur e-mail: susan.shishufeng@huawei.com
- 2139: CP#60 completed / Impacted TSs and TRs: 29.328, 29.329, 29.364 / WI rapporteur e-mail: susan.shishufeng@huawei.com
- 2140: CP#62 completed / Impacted TSs and TRs: Stage 2/3 / WI rapporteur e-mail: jean-jacques.trottin@alcatel-lucent.com
- 2141: CP#62 completed / Impacted TSs and TRs: 23.040 / WI rapporteur e-mail: jean-jacques.trottin@alcatel-lucent.com
- 2142: CP#62 completed / Impacted TSs and TRs: 29.002, 29.230, 29.272, 29.305, 29.336, 29.337, 29.338 / WI rapporteur e-mail: jean-jacques.trottin@alcatel-lucent.com
- 2143: CP#62 completed. Updated WID CP-130273=>CP-130598. No Stage 2 impact. Define a Diameter variant for the protocol used over existing reference points between SGSN and GMLC for LCS (replace the use of MAP by Diameter protocol) / Impacted TSs and TRs: 29.002, 29.172, 29.173, 29.230, 29.272 / WI rapporteur e-mail: Nirav Salot (nsalot@cisco.com)
- 2144: CP#65 completion 09/14=>12/14. Exception in CP-140696. Dec.14: 85->100% / Impacted TSs and TRs: 31.102, 31.103, 31.111, 31.130 / WI rapporteur e-mail: sergi.espi@gi-de.com

| ID | WBS | Task | Duration | Start | Finish | Complete | Baseline start | Baseline finish | Baseline duration | Constraint | Resources | Work | Actual work | Acronym | PCG approved | Impacted TSs and TRs | WI rapporteur name | WI rapporteur e-mail | Release | TSG approved | MCC resp | Acronym_3GU_Export | Status Report |
| --- | --- | --- | --- | --- | --- | --- | --- | --- | --- | --- | --- | --- | --- | --- | --- | --- | --- | --- | --- | --- | --- | --- | --- |
| 2145 | 592 | **eMBMS restoration procedures** | 406d? | 2013-03-01 A | 2014-09-11 A | 100% | 2013-03-01 | 2014-06-13 | 341d? |  | C4; C3 | 10272h | 10272h | eMBMS_Rest | 30 | Stage 3 | Alcatel-Lucent | bruno.landais@alcatel-lucent.com | Rel-12 | 59 | Kimmo | eMBMS_Rest |  |
| 2146 | 592.1 | CT4 part of eMBMS restoration procedures | 205d? | 2013-03-01 A | 2013-12-06 A | 100% | 2013-03-01 | 2013-12-06 | 205d? | finish no earlier than 2013-12-06 | C4 | 1616h | 1616h | eMBMS_Rest | 30 | 23.007, 23.008, 29.274 | Alcatel-Lucent | bruno.landais@alcatel-lucent.com | Rel-12 | 59 | Kimmo |  |  |
| 2147 | 592.2 | CT3 part of eMBMS restoration procedures | 270d? | 2013-09-04 A | 2014-09-11 A | 100% | 2013-09-04 | 2014-06-13 | 205d? | finish no earlier than 2014-09-12 | C3 | 2160h | 2160h | eMBMS_Rest | 31 | 29.061 | Alcatel-Lucent | bruno.landais@alcatel-lucent.com | Rel-12 | 61 | Kimmo |  |  |
| 2148 | 593 | **Dual Radio VCC enhancements (Stage 2/3)** | 325d? | 2012-09-19 A | 2013-12-06 A | 100% | 2012-09-19 | 2013-12-06 | 325d? |  | C1; C3.S2 | 10866.2h | 10866.2h | eDRVCC | 30 | Stage 2/3 | Ericsson | Jan.Holm@ericsson.com | Rel-12 | 59 | Maurice | eDRVCC |  |
| 2149 | 593.1 | Stage 2 for Dual Radio VCC enhancements | 57.55d? | 2012-09-19 A | 2013-03-01 A | 100% | 2012-09-19 | 2013-03-01 | 57.55d? | finish no earlier than 2013-03-01 | S2 | 460.4h | 460.4h | eDRVCC | 30 | 23.237 | Ericsson | Jan.Holm@ericsson.com | Rel-12 | 59 | Maurice |  |  |
| 2150 | 593.2 | **Stage 3 for Dual Radio VCC enhancements** | 205d? | 2013-03-01 A | 2013-12-06 A | 100% | 2013-03-01 | 2013-12-06 | 205d? |  | C1; C3 | 5205.8h | 5205.8h | eDRVCC | 30 | Stage 3 | Ericsson | Jan.Holm@ericsson.com | Rel-12 | 59 | Frederic |  |  |
| 2151 | 593.2.1 | CT1 part of Stage 3 for Dual Radio VCC enhancements | 205d? | 2013-03-01 A | 2013-12-06 A | 100% | 2013-03-01 | 2013-12-06 | 205d? | finish no earlier than 2013-12-06 | C1 | 1608h | 1608h | eDRVCC | 30 | 24.237, 24.292 | Ericsson | Jan.Holm@ericsson.com | Rel-12 | 59 | Frederic |  |  |
| 2152 | 593.2.2 | CT3 part of Stage 3 for Dual Radio VCC enhancements | 41.7d? | 2013-03-01 A | 2013-09-06 A | 100% | 2013-03-01 | 2013-09-06 | 41.7d? | finish no earlier than 2013-09-06 | C3 | 317.8h | 317.8h | eDRVCC | 30 | 29.165 | Ericsson | Jan.Holm@ericsson.com | Rel-12 | 59 | Adrian |  |  |
| 2153 | 594 | **CT aspects of Signalling of Image Size (Stage 2/3)** | 129d? | 2013-06-14 A | 2013-12-06 A | 100% | 2013-06-14 | 2013-12-06 | 129d? |  | C4; C1; C3 | 6136.8h | 6136.8h | SIS_CT | 31 | Stage 2/3 | Ericsson | nevenka.biondic@ericsson.com | Rel-12 | 60 | Kimmo | SIS_CT |  |
| 2154 | 594.1 | CT4 part of Signalling of Image Size | 128.05d? | 2013-06-14 A | 2013-12-06 A | 100% | 2013-06-14 | 2013-12-06 | 128.05d? | finish no earlier than 2013-12-06 | C4 | 1008.4h | 1008.4h | SIS_CT | 31 | 23.333, 23.334, 29.238, 29.332, 29.333, 29.334 | Ericsson | nevenka.biondic@ericsson.com | Rel-12 | 60 | Kimmo |  |  |
| 2155 | 594.2 | CT1 part of CT Aspects of Signalling of Image Size | 129d? | 2013-06-14 A | 2013-12-06 A | 100% | 2013-06-14 | 2013-12-06 | 129d? | finish no earlier than 2013-12-06 | C1 | 1016h | 1016h | SIS_CT | 31 | 24.229 | Ericsson | nevenka.biondic@ericsson.com | Rel-12 | 60 | Frederic |  |  |
| 2156 | 594.3 | CT3 part of CT Aspects of Signalling of Image Size | 128.05d? | 2013-06-14 A | 2013-12-06 A | 100% | 2013-06-14 | 2013-12-06 | 128.05d? | finish no earlier than 2013-12-06 | C3 | 1016.4h | 1016.4h | SIS_CT | 31 | 29.162, 29.163 | Ericsson | nevenka.biondic@ericsson.com | Rel-12 | 60 | Adrian |  |  |
| 2157 | 595 | IMS Centralized Services (ICS) InterWorking Enhancement in Mobile Switching Center Server (MSC-S) | 129d? | 2013-06-14 A | 2013-12-06 A | 100% | 2013-06-14 | 2013-12-06 | 129d? | finish no earlier than 2013-12-06 | C3 | 1008h | 1008h | ICS_IWE | 31 | 29.292 | Orange | marianne.mohali@orange.com | Rel-12 | 60 | Adrian | ICS_IWE |  |
| 2158 | 596 | GPRS Tunnelling Protocol for the Control plane (GTP-C) Overload Control Mechanisms | 267d? | 2013-09-06 A | 2014-09-11 A | 100% | 2013-09-06 | 2014-09-12 | 267d? | finish no earlier than 2014-09-12 | C4 | 2136h | 2136h | GOCMe | 31 | 23.008, 29.230, 29.273, 29.274, 29.303, New TR 29.807 | Cisco | Nirav Salot (nsalot@cisco.com) | Rel-12 | 61 | Kimmo | GOCMe |  |
| 2159 | 597 | **Proxy Call Session Control Function (P-CSCF) restoration enhancements (Stage 2/3)** | 447.1d? | 2013-04-03 A | 2014-12-09 A | 100% | 2013-04-03 | 2014-12-05 | 442.1d? |  | C4; C3; C1 | 54903.2h | 54903.2h | PCSCF_RES | 31 | Stage 2/3 | Ericsson | maria.cruz.bartolome@ericsson.com | Rel-12 | 61 | Kimmo | PCSCF_RES |  |
| 2160 | 597.1 | TR on Proxy Call Session Control Function (P-CSCF) restoration enhancements | 266d? | 2013-09-06 A | 2014-09-11 A | 100% | 2013-09-06 | 2014-09-12 | 266d? | finish no earlier than 2014-09-12 | C4 | 2128h | 2128h | PCSCF_RES | 31 | New TR 29.806 | Ericsson | maria.cruz.bartolome@ericsson.com | Rel-12 | 61 | Kimmo |  |  |
| 2161 | 597.2 | **Common for HSS & PCRF solutions** | 447.1d? | 2013-04-03 A | 2014-12-09 A | 100% |  |  |  |  | C4; C3; C1 | 18602.4h | 18602.4h | PCSCF_RES | 33 |  | Ericsson | maria.cruz.bartolome@ericsson.com | Rel-12 | 64 |  |  |  |
| 2162 | 597.2.1 | CT4 part of Common for HSS & PCRF solutions | 328d? | 2013-09-06 A | 2014-12-09 A | 100% | 2013-09-06 | 2014-12-05 | 326d? | finish no earlier than 2014-12-09 | C4 | 2624h | 2624h | PCSCF_RES | 31 | 23.380, 29.060, 29.274 | Ericsson | maria.cruz.bartolome@ericsson.com | Rel-12 | 61 | Kimmo |  | CP-140481 |
| 2163 | 597.2.2 | CT1 part of Common for HSS & PCRF solutions | 328d? | 2013-04-03 A | 2014-12-05 A | 100% | 2013-04-03 | 2014-12-05 | 326d? | finish no earlier than 2014-12-09 | C1 | 2624h | 2624h | PCSCF_RES | 33 | 24.008 | Ericsson | maria.cruz.bartolome@ericsson.com | Rel-12 | 64 | Kimmo |  |  |
| 2164 | 597.2.3 | CT3 part of Common for HSS & PCRF solutions | 328d? | 2013-05-03 A | 2014-12-09 A | 100% | 2013-05-03 | 2014-12-05 | 326d? | finish no earlier than 2014-12-09 | C3 | 2624h | 2624h | PCSCF_RES | 33 | 29.061, 29.165 | Huawei | susan.shishufeng@huawei.com | Rel-12 | 65 | Kimmo |  | CP-140687 |
| 2165 | 597.3 | **HSS based solution** | 447.1d? | 2013-04-03 A | 2014-12-09 A | 100% |  |  |  |  | C4; C1 | 12401.6h | 12401.6h | PCSCF_RES | 33 |  | Ericsson | maria.cruz.bartolome@ericsson.com | Rel-12 | 64 |  |  |  |
| 2166 | 597.3.1 | CT4 part of HSS based solution | 328d? | 2013-09-06 A | 2014-12-09 A | 100% | 2013-09-06 | 2014-12-05 | 326d? | finish no earlier than 2014-12-09 | C4 | 2624h | 2624h | PCSCF_RES | 31 | 29.002, 29.228, 29.229, 29.272, 29.305 | Ericsson | maria.cruz.bartolome@ericsson.com | Rel-12 | 61 | Kimmo |  | CP-140481 |
| 2167 | 597.3.2 | CT1 part of HSS based solution | 328d? | 2013-04-03 A | 2014-12-09 A | 100% | 2013-04-03 | 2014-12-05 | 326d? | finish no earlier than 2014-12-09 | C1 | 2624h | 2624h | PCSCF_RES | 33 | 24.229 | Ericsson | maria.cruz.bartolome@ericsson.com | Rel-12 | 64 | Kimmo |  | CP-140605 |
| 2168 | 597.4 | **PCRF based solution** | 447.1d? | 2013-04-03 A | 2014-12-09 A | 100% |  |  |  |  | C3; C1 | 12401.6h | 12401.6h | PCSCF_RES | 33 |  | Huawei | susan.shishufeng@huawei.com | Rel-12 | 64 |  |  |  |
| 2169 | 597.4.1 | CT3 part of PCRF based solution | 328d? | 2013-05-03 A | 2014-12-09 A | 100% | 2013-05-03 | 2014-12-05 | 326d? | finish no earlier than 2014-12-09 | C3 | 2624h | 2624h | PCSCF_RES | 33 | 29.212, 29.213, 29.214, 29.215 | Huawei | susan.shishufeng@huawei.com | Rel-12 | 64 | Kimmo |  | CP-140687 |
| 2170 | 597.4.2 | CT1 part of PCRF based solution | 328d? | 2013-04-03 A | 2014-12-09 A | 100% | 2013-04-03 | 2014-12-05 | 326d? | finish no earlier than 2014-12-09 | C1 | 2624h | 2624h | PCSCF_RES | 33 | 24.229 | Huawei | susan.shishufeng@huawei.com | Rel-12 | 64 | Kimmo |  | CP-140605 |

Notes:
- 2145: CP#62 completed. Linked to Rel-9 MBMS support in EPS (MBMS_EPS). Rel-10 CT Features EPC Node Restoration with/out Idle mode Signalling Reduction (ISR) activated (EPC_NR/EPC_NR_ISR)
- 2146: CP#62 completed
- 2147: CP#65 completed
- 2148: CP#62 completed. Stage 2 in Rel-12 TEI12 TS 23.237 CR#0431, CR#0440, CR#0441, CR#0453 (pre-alerting). Stage 3 linked to Rel-8 Feature IMS Service Continuity (IMS-Cont) UID_390056 (Stage 2 in TS 23.237). 2/4/15: acronym changed to eDRVCC
- 2149: Stage 2 in Rel-12 TEI12 TS 23.237 CR#0431, CR#0440, CR#0441, CR#0453 (pre-alerting). 2/4/15: acronym changed to eDRVCC
- 2150: CP#62 completed
- 2151: CP#62 completed. 2/4/15: acronym changed to eDRVCC
- 2152: CP#61 completed. 2/4/15: acronym changed to eDRVCC
- 2153: CP#62 completed. SA4 Rel-8 MTSI Video: Dynamic Rate Adaptation/Signalling of Image Size UID_34041 has included service aspects to support image attribute (a=imageattr) in TS 26.114 as in RFC 6236. But associated CN aspects were not included
- 2154: CP#62 completed
- 2155: CP#62 completed
- 2156: CP#62 completed
- 2157: CP#62 completed. Stage 3 enhancement interworking between IMS and MSC-S for IMS Centralized Services (ICS)
- 2158: CP#65 completed. Updated WID CP-130433=>CP-140488
- 2159: CP#65 updated WID CP-140443=>CP-140490. Based TR 29.806, solutions B and D are selected for standardization. Dec.14: 95->100
- 2160: CP#65 completed. TR 29.806v200 for Approval
- 2161: -
- 2162: CP#65 completion 09/14=>12/14. Exception in CP-140481. Dec.14: 90->100
- 2163: CP#65 completed
- 2164: CP#65 updated WID CP-140443=>CP-140490 (added CT3 part). Exception in CP-140687
- 2165: -
- 2166: CP#65 completion 09/14=>12/14. Exception in CP-140481. Dec.14: 90->100
- 2167: CP#65 completion 09/14=>12/14. Exception in CP-140605. Dec.14: 65->100%
- 2168: -
- 2169: CP#65 updated WID CP-140443=>CP-140490 (added CT3 part). Exception in CP-140687
- 2170: CP#65 completion 09/14=>12/14. Exception in CP-140605. Dec.14: 65->100

| ID | WBS | Task | Duration | Start | Finish | Complete | Baseline start | Baseline finish | Baseline duration | Constraint | Resources | Work | Actual work | Acronym | PCG approved | WI rapporteur name | WI rapporteur e-mail | Release | TSG approved | MCC resp | Acronym_3GU_Export | Status Report |
| --- | --- | --- | --- | --- | --- | --- | --- | --- | --- | --- | --- | --- | --- | --- | --- | --- | --- | --- | --- | --- | --- | --- |
| 2171 | 598 | **Updating IMS to conform to RFC 6665 (Stage 3)** | 400d? | 2013-09-09 A | 2015-03-13 A | 100% | 2013-09-09 | 2014-09-12 | 267d? |  | C1; C3 | 9576h | 9576h | UP6665 | 31 | BlackBerry | Andrew Allen (aallen@blackberry.com) | Rel-12 | 61 | Frederic | UP6665 |  |
| 2172 | 598.1 | CT1 part of Updating IMS to conform to RFC 6665 | 329d? | 2013-09-09 A | 2014-12-09 A | 100% | 2013-09-09 | 2014-09-12 | 267d? | finish no earlier than 2014-12-09 | C1 | 2624h | 2624h | UP6665 | 31 | BlackBerry | Andrew Allen (aallen@blackberry.com) | Rel-12 | 61 | Frederic |  | CP-140620 |
| 2173 | 598.2 | CT3 part of Updating IMS to conform to RFC 6665 | 66d? | 2013-09-09 A | 2013-12-06 A | 100% | 2013-09-09 | 2013-12-06 | 66d? | finish no earlier than 2013-12-06 | C3 | 528h | 528h | UP6665 | 31 | BlackBerry | Andrew Allen (aallen@blackberry.com) | Rel-12 | 61 | Maurice |  |  |
| 2174 | 598.3 | (IETF) CT1 part of Updating IMS to conform to RFC 6665 (draft-ietf-sipcore-refer-clarifications) | 1d? | 2015-03-13 A | 2015-03-13 A | 100% |  |  |  |  | C1-IETF | 8h | 8h | UP6665 | 34 | BlackBerry | Andrew Allen (aallen@blackberry.com) | Rel-12 | 67 |  |  |  |
| 2175 | 598.4 | (IETF) CT1 part of Updating IMS to conform to RFC 6665 (draft-ietf-sipcore-refer-explicit-subscription) | 1d? | 2015-03-13 A | 2015-03-13 A | 100% |  |  |  |  | C1-IETF | 8h | 8h | UP6665 | 34 | BlackBerry | Andrew Allen (aallen@blackberry.com) | Rel-12 | 67 |  |  |  |
| 2176 | 598.5 | (IETF) CT1 part of Updating IMS to conform to RFC 6665 (draft-roach-sipcore-6665-clarifications) | 1d? | 2015-03-13 A | 2015-03-13 A | 100% |  |  |  |  | C1-IETF | 8h | 8h | UP6665 | 34 | BlackBerry | Andrew Allen (aallen@blackberry.com) | Rel-12 | 67 |  |  |  |
| 2177 | 599 | **IMS Operator Determined Call Barring enhancements (Stage 3)** | 202d? | 2013-12-06 A | 2014-09-11 A | 100% | 2013-12-06 | 2014-06-13 | 137d? |  | C1; C3 | 5928h | 5928h | eIODB | 32 | Ericsson | Jorgen.Axell@ericsson.com | Rel-12 | 62 | Frederic | eIODB |  |
| 2178 | 599.1 | CT1 part of IMS Operator Determined Call Barring enhancements | 136d? | 2013-12-06 A | 2014-06-13 A | 100% | 2013-12-06 | 2014-06-13 | 136d? | finish no earlier than 2014-06-13 | C1 | 1088h | 1088h | eIODB | 32 | Ericsson | Jorgen.Axell@ericsson.com | Rel-12 | 62 | Frederic |  |  |
| 2179 | 599.2 | CT3 part of IMS Operator Determined Call Barring enhancements | 201d? | 2013-12-09 A | 2014-09-11 A | 100% | 2013-12-09 | 2014-06-13 | 136d? | finish no earlier than 2014-09-12 | C3 | 1608h | 1608h | eIODB | 32 | Ericsson | Jorgen.Axell@ericsson.com | Rel-12 | 62 | Adrian |  |  |
| 2180 | 600 | Signalling Improvements for Network Efficiency (Stage 3) | 264d? | 2013-12-06 A | 2014-12-09 A | 100% | 2013-12-06 | 2014-09-12 | 202d? | finish no earlier than 2014-12-09 | C1 | 2112h | 2112h | SINE | 32 | Huawei | Lin Shu (shulin@huawei.com) | Rel-12 | 62 | Frederic | SINE | CP-140617 |
| 2181 | 601 | **Interactive Connectivity Establishment (ICE, IETF RFC 5245) impacts on IMS H.248 profiles** | 138d? | 2014-03-05 A | 2014-09-11 A | 100% | 2014-03-05 | 2014-09-12 | 138d? |  | C4; C3 | 3896h | 3896h | ICEH248 | 32 | NSN | Jan.Kall@nsn.com | Rel-12 | 63 | Kimmo | ICEH248 |  |
| 2182 | 601.1 | CT4 part of ICE impacts on IMS H.248 profiles (Stage 2/3) | 138d? | 2014-03-05 A | 2014-09-11 A | 100% | 2014-03-05 | 2014-09-12 | 138d? | finish no earlier than 2014-09-12 | C4 | 1104h | 1104h | ICEH248 | 32 | NSN | Jan.Kall@nsn.com | Rel-12 | 63 | Kimmo |  |  |
| 2183 | 601.2 | CT3 part of ICE impacts on IMS H.248 profiles (Stage 2) | 73d? | 2014-03-05 A | 2014-06-13 A | 100% | 2014-03-05 | 2014-06-13 | 73d? | finish no earlier than 2014-06-13 | C3 | 584h | 584h | ICEH248 | 32 | NSN | Jan.Kall@nsn.com | Rel-12 | 63 | Adrian |  |  |
| 2184 | 602 | **Transfer of ETSI business trunking specifications** | 203d? | 2014-03-05 A | 2014-12-09 A | 100% | 2014-03-05 | 2014-09-17 | 141d? |  | C1; S1 | 5976h | 5976h | IMS_Corp2 | 32 | Alcatel-Lucent | keith.drage@alcatel-lucent.com, Youssef Chadli | Rel-12 | 63 | Frederic | IMS_Corp2 |  |
| 2185 | 602.1 | SA1 part of Transfer of ETSI business trunking specifications | 141d? | 2014-03-05 A | 2014-09-17 A | 100% | 2014-03-05 | 2014-09-17 | 141d? | finish no earlier than 2014-09-17 | S1 | 1128h | 1128h | IMS_Corp2 | 32 | Alcatel-Lucent | betsy.covell@alcatel-lucent.com | Rel-12 | 63 | Alain |  | S1-143300 |
| 2186 | 602.2 | CT1 part of Transfer of ETSI business trunking specifications | 200d? | 2014-03-05 A | 2014-12-09 A | 100% | 2014-03-05 | 2014-09-12 | 138d? | finish no earlier than 2014-12-09 | C1 | 1600h | 1600h | IMS_Corp2 | 32 | Alcatel-Lucent | keith.drage@alcatel-lucent.com, Youssef Chadli | Rel-12 | 63 | Frederic |  | CP-140619 |
| 2187 | 603 | **Support of ALT-C attribute** | 200d? | 2014-03-10 A | 2014-12-09 A | 100% | 2014-03-05 | 2014-09-12 | 138d? |  | C4; C1; C3 | 9600h | 9600h | ALTC | 32 | Orange | lionel.morand@orange.com | Rel-12 | 63 | Kimmo | ALTC |  |
| 2188 | 603.1 | CT4 part of Support of ALT-C attribute | 200d? | 2014-03-10 A | 2014-12-09 A | 100% | 2014-03-05 | 2014-09-12 | 138d? | finish no earlier than 2014-12-09 | C4 | 1600h | 1600h | ALTC | 32 | Orange | lionel.morand@orange.com | Rel-12 | 63 | Kimmo |  | CP-140485 |
| 2189 | 603.2 | CT1 part of Support of ALT-C attribute | 200d? | 2014-03-10 A | 2014-12-09 A | 100% | 2014-03-05 | 2014-09-12 | 138d? | finish no earlier than 2014-12-09 | C1 | 1600h | 1600h | ALTC | 32 | Orange | lionel.morand@orange.com | Rel-12 | 63 | Frederic |  | CP-140611 |
| 2190 | 603.3 | CT3 part of Support of ALT-C attribute | 200d? | 2014-03-10 A | 2014-12-09 A | 100% | 2014-03-05 | 2014-06-13 | 73d? | finish no earlier than 2014-12-09 | C3 | 1600h | 1600h | ALTC | 32 | Orange | lionel.morand@orange.com | Rel-12 | 63 | Adrian |  | CP-140563 |
| 2191 | 604 | **Diameter Overload Control Mechanisms** | 131d? | 2014-06-13 A | 2014-12-09 A | 100% | 2014-06-13 | 2014-12-05 | 126d? |  | C4; IETF | 4144h | 4144h | DOCME | 33 | Orange | lionel.morand@orange.com | Rel-12 | 64 |  | DOCME |  |
| 2192 | 604.1 | CT4 part of Diameter Overload Control Mechanisms | 128d? | 2014-06-13 A | 2014-12-09 A | 100% | 2014-06-13 | 2014-09-12 | 66d? | finish no earlier than 2014-12-09 | C4 | 1024h | 1024h | DOCME | 33 | Orange | lionel.morand@orange.com | Rel-12 | 64 |  |  | CP-140486 |
| 2193 | 604.2 | (IETF) Diameter Overload Control Mechanisms | 128d? | 2014-06-13 A | 2014-12-09 A | 100% | 2014-06-13 | 2014-12-05 | 126d? | finish no earlier than 2014-12-09 | C4-IETF | 1024h | 1024h | DOCME | 33 | christer.holmberg@ericsson.com | christer.holmberg@ericsson.com | Rel-12 | 64 |  |  |  |
| 2194 | 605 | **Impacts of RFC7044 for introduction of the new History-Info header field** | 131d? | 2014-06-13 A | 2014-12-09 A | 100% | 2014-06-13 | 2014-09-12 | 66d? |  | C1; C3 | 3648h | 3648h | HISTORY_CT | 33 | Deutsche Telekom | Roland Jesske (r.jesske@telekom.de) | Rel-12 | 64 |  | HISTORY_CT |  |
| 2195 | 605.1 | CT1 part of Impacts of RFC7044 for introduction of the new History-Info header field | 128d? | 2014-06-13 A | 2014-12-09 A | 100% | 2014-06-13 | 2014-09-12 | 66d? | finish no earlier than 2014-12-09 | C1 | 1024h | 1024h | HISTORY_CT | 33 | Deutsche Telekom | Roland Jesske (r.jesske@telekom.de) | Rel-12 | 64 |  |  | CP-140609 |
| 2196 | 605.2 | CT3 part of Impacts of RFC7044 for introduction of the new History-Info header field | 66d? | 2014-06-13 A | 2014-09-11 A | 100% | 2014-06-13 | 2014-09-12 | 66d? | finish no earlier than 2014-09-12 | C3 | 528h | 528h | HISTORY_CT | 33 | Deutsche Telekom | Roland Jesske (r.jesske@telekom.de) | Rel-12 | 64 |  |  |  |

Notes:
- 2171: Stage 3. Review the references related to RFC 3265 in the 3GPP IMS specifications and determine the impact of the RFC 6665 changes / Impacted TSs and TRs: Stage 3
- 2172: CP#65 completion 09/14=>12/14. Exception in CP-140620. 3/3/15: 100% cpltd. / Impacted TSs and TRs: 23.218, 24.141, 24.147, 24.229, 24.237, 24.292, 24.337, 24.341, 24.604, 24.606, 24.623, 24.628, 24.629, 24.642
- 2173: CP#62 completed / Impacted TSs and TRs: 29.163, 29.165
- 2174: Added as per CT chair indications on 12th March 2015, no WID, no end date / Impacted TSs and TRs: draft-ietf-sipcore-refer-clarification
- 2175: Added as per CT chair indications on 12th March 2015, no WID, no end date; 14/09/15: 50%->100 / Impacted TSs and TRs: draft-ietf-sipcore-refer-explicit-subscription
- 2176: Added as per CT chair indications on 12th March 2015, no WID, no end date; 14/09/15: 50%->100 / Impacted TSs and TRs: draft-roach-sipcore-6665-clarification
- 2177: Handling of premium rate numbers remained OPEN in Rel-11 (shifted to Rel-12). CP-130384 LS_out sent to SA1 / GSMA informing this TSG CP#60 decision / Impacted TSs and TRs: Stage 3
- 2178: CP#64 completed / Impacted TSs and TRs: 24.229, 24.315
- 2179: CP#65 completed / Impacted TSs and TRs: 29.165
- 2180: CP#65 completion 09/14=>12/14. Exception in CP-140617.Dec.14: 80->85%. 3/3/15: 100% cpltd. / Impacted TSs and TRs: 24.008, 24.301
- 2181: Add optional ICE support as defined in Rel-8 TS (23.228, 24.229) to Iq, Ix, Mn, Mp, Mc interfaces. SA2 Rel-12 TS 23.228 requires support for ICE in eP-CSCF, eIMS-AGW for WebRTC / Impacted TSs and TRs: Stage 2/3
- 2182: CP#65 completed / Impacted TSs and TRs: 23.333, 23.334, 29.232, 29.238, 29.332, 29.333, 29.334
- 2183: CP#64 completed / Impacted TSs and TRs: 29.162, 29.163, 29.292
- 2184: Rel-12 enhancements to business trunking (BusTI). ETSI E2NA(14)000019 asked 3GPP to take responsibility of business communications over IMS: TS 181 019, TS 182 023, TS 182 024, TS 182 025, TR 183 060
- 2185: SP#65 completed. TS 22.519v200 for Approval / Impacted TSs and TRs: New TS 22.519 (ETSI TS 181 019)
- 2186: CP#65 TS 24.525v200 for Approval. TR 24.969v100 for Information. Completion 09/14=>12/14. Exception in CP-140619. Dec.14: 90->100 / Impacted TSs and TRs: New TSs [24.523 (TS 182 023), 24.524 (TS 182 024), 24.525 (TS 182 025)], New TR 24.969 (TR 183 069)
- 2187: SA2 TS 23.228 requires UEs supporting IPv4, IPv6 or both IPv4 and IPv6 IP address formats shall be supported by IMS. Specify procedures to support altc SDP attribute within IMS for terminating communications destined to an enterprise network.
- 2188: CP#65 completion 09/14=>12/14. Exception in CP-140485. Dec.14: 0->100 / Impacted TSs and TRs: 23.334, 29.238, 29.334
- 2189: CP#65 completion 09/14=>12/14. Exception in CP-140611. Dec.14: 0->100 / Impacted TSs and TRs: 24.229
- 2190: CP#65 completion 09/14=>12/14. Exception in CP-140563. Dec.14: 0->100 / Impacted TSs and TRs: 29.162
- 2191: Triggered by TR 29.809 Study on Diameter overload control mechanism (FS_DOCME)
- 2192: CP#65 completion 09/14=>12/14. Exception in CP-140486. Dec.14: 70->100 / Impacted TSs and TRs: 29.228, 29.229, 29.272, 29.273, 29.328, 29.329, 29.336, 29.337, 29.344, 29.345
- 2193: Mar15: In WGLC; 7/3/16: 50%->100 / Impacted TSs and TRs: draft-ietf-dime-ovli
- 2194: IETF updated RFC4244 for History-Info header field to RFC7044. IETF introduced new features which could be useful for 3GPP use cases.
- 2195: CP#65 completion 09/14=>12/14. Exception in CP-140609. Dec.14: 85->100 / Impacted TSs and TRs: 24.229, 24.259, 24.604
- 2196: CP#65 completed / Impacted TSs and TRs: 29.163, 29.165, 29.292

| ID | WBS | Task | Duration | Start | Finish | Complete | Remaining | Baseline start | Baseline finish | Baseline duration | Total slack | Constraint | Resources | Work | Actual work | Acronym | PCG approved | WI rapporteur name | Release | TSG approved | Acronym_3GU_Export | Status Report | MCC resp |
| --- | --- | --- | --- | --- | --- | --- | --- | --- | --- | --- | --- | --- | --- | --- | --- | --- | --- | --- | --- | --- | --- | --- | --- |
| 2197 | 606 | **Indication of NNI Routeing scenarios in SIP requests** | 131d? | 2014-06-13 A | 2014-12-09 | 100% | 0d? | 2014-06-13 | 2014-12-05 | 126d? | 0d |  | C1; C3; IETF | 5456h | 4408h | NNI_RS | 33 | Ericsson | Rel-12 | 64 | NNI_RS |  |  |
| 2198 | 606.1 | CT1 part of Indication of NNI Routeing scenarios in SIP requests | 128d? | 2014-06-13 A | 2014-12-09 A | 100% |  | 2014-06-13 | 2014-09-12 | 66d? |  | finish no earlier than 2014-12-09 | C1 | 1024h | 1024h | NNI_RS | 33 | Ericsson | Rel-12 | 64 |  | CP-140613 |  |
| 2199 | 606.2 | (IETF) CT1 part of Indication of NNI Routeing scenarios in SIP requests (holmberg-dispatch-iotl) | 95d? | 2014-06-13 A | 2014-12-09 A | 100% |  | 2014-06-13 | 2014-12-05 | 93d? |  | finish no earlier than 2014-12-09 | C1-IETF | 760h | 760h | NNI_RS | 33 | christer.holmberg@ericsson.com | Rel-12 | 64 |  |  |  |
| 2200 | 606.3 | CT3 part of Indication of NNI Routeing scenarios in SIP requests | 66d? | 2014-06-13 A | 2014-09-11 A | 100% |  | 2014-06-13 | 2014-09-12 | 66d? |  | finish no earlier than 2014-09-12 | C3 | 528h | 528h | NNI_RS | 33 | Ericsson | Rel-12 | 64 |  |  |  |
| 2201 | 607 | Unstructured Supplementary Service Data (USSD) method selection (Stage 3) | 3d? | 2014-06-11 A | 2014-06-13 A | 100% |  | 2014-06-11 | 2014-06-13 | 3d? |  | finish no earlier than 2014-06-13 | C1 | 24h | 24h | USSD_MS | 33 | Ericsson | Rel-12 | 64 | USSD_MS |  |  |
| 2202 | 608 | Representational State Transfer (REST) reference point between Application Function (AF) and Protocol Converter (PC) | 128d? | 2014-06-13 A | 2014-12-09 A | 100% |  | 2014-06-13 | 2014-09-12 | 66d? |  | finish no earlier than 2014-12-09 | C3 | 1024h | 1024h | REST_AF_PC | 33 | Alcatel-Lucent | Rel-12 | 64 | REST_AF_PC | CP-140561 |  |
| 2203 | 609 | **Overload Control for PCC based Diameter applications** | 131d? | 2014-06-13 A | 2014-12-09 A | 100% |  | 2014-06-13 | 2014-12-05 | 126d? |  |  | C3; IETF | 3648h | 3648h | DOCME-PCC | 33 | Huawei | Rel-12 | 64 | DOCME-PCC |  |  |
| 2204 | 609.1 | CT3 part of Overload Control for PCC based Diameter applications | 66d? | 2014-06-13 A | 2014-09-11 A | 100% |  | 2014-06-13 | 2014-09-12 | 66d? |  | finish no earlier than 2014-09-12 | C3 | 528h | 528h | DOCME-PCC | 33 | Huawei | Rel-12 | 64 |  |  |  |
| 2205 | 609.2 | (IETF) Overload Control for PCC based Diameter applications | 128d? | 2014-06-13 A | 2014-12-09 A | 100% |  | 2014-06-13 | 2014-12-05 | 126d? |  | finish no earlier than 2014-12-09 | C3-IETF | 1024h | 1024h | DOCME-PCC | 33 | christer.holmberg@ericsson.com | Rel-12 | 64 |  |  |  |
| 2206 | 610 | Network Initiated USSD Simulation Services in IMS | 63d? | 2014-09-12 A | 2014-12-09 A | 100% |  |  |  |  |  | finish no earlier than 2014-12-09 | C1 | 504h | 504h | USSI-NET | 33 | AT&T | Rel-12 | 65 | USSI-NET | CP-140610 |  |
| 2207 | 611 | **Introduction of ER-GSM band for GSM-R** | 651d? | 2011-09-16 A | 2014-02-28 A | 100% |  | 2011-09-16 | 2014-02-28 | 651d? |  |  | G1; C1; G3new | 26496h | 26496h | RT_ERGSM | 27 | Kapsch Carriercom, Sierra Wireless | Rel-12 | 51 | RT_ERGSM |  | Paolo |
| 2208 | 611.1 | GERAN1 part of Introduction of ER-GSM band for GSM-R | 647d? | 2011-09-16 A | 2014-02-28 A | 100% |  | 2011-09-16 | 2014-02-28 | 647d? |  | finish no earlier than 2014-02-28 | G1 | 5168h | 5168h | RT_ERGSM | 27 | Kapsch Carriercom, Sierra Wireless | Rel-12 | 51 |  |  | Paolo |
| 2209 | 611.2 | Test part: Introduction of ER-GSM band for GSM-R | 131d? | 2013-09-02 A | 2014-02-28 A | 100% |  | 2013-09-02 | 2014-02-28 | 131d? |  | finish no earlier than 2014-02-28 | G3new | 1048h | 1048h | RT_ERGSM | 31 | Kapsch Carriercom, Sierra Wireless | Rel-12 | 59 |  |  | Ingbert |
| 2210 | 611.3 | CT1 part of Introduction of ER-GSM band for GSM-R | 582d? | 2011-09-28 A | 2013-12-06 A | 100% |  | 2011-09-28 | 2013-12-06 | 582d? |  | finish no earlier than 2013-12-06 | C1 | 4656h | 4656h | RT_ERGSM | 27 | Kapsch Carriercom, Sierra Wireless | Rel-12 | 53 |  |  | Frederic |
| 2211 | 612 | **Downlink Multi Carrier GERAN** | 666d? | 2012-09-10 A | 2015-03-13 | 91% | 61.92d? | 2012-09-10 | 2014-09-12 | 533d? | 5412d |  | G2; G1; C1; G3new | 34536h | 12164.8h | DMCG | 29 | Ericsson | Rel-12 | 55 | DMCG |  | Gert |
| 2212 | 612.1 | Core part: Downlink Multi Carrier GERAN | 229d? | 2013-07-22 A | 2014-05-30 A | 100% |  | 2013-07-22 | 2014-05-30 | 229d? |  | finish no earlier than 2014-05-30 | G2; G1 | 3664h | 3664h | DMCG | 29 | Ericsson | Rel-12 | 55 |  |  | Gert |
| 2213 | 612.2 | CT part: Downlink Multi Carrier GERAN | 533d? | 2012-09-10 A | 2014-09-11 A | 100% |  | 2012-09-10 | 2014-09-12 | 533d? |  | finish no earlier than 2014-09-12 | C1 | 4264h | 4264h | DMCG | 29 | Ericsson | Rel-12 | 55 |  |  | Frederic |
| 2214 | 612.3 | Test part: Downlink Multi Carrier GERAN | 662d? | 2012-09-10 A | 2015-03-13 | 80% | 132.4d? | 2012-09-10 | 2014-08-29 | 522d? | 5412d | finish no earlier than 2015-03-13 | G3new | 5296h | 4236.8h | DMCG-MStest | 29 | ST-Ericsson | Rel-12 | 55 | DMCG-MStest |  | Ingbert |
| 2215 | 613 | **Mobile Station Receive Diversity (MSRD) for Voice Services over Adaptive Multi-user channels on One Slot (VAMOS)** | 459d? | 2013-03-01 A | 2014-11-21 A | 100% |  | 2013-03-01 | 2014-08-29 | 396d? |  |  | G1; G2; C1; G3new | 24064h | 24064h | MSRD_VAMOS | 30 | Nokia Networks, Microsoft | Rel-12 | 57 | MSRD_VAMOS | GP-140579 | Paolo |
| 2216 | 613.1 | CT1 introduction of MS capability support for MS supporting MSRD for VAMOS | 205d? | 2013-03-01 A | 2013-12-06 A | 100% |  | 2013-03-01 | 2013-12-06 | 205d? |  | finish no earlier than 2013-12-06 | C1 | 1640h | 1640h | MSRD_VAMOS | 30 | Nokia Networks, Microsoft | Rel-12 | 57 |  |  | Frederic |
| 2217 | 613.2 | MSRD for VAMOS - Performance Requirements | 257.5d? | 2013-11-28 A | 2014-11-21 A | 100% |  | 2013-11-28 | 2014-08-29 | 197.5d? |  | finish no earlier than 2014-11-21 | G1; G2 | 4120h | 4120h | MSRD_VAMOS-PerfReq | 30 | Nokia Networks, Microsoft | Rel-12 | 57 | MSRD_VAMOS-PerfReq | GP-140579 | Paolo |
| 2218 | 613.3 | MSRD for VAMOS - MS Conformance Test | 453d? | 2013-03-06 A | 2014-11-21 A | 100% |  | 2013-03-06 | 2014-08-29 | 393d? |  | finish no earlier than 2014-11-21 | G3new | 3616h | 3616h | MSRD_VAMOS-Test | 30 | Nokia Networks, Microsoft | Rel-12 | 57 | MSRD_VAMOS-Test | GP-140579 | Ingbert |
| 2219 | 614 | **New Training Sequence Codes (TSC) for GERAN** | 277d? | 2013-11-22 A | 2014-12-09 | 93% | 18.18d? | 2013-11-22 | 2014-08-29 | 202d? | 5480d |  | G1; G2; C1 | 11184h | 10449.7h | NewToN | 32 | Ericsson | Rel-12 | 60 | NewToN | GP-140542 | Paolo |
| 2220 | 614.1 | GERAN1 part of New Training Sequence Codes (TSC) for GERAN | 261d? | 2013-11-22 A | 2014-11-21 A | 100% |  | 2013-11-22 | 2014-08-29 | 201d? |  | finish no earlier than 2014-11-21 | G1 | 2088h | 2088h | NewToN | 32 | Ericsson | Rel-12 | 60 |  | GP-140542 | Paolo |
| 2221 | 614.2 | GERAN2 part of New Training Sequence Codes (TSC) for GERAN | 261d? | 2013-11-22 A | 2014-11-21 | 80% | 52.2d? | 2013-11-22 | 2014-08-29 | 201d? | 5492d | finish no earlier than 2014-11-21 | G2 | 2088h | 1670.4h | NewToN | 32 | Ericsson | Rel-12 | 60 |  | GP-140542 | Gert |
| 2222 | 614.3 | CT1 part of New Training Sequence Codes (TSC) for GERAN (Stage 3) | 273d? | 2013-11-22 A | 2014-12-09 A | 100% |  | 2013-11-22 | 2014-08-29 | 201d? |  | finish no earlier than 2014-12-09 | C1 | 2184h | 2184h | NewToN | 32 | Ericsson | Rel-12 | 60 |  | CP-140604 | Frederic |

Notes:
- 2197: Triggered by TR 24.802 Study on Indication of Network to Network Interface (NNI) Routeing scenarios in SIP requests UID_580025 / WI rapporteur e-mail: Jan.Holm@ericsson.com
- 2198: CP#65 completion 09/14=>12/14. Exception in CP-140613. Dec.14: 95->100 / Impacted TSs and TRs: 24.229 / WI rapporteur e-mail: Jan.Holm@ericsson.com
- 2199: Publication requested; 7/3/16: 50%->100 / Impacted TSs and TRs: draft-holmberg-dispatch-iotl / WI rapporteur e-mail: christer.holmberg@ericsson.com
- 2200: CP#65 completed / Impacted TSs and TRs: 29.079, 29.165 / WI rapporteur e-mail: Jan.Holm@ericsson.com
- 2201: CP#64 approved WID & completed. Related to R11 USSD simulation service in IMS (delivery of UE originating USSD request using IMS, I.e. introduce 2nd method for delivery of UE originating USSD request to network (additional to USSD using CS domain) / Impacted TSs and TRs: 24.173, 24.390, New TS 24.391 / WI rapporteur e-mail: ivo.sedlacek@ericsson.com
- 2202: CP#65 completion 09/14=>12/14. TS 29.201v200 for Approval. Exception in CP-140561. Dec.14: 80->100 / Impacted TSs and TRs: 29.213, 29.214, new TS 29.201 / WI rapporteur e-mail: horst.brinkmann@alcatel-lucent.com
- 2203: Triggered by TR 29.809 Study on Diameter overload control mechanism (FS_DOCME) / WI rapporteur e-mail: Xia Haitao (xiahaitao@huawei.com)
- 2204: CP#65 completed / Impacted TSs and TRs: 29.212, 29.213, 29.214 / WI rapporteur e-mail: Xia Haitao (xiahaitao@huawei.com)
- 2205: work in progress; 7/3/16: 50%->100 / Impacted TSs and TRs: draft-ietf-dime-ovli / WI rapporteur e-mail: christer.holmberg@ericsson.com
- 2206: CP#65 exception in CP-140610. Dec.14: 75->100 / Impacted TSs and TRs: 24.390 / WI rapporteur e-mail: Martin Dolly (md3135@att.com)
- 2207: Use of band 870-876/915-921 MHz for land mobile service on national possibilities/market demand - as per ECC/DEC/(04)06. Introduction of ERGSM band, Performance requirements and Deployment scenarios. / Impacted TSs and TRs: GERAN / WI rapporteur e-mail: thomas.chatelet@kapsch.net, Rémi Lascoux (rlascoux@sierrawireless.com)
- 2208: GP#61 completed. GP#51 approved WID / Impacted TSs and TRs: 45.001, 45.005, 45.008, 45.050 / WI rapporteur e-mail: thomas.chatelet@kapsch.net, Rémi Lascoux (rlascoux@sierrawireless.com)
- 2209: GP#61 completed / Impacted TSs and TRs: 51.010, 51.021 / WI rapporteur e-mail: thomas.chatelet@kapsch.net, Rémi Lascoux (rlascoux@sierrawireless.com)
- 2210: CP#62 completed. Added ERGSM capability indication (24.008 CR#2469R1) / Impacted TSs and TRs: 24.008 / WI rapporteur e-mail: thomas.chatelet@kapsch.net, Rémi Lascoux (rlascoux@sierrawireless.com)
- 2211: Linked to Rel-7 Downlink Dual Carrier UID_50579 (Previous work on multiple carriers on the downlink was limited to two). Ref: TR 45.912 Feasibility study for evolved GERAN, TS 43.064 GPRS Stage 2 / Impacted TSs and TRs: GERAN / WI rapporteur e-mail: paul.schliwa-bertling@ericsson.com
- 2212: GP#62 completed. GP#55 approved WID / Impacted TSs and TRs: 43.064, 44.004, 44.018, 44.060, 45.002, 45.003, 45.005, 45.008, 48.018 / WI rapporteur e-mail: paul.schliwa-bertling@ericsson.com
- 2213: CP#65 completed / Impacted TSs and TRs: 24.008 / WI rapporteur e-mail: paul.schliwa-bertling@ericsson.com
- 2214: GP#63 completion 08/14=>11/14. Dec.14: 35->80%, CD:11/14->03/15 / Impacted TSs and TRs: 51.010-1, 51.010-2 / WI rapporteur e-mail: hakan.e.grunditz@stericsson.com
- 2215: GP#63 completion 08/14=>11/14. Exception in GP-140579. Linked to Rel-7 Mobile Station Receive Diversity (DARP Phase II) UID_50569, Rel-9 Voice Services over Adaptive Multiuser channels on One Slot (VAMOS) UID_420002 / Impacted TSs and TRs: GERAN / WI rapporteur e-mail: Khairul Hasan (Nokia Networks), Markku Tarkiainen (Nokia=>Microsoft)
- 2216: CP#62 completed / Impacted TSs and TRs: 24.008 / WI rapporteur e-mail: Khairul Hasan (Nokia Networks), Markku Tarkiainen (Nokia=>Microsoft)
- 2217: GP#63 completion 08/14=>11/14. Exception in GP-140579. Dec.14: 95->100 / Impacted TSs and TRs: 44.018, 45.001, 45.002, 45.005, 45.008, 45.009 / WI rapporteur e-mail: Khairul Hasan (Nokia Networks), Markku Tarkiainen (Nokia=>Microsoft)
- 2218: GP#63 completion 08/14=>11/14. Exception in GP-140579. Dec.14: 85->100 / Impacted TSs and TRs: 51.010-1, 51.010-2 / WI rapporteur e-mail: Khairul Hasan (Nokia Networks), Markku Tarkiainen (Nokia=>Microsoft)
- 2219: GP#63 completion 08/14=>11/14. Exception in GP-140542. GP#60 approved WID. Triggered by GP-131041, GP#40 GP-081949 (WID VAMOS). Linked to Rel-9 VAMOS (Previous work where new TSCs were defined for GMSK modulation) UID_420002 / Impacted TSs and TRs: GERAN / WI rapporteur e-mail: Mårten Sundberg
- 2220: GP#63 completion 08/14=>11/14. Exception in GP-140542. Dec.14: 80->100% / Impacted TSs and TRs: 45.001, 45.002, 45.008, 45.009, 45.050 / WI rapporteur e-mail: Mårten Sundberg
- 2221: GP#63 completion 08/14=>11/14. Exception in GP-140542. / Impacted TSs and TRs: 44.018, 44.060 / WI rapporteur e-mail: Mårten Sundberg
- 2222: CP#65 completion 09/14=>12/14. CP#65 exception in CP-140604. 3/3/15: 100% cpltd. / Impacted TSs and TRs: 24.008 / WI rapporteur e-mail: Mårten Sundberg

| ID | WBS | Task | Duration | Start | Finish | Complete | Remaining | Baseline start | Baseline finish | Baseline duration | Total slack | Constraint | Resources | Work | Actual work | Acronym | PCG approved | WI rapporteur name | Release | TSG approved | MCC resp | Acronym_3GU_Export | Status Report | Special Focus Doc | PCG stopped | TSG stopped |
| --- | --- | --- | --- | --- | --- | --- | --- | --- | --- | --- | --- | --- | --- | --- | --- | --- | --- | --- | --- | --- | --- | --- | --- | --- | --- | --- |
| 2223 | 615 | **Verification of radiated multi-antenna reception performance of UEs in LTE/UMTS** | 469d? | 2012-03-05 A | 2013-12-06 A | 100% |  | 2012-03-05 | 2013-12-06 | 469d? |  |  | R4 | 7464h | 7464h | HSPA_LTE_measRP_MIMO | 28 | Vodafone | Rel-12 | 55 | Issam | HSPA_LTE_measRP_MIMO |  |  |  |  |
| 2224 | 615.1 | Perf. Part: Verification of radiated multi-antenna reception performance of UEs in LTE/UMTS | 464d? | 2012-03-05 A | 2013-12-06 A | 100% |  | 2012-03-05 | 2013-12-06 | 464d? |  | finish no earlier than 2013-12-06 | R4 | 3712h | 3712h | HSPA_LTE_measRP_MIMO-Perf | 28 | Vodafone | Rel-12 | 55 | Issam | HSPA_LTE_measRP_MIMO-Perf | RP-131507 |  |  |  |
| 2225 | 616 | **Further enhancements to H(e)NB mobility - Part 3 (Stage 2/3)** | 330d? | 2012-09-12 A | 2013-12-06 A | 100% |  | 2012-09-12 | 2013-12-06 | 330d? |  |  | R3; R2 | 10560h | 10560h | EHNB_enh3 | 29 | Alcatel-Lucent | Rel-12 | 57 | Juha | EHNB_enh3 |  | HNB |  |  |
| 2226 | 616.1 | Core part: Further enhancements to H(e)NB mobility - Part 3 | 330d? | 2012-09-12 A | 2013-12-06 A | 100% |  | 2012-09-12 | 2013-12-06 | 330d? |  | finish no earlier than 2013-12-06 | R3; R2 | 5280h | 5280h | EHNB_enh3-Core | 29 | Alcatel-Lucent | Rel-12 | 57 | Juha | EHNB_enh3-Core | RP-131508 | HNB |  |  |
| 2227 | 617 | **Support for BeiDou Navigation Satellite System (BDS) for UTRA and LTE** | 604d? | 2013-03-04 A | 2015-06-15 A | 100% |  | 2013-03-04 | 2015-06-12 | 600d? |  |  | R2; R3; R4; R5 | 31680h | 31680h | LCS_BDS | 30 | CATR | Rel-12 | 59 | Yong-Jun | LCS_BDS |  |  |  |  |
| 2228 | 617.1 | Core part: Support for BeiDou Navigation Satellite System (BDS) for UTRA | 204d? | 2013-06-02 A | 2014-03-06 A | 100% |  | 2013-06-02 | 2014-03-06 | 204d? |  | finish no earlier than 2014-03-06 | R2; R3 | 3264h | 3264h | LCS_BDS-UTRA-Core | 30 | ZTE | Rel-12 | 59 | Yong-Jun | LCS_BDS-UTRA-Core | RP-131500 |  |  |  |
| 2229 | 617.2 | Perf. part: Support for BeiDou Navigation Satellite System (BDS) for UTRA | 336d? | 2013-03-07 A | 2014-06-13 A | 100% |  | 2013-03-07 | 2014-06-13 | 336d? |  | finish no earlier than 2014-06-13 | R4 | 2688h | 2688h | LCS_BDS-UTRA-Perf | 30 | ZTE | Rel-12 | 59 | Issam | LCS_BDS-UTRA-Perf | RP-140714 |  |  |  |
| 2230 | 617.3 | Core part: Support for BeiDou Navigation Satellite System (BDS) for LTE | 202d? | 2013-03-04 A | 2013-12-06 A | 100% |  | 2013-03-04 | 2013-12-06 | 202d? |  | finish no earlier than 2013-12-06 | R2 | 1616h | 1616h | LCS_BDS-LTE-Core | 30 | CATR | Rel-12 | 59 | Yong-Jun | LCS_BDS-LTE-Core | RP-131525 |  |  |  |
| 2231 | 617.4 | Perf. part: Support for BeiDou Navigation Satellite System (BDS) for LTE | 336d? | 2013-03-07 A | 2014-06-13 A | 100% |  | 2013-03-07 | 2014-06-13 | 336d? |  | finish no earlier than 2014-06-13 | R4 | 2688h | 2688h | LCS_BDS-LTE-Perf | 30 | ZTE | Rel-12 | 59 | Issam | LCS_BDS-LTE-Perf | RP-140713 |  |  |  |
| 2232 | 617.5 | Test part: BeiDou Navigation Satellite System (BDS) Positioning Support for LTE and UMTS | 262d? | 2014-06-15 A | 2015-06-15 A | 100% |  | 2014-06-13 | 2015-06-12 | 261d? |  | finish no earlier than 2015-06-15 | R5 | 2096h | 2096h | LCS_BDS-UEConTest | 33 | CATT | Rel-12 | 64 |  | LCS_BDS-UEConTest | RP-150656 |  |  |  |
| 2233 | 618 | **Support for BeiDou Navigation Satellite System (BDS) for LCS in GERAN** | 345d? | 2013-11-22 A | 2015-03-13 | 93% | 25.19d? | 2013-11-22 | 2014-11-21 | 262d? | 5412d |  | G2; G1; G3new | 14213.2h | 5848.39h | LCS_BDS_GERAN | 32 | ZTE | Rel-12 | 60 | Gert | LCS_BDS_GERAN |  |  |  |  |
| 2234 | 618.1 | GERAN2 part of Support for BeiDou Navigation Satellite System (BDS) for LCS in GERAN | 201d? | 2013-11-22 A | 2014-08-29 A | 100% |  | 2013-11-22 | 2014-08-29 | 201d? |  | finish no earlier than 2014-08-29 | G2 | 1608h | 1608h | LCS_BDS_GERAN | 32 | ZTE | Rel-12 | 60 | Gert |  |  |  |  |  |
| 2235 | 618.2 | GERAN1 part of Support for BeiDou Navigation Satellite System (BDS) for LCS in GERAN | 201d? | 2013-11-22 A | 2014-08-29 A | 100% |  | 2013-11-22 | 2014-08-29 | 201d? |  | finish no earlier than 2014-08-29 | G1 | 1608h | 1608h | LCS_BDS_GERAN | 32 | ZTE | Rel-12 | 60 | Paolo |  |  |  |  |  |
| 2236 | 618.3 | Support for BeiDou Navigation Satellite System (BDS) for LCS in GERAN3new | 272d? | 2014-03-01 A | 2015-03-13 | 80% | 54.4d? | 2014-02-28 | 2014-11-21 | 192d? | 5412d | finish no earlier than 2015-03-13 | G3new | 2176h | 1740.8h | LCS_BDS_GERAN-GERAN3new | 32 | CATR | Rel-12 | 61 | Ingbert | LCS_BDS_GERAN-GERAN3new |  |  |  |  |
| 2237 | 618.4 | Deleted - Test part: Support for BeiDou Navigation Satellite System (BDS) for LCS in GERAN | 71d? | 2013-11-22 A | 2014-02-28 A | 100% |  | 2013-11-22 | 2014-02-28 | 71d? |  | finish no earlier than 2014-08-29 | G3new | 565.19h | 565.19h | LCS_BDS_GERAN-MStest | 32 | ZTE | Rel-12 | 60 | Ingbert | LCS_BDS_GERAN-MStest |  |  | PCG-32 | GP-61 |
| 2238 | 619 | **Deleted - New Base Station specification structure** | 127d? | 2013-06-18 A | 2013-12-06 A | 100% |  | 2013-06-18 | 2013-12-06 | 127d? |  |  | R4 | 3024h | 3024h | BSspec_struc | 31 | Ericsson | Rel-12 | 60 | Issam | BSspec_struc |  |  | PCG-32 | RP-62 |
| 2239 | 619.1 | Deleted - Core part: New Base Station specification structure | 126d? | 2013-06-18 A | 2013-12-06 A | 100% |  | 2013-06-18 | 2013-12-06 | 126d? |  | finish no earlier than 2013-12-06 | R4 | 1008h | 1008h | BSspec_struc-Core | 31 | Ericsson | Rel-12 | 60 | Issam | BSspec_struc-Core | RP-131513 |  | PCG-32 | RP-62 |
| 2240 | 619.2 | Deleted - Perf. part: New Base Station specification structure | 125d? | 2013-06-20 A | 2013-12-06 A | 100% |  | 2013-06-20 | 2013-12-06 | 125d? |  | finish no earlier than 2013-12-06 | R4 | 1000h | 1000h | BSspec_struc-Perf | 31 | Ericsson | Rel-12 | 60 | Issam | BSspec_struc-Perf | RP-131514 |  | PCG-32 | RP-62 |
| 2241 | 620 | **L-band for Supplemental Downlink in E-UTRA and UTRA** | 659d? | 2013-06-17 A | 2015-12-15 A | 100% |  | 2013-06-17 | 2014-06-13 | 264d? |  |  | R4; R2; R3 | 21600h | 21600h | LTE_UTRA_SDL_BandL | 31 | Orange | Rel-12 | 60 | Issam | LTE_UTRA_SDL_BandL |  |  |  |  |
| 2242 | 620.1 | Core part: L-band for Supplemental Downlink in E-UTRA and UTRA | 87.33d? | 2014-02-13 A | 2014-06-13 A | 100% |  | 2014-02-13 | 2014-06-13 | 87.33d? |  | finish no earlier than 2014-06-13 | R4; R2; R3 | 2096h | 2096h | LTE_UTRA_SDL_BandL-Core | 31 | Orange | Rel-12 | 60 | Issam | LTE_UTRA_SDL_BandL-Core | RP-140633 |  |  |  |
| 2243 | 620.2 | Perf. part: L-band for Supplemental Downlink in E-UTRA and UTRA | 264d? | 2013-06-17 A | 2014-06-13 A | 100% |  | 2013-06-17 | 2014-06-13 | 264d? |  | finish no earlier than 2014-06-13 | R4 | 2112h | 2112h | LTE_UTRA_SDL_BandL-Perf | 31 | Orange | Rel-12 | 60 | Issam | LTE_UTRA_SDL_BandL-Perf | RP-140633 |  |  |  |
| 2244 | 620.3 | UE Conformance Test Aspects - L-band for Supplemental Downlink in E-UTRA and UTRA | 197d? | 2015-03-16 A | 2015-12-15 A | 100% |  |  |  |  |  | finish no earlier than 2015-12-15 | R5 | 1576h | 1576h | LTE_UTRA_SDL_BandL-UEConTest | 34 | Ericsson | Rel-12 | 67 |  |  | RP-151163 |  |  |  |
| 2245 | 621 | **LTE-HRPD (High Rate Packet Data in 3GPP2) inter-RAT SON** | 263d? | 2013-06-18 A | 2014-06-13 A | 100% |  | 2013-06-18 | 2014-06-13 | 263d? |  |  | R3; S2; C4; G2 | 11096h | 11096h | LTE_HRPD_SON | 31 | China Telecom | Rel-12 | 60 | Juha | LTE_HRPD_SON |  | SON |  |  |
| 2246 | 621.1 | Stage 2 for LTE-HRPD (High Rate Packet Data in 3GPP2) inter-RAT SON | 67d? | 2013-09-11 A | 2013-12-11 A | 100% |  | 2013-09-11 | 2013-12-11 | 67d? |  | finish no earlier than 2013-09-11 | S2 | 528h | 528h | LTE_HRPD_SON | 31 | Huawei | Rel-12 | 61 | Maurice |  |  |  |  |  |
| 2247 | 621.2 | Core part: LTE-HRPD (High Rate Packet Data in 3GPP2) inter-RAT SON | 263d? | 2013-06-18 A | 2014-06-13 A | 100% |  | 2013-06-18 | 2014-06-13 | 263d? |  | finish no earlier than 2014-06-13 | R3 | 2088h | 2088h | LTE_HRPD_SON-Core | 31 | China Telecom | Rel-12 | 60 | Juha | LTE_HRPD_SON-Core | RP-140745 |  |  |  |
| 2248 | 621.3 | CT aspects for LTE-HRPD (High Rate Packet Data in 3GPP2) inter-RAT SON (Stage 3) | 3d? | 2013-09-04 A | 2013-09-06 A | 100% |  | 2013-09-04 | 2013-09-06 | 3d? |  | finish no earlier than 2013-09-06 | C4 | 24h | 24h | LTE_HRPD_SON-CT | 31 | Huawei | Rel-12 | 61 | Kimmo | LTE_HRPD_SON-CT |  |  |  |  |
| 2249 | 621.4 | GERAN aspects for LTE-HRPD inter-RAT SON, RAN Information Management (RIM) - Stage 3 | 5d? | 2013-08-26 A | 2013-08-30 A | 100% |  | 2013-08-26 | 2013-08-30 | 5d? |  | finish no earlier than 2013-09-06 | G2 | 40h | 40h | LTE_HRPD_SON-RIM | 31 | Alcatel-Lucent | Rel-12 | 59 | Gert | LTE_HRPD_SON-RIM |  |  |  |  |

Notes:
- 2223: RP#59 moved to Rel-12. Triggered by FS_HSPA_LTE_measRP_MIMO_multi-antenna. Core functionality exists since Rel-6 & Rel-7 (MIMO). Adds a very generic test method to test UEs with 2 or more Rx antennas / Impacted TSs and TRs: UTRA, LTE / WI rapporteur e-mail: Luis Anaya
- 2224: RP#62 completed. Rx diversity (defined as Rel-6 HSDPA RAN4 enhanced type 1 req.) & MIMO (defined as Rel-7 HSDPA MIMO for HSPA). Rx diversity & MIMO (defined as part of Rel-8 basic LTE WI) / Impacted TSs and TRs: new TR 37.977 / WI rapporteur e-mail: luis.anaya@vodafone.com
- 2225: Triggered by FS_EHNB_enh (TR 37.803) / Impacted TSs and TRs: UTRA, LTE / WI rapporteur e-mail: Martin.Warner@alcatel-lucent.com
- 2226: RP#62 completed / Impacted TSs and TRs: 25.304, 25.331, 25.367, 25.467, 25.469, 36.300, 36.331 / WI rapporteur e-mail: Martin.Warner@alcatel-lucent.com
- 2227: BeiDou = Chinese Navigation Satellite System. Location Services (LCS) TS 22.071 Stage 1, TS 23.271 Stage 2 / Impacted TSs and TRs: UTRA, LTE / WI rapporteur e-mail: Ying Du (duying1@catr.cn)
- 2228: RP#62 completed / Impacted TSs and TRs: 25.305, 25.306, 25.331, 25.453, 25.413, 25.423, 25.433 / WI rapporteur e-mail: Huang He (huang.he4@zte.com.cn)
- 2229: RP#64 completed. TS 25.173v100 for 1-step Approval / Impacted TSs and TRs: 25.172 (FDD), new TS 25.173 (TDD) / WI rapporteur e-mail: Ling Soonleh (soonleh.ling@zte.com.cn)
- 2230: RP#62 completed / Impacted TSs and TRs: 36.305, 36.355 / WI rapporteur e-mail: Ying Du (duying1@catr.cn)
- 2231: RP#64 completed / Impacted TSs and TRs: 36.171 / WI rapporteur e-mail: Ling Soonleh (soonleh.ling@zte.com.cn)
- 2232: ; Stat Rep: RP-141350->RP-141950 1st Apr 15: Compl:80%->90% 1st Apr 15: Stat Rep: RP-141950->RP-150357 03/07/15: Compl:90%->100% 03/07/15: Stat Rep: RP-150357->RP-150656 / Impacted TSs and TRs: 34.108, 36.508, 37.571-1, 37.571-2, 37.571-3, 37.571-4, 37.571-5 / WI rapporteur e-mail: Chen Xiaiozhong (chenxiaozhong@catt.cn)
- 2233: GP#60 approved WID. Based on the same framework used in Rel-8 Support for Additional Navigation Satellite Systems (ANSS) for LCS UID_38001 / Impacted TSs and TRs: GERAN / WI rapporteur e-mail: Wang Xinhui (wangxinhui@zte.com.cn)
- 2234: GP#63 completed / Impacted TSs and TRs: 44.031, 49.031, 44.071, 48.031 / WI rapporteur e-mail: Wang Xinhui (wangxinhui@zte.com.cn)
- 2235: GP#63 completed / Impacted TSs and TRs: 43.059, 45.005 / WI rapporteur e-mail: Wang Xinhui (wangxinhui@zte.com.cn)
- 2236: Dec.14: 25->80%, CD: 11/14->03/15 / Impacted TSs and TRs: 51010-1, 51.010-2, 51.010-7 / WI rapporteur e-mail: Zhou DaiWei, China Academy of Telecommunication Research, zhoudaiwei@catr.cn
- 2237: GP#61 stopped / Impacted TSs and TRs: 51.010-1 / WI rapporteur e-mail: Wang Xinhui (wangxinhui@zte.com.cn)
- 2238: Triggered by Rel-12 TR 37.810 Study on Base Station specification structure (FS_BSspec_struc) / Impacted TSs and TRs: UTRA, LTE, MSR / WI rapporteur e-mail: johan.skold@ericsson.com
- 2239: RP#62 stopped (at 20% completion) / Impacted TSs and TRs: 25.104, 25.105, 36.104, 37.104, 37.810, New TR 37.811 (New BS specification structure), New TS 37.xya (New RF core specification) / WI rapporteur e-mail: johan.skold@ericsson.com
- 2240: RP#62 stopped (at 0% completion) / Impacted TSs and TRs: 25.113, 25.141, 25.142, 36.113, 36.141, 37.113, 37.141, 37.810, New TS 37.xyz (New RF test specification, New TS 37.xyw (ew EMC specification) / WI rapporteur e-mail: johan.skold@ericsson.com
- 2241: ECC(12)052 CEPT decision to harmonize 1452-1492 MHz (L-band) for mobile communications Supplemental Downlink (SDL) => standardize L-band and corresponding E-UTRA and UTRA requirements for SDL operation in Region 1 / Impacted TSs and TRs: UTRA, LTE / WI rapporteur e-mail: olfa.benhaddada@orange.com
- 2242: RP#64 completed. RP#65 forgotten TR 37.814 v100 for 1-step Approval / Impacted TSs and TRs: 25.101, 25.104, 25.113, 25.133, 25.307, 25.327, 25.461, 25.466, 34.124, 36.101, 36.104, 36.113, 36.124, 36.133, 36.307, 36.331, 37.104, 37.113, new TR 37.814 / WI rapporteur e-mail: olfa.benhaddada@orange.com
- 2243: RP#64 completed / Impacted TSs and TRs: 25.133, 25.141, 25.307, 25.327, 36.133, 36.141, 36.307, 37.141 / WI rapporteur e-mail: olfa.benhaddada@orange.com
- 2244: 03/07/15: Compl:0%->85% 03/07/15: CD:Mon 15/06/15->Tue 15/09/15 03/07/15: WID: RP-150134->RP-150835 03/07/15: Stat Rep: ->RP-150830 29/09/15: Compl:85%->90% 29/09/15: CD:Tue 15/09/15->Tue 15/12/15 29/09/15: Stat Rep: RP-150830->RP-151163; 1/1/16
- 2245: Triggered by Rel-12 TR 37.813 (FS_LTE_HRPD_SON). SA2 should verify the architecture solution in TR 37.813 for inter-RAT load balancing between LTE-HRPD. CT4 should specify the RIM extension to support the feature. / Impacted TSs and TRs: UTRA, LTE / WI rapporteur e-mail: Jinlian_wu@189.cn
- 2246: SP#62 completed / Impacted TSs and TRs: 23.402 / WI rapporteur e-mail: Huan Li (ivy.lihuan@huawei.com)
- 2247: RP#64 completed / Impacted TSs and TRs: 36.300, 36.413 / WI rapporteur e-mail: Jinlian_wu@189.cn
- 2248: CP#61 WID approved & Completed / Impacted TSs and TRs: 29.274, 29.276, 29.280 / WI rapporteur e-mail: Xiaoyan SHI (sean.shixiaoyan@huawei.com
- 2249: GP#59 WID approved & Completed / Impacted TSs and TRs: 48.018 / WI rapporteur e-mail: marguerite.woch@alcatel-lucent.com

| ID | WBS | Task | Duration | Start | Finish | Complete | Remaining | Baseline start | Baseline finish | Baseline duration | Total slack | Constraint | Resources | Work | Actual work | Acronym | PCG approved | Impacted TSs and TRs | WI rapporteur name | WI rapporteur e-mail | Release | TSG approved | MCC resp | Acronym_3GU_Export | Status Report | Special Focus Doc | PCG stopped | TSG stopped |
| --- | --- | --- | --- | --- | --- | --- | --- | --- | --- | --- | --- | --- | --- | --- | --- | --- | --- | --- | --- | --- | --- | --- | --- | --- | --- | --- | --- | --- |
| 2250 | 622 | **Increasing the minimum number of carriers for UE monitoring in UTRA and E-UTRA** | 1180d? | 2013-12-15 A | 2018-06-15 | 61% | 463.37d? | 2013-12-09 | 2015-03-13 | 331d? | 4561d |  | R4; R2 | 22844.4h | 9474.4h | LTE_UTRA_IncMon | 32 | UTRA, LTE | Ericsson | christopher.callender@ericsson.com | Rel-12 | 62 | Issam | LTE_UTRA_IncMon |  |  |  |  |
| 2251 | 622.1 | Core part: Increasing the minimum number of carriers for UE monitoring in UTRA and E-UTRA | 201d? | 2013-12-15 A | 2014-12-15 A | 100% |  | 2014-01-06 | 2014-09-12 | 133d? |  | finish no earlier than 2014-12-15 | R4; R2 | 1844.4h | 1844.4h | LTE_UTRA_IncMon-Core | 32 | 25.133, 25.331, 36.133 | Ericsson | christopher.callender@ericsson.com | Rel-12 | 62 | Issam | LTE_UTRA_IncMon-Core | RP-141787 |  |  |  |
| 2252 | 622.2 | Perf. part: Increasing the minimum number of carriers for UE monitoring in UTRA and E-UTRA | 395d? | 2013-12-15 A | 2015-06-15 A | 100% |  | 2013-12-09 | 2015-03-13 | 331d? |  | finish no earlier than 2015-06-15 | R4 | 3160h | 3160h | LTE_UTRA_IncMon-Perf | 32 | 25.133, 36.133 | Ericsson | christopher.callender@ericsson.com | Rel-12 | 62 | Issam | LTE_UTRA_IncMon-Perf | RP-150596 |  |  |  |
| 2253 | 622.3 | UE Conformance Test Aspects - Increasing the minimum number of carriers for UE monitoring in UTRA and E-UTRA | 655d? | 2015-12-15 A | 2018-06-15 | 25% | 491.25d? |  |  |  | 4561d | finish no earlier than 2018-06-15 | R5 | 5240h | 1310h | LTE_UTRA_IncMon-UEConTest | 36 |  | Ericsson |  | Rel-12 | 70 |  |  |  |  |  |  |
| 2254 | 623 | **WLAN/3GPP Radio Interworking** | 267d? | 2013-12-06 A | 2014-12-09 A | 100% |  | 2013-12-06 | 2014-09-17 | 205d? |  |  | R2; S2; C1; C4 | 11021h | 11021h | UTRA_LTE_WLAN_interw | 32 | UTRA, LTE | Intel | sasha.sirotkin@intel.com | Rel-12 | 62 | Yong-Jun | UTRA_LTE_WLAN_interw |  | WLAN |  |  |
| 2255 | 623.1 | Core part: WLAN/3GPP Radio Interworking | 202d? | 2013-12-06 A | 2014-09-12 A | 100% |  | 2013-12-06 | 2014-09-12 | 202d? |  | finish no earlier than 2014-09-12 | R2 | 1616h | 1616h | UTRA_LTE_WLAN_interw-Core | 32 | 25.304, 25.306, 25.331, 36.304, 36.306, 36.331 | Intel | sasha.sirotkin@intel.com | Rel-12 | 62 | Yong-Jun | UTRA_LTE_WLAN_interw-Core | RP-141310 | WLAN |  |  |
| 2256 | 623.2 | SA2 aspects of WLAN/3GPP Radio Interworking | 140d? | 2014-03-07 A | 2014-09-17 A | 100% |  | 2014-03-07 | 2014-09-17 | 139d? |  | finish no earlier than 2014-09-17 | S2 | 1120h | 1120h | UTRA_LTE_WLAN_interw-SA2 | 32 | 23.402, 23.401, 23.060, 23.251 | Alcatel-Lucent | nicolas.drevon@alcatel-lucent.com | Rel-12 | 63 | Maurice | UTRA_LTE_WLAN_interw-SA2 |  | WLAN |  |  |
| 2257 | 623.3 | **CT aspects of WLAN/3GPP Radio Interworking (Stage 2/3)** | 68d? | 2014-09-09 A | 2014-12-09 A | 100% |  | 2014-06-13 | 2014-09-12 | 66d? |  |  | C1; C4 | 1665.6h | 1665.6h | UTRA_LTE_WLAN_interw-CT | 33 | Stage 2/3 | Alcatel-Lucent | jennifer.liu@alcatel-lucent.com | Rel-12 | 64 |  | UTRA_LTE_WLAN_interw-CT |  | WLAN |  |  |
| 2258 | 623.3.1 | CT1 part of CT aspects of WLAN/3GPP Radio Interworking (Stage 3) | 68d? | 2014-09-09 A | 2014-12-09 A | 100% |  | 2014-06-13 | 2014-09-12 | 66d? |  | finish no earlier than 2014-12-09 | C1 | 528h | 528h | UTRA_LTE_WLAN_interw-CT | 33 | 24.008, 24.301, 24.302, 24.312 | Alcatel-Lucent | jennifer.liu@alcatel-lucent.com | Rel-12 | 64 |  |  | CP-140720 | WLAN |  |  |
| 2259 | 623.3.2 | CT4 part of CT aspects of WLAN/3GPP Radio Interworking (Stage 2/3) | 63d? | 2014-09-12 A | 2014-12-09 A | 100% |  |  |  |  |  | finish no earlier than 2014-12-09 | C4 | 504h | 504h | UTRA_LTE_WLAN_interw-CT | 33 | 23.008, 29.002, 29.272, 29.274, 29.305 | Alcatel-Lucent | jennifer.liu@alcatel-lucent.com | Rel-12 | 65 |  |  | CP-140482 | WLAN |  |  |
| 2260 | 624 | UE Conformance Test Aspects – WLAN/3GPP Radio Interworking | 327d? | 2014-12-15 A | 2016-03-15 A | 100% |  |  |  |  |  | finish no earlier than 2016-03-15 | R5 | 2616h | 2616h | UTRA_LTE_WLAN_interw-UEConTest | 34 |  | Intel | Intel | Rel-12 | 66 |  |  | RP-151264 |  |  |  |
| 2261 | 625 | **Rel-12 LTE Carrier Aggregation** | 1384d? | 2011-09-19 A | 2016-12-15 A | 100% |  | 2011-09-19 | 2014-12-11 | 855d? |  |  | R4 | 567982h | 567982h | LTE_CA_Rel-12 | 30 | LTE |  |  | Rel-12 | 58 | Issam | LTE_CA_Rel-12 |  | CA |  |  |
| 2262 | 625.1 | **LTE Advanced inter-band Carrier Aggregation of Band 1 and Band 7** | 792d? | 2011-09-19 A | 2014-09-12 A | 100% |  | 2011-09-19 | 2014-09-12 | 791d? |  |  | R4 | 18896h | 18896h | LTE_CA_B1_B7 | 27 | LTE | Ericsson | christian.bergljung@ericsson.com | Rel-12 | 53 | Issam | LTE_CA_B1_B7 |  | CA |  |  |
| 2263 | 625.1.1 | Core part:LTE Advanced inter-band Carrier Aggregation of Band 1 and Band 7 | 790d? | 2011-09-19 A | 2014-09-12 A | 100% |  | 2011-09-19 | 2014-09-12 | 790d? |  | finish no earlier than 2014-09-12 | R4 | 6312h | 6312h | LTE_CA_B1_B7-Core | 27 | 36.101, 36.104, new generic TR 36.851 | Ericsson | christian.bergljung@ericsson.com | Rel-12 | 53 | Issam | LTE_CA_B1_B7-Core | RP-141084 | CA |  |  |
| 2264 | 625.1.2 | Perf. part:LTE Advanced inter-band Carrier Aggregation of Band 1 and Band 7 | 781d? | 2011-10-03 A | 2014-09-12 A | 100% |  | 2011-09-30 | 2014-09-12 | 781d? |  | finish no earlier than 2014-09-12 | R4 | 6248h | 6248h | LTE_CA_B1_B7-Perf | 27 | 36.141, 36.307 | Ericsson | christian.bergljung@ericsson.com | Rel-12 | 53 | Issam | LTE_CA_B1_B7-Perf | RP-141084 | CA |  |  |
| 2265 | 625.2 | **LTE Advanced intra-band non-contiguous Carrier Aggregation in Band 25** | 462d? | 2011-09-19 A | 2013-06-14 A | 100% |  | 2011-09-19 | 2013-06-14 | 462d? |  |  | R4 | 11056h | 11056h | LTE_CA_NC_B25 | 27 | LTE | Sprint | George.Cummings@sprint.com | Rel-12 | 53 | Issam | LTE_CA_NC_B25 |  | CA |  |  |
| 2266 | 625.2.1 | Core part:LTE Advanced intra-band non-contiguous Carrier Aggregation in Band 25 | 459d? | 2011-09-19 A | 2013-06-14 A | 100% |  | 2011-09-19 | 2013-06-14 | 459d? |  | finish no earlier than 2013-06-14 | R4 | 3672h | 3672h | LTE_CA_NC_B25-Core | 27 | 36.101, 36.104, 36.133, new TR 36.833-2-25 | Sprint | George.Cummings@sprint.com | Rel-12 | 53 | Issam | LTE_CA_NC_B25-Core | RP-130563 | CA |  |  |
| 2267 | 625.2.2 | Perf. part:LTE Advanced intra-band non-contiguous Carrier Aggregation in Band 25 | 461d? | 2011-09-19 A | 2013-06-14 A | 100% |  | 2011-09-19 | 2013-06-14 | 461d? |  | finish no earlier than 2013-06-14 | R4 | 3688h | 3688h | LTE_CA_NC_B25-Perf | 27 | 36.141, 36.307 | Sprint | George.Cummings@sprint.com | Rel-12 | 53 | Issam | LTE_CA_NC_B25-Perf | RP-130759 | CA |  |  |
| 2268 | 625.3 | **Deleted -LTE Advanced inter-band Carrier Aggregation of Band 3 and Band 5 with 2UL** | 265d? | 2012-03-05 A | 2013-03-01 A | 100% |  | 2012-03-05 | 2013-03-01 | 265d? |  |  | R4 | 6296h | 6296h | LTE_CA_B3_B5_2UL | 28 | LTE | SK Telecom | Seungpyo Hong | Rel-12 | 55 | Issam | LTE_CA_B3_B5_2UL |  | CA | PCG-30 | RP-59 |
| 2269 | 625.3.1 | Deleted - Core part:LTE Advanced inter-band Carrier Aggregation of Band 3 and Band 5 with 2UL | 262d? | 2012-03-05 A | 2013-03-01 A | 100% |  | 2012-03-05 | 2013-03-01 | 262d? |  | finish no earlier than 2013-03-01 | R4 | 2096h | 2096h | LTE_CA_B3_B5_2UL-Core | 28 | 36.101, 36.104, 36.133, 36.307, new generic TR 36.851 | SK Telecom | Seungpyo Hong | Rel-12 | 55 | Issam | LTE_CA_B3_B5_2UL-Core | RP-130098 | CA | PCG-30 | RP-59 |
| 2270 | 625.3.2 | Deleted - Perf. part:LTE Advanced inter-band Carrier Aggregation of Band 3 and Band 5 with 2UL | 260d? | 2012-03-12 A | 2013-03-01 A | 100% |  | 2012-03-12 | 2013-03-01 | 260d? |  | finish no earlier than 2013-03-01 | R4 | 2080h | 2080h | LTE_CA_B3_B5_2UL-Perf | 28 | 36.133, 36.141 | SK Telecom | Seungpyo Hong | Rel-12 | 55 | Issam | LTE_CA_B3_B5_2UL-Perf | RP-130099 | CA | PCG-30 | RP-59 |
| 2271 | 625.4 | UE Conformance Test Aspects - Further Rel-12 configurations for LTE Advanced Carrier Aggregation with 2UL | 460d? | 2015-03-16 A | 2016-12-15 A | 100% |  |  |  |  |  | finish no earlier than 2016-12-15 | R5 | 3680h | 3680h | LTE_CA_Rel12_2UL-UEConTest | 34 |  | Ericsson | NA | Rel-12 | 67 |  |  |  |  |  |  |
| 2272 | 625.5 | **LTE Advanced intra-band non-contiguous Carrier Aggregation in Band 3** | 469d? | 2012-03-05 A | 2013-12-06 A | 100% |  | 2012-03-05 | 2013-12-06 | 469d? |  |  | R4 | 11136h | 11136h | LTE_CA_NC_B3 | 28 | LTE | SK Telecom | haesung.park@sk.com | Rel-12 | 55 | Issam | LTE_CA_NC_B3 |  | CA |  |  |
| 2273 | 625.5.1 | Core part:LTE Advanced intra-band non-contiguous Carrier Aggregation in Band 3 | 462d? | 2012-03-05 A | 2013-12-06 A | 100% |  | 2012-03-05 | 2013-12-06 | 462d? |  | finish no earlier than 2013-12-06 | R4 | 3696h | 3696h | LTE_CA_NC_B3-Core | 28 | 36.101, 36.104, 36.133, new TR 36.833-2-03 | SK Telecom | haesung.park@sk.com | Rel-12 | 55 | Issam | LTE_CA_NC_B3-Core | RP-131573 | CA |  |  |
| 2274 | 625.5.2 | Perf. part:LTE Advanced intra-band non-contiguous Carrier Aggregation in Band 3 | 461d? | 2012-03-15 A | 2013-12-06 A | 100% |  | 2012-03-15 | 2013-12-06 | 461d? |  | finish no earlier than 2013-12-06 | R4 | 3688h | 3688h | LTE_CA_NC_B3-Perf | 28 | 36.101, 36.104, 36.133, 36.141, 36.307 | SK Telecom | haesung.park@sk.com | Rel-12 | 55 | Issam | LTE_CA_NC_B3-Perf | RP-131574 | CA |  |  |

Notes:
- 2250: -
- 2251: ; CD:Thu 18/12/14->Mon 15/12/14; WID: RP-141966->RP-142235; Stat Rep: RP-141600->RP-141787
- 2252: ; CD:Fri 12/06/15->Mon 15/06/15; WID: RP-141966->RP-142235; Stat Rep: RP-141600->RP-141787 1st Apr 15: Compl:5%->40% 1st Apr 15: Stat Rep: RP-141787->RP-150063 03/07/15: Compl:40%->100% 03/07/15: Stat Rep: RP-150063->RP-150596
- 2253: 22/3/16: Compl:0%->4%1/7/16: CD:Thu 15/09/16->Thu 15/12/16; 26/9/16: Com 21/3/17: Compl...; ...;...; ;...
- 2254: Triggered by Rel-12 TR 37.834 Study on WLAN/3GPP Radio Interworking (FS_UTRA_LTE_WLAN_interw)
- 2255: SP#65 completed
- 2256: SP#65 completed
- 2257: CP#65 revised WID CP-140287=>CP-140623 (added CT4 part)
- 2258: CP#65 completion 09/14=>12/14. Exception in CP-140720. 78%->95%. 12/12: 95->78%. 3/3/15: 100% cpltd.
- 2259: CP#65 revised WID CP-140287=>CP-140623 (added CT4 part). Exception in CP-140482. Dec.14: 50->100
- 2260: Rel13->Rel-12; Moved at appropriate place 1st Apr 15: Compl:0%->5% 1st Apr 15: Stat Rep: ->RP-150098 03/07/15: Compl:5%->20% 03/07/15: Stat Rep: RP-150098->RP-150929 29/09/15: Compl:20%->60% 29/09/15: WID: RP-141879->RP-151270 29/09/15: Stat Rep: RP-15
- 2261: LTE_CA_Rel-12
- 2262: Inter-band CA 2DL
- 2263: RP#65 completed. Updated WID RP-132042=>RP-141487
- 2264: RP#65 completed
- 2265: Intra-band NC
- 2266: RP#60 completed. TR 36.841 for 1-step Approval
- 2267: RP#60 completed
- 2268: Inter-band 2UL
- 2269: RP#59 stopped (covered by new WI LTE_CA_2UL-A4)
- 2270: RP#59 stopped (covered by new WI LTE_CA_2UL-A4)
- 2271: 03/07/15: Compl:0%->29% 03/07/15: Stat Rep: ->RP-150834 29/09/15: Compl:29%->55% 29/09/15: Stat Rep: RP-150834->RP-151166 1/1/16: Compl:55%->70% 1/1/16: CD:Tue 15/12/15->Tue 15/03/16 1/1/16: WID: RP-1;
- 2272: Intra-band NC
- 2273: RP#62 completed
- 2274: RP#62 completed

| ID | WBS | Task | Duration | Start | Finish | Complete | Baseline start | Baseline finish | Baseline duration | Constraint | Resources | Work | Actual work | Acronym | PCG approved | Impacted TSs and TRs | WI rapporteur name | WI rapporteur e-mail | Release | TSG approved | MCC resp | PCG stopped | TSG stopped | Special Focus Doc | Acronym_3GU_Export | Status Report |
| --- | --- | --- | --- | --- | --- | --- | --- | --- | --- | --- | --- | --- | --- | --- | --- | --- | --- | --- | --- | --- | --- | --- | --- | --- | --- | --- |
| 2275 | 625.6 | **Deleted - LTE Advanced intra-band contiguous Carrier Aggregation in Band 1** | 265d? | 2012-06-18 A | 2013-06-14 A | 100% | 2012-06-18 | 2013-06-14 | 265d? |  | R4 | 6328h | 6328h | LTE_CA_C_B1 | 29 | LTE | KDDI | Masaaki Obara (ms-obara@kddi.com) | Rel-12 | 56 | Issam | PCG-31 | RP-60 | CA | LTE_CA_C_B1 |  |
| 2276 | 625.6.1 | Deleted - Core part: LTE Advanced intra-band contiguous Carrier Aggregation in Band 1 | 265d? | 2012-06-18 A | 2013-06-14 A | 100% | 2012-06-18 | 2013-06-14 | 265d? | finish no earlier than 2013-06-14 | R4 | 2120h | 2120h | LTE_CA_C_B1-Core | 29 | 36.101, 36.104, 36.133, 36.141, 36.307, new TR 36.835 | KDDI | Masaaki Obara (ms-obara@kddi.com) | Rel-12 | 56 | Issam | PCG-31 | RP-60 | CA | LTE_CA_C_B1-Core | RP-130549 |
| 2277 | 625.6.2 | Deleted - Perf. part: LTE Advanced intra-band contiguous Carrier Aggregation in Band 1 | 261d? | 2012-06-22 A | 2013-06-14 A | 100% | 2012-06-22 | 2013-06-14 | 261d? | finish no earlier than 2013-06-14 | R4 | 2088h | 2088h | LTE_CA_C_B1-Perf | 29 | 36.101, 36.104, 36.133, 36.141, 36.307 | KDDI | Masaaki Obara (ms-obara@kddi.com) | Rel-12 | 56 | Issam | PCG-31 | RP-60 | CA | LTE_CA_C_B1-Perf | RP-130550 |
| 2278 | 625.7 | **LTE Advanced intra-band non-contiguous Carrier Aggregation in Band 4** | 327d? | 2012-06-18 A | 2013-09-06 A | 100% | 2012-06-18 | 2013-09-06 | 327d? |  | R4 | 7752h | 7752h | LTE_CA_NC_B4 | 29 | LTE | T-Mobile USA | nelson.ueng@t-mobile.com | Rel-12 | 56 | Issam |  |  | CA | LTE_CA_NC_B4 |  |
| 2279 | 625.7.1 | Core part:LTE Advanced intra-band non-contiguous Carrier Aggregation in Band 4 | 323d? | 2012-06-18 A | 2013-09-06 A | 100% | 2012-06-18 | 2013-09-06 | 323d? | finish no earlier than 2013-09-06 | R4 | 2568h | 2568h | LTE_CA_NC_B4-Core | 29 | 36.101, 36.104, 36.133, new TR 36.833-2-04 | T-Mobile USA | nelson.ueng@t-mobile.com | Rel-12 | 56 | Issam |  |  | CA | LTE_CA_NC_B4-Core | RP-131039 |
| 2280 | 625.7.2 | Perf. part:LTE Advanced intra-band non-contiguous Carrier Aggregation in Band 4 | 323d? | 2012-06-22 A | 2013-09-06 A | 100% | 2012-06-22 | 2013-09-06 | 323d? | finish no earlier than 2013-09-06 | R4 | 2568h | 2568h | LTE_CA_NC_B4-Perf | 29 | 36.101, 36.104, 36.133, 36.141, 36.307 | T-Mobile USA | nelson.ueng@t-mobile.com | Rel-12 | 56 | Issam |  |  | CA | LTE_CA_NC_B4-Perf | RP-131040 |
| 2281 | 625.8 | **LTE Advanced inter-band Carrier Aggregation of Band 2 and Band 4** | 327d? | 2012-06-18 A | 2013-09-06 A | 100% | 2012-06-18 | 2013-09-06 | 327d? |  | R4 | 7752h | 7752h | LTE_CA_B2_B4 | 29 | LTE | T-Mobile USA | nelson.ueng@t-mobile.com | Rel-12 | 56 | Issam |  |  | CA | LTE_CA_B2_B4 |  |
| 2282 | 625.8.1 | Core part:LTE Advanced inter-band Carrier Aggregation of Band 2 and Band 4 | 321d? | 2012-06-18 A | 2013-09-06 A | 100% | 2012-06-18 | 2013-09-06 | 321d? | finish no earlier than 2013-09-06 | R4 | 2568h | 2568h | LTE_CA_B2_B4-Core | 29 | 36.101, 36.104, 36.133, new generic TR 36.851 | T-Mobile USA | nelson.ueng@t-mobile.com | Rel-12 | 56 | Issam |  |  | CA | LTE_CA_B2_B4-Core | RP-131007 |
| 2283 | 625.8.2 | Perf. part:LTE Advanced inter-band Carrier Aggregation of Band 2 and Band 4 | 321d? | 2012-06-22 A | 2013-09-06 A | 100% | 2012-06-22 | 2013-09-06 | 321d? | finish no earlier than 2013-09-06 | R4 | 2568h | 2568h | LTE_CA_B2_B4-Perf | 29 | 36.101, 36.104, 36.133, 36.141, 36.307 | T-Mobile USA | nelson.ueng@t-mobile.com | Rel-12 | 56 | Issam |  |  | CA | LTE_CA_B2_B4-Perf | RP-131376 |
| 2284 | 625.9 | **LTE Advanced inter-band Carrier Aggregation of Band 23 and Band 29** | 202d? | 2012-09-12 A | 2013-06-14 A | 100% | 2012-09-12 | 2013-06-14 | 202d? |  | R4 | 4832h | 4832h | LTE_CA_B23_B29 | 29 | LTE | DISH Network | mariam.sorond@dish.com, johny.kim@dish.com | Rel-12 | 57 | Issam |  |  | CA | LTE_CA_B23_B29 |  |
| 2285 | 625.9.1 | Core part:LTE Advanced inter-band Carrier Aggregation of Band 23 and Band 29 | 201d? | 2012-09-12 A | 2013-06-14 A | 100% | 2012-09-12 | 2013-06-14 | 201d? | finish no earlier than 2013-06-14 | R4 | 1608h | 1608h | LTE_CA_B23_B29-Core | 29 | 36.101, 36.104, 36.133, new generic TR 36.851 | DISH Network | mariam.sorond@dish.com, johny.kim@dish.com | Rel-12 | 57 | Issam |  |  | CA | LTE_CA_B23_B29-Core | RP-130535 |
| 2286 | 625.9.2 | Perf. part:LTE Advanced inter-band Carrier Aggregation of Band 23 and Band 29 | 201d? | 2012-09-12 A | 2013-06-14 A | 100% | 2012-09-12 | 2013-06-14 | 201d? | finish no earlier than 2013-06-14 | R4 | 1608h | 1608h | LTE_CA_B23_B29-Perf | 29 | 36.141, 36.307 | DISH Network | mariam.sorond@dish.com, johny.kim@dish.com | Rel-12 | 57 | Issam |  |  | CA | LTE_CA_B23_B29-Perf | RP-130536 |
| 2287 | 625.10 | **LTE Advanced inter-band Carrier Aggregation of Band 3 and Band 26** | 203d? | 2012-09-11 A | 2013-06-14 A | 100% | 2012-09-11 | 2013-06-14 | 203d? |  | R4 | 4840h | 4840h | LTE_CA_B3_B26 | 29 | LTE | KT | Chungwoo HWANG (cwhwang@kt.com) | Rel-12 | 57 | Issam |  |  | CA | LTE_CA_B3_B26 |  |
| 2288 | 625.10.1 | Core part:LTE Advanced inter-band Carrier Aggregation of Band 3 and Band 26 | 202d? | 2012-09-11 A | 2013-06-14 A | 100% | 2012-09-11 | 2013-06-14 | 202d? | finish no earlier than 2013-06-14 | R4 | 1608h | 1608h | LTE_CA_B3_B26-Core | 29 | 36.101, 36.104, 36.133, 36.307, new generic TR 36.851 | KT | Chungwoo HWANG (cwhwang@kt.com) | Rel-12 | 57 | Issam |  |  | CA | LTE_CA_B3_B26-Core | RP-130527 |
| 2289 | 625.10.2 | Perf. part:LTE Advanced inter-band Carrier Aggregation of Band 3 and Band 26 | 202d? | 2012-09-11 A | 2013-06-14 A | 100% | 2012-09-11 | 2013-06-14 | 202d? | finish no earlier than 2013-06-14 | R4 | 1608h | 1608h | LTE_CA_B3_B26-Perf | 29 | 36.101, 36.104, 36.133, 36.141, 36.307 | KT | Chungwoo HWANG (cwhwang@kt.com) | Rel-12 | 57 | Issam |  |  | CA | LTE_CA_B3_B26-Perf | RP-130528 |
| 2290 | 625.11 | **LTE Advanced inter-band Carrier Aggregation of Band 3 and Band 19** | 203d? | 2012-09-11 A | 2013-06-14 A | 100% | 2012-09-11 | 2013-06-14 | 203d? |  | R4 | 4840h | 4840h | LTE_CA_B3_B19 | 29 | LTE | NTT DOCOMO | Kei ANDO | Rel-12 | 57 | Issam |  |  | CA | LTE_CA_B3_B19 |  |
| 2291 | 625.11.1 | Core part:LTE Advanced inter-band Carrier Aggregation of Band 3 and Band 19 | 201d? | 2012-09-11 A | 2013-06-14 A | 100% | 2012-09-11 | 2013-06-14 | 201d? | finish no earlier than 2013-06-14 | R4 | 1608h | 1608h | LTE_CA_B3_B19-Core | 29 | 36.101, 36.104, 36.133, new generic TR 36.851 | NTT DOCOMO | Kei ANDO | Rel-12 | 57 | Issam |  |  | CA | LTE_CA_B3_B19-Core | RP-130525 |
| 2292 | 625.11.2 | Perf. part:LTE Advanced inter-band Carrier Aggregation of Band 3 and Band 19 | 201d? | 2012-09-13 A | 2013-06-14 A | 100% | 2012-09-13 | 2013-06-14 | 201d? | finish no earlier than 2013-06-14 | R4 | 1608h | 1608h | LTE_CA_B3_B19-Perf | 29 | 36.141, 36.307 | NTT DOCOMO | Kei ANDO | Rel-12 | 57 | Issam |  |  | CA | LTE_CA_B3_B19-Perf | RP-130526 |
| 2293 | 625.12 | **Deleted -LTE Advanced inter-band Carrier Aggregation of Band 38 and Band 39** | 66d? | 2012-09-11 A | 2012-12-07 A | 100% | 2012-09-11 | 2012-12-07 | 66d? |  | R4 | 1584h | 1584h | LTE_CA_B38_B39 | 29 | LTE | China Mobile | Pan Qun (panqun@chinamobile.com) | Rel-12 | 57 | Issam | PCG-30 | RP-58 | CA | LTE_CA_B38_B39 |  |
| 2294 | 625.12.1 | Deleted - Core part:LTE Advanced inter-band Carrier Aggregation of Band 38 and Band 39 | 66d? | 2012-09-11 A | 2012-12-07 A | 100% | 2012-09-11 | 2012-12-07 | 66d? | finish no earlier than 2012-12-07 | R4 | 528h | 528h | LTE_CA_B38_B39-Core | 29 | 36.101, 36.104, 36.307, new generic TR 36.851 | China Mobile | Pan Qun (panqun@chinamobile.com) | Rel-12 | 57 | Issam | PCG-30 | RP-58 | CA | LTE_CA_B38_B39-Core | RP-121624 |
| 2295 | 625.12.2 | Deleted - Perf. part:LTE Advanced inter-band Carrier Aggregation of Band 38 and Band 39 | 66d? | 2012-09-11 A | 2012-12-07 A | 100% | 2012-09-11 | 2012-12-07 | 66d? | finish no earlier than 2012-12-07 | R4 | 528h | 528h | LTE_CA_B38_B39-Perf | 29 | 36.133, 36.141 | China Mobile | Pan Qun (panqun@chinamobile.com) | Rel-12 | 57 | Issam | PCG-30 | RP-58 | CA | LTE_CA_B38_B39-Perf | RP-121625 |
| 2296 | 625.13 | **LTE Advanced intra-band contiguous Carrier Aggregation in Band 3** | 265d? | 2012-09-11 A | 2013-09-06 A | 100% | 2012-09-11 | 2013-09-06 | 265d? |  | R4 | 6312h | 6312h | LTE_CA_C_B3 | 29 | LTE | China Unicom | Fei CUI (cuifei1@chinaunicom.cn) | Rel-12 | 57 | Issam |  |  | CA | LTE_CA_C_B3 |  |
| 2297 | 625.13.1 | Core part: LTE Advanced intra-band contiguous Carrier Aggregation in Band 3 | 263d? | 2012-09-11 A | 2013-09-06 A | 100% | 2012-09-11 | 2013-09-06 | 263d? | finish no earlier than 2013-09-06 | R4 | 2096h | 2096h | LTE_CA_C_B3-Core | 29 | 36.101, 36.104, 36.133, new TR 36.833-1-03 | China Unicom | Fei CUI (cuifei1@chinaunicom.cn) | Rel-12 | 57 | Issam |  |  | CA | LTE_CA_C_B3-Core | RP-131029 |
| 2298 | 625.13.2 | Perf. part: LTE Advanced intra-band contiguous Carrier Aggregation in Band 3 | 263d? | 2012-09-11 A | 2013-09-06 A | 100% | 2012-09-11 | 2013-09-06 | 263d? | finish no earlier than 2013-09-06 | R4 | 2096h | 2096h | LTE_CA_C_B3-Perf | 29 | 36.141, 36.307 | China Unicom | Fei CUI (cuifei1@chinaunicom.cn) | Rel-12 | 57 | Issam |  |  | CA | LTE_CA_C_B3-Perf | RP-131030 |

Notes:
- 2275: Intra-band C
- 2276: RP#60 stopped at 10% completion (rationale in RP-130670)
- 2277: RP#60 stopped at 0% completion
- 2278: Intra-band NC
- 2279: RP#61 completed. Updated WID RP-130842=>RP-131135
- 2280: RP#61 completed. Updated WID RP-130842=>RP-131135
- 2281: Inter-band 1 UL
- 2282: RP#61 completed
- 2283: RP#61 completed
- 2284: Inter-band 1 UL
- 2285: RP#60 completed
- 2286: RP#60 completed
- 2287: Inter-band 1 UL
- 2288: RP#60 completed. Updated WID RP-130199=>RP-130658
- 2289: RP#60 completed. Updated WID RP-130199=>RP-130658
- 2290: Inter-band 1 UL
- 2291: RP#60 completed
- 2292: RP#60 completed
- 2293: Inter-band 1 UL
- 2294: RP#58 stopped at 10% completion following regulatory decisions (see instead new WI LTE_CA_B39_B41)
- 2295: RP#58 stopped at 0% completion following regulatory decisions (see instead new WI LTE_CA_B39_B41)
- 2296: Intra-band NC
- 2297: RP#61 completed. Updated WID RP-130294=>RP-131184 (impacted specs)
- 2298: RP#61 completed

| ID | WBS | Task | Duration | Start | Finish | Complete | Baseline start | Baseline finish | Baseline duration | Constraint | Resources | Work | Actual work | Acronym | PCG approved | WI rapporteur name | WI rapporteur e-mail | Release | TSG approved | MCC resp | Special Focus Doc | Acronym_3GU_Export | Status Report |
| --- | --- | --- | --- | --- | --- | --- | --- | --- | --- | --- | --- | --- | --- | --- | --- | --- | --- | --- | --- | --- | --- | --- | --- |
| 2299 | 625.14 | **LTE Advanced inter-band Carrier Aggregation of Band 1 and Band 8** | 362.8d? | 2012-02-02 A | 2013-06-14 A | 100% | 2012-02-02 | 2013-06-14 | 362.8d? |  | R4 | 6118.4h | 6118.4h | LTE_CA_B1_B8 | 29 | Softbank Mobile | Kenichi Kihara | Rel-12 | 57 | Issam | CA | LTE_CA_B1_B8 |  |
| 2300 | 625.14.1 | Core part:LTE Advanced inter-band Carrier Aggregation of Band 1 and Band 8 | 201d? | 2012-02-02 A | 2013-06-14 A | 100% | 2012-02-02 | 2013-06-14 | 201d? | finish no earlier than 2013-06-14 | R4 | 1608h | 1608h | LTE_CA_B1_B8-Core | 29 | Softbank Mobile | Kenichi Kihara | Rel-12 | 57 | Issam | CA | LTE_CA_B1_B8-Core | RP-130515 |
| 2301 | 625.14.2 | Perf. part:LTE Advanced inter-band Carrier Aggregation of Band 1 and Band 8 | 202d? | 2012-09-11 A | 2013-06-14 A | 100% | 2012-09-11 | 2013-06-14 | 202d? | finish no earlier than 2013-06-14 | R4 | 1608h | 1608h | LTE_CA_B1_B8-Perf | 29 | Softbank Mobile | Kenichi Kihara | Rel-12 | 57 | Issam | CA | LTE_CA_B1_B8-Perf | RP-130516 |
| 2302 | 625.15 | **LTE Advanced inter-band Carrier Aggregation of Band 3 and Band 28** | 203d? | 2012-09-11 A | 2013-06-14 A | 100% | 2012-09-11 | 2013-06-14 | 203d? |  | R4 | 4840h | 4840h | LTE_CA_B3_B28 | 29 | eAccess | FukumotoShiro@eaccess.net | Rel-12 | 57 | Issam | CA | LTE_CA_B3_B28 |  |
| 2303 | 625.15.1 | Core part:LTE Advanced inter-band Carrier Aggregation of Band 3 and Band 28 | 202d? | 2012-09-11 A | 2013-06-14 A | 100% | 2012-09-11 | 2013-06-14 | 202d? | finish no earlier than 2013-06-14 | R4 | 1608h | 1608h | LTE_CA_B3_B28-Core | 29 | eAccess | FukumotoShiro@eaccess.net | Rel-12 | 57 | Issam | CA | LTE_CA_B3_B28-Core | RP-130529 |
| 2304 | 625.15.2 | Perf. part:LTE Advanced inter-band Carrier Aggregation of Band 3 and Band 28 | 201d? | 2012-09-12 A | 2013-06-14 A | 100% | 2012-09-12 | 2013-06-14 | 201d? | finish no earlier than 2013-06-14 | R4 | 1608h | 1608h | LTE_CA_B3_B28-Perf | 29 | eAccess | FukumotoShiro@eaccess.net | Rel-12 | 57 | Issam | CA | LTE_CA_B3_B28-Perf | RP-130530 |
| 2305 | 625.16 | **LTE Advanced inter-band Carrier Aggregation of Band 1 and Band 26** | 200d? | 2012-12-07 A | 2013-09-06 A | 100% | 2012-12-07 | 2013-09-06 | 200d? |  | R4 | 4768h | 4768h | LTE_CA_B1_B26 | 30 | KDDI | Masaaki Obara (ms-obara@kddi.com) | Rel-12 | 58 | Issam | CA | LTE_CA_B1_B26 |  |
| 2306 | 625.16.1 | Core part:LTE Advanced inter-band Carrier Aggregation of Band 1 and Band 26 | 200d? | 2012-12-07 A | 2013-09-06 A | 100% | 2012-12-07 | 2013-09-06 | 200d? | finish no earlier than 2013-09-06 | R4 | 1576h | 1576h | LTE_CA_B1_B26-Core | 30 | KDDI | Masaaki Obara (ms-obara@kddi.com) | Rel-12 | 58 | Issam | CA | LTE_CA_B1_B26-Core | RP-131005 |
| 2307 | 625.16.2 | Perf. part:LTE Advanced inter-band Carrier Aggregation of Band 1 and Band 26 | 200d? | 2012-12-07 A | 2013-09-06 A | 100% | 2012-12-07 | 2013-09-06 | 200d? | finish no earlier than 2013-09-06 | R4 | 1600h | 1600h | LTE_CA_B1_B26-Perf | 30 | KDDI | Masaaki Obara (ms-obara@kddi.com) | Rel-12 | 58 | Issam | CA | LTE_CA_B1_B26-Perf | RP-131006 |
| 2308 | 625.17 | **LTE Advanced inter-band Carrier Aggregation of Band 39 and Band 41** | 330d? | 2012-12-10 A | 2014-03-06 A | 100% | 2012-12-10 | 2014-03-06 | 330d? |  | R4 | 7848h | 7848h | LTE_CA_B39_B41 | 30 | China Mobile | Pan Qun (panqun@chinamobile.com) | Rel-12 | 58 | Issam | CA | LTE_CA_B39_B41 | RP-140428 |
| 2309 | 625.17.1 | Core part:LTE Advanced inter-band Carrier Aggregation of Band 39 and Band 41 | 326d? | 2012-12-10 A | 2014-03-06 A | 100% | 2012-12-10 | 2014-03-06 | 326d? | finish no earlier than 2014-03-06 | R4 | 2608h | 2608h | LTE_CA_B39_B41-Core | 30 | China Mobile | Pan Qun (panqun@chinamobile.com) | Rel-12 | 58 | Issam | CA | LTE_CA_B39_B41-Core | RP-140428 |
| 2310 | 625.17.2 | Perf. part:LTE Advanced inter-band Carrier Aggregation of Band 39 and Band 41 | 325d? | 2012-12-14 A | 2014-03-06 A | 100% | 2012-12-14 | 2014-03-06 | 325d? | finish no earlier than 2014-03-06 | R4 | 2600h | 2600h | LTE_CA_B39_B41-Perf | 30 | China Mobile | Pan Qun (panqun@chinamobile.com) | Rel-12 | 58 | Issam | CA | LTE_CA_B39_B41-Perf | RP-140428 |
| 2311 | 625.18 | **LTE Advanced inter-band Carrier Aggregation of Band 2 and Band 12** | 467d? | 2012-12-10 A | 2014-09-12 A | 100% | 2012-12-10 | 2014-09-12 | 466d? |  | R4 | 10040h | 10040h | LTE_CA_B2_B12 | 30 | US Cellular | sebastian.thalanany@uscellular.com | Rel-12 | 58 | Issam | CA | LTE_CA_B2_B12 |  |
| 2312 | 625.18.1 | Core part:LTE Advanced inter-band Carrier Aggregation of Band 2 and Band 12 | 464d? | 2012-12-10 A | 2014-09-12 A | 100% | 2012-12-10 | 2014-09-12 | 464d? | finish no earlier than 2014-09-12 | R4 | 3704h | 3704h | LTE_CA_B2_B12-Core | 30 | US Cellular | sebastian.thalanany@uscellular.com | Rel-12 | 58 | Issam | CA | LTE_CA_B2_B12-Core | RP-141084 |
| 2313 | 625.18.2 | Perf. part:LTE Advanced inter-band Carrier Aggregation of Band 2 and Band 12 | 325d? | 2012-12-14 A | 2014-03-06 A | 100% | 2012-12-14 | 2014-03-06 | 325d? | finish no earlier than 2014-06-13 | R4 | 2600h | 2600h | LTE_CA_B2_B12-Perf | 30 | US Cellular | sebastian.thalanany@uscellular.com | Rel-12 | 58 | Issam | CA | LTE_CA_B2_B12-Perf | RP-140428 |
| 2314 | 625.19 | **LTE Advanced intra-band non-contiguous Carrier Aggregation in Band 7** | 265d? | 2012-12-10 A | 2013-12-06 A | 100% | 2012-12-10 | 2013-12-06 | 265d? |  | R4 | 6296h | 6296h | LTE_CA_NC_B7 | 30 | Ericsson | christian.bergljung@ericsson.com | Rel-12 | 58 | Issam | CA | LTE_CA_NC_B7 |  |
| 2315 | 625.19.1 | Core part:LTE Advanced intra-band non-contiguous Carrier Aggregation in Band 7 | 261d? | 2012-12-10 A | 2013-12-06 A | 100% | 2012-12-10 | 2013-12-06 | 261d? | finish no earlier than 2013-12-06 | R4 | 2088h | 2088h | LTE_CA_NC_B7-Core | 30 | Ericsson | christian.bergljung@ericsson.com | Rel-12 | 58 | Issam | CA | LTE_CA_NC_B7-Core | RP-131575 |
| 2316 | 625.19.2 | Perf. part:LTE Advanced intra-band non-contiguous Carrier Aggregation in Band 7 | 261d? | 2012-12-14 A | 2013-12-06 A | 100% | 2012-12-14 | 2013-12-06 | 261d? | finish no earlier than 2013-12-06 | R4 | 2088h | 2088h | LTE_CA_NC_B7-Perf | 30 | Ericsson | christian.bergljung@ericsson.com | Rel-12 | 58 | Issam | CA | LTE_CA_NC_B7-Perf | RP-131576 |
| 2317 | 625.20 | **LTE Advanced intra-band contiguous Carrier Aggregation in Band 27** | 401d? | 2012-12-10 A | 2014-06-13 A | 100% | 2012-12-10 | 2014-06-13 | 401d? |  | R4 | 8472h | 8472h | LTE_CA_C_B27 | 30 | NII Holdings | bill.shvodian@nii.com | Rel-12 | 58 | Issam | CA | LTE_CA_C_B27 |  |
| 2318 | 625.20.1 | Core part: LTE Advanced intra-band contiguous Carrier Aggregation in Band 27 | 261d? | 2012-12-10 A | 2013-12-06 A | 100% | 2012-12-10 | 2013-12-06 | 261d? | finish no earlier than 2013-12-06 | R4 | 2088h | 2088h | LTE_CA_C_B27-Core | 30 | NII Holdings | bill.shvodian@nii.com | Rel-12 | 58 | Issam | CA | LTE_CA_C_B27-Core | RP-131567 |
| 2319 | 625.20.2 | Perf part: LTE Advanced intra-band contiguous Carrier Aggregation in Band 27 | 397d? | 2012-12-14 A | 2014-06-13 A | 100% | 2012-12-14 | 2014-06-13 | 397d? | finish no earlier than 2014-06-13 | R4 | 3176h | 3176h | LTE_CA_C_B27-Perf | 30 | NII Holdings | bill.shvodian@nii.com | Rel-12 | 58 | Issam | CA | LTE_CA_C_B27-Perf | RP-140569 |
| 2320 | 625.21 | **LTE Advanced inter-band Carrier Aggregation of Band 2 and Band 13** | 76d? | 2013-03-04 A | 2013-06-14 A | 100% | 2013-03-04 | 2013-06-14 | 76d? |  | R4 | 1824h | 1824h | LTE_CA_B2_B13 | 30 | Ericsson | christian.bergljung@ericsson.com | Rel-12 | 59 | Issam | CA | LTE_CA_B2_B13 |  |
| 2321 | 625.21.1 | Core part:LTE Advanced inter-band Carrier Aggregation of Band 2 and Band 13 | 76d? | 2013-03-04 A | 2013-06-14 A | 100% | 2013-03-04 | 2013-06-14 | 76d? | finish no earlier than 2013-06-14 | R4 | 608h | 608h | LTE_CA_B2_B13-Core | 30 | Ericsson | christian.bergljung@ericsson.com | Rel-12 | 59 | Issam | CA | LTE_CA_B2_B13-Core | RP-130523 |
| 2322 | 625.21.2 | Perf. part:LTE Advanced inter-band Carrier Aggregation of Band 2 and Band 13 | 76d? | 2013-03-04 A | 2013-06-14 A | 100% | 2013-03-04 | 2013-06-14 | 76d? | finish no earlier than 2013-06-14 | R4 | 608h | 608h | LTE_CA_B2_B13-Perf | 30 | Ericsson | christian.bergljung@ericsson.com | Rel-12 | 59 | Issam | CA | LTE_CA_B2_B13-Perf | RP-130524 |

Notes:
- 2299: Inter-band 1 UL / Impacted TSs and TRs: LTE
- 2300: RP#60 completed / Impacted TSs and TRs: 36.101, 36.104, new generic TR 36.851
- 2301: RP#60 completed / Impacted TSs and TRs: 36.141, 36.307
- 2302: Inter-band 1 UL / Impacted TSs and TRs: LTE
- 2303: RP#60 completed / Impacted TSs and TRs: 36.101, 36.104, new generic TR 36.851
- 2304: RP#60 completed / Impacted TSs and TRs: 36.141, 36.307
- 2305: Inter-band 1UL/2DL / Impacted TSs and TRs: LTE
- 2306: RP#61 completed / Impacted TSs and TRs: 36.101, 36.104, 36.133, new generic TR 36.851
- 2307: RP#61 completed / Impacted TSs and TRs: 36.141, 36.307
- 2308: Inter-band 2DL / Impacted TSs and TRs: LTE
- 2309: RP#63 completed. Replaces the Stopped WI - LTE Advanced inter-band Carrier Aggregation of Band 38 and Band 39 (LTE_CA_B38_B39) UID_570015 / Impacted TSs and TRs: 36.101, 36.104, 36.307, new generic TR 36.851
- 2310: RP#63 completed / Impacted TSs and TRs: 36.133, 36.141
- 2311: Inter-band CA 2DL / Impacted TSs and TRs: LTE
- 2312: RP#65 completed / Impacted TSs and TRs: 36.101, 36.104, 36.133, 36.141, 36.307, new generic TR 36.851
- 2313: RP#63 completed / Impacted TSs and TRs: 36.101, 36.104, 36.133, 36.141, 36.307
- 2314: Intra-band NC / Impacted TSs and TRs: LTE
- 2315: RP#62 completed / Impacted TSs and TRs: 36.101, 36.104, 36.133, new TR 36.833-2-07
- 2316: RP#62 completed / Impacted TSs and TRs: 36.141, 36.307
- 2317: Intra-band contig. CA 2DL/1UL / Impacted TSs and TRs: LTE
- 2318: RP#62 completed / Impacted TSs and TRs: 36.101, 36.104, new TR 36.833-1-27
- 2319: RP#64 completed. TR 36.833-1-27v200 for Approval / Impacted TSs and TRs: 36.101, 36.133, 36.141, 36.307, new TR 36.833-1-27
- 2320: Inter-band 1 UL / Impacted TSs and TRs: LTE
- 2321: RP#60 completed / Impacted TSs and TRs: 36.101, 36.104, 36.133, new generic TR 36.851
- 2322: RP#60 completed / Impacted TSs and TRs: 36.101, 36.104, 36.133, 36.141, 36.307

| ID | WBS | Task | Duration | Start | Finish | Complete | Baseline start | Baseline finish | Baseline duration | Constraint | Resources | Work | Actual work | Acronym | PCG approved | WI rapporteur name | WI rapporteur e-mail | Release | TSG approved | MCC resp | Special Focus Doc | Acronym_3GU_Export | Status Report | PCG stopped | TSG stopped |
| --- | --- | --- | --- | --- | --- | --- | --- | --- | --- | --- | --- | --- | --- | --- | --- | --- | --- | --- | --- | --- | --- | --- | --- | --- | --- |
| 2323 | 625.22 | **LTE Advanced inter-band Carrier Aggregation of Band 19 and Band 21** | 76d? | 2013-03-04 A | 2013-06-14 A | 100% | 2013-03-04 | 2013-06-14 | 76d? |  | R4 | 1824h | 1824h | LTE_CA_B19_B21 | 30 | NTT DOCOMO | Kei ANDO | Rel-12 | 59 | Issam | CA | LTE_CA_B19_B21 |  |  |  |
| 2324 | 625.22.1 | Core part:LTE Advanced inter-band Carrier Aggregation of Band 19 and Band 21 | 76d? | 2013-03-04 A | 2013-06-14 A | 100% | 2013-03-04 | 2013-06-14 | 76d? | finish no earlier than 2013-06-14 | R4 | 608h | 608h | LTE_CA_B19_B21-Core | 30 | NTT DOCOMO | Kei ANDO | Rel-12 | 59 | Issam | CA | LTE_CA_B19_B21-Core | RP-130533 |  |  |
| 2325 | 625.22.2 | Perf. part:LTE Advanced inter-band Carrier Aggregation of Band 19 and Band 21 | 76d? | 2013-03-04 A | 2013-06-14 A | 100% | 2013-03-04 | 2013-06-14 | 76d? | finish no earlier than 2013-06-14 | R4 | 608h | 608h | LTE_CA_B19_B21-Perf | 30 | NTT DOCOMO | Kei ANDO | Rel-12 | 59 | Issam | CA | LTE_CA_B19_B21-Perf | RP-130534 |  |  |
| 2326 | 625.23 | **Deleted -LTE Advanced inter-band Carrier Aggregation of Band 8 and Band 26** | 204d? | 2013-03-04 A | 2013-12-06 A | 100% | 2013-03-04 | 2013-12-06 | 204d? |  | R4 | 4848h | 4848h | LTE_CA_B8_B26 | 30 | KT | Chungwoo HWANG (cwhwang@kt.com) | Rel-12 | 59 | Issam | CA | LTE_CA_B8_B26 |  | PCG-32 | RP-62 |
| 2327 | 625.23.1 | Deleted - Core part:LTE Advanced inter-band Carrier Aggregation of Band 8 and Band 26 | 201d? | 2013-03-04 A | 2013-12-06 A | 100% | 2013-03-04 | 2013-12-06 | 201d? | finish no earlier than 2013-12-06 | R4 | 1608h | 1608h | LTE_CA_B8_B26-Core | 30 | KT | Chungwoo HWANG (cwhwang@kt.com) | Rel-12 | 59 | Issam | CA | LTE_CA_B8_B26-Core | RP-131549 | PCG-32 | RP-62 |
| 2328 | 625.23.2 | Deleted - Perf. part:LTE Advanced inter-band Carrier Aggregation of Band 8 and Band 26 | 201d? | 2013-03-04 A | 2013-12-06 A | 100% | 2013-03-04 | 2013-12-06 | 201d? | finish no earlier than 2013-12-06 | R4 | 1608h | 1608h | LTE_CA_B8_B26-Perf | 30 | KT | Chungwoo HWANG (cwhwang@kt.com) | Rel-12 | 59 | Issam | CA | LTE_CA_B8_B26-Perf | RP-131550 | PCG-32 | RP-62 |
| 2329 | 625.24 | **LTE Advanced dual uplink inter-band Carrier Aggregation Class A1** | 474d? | 2013-03-04 A | 2014-12-15 A | 100% | 2013-03-04 | 2014-09-12 | 405d? |  | R4 | 11272h | 11272h | LTE_CA_2UL-A1 | 30 | Huawei | Liu Ye (leo.liuye@huawei.com) | Rel-12 | 59 | Issam | CA | LTE_CA_2UL-A1 |  |  |  |
| 2330 | 625.24.1 | Core part:LTE Advanced dual uplink inter-band Carrier Aggregation Class A1 | 468d? | 2013-03-04 A | 2014-12-15 A | 100% | 2013-03-04 | 2014-09-12 | 402d? | finish no earlier than 2014-12-15 | R4 | 3744h | 3744h | LTE_CA_2UL-A1-Core | 30 | Huawei | Liu Ye (leo.liuye@huawei.com) | Rel-12 | 59 | Issam | CA | LTE_CA_2UL-A1-Core | RP-141732 |  |  |
| 2331 | 625.24.2 | Perf. part:LTE Advanced dual uplink inter-band Carrier Aggregation Class A1 | 467d? | 2013-03-13 A | 2014-12-15 A | 100% | 2013-03-08 | 2014-09-12 | 401d? | finish no earlier than 2014-12-15 | R4 | 3736h | 3736h | LTE_CA_2UL-A1-Perf | 30 | Huawei | Liu Ye (leo.liuye@huawei.com) | Rel-12 | 59 | Issam | CA | LTE_CA_2UL-A1-Perf | RP-141732 |  |  |
| 2332 | 625.25 | **LTE Advanced dual uplink inter-band Carrier Aggregation Class A2** | 474d? | 2013-03-04 A | 2014-12-15 A | 100% | 2013-03-04 | 2014-09-12 | 405d? |  | R4 | 11272h | 11272h | LTE_CA_2UL-A2 | 30 | Qualcomm | Gene Fong (gfong@qti.qualcomm.com) | Rel-12 | 59 | Issam | CA | LTE_CA_2UL-A2 |  |  |  |
| 2333 | 625.25.1 | Core part:LTE Advanced dual uplink inter-band Carrier Aggregation Class A2 | 468d? | 2013-03-04 A | 2014-12-15 A | 100% | 2013-03-04 | 2014-09-12 | 402d? | finish no earlier than 2014-12-15 | R4 | 3744h | 3744h | LTE_CA_2UL-A2-Core | 30 | Qualcomm | Gene Fong (gfong@qti.qualcomm.com) | Rel-12 | 59 | Issam | CA | LTE_CA_2UL-A2-Core | RP-141732 |  |  |
| 2334 | 625.25.2 | Perf. part:LTE Advanced dual uplink inter-band Carrier Aggregation Class A2 | 467d? | 2013-03-13 A | 2014-12-15 A | 100% | 2013-03-08 | 2014-09-12 | 401d? | finish no earlier than 2014-12-15 | R4 | 3736h | 3736h | LTE_CA_2UL-A2-Perf | 30 | Qualcomm | Gene Fong (gfong@qti.qualcomm.com) | Rel-12 | 59 | Issam | CA | LTE_CA_2UL-A2-Perf | RP-141732 |  |  |
| 2335 | 625.26 | **LTE Advanced dual uplink inter-band Carrier Aggregation Class A3** | 474d? | 2013-03-04 A | 2014-12-15 A | 100% | 2013-03-04 | 2014-09-12 | 405d? |  | R4 | 11264h | 11264h | LTE_CA_2UL-A3 | 30 | Ericsson | christian.bergljung@ericsson.com | Rel-12 | 59 | Issam | CA | LTE_CA_2UL-A3 |  |  |  |
| 2336 | 625.26.1 | Core part:LTE Advanced dual uplink inter-band Carrier Aggregation Class A3 | 467d? | 2013-03-04 A | 2014-12-15 A | 100% | 2013-03-04 | 2014-09-12 | 401d? | finish no earlier than 2014-12-15 | R4 | 3736h | 3736h | LTE_CA_2UL-A3-Core | 30 | Ericsson | christian.bergljung@ericsson.com | Rel-12 | 59 | Issam | CA | LTE_CA_2UL-A3-Core | RP-141732 |  |  |
| 2337 | 625.26.2 | Perf. part:LTE Advanced dual uplink inter-band Carrier Aggregation Class A3 | 467d? | 2013-03-13 A | 2014-12-15 A | 100% | 2013-03-08 | 2014-09-12 | 401d? | finish no earlier than 2014-12-15 | R4 | 3736h | 3736h | LTE_CA_2UL-A3-Perf | 30 | Ericsson | christian.bergljung@ericsson.com | Rel-12 | 59 | Issam | CA | LTE_CA_2UL-A3-Perf | RP-141732 |  |  |
| 2338 | 625.27 | **LTE Advanced dual uplink inter-band Carrier Aggregation Class A4** | 474d? | 2013-03-04 A | 2014-12-15 A | 100% | 2013-03-04 | 2014-09-12 | 405d? |  | R4 | 11272h | 11272h | LTE_CA_2UL-A4 | 30 | Nokia | petri.j.vasenkari@nokia.com | Rel-12 | 59 | Issam | CA | LTE_CA_2UL-A4 |  |  |  |
| 2339 | 625.27.1 | Core part:LTE Advanced dual uplink inter-band Carrier Aggregation Class A4 | 468d? | 2013-03-04 A | 2014-12-15 A | 100% | 2013-03-04 | 2014-09-12 | 402d? | finish no earlier than 2014-12-15 | R4 | 3744h | 3744h | LTE_CA_2UL-A4-Core | 30 | Nokia | petri.j.vasenkari@nokia.com | Rel-12 | 59 | Issam | CA | LTE_CA_2UL-A4-Core | RP-141732 |  |  |
| 2340 | 625.27.2 | Perf. part:LTE Advanced dual uplink inter-band Carrier Aggregation Class A4 | 467d? | 2013-03-13 A | 2014-12-15 A | 100% | 2013-03-08 | 2014-09-12 | 401d? | finish no earlier than 2014-12-15 | R4 | 3736h | 3736h | LTE_CA_2UL-A4-Perf | 30 | Nokia | petri.j.vasenkari@nokia.com | Rel-12 | 59 | Issam | CA | LTE_CA_2UL-A4-Perf | RP-141732 |  |  |
| 2341 | 625.28 | **LTE Advanced dual uplink inter-band Carrier Aggregation Class A5** | 474d? | 2013-03-04 A | 2014-12-15 A | 100% | 2013-03-04 | 2014-09-12 | 405d? |  | R4 | 11264h | 11264h | LTE_CA_2UL-A5 | 30 | NTT DOCOMO | kei.andou.ye@nttdocomo.com | Rel-12 | 59 | Issam | CA | LTE_CA_2UL-A5 |  |  |  |
| 2342 | 625.28.1 | Core part:LTE Advanced dual uplink inter-band Carrier Aggregation Class A5 | 467d? | 2013-03-04 A | 2014-12-15 A | 100% | 2013-03-04 | 2014-09-12 | 401d? | finish no earlier than 2014-12-15 | R4 | 3736h | 3736h | LTE_CA_2UL-A5-Core | 30 | NTT DOCOMO | kei.andou.ye@nttdocomo.com | Rel-12 | 59 | Issam | CA | LTE_CA_2UL-A5-Core | RP-141732 |  |  |
| 2343 | 625.28.2 | Perf. part:LTE Advanced dual uplink inter-band Carrier Aggregation Class A5 | 467d? | 2013-03-13 A | 2014-12-15 A | 100% | 2013-03-08 | 2014-09-12 | 401d? | finish no earlier than 2014-12-15 | R4 | 3736h | 3736h | LTE_CA_2UL-A5-Perf | 30 | NTT DOCOMO | kei.andou.ye@nttdocomo.com | Rel-12 | 59 | Issam | CA | LTE_CA_2UL-A5-Perf | RP-141732 |  |  |
| 2344 | 625.29 | **LTE Advanced intra-band contiguous Carrier Aggregation in Band 39** | 269d? | 2013-03-04 A | 2014-03-06 A | 100% | 2013-03-04 | 2014-03-06 | 269d? |  | R4 | 6400h | 6400h | LTE_CA_C_B39 | 30 | China Mobile | Li Nan (linan@chinamobile.com) | Rel-12 | 59 | Issam | CA | LTE_CA_C_B39 |  |  |  |
| 2345 | 625.29.1 | Core part: LTE Advanced intra-band contiguous Carrier Aggregation in Band 39 | 266d? | 2013-03-04 A | 2014-03-06 A | 100% | 2013-03-04 | 2014-03-06 | 266d? | finish no earlier than 2014-03-06 | R4 | 2128h | 2128h | LTE_CA_C_B39-Core | 30 | China Mobile | Li Nan (linan@chinamobile.com) | Rel-12 | 59 | Issam | CA | LTE_CA_C_B39-Core | RP-140428 |  |  |
| 2346 | 625.29.2 | Perf. part: LTE Advanced intra-band contiguous Carrier Aggregation in Band 39 | 265d? | 2013-03-07 A | 2014-03-06 A | 100% | 2013-03-07 | 2014-03-06 | 265d? | finish no earlier than 2014-03-06 | R4 | 2120h | 2120h | LTE_CA_C_B39-Perf | 30 | China Mobile | Li Nan (linan@chinamobile.com) | Rel-12 | 59 | Issam | CA | LTE_CA_C_B39-Perf | RP-140428 |  |  |

Notes:
- 2323: Inter-band 1 UL / Impacted TSs and TRs: LTE
- 2324: RP#60 completed / Impacted TSs and TRs: 36.101, 36.104, 36.133, new generic TR 36.851
- 2325: RP#60 completed / Impacted TSs and TRs: 36.141, 36.307
- 2326: Inter-band 1 UL / Impacted TSs and TRs: LTE
- 2327: RP#62 stopped (at 20%) / Impacted TSs and TRs: 36.101, 36.104, 36.133, new generic TR 36.851
- 2328: RP#62 stopped (at 20%) / Impacted TSs and TRs: 36.141, 36.307
- 2329: Inter-band CA 2UL / Impacted TSs and TRs: LTE
- 2330: ; WID: RP-142043->RP-141941; Stat Rep: RP-141084->RP-141732 / Impacted TSs and TRs: 36.101, 36.104, New generic TR 36.860
- 2331: ; WID: RP-142043->RP-141941; Stat Rep: RP-141084->RP-141732 / Impacted TSs and TRs: 36.133
- 2332: Inter-band CA 2UL / Impacted TSs and TRs: LTE
- 2333: ; Stat Rep: RP-141084->RP-141732 / Impacted TSs and TRs: 36.101, 36.104, 36.133, New generic TR 36.860
- 2334: ; Stat Rep: RP-141084->RP-141732 / Impacted TSs and TRs: 36.141, 36.307
- 2335: Inter-band CA 2UL / Impacted TSs and TRs: LTE
- 2336: ; Stat Rep: RP-141084->RP-141732 / Impacted TSs and TRs: 36.101, 36.104, 36.133, New generic TR 36.860
- 2337: ; Stat Rep: RP-141084->RP-141732 / Impacted TSs and TRs: 36.141, 36.307
- 2338: Inter-band CA 2UL. RP#65 updated WID RP-140476=>RP-141160. / Impacted TSs and TRs: LTE
- 2339: ; WID: RP-142043->RP-141967; Stat Rep: RP-141084->RP-141732 / Impacted TSs and TRs: 36.101, 36.104, 36.133, New generic TR 36.860
- 2340: ; WID: RP-142043->RP-141967; Stat Rep: RP-141084->RP-141732 / Impacted TSs and TRs: 36.141, 36.307
- 2341: Inter-band CA 2UL. RP#65 updated WID RP-131146=>RP-141195. Changed Rapp Renesas=>Broadcom=>NTT DOCOMO / Impacted TSs and TRs: LTE
- 2342: ; Stat Rep: RP-141084->RP-141732 / Impacted TSs and TRs: 36.101, 36.104, 36.133, New generic TR 36.860
- 2343: ; Stat Rep: RP-141084->RP-141732 / Impacted TSs and TRs: 36.141, 36.307
- 2344: Intra-band C 2DL/2UL / Impacted TSs and TRs: LTE
- 2345: RP#63 completed / Impacted TSs and TRs: 36.101, 36.104, 36.133, New TR 36.833-1-39 [instead of 36.845]
- 2346: RP#63 completed / Impacted TSs and TRs: 36.141, 36.307

| ID | WBS | Task | Duration | Start | Finish | Complete | Baseline start | Baseline finish | Baseline duration | Constraint | Resources | Work | Actual work | Acronym | PCG approved | WI rapporteur name | WI rapporteur e-mail | Release | TSG approved | MCC resp | Special Focus Doc | Acronym_3GU_Export | Status Report | PCG stopped | TSG stopped |
| --- | --- | --- | --- | --- | --- | --- | --- | --- | --- | --- | --- | --- | --- | --- | --- | --- | --- | --- | --- | --- | --- | --- | --- | --- | --- |
| 2347 | 625.30 | **LTE Advanced intra-band non-contiguous Carrier Aggregation: framework requirements for 2UL** | 397d? | 2013-06-18 A | 2014-12-15 A | 100% | 2013-06-18 | 2014-09-12 | 328d? |  | R4 | 6328h | 6328h | LTE_CA_NC_2UL | 31 | Nokia | petri.j.vasenkari@nokia.com | Rel-12 | 60 | Issam | CA | LTE_CA_NC_2UL |  |  |  |
| 2348 | 625.30.1 | Core part:LTE Advanced intra-band non-contiguous Carrier Aggregation: framework requirements for 2UL | 394d? | 2013-06-18 A | 2014-12-15 A | 100% | 2013-06-18 | 2014-09-12 | 328d? | finish no earlier than 2014-12-15 | R4 | 3152h | 3152h | LTE_CA_NC_2UL-Core | 31 | Nokia | petri.j.vasenkari@nokia.com | Rel-12 | 60 | Issam | CA | LTE_CA_NC_2UL-Core | RP-141732 |  |  |
| 2349 | 625.31 | **Deleted -LTE Advanced intra-band non-contiguous Carrier Aggregation in Band 41 for 2UL** | 191d? | 2013-06-19 A | 2014-03-06 A | 100% | 2013-06-19 | 2014-03-06 | 191d? |  | R4 | 4576h | 4576h | LTE_CA_NC_B41_2UL | 31 | Sprint | yang.xu@clearwire.com | Rel-12 | 60 | Issam | CA | LTE_CA_NC_B41_2UL | RP-140428 | PCG-32 | RP-63 |
| 2350 | 625.31.1 | Deleted - Core part:LTE Advanced intra-band non-contiguous Carrier Aggregation in Band 41 for 2UL | 191d? | 2013-06-19 A | 2014-03-06 A | 100% | 2013-06-19 | 2014-03-06 | 191d? | finish no earlier than 2014-03-06 | R4 | 1528h | 1528h | LTE_CA_NC_B41_2UL-Core | 31 | Sprint | yang.xu@clearwire.com | Rel-12 | 60 | Issam | CA | LTE_CA_NC_B41_2UL-Core | RP-140428 | PCG-32 | RP-63 |
| 2351 | 625.31.2 | Deleted - Perf. part:LTE Advanced intra-band non-contiguous Carrier Aggregation in Band 41 for 2UL | 190d? | 2013-06-20 A | 2014-03-06 A | 100% | 2013-06-20 | 2014-03-06 | 190d? | finish no earlier than 2014-03-06 | R4 | 1520h | 1520h | LTE_CA_NC_B41_2UL-Perf | 31 | Sprint | yang.xu@clearwire.com | Rel-12 | 60 | Issam | CA | LTE_CA_NC_B41_2UL-Perf | RP-140428 | PCG-32 | RP-63 |
| 2352 | 625.32 | **LTE Advanced intra-band non-contiguous Carrier Aggregation in Band 4 for 2UL** | 396d? | 2013-06-19 A | 2014-12-15 A | 100% | 2013-06-19 | 2014-09-12 | 327d? |  | R4 | 9448h | 9448h | LTE_CA_NC_B4_2UL | 31 | T-Mobile USA | nelson.ueng@t-mobile.com | Rel-12 | 60 | Issam | CA | LTE_CA_NC_B4_2UL |  |  |  |
| 2353 | 625.32.1 | Core part:LTE Advanced intra-band non-contiguous Carrier Aggregation in Band 4 for 2UL | 393d? | 2013-06-19 A | 2014-12-15 A | 100% | 2013-06-19 | 2014-09-12 | 327d? | finish no earlier than 2014-12-15 | R4 | 3144h | 3144h | LTE_CA_NC_B4_2UL-Core | 31 | T-Mobile USA | nelson.ueng@t-mobile.com | Rel-12 | 60 | Issam | CA | LTE_CA_NC_B4_2UL-Core | RP-141732 |  |  |
| 2354 | 625.32.2 | Perf. part:LTE Advanced intra-band non-contiguous Carrier Aggregation in Band 4 for 2UL | 392d? | 2013-06-25 A | 2014-12-15 A | 100% | 2013-06-20 | 2014-09-12 | 326d? | finish no earlier than 2014-12-15 | R4 | 3136h | 3136h | LTE_CA_NC_B4_2UL-Perf | 31 | T-Mobile USA | nelson.ueng@t-mobile.com | Rel-12 | 60 | Issam | CA | LTE_CA_NC_B4_2UL-Perf | RP-141732 |  |  |
| 2355 | 625.33 | **LTE Advanced intra-band contiguous Carrier Aggregation in Band 23** | 127d? | 2013-06-18 A | 2013-12-06 A | 100% | 2013-06-18 | 2013-12-06 | 127d? |  | R4 | 3032h | 3032h | LTE_CA_C_B23 | 31 | Dish Network | mariam.sorond@dish.com, johny.kim@dish.com | Rel-12 | 60 | Issam | CA | LTE_CA_C_B23 |  |  |  |
| 2356 | 625.33.1 | Core part: LTE Advanced intra-band contiguous Carrier Aggregation in Band 23 | 126d? | 2013-06-18 A | 2013-12-06 A | 100% | 2013-06-18 | 2013-12-06 | 126d? | finish no earlier than 2013-12-06 | R4 | 1008h | 1008h | LTE_CA_C_B23-Core | 31 | Dish Network | mariam.sorond@dish.com, johny.kim@dish.com | Rel-12 | 60 | Issam | CA | LTE_CA_C_B23-Core | RP-131565 |  |  |
| 2357 | 625.33.2 | Perf. part: LTE Advanced intra-band contiguous Carrier Aggregation in Band 23 | 126d? | 2013-06-18 A | 2013-12-06 A | 100% | 2013-06-18 | 2013-12-06 | 126d? | finish no earlier than 2013-12-06 | R4 | 1008h | 1008h | LTE_CA_C_B23-Perf | 31 | Dish Network | mariam.sorond@dish.com, johny.kim@dish.com | Rel-12 | 60 | Issam | CA | LTE_CA_C_B23-Perf | RP-131566 |  |  |
| 2358 | 625.34 | **LTE Advanced intra-band non-contiguous Carrier Aggregation in Band 23** | 263d? | 2013-06-18 A | 2014-06-13 A | 100% | 2013-06-18 | 2014-06-13 | 263d? |  | R4 | 5216h | 5216h | LTE_CA_NC_B23 | 31 | Dish Network | mariam.sorond@dish.com, johny.kim@dish.com | Rel-12 | 60 | Issam | CA | LTE_CA_NC_B23 |  |  |  |
| 2359 | 625.34.1 | Core part:LTE Advanced intra-band non-contiguous Carrier Aggregation in Band 23 | 126d? | 2013-06-18 A | 2013-12-06 A | 100% | 2013-06-18 | 2013-12-06 | 126d? | finish no earlier than 2013-12-06 | R4 | 1008h | 1008h | LTE_CA_NC_B23-Core | 31 | Dish Network | mariam.sorond@dish.com, johny.kim@dish.com | Rel-12 | 60 | Issam | CA | LTE_CA_NC_B23-Core | RP-131577 |  |  |
| 2360 | 625.34.2 | Perf. part:LTE Advanced intra-band non-contiguous Carrier Aggregation in Band 23 | 263d? | 2013-06-18 A | 2014-06-13 A | 100% | 2013-06-18 | 2014-06-13 | 263d? | finish no earlier than 2014-06-13 | R4 | 2104h | 2104h | LTE_CA_NC_B23-Perf | 31 | Dish Network | mariam.sorond@dish.com, johny.kim@dish.com | Rel-12 | 60 | Issam | CA | LTE_CA_NC_B23-Perf | RP-140569 |  |  |
| 2361 | 625.35 | **LTE Advanced inter-band Carrier Aggregation of Band 12 and Band 25** | 127d? | 2013-06-18 A | 2013-12-06 A | 100% | 2013-06-18 | 2013-12-06 | 127d? |  | R4 | 3032h | 3032h | LTE_CA_B12_B25 | 31 | US Cellular | sebastian.thalanany@uscellular.com | Rel-12 | 60 | Issam | CA | LTE_CA_B12_B25 |  |  |  |
| 2362 | 625.35.1 | Core part:LTE Advanced inter-band Carrier Aggregation of Band 12 and Band 25 | 126d? | 2013-06-18 A | 2013-12-06 A | 100% | 2013-06-18 | 2013-12-06 | 126d? | finish no earlier than 2013-12-06 | R4 | 1008h | 1008h | LTE_CA_B12_B25-Core | 31 | US Cellular | sebastian.thalanany@uscellular.com | Rel-12 | 60 | Issam | CA | LTE_CA_B12_B25-Core | RP-131705 |  |  |
| 2363 | 625.35.2 | Perf. part:LTE Advanced inter-band Carrier Aggregation of Band 12 and Band 25 | 126d? | 2013-06-19 A | 2013-12-06 A | 100% | 2013-06-19 | 2013-12-06 | 126d? | finish no earlier than 2013-12-06 | R4 | 1008h | 1008h | LTE_CA_B12_B25-Perf | 31 | US Cellular | sebastian.thalanany@uscellular.com | Rel-12 | 60 | Issam | CA | LTE_CA_B12_B25-Perf | RP-131706 |  |  |
| 2364 | 625.36 | **LTE Advanced inter-band Carrier Aggregation of Band 1 and Band 18 - Additional bandwidth combination set** | 61d? | 2013-06-18 A | 2013-09-06 A | 100% | 2013-06-18 | 2013-09-06 | 61d? |  | R4 | 1464h | 1464h | LTE_CA_B1_B18_BWset | 31 | KDDI | Masaaki Obara (ms-obara@kddi.com) | Rel-12 | 60 | Issam | CA | LTE_CA_B1_B18_BWset |  |  |  |
| 2365 | 625.36.1 | Core part:LTE Advanced inter-band Carrier Aggregation of Band 1 and Band 18 - Additional bandwidth combination set | 61d? | 2013-06-18 A | 2013-09-06 A | 100% | 2013-06-18 | 2013-09-06 | 61d? | finish no earlier than 2013-09-06 | R4 | 488h | 488h | LTE_CA_B1_B18_BWset-Core | 31 | KDDI | Masaaki Obara (ms-obara@kddi.com) | Rel-12 | 60 | Issam | CA | LTE_CA_B1_B18_BWset-Core | RP-131003 |  |  |
| 2366 | 625.36.2 | Perf. part:LTE Advanced inter-band Carrier Aggregation of Band 1 and Band 18 - Additional bandwidth combination set | 61d? | 2013-06-18 A | 2013-09-06 A | 100% | 2013-06-18 | 2013-09-06 | 61d? | finish no earlier than 2013-09-06 | R4 | 488h | 488h | LTE_CA_B1_B18_BWset-Perf | 31 | KDDI | Masaaki Obara (ms-obara@kddi.com) | Rel-12 | 60 | Issam | CA | LTE_CA_B1_B18_BWset-Perf | RP-131004 |  |  |
| 2367 | 625.37 | **LTE Advanced inter-band Carrier Aggregation of Band 2 and Band 5** | 61d? | 2013-06-18 A | 2013-09-06 A | 100% | 2013-06-18 | 2013-09-06 | 61d? |  | R4 | 1464h | 1464h | LTE_CA_B2_B5 | 31 | AT&T | marc.grant@att.com | Rel-12 | 60 | Issam | CA | LTE_CA_B2_B5 |  |  |  |
| 2368 | 625.37.1 | Core part:LTE Advanced inter-band Carrier Aggregation of Band 2 and Band 5 | 61d? | 2013-06-18 A | 2013-09-06 A | 100% | 2013-06-18 | 2013-09-06 | 61d? | finish no earlier than 2013-09-06 | R4 | 488h | 488h | LTE_CA_B2_B5-Core | 31 | AT&T | marc.grant@att.com | Rel-12 | 60 | Issam | CA | LTE_CA_B2_B5-Core | RP-131009 |  |  |
| 2369 | 625.37.2 | Perf. part:LTE Advanced inter-band Carrier Aggregation of Band 2 and Band 5 | 61d? | 2013-06-18 A | 2013-09-06 A | 100% | 2013-06-18 | 2013-09-06 | 61d? | finish no earlier than 2013-12-06 | R4 | 488h | 488h | LTE_CA_B2_B5-Perf | 31 | AT&T | marc.grant@att.com | Rel-12 | 60 | Issam | CA | LTE_CA_B2_B5-Perf | RP-131010 |  |  |
| 2370 | 625.38 | **LTE Advanced 3 Band Carrier Aggregation (3DL/1UL) of Band 2, Band 5 and Band 30** | 329d? | 2013-06-18 A | 2014-09-12 A | 100% | 2013-06-18 | 2014-09-12 | 328d? |  | R4 | 7872h | 7872h | LTE_CA_B2_B5_B30 | 31 | AT&T | marc.grant@att.com | Rel-12 | 60 | Issam | CA | LTE_CA_B2_B5_B30 |  |  |  |
| 2371 | 625.38.1 | Core part:LTE Advanced 3 Band Carrier Aggregation (3DL/1UL) of Band 2, Band 5 and Band 30 | 328d? | 2013-06-18 A | 2014-09-12 A | 100% | 2013-06-18 | 2014-09-12 | 328d? | finish no earlier than 2014-09-12 | R4 | 2624h | 2624h | LTE_CA_B2_B5_B30-Core | 31 | AT&T | marc.grant@att.com | Rel-12 | 60 | Issam | CA | LTE_CA_B2_B5_B30-Core | RP-141084 |  |  |
| 2372 | 625.38.2 | Perf. part:LTE Advanced 3 Band Carrier Aggregation (3DL/1UL) of Band 2, Band 5 and Band 30 | 327d? | 2013-06-18 A | 2014-09-12 A | 100% | 2013-06-18 | 2014-09-12 | 327d? | finish no earlier than 2014-09-12 | R4 | 2616h | 2616h | LTE_CA_B2_B5_B30-Perf | 31 | AT&T | marc.grant@att.com | Rel-12 | 60 | Issam | CA | LTE_CA_B2_B5_B30-Perf | RP-141084 |  |  |

Notes:
- 2347: Intra-band non-contig. CA 2DL / Impacted TSs and TRs: LTE
- 2348: ; WID: RP-142043->RP-141962; Stat Rep: RP-141084->RP-141732 / Impacted TSs and TRs: 36.101, 36.104, 36.133, 36.306, 36.331, New TR 36.833-4
- 2349: Intra-band NC 2UL / Impacted TSs and TRs: LTE
- 2350: RP#63 stopped (5% complete). Reason: Market conditions have eliminated the need for this feature, at least for the foreseeable future / Impacted TSs and TRs: 36.101, 36.104, 36.133, new TR 36.833-3-41
- 2351: RP#63 stopped (0% complete). / Impacted TSs and TRs: 36.101, 36.104, 36.133, 36.141, 36.307
- 2352: Intra-band non-contig. CA 2DL / Impacted TSs and TRs: LTE
- 2353: ; WID: RP-142043->RP-141784; Stat Rep: RP-141084->RP-141732 / Impacted TSs and TRs: 36.101, 36.104, 36.133, new TR 36.833-4-04
- 2354: ; WID: RP-142043->RP-141784; Stat Rep: RP-141084->RP-141732 / Impacted TSs and TRs: 36.101, 36.104, 36.133, 36.141, 36.307
- 2355: Intra-band C CA / Impacted TSs and TRs: LTE
- 2356: RP#62 completed / Impacted TSs and TRs: 36.101, 36.104, 36.133, new TR 36.833-1-23 [instead of 36.864]
- 2357: RP#62 completed / Impacted TSs and TRs: 36.141, 36.307
- 2358: Intra-band non-contig. CA 2DL / Impacted TSs and TRs: LTE
- 2359: RP#62 completed / Impacted TSs and TRs: 36.101, 36.104, 36.133, new TR 36.833-2-23
- 2360: RP#64 completed. TR 36.833-2-23v200 for Approval / Impacted TSs and TRs: 36.101, 36.133, 36.141, 36.307, new TR 36.833-2-23
- 2361: Inter-band 1UL/2DL / Impacted TSs and TRs: LTE
- 2362: RP#62 completed / Impacted TSs and TRs: 36.101, 36.104, 36.133, new generic TR 36.851
- 2363: RP#62 completed / Impacted TSs and TRs: 36.141, 36.307
- 2364: Inter-band 1UL/2DL / Impacted TSs and TRs: LTE
- 2365: RP#61 completed / Impacted TSs and TRs: 36.101, new generic TR 36.851
- 2366: RP#61 completed / Impacted TSs and TRs: 36.307
- 2367: Inter-band 2DL / Impacted TSs and TRs: LTE
- 2368: RP#61 completed / Impacted TSs and TRs: 36.101, 36.104, 36.307
- 2369: RP#61 completed / Impacted TSs and TRs: 36.101, 36.104, 36.133, 36.141, 36.307
- 2370: Inter-band 3DL / Impacted TSs and TRs: LTE
- 2371: RP#65 completed. TR 36.853v200 for Approval / Impacted TSs and TRs: 36.101, 36.104, 36.133, 36.141, 36.307, new generic TR 36.853 (3 Band CA with 1UL)
- 2372: RP#65 completed / Impacted TSs and TRs: 36.101, 36.104, 36.133, 36.141, 36.307

| ID | WBS | Task | Duration | Start | Finish | Complete | Baseline start | Baseline finish | Baseline duration | Constraint | Resources | Work | Actual work | Acronym | PCG approved | WI rapporteur name | WI rapporteur e-mail | Release | TSG approved | MCC resp | PCG stopped | TSG stopped | Special Focus Doc | Acronym_3GU_Export | Status Report |
| --- | --- | --- | --- | --- | --- | --- | --- | --- | --- | --- | --- | --- | --- | --- | --- | --- | --- | --- | --- | --- | --- | --- | --- | --- | --- |
| 2373 | 625.39 | **Deleted -LTE Advanced 3 Band Carrier Aggregation (3DL/1UL) of Band 2, Band 17 and Band 30** | 127d? | 2013-06-18 A | 2013-12-06 A | 100% | 2013-06-18 | 2013-12-06 | 127d? |  | R4 | 3024h | 3024h | LTE_CA_B2_B17_B30 | 31 | AT&T | marc.grant@att.com | Rel-12 | 60 | Issam | PCG-32 | RP-62 | CA | LTE_CA_B2_B17_B30 |  |
| 2374 | 625.39.1 | Deleted - Core part:LTE Advanced 3 Band Carrier Aggregation (3DL/1UL) of Band 2, Band 17 and Band 30 | 126d? | 2013-06-18 A | 2013-12-06 A | 100% | 2013-06-18 | 2013-12-06 | 126d? | finish no earlier than 2014-06-13 | R4 | 1008h | 1008h | LTE_CA_B2_B17_B30-Core | 31 | AT&T | marc.grant@att.com | Rel-12 | 60 | Issam | PCG-32 | RP-62 | CA | LTE_CA_B2_B17_B30-Core | RP-131590 |
| 2375 | 625.39.2 | Deleted - Perf. part:LTE Advanced 3 Band Carrier Aggregation (3DL/1UL) of Band 2, Band 17 and Band 30 | 125d? | 2013-06-19 A | 2013-12-06 A | 100% | 2013-06-19 | 2013-12-06 | 125d? | finish no earlier than 2014-09-12 | R4 | 1000h | 1000h | LTE_CA_B2_B17_B30-Perf | 31 | AT&T | marc.grant@att.com | Rel-12 | 60 | Issam | PCG-32 | RP-62 | CA | LTE_CA_B2_B17_B30-Perf | RP-131591 |
| 2376 | 625.40 | **LTE Advanced 3 Band Carrier Aggregation (3DL/1UL) of Band 2, Band 29 and Band 30** | 328d? | 2013-06-19 A | 2014-09-12 A | 100% | 2013-06-19 | 2014-09-12 | 327d? |  | R4 | 7856h | 7856h | LTE_CA_B2_B29_B30 | 31 | AT&T | marc.grant@att.com | Rel-12 | 60 | Issam |  |  | CA | LTE_CA_B2_B29_B30 |  |
| 2377 | 625.40.1 | Core part:LTE Advanced 3 Band Carrier Aggregation (3DL/1UL) of Band 2, Band 29 and Band 30 | 327d? | 2013-06-19 A | 2014-09-12 A | 100% | 2013-06-19 | 2014-06-13 | 262d? | finish no earlier than 2014-09-12 | R4 | 2616h | 2616h | LTE_CA_B2_B29_B30-Core | 31 | AT&T | marc.grant@att.com | Rel-12 | 60 | Issam |  |  | CA | LTE_CA_B2_B29_B30-Core | RP-141084 |
| 2378 | 625.40.2 | Perf. part:LTE Advanced 3 Band Carrier Aggregation (3DL/1UL) of Band 2, Band 29 and Band 30 | 327d? | 2013-06-19 A | 2014-09-12 A | 100% | 2013-06-19 | 2014-09-12 | 327d? | finish no earlier than 2014-09-12 | R4 | 2616h | 2616h | LTE_CA_B2_B29_B30-Perf | 31 | AT&T | marc.grant@att.com | Rel-12 | 60 | Issam |  |  | CA | LTE_CA_B2_B29_B30-Perf | RP-141084 |
| 2379 | 625.41 | **LTE Advanced 3 Band Carrier Aggregation (3DL/1UL) of Band 4, Band 5 and Band 30** | 331d? | 2013-06-14 A | 2014-09-12 A | 100% | 2013-06-14 | 2014-09-12 | 330d? |  | R4 | 7904h | 7904h | LTE_CA_B4_B5_B30 | 31 | AT&T | marc.grant@att.com | Rel-12 | 60 | Issam |  |  | CA | LTE_CA_B4_B5_B30 |  |
| 2380 | 625.41.1 | Core part:LTE Advanced 3 Band Carrier Aggregation (3DL/1UL) of Band 4, Band 5 and Band 30 | 330d? | 2013-06-14 A | 2014-09-12 A | 100% | 2013-06-14 | 2014-09-12 | 330d? | finish no earlier than 2014-09-12 | R4 | 2640h | 2640h | LTE_CA_B4_B5_B30-Core | 31 | AT&T | marc.grant@att.com | Rel-12 | 60 | Issam |  |  | CA | LTE_CA_B4_B5_B30-Core | RP-141084 |
| 2381 | 625.41.2 | Perf. part:LTE Advanced 3 Band Carrier Aggregation (3DL/1UL) of Band 4, Band 5 and Band 30 | 327d? | 2013-06-19 A | 2014-09-12 A | 100% | 2013-06-19 | 2014-09-12 | 327d? | finish no earlier than 2014-09-12 | R4 | 2616h | 2616h | LTE_CA_B4_B5_B30-Perf | 31 | AT&T | marc.grant@att.com | Rel-12 | 60 | Issam |  |  | CA | LTE_CA_B4_B5_B30-Perf | RP-141084 |
| 2382 | 625.42 | **Deleted -LTE Advanced 3 Band Carrier Aggregation (3DL/1UL) of Band 4, Band 17 and Band 30** | 127d? | 2013-06-18 A | 2013-12-06 A | 100% | 2013-06-18 | 2013-12-06 | 127d? |  | R4 | 3040h | 3040h | LTE_CA_B4_B17_B30 | 31 | AT&T | marc.grant@att.com | Rel-12 | 60 | Issam | PCG-32 | RP-62 | CA | LTE_CA_B4_B17_B30 |  |
| 2383 | 625.42.1 | Deleted - Core part:LTE Advanced 3 Band Carrier Aggregation (3DL/1UL) of Band 4, Band 17 and Band 30 | 127d? | 2013-06-18 A | 2013-12-06 A | 100% | 2013-06-18 | 2013-12-06 | 127d? | finish no earlier than 2013-12-06 | R4 | 1016h | 1016h | LTE_CA_B4_B17_B30-Core | 31 | AT&T | marc.grant@att.com | Rel-12 | 60 | Issam | PCG-32 | RP-62 | CA | LTE_CA_B4_B17_B30-Core | RP-131598 |
| 2384 | 625.42.2 | Deleted - Perf. part:LTE Advanced 3 Band Carrier Aggregation (3DL/1UL) of Band 4, Band 17 and Band 30 | 126d? | 2013-06-19 A | 2013-12-06 A | 100% | 2013-06-19 | 2013-12-06 | 126d? | finish no earlier than 2013-12-06 | R4 | 1008h | 1008h | LTE_CA_B4_B17_B30-Perf | 31 | AT&T | marc.grant@att.com | Rel-12 | 60 | Issam | PCG-32 | RP-62 | CA | LTE_CA_B4_B17_B30-Perf | RP-131599 |
| 2385 | 625.43 | **LTE Advanced 3 Band Carrier Aggregation (3DL/1UL) of Band 4, Band 29 and Band 30** | 331d? | 2013-06-14 A | 2014-09-12 A | 100% | 2013-06-14 | 2014-09-12 | 330d? |  | R4 | 7904h | 7904h | LTE_CA_B4_B29_B30 | 31 | AT&T | marc.grant@att.com | Rel-12 | 60 | Issam |  |  | CA | LTE_CA_B4_B29_B30 |  |
| 2386 | 625.43.1 | Core part:LTE Advanced 3 Band Carrier Aggregation (3DL/1UL) of Band 4, Band 29 and Band 30 | 330d? | 2013-06-14 A | 2014-09-12 A | 100% | 2013-06-14 | 2014-09-12 | 330d? | finish no earlier than 2014-09-12 | R4 | 2640h | 2640h | LTE_CA_B4_B29_B30-Core | 31 | AT&T | marc.grant@att.com | Rel-12 | 60 | Issam |  |  | CA | LTE_CA_B4_B29_B30-Core | RP-141084 |
| 2387 | 625.43.2 | Perf. part:LTE Advanced 3 Band Carrier Aggregation (3DL/1UL) of Band 4, Band 29 and Band 30 | 327d? | 2013-06-19 A | 2014-09-12 A | 100% | 2013-06-19 | 2014-09-12 | 327d? | finish no earlier than 2014-09-12 | R4 | 2616h | 2616h | LTE_CA_B4_B29_B30-Perf | 31 | AT&T | marc.grant@att.com | Rel-12 | 60 | Issam |  |  | CA | LTE_CA_B4_B29_B30-Perf | RP-141084 |
| 2388 | 625.44 | **LTE Advanced 3 Band Carrier Aggregation (3DL/1UL) of Band 2, Band 4 and Band 13** | 331d? | 2013-06-14 A | 2014-09-12 A | 100% | 2013-06-14 | 2014-09-12 | 330d? |  | R4 | 7904h | 7904h | LTE_CA_B2_B4_B13 | 31 | Verizon | zheng.zhao@verizonwireless.com | Rel-12 | 60 | Issam |  |  | CA | LTE_CA_B2_B4_B13 |  |
| 2389 | 625.44.1 | Core part:LTE Advanced 3 Band Carrier Aggregation (3DL/1UL) of Band 2, Band 4 and Band 13 | 330d? | 2013-06-14 A | 2014-09-12 A | 100% | 2013-06-14 | 2014-09-12 | 330d? | finish no earlier than 2014-09-12 | R4 | 2640h | 2640h | LTE_CA_B2_B4_B13-Core | 31 | Verizon | zheng.zhao@verizonwireless.com | Rel-12 | 60 | Issam |  |  | CA | LTE_CA_B2_B4_B13-Core | RP-141084 |
| 2390 | 625.44.2 | Perf. part:LTE Advanced 3 Band Carrier Aggregation (3DL/1UL) of Band 2, Band 4 and Band 13 | 327d? | 2013-06-19 A | 2014-09-12 A | 100% | 2013-06-19 | 2014-09-12 | 327d? | finish no earlier than 2014-09-12 | R4 | 2616h | 2616h | LTE_CA_B2_B4_B13-Perf | 31 | Verizon | zheng.zhao@verizonwireless.com | Rel-12 | 60 | Issam |  |  | CA | LTE_CA_B2_B4_B13-Perf | RP-141084 |
| 2391 | 625.45 | **LTE Advanced 3 Band Carrier Aggregation (3DL/1UL) of Band 2, Band 2 and Band 13** | 329d? | 2013-06-18 A | 2014-09-12 A | 100% | 2013-06-18 | 2014-09-12 | 328d? |  | R4 | 7864h | 7864h | LTE_CA_B2_B2_B13 | 31 | Verizon | zheng.zhao@verizonwireless.com | Rel-12 | 60 | Issam |  |  | CA | LTE_CA_B2_B2_B13 |  |
| 2392 | 625.45.1 | Core part:LTE Advanced 3 Band Carrier Aggregation (3DL/1UL) of Band 2, Band 2 and Band 13 | 327d? | 2013-06-18 A | 2014-09-12 A | 100% | 2013-06-18 | 2014-09-12 | 327d? | finish no earlier than 2014-09-12 | R4 | 2616h | 2616h | LTE_CA_B2_B2_B13-Core | 31 | Verizon | zheng.zhao@verizonwireless.com | Rel-12 | 60 | Issam |  |  | CA | LTE_CA_B2_B2_B13-Core | RP-141084 |
| 2393 | 625.45.2 | Perf. part:LTE Advanced 3 Band Carrier Aggregation (3DL/1UL) of Band 2, Band 2 and Band 13 | 327d? | 2013-06-19 A | 2014-09-12 A | 100% | 2013-06-19 | 2014-09-12 | 327d? | finish no earlier than 2014-09-12 | R4 | 2616h | 2616h | LTE_CA_B2_B2_B13-Perf | 31 | Verizon | zheng.zhao@verizonwireless.com | Rel-12 | 60 | Issam |  |  | CA | LTE_CA_B2_B2_B13-Perf | RP-141084 |
| 2394 | 625.46 | **LTE Advanced 3 Band Carrier Aggregation (3DL/1UL) of Band 4, Band 4 and Band 13** | 331d? | 2013-06-14 A | 2014-09-12 A | 100% | 2013-06-14 | 2014-09-12 | 330d? |  | R4 | 7928h | 7928h | LTE_CA_B4_B4_B13 | 31 | Verizon | zheng.zhao@verizonwireless.com | Rel-12 | 60 | Issam |  |  | CA | LTE_CA_B4_B4_B13 |  |
| 2395 | 625.46.1 | Core part:LTE Advanced 3 Band Carrier Aggregation (3DL/1UL) of Band 4, Band 4 and Band 13 | 330d? | 2013-06-14 A | 2014-09-12 A | 100% | 2013-06-14 | 2014-09-12 | 330d? | finish no earlier than 2014-09-12 | R4 | 2640h | 2640h | LTE_CA_B4_B4_B13-Core | 31 | Verizon | zheng.zhao@verizonwireless.com | Rel-12 | 60 | Issam |  |  | CA | LTE_CA_B4_B4_B13-Core | RP-141084 |
| 2396 | 625.46.2 | Perf. part:LTE Advanced 3 Band Carrier Aggregation (3DL/1UL) of Band 4, Band 4 and Band 13 | 330d? | 2013-06-14 A | 2014-09-12 A | 100% | 2013-06-14 | 2014-09-12 | 330d? | finish no earlier than 2014-09-12 | R4 | 2640h | 2640h | LTE_CA_B4_B4_B13-Perf | 31 | Verizon | zheng.zhao@verizonwireless.com | Rel-12 | 60 | Issam |  |  | CA | LTE_CA_B4_B4_B13-Perf | RP-141084 |

Notes:
- 2373: Inter-band 3DL / Impacted TSs and TRs: LTE
- 2374: RP#62 stopped (25% complete) following RP-131652 discussion / Impacted TSs and TRs: 36.101, 36.104, 36.133, 36.141, 36.307, new generic TR 36.853 (3 Band CA with 1UL)
- 2375: RP#62 stopped (25% complete) following RP-131652 discussion / Impacted TSs and TRs: 36.101, 36.104, 36.133, 36.141, 36.307
- 2376: Inter-band 3DL / Impacted TSs and TRs: LTE
- 2377: RP#65 completed. Updated WID RP-131697=>RP-141212 / Impacted TSs and TRs: 36.101, 36.104, 36.133, 36.141, 36.307, new generic TR 36.853 (3 Band CA with 1UL)
- 2378: RP#65 completed / Impacted TSs and TRs: 36.101, 36.104, 36.133, 36.141, 36.307
- 2379: Inter-band CA 3DL / Impacted TSs and TRs: LTE
- 2380: RP#65 completed. Updated WID RP-131698=>RP-141213 / Impacted TSs and TRs: 36.101, 36.104, 36.133, 36.141, 36.307, new generic TR 36.853 (3 Band CA with 1UL)
- 2381: RP#65 completed / Impacted TSs and TRs: 36.101, 36.104, 36.133, 36.141, 36.307
- 2382: Inter-band 3DL / Impacted TSs and TRs: LTE
- 2383: RP#62 stopped (25% complete) following RP-131653 discussion / Impacted TSs and TRs: 36.101, 36.104, 36.133, 36.141, 36.307, new generic TR 36.853 (3 Band CA with 1UL)
- 2384: RP#62 stopped (25% complete) following RP-131653 discussion / Impacted TSs and TRs: 36.101, 36.104, 36.133, 36.141, 36.307
- 2385: Inter-band CA 3DL / Impacted TSs and TRs: LTE
- 2386: RP#65 completed. Updated WID RP-131699=>RP- 141215 / Impacted TSs and TRs: 36.101, 36.104, 36.133, 36.141, 36.307, new generic TR 36.853 (3 Band CA with 1UL)
- 2387: RP#65 completed / Impacted TSs and TRs: 36.101, 36.104, 36.133, 36.141, 36.307
- 2388: Inter-band CA 3DL / Impacted TSs and TRs: LTE
- 2389: RP#65 completed. Updated RP-131684=>RP-141434 / Impacted TSs and TRs: 36.101, 36.104, 36.133, new generic TR 36.853 (3 Band CA with 1UL)
- 2390: RP#65 completed / Impacted TSs and TRs: 36.101, 36.133, 36.141, 36.307
- 2391: Inter-band CA 3DL / Impacted TSs and TRs: LTE
- 2392: RP#65 completed. Updated WID RP-131682=>RP-141435 / Impacted TSs and TRs: 36.101, 36.104, 36.133, new generic TR 36.853 (3 Band CA with 1UL)
- 2393: RP#65 completed / Impacted TSs and TRs: 36.101, 36.133, 36.141, 36.307
- 2394: Inter-band CA 3DL / Impacted TSs and TRs: LTE
- 2395: RP#65 completed. Updated WID RP-131683=>RP-141433 / Impacted TSs and TRs: 36.101, 36.104, 36.133, new generic TR 36.853 (3 Band CA with 1UL)
- 2396: RP#65 completed / Impacted TSs and TRs: 36.101, 36.133, 36.141, 36.307

| ID | WBS | Task | Duration | Start | Finish | Complete | Baseline start | Baseline finish | Baseline duration | Constraint | Resources | Work | Actual work | Acronym | PCG approved | Impacted TSs and TRs | WI rapporteur name | WI rapporteur e-mail | Release | TSG approved | MCC resp | Special Focus Doc | Acronym_3GU_Export | Status Report |
| --- | --- | --- | --- | --- | --- | --- | --- | --- | --- | --- | --- | --- | --- | --- | --- | --- | --- | --- | --- | --- | --- | --- | --- | --- |
| 2397 | 625.47 | **LTE Advanced inter-band Carrier Aggregation of Band 7 and Band 28** | 66d? | 2013-09-09 A | 2013-12-06 A | 100% | 2013-09-09 | 2013-12-06 | 66d? |  | R4 | 1584h | 1584h | LTE_CA_B7_B28 | 31 | LTE | Huawei | Liehai Liu (liuliehai@huawei.com) | Rel-12 | 61 | Issam | CA | LTE_CA_B7_B28 |  |
| 2398 | 625.47.1 | Core part:LTE Advanced inter-band Carrier Aggregation of Band 7 and Band 28 | 66d? | 2013-09-09 A | 2013-12-06 A | 100% | 2013-09-09 | 2013-12-06 | 66d? | finish no earlier than 2013-12-06 | R4 | 528h | 528h | LTE_CA_B7_B28-Core | 31 | 36.101, 36.104, 36.307 | Huawei | Liehai Liu (liuliehai@huawei.com) | Rel-12 | 61 | Issam | CA | LTE_CA_B7_B28-Core | RP-131545 |
| 2399 | 625.47.2 | Perf. part:LTE Advanced inter-band Carrier Aggregation of Band 7 and Band 28 | 66d? | 2013-09-09 A | 2013-12-06 A | 100% | 2013-09-09 | 2013-12-06 | 66d? | finish no earlier than 2013-12-06 | R4 | 528h | 528h | LTE_CA_B7_B28-Perf | 31 | 36.141 | Huawei | Liehai Liu (liuliehai@huawei.com) | Rel-12 | 61 | Issam | CA | LTE_CA_B7_B28-Perf | RP-131546 |
| 2400 | 625.48 | **LTE Advanced inter-band Carrier Aggregation of Band 5 and Band 25** | 66d? | 2013-09-09 A | 2013-12-06 A | 100% | 2013-09-09 | 2013-12-06 | 66d? |  | R4 | 1584h | 1584h | LTE_CA_B5_B25 | 31 | LTE | U.S. Cellular | sebastian.thalanany@uscellular.com | Rel-12 | 61 | Issam | CA | LTE_CA_B5_B25 |  |
| 2401 | 625.48.1 | Core part:LTE Advanced inter-band Carrier Aggregation of Band 5 and Band 25 | 66d? | 2013-09-09 A | 2013-12-06 A | 100% | 2013-09-09 | 2013-12-06 | 66d? | finish no earlier than 2013-12-06 | R4 | 528h | 528h | LTE_CA_B5_B25-Core | 31 | 36.101, 36.104, 36.133, new generic TR 36.851 | U.S. Cellular | sebastian.thalanany@uscellular.com | Rel-12 | 61 | Issam | CA | LTE_CA_B5_B25-Core | RP-131543 |
| 2402 | 625.48.2 | Perf. part:LTE Advanced inter-band Carrier Aggregation of Band 5 and Band 25 | 66d? | 2013-09-09 A | 2013-12-06 A | 100% | 2013-09-09 | 2013-12-06 | 66d? | finish no earlier than 2013-12-06 | R4 | 528h | 528h | LTE_CA_B5_B25-Perf | 31 | 36.141, 36.307 | U.S. Cellular | sebastian.thalanany@uscellular.com | Rel-12 | 61 | Issam | CA | LTE_CA_B5_B25-Perf | RP-131705 |
| 2403 | 625.49 | **LTE Advanced inter-band Carrier Aggregation of Band 1 and Band 11** | 202d? | 2013-09-09 A | 2014-06-13 A | 100% | 2013-09-09 | 2014-06-13 | 202d? |  | R4 | 4848h | 4848h | LTE_CA_B1_B11 | 31 | LTE | SoftBank Mobile | kenichi.kihara@g.softbank.co.jp | Rel-12 | 61 | Issam | CA | LTE_CA_B1_B11 |  |
| 2404 | 625.49.1 | Core part:LTE Advanced inter-band Carrier Aggregation of Band 1 and Band 11 | 202d? | 2013-09-09 A | 2014-06-13 A | 100% | 2013-09-09 | 2014-06-13 | 202d? | finish no earlier than 2014-06-13 | R4 | 1616h | 1616h | LTE_CA_B1_B11-Core | 31 | 36.101, 36.104, new generic TR 36.851 | SoftBank Mobile | kenichi.kihara@g.softbank.co.jp | Rel-12 | 61 | Issam | CA | LTE_CA_B1_B11-Core | RP-140569 |
| 2405 | 625.49.2 | Perf. part:LTE Advanced inter-band Carrier Aggregation of Band 1 and Band 11 | 202d? | 2013-09-09 A | 2014-06-13 A | 100% | 2013-09-09 | 2014-06-13 | 202d? | finish no earlier than 2014-06-13 | R4 | 1616h | 1616h | LTE_CA_B1_B11-Perf | 31 | 36.141, 36.307 | SoftBank Mobile | kenichi.kihara@g.softbank.co.jp | Rel-12 | 61 | Issam | CA | LTE_CA_B1_B11-Perf | RP-140569 |
| 2406 | 625.50 | **LTE Advanced inter-band Carrier Aggregation of Band 8 and Band 11** | 268d? | 2013-09-09 A | 2014-09-12 A | 100% | 2013-09-09 | 2014-09-12 | 267d? |  | R4 | 6416h | 6416h | LTE_CA_B8_B11 | 31 | LTE | SoftBank Mobile | kenichi.kihara@g.softbank.co.jp | Rel-12 | 61 | Issam | CA | LTE_CA_B8_B11 |  |
| 2407 | 625.50.1 | Core part:LTE Advanced inter-band Carrier Aggregation of Band 8 and Band 11 | 267d? | 2013-09-09 A | 2014-09-12 A | 100% | 2013-09-09 | 2014-09-12 | 267d? | finish no earlier than 2014-09-12 | R4 | 2136h | 2136h | LTE_CA_B8_B11-Core | 31 | 36.101, 36.104, new generic TR 36.851 | SoftBank Mobile | kenichi.kihara@g.softbank.co.jp | Rel-12 | 61 | Issam | CA | LTE_CA_B8_B11-Core | RP-141084 |
| 2408 | 625.50.2 | Perf. part:LTE Advanced inter-band Carrier Aggregation of Band 8 and Band 11 | 267d? | 2013-09-09 A | 2014-09-12 A | 100% | 2013-09-09 | 2014-09-12 | 267d? | finish no earlier than 2014-09-12 | R4 | 2136h | 2136h | LTE_CA_B8_B11-Perf | 31 | 36.141, 36.307 | SoftBank Mobile | kenichi.kihara@g.softbank.co.jp | Rel-12 | 61 | Issam | CA | LTE_CA_B8_B11-Perf | RP-141084 |
| 2409 | 625.51 | **LTE Advanced inter-band Carrier Aggregation of Band 5 and Band 7** | 62d? | 2013-09-09 A | 2013-12-02 A | 100% | 2013-09-09 | 2013-12-02 | 62d? |  | R4 | 1488h | 1488h | LTE_CA_B5_B7 | 31 | LTE | LG Uplus | Yeonsang KOO (yskoo@lguplus.co.kr) | Rel-12 | 61 | Issam | CA | LTE_CA_B5_B7 |  |
| 2410 | 625.51.1 | Core part:LTE Advanced inter-band Carrier Aggregation of Band 5 and Band 7 | 62d? | 2013-09-09 A | 2013-12-02 A | 100% | 2013-09-09 | 2013-12-02 | 62d? | finish no earlier than 2013-12-02 | R4 | 496h | 496h | LTE_CA_B5_B7-Core | 31 | 36.101, 36.104, 36.133, new generic TR 36.851 | LG Uplus | Yeonsang KOO (yskoo@lguplus.co.kr) | Rel-12 | 61 | Issam | CA | LTE_CA_B5_B7-Core | RP-131541 |
| 2411 | 625.51.2 | Perf. part:LTE Advanced inter-band Carrier Aggregation of Band 5 and Band 7 | 62d? | 2013-09-09 A | 2013-12-02 A | 100% | 2013-09-09 | 2013-12-02 | 62d? | finish no earlier than 2013-12-02 | R4 | 496h | 496h | LTE_CA_B5_B7-Perf | 31 | 36.141, 36.307 | LG Uplus | Yeonsang KOO (yskoo@lguplus.co.kr) | Rel-12 | 61 | Issam | CA | LTE_CA_B5_B7-Perf | RP-131542 |
| 2412 | 625.52 | **LTE Advanced intra-band contiguous Carrier Aggregation in Band 41 for 3DL** | 400d? | 2013-09-09 A | 2015-03-15 A | 100% | 2013-09-09 | 2014-09-12 | 267d? |  | R4 | 8512h | 8512h | LTE_CA_C_B41_3DL | 31 | LTE | Alcatel-Lucent | man-hung.ng@alcatel-lucent.com | Rel-12 | 61 | Issam | CA | LTE_CA_C_B41_3DL |  |
| 2413 | 625.52.1 | Core part: LTE Advanced intra-band contiguous Carrier Aggregation in Band 41 for 3DL | 267d? | 2013-09-09 A | 2014-09-12 A | 100% | 2013-09-09 | 2014-09-12 | 267d? | finish no earlier than 2014-09-12 | R4 | 2136h | 2136h | LTE_CA_C_B41_3DL-Core | 31 | 36.101, 36.104, 36.133, 36.307, New TR 36.833-5-41 | Alcatel-Lucent | man-hung.ng@alcatel-lucent.com | Rel-12 | 61 | Issam | CA | LTE_CA_C_B41_3DL-Core | RP-141084 |
| 2414 | 625.52.2 | Perf. part: LTE Advanced intra-band contiguous Carrier Aggregation in Band 41 for 3DL | 397d? | 2013-09-09 A | 2015-03-15 A | 100% | 2013-09-09 | 2014-09-12 | 267d? | finish no earlier than 2015-03-15 | R4 | 3176h | 3176h | LTE_CA_C_B41_3DL-Perf | 31 | 36.141 | Alcatel-Lucent | man-hung.ng@alcatel-lucent.com | Rel-12 | 61 | Issam | CA | LTE_CA_C_B41_3DL-Perf | RP-150013 |
| 2415 | 625.53 | **LTE Advanced intra-band non-contiguous Carrier Aggregation in Band 2** | 202d? | 2013-09-09 A | 2014-06-13 A | 100% | 2013-09-09 | 2014-06-13 | 202d? |  | R4 | 4840h | 4840h | LTE_CA_NC_B2 | 31 | LTE | Ericsson | imadur.rahman@ericsson.com | Rel-12 | 61 | Issam | CA | LTE_CA_NC_B2 |  |
| 2416 | 625.53.1 | Core part:LTE Advanced intra-band non-contiguous Carrier Aggregation in Band 2 | 202d? | 2013-09-09 A | 2014-06-13 A | 100% | 2013-09-09 | 2014-06-13 | 202d? | finish no earlier than 2014-06-13 | R4 | 1616h | 1616h | LTE_CA_NC_B2-Core | 31 | 36.101, 36.104, 36.133, New TR 36.833-2-02 | Ericsson | imadur.rahman@ericsson.com | Rel-12 | 61 | Issam | CA | LTE_CA_NC_B2-Core | RP-140569 |
| 2417 | 625.53.2 | Perf. part:LTE Advanced intra-band non-contiguous Carrier Aggregation in Band 2 | 201d? | 2013-09-10 A | 2014-06-13 A | 100% | 2013-09-10 | 2014-06-13 | 201d? | finish no earlier than 2014-06-13 | R4 | 1608h | 1608h | LTE_CA_NC_B2-Perf | 31 | 36.141, 36.307 | Ericsson | imadur.rahman@ericsson.com | Rel-12 | 61 | Issam | CA | LTE_CA_NC_B2-Perf | RP-140569 |
| 2418 | 625.54 | **LTE Advanced inter-band Carrier Aggregation of Band 1 and Band 3** | 202d? | 2013-12-09 A | 2014-09-12 A | 100% | 2013-12-09 | 2014-09-12 | 201d? |  | R4 | 4832h | 4832h | LTE_CA_B1_B3 | 32 | LTE | China Unicom | Hao Chen (chenhao49@chinaunicom.cn) | Rel-12 | 62 | Issam | CA | LTE_CA_B1_B3 |  |
| 2419 | 625.54.1 | Core part:LTE Advanced inter-band Carrier Aggregation of Band 1 and Band 3 | 201d? | 2013-12-09 A | 2014-09-12 A | 100% | 2013-12-09 | 2014-09-12 | 201d? | finish no earlier than 2014-09-12 | R4 | 1608h | 1608h | LTE_CA_B1_B3-Core | 32 | 36.101, 36.104, 36.133, new generic TR 36.851 | China Unicom | Hao Chen (chenhao49@chinaunicom.cn) | Rel-12 | 62 | Issam | CA | LTE_CA_B1_B3-Core | RP-141084 |
| 2420 | 625.54.2 | Perf. part:LTE Advanced inter-band Carrier Aggregation of Band 1 and Band 3 | 201d? | 2013-12-09 A | 2014-09-12 A | 100% | 2013-12-09 | 2014-09-12 | 201d? | finish no earlier than 2014-09-12 | R4 | 1608h | 1608h | LTE_CA_B1_B3-Perf | 32 | 36.141, 36.307 | China Unicom | Hao Chen (chenhao49@chinaunicom.cn) | Rel-12 | 62 | Issam | CA | LTE_CA_B1_B3-Perf | RP-141084 |

Notes:
- 2397: Inter-band 1UL/2DL
- 2398: RP#62 completed
- 2399: RP#62 completed
- 2400: Inter-band 1UL/2DL
- 2401: RP#62 completed
- 2402: RP#62 completed
- 2403: Inter-band CA 2DL
- 2404: RP#64 completed
- 2405: RP#64 completed
- 2406: Inter-band CA 2DL
- 2407: RP#65 completed
- 2408: RP#65 completed
- 2409: Inter-band 1UL/2DL
- 2410: RP#62 completed
- 2411: RP#62 completed
- 2412: Intra-band contig. CA 3DL
- 2413: RP#65 completed
- 2414: ; WID: RP-142043->RP-142017; Stat Rep: RP-141084->RP-141732 1st Apr 15: Compl:70%->100% 1st Apr 15: Stat Rep: RP-141732->RP-150013
- 2415: Intra-band non-contig. CA 2DL
- 2416: RP#64 completed. TR 36.833-2-02v100 for 1-step Approval
- 2417: RP#64 completed
- 2418: Inter-band CA 2DL
- 2419: RP#65 completed
- 2420: RP#65 completed

| ID | WBS | Task | Duration | Start | Finish | Complete | Baseline start | Baseline finish | Baseline duration | Constraint | Resources | Work | Actual work | Acronym | PCG approved | WI rapporteur name | WI rapporteur e-mail | Release | TSG approved | MCC resp | Special Focus Doc | Acronym_3GU_Export | Status Report |
| --- | --- | --- | --- | --- | --- | --- | --- | --- | --- | --- | --- | --- | --- | --- | --- | --- | --- | --- | --- | --- | --- | --- | --- |
| 2421 | 625.55 | **LTE Advanced inter-band Carrier Aggregation of Band 1 and Band 28** | 270d? | 2013-12-09 A | 2014-12-15 A | 100% | 2013-12-09 | 2014-09-12 | 201d? |  | R4 | 6432h | 6432h | LTE_CA_B1_B28 | 32 | KDDI | Masaaki Obara (ms-obara@kddi.com) | Rel-12 | 62 | Issam | CA | LTE_CA_B1_B28 |  |
| 2422 | 625.55.1 | Core part:LTE Advanced inter-band Carrier Aggregation of Band 1 and Band 28 | 267d? | 2013-12-09 A | 2014-12-15 A | 100% | 2013-12-09 | 2014-09-12 | 201d? | finish no earlier than 2014-12-15 | R4 | 2136h | 2136h | LTE_CA_B1_B28-Core | 32 | KDDI | Masaaki Obara (ms-obara@kddi.com) | Rel-12 | 62 | Issam | CA | LTE_CA_B1_B28-Core | RP-141732 |
| 2423 | 625.55.2 | Perf. part:LTE Advanced inter-band Carrier Aggregation of Band 1 and Band 28 | 267d? | 2013-12-12 A | 2014-12-15 A | 100% | 2013-12-09 | 2014-09-12 | 201d? | finish no earlier than 2014-12-15 | R4 | 2136h | 2136h | LTE_CA_B1_B28-Perf | 32 | KDDI | Masaaki Obara (ms-obara@kddi.com) | Rel-12 | 62 | Issam | CA | LTE_CA_B1_B28-Perf | RP-141732 |
| 2424 | 625.56 | **LTE Advanced inter-band Carrier Aggregation of Band 2 and Band 4 - Additional bandwidth combination set** | 65d? | 2013-12-09 A | 2014-03-06 A | 100% | 2013-12-09 | 2014-03-06 | 65d? |  | R4 | 1560h | 1560h | LTE_CA_B2_B4_BWset | 32 | T-Mobile USA | nelson.ueng@t-mobile.com | Rel-12 | 62 | Issam | CA | LTE_CA_B2_B4_BWset |  |
| 2425 | 625.56.1 | Core part:LTE Advanced inter-band Carrier Aggregation of Band 2 and Band 4 - Additional bandwidth combination set | 65d? | 2013-12-09 A | 2014-03-06 A | 100% | 2013-12-09 | 2014-03-06 | 65d? | finish no earlier than 2014-03-06 | R4 | 520h | 520h | LTE_CA_B2_B4_BWset-Core | 32 | T-Mobile USA | nelson.ueng@t-mobile.com | Rel-12 | 62 | Issam | CA | LTE_CA_B2_B4_BWset-Core | RP-140428 |
| 2426 | 625.56.2 | Perf. part:LTE Advanced inter-band Carrier Aggregation of Band 2 and Band 4 - Additional bandwidth combination set | 65d? | 2013-12-09 A | 2014-03-06 A | 100% | 2013-12-09 | 2014-03-06 | 65d? | finish no earlier than 2014-03-06 | R4 | 520h | 520h | LTE_CA_B2_B4_BWset-Perf | 32 | T-Mobile USA | nelson.ueng@t-mobile.com | Rel-12 | 62 | Issam | CA | LTE_CA_B2_B4_BWset-Perf | RP-140428 |
| 2427 | 625.57 | **LTE Advanced inter-band Carrier Aggregation of Band 4 and Band 27** | 136d? | 2013-12-09 A | 2014-06-13 A | 100% | 2013-12-09 | 2014-06-13 | 136d? |  | R4 | 3264h | 3264h | LTE_CA_B4_B27 | 32 | NII Holdings | bill.shvodian@nii.com | Rel-12 | 62 | Issam | CA | LTE_CA_B4_B27 |  |
| 2428 | 625.57.1 | Core part:LTE Advanced inter-band Carrier Aggregation of Band 4 and Band 27 | 136d? | 2013-12-09 A | 2014-06-13 A | 100% | 2013-12-09 | 2014-06-13 | 136d? | finish no earlier than 2014-06-13 | R4 | 1088h | 1088h | LTE_CA_B4_B27-Core | 32 | NII Holdings | bill.shvodian@nii.com | Rel-12 | 62 | Issam | CA | LTE_CA_B4_B27-Core | RP-140569 |
| 2429 | 625.57.2 | Perf. part:LTE Advanced inter-band Carrier Aggregation of Band 4 and Band 27 | 136d? | 2013-12-09 A | 2014-06-13 A | 100% | 2013-12-09 | 2014-06-13 | 136d? | finish no earlier than 2014-06-13 | R4 | 1088h | 1088h | LTE_CA_B4_B27-Perf | 32 | NII Holdings | bill.shvodian@nii.com | Rel-12 | 62 | Issam | CA | LTE_CA_B4_B27-Perf | RP-140569 |
| 2430 | 625.58 | **LTE Advanced inter-band Carrier Aggregation of Band 3 and Band 27** | 65d? | 2013-12-09 A | 2014-03-06 A | 100% | 2013-12-09 | 2014-03-06 | 65d? |  | R4 | 1560h | 1560h | LTE_CA_B3_B27 | 32 | KT | Chungwoo HWANG (cwhwang@kt.com) | Rel-12 | 62 | Issam | CA | LTE_CA_B3_B27 | RP-140428 |
| 2431 | 625.58.1 | Core part:LTE Advanced inter-band Carrier Aggregation of Band 3 and Band 27 | 65d? | 2013-12-09 A | 2014-03-06 A | 100% | 2013-12-09 | 2014-03-06 | 65d? | finish no earlier than 2014-03-06 | R4 | 520h | 520h | LTE_CA_B3_B27-Core | 32 | KT | Chungwoo HWANG (cwhwang@kt.com) | Rel-12 | 62 | Issam | CA | LTE_CA_B3_B27-Core | RP-140428 |
| 2432 | 625.58.2 | Perf. part:LTE Advanced inter-band Carrier Aggregation of Band 3 and Band 27 | 65d? | 2013-12-09 A | 2014-03-06 A | 100% | 2013-12-09 | 2014-03-06 | 65d? | finish no earlier than 2014-03-06 | R4 | 520h | 520h | LTE_CA_B3_B27-Perf | 32 | KT | Chungwoo HWANG (cwhwang@kt.com) | Rel-12 | 62 | Issam | CA | LTE_CA_B3_B27-Perf | RP-140428 |
| 2433 | 625.59 | **LTE Advanced inter-band Carrier Aggregation in Band 8 and Band 20 - Additional channel bandwidth** | 65d? | 2013-12-09 A | 2014-03-06 A | 100% | 2013-12-09 | 2014-03-06 | 65d? |  | R4 | 1560h | 1560h | LTE_CA_B8_B20_BW | 32 | Vodafone | luis.anaya@vodafone.com | Rel-12 | 62 | Issam | CA | LTE_CA_B8_B20_BW | RP-140428 |
| 2434 | 625.59.1 | Core part:LTE Advanced inter-band Carrier Aggregation in Band 8 and Band 20 - Additional channel bandwidth | 65d? | 2013-12-09 A | 2014-03-06 A | 100% | 2013-12-09 | 2014-03-06 | 65d? | finish no earlier than 2014-03-06 | R4 | 520h | 520h | LTE_CA_B8_B20_BW-Core | 32 | Vodafone | luis.anaya@vodafone.com | Rel-12 | 62 | Issam | CA | LTE_CA_B8_B20_BW-Core | RP-140428 |
| 2435 | 625.59.2 | Perf. part:LTE Advanced inter-band Carrier Aggregation in Band 8 and Band 20 - Additional channel bandwidth | 65d? | 2013-12-09 A | 2014-03-06 A | 100% | 2013-12-09 | 2014-03-06 | 65d? | finish no earlier than 2014-03-06 | R4 | 520h | 520h | LTE_CA_B8_B20_BW-Perf | 32 | Vodafone | luis.anaya@vodafone.com | Rel-12 | 62 | Issam | CA | LTE_CA_B8_B20_BW-Perf | RP-140428 |
| 2436 | 625.60 | **LTE Advanced 3 Band Carrier Aggregation (3DL/1UL) for Band 1, Band 3 and Band 8** | 202d? | 2013-12-09 A | 2014-09-12 A | 100% | 2013-12-09 | 2014-09-12 | 201d? |  | R4 | 4832h | 4832h | LTE_CA_B1_B3_B8 | 32 | KT | Ilwhan Kim (ilwhan.kim@kt.com) | Rel-12 | 62 | Issam | CA | LTE_CA_B1_B3_B8 |  |
| 2437 | 625.60.1 | Core part:LTE Advanced 3 Band Carrier Aggregation (3DL/1UL) for Band 1, Band 3 and Band 8 | 201d? | 2013-12-09 A | 2014-09-12 A | 100% | 2013-12-09 | 2014-09-12 | 201d? | finish no earlier than 2014-09-12 | R4 | 1608h | 1608h | LTE_CA_B1_B3_B8-Core | 32 | KT | Ilwhan Kim (ilwhan.kim@kt.com) | Rel-12 | 62 | Issam | CA | LTE_CA_B1_B3_B8-Core | RP-141084 |
| 2438 | 625.60.2 | Perf. part:LTE Advanced 3 Band Carrier Aggregation (3DL/1UL) for Band 1, Band 3 and Band 8 | 201d? | 2013-12-09 A | 2014-09-12 A | 100% | 2013-12-09 | 2014-09-12 | 201d? | finish no earlier than 2014-09-12 | R4 | 1608h | 1608h | LTE_CA_B1_B3_B8-Perf | 32 | KT | Ilwhan Kim (ilwhan.kim@kt.com) | Rel-12 | 62 | Issam | CA | LTE_CA_B1_B3_B8-Perf | RP-141084 |
| 2439 | 625.61 | **LTE Advanced 3 Band Carrier Aggregation (3DL/1UL) for Band 1, Band 5 and Band 7** | 202d? | 2013-12-09 A | 2014-09-12 A | 100% | 2013-12-09 | 2014-09-12 | 201d? |  | R4 | 4832h | 4832h | LTE_CA_B1_B5_B7 | 32 | LG Uplus | Yeonsang KOO (yskoo@lguplus.co.kr) | Rel-12 | 62 | Issam | CA | LTE_CA_B1_B5_B7 |  |
| 2440 | 625.61.1 | Core part:LTE Advanced 3 Band Carrier Aggregation (3DL/1UL) for Band 1, Band 5 and Band 7 | 201d? | 2013-12-09 A | 2014-09-12 A | 100% | 2013-12-09 | 2014-09-12 | 201d? | finish no earlier than 2014-09-12 | R4 | 1608h | 1608h | LTE_CA_B1_B5_B7-Core | 32 | LG Uplus | Yeonsang KOO (yskoo@lguplus.co.kr) | Rel-12 | 62 | Issam | CA | LTE_CA_B1_B5_B7-Core | RP-141084 |
| 2441 | 625.61.2 | Perf. part:LTE Advanced 3 Band Carrier Aggregation (3DL/1UL) for Band 1, Band 5 and Band 7 | 201d? | 2013-12-09 A | 2014-09-12 A | 100% | 2013-12-09 | 2014-09-12 | 201d? | finish no earlier than 2014-09-12 | R4 | 1608h | 1608h | LTE_CA_B1_B5_B7-Perf | 32 | LG Uplus | Yeonsang KOO (yskoo@lguplus.co.kr) | Rel-12 | 62 | Issam | CA | LTE_CA_B1_B5_B7-Perf | RP-141084 |
| 2442 | 625.62 | **LTE Advanced 3 Band Carrier Aggregation (3DL/1UL) for Band 2, Band 4 and Band 5** | 202d? | 2013-12-09 A | 2014-09-12 A | 100% | 2013-12-09 | 2014-09-12 | 201d? |  | R4 | 4832h | 4832h | LTE_CA_B2_B4_B5 | 32 | U.S. Cellular | sebastian.thalanany@uscellular.com | Rel-12 | 62 | Issam | CA | LTE_CA_B2_B4_B5 |  |
| 2443 | 625.62.1 | Core part:LTE Advanced 3 Band Carrier Aggregation (3DL/1UL) for Band 2, Band 4 and Band 5 | 201d? | 2013-12-09 A | 2014-09-12 A | 100% | 2013-12-09 | 2014-09-12 | 201d? | finish no earlier than 2014-09-12 | R4 | 1608h | 1608h | LTE_CA_B2_B4_B5-Core | 32 | U.S. Cellular | sebastian.thalanany@uscellular.com | Rel-12 | 62 | Issam | CA | LTE_CA_B2_B4_B5-Core | RP-141084 |
| 2444 | 625.62.2 | Perf. part:LTE Advanced 3 Band Carrier Aggregation (3DL/1UL) for Band 2, Band 4 and Band 5 | 201d? | 2013-12-09 A | 2014-09-12 A | 100% | 2013-12-09 | 2014-09-12 | 201d? | finish no earlier than 2014-09-12 | R4 | 1608h | 1608h | LTE_CA_B2_B4_B5-Perf | 32 | U.S. Cellular | sebastian.thalanany@uscellular.com | Rel-12 | 62 | Issam | CA | LTE_CA_B2_B4_B5-Perf | RP-141084 |

Notes:
- 2421: Inter-band CA 2DL / Impacted TSs and TRs: LTE
- 2422: ; WID: RP-142043->RP-141803; Stat Rep: RP-141084->RP-141732 / Impacted TSs and TRs: 36.101, 36.104, 36.133, 36.307, new generic TR 36.851
- 2423: ; WID: RP-142043->RP-141803; Stat Rep: RP-141084->RP-141732 / Impacted TSs and TRs: 36.133, 36.141
- 2424: Inter-band 2DL / Impacted TSs and TRs: LTE
- 2425: RP#63 completed / Impacted TSs and TRs: 36.101, new generic TR 36.851
- 2426: RP#63 completed / Impacted TSs and TRs: 36.307
- 2427: Inter-band CA 2DL / Impacted TSs and TRs: LTE
- 2428: RP#64 completed / Impacted TSs and TRs: 36.101, 36.104, 36.133, new generic TR 36.851
- 2429: RP#64 completed / Impacted TSs and TRs: 36.141, 36.307
- 2430: Inter-band CA 2DL/1UL / Impacted TSs and TRs: LTE
- 2431: RP#63 completed. Updated WID RP-131752=>RP-140119 / Impacted TSs and TRs: 36.101, 36.104, 36.133, 36.307, New generic TR 36.851
- 2432: RP#63 completed. Updated WID RP-131752=>RP-140119 / Impacted TSs and TRs: 36.101, 36.104, 36.133, 36.141
- 2433: Inter-band 2DL / Impacted TSs and TRs: LTE
- 2434: RP#63 completed / Impacted TSs and TRs: 36.101, 36.104, 36.307
- 2435: RP#63 completed / Impacted TSs and TRs: 36.141
- 2436: Inter-band CA 3DL / Impacted TSs and TRs: LTE
- 2437: RP#65 completed. Updated WID RP-131753=>RP-141654 / Impacted TSs and TRs: 36.101, 36.104, 36.133, 36.141, 36.307, new generic TR 36.853 (3 Band CA with 1UL)
- 2438: RP#65 completed / Impacted TSs and TRs: 36.101, 36.104, 36.133, 36.141, 36.307
- 2439: Inter-band CA 3DL / Impacted TSs and TRs: LTE
- 2440: RP#65 completed. Updated WID RP-140209=>RP-141462 / Impacted TSs and TRs: 36.101, 36.104, 36.133, new generic TR 36.853 (3 Band CA with 1UL)
- 2441: RP#65 completed / Impacted TSs and TRs: 36.141, 36.307
- 2442: Inter-band CA 3DL / Impacted TSs and TRs: LTE
- 2443: RP#65 completed / Impacted TSs and TRs: 36.101, 36.104, 36.133, new generic TR 36.853 (3 Band CA with 1UL)
- 2444: RP#65 completed / Impacted TSs and TRs: 36.141, 36.307

| ID | WBS | Task | Duration | Start | Finish | Complete | Baseline start | Baseline finish | Baseline duration | Constraint | Resources | Work | Actual work | Acronym | PCG approved | WI rapporteur name | WI rapporteur e-mail | Release | TSG approved | MCC resp | Special Focus Doc | Acronym_3GU_Export | Status Report |
| --- | --- | --- | --- | --- | --- | --- | --- | --- | --- | --- | --- | --- | --- | --- | --- | --- | --- | --- | --- | --- | --- | --- | --- |
| 2445 | 625.63 | **LTE Advanced 3 Band Carrier Aggregation (3DL/1UL) for Band 2, Band 4 and Band 12** | 268d? | 2013-12-09 A | 2014-12-11 A | 100% | 2013-12-09 | 2014-09-12 | 201d? |  | R4 | 5872h | 5872h | LTE_CA_B2_B4_B12 | 32 | U.S. Cellular | sebastian.thalanany@uscellular.com | Rel-12 | 62 | Issam | CA | LTE_CA_B2_B4_B12 |  |
| 2446 | 625.63.1 | Core part:LTE Advanced 3 Band Carrier Aggregation (3DL/1UL) for Band 2, Band 4 and Band 12 | 201d? | 2013-12-09 A | 2014-09-12 A | 100% | 2013-12-09 | 2014-09-12 | 201d? | finish no earlier than 2014-09-12 | R4 | 1608h | 1608h | LTE_CA_B2_B4_B12-Core | 32 | U.S. Cellular | sebastian.thalanany@uscellular.com | Rel-12 | 62 | Issam | CA | LTE_CA_B2_B4_B12-Core | RP-141084 |
| 2447 | 625.63.2 | Perf. part:LTE Advanced 3 Band Carrier Aggregation (3DL/1UL) for Band 2, Band 4 and Band 12 | 265d? | 2013-12-09 A | 2014-12-11 A | 100% | 2013-12-09 | 2014-09-12 | 201d? | finish no earlier than 2014-12-11 | R4 | 2120h | 2120h | LTE_CA_B2_B4_B12-Perf | 32 | U.S. Cellular | sebastian.thalanany@uscellular.com | Rel-12 | 62 | Issam | CA | LTE_CA_B2_B4_B12-Perf | RP-141084 |
| 2448 | 625.64 | **LTE Advanced 3 Band Carrier Aggregation (3DL/1UL) for Band 2, Band 5 and Band 12** | 202d? | 2013-12-09 A | 2014-09-12 A | 100% | 2013-12-09 | 2014-09-12 | 201d? |  | R4 | 4832h | 4832h | LTE_CA_B2_B5_B12 | 32 | U.S. Cellular | sebastian.thalanany@uscellular.com | Rel-12 | 62 | Issam | CA | LTE_CA_B2_B5_B12 |  |
| 2449 | 625.64.1 | Core part:LTE Advanced 3 Band Carrier Aggregation (3DL/1UL) for Band 2, Band 5 and Band 12 | 201d? | 2013-12-09 A | 2014-09-12 A | 100% | 2013-12-09 | 2014-09-12 | 201d? | finish no earlier than 2014-09-12 | R4 | 1608h | 1608h | LTE_CA_B2_B5_B12-Core | 32 | U.S. Cellular | sebastian.thalanany@uscellular.com | Rel-12 | 62 | Issam | CA | LTE_CA_B2_B5_B12-Core | RP-141084 |
| 2450 | 625.64.2 | Perf. part:LTE Advanced 3 Band Carrier Aggregation (3DL/1UL) for Band 2, Band 5 and Band 12 | 201d? | 2013-12-10 A | 2014-09-12 A | 100% | 2013-12-09 | 2014-09-12 | 201d? | finish no earlier than 2014-09-12 | R4 | 1608h | 1608h | LTE_CA_B2_B5_B12-Perf | 32 | U.S. Cellular | sebastian.thalanany@uscellular.com | Rel-12 | 62 | Issam | CA | LTE_CA_B2_B5_B12-Perf | RP-141084 |
| 2451 | 625.65 | **LTE Advanced 3 Band Carrier Aggregation (3DL/1UL) for Band 2, Band 12 and Band 12** | 202d? | 2013-12-09 A | 2014-09-12 A | 100% | 2013-12-09 | 2014-09-12 | 201d? |  | R4 | 4832h | 4832h | LTE_CA_B2_B12_B12 | 32 | AT&T | marc.grant@att.com | Rel-12 | 62 | Issam | CA | LTE_CA_B2_B12_B12 |  |
| 2452 | 625.65.1 | Core part:LTE Advanced 3 Band Carrier Aggregation (3DL/1UL) for Band 2, Band 12 and Band 12 | 201d? | 2013-12-09 A | 2014-09-12 A | 100% | 2013-12-09 | 2014-09-12 | 201d? | finish no earlier than 2014-09-12 | R4 | 1608h | 1608h | LTE_CA_B2_B12_B12-Core | 32 | AT&T | marc.grant@att.com | Rel-12 | 62 | Issam | CA | LTE_CA_B2_B12_B12-Core | RP-141084 |
| 2453 | 625.65.2 | Perf. part:LTE Advanced 3 Band Carrier Aggregation (3DL/1UL) for Band 2, Band 12 and Band 12 | 201d? | 2013-12-09 A | 2014-09-12 A | 100% | 2013-12-09 | 2014-09-12 | 201d? | finish no earlier than 2014-09-12 | R4 | 1608h | 1608h | LTE_CA_B2_B12_B12-Perf | 32 | AT&T | marc.grant@att.com | Rel-12 | 62 | Issam | CA | LTE_CA_B2_B12_B12-Perf | RP-141084 |
| 2454 | 625.66 | **LTE Advanced 3 Band Carrier Aggregation (3DL/1UL) for Band 2, Band 12 and Band 30** | 202d? | 2013-12-09 A | 2014-09-12 A | 100% | 2013-12-09 | 2014-09-12 | 201d? |  | R4 | 4832h | 4832h | LTE_CA_B2_B12_B30 | 32 | AT&T | marc.grant@att.com | Rel-12 | 62 | Issam | CA | LTE_CA_B2_B12_B30 |  |
| 2455 | 625.66.1 | Core part:LTE Advanced 3 Band Carrier Aggregation (3DL/1UL) for Band 2, Band 12 and Band 30 | 201d? | 2013-12-09 A | 2014-09-12 A | 100% | 2013-12-09 | 2014-09-12 | 201d? | finish no earlier than 2014-09-12 | R4 | 1608h | 1608h | LTE_CA_B2_B12_B30-Core | 32 | AT&T | marc.grant@att.com | Rel-12 | 62 | Issam | CA | LTE_CA_B2_B12_B30-Core | RP-141084 |
| 2456 | 625.66.2 | Perf. part:LTE Advanced 3 Band Carrier Aggregation (3DL/1UL) for Band 2, Band 12 and Band 30 | 201d? | 2013-12-09 A | 2014-09-12 A | 100% | 2013-12-09 | 2014-09-12 | 201d? | finish no earlier than 2014-09-12 | R4 | 1608h | 1608h | LTE_CA_B2_B12_B30-Perf | 32 | AT&T | marc.grant@att.com | Rel-12 | 62 | Issam | CA | LTE_CA_B2_B12_B30-Perf | RP-141084 |
| 2457 | 625.67 | **LTE Advanced 3 Band Carrier Aggregation (3DL/1UL) for Band 3, Band 7 and Band 20** | 202d? | 2013-12-09 A | 2014-09-12 A | 100% | 2013-12-09 | 2014-09-12 | 201d? |  | R4 | 4832h | 4832h | LTE_CA_B3_B7_B20 | 32 | Vodafone | luis.anaya@vodafone.com | Rel-12 | 62 | Issam | CA | LTE_CA_B3_B7_B20 |  |
| 2458 | 625.67.1 | Core part:LTE Advanced 3 Band Carrier Aggregation (3DL/1UL) for Band 3, Band 7 and Band 20 | 201d? | 2013-12-09 A | 2014-09-12 A | 100% | 2013-12-09 | 2014-09-12 | 201d? | finish no earlier than 2014-09-12 | R4 | 1608h | 1608h | LTE_CA_B3_B7_B20-Core | 32 | Vodafone | luis.anaya@vodafone.com | Rel-12 | 62 | Issam | CA | LTE_CA_B3_B7_B20-Core | RP-141084 |
| 2459 | 625.67.2 | Perf. part:LTE Advanced 3 Band Carrier Aggregation (3DL/1UL) for Band 3, Band 7 and Band 20 | 201d? | 2013-12-10 A | 2014-09-12 A | 100% | 2013-12-09 | 2014-09-12 | 201d? | finish no earlier than 2014-09-12 | R4 | 1608h | 1608h | LTE_CA_B3_B7_B20-Perf | 32 | Vodafone | luis.anaya@vodafone.com | Rel-12 | 62 | Issam | CA | LTE_CA_B3_B7_B20-Perf | RP-141084 |
| 2460 | 625.68 | **LTE Advanced 3 Band Carrier Aggregation (3DL/1UL) for Band 4, Band 5 and Band 12** | 202d? | 2013-12-09 A | 2014-09-12 A | 100% | 2013-12-09 | 2014-09-12 | 201d? |  | R4 | 4832h | 4832h | LTE_CA_B4_B5_B12 | 32 | U.S. Cellular | sebastian.thalanany@uscellular.com | Rel-12 | 62 | Issam | CA | LTE_CA_B4_B5_B12 |  |
| 2461 | 625.68.1 | Core part:LTE Advanced 3 Band Carrier Aggregation (3DL/1UL) for Band 4, Band 5 and Band 12 | 201d? | 2013-12-09 A | 2014-09-12 A | 100% | 2013-12-09 | 2014-09-12 | 201d? | finish no earlier than 2014-09-12 | R4 | 1608h | 1608h | LTE_CA_B4_B5_B12-Core | 32 | U.S. Cellular | sebastian.thalanany@uscellular.com | Rel-12 | 62 | Issam | CA | LTE_CA_B4_B5_B12-Core | RP-141084 |
| 2462 | 625.68.2 | Perf. part:LTE Advanced 3 Band Carrier Aggregation (3DL/1UL) for Band 4, Band 5 and Band 12 | 201d? | 2013-12-09 A | 2014-09-12 A | 100% | 2013-12-09 | 2014-09-12 | 201d? | finish no earlier than 2014-09-12 | R4 | 1608h | 1608h | LTE_CA_B4_B5_B12-Perf | 32 | U.S. Cellular | sebastian.thalanany@uscellular.com | Rel-12 | 62 | Issam | CA | LTE_CA_B4_B5_B12-Perf | RP-141084 |
| 2463 | 625.69 | **LTE Advanced 3 Band Carrier Aggregation (3DL/1UL) for Band 4, Band 12 and Band 12** | 202d? | 2013-12-09 A | 2014-09-12 A | 100% | 2013-12-09 | 2014-09-12 | 201d? |  | R4 | 4832h | 4832h | LTE_CA_B4_B12_B12 | 32 | AT&T | marc.grant@att.com | Rel-12 | 62 | Issam | CA | LTE_CA_B4_B12_B12 |  |
| 2464 | 625.69.1 | Core part:LTE Advanced 3 Band Carrier Aggregation (3DL/1UL) for Band 4, Band 12 and Band 12 | 201d? | 2013-12-09 A | 2014-09-12 A | 100% | 2013-12-09 | 2014-09-12 | 201d? | finish no earlier than 2014-09-12 | R4 | 1608h | 1608h | LTE_CA_B4_B12_B12-Core | 32 | AT&T | marc.grant@att.com | Rel-12 | 62 | Issam | CA | LTE_CA_B4_B12_B12-Core | RP-141084 |
| 2465 | 625.69.2 | Perf. part:LTE Advanced 3 Band Carrier Aggregation (3DL/1UL) for Band 4, Band 12 and Band 12 | 201d? | 2013-12-09 A | 2014-09-12 A | 100% | 2013-12-09 | 2014-09-12 | 201d? | finish no earlier than 2014-09-12 | R4 | 1608h | 1608h | LTE_CA_B4_B12_B12-Perf | 32 | AT&T | marc.grant@att.com | Rel-12 | 62 | Issam | CA | LTE_CA_B4_B12_B12-Perf | RP-141084 |
| 2466 | 625.70 | **LTE Advanced 3 Band Carrier Aggregation (3DL/1UL) for Band 4, Band 12 and Band 30** | 202d? | 2013-12-09 A | 2014-09-12 A | 100% | 2013-12-09 | 2014-09-12 | 201d? |  | R4 | 4832h | 4832h | LTE_CA_B4_B12_B30 | 32 | AT&T | marc.grant@att.com | Rel-12 | 62 | Issam | CA | LTE_CA_B4_B12_B30 |  |
| 2467 | 625.70.1 | Core part:LTE Advanced 3 Band Carrier Aggregation (3DL/1UL) for Band 4, Band 12 and Band 30 | 201d? | 2013-12-09 A | 2014-09-12 A | 100% | 2013-12-09 | 2014-09-12 | 201d? | finish no earlier than 2014-09-12 | R4 | 1608h | 1608h | LTE_CA_B4_B12_B30-Core | 32 | AT&T | marc.grant@att.com | Rel-12 | 62 | Issam | CA | LTE_CA_B4_B12_B30-Core | RP-141084 |
| 2468 | 625.70.2 | Perf. part:LTE Advanced 3 Band Carrier Aggregation (3DL/1UL) for Band 4, Band 12 and Band 30 | 201d? | 2013-12-09 A | 2014-09-12 A | 100% | 2013-12-09 | 2014-09-12 | 201d? | finish no earlier than 2014-09-12 | R4 | 1608h | 1608h | LTE_CA_B4_B12_B30-Perf | 32 | AT&T | marc.grant@att.com | Rel-12 | 62 | Issam | CA | LTE_CA_B4_B12_B30-Perf | RP-141084 |

Notes:
- 2445: Inter-band CA 3DL / Impacted TSs and TRs: LTE
- 2446: RP#65 completed / Impacted TSs and TRs: 36.101, 36.104, 36.133, new generic TR 36.853 (3 Band CA with 1UL)
- 2447: RP#65 completion 09/14=>12/14 / Impacted TSs and TRs: 36.141, 36.307
- 2448: Inter-band CA 3DL / Impacted TSs and TRs: LTE
- 2449: RP#65 completed / Impacted TSs and TRs: 36.101, 36.104, 36.133, new generic TR 36.853 (3 Band CA with 1UL)
- 2450: RP#65 completed / Impacted TSs and TRs: 36.141, 36.307
- 2451: Inter-band CA 3DL / Impacted TSs and TRs: LTE
- 2452: RP#65 completed / Impacted TSs and TRs: 36.101, 36.104, 36.133, 36.141, 36.307, new generic TR 36.853
- 2453: RP#65 completed / Impacted TSs and TRs: 36.101, 36.104, 36.133, 36.141, 36.307
- 2454: Inter-band CA 3DL / Impacted TSs and TRs: LTE
- 2455: RP#65 completed. Updated WID RP-131652=>RP-141211. / Impacted TSs and TRs: 36.101, 36.104, 36.133, 36.141, 36.307, new generic TR 36.853 (3 Band CA with 1UL)
- 2456: RP#65 completed / Impacted TSs and TRs: 36.101, 36.104, 36.133, 36.141, 36.307
- 2457: Inter-band CA 3DL / Impacted TSs and TRs: LTE
- 2458: RP#65 completed. Updated WID RP-140244=>RP-141224 / Impacted TSs and TRs: 36.101, 36.104, 36.133, new generic TR 36.853 (3 Band CA with 1UL)
- 2459: RP#65 completed / Impacted TSs and TRs: 36.101, 36.133, 36.141, 36.307
- 2460: Inter-band CA 3DL / Impacted TSs and TRs: LTE
- 2461: RP#65 completed / Impacted TSs and TRs: 36.101, 36.104, 36.133, new generic TR 36.853 (3 Band CA with 1UL)
- 2462: RP#65 completed / Impacted TSs and TRs: 36.141, 36.307
- 2463: Inter-band CA 3DL / Impacted TSs and TRs: LTE
- 2464: RP#65 completed / Impacted TSs and TRs: 36.101, 36.104, 36.133, 36.141, 36.307, new generic TR 36.853 (3 Band CA with 1UL)
- 2465: RP#65 completed / Impacted TSs and TRs: 36.101, 36.104, 36.133, 36.141, 36.307
- 2466: Inter-band CA 3DL / Impacted TSs and TRs: LTE
- 2467: RP#65 completed. Updated WID RP-131653=>RP-141214 / Impacted TSs and TRs: 36.101, 36.104, 36.133, 36.141, 36.307, new generic TR 36.853 (3 Band CA with 1UL)
- 2468: RP#65 completed / Impacted TSs and TRs: 36.101, 36.104, 36.133, 36.141, 36.307

| ID | WBS | Task | Duration | Start | Finish | Complete | Baseline start | Baseline finish | Baseline duration | Constraint | Resources | Work | Actual work | Acronym | PCG approved | WI rapporteur name | WI rapporteur e-mail | Release | TSG approved | MCC resp | Special Focus Doc | Acronym_3GU_Export | Status Report |
| --- | --- | --- | --- | --- | --- | --- | --- | --- | --- | --- | --- | --- | --- | --- | --- | --- | --- | --- | --- | --- | --- | --- | --- |
| 2469 | 625.71 | **LTE Advanced intra-band contiguous Carrier Aggregation in Band 42** | 136d? | 2013-12-09 A | 2014-06-13 A | 100% | 2013-12-09 | 2014-06-13 | 136d? |  | R4 | 3264h | 3264h | LTE_CA_C_B42 | 32 | CATT | Yuexia Song (songyuexia@catt.cn) | Rel-12 | 62 | Issam | CA | LTE_CA_C_B42 |  |
| 2470 | 625.71.1 | Core part: LTE Advanced intra-band contiguous Carrier Aggregation in Band 42 | 136d? | 2013-12-09 A | 2014-06-13 A | 100% | 2013-12-09 | 2014-06-13 | 136d? | finish no earlier than 2014-06-13 | R4 | 1088h | 1088h | LTE_CA_C_B42-Core | 32 | CATT | Yuexia Song (songyuexia@catt.cn) | Rel-12 | 62 | Issam | CA | LTE_CA_C_B42-Core | RP-140569 |
| 2471 | 625.71.2 | Perf. part: LTE Advanced intra-band contiguous Carrier Aggregation in Band 42 | 136d? | 2013-12-09 A | 2014-06-13 A | 100% | 2013-12-09 | 2014-06-13 | 136d? | finish no earlier than 2014-06-13 | R4 | 1088h | 1088h | LTE_CA_C_B42-Perf | 32 | CATT | Yuexia Song (songyuexia@catt.cn) | Rel-12 | 62 | Issam | CA | LTE_CA_C_B42-Perf | RP-140569 |
| 2472 | 625.72 | **LTE Advanced intra-band contiguous Carrier Aggregation in Band 7 - Additional bandwidth combinations** | 136d? | 2013-12-09 A | 2014-06-13 A | 100% | 2013-12-09 | 2014-06-13 | 136d? |  | R4 | 3264h | 3264h | LTE_CA_C_B7_BW | 32 | Orange | Olfa BEN HADDADA | Rel-12 | 62 | Issam | CA | LTE_CA_C_B7_BW |  |
| 2473 | 625.72.1 | Core part: LTE Advanced intra-band contiguous Carrier Aggregation in Band 7 - Additional bandwidth combinations | 136d? | 2013-12-09 A | 2014-06-13 A | 100% | 2013-12-09 | 2014-06-13 | 136d? | finish no earlier than 2014-06-13 | R4 | 1088h | 1088h | LTE_CA_C_B7_BW-Core | 32 | Orange | Olfa BEN HADDADA | Rel-12 | 62 | Issam | CA | LTE_CA_C_B7_BW-Core | RP-140569 |
| 2474 | 625.72.2 | Perf. part: LTE Advanced intra-band contiguous Carrier Aggregation in Band 7 - Additional bandwidth combinations | 136d? | 2013-12-09 A | 2014-06-13 A | 100% | 2013-12-09 | 2014-06-13 | 136d? | finish no earlier than 2014-06-13 | R4 | 1088h | 1088h | LTE_CA_C_B7_BW-Perf | 32 | Orange | Olfa BEN HADDADA | Rel-12 | 62 | Issam | CA | LTE_CA_C_B7_BW-Perf | RP-140569 |
| 2475 | 625.73 | **LTE Advanced intra-band non-contiguous Carrier Aggregation in Band 41 for 3 DL** | 334d? | 2013-12-09 A | 2015-03-15 A | 100% | 2013-12-09 | 2014-09-12 | 200d? |  | R4 | 6920h | 6920h | LTE_CA_NC_B41_3DL | 32 | Sprint, Alcatel-Lucent | man-hung.ng@alcatel-lucent.com | Rel-12 | 62 | Issam | CA | LTE_CA_NC_B41_3DL |  |
| 2476 | 625.73.1 | Core part:LTE Advanced intra-band non-contiguous Carrier Aggregation in Band 41 for 3 DL | 200d? | 2013-12-09 A | 2014-09-11 A | 100% | 2013-12-09 | 2014-09-12 | 200d? | finish no earlier than 2014-09-12 | R4 | 1600h | 1600h | LTE_CA_NC_B41_3DL-Core | 32 | Sprint, Alcatel-Lucent | man-hung.ng@alcatel-lucent.com | Rel-12 | 62 | Issam | CA | LTE_CA_NC_B41_3DL-Core | RP-141084 |
| 2477 | 625.73.2 | Perf. part:LTE Advanced intra-band non-contiguous Carrier Aggregation in Band 41 for 3 DL | 331d? | 2013-12-09 A | 2015-03-15 A | 100% | 2013-12-09 | 2014-09-12 | 200d? | finish no earlier than 2015-03-15 | R4 | 2648h | 2648h | LTE_CA_NC_B41_3DL-Perf | 32 | Sprint, Alcatel-Lucent | man-hung.ng@alcatel-lucent.com | Rel-12 | 62 | Issam | CA | LTE_CA_NC_B41_3DL-Perf | RP-150013 |
| 2478 | 625.74 | **LTE Advanced intra-band non-contiguous Carrier Aggregation in Band 42** | 136d? | 2013-12-09 A | 2014-06-13 A | 100% | 2013-12-09 | 2014-06-13 | 136d? |  | R4 | 3264h | 3264h | LTE_CA_NC_B42 | 32 | Huawei | Liu Liehai (liuliehai@huawei.com) | Rel-12 | 62 | Issam | CA | LTE_CA_NC_B42 |  |
| 2479 | 625.74.1 | Core part:LTE Advanced intra-band non-contiguous Carrier Aggregation in Band 42 | 136d? | 2013-12-09 A | 2014-06-13 A | 100% | 2013-12-09 | 2014-06-13 | 136d? | finish no earlier than 2014-06-13 | R4 | 1088h | 1088h | LTE_CA_NC_B42-Core | 32 | Huawei | Liu Liehai (liuliehai@huawei.com) | Rel-12 | 62 | Issam | CA | LTE_CA_NC_B42-Core | RP-140569 |
| 2480 | 625.74.2 | Perf. part:LTE Advanced intra-band non-contiguous Carrier Aggregation in Band 42 | 136d? | 2013-12-09 A | 2014-06-13 A | 100% | 2013-12-09 | 2014-06-13 | 136d? | finish no earlier than 2014-06-13 | R4 | 1088h | 1088h | LTE_CA_NC_B42-Perf | 32 | Huawei | Liu Liehai (liuliehai@huawei.com) | Rel-12 | 62 | Issam | CA | LTE_CA_NC_B42-Perf | RP-140569 |
| 2481 | 625.75 | **LTE Advanced 3 Band Carrier Aggregation (3DL/1UL) for Band 1, Band 3 and Band 5** | 203d? | 2013-12-06 A | 2014-09-12 A | 100% | 2013-12-06 | 2014-09-12 | 202d? |  | R4 | 4856h | 4856h | LTE_CA_B1_B3_B5 | 32 | SK Telecom | haesung.park@sk.com | Rel-12 | 62 | Issam | CA | LTE_CA_B1_B3_B5 |  |
| 2482 | 625.75.1 | Core part:LTE Advanced 3 Band Carrier Aggregation(3DL/1UL) for Band 1, Band 3 and Band 5 | 202d? | 2013-12-06 A | 2014-09-12 A | 100% | 2013-12-06 | 2014-09-12 | 202d? | finish no earlier than 2014-09-12 | R4 | 1616h | 1616h | LTE_CA_B1_B3_B5-Core | 32 | SK Telecom | haesung.park@sk.com | Rel-12 | 62 | Issam | CA | LTE_CA_B1_B3_B5-Core | RP-141084 |
| 2483 | 625.75.2 | Perf. part:LTE Advanced 3 Band Carrier Aggregation(3DL/1UL) for Band 1, Band 3 and Band 5 | 202d? | 2013-12-06 A | 2014-09-12 A | 100% | 2013-12-06 | 2014-09-12 | 202d? | finish no earlier than 2014-09-12 | R4 | 1616h | 1616h | LTE_CA_B1_B3_B5-Perf | 32 | SK Telecom | haesung.park@sk.com | Rel-12 | 62 | Issam | CA | LTE_CA_B1_B3_B5-Perf | RP-141084 |
| 2484 | 625.76 | **LTE Advanced 3 Band Carrier Aggregation (3DL/1UL) for Band 1, Band 3 and Band 20** | 202d? | 2013-12-09 A | 2014-09-12 A | 100% | 2013-12-09 | 2014-09-12 | 201d? |  | R4 | 4832h | 4832h | LTE_CA_B1_B3_B20 | 32 | Vodafone | luis.anaya@vodafone.com | Rel-12 | 62 | Issam | CA | LTE_CA_B1_B3_B20 |  |
| 2485 | 625.76.1 | Core part:LTE Advanced 3 Band Carrier Aggregation (3DL/1UL) for Band 1, Band 3 and Band 20 | 201d? | 2013-12-09 A | 2014-09-12 A | 100% | 2013-12-09 | 2014-09-12 | 201d? | finish no earlier than 2014-09-12 | R4 | 1608h | 1608h | LTE_CA_B1_B3_B20-Core | 32 | Vodafone | luis.anaya@vodafone.com | Rel-12 | 62 | Issam | CA | LTE_CA_B1_B3_B20-Core | RP-141084 |
| 2486 | 625.76.2 | Perf. part:LTE Advanced 3 Band Carrier Aggregation (3DL/1UL) for Band 1, Band 3 and Band 20 | 201d? | 2013-12-10 A | 2014-09-12 A | 100% | 2013-12-09 | 2014-09-12 | 201d? | finish no earlier than 2014-09-12 | R4 | 1608h | 1608h | LTE_CA_B1_B3_B20-Perf | 32 | Vodafone | luis.anaya@vodafone.com | Rel-12 | 62 | Issam | CA | LTE_CA_B1_B3_B20-Perf | RP-141084 |
| 2487 | 625.77 | **LTE Advanced 3 Band Carrier Aggregation (3DL/1UL) for Band 1, Band 7 and Band 20** | 202d? | 2013-12-09 A | 2014-09-12 A | 100% | 2013-12-09 | 2014-09-12 | 201d? |  | R4 | 4832h | 4832h | LTE_CA_B1_B7_B20 | 32 | Vodafone | luis.anaya@vodafone.com | Rel-12 | 62 | Issam | CA | LTE_CA_B1_B7_B20 |  |
| 2488 | 625.77.1 | Core part:LTE Advanced 3 Band Carrier Aggregation (3DL/1UL) for Band 1, Band 7 and Band 20 | 201d? | 2013-12-09 A | 2014-09-12 A | 100% | 2013-12-09 | 2014-09-12 | 201d? | finish no earlier than 2014-09-12 | R4 | 1608h | 1608h | LTE_CA_B1_B7_B20-Core | 32 | Vodafone | luis.anaya@vodafone.com | Rel-12 | 62 | Issam | CA | LTE_CA_B1_B7_B20-Core | RP-141084 |
| 2489 | 625.77.2 | Perf. part:LTE Advanced 3 Band Carrier Aggregation (3DL/1UL) for Band 1, Band 7 and Band 20 | 201d? | 2013-12-10 A | 2014-09-12 A | 100% | 2013-12-09 | 2014-09-12 | 201d? | finish no earlier than 2014-09-12 | R4 | 1608h | 1608h | LTE_CA_B1_B7_B20-Perf | 32 | Vodafone | luis.anaya@vodafone.com | Rel-12 | 62 | Issam | CA | LTE_CA_B1_B7_B20-Perf | RP-141084 |
| 2490 | 625.78 | **LTE Advanced 3 Band Carrier Aggregation (3DL/1UL) for Band 7, Band 8 and Band 20** | 270d? | 2013-12-09 A | 2014-12-15 A | 100% | 2013-12-09 | 2014-09-12 | 201d? |  | R4 | 6432h | 6432h | LTE_CA_B7_B8_B20 | 32 | Vodafone | luis.anaya@vodafone.com | Rel-12 | 62 | Issam | CA | LTE_CA_B7_B8_B20 |  |
| 2491 | 625.78.1 | Core part:LTE Advanced 3 Band Carrier Aggregation (3DL/1UL) for Band 7, Band 8 and Band 20 | 267d? | 2013-12-09 A | 2014-12-15 A | 100% | 2013-12-09 | 2014-09-12 | 201d? | finish no earlier than 2014-12-15 | R4 | 2136h | 2136h | LTE_CA_B7_B8_B20-Core | 32 | Vodafone | luis.anaya@vodafone.com | Rel-12 | 62 | Issam | CA | LTE_CA_B7_B8_B20-Core | RP-141732 |
| 2492 | 625.78.2 | Perf. part:LTE Advanced 3 Band Carrier Aggregation (3DL/1UL) for Band 7, Band 8 and Band 20 | 267d? | 2013-12-12 A | 2014-12-15 A | 100% | 2013-12-09 | 2014-09-12 | 201d? | finish no earlier than 2014-12-15 | R4 | 2136h | 2136h | LTE_CA_B7_B8_B20-Perf | 32 | Vodafone | luis.anaya@vodafone.com | Rel-12 | 62 | Issam | CA | LTE_CA_B7_B8_B20-Perf | RP-141732 |

Notes:
- 2469: Intra-band contig. CA 2DL/2UL / Impacted TSs and TRs: LTE
- 2470: RP#64 completed. TR 36.833-1-42v100 for 1-step Approval. Updated WID RP-132029=>RP-140728 / Impacted TSs and TRs: 36.101, 36.104, 36.133, new TR 36.833-1-42
- 2471: RP#64 completed. TR 36.833-1-42v100 for 1-step Approval. Updated WID RP-132029=>RP-140728 / Impacted TSs and TRs: 36.141, 36.307
- 2472: Intra-band contig. CA 2DL/2UL / Impacted TSs and TRs: LTE
- 2473: RP#64 completed / Impacted TSs and TRs: 36.101, 36.307
- 2474: RP#64 completed / Impacted TSs and TRs: 36.307
- 2475: Intra-band non-contig. CA 3DL / Impacted TSs and TRs: LTE
- 2476: RP#65 completed / Impacted TSs and TRs: 36.101, 36.104, 36.133, 36.307, new TR 36.833-6-xy
- 2477: CD:Thu 12/03/15->Sun 15/03/15; Compl:60%->70%; Stat Rep: RP-141084->RP-141732 1st Apr 15: Compl:70%->100% 1st Apr 15: Stat Rep: RP-141732->RP-150013 / Impacted TSs and TRs: 36.141
- 2478: Intra-band non-contig. CA 2DL / Impacted TSs and TRs: LTE
- 2479: RP#64 completed. Updated WID RP-140404=>RP-140671. TR 36.833-2-42v100 for 1-step Approval / Impacted TSs and TRs: 36.101, 36.104, 36.133, new TR 36.833-2-42
- 2480: RP#64 completed / Impacted TSs and TRs: 36.141, 36.307
- 2481: Inter-band CA 3DL / Impacted TSs and TRs: LTE
- 2482: RP#65 completed. Updated WID RP-132121=>RP-141454 / Impacted TSs and TRs: 36.101, 36.104, 36.133, new generic TR 36.853 (3 Band CA with 1UL)
- 2483: RP#65 completed. Updated WID RP-132121=>RP-141454 / Impacted TSs and TRs: 36.141, 36.307
- 2484: Inter-band CA 3DL / Impacted TSs and TRs: LTE
- 2485: RP#65 completed. Updated WID RP-141017=>RP-141222 / Impacted TSs and TRs: 36.101, 36.104, 36.133, new generic TR 36.851 (2 Band CA with 1UL), TR 36.853 (3 Band CA with 1UL)
- 2486: RP#65 completed / Impacted TSs and TRs: 36.101, 36.133, 36.141, 36.307
- 2487: Inter-band CA 3DL / Impacted TSs and TRs: LTE
- 2488: RP#65 completed. Updated WID RP-140243=>RP-141223 / Impacted TSs and TRs: 36.101, 36.104, 36.133, new generic TR 36.853 (3 Band CA with 1UL), TR 36.851 (2 Band CA with 1UL)
- 2489: RP#65 completed / Impacted TSs and TRs: 36.101, 36.133, 36.141, 36.307
- 2490: Inter-band CA 3DL / Impacted TSs and TRs: LTE
- 2491: CD:Thu 11/12/14->Mon 15/12/14; Compl:85%->100%; Stat Rep: RP-141084->RP-141732 / Impacted TSs and TRs: 36.101, 36.104, 36.133, new generic TR 36.853 (3 Band CA with 1UL), TR 36.851 (2 Band CA with 1UL)
- 2492: CD:Thu 11/12/14->Mon 15/12/14; Compl:0%->100%; Stat Rep: RP-141084->RP-141732 / Impacted TSs and TRs: 36.101, 36.133, 36.141, 36.307

| ID | WBS | Task | Duration | Start | Finish | Complete | Baseline start | Baseline finish | Baseline duration | Constraint | Resources | Work | Actual work | Acronym | PCG approved | WI rapporteur name | WI rapporteur e-mail | Release | TSG approved | MCC resp | Special Focus Doc | Acronym_3GU_Export | Status Report | PCG stopped | TSG stopped |
| --- | --- | --- | --- | --- | --- | --- | --- | --- | --- | --- | --- | --- | --- | --- | --- | --- | --- | --- | --- | --- | --- | --- | --- | --- | --- |
| 2493 | 625.79 | **Additional bandwidth combinations for LTE Advanced inter-band Carrier Aggregation of Band 2 and Band 29 and of Band 4 and Band 29** | 4d? | 2014-03-03 A | 2014-03-06 A | 100% | 2014-03-03 | 2014-03-06 | 4d? |  | R4 | 64h | 64h | LTE_DL_FDD700_B29_Bwset | 32 | AT&T | marc.grant@att.com | Rel-12 | 63 | Issam | CA | LTE_DL_FDD700_B29_Bwset |  |  |  |
| 2494 | 625.79.1 | Core part: Additional bandwidth combinations for LTE Advanced inter-band Carrier Aggregation of Band 2 and Band 29 and of Band 4 and Band 29 | 4d? | 2014-03-03 A | 2014-03-06 A | 100% | 2014-03-03 | 2014-03-06 | 4d? | finish no earlier than 2014-03-06 | R4 | 32h | 32h | LTE_DL_FDD700_B29_BWset-Core | 32 | AT&T | marc.grant@att.com | Rel-12 | 63 | Issam | CA | LTE_DL_FDD700_B29_BWset-Core | RP-140428 |  |  |
| 2495 | 625.80 | **Additional bandwidth combination set for LTE Advanced inter-band Carrier Aggregation of Band 3 and Band 20** | 72d? | 2014-03-06 A | 2014-06-13 A | 100% | 2014-03-06 | 2014-06-13 | 72d? |  | R4 | 1152h | 1152h | LTE_CA_B3_B20_BWset | 32 | NSN | iwajlo.angelow@nsn.com | Rel-12 | 63 | Issam | CA | LTE_CA_B3_B20_BWset |  |  |  |
| 2496 | 625.80.1 | Core part: Additional bandwidth combination set for LTE Advanced inter-band Carrier Aggregation of Band 3 and Band 20 | 72d? | 2014-03-06 A | 2014-06-13 A | 100% | 2014-03-06 | 2014-06-13 | 72d? | finish no earlier than 2014-06-13 | R4 | 576h | 576h | LTE_CA_B3_B20_BWset-Core | 32 | NSN | iwajlo.angelow@nsn.com | Rel-12 | 63 | Issam | CA | LTE_CA_B3_B20_BWset-Core | RP-140569 |  |  |
| 2497 | 625.81 | **Additional bandwidth combination set for LTE Advanced inter-band Carrier Aggregation of Band 7 and Band 20** | 72d? | 2014-03-06 A | 2014-06-13 A | 100% | 2014-03-06 | 2014-06-13 | 72d? |  | R4 | 1152h | 1152h | LTE_CA_B7_B20_BWset | 32 | NSN | iwajlo.angelow@nsn.com | Rel-12 | 63 | Issam | CA | LTE_CA_B7_B20_BWset |  |  |  |
| 2498 | 625.81.1 | Core part: Additional bandwidth combination set for LTE Advanced inter-band Carrier Aggregation of Band 7 and Band 20 | 72d? | 2014-03-06 A | 2014-06-13 A | 100% | 2014-03-06 | 2014-06-13 | 72d? | finish no earlier than 2014-06-13 | R4 | 576h | 576h | LTE_CA_B7_B20_BWset-Core | 32 | NSN | iwajlo.angelow@nsn.com | Rel-12 | 63 | Issam | CA | LTE_CA_B7_B20_BWset-Core | RP-140569 |  |  |
| 2499 | 625.82 | **Additional bandwidth combinations for LTE Advanced inter-band Carrier Aggregation to support 3DL fallback** | 72d? | 2014-03-06 A | 2014-06-13 A | 100% | 2014-03-06 | 2014-06-13 | 72d? |  | R4 | 1152h | 1152h | LTE_CA_3DL_FB_BW | 32 | Qualcomm | Fong Gene (gfong@qti.qualcomm.com) | Rel-12 | 63 | Issam | CA | LTE_CA_3DL_FB_BW |  |  |  |
| 2500 | 625.82.1 | Core part: Additional bandwidth combinations for LTE Advanced inter-band Carrier Aggregation to support 3DL fallback | 72d? | 2014-03-06 A | 2014-06-13 A | 100% | 2014-03-06 | 2014-06-13 | 72d? | finish no earlier than 2014-06-13 | R4 | 576h | 576h | LTE_CA_3DL_FB_BW-Core | 32 | Qualcomm | Fong Gene (gfong@qti.qualcomm.com) | Rel-12 | 63 | Issam | CA | LTE_CA_3DL_FB_BW-Core | RP-140569 |  |  |
| 2501 | 625.83 | **LTE Advanced 3 Band Carrier Aggregation (3DL/1UL) of Band 3, Band 7 and Band 7** | 138d? | 2014-03-06 A | 2014-09-12 A | 100% | 2014-03-06 | 2014-09-12 | 137d? |  | R4 | 3296h | 3296h | LTE_CA_B3_B7_B7 | 32 | Nokia Networks | iwajlo.angelow@nsn.com | Rel-12 | 63 | Issam | CA | LTE_CA_B3_B7_B7 |  |  |  |
| 2502 | 625.83.1 | Core part:LTE Advanced 3 Band Carrier Aggregation (3DL/1UL) of Band 3, Band 7 and Band 7 | 137d? | 2014-03-06 A | 2014-09-12 A | 100% | 2014-03-06 | 2014-09-12 | 137d? | finish no earlier than 2014-09-12 | R4 | 1096h | 1096h | LTE_CA_B3_B7_B7-Core | 32 | Nokia Networks | iwajlo.angelow@nsn.com | Rel-12 | 63 | Issam | CA | LTE_CA_B3_B7_B7-Core | RP-141084 |  |  |
| 2503 | 625.83.2 | Perf. part:LTE Advanced 3 Band Carrier Aggregation (3DL/1UL) of Band 3, Band 7 and Band 7 | 137d? | 2014-03-06 A | 2014-09-12 A | 100% | 2014-03-06 | 2014-09-12 | 137d? | finish no earlier than 2014-09-12 | R4 | 1096h | 1096h | LTE_CA_B3_B7_B7-Perf | 32 | Nokia Networks | iwajlo.angelow@nsn.com | Rel-12 | 63 | Issam | CA | LTE_CA_B3_B7_B7-Perf | RP-141084 |  |  |
| 2504 | 625.84 | **LTE Advanced 3 Band Carrier Aggregation (3DL/1UL) of Band 1, Band 19 and Band 21** | 138d? | 2014-03-06 A | 2014-09-12 A | 100% | 2014-03-06 | 2014-09-12 | 137d? |  | R4 | 3296h | 3296h | LTE_CA_B1_B19_B21 | 32 | NTT DOCOMO | teruaki.toeda.zf@nttdocomo.com | Rel-12 | 63 | Issam | CA | LTE_CA_B1_B19_B21 |  |  |  |
| 2505 | 625.84.1 | Core part:LTE Advanced 3 Band Carrier Aggregation (3DL/1UL) of Band 1, Band 19 and Band 21 | 137d? | 2014-03-06 A | 2014-09-12 A | 100% | 2014-03-06 | 2014-09-12 | 137d? | finish no earlier than 2014-09-12 | R4 | 1096h | 1096h | LTE_CA_B1_B19_B21-Core | 32 | NTT DOCOMO | teruaki.toeda.zf@nttdocomo.com | Rel-12 | 63 | Issam | CA | LTE_CA_B1_B19_B21-Core | RP-141084 |  |  |
| 2506 | 625.84.2 | Perf. part:LTE Advanced 3 Band Carrier Aggregation (3DL/1UL) of Band 1, Band 19 and Band 21 | 137d? | 2014-03-06 A | 2014-09-12 A | 100% | 2014-03-06 | 2014-09-12 | 137d? | finish no earlier than 2014-09-12 | R4 | 1096h | 1096h | LTE_CA_B1_B19_B21-Perf | 32 | NTT DOCOMO | teruaki.toeda.zf@nttdocomo.com | Rel-12 | 63 | Issam | CA | LTE_CA_B1_B19_B21-Perf | RP-141084 |  |  |
| 2507 | 625.85 | **LTE Advanced 3 Band Carrier Aggregation (3DL/1UL) of Band 3, Band 3 and Band 7** | 138d? | 2014-03-06 A | 2014-09-12 A | 100% | 2014-03-06 | 2014-09-12 | 137d? |  | R4 | 3296h | 3296h | LTE_CA_B3_B3_B7 | 32 | TeliaSonera | Ralf.Schuh@TeliaSonera.com | Rel-12 | 63 | Issam | CA | LTE_CA_B3_B3_B7 |  |  |  |
| 2508 | 625.85.1 | Core part: LTE-Advanced 3 Band Carrier Aggregation (3DL/1UL) of Band 3, Band 3 and Band 7 | 137d? | 2014-03-06 A | 2014-09-12 A | 100% | 2014-03-06 | 2014-09-12 | 137d? | finish no earlier than 2014-09-12 | R4 | 1096h | 1096h | LTE_CA_B3_B3_B7-Core | 32 | TeliaSonera | Ralf.Schuh@TeliaSonera.com | Rel-12 | 63 | Issam | CA | LTE_CA_B3_B3_B7-Core | RP-141084 |  |  |
| 2509 | 625.85.2 | Perf. part: LTE-Advanced 3 Band Carrier Aggregation (3DL/1UL) of Band 3, Band 3 and Band 7 | 137d? | 2014-03-06 A | 2014-09-12 A | 100% | 2014-03-06 | 2014-09-12 | 137d? | finish no earlier than 2014-09-12 | R4 | 1096h | 1096h | LTE_CA_B3_B3_B7-Perf | 32 | TeliaSonera | Ralf.Schuh@TeliaSonera.com | Rel-12 | 63 | Issam | CA | LTE_CA_B3_B3_B7-Perf | RP-141084 |  |  |
| 2510 | 625.86 | **LTE Advanced intra-band contiguous Carrier Aggregation in Band 40 for 3DL** | 72d? | 2014-03-06 A | 2014-06-13 A | 100% | 2014-03-06 | 2014-06-13 | 72d? |  | R4 | 1728h | 1728h | LTE_CA_C_B40_3DL | 32 | China Mobile | Pan Qun (panqun@chinamobile.com) | Rel-12 | 63 | Issam | CA | LTE_CA_C_B40_3DL |  |  |  |
| 2511 | 625.86.1 | Core part: LTE Advanced intra-band contiguous Carrier Aggregation in Band 40 for 3DL | 72d? | 2014-03-06 A | 2014-06-13 A | 100% | 2014-03-06 | 2014-06-13 | 72d? | finish no earlier than 2014-06-13 | R4 | 576h | 576h | LTE_CA_C_B40_3DL-Core | 32 | China Mobile | Pan Qun (panqun@chinamobile.com) | Rel-12 | 63 | Issam | CA | LTE_CA_C_B40_3DL-Core | RP-140569 |  |  |
| 2512 | 625.86.2 | Perf. part: LTE Advanced intra-band contiguous Carrier Aggregation in Band 40 for 3DL | 72d? | 2014-03-06 A | 2014-06-13 A | 100% | 2014-03-06 | 2014-06-13 | 72d? | finish no earlier than 2014-06-13 | R4 | 576h | 576h | LTE_CA_C_B40_3DL-Perf | 32 | China Mobile | Pan Qun (panqun@chinamobile.com) | Rel-12 | 63 | Issam | CA | LTE_CA_C_B40_3DL-Perf | RP-140569 |  |  |
| 2513 | 625.87 | **Additional bandwidth combination set for LTE Advanced inter-band Carrier Aggregation of Band 4 and Band 12** | 137d? | 2014-03-07 A | 2014-09-12 A | 100% | 2014-03-06 | 2014-12-05 | 197d? |  | R4 | 3288h | 3288h | LTE_CA_B4_B12_BWset | 32 | T-Mobile USA | nelson.ueng@t-mobile.com | Rel-12 | 63 | Issam | CA | LTE_CA_B4_B12_BWset |  |  |  |
| 2514 | 625.87.1 | Core part: Additional bandwidth combination set for LTE Advanced inter-band Carrier Aggregation of Band 4 and Band 12 | 137d? | 2014-03-07 A | 2014-09-12 A | 100% | 2014-03-06 | 2014-12-05 | 197d? | finish no earlier than 2014-09-12 | R4 | 1096h | 1096h | LTE_CA_B4_B12_BWset-Core | 32 | T-Mobile USA | nelson.ueng@t-mobile.com | Rel-12 | 63 | Issam | CA | LTE_CA_B4_B12_BWset-Core | RP-141084 |  |  |
| 2515 | 625.87.2 | Deleted - Perf. part: Additional bandwidth combination set for LTE Advanced inter-band Carrier Aggregation of Band 4 and Band 12 | 137d? | 2014-03-07 A | 2014-09-12 A | 100% | 2014-03-06 | 2014-12-05 | 197d? | finish no earlier than 2014-09-12 | R4 | 1096h | 1096h | LTE_CA_B4_B12_BWset-Perf | 32 | T-Mobile USA | nelson.ueng@t-mobile.com | Rel-12 | 63 | Issam | CA | LTE_CA_B4_B12_BWset-Perf | RP-141084 | PCG-33 | RP-65 |
| 2516 | 625.88 | **LTE Advanced inter-band Carrier Aggregation of Band 41 and Band 42** | 138d? | 2014-03-06 A | 2014-09-12 A | 100% | 2014-03-06 | 2014-09-12 | 137d? |  | R4 | 2776h | 2776h | LTE_CA_B41_B42 | 32 | Huawei | leo.liuye@huawei.com | Rel-12 | 63 | Issam | CA | LTE_CA_B41_B42 |  |  |  |
| 2517 | 625.88.1 | Core part:LTE Advanced inter-band Carrier Aggregation of Band 41 and Band 42 | 72d? | 2014-03-06 A | 2014-09-12 A | 100% | 2014-03-06 | 2014-09-12 | 72d? | finish no earlier than 2014-09-12 | R4 | 576h | 576h | LTE_CA_B41_B42-Core | 32 | Huawei | leo.liuye@huawei.com | Rel-12 | 63 | Issam | CA | LTE_CA_B41_B42-Core | RP-141084 |  |  |
| 2518 | 625.88.2 | Perf. Part:LTE Advanced inter-band Carrier Aggregation of Band 41 and Band 42 | 137d? | 2014-03-07 A | 2014-09-12 A | 100% | 2014-03-06 | 2014-09-12 | 137d? | finish no earlier than 2014-09-12 | R4 | 1096h | 1096h | LTE_CA_B41_B42-Perf | 32 | Huawei | leo.liuye@huawei.com | Rel-12 | 63 | Issam | CA | LTE_CA_B41_B42-Perf | RP-141084 |  |  |

Notes:
- 2493: Inter-band 2DL/1UL / Impacted TSs and TRs: LTE
- 2494: RP#63 approved WI (no Perf. Part) & completed. Rel-10 and Rel-11 versions of 36.307 affected / Impacted TSs and TRs: 36.101, 36.307
- 2495: Inter-band CA 2DL / Impacted TSs and TRs: LTE
- 2496: RP#64 completed / Impacted TSs and TRs: 36.101, TR 36.851
- 2497: Inter-band CA 2DL / Impacted TSs and TRs: LTE
- 2498: RP#64 completed / Impacted TSs and TRs: 36.101, TR 36.851
- 2499: Inter-band CA 2DL / Impacted TSs and TRs: LTE
- 2500: RP#64 completed, Additional BW combinations added for 6 Wis: 3 open Rel-12 Wis (B1_B5_B7, B2_B29_B30, B4_B29_B30) and 3 completed Rel-11 Wis (B3_B5, B4_B5, B4_B12) / Impacted TSs and TRs: 36.101, 36.307
- 2501: Inter-band CA 3DL. Mar15: acronym reverted to LTE_CA_B3_B7_B7_ / Impacted TSs and TRs: LTE
- 2502: RP#65 completed. Updated WID RP-140095=>RP-141196. Mar15: acronym reverted to LTE_CA_B3_B7_B7-Core_ / Impacted TSs and TRs: 36.101, 36.104, 36.133, new generic TR 36.853 (3 Band CA with 1UL)
- 2503: RP#65 completed. Updated WID RP-140095=>RP-141196. Mar15: acronym reverted from LTE_CA_B3_B7_B7-Perf_ / Impacted TSs and TRs: 36.141, 36.307
- 2504: Inter-band CA 3DL / Impacted TSs and TRs: LTE
- 2505: RP#65 completed. Updated WID RP-140106=>RP-141193 / Impacted TSs and TRs: 36.101, 36.104, 36.133, new generic TR 36.853 (3 Band CA with 1UL)
- 2506: RP#65 completed. Updated WID RP-140106=>RP-141193 / Impacted TSs and TRs: 36.141, 36.307
- 2507: Inter-band CA 3DL / Impacted TSs and TRs: LTE
- 2508: RP#65 completed. Updated RP-140390=>RP-141126 / Impacted TSs and TRs: 36.101, 36.104, 36.133, new generic TR 36.853 (3 Band CA with 1UL)
- 2509: RP#65 completed. Updated RP-140390=>RP-141126 / Impacted TSs and TRs: 36.141, 36.307
- 2510: Intra-band contig. CA 3DL / Impacted TSs and TRs: LTE
- 2511: RP#64 completed. Updated WID RP-140453=>RP-140948 / Impacted TSs and TRs: 36.101, 36.104, 36.133, New TR 36.833-5-40
- 2512: RP#64 completed. Updated WID RP-140453=>RP-140948 / Impacted TSs and TRs: 36.141, 36.307
- 2513: Inter-band CA 2DL / Impacted TSs and TRs: LTE
- 2514: RP#65 completed. Updated WID RP-140987=>RP-141235 (removed Perf. Part) / Impacted TSs and TRs: 36.101, generic TR 36.850
- 2515: RP#65 stopped. Updated WID RP-140987=>RP-141235 (removed Perf. Part) / Impacted TSs and TRs: 36.307
- 2516: Inter-band CA 2DL / Impacted TSs and TRs: LTE
- 2517: RP#65 completed / Impacted TSs and TRs: 36.101, 36.104, TR 36.851
- 2518: RP#65 completed / Impacted TSs and TRs: 36.141

| ID | WBS | Task | Duration | Start | Finish | Complete | Baseline start | Baseline finish | Baseline duration | Constraint | Resources | Work | Actual work | Acronym | PCG approved | WI rapporteur name | WI rapporteur e-mail | Release | TSG approved | MCC resp | Special Focus Doc | Acronym_3GU_Export | Status Report |
| --- | --- | --- | --- | --- | --- | --- | --- | --- | --- | --- | --- | --- | --- | --- | --- | --- | --- | --- | --- | --- | --- | --- | --- |
| 2519 | 625.89 | **LTE Advanced 3 Band Carrier Aggregation (3DL/1UL) of Band 4, Band 4, and Band 12** | 138d? | 2014-03-06 A | 2014-09-12 A | 100% | 2014-03-06 | 2014-12-05 | 197d? |  | R4 | 3296h | 3296h | LTE_CA_B4_B4_B12 | 32 | T-Mobile USA | nelson.ueng@t-mobile.com | Rel-12 | 63 | Issam | CA | LTE_CA_B4_B4_B12 |  |
| 2520 | 625.89.1 | Core part:LTE Advanced 3 Band Carrier Aggregation (3DL/1UL) of Band 4, Band 4, and Band 12 | 137d? | 2014-03-06 A | 2014-09-12 A | 100% | 2014-03-06 | 2014-12-05 | 197d? | finish no earlier than 2014-09-12 | R4 | 1096h | 1096h | LTE_CA_B4_B4_B12-Core | 32 | T-Mobile USA | nelson.ueng@t-mobile.com | Rel-12 | 63 | Issam | CA | LTE_CA_B4_B4_B12-Core | RP-141084 |
| 2521 | 625.89.2 | Perf. part:LTE Advanced 3 Band Carrier Aggregation (3DL/1UL) of Band 4, Band 4, and Band 12 | 137d? | 2014-03-07 A | 2014-09-12 A | 100% | 2014-03-06 | 2014-12-05 | 197d? | finish no earlier than 2014-09-12 | R4 | 1096h | 1096h | LTE_CA_B4_B4_B12-Perf | 32 | T-Mobile USA | nelson.ueng@t-mobile.com | Rel-12 | 63 | Issam | CA | LTE_CA_B4_B4_B12-Perf | RP-141084 |
| 2522 | 625.90 | **LTE Advanced 3 Band Carrier Aggregation (3DL/1UL) of Band 2, Band 4, and Band 4** | 138d? | 2014-03-06 A | 2014-09-12 A | 100% | 2014-03-06 | 2014-12-05 | 197d? |  | R4 | 3296h | 3296h | LTE_CA_B2_B4_B4 | 32 | T-Mobile USA | nelson.ueng@T-Mobile.com | Rel-12 | 63 | Issam | CA | LTE_CA_B2_B4_B4 |  |
| 2523 | 625.90.1 | Core part:LTE Advanced 3 Band Carrier Aggregation (3DL/1UL) of Band 2, Band 4, and Band 4 | 137d? | 2014-03-06 A | 2014-09-12 A | 100% | 2014-03-06 | 2014-12-05 | 197d? | finish no earlier than 2014-09-12 | R4 | 1096h | 1096h | LTE_CA_B2_B4_B4-Core | 32 | T-Mobile USA | nelson.ueng@T-Mobile.com | Rel-12 | 63 | Issam | CA | LTE_CA_B2_B4_B4-Core | RP-141084 |
| 2524 | 625.90.2 | Perf. part:LTE Advanced 3 Band Carrier Aggregation (3DL/1UL) of Band 2, Band 4, and Band 4 | 137d? | 2014-03-07 A | 2014-09-12 A | 100% | 2014-03-06 | 2014-12-05 | 197d? | finish no earlier than 2014-09-12 | R4 | 1096h | 1096h | LTE_CA_B2_B4_B4-Perf | 32 | T-Mobile USA | nelson.ueng@T-Mobile.com | Rel-12 | 63 | Issam | CA | LTE_CA_B2_B4_B4-Perf | RP-141084 |
| 2525 | 625.91 | **Additional bandwidth combinations for LTE Advanced intra-band non-contiguous Carrier Aggregation in Band 25** | 138d? | 2014-03-06 A | 2014-09-12 A | 100% | 2014-03-06 | 2014-09-12 | 137d? |  | R4 | 3296h | 3296h | LTE_CA_NC_B25_BWset | 32 | Huawei | Liu Liehai (liuliehai@huawei.com) | Rel-12 | 63 | Issam | CA | LTE_CA_NC_B25_BWset |  |
| 2526 | 625.91.1 | Core part: Additional bandwidth combinations for LTE Advanced intra-band non-contiguous Carrier Aggregation in Band 25 | 137d? | 2014-03-06 A | 2014-09-12 A | 100% | 2014-03-06 | 2014-09-12 | 137d? | finish no earlier than 2014-09-12 | R4 | 1096h | 1096h | LTE_CA_NC_B25_BWset-Core | 32 | Huawei | Liu Liehai (liuliehai@huawei.com) | Rel-12 | 63 | Issam | CA | LTE_CA_NC_B25_BWset-Core | RP-141084 |
| 2527 | 625.91.2 | Perf. part: Additional bandwidth combinations for LTE Advanced intra-band non-contiguous Carrier Aggregation in Band 25 | 137d? | 2014-03-07 A | 2014-09-12 A | 100% | 2014-03-06 | 2014-09-12 | 137d? | finish no earlier than 2014-09-12 | R4 | 1096h | 1096h | LTE_CA_NC_B25_BWset-Perf | 32 | Huawei | Liu Liehai (liuliehai@huawei.com) | Rel-12 | 63 | Issam | CA | LTE_CA_NC_B25_BWset-Perf | RP-141084 |
| 2528 | 625.92 | **Additional bandwidth combination set for LTE Advanced inter-band Carrier Aggregation of Band 2 and Band 4** | 66d? | 2014-06-15 A | 2014-09-15 A | 100% | 2014-06-13 | 2014-09-12 | 66d? |  | R4 | 1056h | 1056h | LTE_CA_B2_B4_Bwset2 | 33 | T-Mobile USA | nelson.ueng@T-Mobile.com | Rel-12 | 64 |  | CA | LTE_CA_B2_B4_BWset |  |
| 2529 | 625.92.1 | Core part: Additional bandwidth combination set 2 for LTE Advanced inter-band Carrier Aggregation of Band 2 and Band 4 | 66d? | 2014-06-15 A | 2014-09-15 A | 100% | 2014-06-13 | 2014-09-12 | 66d? | finish no earlier than 2014-09-15 | R4 | 528h | 528h | LTE_CA_B2_B4_BWset2-Core | 33 | T-Mobile USA | nelson.ueng@T-Mobile.com | Rel-12 | 64 |  | CA | LTE_CA_B2_B4_BWset-Core | RP-141084 |
| 2530 | 625.93 | **Additional bandwidth combination set for LTE Advanced inter-band Carrier Aggregation of Band 2 and Band 5** | 132d? | 2014-06-18 A | 2014-12-15 A | 100% | 2014-06-13 | 2014-09-12 | 66d? |  | R4 | 3168h | 3168h | LTE_CA_B2_B5_BWset | 33 | AT&T | marc.grant@att.com | Rel-12 | 64 |  | CA | LTE_CA_B2_B5_BWset |  |
| 2531 | 625.93.1 | Core part: Additional bandwidth combination set for LTE Advanced inter-band Carrier Aggregation of Band 2 and Band 5 | 132d? | 2014-06-18 A | 2014-12-15 A | 100% | 2014-06-13 | 2014-09-12 | 66d? | finish no earlier than 2014-12-15 | R4 | 1056h | 1056h | LTE_CA_B2_B5_Bwset-Core | 33 | AT&T | marc.grant@att.com | Rel-12 | 64 |  | CA | LTE_CA_B2_B5_Bwset-Core | RP-141732 |
| 2532 | 625.93.2 | Perf. Part: Additional bandwidth combination set for LTE Advanced inter-band Carrier Aggregation of Band 2 and Band 5 | 132d? | 2014-06-18 A | 2014-12-15 A | 100% | 2014-06-13 | 2014-09-12 | 66d? | finish no earlier than 2014-12-15 | R4 | 1056h | 1056h | LTE_CA_B2_B5_BWset-Perf | 33 | AT&T | marc.grant@att.com | Rel-12 | 64 |  | CA | LTE_CA_B2_B5_BWset-Perf | RP-141732 |
| 2533 | 625.94 | **E-UTRA UE demodulation/Channel State Information (CSI) performance requirements for multiple Carrier Aggregation configurations** | 198d? | 2014-06-16 A | 2015-03-15 A | 100% | 2014-06-13 | 2015-03-13 | 196d? |  | R4 | 3152h | 3152h | LTE_CA_Mult | 33 | China Mobile | Zhang Xiaoran (zhangxiaoran@chinamobile.com) | Rel-12 | 64 |  | CA | LTE_CA_Mult |  |
| 2534 | 625.94.1 | Perf. Part: E-UTRA UE demodulation/Channel State Information (CSI) performance requirements for multiple Carrier Aggregation configurations | 196d? | 2014-06-16 A | 2015-03-15 A | 100% | 2014-06-13 | 2015-03-13 | 196d? | finish no earlier than 2015-03-15 | R4 | 1568h | 1568h | LTE_CA_Mult-Perf | 33 | China Mobile | Zhang Xiaoran (zhangxiaoran@chinamobile.com) | Rel-12 | 64 |  | CA | LTE_CA_Mult-Perf | RP-150188 |
| 2535 | 625.95 | **LTE Advanced 3 Band Carrier Aggregation (3DL/1UL) of Band 1, Band 3 and Band 19** | 66d? | 2014-06-16 A | 2014-09-12 A | 100% | 2014-06-13 | 2014-09-12 | 66d? |  | R4 | 1584h | 1584h | LTE_CA_B1_B3_B19 | 33 | NTT DOCOMO | teruaki.toeda.zf@nttdocomo.com | Rel-12 | 64 |  | CA | LTE_CA_B1_B3_B19 |  |
| 2536 | 625.95.1 | Core part:LTE Advanced 3 Band Carrier Aggregation (3DL/1UL) of Band 1, Band 3 and Band 19 | 66d? | 2014-06-16 A | 2014-09-12 A | 100% | 2014-06-13 | 2014-09-12 | 66d? | finish no earlier than 2014-09-12 | R4 | 528h | 528h | LTE_CA_B1_B3_B19-Core | 33 | NTT DOCOMO | teruaki.toeda.zf@nttdocomo.com | Rel-12 | 64 |  | CA | LTE_CA_B1_B3_B19-Core | RP-141084 |
| 2537 | 625.95.2 | Perf. Part:LTE Advanced 3 Band Carrier Aggregation (3DL/1UL) of Band 1, Band 3 and Band 19 | 66d? | 2014-06-16 A | 2014-09-12 A | 100% | 2014-06-13 | 2014-09-12 | 66d? | finish no earlier than 2014-09-12 | R4 | 528h | 528h | LTE_CA_B1_B3_B19-Perf | 33 | NTT DOCOMO | teruaki.toeda.zf@nttdocomo.com | Rel-12 | 64 |  | CA | LTE_CA_B1_B3_B19-Perf | RP-141084 |
| 2538 | 625.96 | **LTE Advanced 3 Band Carrier Aggregation (3DL/1UL) of Band 19, Band 42 and Band 42** | 66d? | 2014-06-16 A | 2014-09-12 A | 100% | 2014-06-13 | 2014-09-12 | 66d? |  | R4 | 1584h | 1584h | LTE_CA_B19_B42_B42 | 33 | NTT DOCOMO | teruaki.toeda.zf@nttdocomo.com | Rel-12 | 64 |  | CA | LTE_CA_B19_B42_B42 |  |
| 2539 | 625.96.1 | Core part:LTE Advanced 3 Band Carrier Aggregation (3DL/1UL) of Band 19, Band 42 and Band 42 | 66d? | 2014-06-16 A | 2014-09-12 A | 100% | 2014-06-13 | 2014-09-12 | 66d? | finish no earlier than 2014-09-12 | R4 | 528h | 528h | LTE_CA_B19_B42_B42-Core | 33 | NTT DOCOMO | teruaki.toeda.zf@nttdocomo.com | Rel-12 | 64 |  | CA | LTE_CA_B19_B42_B42-Core | RP-141084 |
| 2540 | 625.96.2 | Perf. Part:LTE Advanced 3 Band Carrier Aggregation (3DL/1UL) of Band 19, Band 42 and Band 42 | 66d? | 2014-06-16 A | 2014-09-12 A | 100% | 2014-06-13 | 2014-09-12 | 66d? | finish no earlier than 2014-09-12 | R4 | 528h | 528h | LTE_CA_B19_B42_B42-Perf | 33 | NTT DOCOMO | teruaki.toeda.zf@nttdocomo.com | Rel-12 | 64 |  | CA | LTE_CA_B19_B42_B42-Perf | RP-141084 |
| 2541 | 625.97 | **LTE Advanced 3 Band Carrier Aggregation (3DL/1UL) of Band 3, Band 42 and Band 42** | 198d? | 2014-06-16 A | 2015-03-15 A | 100% | 2014-06-13 | 2014-09-12 | 66d? |  | R4 | 4720h | 4720h | LTE_CA_B3_B42_B42 | 33 | NTT DOCOMO | ANDO Kei (kei.andou.ye@nttdocomo.com) | Rel-12 | 64 |  | CA | LTE_CA_B3_B42_B42 |  |
| 2542 | 625.97.1 | Core part:LTE Advanced 3 Band Carrier Aggregation (3DL/1UL) of Band 3, Band 42 and Band 42 | 196d? | 2014-06-16 A | 2015-03-15 A | 100% | 2014-06-13 | 2014-09-12 | 66d? | finish no earlier than 2015-03-15 | R4 | 1568h | 1568h | LTE_CA_B3_B42_B42-Core | 33 | NTT DOCOMO | ANDO Kei (kei.andou.ye@nttdocomo.com) | Rel-12 | 64 |  | CA | LTE_CA_B3_B42_B42-Core | RP-150013 |
| 2543 | 625.97.2 | Perf. Part:LTE Advanced 3 Band Carrier Aggregation (3DL/1UL) of Band 3, Band 42 and Band 42 | 196d? | 2014-06-16 A | 2015-03-15 A | 100% | 2014-06-13 | 2014-09-12 | 66d? | finish no earlier than 2016-03-15 | R4 | 1568h | 1568h | LTE_CA_B3_B42_B42-Perf | 33 | NTT DOCOMO | ANDO Kei (kei.andou.ye@nttdocomo.com) | Rel-12 | 64 |  | CA | LTE_CA_B3_B42_B42-Perf | RP-150013 |

Notes:
- 2519: Inter-band CA 3DL / Impacted TSs and TRs: LTE
- 2520: RP#65 completed. Updated WID RP-140116=>RP-141709 / Impacted TSs and TRs: 36.101, 36.104, 36.133, 36.141, 36.307, generic TR 36.853 (3 Band CA with 1UL)
- 2521: RP#65 completed / Impacted TSs and TRs: 36.101, 36.104, 36.133, 36.141, 36.307
- 2522: Inter-band CA 3DL / Impacted TSs and TRs: LTE
- 2523: RP#65 completed. Updated WID RP-140117=>RP-141236 / Impacted TSs and TRs: 36.101, 36.104, 36.133, 36.141, 36.307, generic TR 36.853 (3 Band CA with 1UL)
- 2524: RP#65 completed / Impacted TSs and TRs: 36.101, 36.104, 36.133, 36.141, 36.307
- 2525: Intra-band non-contig. CA 2DL / Impacted TSs and TRs: LTE
- 2526: RP#65 completed / Impacted TSs and TRs: 36.101, 36.307, TR 36.833-2-25
- 2527: RP#65 completed / Impacted TSs and TRs: 36.307
- 2528: Inter-band CA 2DL. Mar 15: acronym changed from LTE_CA_B2_B4_Bwset_ / Impacted TSs and TRs: LTE
- 2529: Dec 14: Prev CD:Fri 12/09/14; Prev %:100%, title changed. Mar 15: Acronym changed to LTE_CA_B2_B4_BWset2-Core_ / Impacted TSs and TRs: 36.101, 36.851
- 2530: 2DL/1UL / Impacted TSs and TRs: LTE
- 2531: ; WID: RP-142043->RP-141803; Stat Rep: RP-141084->RP-141732 / Impacted TSs and TRs: 36.101, 36.851
- 2532: CD:Thu 11/12/14->Mon 15/12/14; Compl:0%->0%; Stat Rep: RP-141084->RP-141732 / Impacted TSs and TRs: 36.307
- 2533: LTE / Impacted TSs and TRs: LTE
- 2534: CD:Thu 12/03/15->Sun 15/03/15; Compl:10%->90%; Stat Rep: RP-141303->RP-141839 1st Apr 15: Compl:90%->100% 1st Apr 15: Stat Rep: RP-141839->RP-150188 / Impacted TSs and TRs: 36.101
- 2535: Inter-band CA 3DL / Impacted TSs and TRs: LTE
- 2536: RP#65 completed / Impacted TSs and TRs: 36.101, 36.104, 36.133, generic TR 36.853 (3 Band CA with 1UL)
- 2537: RP#65 completed / Impacted TSs and TRs: 36.141, 36.307
- 2538: Inter-band CA 3DL / Impacted TSs and TRs: LTE
- 2539: RP#65 completed / Impacted TSs and TRs: 36.101, 36.104, 36.133, generic TR 36.853 (3 Band CA with 1UL)
- 2540: RP#65 completed / Impacted TSs and TRs: 36.141, 36.307
- 2541: 3DL/1UL / Impacted TSs and TRs: LTE
- 2542: CD:Thu 11/12/14->Sun 15/03/15; Compl:50%->70%; Stat Rep: RP-141084->RP-141732 1st Apr 15: Compl:70%->100% 1st Apr 15: Stat Rep: RP-141732->RP-150013 / Impacted TSs and TRs: 36.101, 36.104, 36.133, generic TR 36.853 (3 Band CA with 1UL)
- 2543: CD:Thu 11/12/14->Tue 15/03/16; Compl:50%->70%; Stat Rep: RP-141084->RP-141732 1st Apr 15: Compl:70%->100% 1st Apr 15: CD:Tue 15/03/16->Sun 15/03/15 1st Apr 15: Stat Rep: RP-141732->RP-150013 / Impacted TSs and TRs: 36.141, 36.307

| ID | WBS | Task | Duration | Start | Finish | Complete | Baseline start | Baseline finish | Baseline duration | Constraint | Resources | Work | Actual work | Acronym | PCG approved | WI rapporteur name | WI rapporteur e-mail | Release | TSG approved | Special Focus Doc | Acronym_3GU_Export | Status Report | MCC resp |
| --- | --- | --- | --- | --- | --- | --- | --- | --- | --- | --- | --- | --- | --- | --- | --- | --- | --- | --- | --- | --- | --- | --- | --- |
| 2544 | 625.98 | **LTE Advanced 3 Band Carrier Aggregation (3DL/1UL) of Band 1, Band 42 and Band 42** | 66d? | 2014-06-16 A | 2014-09-12 A | 100% | 2014-06-13 | 2014-09-12 | 66d? |  | R4 | 1584h | 1584h | LTE_CA_B1_B42_B42 | 33 | NTT DOCOMO | ANDO Kei (kei.andou.ye@nttdocomo.com) | Rel-12 | 64 | CA | LTE_CA_B1_B42_B42 |  |  |
| 2545 | 625.98.1 | Core part:LTE Advanced 3 Band Carrier Aggregation (3DL/1UL) of Band 1, Band 42 and Band 42 | 66d? | 2014-06-16 A | 2014-09-12 A | 100% | 2014-06-13 | 2014-09-12 | 66d? | finish no earlier than 2014-09-12 | R4 | 528h | 528h | LTE_CA_B1_B42_B42-Core | 33 | NTT DOCOMO | ANDO Kei (kei.andou.ye@nttdocomo.com) | Rel-12 | 64 | CA | LTE_CA_B1_B42_B42-Core | RP-141084 |  |
| 2546 | 625.98.2 | Perf. Part:LTE Advanced 3 Band Carrier Aggregation (3DL/1UL) of Band 1, Band 42 and Band 42 | 66d? | 2014-06-16 A | 2014-09-12 A | 100% | 2014-06-13 | 2014-09-12 | 66d? | finish no earlier than 2014-09-12 | R4 | 528h | 528h | LTE_CA_B1_B42_B42-Perf | 33 | NTT DOCOMO | ANDO Kei (kei.andou.ye@nttdocomo.com) | Rel-12 | 64 | CA | LTE_CA_B1_B42_B42-Perf | RP-141084 |  |
| 2547 | 625.99 | **Additional bandwidth combination set for LTE Advanced intra-band contiguous Carrier Aggregation in Band 40 for 3DL** | 66d? | 2014-06-16 A | 2014-09-12 A | 100% | 2014-06-13 | 2014-09-12 | 66d? |  | R4 | 1096h | 1096h | LTE_CA_C_B40_3DL_BW | 33 | TeliaSonera | Ralf.Schuh@TeliaSonera.com | Rel-12 | 64 | CA | LTE_CA_C_B40_3DL_BW |  |  |
| 2548 | 625.99.1 | Core part: Additional bandwidth combination set for LTE Advanced intra-band contiguous Carrier Aggregation in Band 40 for 3DL | 66d? | 2014-06-16 A | 2014-09-12 A | 100% | 2014-06-13 | 2014-09-12 | 66d? | finish no earlier than 2014-09-12 | R4 | 528h | 528h | LTE_CA_C_B40_3DL_BW-Core | 33 | TeliaSonera | Ralf.Schuh@TeliaSonera.com | Rel-12 | 64 | CA | LTE_CA_C_B40_3DL_BW-Core | RP-141084 |  |
| 2549 | 625.99.2 | Perf. part: Additional bandwidth combination set for LTE Advanced intra-band contiguous Carrier Aggregation in Band 40 for 3DL | 5d? | 2014-09-08 A | 2014-09-12 A | 100% |  |  |  | finish no earlier than 2014-09-12 | R4 | 40h | 40h | LTE_CA_C_B40_3DL_BW-Perf | 33 | TeliaSonera | Ralf.Schuh@TeliaSonera.com | Rel-12 | 65 |  | LTE_CA_C_B40_3DL_BW-Perf | RP-141084 |  |
| 2550 | 625.100 | **LTE Advanced inter-band Carrier Aggregation of Band 18 and Band 28** | 3d? | 2014-09-10 A | 2014-09-12 A | 100% | 2014-03-06 | 2015-03-13 | 267d? |  | R4 | 72h | 72h | LTE_CA_B18_B28 | 33 | KDDI | Masaaki Obara (ms-obara@kddi.com) | Rel-12 | 65 | CA | LTE_CA_B18_B28 |  | Issam |
| 2551 | 625.100.1 | Core part:LTE Advanced inter-band Carrier Aggregation of Band 18 and Band 28 | 3d? | 2014-09-10 A | 2014-09-12 A | 100% | 2014-03-06 | 2015-03-13 | 267d? | finish no earlier than 2014-09-12 | R4 | 24h | 24h | LTE_CA_B18_B28-Core | 33 | KDDI | Masaaki Obara (ms-obara@kddi.com) | Rel-12 | 65 | CA | LTE_CA_B18_B28-Core |  | Issam |
| 2552 | 625.100.2 | Perf. Part:LTE Advanced inter-band Carrier Aggregation of Band 18 and Band 28 | 3d? | 2014-09-10 A | 2014-09-12 A | 100% | 2014-03-06 | 2015-03-13 | 267d? | finish no earlier than 2014-09-12 | R4 | 24h | 24h | LTE_CA_B18_B28-Perf | 33 | KDDI | Masaaki Obara (ms-obara@kddi.com) | Rel-12 | 65 | CA | LTE_CA_B18_B28-Perf |  | Issam |
| 2553 | 625.101 | **LTE Advanced inter-band Carrier Aggregation of Band 5 and Band 13** | 206d? | 2014-03-06 A | 2014-12-15 A | 100% | 2014-03-06 | 2014-12-05 | 197d? |  | R4 | 4896h | 4896h | LTE_CA_B5_B13 | 32 | Intel | xinrong.wang@intel.com | Rel-12 | 63 | CA | LTE_CA_B5_B13 |  | Issam |
| 2554 | 625.101.1 | Core part:LTE Advanced inter-band Carrier Aggregation of Band 5 and Band 13 | 203d? | 2014-03-06 A | 2014-12-15 A | 100% | 2014-03-06 | 2014-12-05 | 197d? | finish no earlier than 2014-12-15 | R4 | 1624h | 1624h | LTE_CA_B5_B13-Core | 32 | Intel | xinrong.wang@intel.com | Rel-12 | 63 | CA | LTE_CA_B5_B13-Core | RP-141732 | Issam |
| 2555 | 625.101.2 | Perf. part:LTE Advanced inter-band Carrier Aggregation of Band 5 and Band 13 | 203d? | 2014-03-06 A | 2014-12-15 A | 100% | 2014-03-06 | 2014-12-05 | 197d? | finish no earlier than 2014-12-15 | R4 | 1624h | 1624h | LTE_CA_B5_B13-Perf | 32 | Intel | xinrong.wang@intel.com | Rel-12 | 63 | CA | LTE_CA_B5_B13-Perf | RP-141732 | Issam |
| 2556 | 625.102 | **LTE Advanced 3 Band Carrier Aggregation (3DL/1UL) of Band 2, Band 2 and Band 5** | 206d? | 2014-03-06 A | 2014-12-15 A | 100% | 2014-03-06 | 2014-12-05 | 197d? |  | R4 | 4912h | 4912h | LTE_CA_B2_B2_B5 | 32 | Intel | peiling.zhang@intel.com | Rel-12 | 63 | CA | LTE_CA_B2_B2_B5 |  | Issam |
| 2557 | 625.102.1 | Core part:LTE Advanced 3 Band Carrier Aggregation (3DL/1UL) of Band 2, Band 2 and Band 5 | 205d? | 2014-03-06 A | 2014-12-15 A | 100% | 2014-03-06 | 2014-12-05 | 197d? | finish no earlier than 2014-12-15 | R4 | 1640h | 1640h | LTE_CA_B2_B2_B5-Core | 32 | Intel | peiling.zhang@intel.com | Rel-12 | 63 | CA | LTE_CA_B2_B2_B5-Core | RP-141732 | Issam |
| 2558 | 625.102.2 | Perf. part:LTE Advanced 3 Band Carrier Aggregation (3DL/1UL) of Band 2, Band 2 and Band 5 | 203d? | 2014-03-06 A | 2014-12-15 A | 100% | 2014-03-06 | 2014-12-05 | 197d? | finish no earlier than 2014-12-15 | R4 | 1624h | 1624h | LTE_CA_B2_B2_B5-Perf | 32 | Intel | peiling.zhang@intel.com | Rel-12 | 63 | CA | LTE_CA_B2_B2_B5-Perf | RP-141732 | Issam |
| 2559 | 625.103 | **LTE Advanced 3 Band Carrier Aggregation (3DL/1UL) of Band 4, Band 4 and Band 5** | 206d? | 2014-03-06 A | 2014-12-15 A | 100% | 2014-03-06 | 2014-12-05 | 197d? |  | R4 | 4912h | 4912h | LTE_CA_B4_B4_B5 | 32 | Intel | peiling.zhang@intel.com | Rel-12 | 63 | CA | LTE_CA_B4_B4_B5 |  | Issam |
| 2560 | 625.103.1 | Core part:LTE Advanced 3 Band Carrier Aggregation (3DL/1UL) of Band 4, Band 4 and Band 5 | 205d? | 2014-03-06 A | 2014-12-15 A | 100% | 2014-03-06 | 2014-12-05 | 197d? | finish no earlier than 2014-12-15 | R4 | 1640h | 1640h | LTE_CA_B4_B4_B5-Core | 32 | Intel | peiling.zhang@intel.com | Rel-12 | 63 | CA | LTE_CA_B4_B4_B5-Core | RP-141732 | Issam |
| 2561 | 625.103.2 | Perf. part:LTE Advanced 3 Band Carrier Aggregation (3DL/1UL) of Band 4, Band 4 and Band 5 | 203d? | 2014-03-06 A | 2014-12-15 A | 100% | 2014-03-06 | 2014-12-05 | 197d? | finish no earlier than 2014-12-15 | R4 | 1624h | 1624h | LTE_CA_B4_B4_B5-Perf | 32 | Intel | peiling.zhang@intel.com | Rel-12 | 63 | CA | LTE_CA_B4_B4_B5-Perf | RP-141732 | Issam |
| 2562 | 625.104 | **LTE Advanced 3 Band Carrier Aggregation (3DL/1UL) of Band 2, Band 5 and Band 13** | 206d? | 2014-03-06 A | 2014-12-15 A | 100% | 2014-03-06 | 2014-12-05 | 197d? |  | R4 | 4896h | 4896h | LTE_CA_B2_B5_B13 | 32 | Intel | xinrong.wang@intel.com | Rel-12 | 63 | CA | LTE_CA_B2_B5_B13 |  | Issam |
| 2563 | 625.104.1 | Core part:LTE Advanced 3 Band Carrier Aggregation (3DL/1UL) of Band 2, Band 5 and Band 13 | 203d? | 2014-03-06 A | 2014-12-15 A | 100% | 2014-03-06 | 2014-12-05 | 197d? | finish no earlier than 2014-12-15 | R4 | 1624h | 1624h | LTE_CA_B2_B5_B13-Core | 32 | Intel | xinrong.wang@intel.com | Rel-12 | 63 | CA | LTE_CA_B2_B5_B13-Core | RP-141732 | Issam |
| 2564 | 625.104.2 | Perf. part:LTE Advanced 3 Band Carrier Aggregation (3DL/1UL) of Band 2, Band 5 and Band 13 | 203d? | 2014-03-06 A | 2014-12-15 A | 100% | 2014-03-06 | 2014-12-05 | 197d? | finish no earlier than 2014-12-15 | R4 | 1624h | 1624h | LTE_CA_B2_B5_B13-Perf | 32 | Intel | xinrong.wang@intel.com | Rel-12 | 63 | CA | LTE_CA_B2_B5_B13-Perf | RP-141732 | Issam |
| 2565 | 625.105 | **LTE Advanced 3 Band Carrier Aggregation (3DL/1UL) of Band 4, Band 5 and Band 13** | 206d? | 2014-03-06 A | 2014-12-15 A | 100% | 2014-03-06 | 2014-12-05 | 197d? |  | R4 | 4896h | 4896h | LTE_CA_B4_B5_B13 | 32 | Intel | xinrong.wang@intel.com | Rel-12 | 63 | CA | LTE_CA_B4_B5_B13 |  | Issam |
| 2566 | 625.105.1 | Core part:LTE Advanced 3 Band Carrier Aggregation (3DL/1UL) of Band 4, Band 5 and Band 13 | 203d? | 2014-03-06 A | 2014-12-15 A | 100% | 2014-03-06 | 2014-12-05 | 197d? | finish no earlier than 2014-12-15 | R4 | 1624h | 1624h | LTE_CA_B4_B5_B13-Core | 32 | Intel | xinrong.wang@intel.com | Rel-12 | 63 | CA | LTE_CA_B4_B5_B13-Core | RP-141732 | Issam |
| 2567 | 625.105.2 | Perf. part:LTE Advanced 3 Band Carrier Aggregation (3DL/1UL) of Band 4, Band 5 and Band 13 | 203d? | 2014-03-06 A | 2014-12-15 A | 100% | 2014-03-06 | 2014-12-05 | 197d? | finish no earlier than 2014-12-15 | R4 | 1624h | 1624h | LTE_CA_B4_B5_B13-Perf | 32 | Intel | xinrong.wang@intel.com | Rel-12 | 63 | CA | LTE_CA_B4_B5_B13-Perf | RP-141732 | Issam |

Notes:
- 2544: Inter-band CA 3DL / Impacted TSs and TRs: LTE
- 2545: RP#65 completed / Impacted TSs and TRs: 36.101, 36.104, 36.133, generic TR 36.853 (3 Band CA with 1UL)
- 2546: RP#65 completed / Impacted TSs and TRs: 36.141, 36.307
- 2547: Inter-band CA 3DL / Impacted TSs and TRs: LTE
- 2548: RP#65 completed. Updated WID RP-140950=>RP-141127 / Impacted TSs and TRs: 36.101
- 2549: RP#65 updated WID RP-140950=>RP-141127 (added Perf. Part). Completed. / Impacted TSs and TRs: 36.307
- 2550: Inter-band CA 2DL / Impacted TSs and TRs: LTE
- 2551: RP#65 WID approved & completed. Triggered by revised Rel-13 WID RP-140451=>RP-141610 (take out B18_B28 for Rel-12 from the Rel-13 B1_B18_B28) / Impacted TSs and TRs: 36.101, 36.104, 36.133
- 2552: - / Impacted TSs and TRs: 36.141, 36.307
- 2553: Inter-band CA 2DL / Impacted TSs and TRs: LTE
- 2554: CD:Thu 12/03/15->Mon 15/12/14; Compl:50%->100%; Stat Rep: RP-141084->RP-141732; Release: Rel-13->Rel-12 / Impacted TSs and TRs: 36.101, 36.104, 36.133, generic TR 36.851 (2 Band CA with 1UL)
- 2555: CD:Thu 12/03/15->Mon 15/12/14; Compl:10%->100%; Stat Rep: RP-141084->RP-141732; Release: Rel-13->Rel-12 / Impacted TSs and TRs: 36.101, 36.133, 36.141, 36.307
- 2556: Inter-band CA 3DL / Impacted TSs and TRs: LTE
- 2557: CD:Thu 12/03/15->Mon 15/12/14; Compl:90%->100%; Stat Rep: RP-141084->RP-141732; Release: Rel-13->Rel-12 / Impacted TSs and TRs: 36.101, 36.104, 36.133, generic TR 36.853 (3 Band CA with 1UL)
- 2558: CD:Thu 12/03/15->Mon 15/12/14; Compl:10%->100%; Stat Rep: RP-141084->RP-141732; Release: Rel-13->Rel-12 / Impacted TSs and TRs: 36.101, 36.133, 36.141, 36.307
- 2559: Inter-band CA 3DL / Impacted TSs and TRs: LTE
- 2560: CD:Thu 12/03/15->Mon 15/12/14; Compl:90%->100%; Stat Rep: RP-141084->RP-141732; Release: Rel-13->Rel-12 / Impacted TSs and TRs: 36.101, 36.104, 36.133, generic TR 36.853 (3 Band CA with 1UL)
- 2561: CD:Thu 12/03/15->Mon 15/12/14; Compl:10%->100%; Stat Rep: RP-141084->RP-141732; Release: Rel-13->Rel-12 / Impacted TSs and TRs: 36.101, 36.133, 36.141, 36.307
- 2562: Inter-band CA 3DL / Impacted TSs and TRs: LTE
- 2563: CD:Thu 12/03/15->Mon 15/12/14; Compl:50%->100%; Stat Rep: RP-141084->RP-141732; Release: Rel-13->Rel-12 / Impacted TSs and TRs: 36.101, 36.104, 36.133, generic TR 36.853 (3 Band CA with 1UL)
- 2564: CD:Thu 12/03/15->Mon 15/12/14; Compl:10%->100%; Stat Rep: RP-141084->RP-141732; Release: Rel-13->Rel-12 / Impacted TSs and TRs: 36.101, 36.133, 36.141, 36.307
- 2565: Inter-band CA 3DL / Impacted TSs and TRs: LTE
- 2566: CD:Thu 12/03/15->Mon 15/12/14; Compl:50%->100%; Stat Rep: RP-141084->RP-141732; Release: Rel-13->Rel-12 / Impacted TSs and TRs: 36.101, 36.104, 36.133, generic TR 36.853 (3 Band CA with 1UL)
- 2567: CD:Thu 12/03/15->Mon 15/12/14; Compl:10%->100%; Stat Rep: RP-141084->RP-141732; Release: Rel-13->Rel-12 / Impacted TSs and TRs: 36.101, 36.133, 36.141, 36.307

| ID | WBS | Task | Duration | Start | Finish | Complete | Baseline start | Baseline finish | Baseline duration | Constraint | Resources | Work | Actual work | Acronym | PCG approved | WI rapporteur name | WI rapporteur e-mail | Release | TSG approved | MCC resp | Special Focus Doc | Acronym_3GU_Export | Status Report |
| --- | --- | --- | --- | --- | --- | --- | --- | --- | --- | --- | --- | --- | --- | --- | --- | --- | --- | --- | --- | --- | --- | --- | --- |
| 2568 | 625.106 | **LTE Advanced 3 Band Carrier Aggregation (3DL/1UL) of Band 1, Band 3 and Band 26** | 206d? | 2014-03-06 A | 2014-12-15 A | 100% | 2014-03-06 | 2014-12-05 | 197d? |  | R4 | 4896h | 4896h | LTE_CA_B1_B3_B26 | 32 | China Telecom | Zhao Dong (zhaodong@ctbri.com.cn) | Rel-12 | 63 | Issam | CA | LTE_CA_B1_B3_B26 |  |
| 2569 | 625.106.1 | Core part:LTE Advanced 3 Band Carrier Aggregation (3DL/1UL) of Band 1, Band 3 and Band 26 | 203d? | 2014-03-06 A | 2014-12-15 A | 100% | 2014-03-06 | 2014-12-05 | 197d? | finish no earlier than 2014-12-15 | R4 | 1624h | 1624h | LTE_CA_B1_B3_B26-Core | 32 | China Telecom | Zhao Dong (zhaodong@ctbri.com.cn) | Rel-12 | 63 | Issam | CA | LTE_CA_B1_B3_B26-Core | RP-141732 |
| 2570 | 625.106.2 | Perf. part:LTE Advanced 3 Band Carrier Aggregation (3DL/1UL) of Band 1, Band 3 and Band 26 | 203d? | 2014-03-06 A | 2014-12-15 A | 100% | 2014-03-06 | 2014-12-05 | 197d? | finish no earlier than 2014-12-15 | R4 | 1624h | 1624h | LTE_CA_B1_B3_B26-Perf | 32 | China Telecom | Zhao Dong (zhaodong@ctbri.com.cn) | Rel-12 | 63 | Issam | CA | LTE_CA_B1_B3_B26-Perf | RP-141732 |
| 2571 | 625.107 | **LTE Advanced 3 Band Carrier Aggregation (3DL/1UL) of Band 1, Band 18 and Band 28** | 206d? | 2014-03-06 A | 2014-12-15 A | 100% | 2014-03-06 | 2015-03-13 | 267d? |  | R4 | 4896h | 4896h | LTE_CA_B1_B18_B28 | 32 | KDDI | Masaaki Obara (ms-obara@kddi.com) | Rel-12 | 63 | Issam | CA | LTE_CA_B1_B18_B28 |  |
| 2572 | 625.107.1 | Core part:LTE Advanced 3 Band Carrier Aggregation (3DL/1UL) of Band 1, Band 18 and Band 28 | 203d? | 2014-03-06 A | 2014-12-15 A | 100% | 2014-03-06 | 2015-03-13 | 267d? | finish no earlier than 2014-12-15 | R4 | 1624h | 1624h | LTE_CA_B1_B18_B28-Core | 32 | KDDI | Masaaki Obara (ms-obara@kddi.com) | Rel-12 | 63 | Issam | CA | LTE_CA_B1_B18_B28-Core | RP-141732 |
| 2573 | 625.107.2 | Perf. part:LTE Advanced 3 Band Carrier Aggregation (3DL/1UL) of Band 1, Band 18 and Band 28 | 203d? | 2014-03-11 A | 2014-12-15 A | 100% | 2014-03-06 | 2015-03-13 | 267d? | finish no earlier than 2014-12-15 | R4 | 1624h | 1624h | LTE_CA_B1_B18_B28-Perf | 32 | KDDI | Masaaki Obara (ms-obara@kddi.com) | Rel-12 | 63 | Issam | CA | LTE_CA_B1_B18_B28-Perf | RP-141732 |
| 2574 | 625.108 | **LTE Advanced 3 Band Carrier Aggregation (3DL/1UL) of Band 4, Band 7 and Band 12** | 132d? | 2014-06-18 A | 2014-12-15 A | 100% | 2014-06-13 | 2015-03-13 | 196d? |  | R4 | 3168h | 3168h | LTE_CA_B4_B7_B12 | 33 | Rogers Wireless | pavlo.nebesny@rci.rogers.com | Rel-12 | 64 |  | CA | LTE_CA_B4_B7_B12 |  |
| 2575 | 625.108.1 | Core part:LTE Advanced 3 Band Carrier Aggregation (3DL/1UL) of Band 4, Band 7 and Band 12 | 132d? | 2014-06-18 A | 2014-12-15 A | 100% | 2014-06-13 | 2015-03-13 | 196d? | finish no earlier than 2014-12-15 | R4 | 1056h | 1056h | LTE_CA_B4_B7_B12-Core | 33 | Rogers Wireless | pavlo.nebesny@rci.rogers.com | Rel-12 | 64 |  | CA | LTE_CA_B4_B7_B12-Core | RP-141732 |
| 2576 | 625.108.2 | Perf. Part:LTE Advanced 3 Band Carrier Aggregation (3DL/1UL) of Band 4, Band 7 and Band 12 | 132d? | 2014-06-18 A | 2014-12-15 A | 100% | 2014-06-13 | 2015-03-13 | 196d? | finish no earlier than 2014-12-15 | R4 | 1056h | 1056h | LTE_CA_B4_B7_B12-Perf | 33 | Rogers Wireless | pavlo.nebesny@rci.rogers.com | Rel-12 | 64 |  | CA | LTE_CA_B4_B7_B12-Perf | RP-141732 |
| 2577 | 625.109 | **LTE Advanced 3 Band Carrier Aggregation (3DL/1UL) of Band 4, Band 4 and Band 7** | 132d? | 2014-06-18 A | 2014-12-15 A | 100% | 2014-06-13 | 2015-03-13 | 196d? |  | R4 | 3168h | 3168h | LTE_CA_B4_B4_B7 | 33 | Rogers Wireless | pavlo.nebesny@rci.rogers.com | Rel-12 | 64 |  | CA | LTE_CA_B4_B4_B7 |  |
| 2578 | 625.109.1 | Core part:LTE Advanced 3 Band Carrier Aggregation (3DL/1UL) of Band 4, Band 4 and Band 7 | 132d? | 2014-06-18 A | 2014-12-15 A | 100% | 2014-06-13 | 2015-03-13 | 196d? | finish no earlier than 2014-12-15 | R4 | 1056h | 1056h | LTE_CA_B4_B4_B7-Core | 33 | Rogers Wireless | pavlo.nebesny@rci.rogers.com | Rel-12 | 64 |  | CA | LTE_CA_B4_B4_B7-Core | RP-141732 |
| 2579 | 625.109.2 | Perf. Part:LTE Advanced 3 Band Carrier Aggregation (3DL/1UL) of Band 4, Band 4 and Band 7 | 132d? | 2014-06-18 A | 2014-12-15 A | 100% | 2014-06-13 | 2015-03-13 | 196d? | finish no earlier than 2014-12-15 | R4 | 1056h | 1056h | LTE_CA_B4_B4_B7-Perf | 33 | Rogers Wireless | pavlo.nebesny@rci.rogers.com | Rel-12 | 64 |  | CA | LTE_CA_B4_B4_B7-Perf | RP-141732 |
| 2580 | 625.110 | **LTE Advanced 3 Band Carrier Aggregation (3DL/1UL) of Band 39, Band 41 and Band 41** | 134d? | 2014-06-16 A | 2014-12-15 A | 100% | 2014-06-13 | 2014-12-05 | 126d? |  | R4 | 3184h | 3184h | LTE_CA_B39_B41_B41 | 33 | China Mobile | PAN Qun (panqun@chinamobile.com) | Rel-12 | 64 |  | CA | LTE_CA_B39_B41_B41 |  |
| 2581 | 625.110.1 | Core part:LTE Advanced 3 Band Carrier Aggregation (3DL/1UL) of Band 39, Band 41 and Band 41 | 132d? | 2014-06-16 A | 2014-12-15 A | 100% | 2014-06-13 | 2014-12-05 | 126d? | finish no earlier than 2014-12-15 | R4 | 1056h | 1056h | LTE_CA_B39_B41_B41-Core | 33 | China Mobile | PAN Qun (panqun@chinamobile.com) | Rel-12 | 64 |  | CA | LTE_CA_B39_B41_B41-Core | RP-141732 |
| 2582 | 625.110.2 | Perf. Part:LTE Advanced 3 Band Carrier Aggregation (3DL/1UL) of Band 39, Band 41 and Band 41 | 132d? | 2014-06-18 A | 2014-12-15 A | 100% | 2014-06-13 | 2014-12-05 | 126d? | finish no earlier than 2014-12-15 | R4 | 1056h | 1056h | LTE_CA_B39_B41_B41-Perf | 33 | China Mobile | PAN Qun (panqun@chinamobile.com) | Rel-12 | 64 |  | CA | LTE_CA_B39_B41_B41-Perf | RP-141732 |
| 2583 | 625.111 | **LTE Advanced 3 Band Carrier Aggregation (3DL/1UL) of Band 1, Band 41 and Band 41** | 132d? | 2014-06-18 A | 2014-12-15 A | 100% | 2014-06-13 | 2015-03-13 | 196d? |  | R4 | 3168h | 3168h | LTE_CA_B1_B41_B41 | 33 | KDDI | Masaaki Obara (ms-obara@kddi.com) | Rel-12 | 64 |  | CA | LTE_CA_B1_B41_B41 |  |
| 2584 | 625.111.1 | Core part:LTE Advanced 3 Band Carrier Aggregation (3DL/1UL) of Band 1, Band 41 and Band 41 | 132d? | 2014-06-18 A | 2014-12-15 A | 100% | 2014-06-13 | 2015-03-13 | 196d? | finish no earlier than 2014-12-15 | R4 | 1056h | 1056h | LTE_CA_B1_B41_B41-Core | 33 | KDDI | Masaaki Obara (ms-obara@kddi.com) | Rel-12 | 64 |  | CA | LTE_CA_B1_B41_B41-Core | RP-141732 |
| 2585 | 625.111.2 | Perf. Part:LTE Advanced 3 Band Carrier Aggregation (3DL/1UL) of Band 1, Band 41 and Band 41 | 132d? | 2014-06-18 A | 2014-12-15 A | 100% | 2014-06-13 | 2015-03-13 | 196d? | finish no earlier than 2014-12-15 | R4 | 1056h | 1056h | LTE_CA_B1_B41_B41-Perf | 33 | KDDI | Masaaki Obara (ms-obara@kddi.com) | Rel-12 | 64 |  | CA | LTE_CA_B1_B41_B41-Perf | RP-141732 |
| 2586 | 625.112 | **LTE Advanced 3 Band Carrier Aggregation (3DL/1UL) of Band 26, Band 41 and Band 41** | 132d? | 2014-06-18 A | 2014-12-15 A | 100% | 2014-06-13 | 2015-03-13 | 196d? |  | R4 | 3168h | 3168h | LTE_CA_B26_B41_B41 | 33 | KDDI | Masaaki Obara (ms-obara@kddi.com) | Rel-12 | 64 |  | CA | LTE_CA_B26_B41_B41 |  |
| 2587 | 625.112.1 | Core part:LTE Advanced 3 Band Carrier Aggregation (3DL/1UL) of Band 26, Band 41 and Band 41 | 132d? | 2014-06-18 A | 2014-12-15 A | 100% | 2014-06-13 | 2015-03-13 | 196d? | finish no earlier than 2014-12-15 | R4 | 1056h | 1056h | LTE_CA_B26_B41_B41-Core | 33 | KDDI | Masaaki Obara (ms-obara@kddi.com) | Rel-12 | 64 |  | CA | LTE_CA_B26_B41_B41-Core | RP-141732 |
| 2588 | 625.112.2 | Perf. Part:LTE Advanced 3 Band Carrier Aggregation (3DL/1UL) of Band 26, Band 41 and Band 41 | 132d? | 2014-06-18 A | 2014-12-15 A | 100% | 2014-06-13 | 2015-03-13 | 196d? | finish no earlier than 2014-12-15 | R4 | 1056h | 1056h | LTE_CA_B26_B41_B41-Perf | 33 | KDDI | Masaaki Obara (ms-obara@kddi.com) | Rel-12 | 64 |  | CA | LTE_CA_B26_B41_B41-Perf | RP-141732 |
| 2589 | 625.113 | **LTE Advanced 3 Band Carrier Aggregation (3DL/1UL) of Band 25, Band 41 and Band 41** | 68d? | 2014-09-15 A | 2014-12-15 A | 100% | 2014-06-13 | 2015-03-13 | 196d? |  | R4 | 1632h | 1632h | LTE_CA_B25_B41_B41 | 33 | Alcatel-Lucent | Ng, Man Hung (man-hung.ng@alcatel-lucent.com) | Rel-12 | 65 |  | CA | LTE_CA_B25_B41_B41 |  |
| 2590 | 625.113.1 | Core part:LTE Advanced 3 Band Carrier Aggregation (3DL/1UL) of Band 25, Band 41 and Band 41 | 68d? | 2014-09-15 A | 2014-12-15 A | 100% | 2014-06-13 | 2015-03-13 | 196d? | finish no earlier than 2014-12-15 | R4 | 544h | 544h | LTE_CA_B25_B41_B41-Core | 33 | Alcatel-Lucent | Ng, Man Hung (man-hung.ng@alcatel-lucent.com) | Rel-12 | 65 |  | CA | LTE_CA_B25_B41_B41-Core | RP-141732 |
| 2591 | 625.113.2 | Perf. Part:LTE Advanced 3 Band Carrier Aggregation (3DL/1UL) of Band 25, Band 41 and Band 41 | 68d? | 2014-09-15 A | 2014-12-15 A | 100% | 2014-06-13 | 2015-03-13 | 196d? | finish no earlier than 2014-12-15 | R4 | 544h | 544h | LTE_CA_B25_B41_B41-Perf | 33 | Alcatel-Lucent | Ng, Man Hung (man-hung.ng@alcatel-lucent.com) | Rel-12 | 65 |  | CA | LTE_CA_B25_B41_B41-Perf | RP-141732 |

Notes:
- 2568: Inter-band CA 3DL / Impacted TSs and TRs: LTE
- 2569: CD:Thu 11/12/14->Mon 15/12/14; Compl:90%->100%; Stat Rep: RP-141084->RP-141732; Release: Rel-13->Rel-12 / Impacted TSs and TRs: 36.101, 36.104, 36.133, generic TR 36.853 (3 Band CA with 1UL)
- 2570: CD:Thu 11/12/14->Mon 15/12/14; Compl:90%->100%; Stat Rep: RP-141084->RP-141732; Release: Rel-13->Rel-12 / Impacted TSs and TRs: 36.141, 36.307
- 2571: Inter-band CA 3DL / Impacted TSs and TRs: LTE
- 2572: ; WID: RP-142043->RP-141788; Stat Rep: RP-141084->RP-141732; Release: Rel-13->Rel-12 / Impacted TSs and TRs: 36.101, 36.104, 36.133, generic TR 36.853 (3 Band CA with 1UL)
- 2573: ; WID: RP-142043->RP-141788; Stat Rep: RP-141084->RP-141732; Release: Rel-13->Rel-12 / Impacted TSs and TRs: 36.141, 36.307
- 2574: Inter-band CA 3DL/1UL / Impacted TSs and TRs: LTE
- 2575: CD:Thu 12/03/15->Mon 15/12/14; Compl:0%->100%; Stat Rep: RP-141084->RP-141732; Release: Rel-13->Rel-12 / Impacted TSs and TRs: 36.101, 36.104, 36.133, 36.307, generic TR 36.851 (2 Band CA with 1UL), generic TR 36.853 (3 Band CA with 1UL)
- 2576: CD:Thu 12/03/15->Mon 15/12/14; Compl:0%->100%; Stat Rep: RP-141084->RP-141732; Release: Rel-13->Rel-12 / Impacted TSs and TRs: 36.133, 36.141
- 2577: Inter-band CA 3DL/1UL / Impacted TSs and TRs: LTE
- 2578: CD:Thu 12/03/15->Mon 15/12/14; Compl:0%->100%; Stat Rep: RP-141084->RP-141732; Release: Rel-13->Rel-12 / Impacted TSs and TRs: 36.101, 36.104, 36.133, 36.307, generic TR 36.853 (3 Band CA with 1UL)
- 2579: CD:Thu 12/03/15->Mon 15/12/14; Compl:0%->100%; Stat Rep: RP-141084->RP-141732; Release: Rel-13->Rel-12 / Impacted TSs and TRs: 36.133, 36.141
- 2580: Inter-band CA 3DL/1UL / Impacted TSs and TRs: LTE
- 2581: ; WID: RP-140708->RP-142301; Stat Rep: RP-141084->RP-141732; Release: Rel-13->Rel-12 / Impacted TSs and TRs: 36.101, 36.104, 36.133, generic TR 36.853 (3 Band CA with 1UL)
- 2582: ; WID: RP-140708->RP-142301; Stat Rep: RP-141084->RP-141732; Release: Rel-13->Rel-12 / Impacted TSs and TRs: 36.141, 36.307
- 2583: Inter-band CA 3DL/1UL / Impacted TSs and TRs: LTE
- 2584: ; WID: RP-142043->RP-142297; Stat Rep: RP-141084->RP-141732; Release: Rel-13->Rel-12 / Impacted TSs and TRs: 36.101, 36.104, 36.133, generic TR 36.853 (3 Band CA with 1UL)
- 2585: Compl:100%->0%; WID: RP-142043->RP-142297; Stat Rep: RP-141084->RP-141732; Release: Rel-13->Rel-12 / Impacted TSs and TRs: 36.141, 36.307
- 2586: Inter-band CA 3DL/1UL / Impacted TSs and TRs: LTE
- 2587: ; WID: RP-142043->RP-142298; Stat Rep: RP-141084->RP-141732; Release: Rel-13->Rel-12 / Impacted TSs and TRs: 36.101, 36.104, 36.133, generic TR 36.853 (3 Band CA with 1UL)
- 2588: Compl:100%->0%; WID: RP-142043->RP-142298; Stat Rep: RP-141084->RP-141732; Release: Rel-13->Rel-12 / Impacted TSs and TRs: 36.141, 36.307
- 2589: Inter-band CA 3DL/1UL / Impacted TSs and TRs: LTE
- 2590: ; WID: RP-142043->RP-142018; Stat Rep: -->RP-141732; Release: Rel-13->Rel-12 / Impacted TSs and TRs: 36.101, 36.104, 36.307, New TR 36.833-x-yz
- 2591: ; WID: RP-142043->RP-142018; Stat Rep: -->RP-141732; Release: Rel-13->Rel-12 / Impacted TSs and TRs: 36.141

| ID | WBS | Task | Duration | Start | Finish | Complete | Baseline start | Baseline finish | Baseline duration | Constraint | Resources | Work | Actual work | Acronym | PCG approved | WI rapporteur name | WI rapporteur e-mail | Release | TSG approved | Special Focus Doc | Acronym_3GU_Export | Status Report | MCC resp | PCG stopped | TSG stopped |
| --- | --- | --- | --- | --- | --- | --- | --- | --- | --- | --- | --- | --- | --- | --- | --- | --- | --- | --- | --- | --- | --- | --- | --- | --- | --- |
| 2592 | 625.114 | **LTE Advanced 3 Band Carrier Aggregation (3DL/1UL) of Band 39, Band 39 and Band 41** | 68d? | 2014-09-15 A | 2014-12-15 A | 100% | 2014-06-13 | 2015-03-13 | 196d? |  | R4 | 1632h | 1632h | LTE_CA_B39_B39_B41 | 33 | China Mobile | PAN, Qun (panqun@chinamobile.com) | Rel-12 | 65 | CA | LTE_CA_B39_B39_B41 |  |  |  |  |
| 2593 | 625.114.1 | Core part:LTE Advanced 3 Band Carrier Aggregation (3DL/1UL) of Band 39, Band 39 and Band 41 | 68d? | 2014-09-15 A | 2014-12-15 A | 100% | 2014-06-13 | 2015-03-13 | 196d? | finish no earlier than 2014-12-15 | R4 | 544h | 544h | LTE_CA_B39_B39_B41-Core | 33 | China Mobile | PAN, Qun (panqun@chinamobile.com) | Rel-12 | 65 | CA | LTE_CA_B39_B39_B41-Core | RP-141732 |  |  |  |
| 2594 | 625.114.2 | Perf. Part:LTE Advanced 3 Band Carrier Aggregation (3DL/1UL) of Band 39, Band 39 and Band 41 | 68d? | 2014-09-15 A | 2014-12-15 A | 100% | 2014-06-13 | 2015-03-13 | 196d? | finish no earlier than 2014-12-15 | R4 | 544h | 544h | LTE_CA_B39_B39_B41-Perf | 33 | China Mobile | PAN, Qun (panqun@chinamobile.com) | Rel-12 | 65 | CA | LTE_CA_B39_B39_B41-Perf | RP-141732 |  |  |  |
| 2595 | 625.115 | **LTE Advanced 3 Band Carrier Aggregation (3DL/1UL) of Band 2, Band 2 and Band 29** | 68d? | 2014-09-15 A | 2014-12-15 A | 100% | 2014-06-13 | 2015-03-13 | 196d? |  | R4 | 1632h | 1632h | LTE_CA_B2_B2_B29 | 33 | AT&T | marc.grant@att.com | Rel-12 | 65 | CA | LTE_CA_B2_B2_B29 |  |  |  |  |
| 2596 | 625.115.1 | Core part:LTE Advanced 3 Band Carrier Aggregation (3DL/1UL) of Band 2, Band 2 and Band 29 | 68d? | 2014-09-15 A | 2014-12-15 A | 100% | 2014-06-13 | 2015-03-13 | 196d? | finish no earlier than 2014-12-15 | R4 | 544h | 544h | LTE_CA_B2_B2_B29-Core | 33 | AT&T | marc.grant@att.com | Rel-12 | 65 | CA | LTE_CA_B2_B2_B29-Core | RP-141732 |  |  |  |
| 2597 | 625.115.2 | Perf. Part:LTE Advanced 3 Band Carrier Aggregation (3DL/1UL) of Band 2, Band 2 and Band 29 | 68d? | 2014-09-15 A | 2014-12-15 A | 100% | 2014-06-13 | 2015-03-13 | 196d? | finish no earlier than 2014-12-15 | R4 | 544h | 544h | LTE_CA_B2_B2_B29-Perf | 33 | AT&T | marc.grant@att.com | Rel-12 | 65 | CA | LTE_CA_B2_B2_B29-Perf | RP-141732 |  |  |  |
| 2598 | 625.116 | **LTE Advanced 3 Band Carrier Aggregation (3DL/1UL) of Band 2, Band 4 and Band 29** | 68d? | 2014-09-15 A | 2014-12-15 A | 100% | 2014-06-13 | 2015-03-13 | 196d? |  | R4 | 1632h | 1632h | LTE_CA_B2_B4_B29 | 33 | Huawei | SHAN Huiping (shanhuiping@huawei.com) | Rel-12 | 65 | CA | LTE_CA_B2_B4_B29 |  |  |  |  |
| 2599 | 625.116.1 | Core part:LTE Advanced 3 Band Carrier Aggregation (3DL/1UL) of Band 2, Band 4 and Band 29 | 68d? | 2014-09-15 A | 2014-12-15 A | 100% | 2014-06-13 | 2015-03-13 | 196d? | finish no earlier than 2014-12-15 | R4 | 544h | 544h | LTE_CA_B2_B4_B29-Core | 33 | Huawei | SHAN Huiping (shanhuiping@huawei.com) | Rel-12 | 65 | CA | LTE_CA_B2_B4_B29-Core | RP-141732 |  |  |  |
| 2600 | 625.116.2 | Perf. Part:LTE Advanced 3 Band Carrier Aggregation (3DL/1UL) of Band 2, Band 4 and Band 29 | 68d? | 2014-09-15 A | 2014-12-15 A | 100% | 2014-06-13 | 2015-03-13 | 196d? | finish no earlier than 2014-12-15 | R4 | 544h | 544h | LTE_CA_B2_B4_B29-Perf | 33 | Huawei | SHAN Huiping (shanhuiping@huawei.com) | Rel-12 | 65 | CA | LTE_CA_B2_B4_B29-Perf | RP-141732 |  |  |  |
| 2601 | 626 | UE Conformance Test Aspects – Further Rel-12 configurations for LTE Advanced Carrier Aggregation | 393d? | 2013-09-15 A | 2015-03-15 A | 100% | 2013-09-09 | 2014-12-05 | 327d? | finish no earlier than 2015-03-15 | R5 | 3144h | 3144h | LTE_CA_Rel12-UEConTest | 31 | Microsoft | jussi.kuusisto@microsoft.com | Rel-12 | 61 | CA | LTE_CA_Rel12-UEConTest | RP-150076 | Ingbert |  |  |
| 2602 | 627 | UE Conformance Test Aspects – Further Rel-12 configurations for LTE Advanced Carrier Aggregation with 3DL | 394d? | 2014-09-15 A | 2016-03-15 A | 100% |  |  |  | finish no earlier than 2016-03-15 | R5 | 3152h | 3152h | LTE_CA_Rel12_3DL-UEConTest | 33 | Microsoft | jussi.kuusisto@microsoft.com | Rel-12 | 65 | CA | LTE_CA_Rel12_3DL-UEConTest | RP-151464 |  |  |  |
| 2603 | 628 | **Deleted - Carrier based HetNet ICIC for LTE** | 595d? | 2011-03-18 A | 2013-06-14 A | 100% | 2011-03-18 | 2013-06-14 | 595d? |  | R3; R1; R2 | 28560h | 28560h | LTE_CA_HetNet_ICIC | 26 | Nokia Siemens Networks | krzysztof.kordybach@nsn.com | Rel-12 | 51 |  | LTE_CA_HetNet_ICIC |  | Juha | PCG-31 | RP-60 |
| 2604 | 628.1 | Deleted - Core part: Carrier based HetNet ICIC for LTE | 595d? | 2011-03-18 A | 2013-06-14 A | 100% | 2011-03-18 | 2013-06-14 | 595d? | finish no earlier than 2013-06-14 | R3; R1; R2 | 14280h | 14280h | LTE_CA_HetNet_ICIC-Core | 26 | Nokia Siemens Networks | krzysztof.kordybach@nsn.com | Rel-12 | 51 |  | LTE_CA_HetNet_ICIC-Core | RP-130500 | Juha | PCG-31 | RP-60 |
| 2605 | 629 | **LTE in the US Wireless Communications Service (WCS) Band 30** | 600d? | 2012-09-12 A | 2014-12-15 A | 100% | 2012-09-12 | 2014-12-05 | 591d? |  | R4; R2; R5 | 20312h | 20312h | LTE_WCS_band | 29 | AT&T | marc.grant@att.com | Rel-12 | 57 |  | LTE_WCS_band |  | Issam |  |  |
| 2606 | 629.1 | Core part: LTE in the US Wireless Communications Service (WCS) Band 30 | 202d? | 2012-09-12 A | 2013-06-14 A | 100% | 2012-09-12 | 2013-06-14 | 202d? | finish no earlier than 2013-06-14 | R4; R2 | 3232h | 3232h | LTE_WCS_band-Core | 29 | AT&T | marc.grant@att.com | Rel-12 | 57 |  | LTE_WCS_band-Core | RP-130569 | Issam |  |  |
| 2607 | 629.2 | Perf. Part: LTE in the US Wireless Communications Service (WCS) Band 30 | 201d? | 2012-09-13 A | 2013-06-14 A | 100% | 2012-09-13 | 2013-06-14 | 201d? | finish no earlier than 2013-06-14 | R4 | 1608h | 1608h | LTE_WCS_band-Perf | 29 | AT&T | marc.grant@att.com | Rel-12 | 57 |  | LTE_WCS_band-Perf | RP-130570 | Issam |  |  |
| 2608 | 629.3 | Test Part: LTE in the US Wireless Communications Service (WCS) Band 30 | 134d? | 2014-06-15 A | 2014-12-15 A | 100% | 2014-06-13 | 2014-12-05 | 126d? | finish no earlier than 2014-12-15 | R5 | 1072h | 1072h | LTE_WCS_band-UEConTest | 33 | Ericsson | fredrik.sundstrom@ericsson.com | Rel-12 | 64 |  | LTE_WCS_band-UEConTest | RP-141773 |  |  |  |
| 2609 | 630 | **Introduction of LTE 450 MHz band in Brazil** | 331d? | 2012-09-11 A | 2013-12-06 A | 100% | 2012-09-11 | 2013-12-06 | 331d? |  | R4; R5 | 10000h | 10000h | LTE450_Brazil | 29 | Huawei | Liehai Liu (liuliehai@huawei.com) | Rel-12 | 57 |  | LTE450_Brazil |  | Issam |  |  |
| 2610 | 630.1 | Core part: Introduction of LTE 450 MHz band in Brazil | 201d? | 2012-09-11 A | 2013-06-14 A | 100% | 2012-09-11 | 2013-06-14 | 201d? | finish no earlier than 2013-06-14 | R4 | 1608h | 1608h | LTE450_Brazil-Core | 29 | Huawei | Liehai Liu (liuliehai@huawei.com) | Rel-12 | 57 |  | LTE450_Brazil-Core | RP-130567 | Issam |  |  |
| 2611 | 630.2 | Perf. part: Introduction of LTE 450 MHz band in Brazil | 261d? | 2012-09-13 A | 2013-09-06 A | 100% | 2012-09-13 | 2013-09-06 | 261d? | finish no earlier than 2013-09-06 | R4 | 2088h | 2088h | LTE450_Brazil-Perf | 29 | Huawei | Liehai Liu (liuliehai@huawei.com) | Rel-12 | 57 |  | LTE450_Brazil-Perf | RP-131070 | Issam |  |  |
| 2612 | 630.3 | Test part: Introduction of LTE 450 MHz band in Brazil | 126d? | 2013-06-18 A | 2013-12-06 A | 100% | 2013-06-18 | 2013-12-06 | 126d? | finish no earlier than 2013-12-06 | R5 | 1008h | 1008h | LTE450_Brazil-UEConTest | 31 | Huawei | Xiang Li (tricia.li@huawei.com) | Rel-12 | 60 |  | LTE450_Brazil-UEConTest | RP-131457 | Ingbert |  |  |
| 2613 | 631 | **Further Downlink MIMO Enhancement for LTE Advanced** | 927d? | 2012-09-11 A | 2016-03-15 A | 100% | 2012-09-11 | 2014-09-12 | 532d? |  | R1; R4 | 25384.8h | 25384.8h | LTE_eDL_MIMO_enh | 29 | Alcatel-Lucent | Min Zhang (min.hs.zhang@alcatel-lucent.com) | Rel-12 | 57 |  | LTE_eDL_MIMO_enh |  | Patrick |  |  |
| 2614 | 631.1 | Core part: Further Downlink MIMO Enhancement for LTE Advanced | 464d? | 2012-09-11 A | 2014-06-13 A | 100% | 2012-09-11 | 2014-06-13 | 464d? | finish no earlier than 2014-06-13 | R1 | 3696.76h | 3696.76h | LTE_eDL_MIMO_enh-Core | 29 | Alcatel-Lucent | Min Zhang (min.hs.zhang@alcatel-lucent.com) | Rel-12 | 57 |  | LTE_eDL_MIMO_enh-Core | RP-140652 | Patrick |  |  |
| 2615 | 631.2 | Perf. part: Further Downlink MIMO Enhancement for LTE Advanced | 595d? | 2012-09-15 A | 2014-12-15 A | 100% | 2012-09-18 | 2014-09-12 | 526d? | finish no earlier than 2014-12-15 | R4 | 4760h | 4760h | LTE_eDL_MIMO_enh-Perf | 29 | Alcatel-Lucent | ren.da@alcatel-lucent.com | Rel-12 | 57 |  | LTE_eDL_MIMO_enh-Perf | RP-142042 | Issam |  |  |
| 2616 | 631.3 | UE Conformance Test Aspects - Further DL MIMO Enhancement for LTE-Advanced | 262d? | 2015-03-16 A | 2016-03-15 A | 100% |  |  |  | finish no earlier than 2016-03-15 | R5 | 2096h | 2096h | LTE_eDL_MIMO_enh-UEConTest | 34 | ZTE |  | Rel-12 | 67 |  |  | RP-151189 |  |  |  |

Notes:
- 2592: Inter-band CA 3DL/1UL / Impacted TSs and TRs: LTE
- 2593: ; WID: RP-141288->RP-142302; Stat Rep: -->RP-141732; Release: Rel-13->Rel-12 / Impacted TSs and TRs: 36.101, 36.104, 36.133, New TR 36.8xx
- 2594: ; WID: RP-141288->RP-142302; Stat Rep: -->RP-141732; Release: Rel-13->Rel-12 / Impacted TSs and TRs: 36.141, 36.307
- 2595: Inter-band CA 3DL/1UL / Impacted TSs and TRs: LTE
- 2596: CD:Thu 11/12/14->Mon 15/12/14; Compl:0%->100%; Stat Rep: -->RP-141732; Release: Rel-13->Rel-12 / Impacted TSs and TRs: 36.101, 36.104, 36.133, New TR 36.8xx
- 2597: CD:Thu 11/12/14->Mon 15/12/14; Compl:0%->100%; Stat Rep: -->RP-141732; Release: Rel-13->Rel-12 / Impacted TSs and TRs: 36.141, 36.307
- 2598: Inter-band CA 3DL/1UL / Impacted TSs and TRs: LTE
- 2599: CD:Fri 11/12/15->Mon 15/12/14; Compl:0%->100%; Stat Rep: -->RP-141732; Release: Rel-13->Rel-12 / Impacted TSs and TRs: 36.101, 36.104, 36.133, New TR 36.8xx
- 2600: CD:Thu 11/12/14->Mon 15/12/14; Compl:0%->100%; Stat Rep: -->RP-141732; Release: Rel-13->Rel-12 / Impacted TSs and TRs: 36.141, 36.307
- 2601: ; Stat Rep: RP-141444->RP-141774 1st Apr 15: Compl:75%->100% 1st Apr 15: WID: RP-140621->RP-150077 1st Apr 15: Stat Rep: RP-141774->RP-150076 / Impacted TSs and TRs: 36.508, 36.521-1, 36.521-2, 36.521-3, 36.523-1, 36.523-2, 36.523-3, 37.571-1, 37.571-3, 37.571-5
- 2602: ; Stat Rep: -->RP-141775 1st Apr 15: Compl:6%->12% 1st Apr 15: CD:Tue 15/09/15->Tue 15/12/15 1st Apr 15: WID: RP-142231->RP-150079 1st Apr 15: Stat Rep: RP-141775->RP-150078 03/07/15: Compl:12%->35% 03/07/15: WID: RP-150079->RP-150594 03/07/15: Stat Re / Impacted TSs and TRs: 36.508, 36.521-1, 36.521-2, 36.521-3, 36.523-1, 36.523-2, 36.523-3, 37.571-1, 37.571-3, 37.571-5
- 2603: RP#60 stopped. RP#58 on hold til June 2013 / Impacted TSs and TRs: LTE
- 2604: RP#60 stopped at 40% completion. RP#58 on hold til June 2013 / Impacted TSs and TRs: 36.300, 36.413, 36.420, 36.423
- 2605: RP#58 RP-121701 work can start based on FCC Order (FCC-12-130) http://hraunfoss.fcc.gov/edocs_public/attachmatch/FCC-12-130A1.pdf / Impacted TSs and TRs: LTE
- 2606: RP#60 completed. Updated WID RP-121419=>RP-130843 / Impacted TSs and TRs: 36.101, 36.104, 36.113, 36.124, 36.133, 36.307, 36.331, new TR 36.846
- 2607: RP#60 completed. Updated WID RP-121419=>RP-130843 / Impacted TSs and TRs: 36.101, 36.133, 36.141
- 2608: ; Stat Rep: RP-141166->RP-141773 / Impacted TSs and TRs: 36.508, 36.521-1, 36.521-2, 36.521-3, 36.523-2, 36.523-3, 37.571-1
- 2609: - / Impacted TSs and TRs: LTE
- 2610: RP#60 completed. TR 36.840 v100 for 1-step Approval / Impacted TSs and TRs: 36.101, 36.104, 36.113, 36.124, 36.133, 37.104, 37.113, 36.307, new TR 36.840
- 2611: RP#61 completed / Impacted TSs and TRs: 36.133, 36.141, 37.141
- 2612: RP#62 completed / Impacted TSs and TRs: 36.508, 36.521-1, 36.521-2, 36.521-3
- 2613: Stage 3 / Impacted TSs and TRs: LTE
- 2614: RP#64 completed / Impacted TSs and TRs: 36.211, 36.212, 36.213, 36.331
- 2615: ; CD:Fri 12/06/15->Mon 15/06/15; WID: RP-141966->RP-142235; Stat Rep: RP-141378->RP-142042 / Impacted TSs and TRs: 36.101
- 2616: 03/07/15: Compl:0%->10% 03/07/15: Stat Rep: ->RP-150606 29/09/15: Compl:10%->70% 29/09/15: Stat Rep: RP-150606->RP-1511891/1/16: Compl:70%->75%

| ID | WBS | Task | Duration | Start | Finish | Complete | Remaining | Baseline start | Baseline finish | Baseline duration | Total slack | Constraint | Resources | Work | Actual work | Acronym | PCG approved | WI rapporteur name | Release | TSG approved | MCC resp | PCG stopped | TSG stopped | Acronym_3GU_Export | Status Report | Special Focus Doc |
| --- | --- | --- | --- | --- | --- | --- | --- | --- | --- | --- | --- | --- | --- | --- | --- | --- | --- | --- | --- | --- | --- | --- | --- | --- | --- | --- |
| 2617 | 632 | **Deleted - New Carrier Type for LTE** | 265d? | 2012-09-11 A | 2013-09-06 A | 100% |  | 2012-09-11 | 2013-09-06 | 265d? |  |  | R1; R2; R4 | 14808h | 14808h | LTE_NCT | 29 | Ericsson | Rel-12 | 57 | Patrick | PCG-31 | RP-61 | LTE_NCT |  |  |
| 2618 | 632.1 | Deleted - Core part: New Carrier Type for LTE | 265d? | 2012-09-11 A | 2013-09-06 A | 100% |  | 2012-09-11 | 2013-09-06 | 265d? |  | finish no earlier than 2013-09-06 | R1; R2; R4 | 6360h | 6360h | LTE_NCT-Core | 29 | Ericsson | Rel-12 | 57 | Patrick | PCG-31 | RP-61 | LTE_NCT-Core | RP-130984 |  |
| 2619 | 632.2 | Deleted - Perf. part: New Carrier Type for LTE | 261d? | 2012-09-17 A | 2013-09-06 A | 100% |  | 2012-09-17 | 2013-09-06 | 261d? |  | finish no earlier than 2013-09-06 | R4 | 2088h | 2088h | LTE_NCT-Perf | 29 | Ericsson | Rel-12 | 57 | Issam | PCG-31 | RP-61 | LTE_NCT-Perf | RP-130985 |  |
| 2620 | 633 | **Further Enhancements to LTE TDD for DL-UL Interference Management and Traffic Adaptation** | 1385d? | 2012-12-07 A | 2018-03-15 | 95% | 64.53d? | 2012-12-07 | 2014-12-05 | 527d? | 4627d |  | R1; R2; R3; R4 | 56138.6h | 15302.1h | LTE_TDD_eIMTA | 30 | CATT | Rel-12 | 58 | Patrick |  |  | LTE_TDD_eIMTA |  | Small cell |
| 2621 | 633.1 | Core part: Further Enhancements to LTE TDD for DL-UL Interference Management and Traffic Adaptation | 24.58d? | 2012-12-07 A | 2014-06-13 A | 100% |  | 2012-12-07 | 2014-06-13 | 24.58d? |  | finish no earlier than 2014-06-13 | R1; R2; R3; R4 | 786.56h | 786.56h | LTE_TDD_eIMTA-Core | 30 | CATT | Rel-12 | 58 | Patrick |  |  | LTE_TDD_eIMTA-Core | RP-140724 | Small cell |
| 2622 | 633.2 | Perf. part: Further Enhancements to LTE TDD for DL-UL Interference Management and Traffic Adaptation | 725d? | 2012-12-15 A | 2015-09-15 A | 100% |  | 2012-12-07 | 2014-12-05 | 527d? |  | finish no earlier than 2015-09-15 | R4 | 5800h | 5800h | LTE_TDD_eIMTA-Perf | 30 | CATT | Rel-12 | 58 | Patrick |  |  | LTE_TDD_eIMTA-Perf | RP-151447 | Small cell |
| 2623 | 633.3 | UE Conformance Test Aspects - Further Enhancements to LTE TDD for DL-UL Interference Management and Traffic Adaptation | 654d? | 2015-09-15 A | 2018-03-15 | 90% | 65.4d? |  |  |  | 4627d | finish no earlier than 2018-03-15 | R5 | 5232h | 4708.8h | LTE_TDD_eIMTA-UEConTest | 35 | CATT | Rel-12 | 69 |  |  |  |  |  |  |
| 2624 | 634 | **HetNet Mobility enhancements for LTE** | 641.65d? | 2012-04-13 A | 2014-09-12 A | 100% |  | 2012-04-13 | 2014-09-12 | 640.65d? |  |  | R2; R4 | 11624h | 11624h | HetNet_eMOB_LTE | 30 | Alcatel-Lucent | Rel-12 | 58 | Yong-Jun |  |  | HetNet_eMOB_LTE |  |  |
| 2625 | 634.1 | Core part: HetNet Mobility enhancements for LTE | 263.5d? | 2012-04-13 A | 2014-09-12 A | 100% |  | 2012-04-13 | 2014-09-12 | 263.5d? |  | finish no earlier than 2014-09-12 | R2; R4 | 4216h | 4216h | HetNet_eMOB_LTE-Core | 30 | Alcatel-Lucent | Rel-12 | 58 | Yong-Jun |  |  | HetNet_eMOB_LTE-Core | RP-141413 |  |
| 2626 | 635 | **Further enhancements for HeNB mobility-X2-GW** | 401d? | 2012-12-10 A | 2014-06-13 A | 100% |  | 2012-12-10 | 2014-06-13 | 401d? |  |  | R3 | 6408h | 6408h | EHNB_enh2_X2GW | 30 | Alcatel-Lucent | Rel-12 | 58 | Juha |  |  | EHNB_enh2_X2GW |  | HNB |
| 2627 | 635.1 | Core part: Further enhancements for HeNB mobility-X2-GW | 400d? | 2012-12-10 A | 2014-06-13 A | 100% |  | 2012-12-10 | 2014-06-13 | 400d? |  | finish no earlier than 2014-06-13 | R3 | 3200h | 3200h | EHNB_enh2_X2GW-Core | 30 | Alcatel-Lucent | Rel-12 | 58 | Juha |  |  | EHNB_enh2_X2GW-Core | RP-140592 | HNB |
| 2628 | 636 | **8 Rx Antennas for LTE UL** | 265d? | 2012-12-10 A | 2013-12-06 A | 100% |  | 2012-12-10 | 2013-12-06 | 265d? |  |  | R4 | 4208h | 4208h | LTE_UL_8Rx | 30 | China Telecom | Rel-12 | 58 | Issam |  |  | LTE_UL_8Rx |  |  |
| 2629 | 636.1 | Perf. part: 8 Rx Antennas for LTE UL | 261d? | 2012-12-10 A | 2013-12-06 A | 100% |  | 2012-12-10 | 2013-12-06 | 261d? |  | finish no earlier than 2013-12-06 | R4 | 2088h | 2088h | LTE_UL_8Rx-Perf | 30 | China Telecom | Rel-12 | 58 | Issam |  |  | LTE_UL_8Rx-Perf | RP-131523 |  |
| 2630 | 637 | **LTE TDD-FDD joint operation including Carrier Aggregation** | 444.03d? | 2013-04-12 A | 2014-12-15 A | 100% |  | 2013-04-12 | 2014-12-05 | 435.03d? |  |  | R1; R2; R4 | 14776h | 14776h | LTE_CA_TDD_FDD | 31 | Nokia | Rel-12 | 60 | Patrick |  |  | LTE_CA_TDD_FDD |  |  |
| 2631 | 637.1 | Core part: LTE TDD-FDD joint operation including Carrier Aggregation | 87.33d? | 2013-04-12 A | 2014-06-13 A | 100% |  | 2013-04-12 | 2014-06-13 | 87.33d? |  | finish no earlier than 2014-06-13 | R1; R2; R4 | 2096h | 2096h | LTE_CA_TDD_FDD-Core | 31 | Nokia, China Mobile (for TR) | Rel-12 | 60 | Patrick |  |  | LTE_CA_TDD_FDD-Core | RP-140982 |  |
| 2632 | 637.2 | Perf. part: LTE TDD-FDD joint operation including Carrier Aggregation | 397d? | 2013-06-15 A | 2014-12-15 A | 100% |  | 2013-06-20 | 2014-12-05 | 386d? |  | finish no earlier than 2014-12-15 | R4 | 3176h | 3176h | LTE_CA_TDD_FDD-Perf | 31 | Nokia | Rel-12 | 60 | Issam |  |  | LTE_CA_TDD_FDD-Perf | RP-141972 |  |
| 2633 | 638 | **LTE Coverage Enhancements** | 604.17d? | 2013-03-01 A | 2015-06-15 | 100% | 0d? | 2013-03-01 | 2014-12-05 | 465.17d? | 0d |  | R1; R2; R4; R5 | 26709.4h | 21348.1h | Cov_Enh_LTE | 31 | China Telecom | Rel-12 | 60 | Patrick |  |  | Cov_Enh_LTE |  |  |
| 2634 | 638.1 | Core part: LTE Coverage Enhancements | 87d? | 2013-03-01 A | 2014-06-13 A | 100% |  | 2013-03-01 | 2014-06-13 | 87d? |  | finish no earlier than 2014-06-13 | R1; R2; R4 | 2088h | 2088h | Cov_Enh_LTE-Core | 31 | China Telecom | Rel-12 | 60 | Patrick |  |  | Cov_Enh_LTE-Core | RP-140683 |  |
| 2635 | 638.2 | Perf. part: LTE Coverage Enhancements | 397d? | 2013-06-15 A | 2014-12-15 A | 100% |  | 2013-06-20 | 2014-12-05 | 386d? |  | finish no earlier than 2014-12-15 | R4 | 3176h | 3176h | Cov_Enh_LTE-Perf | 31 | China Telecom | Rel-12 | 60 | Issam |  |  | Cov_Enh_LTE-Perf | RP-141833 |  |
| 2636 | 638.3 | Test part: LTE Coverage Enhancements | 198d? | 2014-09-15 A | 2015-06-15 A | 100% |  |  |  |  |  | finish no earlier than 2015-09-15 | R5 | 1584h | 1584h | Cov_Enh_LTE-UEConTest | 33 | China Telecom | Rel-12 | 65 |  |  |  | Cov_Enh_LTE-UEConTest | RP-150631 |  |
| 2637 | 639 | **Further MBMS operations support for E-UTRAN** | 330d? | 2013-09-15 A | 2014-12-15 A | 100% |  | 2013-12-09 | 2014-09-12 | 201d? |  |  | R2; R1; R3; R4 | 21280h | 21280h | MBMS_LTE_OS | 31 | Verizon | Rel-12 | 61 | Yong-Jun |  |  | MBMS_LTE_OS |  |  |
| 2638 | 639.1 | Core part: Further MBMS operations support for E-UTRAN | 329d? | 2013-09-15 A | 2014-12-15 A | 100% |  | 2014-04-04 | 2014-09-12 | 115.25d? |  | finish no earlier than 2014-12-15 | R2; R1; R3; R4 | 10528h | 10528h | MBMS_LTE_OS-Core | 31 | Verizon | Rel-12 | 61 | Yong-Jun |  |  | MBMS_LTE_OS-Core | RP-141821 |  |
| 2639 | 639.2 | Perf. part: Further MBMS operations support for E-UTRAN | 264d? | 2013-12-15 A | 2014-12-15 A | 100% |  | 2013-12-09 | 2014-09-12 | 201d? |  | finish no earlier than 2014-12-15 | R4 | 2112h | 2112h | MBMS_LTE_OS-Perf | 32 | Verizon | Rel-12 | 62 | Issam |  |  | MBMS_LTE_OS-Perf | RP-141821 |  |
| 2640 | 640 | **Dual connectivity for LTE** | 985d? | 2013-12-15 A | 2017-09-15 | 99% | 0d? | 2013-12-09 | 2014-12-05 | 261d? | 0d |  | R2; R1; R3; R4; S2; C4 | 55728h | 30528h | LTE_SC_enh_dualC | 32 | NTT DOCOMO | Rel-12 | 62 | Yong-Jun |  |  | LTE_SC_enh_dualC |  | Small cell |
| 2641 | 640.1 | Core part: Dual connectivity for LTE | 264d? | 2013-12-15 A | 2014-12-15 A | 100% |  | 2014-04-29 | 2014-09-12 | 99d? |  | finish no earlier than 2014-12-15 | R2; R1; R3; R4 | 8448h | 8448h | LTE_SC_enh_dualC-Core | 32 | NTT DOCOMO, NEC | Rel-12 | 62 | Yong-Jun |  |  | LTE_SC_enh_dualC-Core | RP-141796 | Small cell |
| 2642 | 640.2 | Perf. part: Dual Connectivity for LTE | 395d? | 2013-12-15 A | 2015-06-15 A | 100% |  | 2013-12-09 | 2014-12-05 | 261d? |  | finish no earlier than 2015-06-15 | R4 | 3160h | 3160h | LTE_SC_enh_dualC-Perf | 32 | NTT DOCOMO | Rel-12 | 62 | Issam |  |  | LTE_SC_enh_dualC-Perf | RP-150791 | Small cell |
| 2643 | 640.3 | SA2 part of Dual connectivity for LTE | 131d? | 2014-03-19 A | 2014-09-17 A | 100% |  | 2014-03-19 | 2014-09-17 | 131d? |  | finish no earlier than 2014-09-17 | S2 | 1048h | 1048h | LTE_SC_enh_dualC-S2 | 32 |  | Rel-12 | 63 |  |  |  |  |  | Small cell |
| 2644 | 640.4 | CT aspects of Dual connectivity for LTE | 63d? | 2014-09-12 A | 2014-12-09 A | 100% |  |  |  |  |  | finish no earlier than 2014-12-09 | C4 | 504h | 504h | LTE_SC_enh_dualC-CT | 33 | Huawei | Rel-12 | 65 |  |  |  | LTE_SC_enh_dualC-CT | CP-140487 | Small cell |
| 2645 | 640.5 | UE Conformance Test Aspects - Dual connectivity for LTE | 591d? | 2015-06-15 A | 2017-09-15 A | 100% |  |  |  |  |  | finish no earlier than 2017-09-15 | R5 | 4728h | 4728h | LTE_SC_enh_dualC-UEConTest | 35 | Ericsson | Rel-12 | 68 |  |  |  |  |  |  |

Notes:
- 2617: RP#61 stopped. Continue discussion on use cases and requirements for a NCT in LTE beyond Rel-12. Action: Ericsson to provide at RP#62 a summary of work done so far / Impacted TSs and TRs: LTE / WI rapporteur e-mail: daniel.n.larsson@ericsson.com
- 2618: RP#61 stopped at 20% completion / Impacted TSs and TRs: 36.101, 36.104, 36.133, 36.211, 36.212, 36.213, 36.321, 36.331 / WI rapporteur e-mail: daniel.n.larsson@ericsson.com
- 2619: RP#61 stopped at 0% completion / Impacted TSs and TRs: 36.101, 36.104, 36.133, 36.141 / WI rapporteur e-mail: daniel.n.larsson@ericsson.com
- 2620: Stage 3. Triggered by Rel-11 TR 36.828 Study on Further Enhancements to LTE TDD for DL-UL Interference Management and Traffic Adaptation (FS_LTE_TDD_eIMTA) UID_510039 / Impacted TSs and TRs: LTE / WI rapporteur e-mail: Zukang Shen (shenzukang@catt.cn)
- 2621: RP#64 completed / Impacted TSs and TRs: 36.101, 36.104, 36.133, 36.211, 36.212, 36.213, 36.214, 36.300, 36.321, 36.331, 36.413, 36.423 / WI rapporteur e-mail: Zukang Shen (shenzukang@catt.cn)
- 2622: ; CD:Thu 18/06/15->Mon 15/06/15; WID: RP-141966->RP-142235; Stat Rep: RP-141342->RP-141948 1st Apr 15: Compl:30%->55% 1st Apr 15: Stat Rep: RP-141948->RP-150154 03/07/15: Compl:55%->95% 03/07/15: CD:Mon 15/06/15->Tue 15/09/15 03/07/15: Stat Rep: RP-150 / Impacted TSs and TRs: 36.101, 36.104, 36.133, 36.141 / WI rapporteur e-mail: Zukang Shen (shenzukang@catt.cn)
- 2623: tested: REL-12 WI LTE_TDD_eIMTA-Core;1/1/16: Compl:0%->5%; 22/3/16: Compl:5%->15% 21/3/...; 19...; 8...
- 2624: Stage 3. Triggered by Rel-11 TR 36.839 Study on HetNet mobility enhancements for LTE (FS_HetNet_eMOB_LTE) / Impacted TSs and TRs: LTE / WI rapporteur e-mail: sudeep.palat@alcatel-lucent.com
- 2625: SP#65 completed / Impacted TSs and TRs: 36.133, 36.304, 36.331 / WI rapporteur e-mail: sudeep.palat@alcatel-lucent.com
- 2626: Rel-10 H(e)NB Mobility Enhancements adds signalling via horizontal RAN interfaces (Iurh, X2) to support H(e)NB to H(e)NB mobility. Rel-11 TR37.803 triggered WI UID_560014 partly completed in Rel-11; remaining work including solution definition is Rel-12 / Impacted TSs and TRs: LTE / WI rapporteur e-mail: Philippe.Godin@alcatel-lucent.com
- 2627: RP#64 completed / Impacted TSs and TRs: 36.300, 36.413, 36.423 / WI rapporteur e-mail: Philippe.Godin@alcatel-lucent.com
- 2628: WI has perf. part only (as change from 4Rx to 8Rx has no Core spec impact) / Impacted TSs and TRs: LTE / WI rapporteur e-mail: Shan Yang (yangshan@ctbri.com.cn)
- 2629: RP#62 completed / Impacted TSs and TRs: 36.104, 36.141 / WI rapporteur e-mail: Shan Yang (yangshan@ctbri.com.cn)
- 2630: - / Impacted TSs and TRs: LTE / WI rapporteur e-mail: lars.e.lindh@nokia.com
- 2631: RP#64 completed / Impacted TSs and TRs: 36.101, 36.104, 36.133, 36.201, 36.211, 36.212, 36.213, 36.300, 36.302, 36.306, 36.331, new TR 36.847 / WI rapporteur e-mail: lars.e.lindh@nokia.com, Xiaodong Shen (shenxiaodong@chinamobile.com)
- 2632: ; CD:Thu 18/06/15->Mon 15/06/15; WID: RP-130848->RP-140522; Stat Rep: RP-141374->RP-141972 / Impacted TSs and TRs: 36.101, 36.104, 36.133 / WI rapporteur e-mail: lars.e.lindh@nokia.com
- 2633: Triggered by Rel-11 TR 36.824 (FS_Cov_Enh_LTE) / Impacted TSs and TRs: LTE / WI rapporteur e-mail: Xiaoming She (shexm@ctbri.com.cn)
- 2634: RP#64 completed / Impacted TSs and TRs: 36.101, 36.104, 36.133, 36.211, 36.212, 36.213, 36.300, 36.321, 36.331 / WI rapporteur e-mail: Xiaoming She (shexm@ctbri.com.cn)
- 2635: ; CD:Thu 18/06/15->Mon 15/06/15; WID: RP-141966->RP-142235; Stat Rep: RP-141149->RP-141833 / Impacted TSs and TRs: 36.101, 36.104, 36.133, 36.141 / WI rapporteur e-mail: Xiaoming She (shexm@ctbri.com.cn)
- 2636: ; Stat Rep: -->RP-141834 03/07/15: Compl:5%->100% 03/07/15: CD:Tue 15/09/15->Mon 15/06/15 03/07/15: Stat Rep: RP-141834->RP-150631 / Impacted TSs and TRs: 36.508, 36.523-1, 36.523-2, 36.523-3 / WI rapporteur e-mail: YANG Shan (yangshan@ctbri.com.cn)
- 2637: Solutions for Minimization of Drive Tests (MDT), in order to reduce the need for manual drive testing for MBMS. / Impacted TSs and TRs: LTE / WI rapporteur e-mail: yeesin.chan@verizonwireless.com
- 2638: ; CD:Thu 18/06/15->Mon 15/06/15; WID: RP-130848->RP-140522; Stat Rep: RP-141431->RP-141821 / Impacted TSs and TRs: 36.133, 36.214, 36.300, 36.304, 36.306, 36.331, 36.413, 36.423, 37.320 / WI rapporteur e-mail: yeesin.chan@verizonwireless.com
- 2639: ; CD:Wed 17/12/14->Mon 15/12/14; WID: RP-130848->RP-140522; Stat Rep: RP-141431->RP-141821 / Impacted TSs and TRs: 36.133 / WI rapporteur e-mail: yeesin.chan@verizonwireless.com
- 2640: Triggered by TR 36.842 Study on Small Cell Enhancements for E-UTRA and E-UTRAN Higher-layer aspects (UID_580044) / Impacted TSs and TRs: LTE / WI rapporteur e-mail: tooru.uchino.fv@nttdocomo.com
- 2641: ; CD:Wed 18/03/15->Sun 15/03/15; WID: RP-130848->RP-140522; Stat Rep: RP-141264->RP-141796 / Impacted TSs and TRs: 36.101, 36.104, 36.133, 36.211, 36.212, 36.213, 36.300, 36.302, 36.306, 36.321, 36.322, 36.323, 36.331, 36.410, 36.413, 36.420, 36.423, new RAN3 TS 36.425 / WI rapporteur e-mail: RAN1/2/4 tooru.uchino.fv@nttdocomo.com, RAN3 Chenghock Ng (ngcheng@da.jp.nec.com)
- 2642: ; Stat Rep: RP-141264->RP-141796 1st Apr 15: Compl:15%->45% 1st Apr 15: Stat Rep: RP-141796->RP-150160 03/07/15: Compl:45%->100% 03/07/15: Stat Rep: RP-150160->RP-150791 / Impacted TSs and TRs: 36.101, 36.104, 36.133 / WI rapporteur e-mail: kunihiko.teshima.hg@nttdocomo.com
- 2643: SP#64 Three CRs agreed in SP-140262 (23.251CR0099, 23.401CR2658&CR2707). Dec.14:99->100% / Impacted TSs and TRs: 23.251, 23.401
- 2644: Stage 2/3. CP#65 exception in CP-140487. LM70->100 / Impacted TSs and TRs: 23.007, 23.008, 29.274, 29.281 / WI rapporteur e-mail: Xiaoyan SHI (sean.shixiaoyan@huawei.com)
- 2645: tested Core part: LTE_SC_enh_dualC-Core 29/09/15: Compl:0%->3% 29/09/15: Stat Rep: -->RP-1511671/1/16: Compl:3%->15%1/1/16: CD:Tue 15/03/16->Wed 15/06/16; ...; ...; ;...

| ID | WBS | Task | Duration | Start | Finish | Complete | Remaining | Baseline start | Baseline finish | Baseline duration | Total slack | Constraint | Resources | Work | Actual work | Acronym | PCG approved | WI rapporteur name | WI rapporteur e-mail | Release | TSG approved | MCC resp | Special Focus Doc | Acronym_3GU_Export | Status Report |
| --- | --- | --- | --- | --- | --- | --- | --- | --- | --- | --- | --- | --- | --- | --- | --- | --- | --- | --- | --- | --- | --- | --- | --- | --- | --- |
| 2646 | 641 | **E-UTRA Small cell enhancements - Physical layer aspects** | 919d? | 2013-12-15 A | 2017-06-15 A | 100% |  | 2013-07-19 | 2014-12-05 | 364.75d? |  |  | R1; R2; R4 | 32364.7h | 32364.7h | LTE_SC_enh_L1 | 32 | Huawei | Elean FAN (fanxiaoan@huawei.com) | Rel-12 | 62 | Patrick | Small cell | LTE_SC_enh_L1 |  |
| 2647 | 641.1 | Core part: E-UTRA Small cell enhancements - Physical layer aspects | 161.25d? | 2013-12-15 A | 2014-12-15 A | 100% |  | 2013-07-19 | 2014-09-12 | 202d? |  | finish no earlier than 2014-12-15 | R1; R2; R4 | 3870h | 3870h | LTE_SC_enh_L1-Core | 32 | Huawei | Elean FAN (fanxiaoan@huawei.com) | Rel-12 | 62 | Patrick | Small cell | LTE_SC_enh_L1-Core | RP-141899 |
| 2648 | 641.2 | Perf. part: E-UTRA Small cell enhancements - Physical layer aspects | 394d? | 2013-12-15 A | 2015-06-15 A | 100% |  | 2013-12-09 | 2014-12-05 | 261d? |  | finish no earlier than 2015-06-15 | R4 | 3152h | 3152h | LTE_SC_enh_L1-Perf | 32 | Huawei | Elean FAN (fanxiaoan@huawei.com) | Rel-12 | 62 | Issam | Small cell | LTE_SC_enh_L1-Perf | RP-150690 |
| 2649 | 641.3 | UE Conformance Test Aspects - E-UTRA Small cell enhancements - Physical layer aspects | 525d? | 2015-06-15 A | 2017-06-15 A | 100% |  |  |  |  |  | finish no earlier than 2017-06-15 | R5 | 4200h | 4200h | LTE_SC_enh_L1-UEConTest | 35 | Huawei |  | Rel-12 | 68 |  |  |  |  |
| 2650 | 642 | **Inter-eNB Coordinated Multi-Point (CoMP) for LTE** | 264d? | 2013-12-15 A | 2014-12-15 A | 100% |  | 2014-03-14 | 2014-09-12 | 130.65d? |  |  | R3; R1 | 4738.38h | 4738.38h | COMP_LTE_IeNB | 32 | Samsung | Sung Hwan Won (sunghwan.won@samsung.com) | Rel-12 | 62 | Juha |  | COMP_LTE_IeNB |  |
| 2651 | 642.1 | Core part: Inter-eNB Coordinated Multi-Point (CoMP) for LTE | 165.5d? | 2013-12-15 A | 2014-12-15 A | 100% |  | 2014-03-14 | 2014-09-12 | 100.5d? |  | finish no earlier than 2014-12-15 | R3; R1 | 2648h | 2648h | COMP_LTE_IeNB-Core | 32 | Samsung | Sung Hwan Won (sunghwan.won@samsung.com) | Rel-12 | 62 | Juha |  | COMP_LTE_IeNB-Core | RP-141804 |
| 2652 | 643 | **Smart Congestion Mitigation in E-UTRAN** | 403d? | 2014-03-05 A | 2015-09-15 A | 100% |  | 2014-03-05 | 2014-09-12 | 138d? |  |  | R2; S1; C1 | 12376h | 12376h | SCM_LTE | 32 | LG Electronics | youngdae.lee@lge.com | Rel-12 | 63 | Yong-Jun |  | SCM_LTE |  |
| 2653 | 643.1 | Core part: Smart Congestion Mitigation in E-UTRAN | 137d? | 2014-03-06 A | 2014-09-12 A | 100% |  | 2014-03-06 | 2014-09-12 | 137d? |  | finish no earlier than 2014-09-12 | R2 | 1096h | 1096h | SCM_LTE-Core | 32 | LG Electronics | youngdae.lee@lge.com | Rel-12 | 63 | Yong-Jun |  | SCM_LTE-Core | RP-141292 |
| 2654 | 643.2 | Stage 1 Prioritization of Multimedia Telephony (MMTel) and Mobile Originating-SMS for Access Class Barring (ACB) | 3d? | 2014-03-05 A | 2014-03-07 A | 100% |  | 2014-03-05 | 2014-03-07 | 3d? |  | finish no earlier than 2013-12-11 | S1 | 24h | 24h |  | 33 |  |  | Rel-12 | 64 |  |  |  |  |
| 2655 | 643.3 | CT aspects of Smart Congestion Mitigation in E-UTRAN (Stage 3) | 66d? | 2014-06-13 A | 2014-09-11 A | 100% |  | 2014-06-13 | 2014-09-12 | 66d? |  | start no earlier than 2014-06-13 | C1 | 528h | 528h | SCM_LTE-CT | 33 | LG Electronics | Kim, Jaehyun (jaehyun7.kim@lge.com) | Rel-12 | 64 |  |  | SCM_LTE-CT |  |
| 2656 | 643.4 | UE Conformance Test Aspects - Smart Congestion Mitigation in E-UTRAN | 132d? | 2015-03-16 A | 2015-09-15 A | 100% |  |  |  |  |  | finish no earlier than 2015-09-15 | R5 | 1056h | 1056h | SCM_LTE-UEConTest | 34 | NTT DOCOMO |  | Rel-12 | 67 |  |  |  | RP-151445 |
| 2657 | 644 | **Positioning Enhancements for RF Pattern Matching in E-UTRA** | 36d? | 2014-04-25 A | 2014-06-13 A | 100% |  | 2014-04-25 | 2014-06-13 | 36d? |  |  | R3; R2 | 1152h | 1152h | LCS_LTE_RFPMT | 32 | Polaris Wireless | Gordon Scot (sgordon@polariswireless.com) | Rel-12 | 63 | Juha |  | LCS_LTE_RFPMT |  |
| 2658 | 644.1 | Core part: Positioning Enhancements for RF Pattern Matching in E-UTRA | 36d? | 2014-04-25 A | 2014-06-13 A | 100% |  | 2014-04-25 | 2014-06-13 | 36d? |  | finish no earlier than 2014-06-13 | R3; R2 | 576h | 576h | LCS_LTE_RFPMT-Core | 32 | Polaris Wireless | Gordon Scot (sgordon@polariswireless.com) | Rel-12 | 63 | Juha |  | LCS_LTE_RFPMT-Core | RP-140591 |
| 2659 | 645 | **Network-Assisted Interference Cancellation and Suppression for LTE** | 791d? | 2014-03-11 A | 2017-03-15 | 100% | 0d? | 2014-03-06 | 2015-06-12 | 332d? | 0d |  | R1; R2; R4; R3 | 25043.9h | 15467.9h | LTE_NAICS | 32 | MediaTek | Craig.Burnet@mediatek.com | Rel-12 | 63 | Patrick |  | LTE_NAICS |  |
| 2660 | 645.1 | Core part: Network-Assisted Interference Cancellation and Suppression for LTE | 113.67d? | 2014-07-11 A | 2014-12-15 A | 100% |  | 2014-07-11 | 2014-09-12 | 45.67d? |  | finish no earlier than 2014-12-15 | R1; R2; R4; R3 | 2803.87h | 2803.87h | LTE_NAICS-Core | 32 | MediaTek | Craig.Burnet@mediatek.com | Rel-12 | 63 | Patrick |  | LTE_NAICS-Core | RP-141866 |
| 2661 | 645.2 | Perf. part: Network-Assisted Interference Cancellation and Suppression for LTE | 399d? | 2014-03-11 A | 2015-09-15 A | 100% |  | 2014-03-06 | 2015-06-12 | 332d? |  | finish no earlier than 2015-09-15 | R4 | 3192h | 3192h | LTE_NAICS-Perf | 32 | MediaTek | Craig.Burnet@mediatek.com | Rel-12 | 63 | Issam |  | LTE_NAICS-Perf | RP-151296 |
| 2662 | 645.3 | UE Conformance Test Aspects: Network-Assisted Interference Cancellation and Suppression for LTE | 393d? | 2015-09-15 A | 2017-03-15 A | 100% |  |  |  |  |  | finish no earlier than 2017-03-15 | R5 | 3144h | 3144h | LTE_NAICS-UEConTest | 35 | Mediatek |  | Rel-12 | 69 |  |  |  |  |
| 2663 | 646 | **Performance requirements of interference cancellation and suppression receiver for SU-MIMO** | 467d? | 2014-03-06 A | 2015-12-15 A | 100% |  | 2014-03-06 | 2015-03-13 | 267d? |  |  | R4 | 7448h | 7448h | LTE_SUMIMO_RX | 32 | Huawei | Qian Cheng (Q.Cheng@Huawei.com) | Rel-12 | 63 | Issam |  | LTE_SUMIMO_RX |  |
| 2664 | 646.1 | Perf. part: Performance requirements of interference cancellation and suppression receiver for SU-MIMO | 267d? | 2014-03-06 A | 2015-03-15 A | 100% |  | 2014-03-06 | 2015-03-13 | 267d? |  | finish no earlier than 2015-03-15 | R4 | 2136h | 2136h | LTE_SUMIMO_RX-Perf | 32 | Huawei | Qian Cheng (Q.Cheng@Huawei.com) | Rel-12 | 63 | Issam |  | LTE_SUMIMO_RX-Perf | RP-150229 |
| 2665 | 646.2 | UE Conformance Test Aspects - Performance Requirements of Interference Cancellation and Suppression Receiver for SU-MIMO for E-UTRA | 197d? | 2015-03-16 A | 2015-12-15 A | 100% |  |  |  |  |  | finish no earlier than 2016-03-15 | R5 | 1576h | 1576h | LTE_SUMIMO_RX-UEConTest | 34 | Huawei |  | Rel-12 | 67 |  |  |  | RP-151245 |
| 2666 | 647 | **HSPA signalling enhancements for more efficient resource usage for LCR** | 274d? | 2012-12-11 A | 2013-12-20 A | 100% |  | 2012-12-10 | 2013-12-06 | 265d? |  |  | R1; R2; R3; R4 | 16832h | 16832h | LCR_TDD_HSPA_sign_enh | 30 | CATT | Yanping Xing (xingyanping@catt.cn) | Rel-12 | 58 | Patrick |  | LCR_TDD_HSPA_sign_enh |  |
| 2667 | 647.1 | Core part: HSPA signalling enhancements for more efficient resource usage for LCR TDD | 270d? | 2012-12-15 A | 2013-12-20 A | 100% |  | 2012-12-10 | 2013-12-06 | 265d? |  | finish no earlier than 2013-12-15 | R1; R2; R3 | 6480h | 6480h | LCR_TDD_HSPA_sign_enh-Core | 30 | CATT | Yanping Xing (xingyanping@catt.cn) | Rel-12 | 58 | Patrick |  | LCR_TDD_HSPA_sign_enh-Core | RP-131499 |
| 2668 | 647.2 | Perf. part: HSPA signalling enhancements for more efficient resource usage for LCR TDD | 198d? | 2012-12-11 A | 2013-09-06 A | 100% |  | 2012-12-11 | 2013-09-06 | 198d? |  | finish no earlier than 2013-09-06 | R4 | 1584h | 1584h | LCR_TDD_HSPA_sign_enh-Perf | 30 | CATT | Yanping Xing (xingyanping@catt.cn) | Rel-12 | 58 | Issam |  | LCR_TDD_HSPA_sign_enh-Perf | RP-130968 |
| 2669 | 648 | **HNB Positioning for UTRA** | 127d? | 2013-06-18 A | 2013-12-06 A | 100% |  | 2013-06-18 | 2013-12-06 | 127d? |  |  | R3 | 2032h | 2032h | UTRA_HNB_Pos | 31 | Alcatel-Lucent | Martin.Warner@alcatel-lucent.com | Rel-12 | 60 | Juha | HNB | UTRA_HNB_Pos |  |
| 2670 | 648.1 | Core part: HNB Positioning for UTRA | 127d? | 2013-06-18 A | 2013-12-06 A | 100% |  | 2013-06-18 | 2013-12-06 | 127d? |  | finish no earlier than 2013-12-06 | R3 | 1016h | 1016h | UTRA_HNB_Pos-Core | 31 | Alcatel-Lucent | Martin.Warner@alcatel-lucent.com | Rel-12 | 60 | Juha | HNB | UTRA_HNB_Pos-Core | RP-131974 |

Notes:
- 2646: Triggered by TR 36.872 Study on Small Cell Enhancements for E-UTRA and E-UTRAN Physical-layer aspects (UID_580041) / Impacted TSs and TRs: LTE
- 2647: ; CD:Tue 12/05/15->Mon 15/12/14; WID: RP-130848->RP-140522; Stat Rep: RP-141632->RP-141899 / Impacted TSs and TRs: 36.101, 36.104, 36.133, 36.211, 36.212, 36.213, 36.214, 36.300, 36.306, 36.321, 36.331, 36.413, 36.423, 36.443
- 2648: ; CD:Wed 18/03/15->Sun 15/03/15; WID: RP-130848->RP-140522; Stat Rep: RP-141632->RP-141899 1st Apr 15: Compl:40%->80% 1st Apr 15: CD:Sun 15/03/15->Mon 15/06/15 1st Apr 15: Stat Rep: RP-141899->RP-150173 03/07/15: Compl:80%->100% 03/07/15: Stat Rep: RP- / Impacted TSs and TRs: 36.101, 36.104, 36.133, 36.141
- 2649: tested Core part: LTE_SC_enh_L1-Core 29/09/15: Compl:0%->10% 29/09/15: CD:Wed 15/06/16->Thu 15/12/16 29/09/15: Stat Rep: -->RP-151247; 1/1/16: Compl:10%->40%; ...;...
- 2650: Stage 3. Rel-11 did not address support of a network interface for CoMP involving multiple eNBs with non-ideal backhaul (affected operators might not take advantage of performance benefit from inter-eNB CoMP operation). / Impacted TSs and TRs: LTE
- 2651: CD:Thu 11/12/14->Mon 15/12/14; Compl:85%->100%; Stat Rep: RP-140597->RP-141804 / Impacted TSs and TRs: 36.300, 36.423
- 2652: follow-up of TR 36.848 FS_SCM_LTE / Impacted TSs and TRs: LTE
- 2653: RP#65 completed / Impacted TSs and TRs: 36.331
- 2654: SP#63 SP-140065 CR under TEI12 / Impacted TSs and TRs: 22.011
- 2655: CP#65 completed / Impacted TSs and TRs: 24.173, 24.301, 24.341, 27.007
- 2656: 03/07/15: Compl:0%->60% 03/07/15: WID: RP-150202->RP-150797 03/07/15: Stat Rep: ->RP-150794 29/09/15: Compl:60%->100% 29/09/15: Stat Rep: RP-150794->RP-151445
- 2657: follow-up of TR 36.809 FS_LCS_LTE_RFPMT / Impacted TSs and TRs: LTE
- 2658: RP#64 completed / Impacted TSs and TRs: 36.305, 36.455
- 2659: follow-up of TR 36.866 FS_LTE_NAICS / Impacted TSs and TRs: LTE
- 2660: CD:Mon 08/12/14->Mon 15/12/14; Compl:95%->100%; Stat Rep: RP-141621->RP-141866 / Impacted TSs and TRs: 36.211, 36.213, 36.300, 36.331, 36.423
- 2661: CD:Fri 12/06/15->Mon 15/06/15; Compl:0%->25%; Stat Rep: RP-141621->RP-141866 1st Apr 15: Compl:25%->50% 1st Apr 15: Stat Rep: RP-141866->RP-150179 03/07/15: Compl:50%->85% 03/07/15: CD:Mon 15/06/15->Tue 15/09/15 03/07/15: Stat Rep: RP-150179->RP-150862 / Impacted TSs and TRs: 36.101
- 2662: tested: LTE_NAICS was a REL-12 RAN1 WI; 1/1/16: Compl:0%->35%; 1/1/16: WID: RP-151298->RP-151945; ...
- 2663: no Core part / Impacted TSs and TRs: LTE
- 2664: CD:Fri 13/03/15->Sun 15/03/15; Compl:50%->80%; Stat Rep: RP-141255->RP-141906 1st Apr 15: Compl:80%->100% 1st Apr 15: Stat Rep: RP-141906->RP-150229 / Impacted TSs and TRs: 36.101
- 2665: 03/07/15: Compl:0%->5% 03/07/15: Stat Rep: ->RP-150692 29/09/15: Compl:5%->55% 29/09/15: WID: RP-150245->RP-151463 29/09/15: Stat Rep: RP-150692->RP-1512451/1/16: Compl:55%->100%1/1/16: CD:Tue 15/03/16->Tue 15/1
- 2666: Stage 2/3. Triggered by Rel-11 TR 25.874 Study on HSPA feedback and signalling efficiency enhancements for LCR TDD (FS_LCRTDD_HSPAenh) UID_540026 / Impacted TSs and TRs: UTRA
- 2667: Prev CD:Fri 06/12/13; Prev %:100% / Impacted TSs and TRs: 25.222, 25.224, 25.331, 25.423, 25.433
- 2668: RP#61 completed / Impacted TSs and TRs: 25.102
- 2669: RP#62 completed / Impacted TSs and TRs: UTRA
- 2670: RP#62 closed at 85% completion. Not completed work on HNB positioning / No consensus (may be TEI12, if contribution and support). Updated WID RP-130868=>RP-132037 (HNB positiong was not addressed in this WI, however it was NOT remoded from the WID) / Impacted TSs and TRs: 25.305, 25.467, new TS 25.470

| ID | WBS | Task | Duration | Start | Finish | Complete | Remaining | Baseline start | Baseline finish | Baseline duration | Total slack | Constraint | Resources | Work | Actual work | Acronym | PCG approved | WI rapporteur name | WI rapporteur e-mail | Release | TSG approved | MCC resp | Acronym_3GU_Export | Status Report | Special Focus Doc | PCG stopped | TSG stopped |
| --- | --- | --- | --- | --- | --- | --- | --- | --- | --- | --- | --- | --- | --- | --- | --- | --- | --- | --- | --- | --- | --- | --- | --- | --- | --- | --- | --- |
| 2671 | 649 | **Dedicated Channel (DCH) enhancements for UMTS** | 722d? | 2013-09-15 A | 2016-06-15 A | 100% |  | 2013-09-10 | 2014-12-05 | 326d? |  |  | R1; R2; R3; R4 | 32048h | 32048h | UTRA_DCHenh | 31 | Qualcomm | arjunb@qti.qualcomm.com | Rel-12 | 61 | Patrick | UTRA_DCHenh |  |  |  |  |
| 2672 | 649.1 | Core part: Dedicated Channel (DCH) enhancements for UMTS | 115.25d? | 2013-11-18 A | 2014-09-12 A | 100% |  | 2013-11-18 | 2014-09-12 | 115.25d? |  | finish no earlier than 2014-09-12 | R1; R2; R3; R4 | 3688h | 3688h | UTRA_DCHenh-Core | 31 | Qualcomm | arjunb@qti.qualcomm.com | Rel-12 | 61 | Patrick | UTRA_DCHenh-Core | RP-141137 |  |  |  |
| 2673 | 649.2 | Perf. part: Dedicated Channel (DCH) enhancements for UMTS | 329d? | 2013-09-15 A | 2014-12-15 A | 100% |  | 2013-09-10 | 2014-12-05 | 326d? |  | finish no earlier than 2014-12-15 | R4 | 2632h | 2632h | UTRA_DCHenh-Perf | 31 | Qualcomm | arjunb@qti.qualcomm.com | Rel-12 | 61 | Issam | UTRA_DCHenh-Perf | RP-141970 |  |  |  |
| 2674 | 649.3 | UE Conformance Test Aspects - DCH Enhancements for UMTS | 328d? | 2015-03-16 A | 2016-06-15 A | 100% |  |  |  |  |  | finish no earlier than 2016-06-15 | R5 | 2624h | 2624h | UTRA_DCHenh-UEConTest | 34 | Qualcomm | NA | Rel-12 | 67 |  |  | RP-151279 |  |  |  |
| 2675 | 650 | **UMTS Mobility enhancements for heterogeneous networks** | 237.85d? | 2013-07-23 A | 2014-06-13 A | 100% |  | 2013-07-23 | 2014-06-13 | 237.85d? |  |  | R2; R3; R4 | 8040h | 8040h | UTRA_HetNet_mob | 31 | Huawei | Xudong Yang (yangxudong@huawei.com) | Rel-12 | 61 | Yong-Jun | UTRA_HetNet_mob |  |  |  |  |
| 2676 | 650.1 | Core part: UMTS Mobility enhancements for heterogeneous networks | 67d? | 2013-07-23 A | 2014-06-13 A | 100% |  | 2013-07-23 | 2014-06-13 | 67d? |  | finish no earlier than 2014-06-13 | R2; R3; R4 | 1608h | 1608h | UTRA_HetNet_mob-Core | 31 | Huawei | Xudong Yang (yangxudong@huawei.com) | Rel-12 | 61 | Yong-Jun | UTRA_HetNet_mob-Core | RP-140636 |  |  |  |
| 2677 | 650.2 | Perf. part: UMTS Mobility enhancements for heterogeneous networks | 201d? | 2013-09-09 A | 2014-06-13 A | 100% |  | 2013-09-09 | 2014-06-13 | 201d? |  | finish no earlier than 2014-06-13 | R4 | 1608h | 1608h | UTRA_HetNet_mob-Perf | 31 | Huawei | Xudong Yang (yangxudong@huawei.com) | Rel-12 | 61 | Issam | UTRA_HetNet_mob-Perf | RP-140636 |  |  |  |
| 2678 | 651 | **UMTS Heterogeneous Networks enhancements** | 271d? | 2013-12-06 A | 2014-12-15 A | 100% |  | 2013-12-06 | 2014-12-05 | 262d? |  |  | R1; R2; R3; R4 | 12408h | 12408h | UTRA_HetNet_enh | 32 | Huawei | carmela.cozzo@huawei.com | Rel-12 | 62 | Patrick | UTRA_HetNet_enh |  |  |  |  |
| 2679 | 651.1 | Core part: Heterogeneous Networks enhancements | 202d? | 2013-12-06 A | 2014-09-12 A | 100% |  | 2013-12-06 | 2014-09-12 | 202d? |  | finish no earlier than 2014-09-15 | R1 | 1616h | 1616h | UTRA_HetNet_enh-Core | 32 | Huawei | carmela.cozzo@huawei.com | Rel-12 | 62 | Patrick | UTRA_HetNet_enh-Core | RP-141702 |  |  |  |
| 2680 | 651.2 | Perf. part: Heterogeneous Networks enhancements | 265d? | 2013-12-15 A | 2014-12-15 A | 100% |  | 2013-12-09 | 2014-12-05 | 261d? |  | finish no earlier than 2014-12-15 | R4 | 2120h | 2120h | UTRA_HetNet_enh-Perf | 32 | Huawei | carmela.cozzo@huawei.com | Rel-12 | 62 | Issam | UTRA_HetNet_enh-Perf | RP-141898 |  |  |  |
| 2681 | 652 | **Enhanced Broadcast of System Information** | 271d? | 2013-12-06 A | 2014-12-15 A | 100% |  | 2013-12-06 | 2014-12-05 | 262d? |  |  | R2; R1; R3; R4 | 16385.6h | 16385.6h | UTRA_SIBenh | 32 | Ericsson | martin.van.der.zee@ericsson.com | Rel-12 | 62 | Yong-Jun | UTRA_SIBenh |  |  |  |  |
| 2682 | 652.1 | Core part: Enhanced Broadcast of System Information | 174.8d? | 2013-12-06 A | 2014-09-12 A | 100% |  | 2013-12-06 | 2014-09-12 | 174.8d? |  | finish no earlier than 2014-09-12 | R2; R1; R3; R4 | 5593.6h | 5593.6h | UTRA_SIBenh-Core | 32 | Ericsson | martin.van.der.zee@ericsson.com | Rel-12 | 62 | Yong-Jun | UTRA_SIBenh-Core | RP-141230 |  |  |  |
| 2683 | 652.2 | Perf. part: Enhanced Broadcast of System Information | 265d? | 2013-12-15 A | 2014-12-15 A | 100% |  | 2013-12-09 | 2014-12-05 | 261d? |  | finish no earlier than 2014-12-15 | R4 | 2120h | 2120h | UTRA_SIBenh-Perf | 32 | Ericsson | martin.van.der.zee@ericsson.com | Rel-12 | 62 | Issam | UTRA_SIBenh-Perf | RP-142080 |  |  |  |
| 2684 | 653 | **Further Enhanced Uplink (EUL) enhancements** | 329d? | 2013-12-15 A | 2015-03-15 A | 100% |  | 2013-12-09 | 2014-12-05 | 261d? |  |  | R2 | 13704h | 13704h | EDCH_enh | 32 | Ericsson | mark.curran@ericsson.com | Rel-12 | 62 | Yong-Jun | EDCH_enh |  |  |  |  |
| 2685 | 653.1 | Core part: Further Enhanced Uplink (EUL) enhancements | 264d? | 2013-12-15 A | 2014-12-15 A | 100% |  | 2014-04-29 | 2014-09-12 | 99d? |  | finish no earlier than 2014-12-15 | R2; R1; R3; R4 | 8448h | 8448h | EDCH_enh-Core | 32 | Ericsson | mark.curran@ericsson.com | Rel-12 | 62 | Yong-Jun | EDCH_enh-Core | RP-141860 |  |  |  |
| 2686 | 653.2 | Perf. part: Further Enhanced Uplink (EUL) enhancements | 328d? | 2013-12-15 A | 2015-03-15 A | 100% |  | 2013-12-09 | 2014-12-05 | 261d? |  | finish no earlier than 2015-03-15 | R4 | 2624h | 2624h | EDCH_enh-Perf | 32 | Ericsson | mark.curran@ericsson.com | Rel-12 | 62 | Issam | EDCH_enh-Perf | RP-150062 |  |  |  |
| 2687 | 654 | (Small) Technical Enhancements and Improvements for Rel-12 | 197.5d? | 2012-12-25 A | 2014-09-16 A | 100% |  | 2012-12-25 | 2014-09-17 | 197.5d? |  | finish no earlier than 2014-09-17 | SP; CP; RP; GP | 6320h | 6320h | TEI12 | 29 |  |  | Rel-12 | 56 |  | TEI12 |  |  |  |  |
| 2688 | 655 | (IETF) (Small) Technical Enhancements and Improvements for Rel-12 (draft-ietf-insipid-session-id) | 131d? | 2014-06-13 A | 2014-12-09 A | 100% |  |  |  |  |  | start no earlier than 2014-06-13 | C1-IETF | 1048h | 1048h | TEI12_IETF | 34 | Alcatel-Lucent |  | Rel-12 | 66 |  |  |  |  |  |  |
| 2689 | 656 | Test - (Small) Technical Enhancements and Improvements for Rel-12 | 295.5d? | 2014-10-24 A | 2015-12-11 A | 100% |  | 2014-10-24 | 2015-12-11 | 295.5d? |  | finish no earlier than 2015-12-11 | R5; G3new | 4728h | 4728h | TEI12_Test | 31 |  |  | Rel-12 | 61 | Ingbert | TEI12_Test |  |  |  |  |
| 2690 | 657 | Release 12 Studies | 296.5d? | 2013-08-05 A | 2014-09-17 | 80% | 59.3d? | 2013-08-05 | 2014-09-17 | 296.5d? | 5541d | finish no earlier than 2014-09-17 | SP; CP; GP; RP | 9488h | 7590.4h |  |  |  |  | Rel-12 |  |  |  |  |  |  |  |
| 2691 | 658 | Study on Alternatives to E.164 for Machine-Type Communications | 513d? | 2010-03-25 A | 2012-03-07 A | 100% |  | 2010-03-25 | 2012-03-07 | 513d? |  | finish no earlier than 2012-03-07 | S1 | 4080h | 4080h | FS_AMTC | 24 | T-Mobile USA | gary.jones@T-Mobile.com | Rel-12 | 47 | Alain | FS_AMTC |  | MTC, M2M |  |  |
| 2692 | 659 | Study on enhancements for Machine-Type Communications (MTC) | 720d? | 2010-06-10 A | 2013-03-06 A | 100% |  | 2010-06-10 | 2013-03-06 | 720d? |  | finish no earlier than 2013-03-06 | S1 | 5751.26h | 5751.26h | FS_MTCe | 25 | Huawei | laurence.meriau@huawei.com | Rel-12 | 48 | Alain | FS_MTCe |  | MTC, M2M |  |  |
| 2693 | 660 | Study on Integration of Single Sign-On (SSO) frameworks with 3GPP networks | 383d? | 2010-09-23 A | 2012-03-07 A | 100% |  | 2010-09-23 | 2012-03-07 | 383d? |  | finish no earlier than 2011-09-08 | S1 | 3041.15h | 3041.15h | FS_SSO_Int | 25 | InterDigital | christopher.wallace@interdigital.com | Rel-12 | 49 | Alain | FS_SSO_Int |  |  |  |  |
| 2694 | 661 | Study on Continuity of Data Sessions to Local Networks | 262.85d? | 2010-12-16 A | 2011-12-14 A | 100% |  | 2010-12-16 | 2011-12-14 | 262.85d? |  | finish no earlier than 2011-12-14 | S1 | 2084.27h | 2084.27h | FS_CSN | 26 | NEC | joerg.swetina@neclab.eu | Rel-12 | 50 | Alain | FS_CSN |  |  |  |  |
| 2695 | 662 | Study on non-MTC Mobile Data Applications Impacts | 262.77d? | 2010-12-16 A | 2011-12-14 A | 100% |  | 2010-12-16 | 2011-12-14 | 262.77d? |  | finish no earlier than 2011-12-14 | S1 | 2083.59h | 2083.59h | FS_MODAI | 26 | Huawei, China Mobile | Amar Deol (adeol@huawei.com), Gang Li | Rel-12 | 50 | Alain | FS_MODAI |  |  |  |  |
| 2696 | 663 | Study on Proximity-based Services | 384d? | 2011-09-22 A | 2013-03-05 A | 100% |  | 2011-09-22 | 2013-03-05 | 384d? |  | finish no earlier than 2012-12-12 | S1 | 3045.82h | 3045.82h | FS_ProSe | 27 | Qualcomm | Rich Hovey (rhovey@qualcomm.com) | Rel-12 | 53 | Alain | FS_ProSe |  | Public Safety (A-A) |  |  |
| 2697 | 664 | Study on User Plane Congestion management | 198d? | 2011-12-14 A | 2012-09-12 A | 100% |  | 2011-12-14 | 2012-09-12 | 198d? |  | finish no earlier than 2012-09-12 | S1 | 1568h | 1568h | FS_UPCON | 28 | KDDI | John Visser (jvisser@rogers.com) | Rel-12 | 54 | Alain | FS_UPCON |  |  |  |  |
| 2698 | 665 | Study on RAN Sharing Enhancements | 401d? | 2011-12-14 A | 2013-06-19 A | 100% |  | 2011-12-14 | 2013-06-19 | 401d? |  | finish no earlier than 2013-06-19 | S1 | 3192h | 3192h | FS_RSE | 28 | NEC | joerg.swetina@neclab.eu | Rel-12 | 54 | Alain | FS_RSE |  |  |  |  |
| 2699 | 666 | Deleted - Study on UICC/USIM enhancements | 588d? | 2009-12-10 A | 2012-03-07 A | 100% |  | 2009-12-10 | 2012-03-07 | 588d? |  | finish no earlier than 2012-03-07 | S1 | 4704h | 4704h | FS_U2e | 24 | Giesecke & Devrient | ilario.macchi@gi-de.com | Rel-12 | 46 | Alain | FS_U2e |  |  | PCG-28 | SP-55 |

Notes:
- 2671: Triggered by Rel-12 TR 25.702 Study on Dedicated Channel (DCH) enhancements for UMTS (FS_UTRA_DCHenh) UID_580040. Stage 2/3 / Impacted TSs and TRs: UTRA
- 2672: RP#65 completed / Impacted TSs and TRs: 25.101, 25.104, 25.133, 25.211, 25.212, 25.213, 25.214, 25.215, 25.306, 25.308, 25.321, 25.331, 25.423, 25.433
- 2673: ; Stat Rep: RP-141137->RP-141970 / Impacted TSs and TRs: 25.101, 25.104, 25.133
- 2674: 03/07/15: Compl:0%->15% 03/07/15: Stat Rep: ->RP-150764 29/09/15: Compl:15%->50% 29/09/15: CD:Tue 15/12/15->Wed 15/06/16 29/09/15: Stat Rep: RP-150764->RP-1512791/1/16: Compl:50%->65%;
- 2675: Triggered by Rel-12 TR 25.800 Study on UMTS heterogeneous networks (FS_UTRA_hetnet) UID_570024. Stage 2/3 / Impacted TSs and TRs: UTRA
- 2676: RP#64 completed. TS 25.300v100 for 1-step Approval / Impacted TSs and TRs: 25.101, 25.104, 25.133, 25.141, 25.304, 25.306, 25.331, 25.433, new TS 25.300
- 2677: RP#64 completed / Impacted TSs and TRs: 25.101, 25.104, 25.133, 25.141
- 2678: Triggered by the 2nd part of TR 25.800 (FS_UTRA_HetNet); the 1st part is addressed by UTRA_HetNet_mob UID_610026 / Impacted TSs and TRs: UTRA
- 2679: RP#65 completed. Updated WID RP-140463=>RP-141701 / Impacted TSs and TRs: 25.101, 25.211, 25.212, 25.213, 25.214, 25.300, 25.302, 25.306, 25.308, 25.319, 25.331, 25.423, 25.433
- 2680: ; Stat Rep: RP-141702->RP-141898 / Impacted TSs and TRs: 25.101, 25.104, 25.133, 25.141
- 2681: Triggered by Rel-12 UTRA TR 25.704 Study on Enhanced Broadcast of System Information (FS_UTRA_SIBenh) / Impacted TSs and TRs: UTRA
- 2682: RP#65 completed / Impacted TSs and TRs: 25.211, 25.212 , 25.213, 25.214, 25.301, 25.302, 25.304, 25.306, 25.321, 25.331, 25.433
- 2683: ; Stat Rep: RP-141230->RP-142080 / Impacted TSs and TRs: 25.101, 25.104, 25.133, 25.141
- 2684: Triggered by Rel-12 UTRA TR 25.700 Study on Further Enhanced Uplink (EUL) enhancements (FS_EDCH_enh) / Impacted TSs and TRs: UTRA
- 2685: ; Stat Rep: RP-141684->RP-141860 / Impacted TSs and TRs: 25.211, 25.212, 25.214, 25.304, 25.306, 25.308, 25.319, 25.321, 25.331, 25.423, 25.425, 25.433, 25.435
- 2686: ; CD:Wed 18/03/15->Sun 15/03/15; Stat Rep: RP-141684->RP-141860 1st Apr 15: Compl:75%->100% 1st Apr 15: Stat Rep: RP-141860->RP-150062 / Impacted TSs and TRs: 25.101, 25.104, 25.133, 25.141
- 2687: -
- 2688: Mar15: In WGLC; 21/3/17: 50%->100 / Impacted TSs and TRs: draft-ietf-insipid-session-id
- 2689: -
- 2690: -
- 2691: SP#55 completed. Determine an alternative to E.164 for identifying individual devices and route messages between those devices / Impacted TSs and TRs: 22.988
- 2692: SP#59 completed. TR 22.888 v100 for Information & Approval. Study addition of new MTC-related use cases and functionality and improvements to existing requirements in TS 22.368 / Impacted TSs and TRs: 22.888
- 2693: SP#55 completed. Linked to SA3 Study on Single Sign On (SSO) Application Security for IMS - based on SIP Digest (UID_480048), SA3 TR 33.924 Extended Identity Management (GBA-IdM) and SA3 TR 33.980 (LibSec) / Impacted TSs and TRs: 22.895
- 2694: SP#54 completed. Linked to SA1 Rel-11 Feature UID_490030 SIPTO Service Continuity of IP Data Session (SIPTO_SC) / Impacted TSs and TRs: 22.896
- 2695: SP#54 completed. Linked to UID_490036 SA2 Rel-11 TR 23.843 Study on Core Network Overload solutions (FS_CNO) / Impacted TSs and TRs: 22.801
- 2696: SP#59 completed / Impacted TSs and TRs: 22.803
- 2697: SP#57 completed. Linked to SAPP (Service Awareness and Privacy Policies), FS_UMONC (Study on Usage Monitoring Control Enhancement), QoS_SSL (QoS Control Based on Subscriber Spending Limits) / Impacted TSs and TRs: 22.805
- 2698: SP#60 completed. Extend Rel-6 Network Sharing UID_31018 (basic scenarios of network/RAN sharing) to cover more complex scenarios that arise due to recent needs for more dynamic co-operation among operators / Impacted TSs and TRs: 22.852
- 2699: SP#55 work stopped. Triggered by GSMA Smart SIM and 3GNBK projects, and to evolve from traditional USAT to multimedia USIM toolkit support, particularly to Smart Card Web Server / Impacted TSs and TRs: 22.817

| ID | WBS | Task | Duration | Start | Finish | Complete | Baseline start | Baseline finish | Baseline duration | Constraint | Resources | Work | Actual work | Acronym | PCG approved | Impacted TSs and TRs | WI rapporteur name | WI rapporteur e-mail | Release | TSG approved | MCC resp | Acronym_3GU_Export | Special Focus Doc | PCG stopped | TSG stopped | Status Report |
| --- | --- | --- | --- | --- | --- | --- | --- | --- | --- | --- | --- | --- | --- | --- | --- | --- | --- | --- | --- | --- | --- | --- | --- | --- | --- | --- |
| 2700 | 667 | **Study on IMS based Peer-to-Peer Content Distribution Services (Stage 2)** | 587d? | 2010-09-23 A | 2012-12-12 A | 100% | 2010-09-23 | 2012-12-12 | 587d? |  | S2; S1; S3 | 19472h | 19472h | FS_IMS_P2P_CDS | 25 | 23.844 | China Mobile | Yu Qing (yuqing@chinamobile.com) | Rel-12 | 49 | Maurice | FS_IMS_P2P_CDS |  |  |  |  |
| 2701 | 667.1 | SA1 part of Study on IMS based Peer-to-Peer Content Distribution Services (Stage 2) | 262d? | 2010-09-23 A | 2011-09-21 A | 100% | 2010-09-23 | 2011-09-21 | 262d? | finish no earlier than 2011-09-21 | S1 | 2080h | 2080h | FS_IMS_P2P_CDS | 25 | 23.844 | China Mobile | Yu Qing (yuqing@chinamobile.com) | Rel-12 | 49 | Maurice |  |  |  |  |  |
| 2702 | 667.2 | SA2 part of Study on IMS based Peer-to-Peer Content Distribution Services (Stage 2) | 347d? | 2010-09-23 A | 2012-06-20 A | 100% | 2010-09-23 | 2012-06-20 | 347d? | finish no earlier than 2012-06-08 | S2 | 2776h | 2776h | FS_IMS_P2P_CDS | 25 | 23.844 | China Mobile | Yu Qing (yuqing@chinamobile.com) | Rel-12 | 49 | Maurice |  |  |  |  |  |
| 2703 | 667.3 | SA3 part of Study on IMS based Peer-to-Peer Content Distribution Services (Stage 2) | 68d? | 2012-09-12 A | 2012-12-12 A | 100% | 2012-09-12 | 2012-12-12 | 68d? | finish no earlier than 2012-12-12 | S3 | 528h | 528h | FS_IMS_P2P_CDS | 29 | 33.844 | China Mobile | Zhu Judy(zhuhongru@chinamobile.com) | Rel-12 | 57 | Mirko |  |  |  |  |  |
| 2704 | 668 | **Study on Core Network Overload solutions** | 852d? | 2010-09-23 A | 2013-12-11 A | 100% | 2010-09-23 | 2013-12-11 | 852d? |  | S2 | 18240.6h | 18240.6h | FS_CNO | 25 | 23.843 | Huawei | Mirko.Schramm@huawei.com | Rel-12 | 49 | Maurice | FS_CNO |  |  |  |  |
| 2705 | 668.1 | Study on Core Network Overload solutions (Phase 1) | 587d? | 2010-09-23 A | 2012-12-12 A | 100% | 2010-09-23 | 2012-12-12 | 587d? | finish no earlier than 2012-12-12 | S2 | 4684.11h | 4684.11h | FS_CNO | 25 | 23.843 | Huawei | Mirko.Schramm@huawei.com | Rel-12 | 49 | Maurice |  |  |  |  |  |
| 2706 | 668.2 | Study on Core Network Overload solutions (Phase 2) | 844d? | 2010-09-23 A | 2013-12-11 A | 100% | 2010-09-23 | 2013-12-11 | 844d? | finish no earlier than 2013-12-11 | S2 | 6744h | 6744h | FS_CNO | 25 | 23.843 | Huawei | Mirko.Schramm@huawei.com | Rel-12 | 49 | Maurice |  |  |  |  |  |
| 2707 | 669 | Study on System Enhancements for Energy Efficiency | 399d? | 2010-12-16 A | 2012-06-20 A | 100% | 2010-12-16 | 2012-06-20 | 399d? | finish no earlier than 2012-06-20 | S2 | 3192h | 3192h | FS_SEEE | 26 | 23.866 | Huawei | frank.mademann@huawei.com | Rel-12 | 50 | Maurice | FS_SEEE |  |  |  |  |
| 2708 | 670 | Study on S2a Mobility based On GTP and WLAN access to EPC | 657d? | 2011-03-23 A | 2013-09-11 A | 100% | 2011-03-23 | 2013-09-11 | 657d? | finish no earlier than 2013-09-11 | S2 | 5165.94h | 5165.94h | FS_SaMOG | 26 | 23.852 | ZTE | Tricci So (tso@zteusa.com) | Rel-12 | 51 | Maurice | FS_SaMOG | WLAN |  |  |  |
| 2709 | 671 | Study on Optimized Offloading to WLAN in 3GPP-RAT Mobility | 326d? | 2012-06-18 A | 2013-09-11 A | 100% | 2012-06-18 | 2013-09-11 | 326d? | finish no earlier than 2013-09-11 | S2 | 2592h | 2592h | FS_WORM | 29 | 23.890 | BlackBerry | Steve Barrett (sbarrett@blackberry.com) | Rel-12 | 56 | Maurice | FS_WORM | WLAN |  |  |  |
| 2710 | 672 | Study on Application Based Charging | 190d? | 2012-06-18 A | 2013-03-06 A | 100% | 2012-06-18 | 2013-03-06 | 190d? | finish no earlier than 2013-03-06 | S2 | 1520h | 1520h | FS_ABC | 29 | 23.800 | Allot | Alla Goldner (agoldner@allot.com) | Rel-12 | 56 | Maurice | FS_ABC |  |  |  |  |
| 2711 | 673 | **Study on Multi Access PDN connectivity and IP flow Mobility** | 1141.96d? | 2008-08-08 A | 2012-12-12 A | 100% | 2008-08-08 | 2012-12-12 | 1141.96d? |  | S2; S1 | 27327.4h | 27327.4h | FS_MAPIM | 21 | 23.861 | Qualcomm | Gerardo Giaretta (gerardog@qualcomm.com) | Rel-12 | 41 | Maurice | FS_MAPIM |  |  |  |  |
| 2712 | 673.1 | SA1 part of Study on Multi Access PDN connectivity and IP flow Mobility | 22d? | 2008-08-08 A | 2011-09-21 A | 100% | 2008-08-08 | 2011-09-21 | 22d? | finish no earlier than 2011-09-21 | S1 | 160h | 160h | FS_MAPIM | 21 | 23.861 | Qualcomm | Gerardo Giaretta (gerardog@qualcomm.com) | Rel-12 | 41 | Maurice |  |  |  |  |  |
| 2713 | 673.2 | SA2 part of Study on Multi Access PDN connectivity and IP flow Mobility | 1113d? | 2008-09-18 A | 2012-12-12 A | 100% | 2008-09-18 | 2012-12-12 | 1113d? | finish no earlier than 2012-12-12 | S2 | 8896h | 8896h | FS_MAPIM | 21 | 23.861 | Qualcomm | Gerardo Giaretta (gerardog@qualcomm.com) | Rel-12 | 41 | Maurice |  |  |  |  |  |
| 2714 | 674 | Deleted - Study on IP Flow Mobility support for S2a and S2b Interfaces | 190d? | 2012-06-18 A | 2013-03-06 A | 100% | 2012-06-18 | 2013-03-06 | 190d? | finish no earlier than 2013-03-06 | S2 | 1520h | 1520h | FS_NBIFOM | 29 | 23.861 | ZTE | Tricci So (tso@zteusa.com) | Rel-12 | 56 | Maurice | FS_NBIFOM |  | PCG-30 | SP-59 |  |
| 2715 | 675 | Study on Extended IMS Media Plane Security features | 719d? | 2010-06-10 A | 2013-03-06 A | 100% | 2010-06-10 | 2013-03-06 | 719d? | finish no earlier than 2013-03-06 | S3 | 5736h | 5736h | FS_eMEDIASEC | 25 | 33.829 | Vodafone | Aguibou.Barry@vodafone.com | Rel-12 | 48 | Mirko | FS_eMEDIASEC |  |  |  |  |
| 2716 | 676 | Deleted - Study on Firewall traversal (Stage 2) | 854d? | 2011-06-17 A | 2014-09-17 A | 100% | 2011-06-17 | 2014-09-17 | 854d? | finish no earlier than 2014-09-17 | S3 | 6832h | 6832h | FS_Fire | 27 | 33.830 | Acme Packet | Prashant Kumar (PKumar@acmepacket.com) | Rel-12 | 53 | Mirko | FS_Fire |  | PCG-33 | SP-65 |  |
| 2717 | 677 | Study on Security on spoofed call detection and prevention (Stage 2) | 662d? | 2012-03-07 A | 2014-09-17 A | 100% | 2012-03-07 | 2014-09-17 | 662d? | finish no earlier than 2014-09-17 | S3 | 5296h | 5296h | FS_SPOOF | 28 | 33.831 | China Mobile | lixiangjun@chinamobile.com | Rel-12 | 55 | Mirko | FS_SPOOF |  |  |  |  |
| 2718 | 678 | Study on Security Assurance Methodology for 3GPP Network Elements | 466d? | 2012-09-13 A | 2014-06-18 A | 100% | 2012-09-13 | 2014-06-18 | 466d? | finish no earlier than 2014-03-07 | S3 | 3696h | 3696h | FS_SECAM | 29 | 33.805 | Orange | loic.habermacher@orange.com | Rel-12 | 57 | Mirko | FS_SECAM |  |  |  |  |
| 2719 | 679 | Study on Improved Support for Dynamic Adaptive Streaming over HTTP in 3GPP | 729d? | 2011-12-14 A | 2014-09-16 A | 100% | 2011-12-14 | 2014-09-17 | 729d? | finish no earlier than 2014-09-17 | S4 | 5824h | 5824h | FS_IS_DASH | 28 | 26.938 | Qualcomm | c_tstock@qualcomm.com | Rel-12 | 54 | Paolo | FS_IS_DASH |  |  |  |  |
| 2720 | 680 | Study on HTML5 for a new presentation layer in 3GPP services | 266d? | 2013-09-12 A | 2014-09-16 A | 100% | 2013-09-12 | 2014-09-17 | 266d? | finish no earlier than 2014-09-17 | S4 | 2128h | 2128h | FS_HTML5 | 31 | 26.907 | Samsung | Imed Bouazizi (i.bouazizi@sta.samsung.com) | Rel-12 | 61 | Paolo | FS_HTML5 |  |  |  |  |
| 2721 | 681 | Study on version handling | 716d? | 2010-03-25 A | 2012-12-12 A | 100% | 2010-03-25 | 2012-12-12 | 716d? | finish no earlier than 2012-12-12 | S5 | 5704h | 5704h | FS_OAM_VH | 24 | 32.830 | Ericsson | thomas.tovinger@ericsson.com | Rel-12 | 47 | Mirko | FS_OAM_VH |  |  |  |  |
| 2722 | 682 | Study on management of Heterogeneous Networks | 852d? | 2011-03-23 A | 2014-06-18 A | 100% | 2011-03-23 | 2014-06-18 | 852d? | finish no earlier than 2014-06-18 | S5 | 6816h | 6816h | FS_OAM_HetNet | 26 | 32.835 | Ericsson | ulf.hubinette@ericsson.com | Rel-12 | 51 | Mirko | FS_OAM_HetNet |  |  |  |  |
| 2723 | 683 | Study on OAM aspects of Network Sharing | 464d? | 2011-12-07 A | 2013-09-11 A | 100% | 2011-12-07 | 2013-09-11 | 464d? | finish no earlier than 2013-09-11 | S5 | 3696h | 3696h | FS_OAM_SHARE | 28 | 32.851 | Alcatel-Lucent, Huawei | Padma.Sudarsan@alcatel-lucent.com, zoulan@huawei.com | Rel-12 | 54 | Mirko | FS_OAM_SHARE |  |  |  |  |
| 2724 | 684 | Study on Enhanced Network Management (NM) centralized Coverage and Capacity Optimization | 590d? | 2011-09-21 A | 2014-09-17 A | 100% | 2011-09-21 | 2014-09-17 | 590d? | finish no earlier than 2014-09-17 | S5 | 4712h | 4712h | FS_SON_NM_CCO | 29 | 32.836 | Ericsson | robert.petersen@ericsson.com | Rel-12 | 56 | Mirko | FS_SON_NM_CCO | SON |  |  |  |
| 2725 | 685 | Study on WLAN management | 788d? | 2011-09-21 A | 2014-09-17 A | 100% | 2012-06-20 | 2014-09-17 | 590d? | finish no earlier than 2014-09-17 | S5 | 6304h | 6304h | FS_WLAN_OAM | 29 | 28.680, 28.681, 28.682, 28.683, 28.403 | Intel | joey.chou@intel.com | Rel-12 | 56 | Mirko | FS_WLAN_OAM | WLAN |  |  |  |
| 2726 | 686 | Study on Alarm Management | 201d? | 2012-12-07 A | 2013-09-11 A | 100% | 2012-12-07 | 2013-09-11 | 201d? | finish no earlier than 2013-09-11 | S5 | 1592h | 1592h | FS_OAM_AM | 30 | 32.859 | TeliaSonera | tommy.berggren@teliasonera.com | Rel-12 | 58 | Mirko | FS_OAM_AM |  |  |  |  |
| 2727 | 687 | Study on Indication of Network to Network Interface (NNI) Routeing scenarios in SIP requests | 400d? | 2012-12-10 A | 2014-06-13 A | 100% | 2012-12-10 | 2014-06-13 | 400d? | finish no earlier than 2014-03-06 | C3 | 3190.27h | 3190.27h | FS_NNI_RS | 30 | 24.802 | Ericsson | Jan.Holm@ericsson.com | Rel-12 | 58 | Adrian | FS_NNI_RS |  |  |  |  |
| 2728 | 688 | Study on Diameter Overload Control Mechanisms | 464d? | 2012-01-05 A | 2014-09-11 A | 100% | 2012-01-05 | 2014-09-12 | 464d? | finish no earlier than 2014-09-12 | C4 | 3712h | 3712h | FS_DOCME | 30 | 29.809 | Orange | lionel.morand@orange.com | Rel-12 | 58 | Kimmo | FS_DOCME |  |  |  |  |
| 2729 | 689 | Study on XML based access of AF to the PCRF | 203d? | 2013-03-01 A | 2013-12-04 A | 100% | 2013-03-01 | 2014-06-13 | 341d? | finish no earlier than 2014-06-13 | C3 | 1608h | 1608h | FS_XML_AF_PCRF | 30 | 29.817 | Alcatel-Lucent | horst.brinkman@alcatel-lucent.com | Rel-12 | 59 | Adrian | FS_XML_AF_PCRF |  |  |  |  |
| 2730 | 690 | Study on Technical aspects on Roaming End-to-end scenarios with VoLTE IMS and other networks | 328d? | 2013-09-09 A | 2014-12-09 A | 100% | 2013-09-09 | 2014-09-12 | 266d? | finish no earlier than 2014-12-09 | C3 | 2624h | 2624h | FS_REVOLTE_IMS | 31 | 29.949 | Deutsche Telekom | Roland Jesske (r.jesske@telekom.de) | Rel-12 | 61 | Adrian | FS_REVOLTE_IMS |  |  |  |  |
| 2731 | 691 | Study on Development of conformance requirements for the IP Multimedia Services Identity Module (ISIM) application support in ME | 263d? | 2013-12-09 A | 2014-12-09 A | 100% | 2013-12-09 | 2014-09-12 | 201d? | finish no earlier than 2014-12-09 | C6 | 2104h | 2104h | FS_ISIM_CR | 32 | 31.829 | Gemalto | ly-thanh.phan@gemalto.com | Rel-12 | 62 | Xavier | FS_ISIM_CR |  |  |  |  |
| 2732 | 692 | Study on Shared Data Update for Multiple Subscribers | 263d? | 2013-12-06 A | 2014-12-09 A | 100% | 2013-12-06 | 2014-09-12 | 201d? | finish no earlier than 2014-12-09 | C4 | 2104h | 2104h | FS_SHARED_SubData_UPD | 32 | 29.854 | Huawei | Susan Shi (susan.shishufeng@huawei.com) | Rel-12 | 62 | Kimmo | FS_SHARED_SubData_UPD |  |  |  |  |
| 2733 | 693 | Study on GERAN improvements for Machine-Type Communications | 661d? | 2010-05-24 A | 2012-11-23 A | 100% | 2010-05-24 | 2012-11-23 | 661d? | finish no earlier than 2012-11-23 | G1; G2 | 10576h | 10576h | FS_NIMTC_GERAN | 24 | 43.868 | Ericsson | paul.schliwa-bertling@ericsson.com | Rel-12 | 44 | Paolo | FS_NIMTC_GERAN | MTC, M2M |  |  |  |
| 2734 | 694 | Study on Voice services over Adaptive Multi-user channels on One Slot (VAMOS) enhancements | 267.67d? | 2010-10-27 A | 2014-05-30 A | 100% | 2010-10-27 | 2014-05-30 | 267.67d? | finish no earlier than 2014-05-30 | GP; G2; G1 | 6424h | 6424h | FS_eVAMOS | 27 | 43.801 | China Mobile, Huawei | Chao Luo (chluo@huawei.com), dengjuan@chinamobile.com | Rel-12 | 50 | Paolo | FS_eVAMOS |  |  |  |  |
| 2735 | 695 | Study on GERAN enhancements for Mobile Data Applications | 430d? | 2011-04-04 A | 2014-08-29 A | 100% | 2011-04-04 | 2014-08-29 | 430d? | finish no earlier than 2014-08-29 | G2; G1 | 6880h | 6880h | FS_GERAN_eMDA | 27 | 43.802 | Huawei | ming.fang@huawei.com | Rel-12 | 50 | Gert | FS_GERAN_eMDA |  |  |  |  |
| 2736 | 696 | Study on Inclusion of RF Pattern Matching Technologies as a positioning method in the E-UTRAN | 722d? | 2010-12-10 A | 2013-09-06 A | 100% | 2010-12-10 | 2013-09-06 | 722d? | finish no earlier than 2013-09-06 | R4 | 5776h | 5776h | FS_LCS_LTE_RFPMT | 26 | LTE 36.809 | Polaris Wireless | Scot Gordon (sgordon@polariswireless.com) | Rel-12 | 50 | Issam | FS_LCS_LTE_RFPMT |  |  |  | RP-131082 |
| 2737 | 697 | Study on Provision of low-cost MTC UEs based on LTE | 462d? | 2011-09-19 A | 2013-06-14 A | 100% | 2011-09-19 | 2013-06-14 | 462d? | finish no earlier than 2013-06-14 | R1; R2; R4 | 11088h | 11088h | FS_LC_MTC_LTE | 27 | LTE 36.888 | Vodafone | prakash.bhat@vodafone.com | Rel-12 | 53 | Patrick | FS_LC_MTC_LTE | MTC, M2M |  |  | RP-130583 |
| 2738 | 698 | Deleted - Study on Mobile Relay for E-UTRA | 881.5d? | 2005-05-19 A | 2014-06-23 A | 100% | 2005-05-19 | 2014-06-23 | 881.5d? | finish no earlier than 2014-06-23 | R3; R1 | 14104h | 14104h | FS_LTE_mobRelay | 27 | LTE 36.836 | CATT | Haijing Hu (huhaijing@catt.cn) | Rel-12 | 53 | Juha | FS_LTE_mobRelay |  | PCG-33 | RP-64 | RP-140726 |
| 2739 | 699 | Study on Scenarios and Requirements of LTE Small Cell Enhancements for E-UTRA and E-UTRAN | 66d? | 2012-09-11 A | 2012-12-07 A | 100% | 2012-09-11 | 2012-12-07 | 66d? | finish no earlier than 2012-12-07 | RP | 528h | 528h | FS_LTE_SC_enh_req | 29 | LTE 36.932 | China Mobile | Hai TANG (tanghai@chinamobile.com) | Rel-12 | 57 | Yong-Jun | FS_LTE_SC_enh_req | Small cell |  |  | RP-121651 |
| 2740 | 700 | Study on Small Cell Enhancements for E-UTRA and E-UTRAN – Physical-layer aspects | 265d? | 2012-09-11 A | 2013-09-06 A | 100% | 2012-09-11 | 2013-09-06 | 265d? | finish no earlier than 2013-09-06 | R1; R2; R4 | 6360h | 6360h | FS_LTE_SC_enh_L1 | 30 | LTE 36.872 | Huawei | Elean Fan (fanxiaoan@huawei.com) | Rel-12 | 58 | Patrick | FS_LTE_SC_enh_L1 | Small cell |  |  | RP-131618 |
| 2741 | 701 | Study on Small Cell Enhancements for E-UTRA and E-UTRAN – Higher-layer aspects | 265d? | 2012-12-10 A | 2013-12-06 A | 100% | 2012-12-10 | 2013-12-06 | 265d? | finish no earlier than 2013-12-06 | R2; R3 | 4240h | 4240h | FS_LTE_SC_enh_hilayer | 30 | LTE 36.842 | NTT DOCOMO | Hideaki Takahashi (h-takahashi@nttdocomo.co.jp) | Rel-12 | 58 | Yong-Jun | FS_LTE_SC_enh_hilayer | Small cell |  |  | RP-131619 |
| 2742 | 702 | Study on LTE Device-to-Device Proximity Services - Radio Aspects | 325d? | 2012-12-17 A | 2014-03-06 A | 100% | 2012-12-17 | 2014-03-06 | 325d? | finish no earlier than 2014-03-06 | R1; R2; R3; R4 | 10400h | 10400h | FS_LTE_D2D_Prox | 30 | LTE 36.843 | Qualcomm | Shailesh Patil (patil@qti.qualcomm.com) | Rel-12 | 58 | Patrick | FS_LTE_D2D_Prox | Public Safety (A-A) |  |  | RP-140416 |
| 2743 | 703 | Study on 3D-channel model for Elevation Beamforming and FD-MIMO studies for LTE | 463d? | 2012-12-10 A | 2014-09-12 A | 100% | 2012-12-10 | 2014-09-12 | 463d? | finish no earlier than 2014-09-12 | R1 | 3704h | 3704h | FS_LTE_3D_channel | 30 | LTE 36.873 | Nokia Networks | bishwarup.mondal@nsn.com | Rel-12 | 58 | Patrick | FS_LTE_3D_channel |  |  |  | RP-141206 |
| 2744 | 704 | Study on Energy Saving Enhancement for E-UTRAN | 397d? | 2012-12-10 A | 2014-06-13 A | 100% | 2012-12-10 | 2014-06-13 | 397d? | finish no earlier than 2014-06-13 | R3 | 3176h | 3176h | FS_Netw_Energy_enh_LTE | 30 | LTE 36.887 | China Mobile | Kimba Dit Adamou, Boubacar (jinba@chinamobile.com) | Rel-12 | 58 | Juha | FS_Netw_Energy_enh_LTE |  |  |  | RP-140604 |
| 2745 | 705 | Study on Expansion of LTE_FDD_1670_US to include 1670-1680MHz Band for LTE in the US | 469d? | 2013-03-01 A | 2014-12-15 A | 100% | 2013-03-01 | 2014-09-12 | 403d? | finish no earlier than 2014-12-15 | R4 | 3752h | 3752h | FS_LTE_FDD_1670_US | 30 | LTE 36.844 | LightSquared | masoud.olfat@lightsquared.com | Rel-13 | 59 | Issam | FS_LTE_FDD_1670_US |  |  |  | RP-141815 |
| 2746 | 706 | Study on Cell-specific Reference Signals (CRS) Interference Mitigation for homogenous deployments for LTE | 201d? | 2013-03-04 A | 2013-12-06 A | 100% | 2013-03-04 | 2013-12-06 | 201d? | finish no earlier than 2013-12-06 | R4 | 1608h | 1608h | FS_LTE_CRSIC | 30 | LTE 36.863 | Ericsson | shaohua.li@ericsson.com | Rel-12 | 59 | Issam | FS_LTE_CRSIC |  |  |  | RP-131623 |
| 2747 | 707 | Study on Network-Assisted Interference Cancellation and Suppression for LTE | 265d? | 2013-03-08 A | 2014-03-06 A | 100% | 2013-03-08 | 2014-03-06 | 265d? | finish no earlier than 2014-03-06 | R1; R4 | 4240h | 4240h | FS_LTE_NAICS | 30 | LTE 36.866 | MediaTek | jeff.zhuang@mediatek.com | Rel-12 | 59 | Patrick | FS_LTE_NAICS |  |  |  | RP-132108 |
| 2748 | 708 | Study on Coordinated Multi-Point (CoMP) operation for LTE with Non-Ideal Backhaul | 126d? | 2013-06-18 A | 2013-12-06 A | 100% | 2013-06-18 | 2013-12-06 | 126d? | finish no earlier than 2013-12-06 | R1 | 1008h | 1008h | FS_COMP_LTE_nibackhaul | 31 | LTE 36.874 | Samsung | Hyojin Lee (hyojin257.lee@samsung.com) | Rel-12 | 60 | Patrick | FS_COMP_LTE_nibackhaul |  |  |  | RP-131626 |
| 2749 | 709 | Study on Group Communication for LTE | 130d? | 2013-09-10 A | 2014-03-06 A | 100% | 2013-09-10 | 2014-03-06 | 130d? | finish no earlier than 2014-03-06 | R2; R3 | 2080h | 2080h | FS_LTE_GC | 31 | LTE 36.868 | Alcatel-Lucent | chandrika.worrall@alcatel-lucent.com | Rel-12 | 61 | Yong-Jun | FS_LTE_GC | Public Safety (A-A) |  |  | RP-140182 |
| 2750 | 710 | Study on Smart Congestion Mitigation in E-UTRAN | 130d? | 2013-09-09 A | 2014-03-06 A | 100% | 2013-09-09 | 2014-03-06 | 130d? | finish no earlier than 2014-03-06 | R2 | 1040h | 1040h | FS_SCM_LTE | 31 | LTE 36.848 | LG Electronics | youngdae.lee@lge.com | Rel-12 | 61 | Yong-Jun | FS_SCM_LTE |  |  |  | RP-140102 |
| 2751 | 711 | Study on RAN aspects of RAN Sharing Enhancements for LTE | 136d? | 2013-12-06 A | 2014-06-13 A | 100% | 2013-12-06 | 2014-06-13 | 136d? | finish no earlier than 2014-06-13 | R3 | 1088h | 1088h | FS_RSE-RAN_LTE | 32 | LTE 36.856 | NEC | Siva.Vakeesar@emea.nec.com | Rel-12 | 62 | Juha | FS_RSE-RAN_LTE |  |  |  | RP-140746 |
| 2752 | 712 | Study on RF and EMC requirements for active Antenna Array System (AAS) Base Station | 386d? | 2011-09-19 A | 2013-03-01 A | 100% | 2011-09-19 | 2013-03-01 | 386d? | finish no earlier than 2013-03-01 | R4; R1 | 6176h | 6176h | FS_AAS_BS_LTE_UTRA | 27 | UTRA, LTE 37.840 | Huawei | Ronnie.zhang@huawei.com | Rel-12 | 53 | Issam | FS_AAS_BS_LTE_UTRA |  |  |  | RP-130124 |
| 2753 | 713 | Study on LTE-HRPD (High Rate Packet Data in 3GPP2) inter-RAT SON | 340d? | 2012-03-02 A | 2013-06-14 A | 100% | 2012-03-02 | 2013-06-14 | 340d? | finish no earlier than 2013-06-14 | R3 | 2712h | 2712h | FS_LTE_HRPD_SON | 28 | UTRA, LTE 37.813 | China Telecom | Wu Jinlian (wujl@gsta.com) | Rel-12 | 55 | Juha | FS_LTE_HRPD_SON | SON |  |  | RP-130585 |
| 2754 | 714 | Study on Passive InterModulation (PIM) handling for UTRA and LTE Base Stations | 403d? | 2012-03-05 A | 2013-09-06 A | 100% | 2012-03-05 | 2013-09-06 | 403d? | finish no earlier than 2013-09-06 | R4; G1 | 6448h | 6448h | FS_BS_PIM | 28 | UTRA, LTE 37.808 | Ericsson | johan.skold@ericsson.com | Rel-12 | 55 | Issam | FS_BS_PIM |  |  |  | RP-131076 |
| 2755 | 715 | Study on WLAN/3GPP Radio Interworking | 264d? | 2012-12-10 A | 2013-12-06 A | 100% | 2012-12-10 | 2013-12-06 | 264d? | finish no earlier than 2013-12-06 | R2 | 2104h | 2104h | FS_UTRA_LTE_WLAN_interw | 30 | UTRA, LTE 37.834 | Intel | sasha.sirotkin@intel.com | Rel-12 | 58 | Yong-Jun | FS_UTRA_LTE_WLAN_interw | WLAN |  |  | RP-131611 |
| 2756 | 716 | Study on RAN Enhancements for UMTS/HSPA and LTE Interworking | 261d? | 2012-12-10 A | 2013-12-06 A | 100% | 2012-12-10 | 2013-12-06 | 261d? | finish no earlier than 2013-12-06 | R3 | 2088h | 2088h | FS_HSPA_LTE_interworking | 30 | UTRA, LTE 37.852 | China Unicom | Meng Zhang (zhangmeng68@chinaunicom.cn) | Rel-12 | 58 | Juha | FS_HSPA_LTE_interworking |  |  |  | RP-131612 |
| 2757 | 717 | Study on Next-Generation SON for UTRA and LTE | 397d? | 2012-12-10 A | 2014-06-13 A | 100% | 2012-12-10 | 2014-06-13 | 397d? | finish no earlier than 2014-06-13 | R3 | 3176h | 3176h | FS_UTRA_LTE_NG_SON | 30 | UTRA, LTE 37.822 | NSN | krzysztof.kordybach@nsn.com | Rel-12 | 58 | Juha | FS_UTRA_LTE_NG_SON | SON |  |  | RP-140747 |
| 2758 | 718 | Study on 2GHz FDD for UTRA and LTE in Region 1 (1980-2010MHz and 2170-2200MHz Bands) | 462d? | 2012-12-11 A | 2014-09-12 A | 100% | 2012-12-11 | 2014-09-12 | 462d? | finish no earlier than 2014-09-12 | R4 | 3696h | 3696h | FS_UTRA_LTE_1980_2170_REG1 | 30 | UTRA, LTE 37.846 | DISH Network | johny.kim@dish.com, mariam.sorond@dish.com | Rel-12 | 58 | Issam | FS_UTRA_LTE_1980_2170_REG1 |  |  |  | RP-141099 |
| 2759 | 719 | Study on Base Station specification structure | 136d? | 2012-12-10 A | 2013-06-14 A | 100% | 2012-12-10 | 2013-06-14 | 136d? | finish no earlier than 2013-06-14 | R4 | 1088h | 1088h | FS_BSspec_struc | 30 | UTRA, LTE, MSR 37.810 | Ericsson | johan.skold@ericsson.com | Rel-12 | 58 | Issam | FS_BSspec_struc |  |  |  | RP-130580 |
| 2760 | 720 | Study on RAN aspects of Machine Type and other mobile data applications Communications enhancements | 137d? | 2013-03-01 A | 2013-09-06 A | 100% | 2013-03-01 | 2013-09-06 | 137d? | finish no earlier than 2013-09-06 | R2 | 1096h | 1096h | FS_MTCe_RAN | 30 | UTRA, LTE 37.869 | ZTE | sergio.parolari@zteitaly.com | Rel-12 | 59 | Yong-Jun | FS_MTCe_RAN | MTC, M2M |  |  | RP-131081 |
| 2761 | 721 | Study on UMTS heterogeneous networks | 331d? | 2012-06-12 A | 2013-09-06 A | 100% | 2012-06-12 | 2013-09-06 | 331d? | finish no earlier than 2013-09-06 | R1; R2; R3 | 7944h | 7944h | FS_UTRA_HetNet | 29 | UTRA 25.800 | Huawei | carmela.cozzo@huawei.com | Rel-12 | 57 | Patrick | FS_UTRA_HetNet |  |  |  | RP-131606 |
| 2762 | 722 | Study on Scalable UMTS FDD bandwidth | 265d? | 2012-12-10 A | 2013-12-06 A | 100% | 2012-12-10 | 2013-12-06 | 265d? | finish no earlier than 2013-12-06 | R1; R4 | 4240h | 4240h | FS_UTRA_SCAL | 30 | UTRA TR 25.701 | China Unicom | Han Xiao (hanxiao91@chinaunicom.cn) | Rel-12 | 58 | Patrick | FS_UTRA_SCAL |  |  |  | RP-132035 |
| 2763 | 723 | Deleted - Study on Scalable UMTS FDD bandwidth by Filtering | 136d? | 2013-12-09 A | 2014-06-13 A | 100% | 2013-12-09 | 2014-06-13 | 136d? | finish no earlier than 2014-06-13 | R1 | 1088h | 1088h | FS_UTRA_SCAL_FILT | 32 | UTRA TR 25.701 | China Unicom | Han Xiao (hanxiao91@chinaunicom.cn) | Rel-12 | 62 | Patrick | FS_UTRA_SCAL_FILT |  | PCG-33 | RP-64 | RP-140988 |
| 2764 | 724 | Study on Dedicated Channel (DCH) enhancements for UMTS | 197d? | 2012-12-10 A | 2013-09-06 A | 100% | 2012-12-10 | 2013-09-06 | 197d? | finish no earlier than 2013-09-06 | R1 | 1576h | 1576h | FS_UTRA_DCHenh | 30 | UTRA TR 25.702 | Qualcomm | Arjun Bharadwaj (arjunb@qti.qualcomm.com) | Rel-12 | 58 | Patrick | FS_UTRA_DCHenh |  |  |  | RP-131073 |
| 2765 | 725 | Study on Further Enhanced Uplink (EUL) enhancements | 265d? | 2012-12-10 A | 2013-12-06 A | 100% | 2012-12-10 | 2013-12-06 | 265d? | finish no earlier than 2013-12-06 | R2; R1; R3 | 6360h | 6360h | FS_EDCH_enh | 30 | UTRA TR 25.700 | Ericsson | alessandro.caverni@ericsson.com | Rel-12 | 58 | Yong-Jun | FS_EDCH_enh |  |  |  | RP-131608 |
| 2766 | 726 | Study on HNB Emergency Warning Area for UTRA | 191d? | 2013-06-18 A | 2014-03-06 A | 100% | 2013-06-18 | 2014-03-06 | 191d? | finish no earlier than 2014-03-06 | R3 | 1520h | 1520h | FS_HNB_warn_area | 31 | UTRA TR 25.703 | Alcatel-Lucent, Ip.access | Martin.Warner@alcatel-lucent.com, Kit.kilgour@ipaccess.com | Rel-12 | 60 | Juha | FS_HNB_warn_area | HNB |  |  | RP-140129 |
| 2767 | 727 | Study on Enhanced Broadcast of System Information | 66d? | 2013-09-09 A | 2013-12-06 A | 100% | 2013-09-09 | 2013-12-06 | 66d? | finish no earlier than 2013-12-06 | R2; R1 | 1056h | 1056h | FS_UTRA_SIBenh | 31 | UTRA TR 25.704 | Ericsson | martin.van.der.zee@ericsson.com | Rel-12 | 61 | Yong-Jun | FS_UTRA_SIBenh |  |  |  | RP-131610 |
| 2768 | 728 | Release 11 Features | 342.75d? | 2013-06-02 A | 2014-09-16 A | 100% | 2013-06-02 | 2014-09-17 | 342.75d? | finish no earlier than 2014-09-17 | SP; CP; GP; RP | 10968h | 10968h |  |  |  |  |  | Rel-11 |  | All |  |  |  |  |  |

Notes:
- 2700: Triggered by TR 22.906 SA1 Study on IMS based Peer-to-Peer Content Distribution Services UID_450047
- 2701: SP#53 completed
- 2702: SP#56 completed. TR 23.844v100 for Information and Approval
- 2703: SP#58 completed. TR 33.844 v100 for Information and Approval
- 2704: SP#62 completed. Linked to CT4 TR 23.857 Study on EPC Nodes Restoration (UID_490014)
- 2705: Phase 1: complete study of overload control related to MAP /Diameter signalling, other 3GPP Core Network signalling optimization
- 2706: SP#62 completed
- 2707: SP#56 completed
- 2708: SP#61 completed. Covers generic non-3GPP access (e.g. WLAN, WIMAX, CDMA/HRPD). Spin-off Feature SaMOG_WLAN. Linked to Rel-8 Support for non-3GPP accesses, Rel-10 SMOG, Rel-11 BBAI
- 2709: SP#61 completed. Linked to UID_350027 SAE for support for non-3GPP accesses (SAES-SA-FP_n3GPP), UID_410043 MAPIM, UID_450041 IFOM, UID_530046 SaMOG
- 2710: SP#59 completed. Linked to Rel-11 Feature UID_500032 Service Awareness and Privacy Policies (SAPP)
- 2711: Spin-off Features MAPCON, IFOM. SP#58 completed FS_MAPIM part of 23.861 (continued under FS_NBIFOM)
- 2712: SP#53 completed
- 2713: SP#43 TR 23.861v100 for Information. SP#56 Rel-9 TR 23.861v130 renamed & progressed under new Study FS_NBIFOM. SP#58 completed the FS_MAPIM part of TR 23.861 (TR continued under FS_NBIFOM).
- 2714: SP#59 stopped (at 40% completion). SP#56 revives dormant Study FS_MAPIM. TR 23.861 title changed from (Multi Access PDN connectivity and IP flow mobility) to (Network based IP flow mobility)
- 2715: SP#59 completed. Continuation of Rel-9 Feature UID_430036 IMS Media Plane Security (MEDIASEC). Study solutions and extensions to features and functionality described in TR 33.828 and TS 33.328
- 2716: SP#65 stopped. Linked to Rel-12 Service and Media Reachability for Users over Restrictive Firewalls (SMURFs) UID_530043
- 2717: SP#65 completed. TR 33.831v100 for 1-step Approval. Linked to Rel-11 SPUCI TR 33.838
- 2718: SP#64 completed. Spin-off Rel-13 Feature SCAS. Study methodologies for specifying product security assurance and hardening requirements on 3GPP network elements (with associated test cases when feasible)
- 2719: SP#65 completed. TR 26.938v200 for Approval. SP#60 TR 26.938v100 for Information. Linked to Feature UID_470034 HTTP-based Streaming and Download Services
- 2720: SP#65 completed. TR 26.907v200 for Approval. SP#64 TR 26.907v100 for Information.
- 2721: SP#58 completed
- 2722: SP#64 completed
- 2723: SP#61 completed. Linked to Network Sharing UID_31018, SA1 22.951 (Service aspects and requirements for network sharing), SA2 23.251 (Network Sharing; Architecture)
- 2724: SP#65 completed. TR 32.836v200 for Approval. SP#63 split of Rel-12 SP-130045 WID (Enhanced NM Centralized Coverage and Capacity Optimization) into a Rel-12 Study (SP-140028) and a Rel-13 Normative WID (SP-140060)
- 2725: SP#65 revised WID SP-130042=>SP-140536 (split into Rel-12 Study & Rel-13 normative WI). Changed Title from "TR on WLAN impacts to Type-2 management interface to the 3GPP Network Manager". TR 32.841v200 for Approval. Completed; 14/09/15: WID:SP-140536->
- 2726: SP#61 completed
- 2727: CP#64 completed
- 2728: CP#65 completed. TR 29.809 v200 for Approval. Triggered by SA2 Rel-12 TR 23.843 Study on Core Network Overload solutions (FS_CNO) UID_490036. Coordinate with CT3, SA5
- 2729: CP#64 completed. Investigate introducing an XML-based protocol (e.g. SOAP, Restful HTTP, etc.) between AF and PCRF for non-IMS applications
- 2730: CP#65 completion 09/14=>12/14. CP#64 TR 29.949v100 for Information.Dec.14:95->100
- 2731: CP#65 completion 09/14=>12/14. Gathering of all ISIM-related conformance requirements and the assessment of CT6 coverage; June2015: Compl:30%->100
- 2732: CP#65 TR 29.854v200 for Approval. Completion 09/14=>12/14. Dec.14: 80->85%. Mar.15: 100%
- 2733: GP#56 completed. GP#44 approved WID
- 2734: GP#62 completed. TR 43.801v100 for 1-step Approval. GP#50 approved WID. Triggered by Rel-8 TR 45.914 Study Multi-User-Reusing One Timeslot (MUROS) UID_50590 and Rel-9 VAMOS UID_420002
- 2735: GP#63 completed. TR~43.802v200 for Approval. GP#50 approved WID (mobile coucou). Triggered by RAN#51 (Mar 2011) WID in RP-110454 (LTE RAN Enhancements for Diverse Data Applications) UID_510031
- 2736: RP#61 completed. Linked to Rel-10 WI on Inclusion of RF Pattern Matching Technologies as a positioning method in the UTRAN (LCS_UMTS_RFPMT) UID_460005
- 2737: RP#60 completed
- 2738: RP#64 stopped at 80% completion
- 2739: RP#58 completed. TR 36.932 v100 for Information and Approval
- 2740: RP#62 completed. RP#61 TR 36.872v100 for 1-step approval. Triggered by Rel-12 TR 36.932 Study on Scenarios and Requirements of LTE Small Cell Enhancements for E-UTRA and E-UTRAN UID_570023
- 2741: RP#62 completed. Triggered by Rel-12 TR 36.932 Study on Scenarios and Requirements of LTE Small Cell Enhancements for E-UTRA and E-UTRAN UID_570023
- 2742: RP#63 completed. TR 36.843 for 1-step approval (90% complete). Started normative work. Linked to Rel-12 TR 22.803 Study on Proximity-based Services (FS_ProSe) and Feature ProSe
- 2743: RP#65 completed. Updated WID RP-130811=>RP-141237. TR 36.873v210 for Approval. Enhance performance with 3D-beamforming or with FD-MIMO. Study new channel modelling in both vertical and horizontal dimensions awa user locations in the network
- 2744: RP#64 completed. Identify potential solutions for energy saving in E-UTRAN non-overlapping scenario. Evaluate possible enhancements in overlapping scenario, so that a subset can be used for further investigation/standardization
- 2745: CD:Thu 11/12/14->Mon 15/12/14; Compl:80%->100%; Stat Rep: RP-141453->RP-141815
- 2746: RP#62 completed. Updated WID RP-130393=>RP-131840
- 2747: RP#63 completed. TR 36.866 (90% complete) for Approval. Started normative work
- 2748: RP#62 completed. Extension of Rel-11 CoMP Operation for LTE Downlink UID_530332)
- 2749: RP#63 completed. Evaluate ability of LTE to meet public safety requirements agreed in SA for GC (GC is a key functionality of Land Mobile Radio/Private Mobile Radio and public safety systems)
- 2750: RP#63 completed
- 2751: RP#64 completed. TR 36.856v100 for 1-step approval. Triggered by SA1 Re-12 TR 22.852 Study on RAN Sharing Enhancements (FS_RSE) and Rel-13 Feature RSE (TS 22.101 Stage 1)
- 2752: RP#59 completed
- 2753: RP#60 completed
- 2754: RP#61 completed (Conclusion: no spin-off WI). Linked to Rel-10 WI on Multi-standard radio Base Station RF requirements for non-contiguous spectrum deployments (MSR_NC) UID_480025
- 2755: RP#62 completed. Evaluate LTE-WLAN/UTRA-WLAN i/w procedures while improving (non-)seamless mobility. Deployed WLAN often under-utilized; User experience suboptimal when UE connects to overloaded WLAN.
- 2756: RP#62 completed. TR 37.852v100 for Information & Approval
- 2757: RP#64 completed. The study of SON features for small cell functionality covered by the Rel-12 small cell enhancement SIs (e.g. dual connectivity) is not in the scope of this study item
- 2758: RP#65 completed. Within EU these bands can be used for terrestrial mobile as a complement to mobile satellite services. Study adding an FDD band into UTRA/E-UTRA in applicable countries of Region 1
- 2759: RP#60 completed (1-step approval). Study new BS spec structure to avoid duplicate work for new RF features (in case of identical features among different RATs); avoid future discussions on how to implement new featurES in CP-150single-RAT/multi-RAT specs
- 2760: RP#61 completed
- 2761: RP#62 completed
- 2762: RP#62 completed. TR 25.701v200 for Approval
- 2763: RP#64 stopped at 85% completion. Follow-up of Rel-12 Study on scalable UMTS FDD bandwidth (FS_UTRA_SCAL). The result is captured in the same TR 25.701
- 2764: RP#61 completed
- 2765: RP#62 completed. TR 25.700v100 for Approval. Identify potential solutions to increase the uplink capacity, coverage and end-user performance (e.g. latency, achievable rates, etc.)
- 2766: RP#63 completed. TR 25.703 v100 for 1-step approval
- 2767: RP#62 completed. TR 25.704v100 for Information & Approval. Study need to add capacity to present SI Broadcast mechanism unchanged since R99
- 2768: -

| ID | WBS | Task | Duration | Start | Finish | Complete | Baseline start | Baseline finish | Baseline duration | Constraint | Resources | Work | Actual work | Acronym | PCG approved | WI rapporteur name | WI rapporteur e-mail | Release | TSG approved | MCC resp | Acronym_3GU_Export | Special Focus Doc | PCG stopped | TSG stopped |
| --- | --- | --- | --- | --- | --- | --- | --- | --- | --- | --- | --- | --- | --- | --- | --- | --- | --- | --- | --- | --- | --- | --- | --- | --- |
| 2769 | 729 | **Advanced IP Interconnection of Services** | 650d? | 2010-03-25 A | 2012-09-12 A | 100% | 2010-03-25 | 2012-09-12 | 650d? |  | S1; S2; C1; C3 | 34381.9h | 34381.9h | IPXS | 24 | Telefónica | chris.friel@O2.com | Rel-11 | 47 | Alain | IPXS |  |  |  |
| 2770 | 729.1 | Stage 1 for Advanced IP Interconnection of Services | 392d | 2010-03-25 A | 2011-09-21 A | 100% | 2010-03-25 | 2011-09-21 | 392d | finish no earlier than 2011-09-21 | S1 | 3120h | 3120h | IPXS | 24 | Telefónica | chris.friel@O2.com | Rel-11 | 47 | Alain |  |  |  |  |
| 2771 | 729.2 | Stage 2 for Advanced IP Interconnection of Services | 263d? | 2010-12-16 A | 2011-12-14 A | 100% | 2010-12-16 | 2011-12-14 | 263d? | finish no earlier than 2012-03-21 | S2 | 2085.91h | 2085.91h | IPXS | 26 | Ericsson | fredrik.lindholm@ericsson.com | Rel-11 | 50 | Maurice |  |  |  |  |
| 2772 | 729.3 | **Stage 3 for Advanced IP Interconnection of Services** | 265d? | 2011-09-13 A | 2012-09-12 A | 100% | 2011-09-13 | 2012-09-12 | 265d? |  | C1; C3 | 8376h | 8376h | IPXS | 27 | Ericsson | christer.holmberg@ericsson.com | Rel-11 | 53 | Frederic |  |  |  |  |
| 2773 | 729.3.1 | CT1 part of Stage 3 for Advanced IP Interconnection of Services | 262d? | 2011-09-16 A | 2012-09-12 A | 100% | 2011-09-16 | 2012-09-12 | 262d? | finish no earlier than 2012-12-07 | C1 | 2048h | 2048h | IPXS | 27 | Ericsson | christer.holmberg@ericsson.com | Rel-11 | 53 | Frederic |  |  |  |  |
| 2774 | 729.3.2 | CT3 part of Stage 3 for Advanced IP Interconnection of Services | 262d? | 2011-09-13 A | 2012-09-07 A | 100% | 2011-09-13 | 2012-09-07 | 262d? | finish no earlier than 2012-09-07 | C3 | 2088h | 2088h | IPXS | 27 | Ericsson | christer.holmberg@ericsson.com | Rel-11 | 53 | Adrian |  |  |  |  |
| 2775 | 730 | **System Improvements to Machine-Type Communications** | 1119d? | 2009-12-10 A | 2014-03-06 A | 100% | 2009-12-10 | 2014-03-06 | 1119d? |  | S1; S2; S5; C1; C3; C4; C6; R2; R3; R5 | 198763h | 198763h | SIMTC | 25 | KPN | toon.norp@tno.nl | Rel-11 | 48 | Alain | SIMTC | MTC, M2M |  |  |
| 2776 | 730.1 | Stage 1 for SIMTC | 337d? | 2010-06-10 A | 2011-09-21 A | 100% | 2010-06-10 | 2011-09-21 | 337d? |  | S1 | 2683.46h | 2683.46h | SIMTC | 25 | KPN | toon.norp@tno.nl | Rel-11 | 48 | Alain |  | MTC, M2M |  |  |
| 2777 | 730.2 | TR on Stage 2 for SIMTC | 593d? | 2010-06-10 A | 2012-09-12 A | 100% | 2010-06-10 | 2012-09-12 | 593d? | finish no earlier than 2012-09-12 | S2 | 4736h | 4736h | SIMTC | 25 | Intel | puneet.jain@intel.com | Rel-11 | 48 | Maurice |  | MTC, M2M |  |  |
| 2778 | 730.3 | **BB1: Stage 2 Reachability Aspects of SIMTC** | 274d? | 2011-06-09 A | 2012-06-20 A | 100% | 2011-06-09 | 2012-06-20 | 274d? |  | S2 | 10773.1h | 10773.1h | SIMTC-Reach | 27 | Intel | puneet.jain@intel.com | Rel-11 | 52 | Maurice | SIMTC-Reach | MTC, M2M |  |  |
| 2779 | 730.3.1 | Deleted - MTC Feature Control (described in TS 22.368, clause 7.1.1 and 23.888, clause 5.7) | 137d? | 2011-06-10 A | 2011-12-14 A | 100% | 2011-06-10 | 2011-12-14 | 137d? | finish no earlier than 2011-11-09 | S2 | 1088h | 1088h | SIMTC-Reach | 27 | Intel | puneet.jain@intel.com | Rel-11 | 52 | Maurice |  | MTC, M2M | PCG-28 | SP-54 |
| 2780 | 730.3.2 | On-line device trigger | 273d? | 2011-06-09 A | 2012-06-20 A | 100% | 2011-06-09 | 2012-06-20 | 273d? | finish no earlier than 2012-06-20 | S2 | 2170.29h | 2170.29h | SIMTC-Reach | 27 | Intel | puneet.jain@intel.com | Rel-11 | 52 | Maurice |  | MTC, M2M |  |  |
| 2781 | 730.3.3 | MTC Addressing | 138d? | 2011-06-09 A | 2011-12-14 A | 100% | 2011-06-09 | 2011-12-14 | 138d? | finish no earlier than 2012-03-21 | S2 | 1097.24h | 1097.24h | SIMTC-Reach | 27 | Intel | puneet.jain@intel.com | Rel-11 | 52 | Maurice |  | MTC, M2M |  |  |
| 2782 | 730.3.4 | Identifiers – especially removal of MSISDN dependencies in the architecture | 273d? | 2011-06-09 A | 2012-06-20 A | 100% | 2011-06-09 | 2012-06-20 | 273d? | finish no earlier than 2012-06-20 | S2 | 2169.53h | 2169.53h | SIMTC-Reach | 27 | Intel | puneet.jain@intel.com | Rel-11 | 52 | Maurice |  | MTC, M2M |  |  |
| 2783 | 730.3.5 | MSISDN-less / PS-Only | 196d? | 2011-06-13 A | 2012-03-07 A | 100% | 2011-06-13 | 2012-03-07 | 196d? | finish no earlier than 2012-03-07 | S2 | 1568h | 1568h | SIMTC-Reach | 27 | Intel | puneet.jain@intel.com | Rel-11 | 52 | Maurice |  | MTC, M2M |  |  |
| 2784 | 730.3.6 | MTC related interfaces and functional entities to support above features (MTCsp, etc.) | 61d? | 2011-12-14 A | 2012-03-07 A | 100% | 2011-12-14 | 2012-03-07 | 61d? | finish no earlier than 2012-03-07 | S2 | 488h | 488h | SIMTC-Reach | 28 | Intel | puneet.jain@intel.com | Rel-11 | 54 | Maurice |  | MTC, M2M |  |  |
| 2785 | 730.4 | **BB1: Stage 3 (CS+PS) Reachability Aspects of SIMTC** | 325d? | 2011-09-19 A | 2012-12-07 A | 100% | 2011-09-19 | 2012-12-07 | 325d? |  | C1; C3; C4; C6 | 19112h | 19112h | SIMTC-ReachCSPS | 27 | Ericsson | mikael.wass@ericsson.com | Rel-11 | 53 | Frederic |  | MTC, M2M |  |  |
| 2786 | 730.4.1 | CT1 part of Stage 3 BB1: Reachability Aspects of SIMTC | 257d? | 2011-09-19 A | 2012-09-07 A | 100% | 2011-09-19 | 2012-09-07 | 257d? | finish no earlier than 2012-09-07 | C1 | 2048h | 2048h | SIMTC-ReachCSPS | 27 | Ericsson | mikael.wass@ericsson.com | Rel-11 | 53 | Frederic |  | MTC, M2M |  |  |
| 2787 | 730.4.2 | CT3 part of Stage 3 BB1: Reachability Aspects of SIMTC | 257d? | 2011-09-19 A | 2012-09-07 A | 100% | 2011-09-19 | 2012-09-07 | 257d? | finish no earlier than 2012-09-07 | C3 | 2048h | 2048h | SIMTC-ReachCSPS | 27 | Ericsson | mikael.wass@ericsson.com | Rel-11 | 53 | Adrian |  | MTC, M2M |  |  |
| 2788 | 730.4.3 | CT4 part of Stage 3 BB1: Reachability Aspects of SIMTC | 324d? | 2011-09-19 A | 2012-12-07 A | 100% | 2011-09-19 | 2012-12-07 | 324d? | finish no earlier than 2012-12-07 | C4 | 2568h | 2568h | SIMTC-ReachCSPS | 27 | Ericsson | mikael.wass@ericsson.com | Rel-11 | 53 | Kimmo |  | MTC, M2M |  |  |
| 2789 | 730.4.4 | CT6 part of Stage 3 BB1: Reachability Aspects of SIMTC | 257d? | 2011-09-19 A | 2012-09-07 A | 100% | 2011-09-19 | 2012-09-07 | 257d? | finish no earlier than 2012-09-07 | C6 | 2048h | 2048h | SIMTC-ReachCSPS | 27 | ST Ericsson | Andrzej Winiarski | Rel-11 | 53 | Xavier |  | MTC, M2M |  |  |
| 2790 | 730.5 | **Stage 2/3 for CS aspects for SIMTC** | 259d? | 2011-09-16 A | 2012-09-07 A | 100% | 2011-09-16 | 2012-09-07 | 259d? |  | C4; C1; C6 | 16544h | 16544h | SIMTC-CS | 27 | Ericsson | mikael.wass@ericsson.com | Rel-11 | 53 | Kimmo | SIMTC-CS | MTC, M2M |  |  |
| 2791 | 730.5.1 | Deleted - Stage 2 CS aspects for SIMTC | 258d? | 2011-09-16 A | 2012-09-06 A | 100% | 2011-09-16 | 2012-09-06 | 258d? | finish no earlier than 2012-09-07 | C4 | 2056h | 2056h | SIMTC-CS | 27 | Ericsson | mikael.wass@ericsson.com | Rel-11 | 53 | Kimmo |  | MTC, M2M | PCG-29 | CP-57 |
| 2792 | 730.5.2 | **Stage 3 CS aspects for SIMTC** | 259d? | 2011-09-16 A | 2012-09-07 A | 100% | 2011-09-16 | 2012-09-07 | 259d? |  | C1; C6 | 8272h | 8272h | SIMTC-CS | 27 | Ericsson | mikael.wass@ericsson.com | Rel-11 | 53 | Frederic |  | MTC, M2M |  |  |
| 2793 | 730.5.2.1 | CT1 part of Stage 3 CS aspects for SIMTC | 259d? | 2011-09-16 A | 2012-09-07 A | 100% | 2011-09-16 | 2012-09-07 | 259d? | start no earlier than 2011-09-16 | C1 | 2064h | 2064h | SIMTC-CS | 27 | Ericsson | mikael.wass@ericsson.com | Rel-11 | 53 | Frederic |  | MTC, M2M |  |  |
| 2794 | 730.5.2.2 | Deleted - CT6 part of Stage 3 CS aspects for SIMTC | 259d? | 2011-09-16 A | 2012-09-07 A | 100% | 2011-09-16 | 2012-09-07 | 259d? | start no earlier than 2011-09-16 | C6 | 2064h | 2064h | SIMTC-CS | 27 | Ericsson | mikael.wass@ericsson.com | Rel-11 | 53 | Xavier |  | MTC, M2M | PCG-29 | CP-57 |

Notes:
- 2769: CP#58 completed. Triggered by Rel-10 TR 22.893 UID_380083 Study on advanced requirements for IP interconnect (FS_IPXS)
- 2770: SP#53 completed / Impacted TSs and TRs: 22.101, 22.228
- 2771: SP#54 completed / Impacted TSs and TRs: 23.228
- 2772: CP#58 completed / Impacted TSs and TRs: Stage 3
- 2773: CP#58 completed / Impacted TSs and TRs: 24.229
- 2774: CP#57 completed / Impacted TSs and TRs: 29.165
- 2775: SP#58 completed. Updated WID SP-110877=>SP-120848. Enhancements to Rel-10 Feature UID_410031 (NIMTC) based on Rel-11 Study on enhancements to MTC
- 2776: SP#53 completed. SP#57 added MTC definitions in 21.905 / Impacted TSs and TRs: 22.368, 21.905 (MTC definitions)
- 2777: SP#57 completed. TR 23.888v200 for Approval. Was Rel-10 UID_450028 (TR on Stage 2 for NIMTC) / Impacted TSs and TRs: New TR 23.888
- 2778: SP#56 completed. SP#58 updated WID SP-110877=>S3-121111 (SA3 normative work on Security aspects of SIMTC incorporated in SA2 TS 23.682) / Impacted TSs and TRs: 23.221, New 23.368
- 2779: SP#54 work stopped
- 2780: SP#56 completed / Impacted TSs and TRs: New 23.682
- 2781: SP#54 completed / Impacted TSs and TRs: 23.221, New 23.682
- 2782: SP#56 completed / Impacted TSs and TRs: New 23.682
- 2783: SP#55 completed / Impacted TSs and TRs: 23.060, 23.272, New 23.682
- 2784: SP#55 completed / Impacted TSs and TRs: New 23.682
- 2785: 22/01: acronym modified / Impacted TSs and TRs: Stage 3
- 2786: 22/01: acronym modified / Impacted TSs and TRs: 23.040, 24.008, 24.301, 24.341, 24.368
- 2787: 22/01: acronym modified / Impacted TSs and TRs: 29.061, New TS 29.368
- 2788: 22/01: acronym modified / Impacted TSs and TRs: 23.003, 23.008, 29.002, 29.060, 29.230, New TS (29.336, 29.337)
- 2789: 22/01: acronym modified / Impacted TSs and TRs: 31.102
- 2790: CP#57 completed. Updated WID CP-120418=>CP-120617 / Impacted TSs and TRs: Stage 2/3
- 2791: CP#57 stopped / Impacted TSs and TRs: 23.012
- 2792: CP#57 completed / Impacted TSs and TRs: Stage 3
- 2793: CP#57 completed / Impacted TSs and TRs: 24.008, 24.301
- 2794: CP#57 stopped / Impacted TSs and TRs: 31.102

| ID | WBS | Task | Duration | Start | Finish | Complete | Baseline start | Baseline finish | Baseline duration | Constraint | Resources | Work | Actual work | Acronym | PCG approved | WI rapporteur name | WI rapporteur e-mail | Release | TSG approved | MCC resp | Special Focus Doc | Acronym_3GU_Export | Status Report | PCG stopped | TSG stopped |
| --- | --- | --- | --- | --- | --- | --- | --- | --- | --- | --- | --- | --- | --- | --- | --- | --- | --- | --- | --- | --- | --- | --- | --- | --- | --- |
| 2795 | 730.6 | **Stage 2/3 for SMS in MME architecture option and related PS-only service subscription** | 129d? | 2012-06-15 A | 2012-12-07 A | 100% | 2012-06-15 | 2012-12-07 | 129d? |  | C1; C4 | 3560h | 3560h | SIMTC-PS_Only | 29 | Ericsson | mikael.wass@ericsson.com | Rel-11 | 56 | Frederic | MTC, M2M | SIMTC-PS_Only |  |  |  |
| 2796 | 730.6.1 | CT1 part of Stage 2/3 for SMS in MME architecture option and related PS-only service subscription | 62d? | 2012-06-15 A | 2012-09-07 A | 100% | 2012-06-15 | 2012-09-07 | 62d? | finish no earlier than 2012-09-07 | C1 | 488h | 488h | SIMTC-PS_Only | 29 | Ericsson | mikael.wass@ericsson.com | Rel-11 | 56 | Frederic | MTC, M2M |  |  |  |  |
| 2797 | 730.6.2 | CT4 part of Stage 2/3 for SMS in MME architecture option and related PS-only service subscription | 129d? | 2012-06-15 A | 2012-12-07 A | 100% | 2012-06-15 | 2012-12-07 | 129d? | finish no earlier than 2012-12-07 | C4 | 1008h | 1008h | SIMTC-PS_Only | 29 | Ericsson | mikael.wass@ericsson.com | Rel-11 | 56 | Kimmo | MTC, M2M |  |  |  |  |
| 2798 | 730.7 | **RAN overload control for Machine-Type Communications** | 259d? | 2011-09-16 A | 2012-09-07 A | 100% | 2011-09-16 | 2012-09-07 | 259d? |  | R2; R3; C1; C6 | 20178.3h | 20178.3h | SIMTC-RAN_OC | 27 | Huawei | Jeff Gao (gaoyongqiang@huawei.com) | Rel-11 | 53 | Yong-Jun | MTC, M2M | SIMTC-RAN_OC |  |  |  |
| 2799 | 730.7.1 | Core part: RAN overload control for Machine-Type Communications | 258d? | 2011-09-19 A | 2012-09-07 A | 100% | 2011-09-19 | 2012-09-07 | 258d? | finish no earlier than 2012-09-07 | R2; R3 | 4128h | 4128h | SIMTC-RAN_OC-Core | 27 | Huawei | Jeff Gao (gaoyongqiang@huawei.com) | Rel-11 | 53 | Yong-Jun | MTC, M2M | SIMTC-RAN_OC-Core |  |  |  |
| 2800 | 730.7.2 | **Stage 3 (CS+PS) Extended Access Barring for UTRAN and E-UTRAN** | 259d? | 2011-09-16 A | 2012-09-07 A | 100% | 2011-09-16 | 2012-09-07 | 259d? |  | C1; C6 | 7762.29h | 7762.29h | SIMTC-RAN_OC | 27 | Ericsson | mikael.wass@ericsson.com | Rel-11 | 53 | Frederic | MTC, M2M |  |  |  |  |
| 2801 | 730.7.2.1 | CT1 part of Stage 3 Extended Access Barring for UTRAN and E-UTRAN | 198d? | 2011-09-16 A | 2012-06-15 A | 100% | 2011-09-16 | 2012-06-15 | 198d? | finish no earlier than 2012-09-14 | C1 | 1570.29h | 1570.29h | SIMTC-RAN_OC | 27 | Ericsson | mikael.wass@ericsson.com | Rel-11 | 53 | Frederic | MTC, M2M |  |  |  |  |
| 2802 | 730.7.2.2 | CT6 part of Stage 3 Extended Access Barring for UTRAN and E-UTRAN | 257d? | 2011-09-20 A | 2012-09-07 A | 100% | 2011-09-20 | 2012-09-07 | 257d? | finish no earlier than 2012-09-07 | C6 | 2048h | 2048h | SIMTC-RAN_OC | 27 | ST Ericsson | Andrzej Winiarski | Rel-11 | 53 | Xavier | MTC, M2M |  |  |  |  |
| 2803 | 730.8 | Test part: System Improvements for Machine-Type Communications | 130d? | 2013-09-09 A | 2014-03-06 A | 100% | 2013-09-09 | 2014-03-06 | 130d? | finish no earlier than 2014-03-06 | R5 | 1040h | 1040h | SIMTC-UEConTest | 31 | Ericsson | calle.hagenfeldt@ericsson.com | Rel-11 | 61 | Ingbert | MTC, M2M | SIMTC-UEConTest | RP-140075 |  |  |
| 2804 | 730.9 | BB5: Charging of SIMTC (Stage 2/3) | 269d? | 2011-12-07 A | 2012-12-12 A | 100% | 2011-12-07 | 2012-12-12 | 269d? | finish no earlier than 2012-12-12 | S5 | 2144h | 2144h | SIMTC-CH | 28 | Ericsson | patrik.teppo@ericsson.com | Rel-11 | 54 | Mirko | MTC, M2M | SIMTC-CH |  |  |  |
| 2805 | 730.10 | **Deleted - BB2: Stage 2 Signalling Optimizations of SIMTC** | 137d? | 2011-06-10 A | 2011-12-14 A | 100% | 2011-06-10 | 2011-12-14 | 137d? |  | S2 | 5240h | 5240h | SIMTC-Sig | 27 | Intel | puneet.jain@intel.com | Rel-11 | 52 | Maurice | MTC, M2M | SIMTC-Sig |  | PCG-28 | SP-55 |
| 2806 | 730.10.1 | Deleted - Effectively maintain connectivity for a large number of MTC Devices (TS 22.368, 7.1.1) | 137d? | 2011-06-10 A | 2011-12-14 A | 100% | 2011-06-10 | 2011-12-14 | 137d? | finish no earlier than 2011-12-07 | S2 | 1088h | 1088h | SIMTC-Sig | 27 | Intel | puneet.jain@intel.com | Rel-11 | 52 | Maurice | MTC, M2M |  |  | PCG-28 | SP-55 |
| 2807 | 730.10.2 | Deleted - Small Data Transmissions (TS 22.368, 7.2.5) | 137d? | 2011-06-10 A | 2011-12-14 A | 100% | 2011-06-10 | 2011-12-14 | 137d? | finish no earlier than 2011-12-07 | S2 | 1088h | 1088h | SIMTC-Sig | 27 | Intel | puneet.jain@intel.com | Rel-11 | 52 | Maurice | MTC, M2M |  |  | PCG-28 | SP-55 |
| 2808 | 730.10.3 | **Deleted - Stage 3 (CS+PS) Signalling Optimizations of SIMTC** | 62d? | 2011-09-16 A | 2011-12-09 A | 100% | 2011-09-16 | 2011-12-09 | 62d? |  | C1; C6 | 1968h | 1968h | SIMTC-Sig | 27 | Ericsson | mikael.wass@ericsson.com | Rel-11 | 53 | Frederic | MTC, M2M |  |  | PCG-28 | CP-55 |
| 2809 | 730.10.3.1 | Deleted - CT1 part of Stage 3 Signalling Optimizations of SIMTC | 62d? | 2011-09-16 A | 2011-12-09 A | 100% | 2011-09-16 | 2011-12-09 | 62d? | finish no earlier than 2011-12-02 | C1 | 488h | 488h | SIMTC-Sig | 27 | Ericsson | mikael.wass@ericsson.com | Rel-11 | 53 | Frederic | MTC, M2M |  |  | PCG-28 | CP-55 |
| 2810 | 730.10.3.2 | Deleted - CT6 part of Stage 3 Signalling Optimizations of SIMTC | 62d? | 2011-09-16 A | 2011-12-09 A | 100% | 2011-09-16 | 2011-12-09 | 62d? | finish no earlier than 2011-12-02 | C6 | 488h | 488h | SIMTC-Sig | 27 | ST Ericsson | Andrzej Winiarski | Rel-11 | 53 | Xavier | MTC, M2M |  |  | PCG-28 | CP-55 |
| 2811 | 730.11 | **Deleted - BB3: Stage 2 CN-based requirements and Power Considerations of SIMTC** | 139d? | 2011-06-08 A | 2011-12-14 A | 100% | 2011-06-08 | 2011-12-14 | 139d? |  | S2 | 6360h | 6360h | SIMTC-CN_Pow | 27 | Intel | puneet.jain@intel.com | Rel-11 | 52 | Maurice | MTC, M2M | SIMTC-CN_Pow |  | PCG-28 | SP-55 |
| 2812 | 730.11.1 | Deleted - Charging Requirements (TS 22.368, 7.1.5) | 137d? | 2011-06-10 A | 2011-12-14 A | 100% | 2011-06-10 | 2011-12-14 | 137d? | finish no earlier than 2012-03-21 | S2 | 1088h | 1088h | SIMTC-CN_Pow | 27 | Intel | puneet.jain@intel.com | Rel-11 | 52 | Maurice | MTC, M2M |  |  | PCG-28 | SP-55 |
| 2813 | 730.11.2 | Deleted - Lower Power Consumption (TS 22.368, 7.1.1) | 137d? | 2011-06-10 A | 2011-12-14 A | 100% | 2011-06-10 | 2011-12-14 | 137d? | finish no earlier than 2011-12-07 | S2 | 1088h | 1088h | SIMTC-CN_Pow | 27 | Intel | puneet.jain@intel.com | Rel-11 | 52 | Maurice | MTC, M2M |  |  | PCG-28 | SP-55 |
| 2814 | 730.11.3 | Deleted - MTC Monitoring (TS 22.368, 7.2.8) | 139d? | 2011-06-08 A | 2011-12-14 A | 100% | 2011-06-08 | 2011-12-14 | 139d? | finish no earlier than 2011-12-07 | S2 | 1104h | 1104h | SIMTC-CN_Pow | 27 | Intel | puneet.jain@intel.com | Rel-11 | 52 | Maurice | MTC, M2M |  |  | PCG-28 | SP-55 |
| 2815 | 730.11.4 | **Deleted - Stage 3 (CS+PS) CN-based requirements and Power Considerations of SIMTC** | 62d? | 2011-09-16 A | 2011-12-09 A | 100% | 2011-09-16 | 2011-12-09 | 62d? |  | C1; C6 | 1968h | 1968h | SIMTC-CN_Pow | 27 | Ericsson | mikael.wass@ericsson.com | Rel-11 | 53 | Frederic | MTC, M2M |  |  | PCG-28 | CP-55 |
| 2816 | 730.11.4.1 | Deleted - CT1 part of Stage 3 CN-based requirements and Power Considerations of SIMTC | 62d? | 2011-09-16 A | 2011-12-09 A | 100% | 2011-09-16 | 2011-12-09 | 62d? | finish no earlier than 2011-12-02 | C1 | 488h | 488h | SIMTC-CN_Pow | 27 | Ericsson | mikael.wass@ericsson.com | Rel-11 | 53 | Frederic | MTC, M2M |  |  | PCG-28 | CP-55 |
| 2817 | 730.11.4.2 | Deleted - CT6 part of Stage 3 CN-based requirements and Power Considerations of SIMTC | 62d? | 2011-09-16 A | 2011-12-09 A | 100% | 2011-09-16 | 2011-12-09 | 62d? | finish no earlier than 2011-12-02 | C6 | 488h | 488h | SIMTC-CN_Pow | 27 | ST Ericsson | Andrzej Winiarski | Rel-11 | 53 | Xavier | MTC, M2M |  |  | PCG-28 | CP-55 |
| 2818 | 730.12 | Deleted - TR on Security aspects of Machine-Type Communications | 662d? | 2009-12-10 A | 2012-06-20 A | 100% | 2009-12-10 | 2012-06-20 | 662d? | finish no earlier than 2012-06-20 | S3 | 5288h | 5288h |  | 25 | Samsung | Rajavelsamy R (rajvel@samsung.com) | Rel-11 | 49 | Mirko | MTC, M2M |  |  | PCG-29 | SP-56 |

Notes:
- 2795: CP#58 completed / Impacted TSs and TRs: Stage 2/3
- 2796: CP#57 completed / Impacted TSs and TRs: 23.040, 24.008, 24.011, 24.301, 29.018, 29.118
- 2797: CP#58 completed. TS 29.338 v200 for Approval / Impacted TSs and TRs: 23.003, 23.008, 23.012, 29.002, 29.272, 29.305, New TS 29.338
- 2798: Stage 2,3. TSG#57 completed / Impacted TSs and TRs: UTRA, LTE
- 2799: RP#57 completed / Impacted TSs and TRs: 25.304, 25.331, 25.413, 36.304, 36.331, 36.413
- 2800: CP#57 completed. Updated WID CP-120418=>CP-120617 / Impacted TSs and TRs: Stage 3
- 2801: CP#56 completed / Impacted TSs and TRs: 23.122, 24.008, 24.301
- 2802: CP#57 completed / Impacted TSs and TRs: 31.102
- 2803: RP#63 completed. Updated WID RP-131341=>RP-140077 (added affected TS 36.508). Testing for core part: SIMTC-Reach, SIMTC-CS, SIMTC-PS_Only, SIMTC-RAN_OC / Impacted TSs and TRs: 34.123-1, 34.123-2, 34.123-3, 36.508, 36.523-1, 36.523-2, 36.523-3
- 2804: SP#58 completed / Impacted TSs and TRs: 32.240, 32.251, 32.298, 32.299
- 2805: SP#54 work stopped. SP#58 updated WID SP-110877=>SP-120848 / Impacted TSs and TRs: TBD
- 2806: SP#54 work stopped / Impacted TSs and TRs: TBD
- 2807: SP#54 work stopped / Impacted TSs and TRs: TBD
- 2808: CP#54 work stopped / Impacted TSs and TRs: Stage 3
- 2809: - / Impacted TSs and TRs: 23.122, 24.008, 24.301, 24.368
- 2810: - / Impacted TSs and TRs: 31.102
- 2811: SP#54 work stopped / Impacted TSs and TRs: TBD
- 2812: SP#54 work stopped / Impacted TSs and TRs: TBD
- 2813: SP#54 work stopped / Impacted TSs and TRs: TBD
- 2814: SP#54 work stopped / Impacted TSs and TRs: TBD
- 2815: CP#54 work stopped / Impacted TSs and TRs: Stage 3
- 2816: - / Impacted TSs and TRs: 23.122, 24.008, 24.301, 24.368
- 2817: - / Impacted TSs and TRs: 31.101, 31.102
- 2818: Was Rel-10 UID_460023 (Security for NIMTC). SP#56 stopped (activity transferred to Rel-12 Feature MTCe under UID_560722). / Impacted TSs and TRs: New TR 33.868

| ID | WBS | Task | Type | Duration | Start | Finish | Complete | Baseline start | Baseline finish | Baseline duration | Constraint | Resources | Work | Actual work | Acronym | PCG approved | Impacted TSs and TRs | WI rapporteur name | Release | TSG approved | MCC resp | PCG stopped | TSG stopped | Special Focus Doc | Acronym_3GU_Export |
| --- | --- | --- | --- | --- | --- | --- | --- | --- | --- | --- | --- | --- | --- | --- | --- | --- | --- | --- | --- | --- | --- | --- | --- | --- | --- |
| 2819 | 730.13 | **Deleted - BB4: Secure Connection and Privacy of SIMTC** |  | 336d? | 2011-06-08 A | 2012-09-12 A | 100% | 2011-06-08 | 2012-09-12 | 336d? |  | S3 | 7424h | 7424h | SIMTC-Sec | 27 | TBD | Samsung | Rel-11 | 52 | Mirko | PCG-29 | CP-57 | MTC, M2M | SIMTC-Sec |
| 2820 | 730.13.1 | Deleted - Secure Connection MTC Feature (TS 22.368, 7.2.10) |  | 333d? | 2011-06-08 A | 2012-09-12 A | 100% | 2011-06-08 | 2012-09-12 | 333d? | finish no earlier than 2012-09-12 | S3 | 2656h | 2656h | SIMTC-Sec | 27 | TBD | Samsung | Rel-11 | 52 | Mirko | PCG-29 | CP-57 | MTC, M2M |  |
| 2821 | 730.13.2 | Deleted - MTC Location Privacy |  | 261d? | 2011-09-19 A | 2012-09-12 A | 100% | 2011-09-19 | 2012-09-12 | 261d? | finish no earlier than 2012-09-12 | S3 | 2080h | 2080h | SIMTC-Priv | 27 | TBD | Samsung | Rel-11 | 53 | Mirko | PCG-29 | CP-57 | MTC, M2M | SIMTC-Priv |
| 2822 | 730.14 | Deleted - Stage 2 on SA2 part for System Improvements to Machine-Type Communications |  | 260d? | 2010-06-10 A | 2011-06-08 A | 100% | 2010-06-10 | 2011-06-08 | 260d? | finish no earlier than 2011-06-08 | S2 | 2080h | 2080h | SIMTC | 25 | TBD | Intel | Rel-11 | 48 | Maurice | PCG-27 | SP-52 | MTC, M2M |  |
| 2823 | 730.15 | Deleted - Stage 2 on Security part for System Improvements to Machine-Type Communications |  | 260d? | 2010-06-10 A | 2011-06-08 A | 100% | 2010-06-10 | 2011-06-08 | 260d? | finish no earlier than 2011-06-08 | S3 | 2080h | 2080h | SIMTC | 25 | TBD | Samsung | Rel-11 | 48 | Mirko | PCG-27 | SP-52 | MTC, M2M |  |
| 2824 | 731 | **Unstructured Supplementary Service Data (USSD) simulation service in IMS** |  | 659d? | 2010-06-10 A | 2012-12-07 A | 100% | 2010-06-10 | 2012-12-07 | 659d? |  | S1; C1; C3 | 28112.1h | 28112.1h | USSI | 25 |  | Deutsche Telekom | Rel-11 | 48 | Alain |  |  |  | USSI |
| 2825 | 731.1 | Stage 1 for USSD simulation service in IMS | milestone | 0d? | 2010-06-10 A | 2010-06-10 A | 100% | 2010-06-10 | 2010-06-10 | 0d? | finish no earlier than 2010-06-10 | S1 |  |  | USSI | 25 | 22.173 | Deutsche Telekom | Rel-11 | 48 | Alain |  |  |  |  |
| 2826 | 731.2 | **Stage 3 for USSD simulation service in IMS** |  | 403d? | 2011-06-03 A | 2012-12-07 A | 100% | 2011-06-03 | 2012-12-07 | 403d? |  | C1; C3 | 12296.1h | 12296.1h | USSI | 27 |  | Deutsche Telekom | Rel-11 | 52 | Frederic |  |  |  |  |
| 2827 | 731.2.1 | CT1 part of Stage 3 for USSD simulation service in IMS |  | 402d? | 2011-06-03 A | 2012-12-07 A | 100% | 2011-06-03 | 2012-12-07 | 402d? | finish no earlier than 2012-12-07 | C1 | 3184.06h | 3184.06h | USSI | 27 | 24.173, 24.229, new TS 24.390 | Deutsche Telekom | Rel-11 | 52 | Frederic |  |  |  |  |
| 2828 | 731.2.2 | CT3 part of Stage 3 for USSD simulation service in IMS |  | 334d? | 2011-06-07 A | 2012-09-07 A | 100% | 2011-06-07 | 2012-09-07 | 334d? | finish no earlier than 2012-09-07 | C3 | 2664h | 2664h | USSI | 27 | 29.165 | Deutsche Telekom | Rel-11 | 52 | Adrian |  |  |  |  |
| 2829 | 732 | **QoS Control Based on Subscriber Spending Limits** |  | 459d? | 2010-09-23 A | 2012-06-20 A | 100% | 2010-09-23 | 2012-06-20 | 459d? |  | S1; S2; S5; C3 | 23152h | 23152h | QoS_SSL | 25 |  | Vodafone | Rel-11 | 49 | Alain |  |  |  | QoS_SSL |
| 2830 | 732.1 | Stage 1 for QoS Control Based on Subscriber Spending Limits |  | 262d? | 2010-09-23 A | 2011-09-21 A | 100% | 2010-09-23 | 2011-09-21 | 262d? | finish no earlier than 2011-09-21 | S1 | 2080h | 2080h | QoS_SSL | 25 | 22.115 | Vodafone | Rel-11 | 49 | Alain |  |  |  |  |
| 2831 | 732.2 | Stage 2 for QoS Control Based on Subscriber Spending Limits |  | 133d? | 2011-03-23 A | 2011-09-21 A | 100% | 2011-03-23 | 2011-09-21 | 133d? | finish no earlier than 2011-12-14 | S2 | 1048h | 1048h | QoS_SSL | 26 | 23.203 | Huawei | Rel-11 | 51 | Maurice |  |  |  |  |
| 2832 | 732.3 | Charging for QoS Control Based on Subscriber Spending Limits (Stage 2) |  | 397d? | 2010-12-16 A | 2012-06-20 A | 100% | 2010-12-16 | 2012-06-20 | 397d? | finish no earlier than 2012-06-20 | S5 | 3168h | 3168h | QoS_SSL | 26 | 32.240, 32.296 | Nokia Siemens Networks, Huawei | Rel-11 | 50 | Mirko |  |  |  |  |
| 2833 | 732.4 | CT3 aspects of QoS Control Based on Subscriber Spending Limits (Stage 3) |  | 273d? | 2011-06-03 A | 2012-06-15 A | 100% | 2011-06-03 | 2012-06-15 | 273d? | finish no earlier than 2012-06-15 | C3 | 2168h | 2168h | QoS_SSL-CT3 | 27 | 29.212, 29.213, 29.214, 29.215, new TS 29.219 | Huawei | Rel-11 | 52 | Adrian |  |  |  | QoS_SSL-CT3 |
| 2834 | 733 | **Optimized Service Charging and Allocation of Resources in IMS whilst Roaming** |  | 383d? | 2010-09-23 A | 2012-03-07 A | 100% | 2010-09-23 | 2012-03-07 | 383d? |  | S1; S2 | 14288h | 14288h | OSCAR | 25 |  | Vodafone | Rel-11 | 49 | Alain |  |  |  | OSCAR |
| 2835 | 733.1 | TR on Stage 2 aspects of Optimized Service Charging and Allocation of Resources in IMS whilst Roaming |  | 383d? | 2010-09-23 A | 2012-03-07 A | 100% | 2010-09-23 | 2012-03-07 | 383d? | finish no earlier than 2011-12-07 | S2 | 3040h | 3040h | OSCAR | 25 | new TR 23.849 | Vodafone | Rel-11 | 49 | Maurice |  |  |  |  |
| 2836 | 733.2 | Stage 1 for Optimized Service Charging and Allocation of Resources in IMS whilst Roaming |  | 262d? | 2010-09-23 A | 2011-09-21 A | 100% | 2010-09-23 | 2011-09-21 | 262d? | finish no earlier than 2011-09-21 | S1 | 2080h | 2080h | OSCAR | 25 | 22.115, 22.173, 22.228 | Vodafone | Rel-11 | 49 | Alain |  |  |  |  |
| 2837 | 733.3 | Deleted - Stage 2 for Optimized Service Charging and Allocation of Resources in IMS whilst Roaming |  | 380d? | 2010-09-28 A | 2012-03-07 A | 100% | 2010-09-28 | 2012-03-07 | 380d? | finish no earlier than 2012-03-07 | S2 | 3040h | 3040h | OSCAR | 25 | None | Vodafone | Rel-11 | 49 | Maurice | PCG-28 | SP-55 |  |  |
| 2838 | 734 | **Inclusion of Media Resource Broker (Stage 2/3)** |  | 463d? | 2011-09-16 A | 2013-06-14 A | 100% | 2011-09-16 | 2013-06-14 | 463d? |  | C1; C3; IETF | 30500h | 30500h | MRB | 27 | Stage 2/3 | AT&T | Rel-11 | 53 | Frederic |  |  |  | MRB |
| 2839 | 734.1 | Stage 2 for Inclusion of Media Resource Broker |  | 259d? | 2011-09-16 A | 2012-09-07 A | 100% | 2011-09-16 | 2012-09-07 | 259d? | finish no earlier than 2012-09-07 | C1 | 2049.98h | 2049.98h | MRB | 27 | 23.218 | AT&T | Rel-11 | 53 | Frederic |  |  |  |  |
| 2840 | 734.2 | **Stage 3 for Inclusion of Media Resource Broker** |  | 463d? | 2011-09-16 A | 2013-06-14 A | 100% | 2011-09-16 | 2013-06-14 | 463d? |  | C1; C3; IETF | 17338h | 17338h | MRB | 27 |  | AT&T | Rel-11 | 53 | Frederic |  |  |  |  |
| 2841 | 734.2.1 | CT1 part of Stage 3 for Inclusion of Media Resource Broker |  | 258d? | 2011-09-16 A | 2012-09-07 A | 100% | 2011-09-16 | 2012-09-07 | 258d? | finish no earlier than 2012-09-07 | C1 | 2049.98h | 2049.98h | MRB | 27 | 24.229, 29.165 | AT&T | Rel-11 | 53 | Frederic |  |  |  |  |
| 2842 | 734.2.2 | (IETF) Inclusion of Media Resource Broker [RFC 6917 (was draft-ietf-mediactrl-mrb)] |  | 462d? | 2011-09-16 A | 2013-06-14 A | 100% | 2011-09-16 | 2013-06-14 | 462d? | finish no earlier than 2013-06-14 | C1-IETF | 3688h | 3688h | MRB | 27 | RFC 6917 (was draft-ietf-mediactrl-mrb) | Keith Drage | Rel-11 | 53 | Frederic |  |  |  |  |
| 2843 | 734.2.3 | CT3 part of Stage 3 for Inclusion of Media Resource Broker |  | 62d? | 2012-06-15 A | 2012-09-07 A | 100% | 2012-06-15 | 2012-09-07 | 62d? | finish no earlier than 2012-09-07 | C3 | 488h | 488h | MRB | 29 | 29.165 | AT&T | Rel-11 | 56 | Adrian |  |  |  |  |

Notes:
- 2819: SP#57 stopped (activity transferred to Rel-12 Feature MTCe under UID_560522) / WI rapporteur e-mail: Rajavelsamy R (rajvel@samsung.com)
- 2820: SP#57 stopped (activity transferred to Rel-12 Feature MTCe / WI rapporteur e-mail: Rajavelsamy R (rajvel@samsung.com)
- 2821: SP#57 stopped (activity transferred to Rel-12 Feature MTCe / WI rapporteur e-mail: Rajavelsamy R (rajvel@samsung.com)
- 2822: SP#52 stopped / WI rapporteur e-mail: puneet.jain@intel.com
- 2823: SP#52 stopped / WI rapporteur e-mail: Rajavelsamy R (rajvel@samsung.com)
- 2824: CP#58 completed / WI rapporteur e-mail: kurt.bischinger@t-mobile.at
- 2825: SP#48 completed. Specify a CS domain USSD like service over IMS (see GSM Mobile User Initiated USSD) / WI rapporteur e-mail: kurt.bischinger@t-mobile.at
- 2826: SP#58 completed. No stage 2 impact, as reuse existing IMS architecture in TS 23.228 / WI rapporteur e-mail: reinhard.lauster@t-mobile.at
- 2827: CP#58 completed / WI rapporteur e-mail: reinhard.lauster@t-mobile.at, TS 24.390 Rapp: lili.yang@huawei.com
- 2828: CP#57 completed / WI rapporteur e-mail: reinhard.lauster@t-mobile.at
- 2829: TSG#56 completed / WI rapporteur e-mail: mona.mustapha@vodafone.com
- 2830: SP#53 completed. Use cases & service requirements to allow: 1) modification of QoS based on subscribers spending limits 2) enforcing of spending limits for roaming subscribers without having dedicated support in the visited network / WI rapporteur e-mail: mona.mustapha@vodafone.com
- 2831: SP#53 completed / WI rapporteur e-mail: Xu Xia (xiatony@huawei.com)
- 2832: SP#56 completed / WI rapporteur e-mail: Gerald.Goermer@nsn.com, shan.mingjun@huawei.com
- 2833: CP#56 completed / WI rapporteur e-mail: QiaoWeihua@huawei.com
- 2834: SP#55 completed (Stage 2/3 specified under CT1 Rel-11 Feature MRB (Inclusion of Media Resource Broker) UID_530021. Triggered by S1-102236/GSMA RILTE 10_007r1 (IREG LS_038 to 3GPP on Optimal Media Routing drawbacks) / WI rapporteur e-mail: mona.mustapha@vodafone.com
- 2835: SP#55 completed / WI rapporteur e-mail: Susana.Sabater@vodafone.com
- 2836: SP#53 completed / WI rapporteur e-mail: mona.mustapha@vodafone.com
- 2837: SP#55 no normative work in SA2. Stage 2/3 to be done in under CT1 Rel-11 Feature MRB (Inclusion of Media Resource Broker) UID_530021 / WI rapporteur e-mail: Susana.Sabater@vodafone.com
- 2838: Stage 1 and TR on Stage 2 in Rel-11 Feature OSCAR UID_490032 / WI rapporteur e-mail: Martin Dolly (md3135@att.com)
- 2839: CP#57 completed / WI rapporteur e-mail: Martin Dolly (md3135@att.com)
- 2840: CP#60 completed / WI rapporteur e-mail: Martin Dolly (md3135@att.com)
- 2841: CP#57 completed / WI rapporteur e-mail: Martin Dolly (md3135@att.com)
- 2842: CP#60 completed
- 2843: CP#57 completed / WI rapporteur e-mail: Martin Dolly (md3135@att.com)

| ID | WBS | Task | Duration | Start | Finish | Complete | Baseline start | Baseline finish | Baseline duration | Constraint | Resources | Work | Actual work | Acronym | PCG approved | WI rapporteur name | WI rapporteur e-mail | Release | TSG approved | MCC resp | Acronym_3GU_Export | Special Focus Doc | PCG stopped | TSG stopped |
| --- | --- | --- | --- | --- | --- | --- | --- | --- | --- | --- | --- | --- | --- | --- | --- | --- | --- | --- | --- | --- | --- | --- | --- | --- |
| 2844 | 735 | **Non Voice Emergency Services** | 323d? | 2010-12-16 A | 2012-03-07 A | 100% | 2010-12-16 | 2012-03-07 | 323d? |  | S1; S2 | 7736h | 7736h | NOVES | 26 | Qualcomm | dwilliams@qualcomm.com | Rel-11 | 50 | Alain | NOVES |  |  |  |
| 2845 | 735.1 | Stage 1 for Non Voice Emergency Services | 202d? | 2010-12-16 A | 2011-09-21 A | 100% | 2010-12-16 | 2011-09-21 | 202d? | finish no earlier than 2011-09-21 | S1 | 1600h | 1600h | NOVES | 26 | Qualcomm | dwilliams@qualcomm.com | Rel-11 | 50 | Alain |  |  |  |  |
| 2846 | 735.2 | Stage 2 for Non Voice Emergency Services (Support of IMS Emergency Sessions with Other Media on UTRAN and E-UTRAN) | 121d? | 2011-09-22 A | 2012-03-07 A | 100% | 2011-09-22 | 2012-03-07 | 121d? | finish no earlier than 2012-03-07 | S2 | 968h | 968h | NOVES-IMSESOM | 27 | Alcatel-Lucent | Deb.Barclay@alcatel-lucent.com | Rel-11 | 53 | Maurice | NOVES-IMSESOM |  |  |  |
| 2847 | 736 | **Support for 3GPP Voice Interworking with Enterprise IP-PBX** | 516d? | 2011-03-23 A | 2013-03-01 A | 100% | 2011-03-23 | 2013-03-01 | 516d? |  | S1; C1 | 12376h | 12376h | VINE | 26 | Tatara Systems | Phillip Brown (pbrown@tatarasystems.com) | Rel-11 | 51 | Alain | VINE |  |  |  |
| 2848 | 736.1 | Stage 1 for Support for 3GPP Voice Interworking with Enterprise IP-PBX | 133d? | 2011-03-23 A | 2011-09-21 A | 100% | 2011-03-23 | 2011-09-21 | 133d? | finish no earlier than 2011-09-21 | S1 | 1048h | 1048h | VINE | 26 | Tatara Systems | Phillip Brown (pbrown@tatarasystems.com) | Rel-11 | 51 | Alain |  |  |  |  |
| 2849 | 736.2 | Stage 2/3 for Support for 3GPP Voice Interworking with Enterprise IP-PBX | 385d? | 2011-09-20 A | 2013-03-01 A | 100% | 2011-09-20 | 2013-03-01 | 385d? | finish no earlier than 2013-03-01 | C1 | 3072h | 3072h | VINE-CT1 | 27 | Alcatel-Lucent | keith.drage@alcatel-lucent.com | Rel-11 | 53 | Frederic | VINE-CT1 |  |  |  |
| 2850 | 737 | **Anonymous Call Rejection in the CS domain** | 132d? | 2011-06-07 A | 2011-12-02 A | 100% | 2011-06-07 | 2011-12-02 | 132d? |  | S1; C4; C3 | 4616h | 4616h | ACR_CS | 27 | Alcatel-Lucent | Betsy.Covell@alcatel-lucent.com | Rel-11 | 52 | Alain | ACR_CS |  |  |  |
| 2851 | 737.1 | Stage 1 for Anonymous Call Rejection in the CS domain | 2d? | 2011-06-07 A | 2011-06-08 A | 100% | 2011-06-07 | 2011-06-08 | 2d? | finish no earlier than 2011-06-07 | S1 | 16h | 16h | ACR_CS | 27 | Alcatel-Lucent | Betsy.Covell@alcatel-lucent.com | Rel-11 | 52 | Alain |  |  |  |  |
| 2852 | 737.2 | **Core Network aspects of Anonymous Call Rejection in the CS domain** | 59d? | 2011-09-14 A | 2011-12-02 A | 100% | 2011-09-14 | 2011-12-02 | 59d? |  | C4; C3 | 1432h | 1432h | ACR_CS-CN | 27 | Alcatel-Lucent | bruno.landais@alcatel-lucent.com | Rel-11 | 53 | Kimmo | ACR_CS-CN |  |  |  |
| 2853 | 737.2.1 | CT4 part of Core Network aspects of Anonymous Call Rejection in the CS domain (Stage 2/3) | 59d? | 2011-09-14 A | 2011-12-02 A | 100% | 2011-09-14 | 2011-12-02 | 59d? | finish no earlier than 2011-12-02 | C4 | 464h | 464h | ACR_CS-CN | 27 | Alcatel-Lucent | bruno.landais@alcatel-lucent.com | Rel-11 | 53 | Kimmo |  |  |  |  |
| 2854 | 737.2.2 | CT3 part of Core Network aspects of Anonymous Call Rejection in the CS domain (Stage 3) | 3d? | 2011-09-14 A | 2011-09-16 A | 100% | 2011-09-14 | 2011-09-16 | 3d? | start no earlier than 2011-09-14 | C3 | 24h | 24h | ACR_CS-CN | 27 | Alcatel-Lucent | bruno.landais@alcatel-lucent.com | Rel-11 | 53 | Adrian |  |  |  |  |
| 2855 | 738 | **Support for BroadBand Forum Accesses Interworking** | 792d? | 2009-12-10 A | 2012-12-12 A | 100% | 2009-12-10 | 2012-12-12 | 792d? |  | S2; S1; C1; C3; C4; IETF | 97983.8h | 97983.8h | BBAI | 24 | Ericsson | peter.bleckert@ericsson.com | Rel-11 | 46 | Alain | BBAI | HNB, WLAN |  |  |
| 2856 | 738.1 | Stage 1 BB I: BBF interworking with home routed traffic for WLAN and H(e)NB | 76d? | 2009-12-10 A | 2010-03-25 A | 100% | 2009-12-10 | 2010-03-25 | 76d? | start no earlier than 2009-12-10 | S1 | 608h | 608h | BBAI | 24 | Ericsson | Olle.Eriksson@ericsson.com | Rel-11 | 46 | Alain |  | HNB, WLAN |  |  |
| 2857 | 738.2 | TR on Stage 2 for BBAI | 588d? | 2010-03-26 A | 2012-06-20 A | 100% | 2010-03-26 | 2012-06-20 | 588d? | finish no earlier than 2012-06-19 | S2 | 4704h | 4704h | BBAI | 24 | Ericsson | marco.spini@huawei.com | Rel-11 | 47 | Maurice |  | HNB, WLAN |  |  |
| 2858 | 738.3 | Stage 2 BB I: BBF interworking with home routed traffic for WLAN and H(e)NB | 588d? | 2010-03-26 A | 2012-06-20 A | 100% | 2010-03-26 | 2012-06-20 | 588d? | finish no earlier than 2012-06-20 | S2 | 4688.06h | 4688.06h | BBAI | 24 | Ericsson | stefan.rommer@ericsson.com | Rel-11 | 47 | Maurice |  | HNB, WLAN |  |  |
| 2859 | 738.4 | (IETF) Stage 2 BB I: BBF interworking with home routed traffic for WLAN and H(e)NB | 266d? | 2011-12-12 A | 2012-12-12 A | 100% | 2011-12-12 | 2012-12-12 | 266d? | finish no earlier than 2012-11-24 | S2-IETF | 2119.59h | 2119.59h | BBAI | 28 | Lionel Morand | Lionel Morand | Rel-11 | 54 | Maurice |  | HNB, WLAN |  |  |
| 2860 | 738.5 | **Stage 3 BB I - Core Network impacts: BBF interworking with home routed traffic for WLAN and H(e)NB** | 326d? | 2011-09-16 A | 2012-12-07 A | 100% | 2011-09-16 | 2012-12-07 | 326d? |  | C1; C3; C4 | 17288.2h | 17288.2h | BBAI_BBI-CT | 27 | Ericsson | Zu.Qiang@Ericsson.com | Rel-11 | 53 | Frederic | BBAI_BBI-CT | HNB, WLAN |  |  |
| 2861 | 738.5.1 | TR on Stage 3 BB I for BBAI; UE to network protocols | 198d? | 2011-09-16 A | 2012-06-15 A | 100% | 2011-09-16 | 2012-06-15 | 198d? | finish no earlier than 2012-06-15 | C1 | 1568.15h | 1568.15h | BBAI_BBI-CT | 27 | Ericsson | Zu.Qiang@Ericsson.com | Rel-11 | 53 | Frederic |  | HNB, WLAN |  |  |
| 2862 | 738.5.2 | TR on Stage 3 BB I for BBAI; Home (e)Node B – Security Gateway Interface | 77d? | 2012-03-02 A | 2012-06-15 A | 100% | 2012-03-02 | 2012-06-15 | 77d? | finish no earlier than 2012-06-01 | C4 | 608h | 608h | BBAI_BBI-CT | 28 | Ericsson | Zu.Qiang@Ericsson.com | Rel-11 | 55 | Kimmo |  | HNB, WLAN |  |  |
| 2863 | 738.5.3 | Deleted - (IETF) on Stage 3 BB I for BBAI; Home (e)Node B – Security Gateway Interface | 77d? | 2012-03-02 A | 2012-06-15 A | 100% | 2012-03-02 | 2012-06-15 | 77d? | finish no earlier than 2012-06-15 | C4-IETF | 616h | 616h | BBAI_BBI-CT | 28 | Lionel Morand |  | Rel-11 | 55 | Kimmo |  | HNB, WLAN | PCG-29 | CP-56 |
| 2864 | 738.5.4 | CT1 part of Stage 3 BB I: BBF interworking with home routed traffic for WLAN and H(e)NB | 258d? | 2011-09-16 A | 2012-09-07 A | 100% | 2011-09-16 | 2012-09-07 | 258d? | finish no earlier than 2012-09-07 | C1 | 2048h | 2048h | BBAI_BBI-CT | 27 | Ericsson | Zu.Qiang@Ericsson.com | Rel-11 | 53 | Frederic |  | HNB, WLAN |  |  |
| 2865 | 738.5.5 | CT3 part of Stage 3 BB I: BBF interworking with home routed traffic for WLAN and H(e)NB | 259d? | 2011-09-16 A | 2012-09-07 A | 100% | 2011-09-16 | 2012-09-07 | 259d? | finish no earlier than 2012-09-07 | C3 | 2048h | 2048h | BBAI_BBI-CT | 27 | Ericsson | Zu.Qiang@Ericsson.com | Rel-11 | 53 | Adrian |  | HNB, WLAN |  |  |
| 2866 | 738.5.6 | CT4 part of Stage 3 BB I: BBF interworking with home routed traffic for WLAN and H(e)NB | 326d? | 2011-09-16 A | 2012-12-07 A | 100% | 2011-09-16 | 2012-12-07 | 326d? | finish no earlier than 2012-12-07 | C4 | 2576h | 2576h | BBAI_BBI-CT | 27 | Ericsson | Zu.Qiang@Ericsson.com | Rel-11 | 53 | Kimmo |  | HNB, WLAN |  |  |
| 2867 | 738.6 | Stage 1 BB II: BBF interworking with offload in access network for WLAN and for H(e)NB | 262d? | 2010-09-23 A | 2011-09-21 A | 100% | 2010-09-23 | 2011-09-21 | 262d? | finish no earlier than 2011-09-21 | S1 | 2080h | 2080h | BBAI_BBII-CTofldS1 | 25 | Ericsson | Olle.Eriksson@ericsson.com | Rel-11 | 49 | Alain |  | HNB, WLAN |  |  |
| 2868 | 738.7 | Stage 2 BB II: BBF interworking with offload in access network for WLAN and for H(e)NB | 455d? | 2010-09-28 A | 2012-06-20 A | 100% | 2010-09-28 | 2012-06-20 | 455d? | finish no earlier than 2012-06-20 | S2 | 3640h | 3640h | BBAI_BBII-CTofldS2 | 24 | Ericsson | stefan.rommer@ericsson.com | Rel-11 | 47 | Maurice |  | HNB, WLAN |  |  |

Notes:
- 2844: SP#55 Stage 2 completed. Triggered by SA1 Rel-11 TR 22.871 Study on Non Voice Emergency Services (FS_NOVES)
- 2845: SP#53 completed / Impacted TSs and TRs: 22.101
- 2846: SP#55 completed / Impacted TSs and TRs: 23.060, 23.167, 23.203, 23.401
- 2847: SP#53 Stage 1 completed. CP#59 completed. Triggered by Rel-11 TR 22.809 Study on Support for 3GPP Voice Interworking with Enterprise IP-PBX (FS_VINE) UID_480033
- 2848: SP#53 completed / Impacted TSs and TRs: 22.228
- 2849: CP#59 completed / Impacted TSs and TRs: 23.218, 24.229
- 2850: CP#54 completed
- 2851: SP#52 completed under TEI11. Approved WID and CRs in SP-110376 (22.082 CR#0005, 22.085 CR#0004, 22.081 CR#0007, 22.088 CR#0003, 22.004 CR#0013) / Impacted TSs and TRs: 22.004, 22.081, 22.082, 22.085, 22.088
- 2852: CP#54 completed / Impacted TSs and TRs: Stage 2/3
- 2853: CP#54 completed / Impacted TSs and TRs: 23.018, 23.081, 23.082, 23.085, 23.088, 23.205, 23.231, 24.088, 29.002, 29.011
- 2854: CP#53 completed / Impacted TSs and TRs: 29.163, 29.292
- 2855: SP#57 updated WID SP-120419=>SP-120539 (removed BB3 objectives not implemented in Stage 2). SP#56 completed. Triggered by BBF WT 203, WT-134 (interworking btw 3GPP EPS and BBF's fixed broadband accesses)
- 2856: SP#57 updated WID SP-120419=>SP-120539 (removed BB3 objectives not implemented in Stage 2). SP#47 completed. Provide service requirements for supporting interworking between 3GPP EPS and the fixed broadband accesses defined by BBF / Impacted TSs and TRs: 22.278 CR#0058
- 2857: TR 23.839 not Approved in Rel-11; progressed in Rel-12 under P4C-TI (UID_560824) / Impacted TSs and TRs: new TR 23.839
- 2858: SP#56 completed / Impacted TSs and TRs: 23.203, new 23.139
- 2859: Solved by IANA-registration. No RFC needed
- 2860: CP#58 completed / Impacted TSs and TRs: Stage 3
- 2861: CP#56 completed. Identify additional FMC specific procedurES in CP-150addition to those in 24.302 (on access authentication & authorization and tunnel management; IP mobility mode selection; security aspects) / Impacted TSs and TRs: new TR 24.820
- 2862: CP#56 completed / Impacted TSs and TRs: new TR 29.839
- 2863: Draft removed from 3GPP documentation / Impacted TSs and TRs: draft-so-ipsecme-ikev2-cpext
- 2864: CP#57 completed / Impacted TSs and TRs: 24.229, new TS 24.139
- 2865: CP#57 completed / Impacted TSs and TRs: 29.212, 29.213, 29.215
- 2866: CP#58 completed / Impacted TSs and TRs: 23.008, 29.273, 29.274, new TS 29.139
- 2867: SP#53 completed. 22/01: acronym modified / Impacted TSs and TRs: 22.278
- 2868: SP#56 completed. 22/01: acronym modified / Impacted TSs and TRs: 23.203, 23.401, 23.402, 23.139

| ID | WBS | Task | Duration | Start | Finish | Complete | Baseline start | Baseline finish | Baseline duration | Constraint | Resources | Work | Actual work | Acronym | PCG approved | Impacted TSs and TRs | WI rapporteur name | WI rapporteur e-mail | Release | TSG approved | MCC resp | Special Focus Doc | Acronym_3GU_Export | PCG stopped | TSG stopped |
| --- | --- | --- | --- | --- | --- | --- | --- | --- | --- | --- | --- | --- | --- | --- | --- | --- | --- | --- | --- | --- | --- | --- | --- | --- | --- |
| 2869 | 738.8 | **Stage 3 BB II - Core Network impacts: BBF interworking with offload in access network for WLAN and for H(e)NB** | 259d? | 2011-09-16 A | 2012-09-07 A | 100% | 2011-09-16 | 2012-09-07 | 259d? |  | C3; C1; C4 | 12888h | 12888h | BBAI_BBII-CT | 27 | Stage 3 | Ericsson | Susana.Fernandez@ericsson.com | Rel-11 | 53 | Adrian | HNB, WLAN | BBAI_BBII-CT |  |  |
| 2870 | 738.8.1 | TR on Stage 3 BB II for 3GPP System to Fixed Broadband Access Network Interworking; UE to network protocols | 198d? | 2011-09-16 A | 2012-06-15 A | 100% | 2011-09-16 | 2012-06-15 | 198d? | finish no earlier than 2012-06-15 | C1 | 1576h | 1576h | BBAI_BBII-CT | 27 | 24.820 | Ericsson | Susana.Fernandez@ericsson.com | Rel-11 | 53 | Frederic | HNB, WLAN |  |  |  |
| 2871 | 738.8.2 | CT1 part of Stage 3 BB II: BBF interworking with offload in access network for WLAN and for H(e)NB | 259d? | 2011-09-16 A | 2012-09-07 A | 100% | 2011-09-16 | 2012-09-07 | 259d? | finish no earlier than 2012-09-07 | C1 | 2064h | 2064h | BBAI_BBII-CT | 27 | new TS 24.320 | Ericsson | Susana.Fernandez@ericsson.com | Rel-11 | 53 | Frederic | HNB, WLAN |  |  |  |
| 2872 | 738.8.3 | CT3 part of Stage 3 BB II: BBF interworking with offload in access network for WLAN and for H(e)NB | 259d? | 2011-09-16 A | 2012-09-07 A | 100% | 2011-09-16 | 2012-09-07 | 259d? | start no earlier than 2011-09-16 | C3 | 2056h | 2056h | BBAI_BBII-CT | 27 | 29.212, 29.213, 29.215 | Ericsson | Susana.Fernandez@ericsson.com | Rel-11 | 53 | Adrian | HNB, WLAN |  |  |  |
| 2873 | 738.8.4 | CT4 part of Stage 3 BB II: BBF interworking with offload in access network for WLAN and for H(e)NB | 122d? | 2011-09-16 A | 2012-03-02 A | 100% | 2011-09-16 | 2012-03-02 | 122d? | start no earlier than 2011-09-16 | C4 | 976h | 976h | BBAI_BBII-CT | 27 | 23.008, 29.273 | Ericsson | Susana.Fernandez@ericsson.com | Rel-11 | 53 | Kimmo | HNB, WLAN |  |  |  |
| 2874 | 738.9 | Deleted - Stage 1 BB III: BBF convergence and network based mobility | 262d? | 2010-09-23 A | 2011-09-21 A | 100% | 2010-09-23 | 2011-09-21 | 262d? | finish no earlier than 2011-09-21 | S1 | 2080h | 2080h |  | 25 | 22.278 | Huawei | Amar Deol (adeol@huawei.com) | Rel-11 | 49 | Alain | HNB, WLAN |  | PCG-29 | SP-57 |
| 2875 | 738.10 | Deleted - Stage 2 BB III: BBF convergence and network based mobility | 380d? | 2010-09-28 A | 2012-03-07 A | 100% | 2010-09-28 | 2012-03-07 | 380d? | finish no earlier than 2012-03-07 | S2 | 3040h | 3040h |  | 24 | 23.203, 23.401, 23.402, 23.139 | Huawei | marco.spini@huawei.com | Rel-11 | 47 | Maurice | HNB, WLAN |  | PCG-28 | SP-55 |
| 2876 | 738.11 | **Deleted - Stage 3 BB III - Core Network impacts: BBF convergence and network based mobility** | 122d? | 2011-09-16 A | 2012-03-02 A | 100% | 2011-09-16 | 2012-03-02 | 122d? |  | C3; C1; C4 | 6832h | 6832h |  | 27 | Stage 3 | Huawei | qiaoweihua@huawei.com | Rel-11 | 53 | Adrian | HNB, WLAN | BBAI_BBIII-CT | PCG-28 | CP-55 |
| 2877 | 738.11.1 | Deleted - TR on Stage 3 BB III for 3GPP System to Fixed Broadband Access Network Interworking; UE to network protocols | 122d? | 2011-09-16 A | 2012-03-02 A | 100% | 2011-09-16 | 2012-03-02 | 122d? | start no earlier than 2011-09-16 | C1 | 976h | 976h |  | 27 | new TR 24.820 | Huawei | qiaoweihua@huawei.com | Rel-11 | 53 | Frederic | HNB, WLAN |  | PCG-28 | CP-55 |
| 2878 | 738.11.2 | Deleted - CT1 part of Stage 3 BB III: BBF convergence and network based mobility | 122d? | 2011-09-16 A | 2012-03-02 A | 100% | 2011-09-16 | 2012-03-02 | 122d? | start no earlier than 2011-09-16 | C1 | 976h | 976h |  | 27 | TBD | Huawei | qiaoweihua@huawei.com | Rel-11 | 53 | Frederic | HNB, WLAN |  | PCG-28 | CP-55 |
| 2879 | 738.11.3 | Deleted - CT3 part of Stage 3 BB III: BBF convergence and network based mobility | 122d? | 2011-09-16 A | 2012-03-02 A | 100% | 2011-09-16 | 2012-03-02 | 122d? | start no earlier than 2011-09-16 | C3 | 976h | 976h |  | 27 | 29.212, 29.213, 29.215 | Huawei | qiaoweihua@huawei.com | Rel-11 | 53 | Adrian | HNB, WLAN |  | PCG-28 | CP-55 |
| 2880 | 738.11.4 | Deleted - CT4 part of Stage 3 BB III: BBF convergence and network based mobility | 122d? | 2011-09-16 A | 2012-03-02 A | 100% | 2011-09-16 | 2012-03-02 | 122d? | start no earlier than 2011-09-16 | C4 | 976h | 976h |  | 27 | 23.008, 29.273 | Huawei | qiaoweihua@huawei.com | Rel-11 | 53 | Kimmo | HNB, WLAN |  | PCG-28 | CP-55 |
| 2881 | 739 | **Single Radio Voice Call Continuity (SRVCC) aspect of enhancements for Multimedia Priority Service** | 398d? | 2010-06-10 A | 2011-12-14 A | 100% | 2010-06-10 | 2011-12-14 | 398d? |  | S2 | 8432h | 8432h | eMPS_SRVCC | 25 | Stage 2 | NTT DoCoMo | Atsushi Minokuchi (minokuchi@nttdocomo.co.jp) | Rel-11 | 48 | Maurice | Public Safety (I-A) | eMPS_SRVCC |  |  |
| 2882 | 739.1 | TR on SRVCC for eMPS | 260d? | 2010-06-10 A | 2011-06-08 A | 100% | 2010-06-10 | 2011-06-08 | 260d? | finish no earlier than 2011-06-08 | S2 | 2080h | 2080h | eMPS_SRVCC | 25 | new TR 23.854 | NTT DoCoMo | Atsushi Minokuchi (minokuchi@nttdocomo.co.jp) | Rel-11 | 48 | Maurice | Public Safety (I-A) |  |  |  |
| 2883 | 739.2 | Stage 2 on SRVCC for eMPS | 398d? | 2010-06-10 A | 2011-12-14 A | 100% | 2010-06-10 | 2011-12-14 | 398d? | finish no earlier than 2011-12-14 | S2 | 3168h | 3168h | eMPS_SRVCC | 25 | 23.216, 23.237 | NTT DoCoMo | Atsushi Minokuchi (minokuchi@nttdocomo.co.jp) | Rel-11 | 48 | Maurice | Public Safety (I-A) |  |  |  |
| 2884 | 740 | **Single Radio Video Call Continuity for 3G-CS** | 440d? | 2010-10-15 A | 2012-06-15 A | 100% | 2010-10-15 | 2012-06-15 | 440d? |  | S2; C1; C3; C4 | 26572.4h | 26572.4h | vSRVCC | 26 |  | Samsung | xiaowan.ke@samsung.com | Rel-11 | 50 | Maurice |  | vSRVCC |  |  |
| 2885 | 740.1 | Stage 2 for Single Radio Video Call Continuity for 3G-CS | 199.85d? | 2010-10-15 A | 2011-09-21 A | 100% | 2010-10-15 | 2011-09-21 | 199.85d? | finish no earlier than 2011-12-07 | S2 | 1580.41h | 1580.41h | vSRVCC | 26 | 23.203, 23.216, 23.237 | Samsung | xiaowan.ke@samsung.com | Rel-11 | 50 | Maurice |  |  |  |  |
| 2886 | 740.2 | **CN aspects of Single Radio Video Call Continuity for 3G-CS** | 275d? | 2011-06-03 A | 2012-06-15 A | 100% | 2011-06-03 | 2012-06-15 | 275d? |  | C1; C3; C4 | 10912h | 10912h | vSRVCC-CT | 27 |  | NEC | gottfried.punz@neclab.eu | Rel-11 | 52 | Frederic |  | vSRVCC-CT |  |  |
| 2887 | 740.2.1 | CT1 aspects of Single Radio Video Call Continuity for 3G-CS | 275d? | 2011-06-03 A | 2012-06-15 A | 100% | 2011-06-03 | 2012-06-15 | 275d? | finish no earlier than 2012-06-15 | C1 | 2184h | 2184h | vSRVCC-CT | 27 | 24.008, 24.237, 24.301 | NEC | gottfried.punz@neclab.eu | Rel-11 | 52 | Frederic |  |  |  |  |
| 2888 | 740.2.2 | CT3 aspects of Single Radio Video Call Continuity for 3G-CS | 134d? | 2011-06-03 A | 2011-12-02 A | 100% | 2011-06-03 | 2011-12-02 | 134d? | finish no earlier than 2011-12-02 | C3 | 1064h | 1064h | vSRVCC-CT | 27 | 29.211, 29.212, 29.213, 29.215 | NEC | gottfried.punz@neclab.eu | Rel-11 | 52 | Adrian |  |  |  |  |
| 2889 | 740.2.3 | CT4 aspects of Single Radio Video Call Continuity for 3G-CS | 134d? | 2011-06-03 A | 2011-12-02 A | 100% | 2011-06-03 | 2011-12-02 | 134d? | finish no earlier than 2011-12-02 | C4 | 1064h | 1064h | vSRVCC-CT | 27 | 29.280 | NEC | gottfried.punz@neclab.eu | Rel-11 | 52 | Kimmo |  |  |  |  |
| 2890 | 741 | **Network-provided Location information for IMS (NETLOC)** | 720d? | 2010-06-10 A | 2013-03-01 A | 100% | 2010-06-10 | 2013-03-01 | 720d? |  | S2; S1; S5; C3; C4; C1 | 57274.7h | 57274.7h | NWK-PL2IMS | 25 |  | T-Mobile | michele.zarri@t-mobile.co.uk | Rel-11 | 48 | Maurice |  | NWK-PL2IMS |  |  |
| 2891 | 741.1 | Stage 1 for Network-provided Location information for IMS | 203d? | 2010-12-15 A | 2011-09-21 A | 100% | 2010-12-15 | 2011-09-21 | 203d? | finish no earlier than 2011-09-21 | S1 | 1608h | 1608h | NWK-PL2IMS | 26 | 22.115 | n/a | n/a | Rel-11 | 50 | Alain |  |  |  |  |
| 2892 | 741.2 | TR on Stage 2 for Network-provided Location information for IMS | 395d? | 2010-06-10 A | 2011-12-14 A | 100% | 2010-06-10 | 2011-12-14 | 395d? | finish no earlier than 2011-12-06 | S2 | 3160h | 3160h | NWK-PL2IMS | 25 | new TR 23.842 | T-Mobile | michele.zarri@t-mobile.co.uk | Rel-11 | 48 | Maurice |  |  |  |  |
| 2893 | 741.3 | Stage 2 for Network-provided Location information for IMS | 455d? | 2010-06-15 A | 2012-03-07 A | 100% | 2010-06-15 | 2012-03-07 | 455d? | finish no earlier than 2012-03-07 | S2 | 3640h | 3640h | NWK-PL2IMS | 25 | 23.060, 23.203, 23.228, 23.401 | T-Mobile | michele.zarri@t-mobile.co.uk | Rel-11 | 48 | Maurice |  |  |  |  |
| 2894 | 741.4 | Charging for Network-provided Location information for IMS | 515d? | 2010-09-23 A | 2012-09-12 A | 100% | 2010-09-23 | 2012-09-12 | 515d? | finish no earlier than 2012-09-12 | S5 | 4120h | 4120h | NWK-PL2IMS_CH | 25 | Stage 2 (32.240, 32.260), Stage 3 (32.298, 32.299) | Nokia Siemens Networks | Gerald.Goermer@nsn.com | Rel-11 | 49 | Mirko |  | NWK-PL2IMS_CH |  |  |

Notes:
- 2869: CP#57 completed
- 2870: CP#56 completed
- 2871: CP#57 completed
- 2872: CP#57 completed
- 2873: CP#55 completed
- 2874: SP#57 stopped. Updated WID SP-120419=>SP-120539 (removed BB3 objectives not implemented in Stage 2). SP#53 completed
- 2875: SP#57 updated WID SP-120419=>SP-120539 (removed BB3 objectives not implemented in Stage 2). SP#55 stopped
- 2876: CP#55 stopped
- 2877: CP#55 stopped
- 2878: CP#55 stopped
- 2879: CP#55 stopped
- 2880: CP#55 stopped
- 2881: SP#54 completed. Analyze and if needed specify mechanisms for the priority handling of SRVCC with regard to LTE/EPC
- 2882: SP#52 completed
- 2883: SP#54 completed
- 2884: CP#56 completed. Provide Single Radio VIDEO Call Continuity from E-UTRAN to UTRAN-CS based on the agreed architecture alternative in TR 23.886
- 2885: SP#53 completed. Triggered by Feasibility Study on video call handover capability in TR 23.886 UID_470048 Study on Single Radio Video Call Continuity for 3G-CS (FS_vSRVCC)
- 2886: Stage 3. CP#56 completed
- 2887: CP#56 completed
- 2888: CP#54 completed
- 2889: CP#54 completed
- 2890: Covers the case where UE is served by a 3GPP RAN. Architecture making Cell/PLMN ID (UE is camped on) available to IMS nodes when the operator needs to record this information either to fulfil legal obligations or for charging.
- 2891: SP#53 completed
- 2892: SP#54 completed
- 2893: SP#55 completed
- 2894: SP#57 completed

| ID | WBS | Task | Type | Duration | Start | Finish | Complete | Baseline start | Baseline finish | Baseline duration | Constraint | Resources | Work | Actual work | Acronym | PCG approved | WI rapporteur name | WI rapporteur e-mail | Release | TSG approved | MCC resp | Acronym_3GU_Export | Special Focus Doc | PCG stopped | TSG stopped |
| --- | --- | --- | --- | --- | --- | --- | --- | --- | --- | --- | --- | --- | --- | --- | --- | --- | --- | --- | --- | --- | --- | --- | --- | --- | --- |
| 2895 | 741.5 | **CT aspects of Network-provided Location information for IMS (Stage 3)** |  | 266d? | 2012-03-02 A | 2013-03-01 A | 100% | 2012-03-02 | 2013-03-01 | 266d? |  | C3; C4; C1 | 10186.7h | 10186.7h | NWK-PL2IMS-CT | 28 | Huawei | Qiao Weihua (qiaoweihua@huawei.com) | Rel-11 | 55 | Adrian | NWK-PL2IMS_CT |  |  |  |
| 2896 | 741.5.1 | CT3 part of CT aspects of Network-provided Location information for IMS |  | 138d? | 2012-03-02 A | 2012-09-07 A | 100% | 2012-03-02 | 2012-09-07 | 138d? | finish no earlier than 2012-09-07 | C3 | 1088h | 1088h | NWK-PL2IMS-CT | 28 | Huawei | Qiao Weihua (qiaoweihua@huawei.com) | Rel-11 | 55 | Adrian |  |  |  |  |
| 2897 | 741.5.2 | CT4 part of CT aspects of Network-provided Location information for IMS |  | 77d? | 2012-03-02 A | 2012-06-15 A | 100% | 2012-03-02 | 2012-06-15 | 77d? | finish no earlier than 2012-06-01 | C4 | 608h | 608h | NWK-PL2IMS-CT | 28 | Huawei | Qiao Weihua (qiaoweihua@huawei.com) | Rel-11 | 55 | Kimmo |  |  |  |  |
| 2898 | 741.5.3 | CT1 part of CT aspects of Network-provided Location information for IMS |  | 266d? | 2012-03-02 A | 2013-03-01 A | 100% | 2012-03-02 | 2013-03-01 | 266d? | finish no earlier than 2013-06-14 | C1 | 2106.67h | 2106.67h | NWK-PL2IMS-CT | 28 | Huawei | Qiao Weihua (qiaoweihua@huawei.com) | Rel-11 | 55 | Frederic |  |  |  |  |
| 2899 | 742 | **Service Awareness and Privacy Policies** |  | 301.15d? | 2010-10-12 A | 2011-12-02 A | 100% | 2010-10-12 | 2011-12-02 | 301.15d? |  | S2; S1; C3 | 10667.6h | 10667.6h | SAPP | 26 | Allot | Alla Goldner (agoldner@allot.com) | Rel-11 | 50 | Maurice | SAPP |  |  |  |
| 2900 | 742.1 | Stage 1 for Service Awareness and Privacy Policies |  | 46.15d? | 2010-10-12 A | 2010-12-15 A | 100% | 2010-10-12 | 2010-12-15 | 46.15d? | finish no earlier than 2010-12-15 | S1 | 369.2h | 369.2h | SAPP | 26 | Allot | Alla Goldner (agoldner@allot.com) | Rel-11 | 50 | Maurice |  |  |  |  |
| 2901 | 742.2 | Stage 2 for Service Awareness and Privacy Policies |  | 199.85d? | 2010-10-15 A | 2011-09-21 A | 100% | 2010-10-15 | 2011-09-21 | 199.85d? | finish no earlier than 2011-09-21 | S2 | 1582.8h | 1582.8h | SAPP | 26 | Allot | Alla Goldner (agoldner@allot.com) | Rel-11 | 50 | Maurice |  |  |  |  |
| 2902 | 742.3 | CT3 part of Service Awareness and Privacy Policies |  | 187d? | 2011-03-18 A | 2011-12-02 A | 100% | 2011-03-18 | 2011-12-02 | 187d? | finish no earlier than 2011-12-02 | C3 | 1488h | 1488h | SAPP-CT3 | 26 | Allot | Alla Goldner (agoldner@allot.com) | Rel-11 | 51 | Adrian | SAPP-CT3 |  |  |  |
| 2903 | 743 | **VPLMN Autonomous CSG Roaming** |  | 307d? | 2010-10-15 A | 2011-12-14 A | 100% | 2010-10-15 | 2011-12-14 | 307d? |  | S2; C4 | 6974.61h | 6974.61h | VCSG | 26 | Qualcomm | AC Mahendran (ac@qualcomm.com) | Rel-11 | 50 | Maurice | VCSG |  |  |  |
| 2904 | 743.1 | Stage 2 for VPLMN Autonomous CSG Roaming |  | 260.85d? | 2010-10-15 A | 2011-12-14 A | 100% | 2010-10-15 | 2011-12-14 | 260.85d? | finish no earlier than 2011-12-07 | S2 | 2062.61h | 2062.61h | VCSG | 26 | Qualcomm | AC Mahendran (ac@qualcomm.com) | Rel-11 | 50 | Maurice |  |  |  |  |
| 2905 | 743.2 | CT aspects of VPLMN Autonomous CSG Roaming | milestone | 0d? | 2011-12-07 A | 2011-12-07 A | 100% | 2011-12-07 | 2011-12-07 | 0d? | finish no earlier than 2012-09-07 | C4 |  |  | VCSG-St3 | 27 | ZTE | Fei Lu (lu.fei1@zte.com.cn) | Rel-11 | 53 | Kimmo | VCSG-St3 |  |  |  |
| 2906 | 744 | **Data Identification in Access Network Discovery and Selection Function (ANDSF)** |  | 455d? | 2011-03-23 A | 2012-12-07 A | 100% | 2011-03-23 | 2012-12-07 | 455d? |  | S2; C1 | 12488h | 12488h | DIDA | 26 | Qualcomm | Gerardo Giaretta (gerardo@qualcomm.com) | Rel-11 | 51 | Maurice | DIDA |  |  |  |
| 2907 | 744.1 | TR on Stage 2 for Data Identification in ANDSF |  | 193d? | 2011-03-23 A | 2011-12-14 A | 100% | 2011-03-23 | 2011-12-14 | 193d? | finish no earlier than 2011-12-07 | S2 | 1544h | 1544h | DIDA | 26 | Qualcomm | Gerardo Giaretta (gerardo@qualcomm.com) | Rel-11 | 51 | Maurice |  |  |  |  |
| 2908 | 744.2 | Stage 2 for Data Identification in ANDSF |  | 253d? | 2011-03-24 A | 2012-03-07 A | 100% | 2011-03-24 | 2012-03-07 | 253d? | finish no earlier than 2012-03-07 | S2 | 2024h | 2024h | DIDA | 26 | Qualcomm | Gerardo Giaretta (gerardo@qualcomm.com) | Rel-11 | 51 | Maurice |  |  |  |  |
| 2909 | 744.3 | CT aspects of Data Identification in Access Network Discovery and Selection Function (ANDSF) Stage 3 |  | 205d? | 2012-03-02 A | 2012-12-07 A | 100% | 2012-03-02 | 2012-12-07 | 205d? | finish no earlier than 2012-12-07 | C1 | 1640h | 1640h | DIDA-CT | 28 | Qualcomm | Patrick Stupar (pstupar@qualcomm.com) | Rel-11 | 55 | Frederic | DIDA-CT |  |  |  |
| 2910 | 745 | **LOcation-Based Selection of gaTEways foR WLAN** |  | 327d? | 2011-03-23 A | 2012-06-15 A | 100% | 2011-03-23 | 2012-06-15 | 327d? |  | S2; C4 | 10170.5h | 10170.5h | LOBSTER | 26 | ZTE | zhu.chunhui@zte.com.cn | Rel-11 | 51 | Maurice | LOBSTER | WLAN |  |  |
| 2911 | 745.1 | Stage 2 for LOcation-Based Selection of gaTEways foR WLAN |  | 194d? | 2011-03-23 A | 2011-12-14 A | 100% | 2011-03-23 | 2011-12-14 | 194d? | finish no earlier than 2011-12-07 | S2 | 1546.52h | 1546.52h | LOBSTER | 26 | ZTE | zhu.chunhui@zte.com.cn | Rel-11 | 51 | Maurice |  | WLAN |  |  |
| 2912 | 745.2 | **CT aspects of LOcation-Based Selection of gaTEways foR WLAN** |  | 142d? | 2011-12-02 A | 2012-06-15 A | 100% | 2011-12-02 | 2012-06-15 | 142d? |  | C4 | 3392h | 3392h | LOBSTER-CT | 28 | ZTE | zhou.xingyue@zte.com.cn | Rel-11 | 54 | Kimmo | LOBSTER-CT | WLAN |  |  |
| 2913 | 745.2.1 | CT4 part of CT aspects of LOcation-Based Selection of gaTEways foR WLAN |  | 142d? | 2011-12-02 A | 2012-06-15 A | 100% | 2011-12-02 | 2012-06-15 | 142d? | finish no earlier than 2012-06-15 | C4 | 1128h | 1128h | LOBSTER-CT | 28 | ZTE | zhou.xingyue@zte.com.cn | Rel-11 | 54 | Kimmo |  | WLAN |  |  |
| 2914 | 745.2.2 | Deleted - CT1 part of CT aspects of LOcation-Based Selection of gaTEways foR WLAN |  | 142d? | 2011-12-02 A | 2012-06-15 A | 100% | 2011-12-02 | 2012-06-15 | 142d? | finish no earlier than 2012-06-15 | C1 | 1128h | 1128h | LOBSTER-CT | 28 | ZTE | zhou.xingyue@zte.com.cn | Rel-11 | 54 | Frederic |  | WLAN | PCG-29 | CP-56 |
| 2915 | 746 | **Single Radio Voice Call Continuity from UTRAN/GERAN to E-UTRAN/HSPA** |  | 929d? | 2011-09-12 A | 2015-03-15 A | 100% | 2011-09-12 | 2014-12-05 | 856d? |  | S2; C1; C3; C4; G2; R2; R3; R5 | 83776.8h | 83776.8h | rSRVCC | 27 | Orange | antoine.mouquet@orange-ftgroup.com | Rel-11 | 53 | Maurice | rSRVCC |  |  |  |
| 2916 | 746.1 | Stage 2 for Single Radio Voice Call Continuity from UTRAN/GERAN to E-UTRAN/HSPA |  | 197d? | 2011-09-22 A | 2012-06-20 A | 100% | 2011-09-22 | 2012-06-20 | 197d? | finish no earlier than 2012-06-20 | S2 | 1568h | 1568h | rSRVCC | 27 | Orange | antoine.mouquet@orange-ftgroup.com | Rel-11 | 53 | Maurice |  |  |  |  |
| 2917 | 746.2 | **CT aspects for Single Radio Voice Call Continuity from UTRAN/GERAN to E-UTRAN/HSPA (Stage 3)** |  | 259d? | 2011-09-16 A | 2012-09-07 A | 100% | 2011-09-16 | 2012-09-07 | 259d? |  | C1; C3; C4 | 12360h | 12360h | rSRVCC-CT | 27 | Ericsson | ivo.sedlacek@ericsson.com | Rel-11 | 53 | Frederic | rSRVCC-CT |  |  |  |
| 2918 | 746.2.1 | CT1 part for Single Radio Voice Call Continuity from UTRAN/GERAN to E-UTRAN/HSPA |  | 258d? | 2011-09-16 A | 2012-09-07 A | 100% | 2011-09-16 | 2012-09-07 | 258d? | finish no earlier than 2012-09-07 | C1 | 2048h | 2048h | rSRVCC-CT | 27 | Ericsson | ivo.sedlacek@ericsson.com | Rel-11 | 53 | Frederic |  |  |  |  |
| 2919 | 746.2.2 | CT3 part for Single Radio Voice Call Continuity from UTRAN/GERAN to E-UTRAN/HSPA |  | 257d? | 2011-09-19 A | 2012-09-07 A | 100% | 2011-09-19 | 2012-09-07 | 257d? | finish no earlier than 2012-09-07 | C3 | 2048h | 2048h | rSRVCC-CT | 27 | Ericsson | ivo.sedlacek@ericsson.com | Rel-11 | 53 | Adrian |  |  |  |  |
| 2920 | 746.2.3 | CT4 part for Single Radio Voice Call Continuity from UTRAN/GERAN to E-UTRAN/HSPA |  | 257d? | 2011-09-19 A | 2012-09-07 A | 100% | 2011-09-19 | 2012-09-07 | 257d? | finish no earlier than 2012-09-07 | C4 | 2048h | 2048h | rSRVCC-CT | 27 | Ericsson | ivo.sedlacek@ericsson.com | Rel-11 | 53 | Kimmo |  |  |  |  |
| 2921 | 746.3 | GERAN aspects of Single Radio Voice Call Continuity from UTRAN/GERAN to E-UTRAN/HSPA (Stage 3) |  | 476.1d? | 2011-09-12 A | 2013-06-28 A | 100% | 2011-09-12 | 2013-06-28 | 476.1d? | finish no earlier than 2013-11-22 | G2 | 2048h | 2048h | rSRVCC-GERAN | 27 | ZTE | li.jing4@zte.com.cn | Rel-11 | 51 | Gert | rSRVCC-GERAN |  |  |  |

Notes:
- 2895: Stage 3. 3/3: Acronym changed from "NWK-PL2IMS_CT"
- 2896: CP#57 completed. 3/3: Acronym changed from "NWK-PL2IMS_CT" / Impacted TSs and TRs: 29.212, 29.214, 29.215
- 2897: CP#57 completed. 3/3: Acronym changed from "NWK-PL2IMS_CT" / Impacted TSs and TRs: 23.008, 29.002, 29.060, 29.230, 29.272, 29.274, 29.305, 29.328, 29.329
- 2898: CP#57 completed. 3/3: Acronym changed from "NWK-PL2IMS_CT" / Impacted TSs and TRs: 24.229, 24.292
- 2899: CP#54 completed. Triggered by the SA1,SA2 Rel-10 TR 23.813 Study on Policy solutions and enhancements (FS_PP) UID_440047
- 2900: For deep packet inspection (i.e. Traffic Detection Functionality) SA1 indicated that no new requirements are needed (see Objective of FS_PP SA1,SA2 Rel-10 Study on Policy solutions and enhancements UID_440047 TR 23.813)
- 2901: SP#53 completed / Impacted TSs and TRs: 23.203
- 2902: CP#54 completed. Stage 3 to support Application Detection and Control Functionality. Update Gx / introduce Sd reference points and procedures. Update S9 reference point in roaming scenarios / Impacted TSs and TRs: 29.212, 29.213, 29.214, 29.215
- 2903: CP#56 completed. Linked to Rel-10 UID_450053 Enhanced Home NodeB / eNodeB (EHNB). Implements Rel-9 requirements for CSG support in SA1 TS 22.220
- 2904: SP#54 completed / Impacted TSs and TRs: 23.002, 23.060, 23.401
- 2905: CP#57 completed / Impacted TSs and TRs: 23.003, 23.007, 23.008, 23.012, 29.002, 29.230, 29.272
- 2906: SP#58 completed. Linked to Rel-10 IFOM (IP Flow Mobility and seamless WLAN offload) UID_450041. Defines IP flow mobility, seamless and non seamless WLAN offload and respective ANDSF extensions / Impacted TSs and TRs: Stage 2/3
- 2907: SP#54 completed / Impacted TSs and TRs: New TR 23.855
- 2908: SP#55 completed / Impacted TSs and TRs: 23.402
- 2909: CP#58 completed / Impacted TSs and TRs: 24.302, 24.312
- 2910: CP#56 completed. Related to UID_350027 SAE for support for non-3GPP accesses (SAES-SA-FP_n3GPP). Enhancements to ePDG and PDN GW selection functions for S2b and S2c based on UE location
- 2911: SP#54 completed / Impacted TSs and TRs: 23.402
- 2912: Stage 3. CP#56 completed / Impacted TSs and TRs: Stage 3
- 2913: CP#56 completed / Impacted TSs and TRs: 29.273
- 2914: CP#56 stopped / Impacted TSs and TRs: 24.302
- 2915: Stage 1 in Rel-8 TS 22.278 clause 7.1.4.2. Triggered by Rel-11 TR 23.885 Study on Single Radio Voice Call Continuity from UTRAN/GERAN to E-UTRAN/HSPA (FS_rSRVCC) UID_460030
- 2916: SP#56 completed / Impacted TSs and TRs: 23.216, 23.237
- 2917: CP#57 completed / Impacted TSs and TRs: Stage 3
- 2918: CP#57 completed / Impacted TSs and TRs: 23.009, 24.008, 24.229, 24.237, 24.292, 24.301
- 2919: CP#57 completed / Impacted TSs and TRs: 29.165, 29.292
- 2920: CP#57 completed / Impacted TSs and TRs: 23.003, 23.008, 29.002, 29.230, 29.272, 29.280, 29.303, 29.305, 29.328
- 2921: GP#60 completed. GP#51 approved WID / Impacted TSs and TRs: 44.018, 48.008

| ID | WBS | Task | Duration | Start | Finish | Complete | Baseline start | Baseline finish | Baseline duration | Constraint | Resources | Work | Actual work | Acronym | PCG approved | Impacted TSs and TRs | WI rapporteur name | Release | TSG approved | MCC resp | Acronym_3GU_Export | Status Report | Special Focus Doc | PCG stopped | TSG stopped |
| --- | --- | --- | --- | --- | --- | --- | --- | --- | --- | --- | --- | --- | --- | --- | --- | --- | --- | --- | --- | --- | --- | --- | --- | --- | --- |
| 2922 | 746.4 | **UTRAN aspects of Single Radio Voice Call Continuity from UTRAN/GERAN to E-UTRAN/HSPA** | 325d? | 2011-09-19 A | 2012-12-07 A | 100% | 2011-09-19 | 2012-12-07 | 325d? |  | R3; R2 | 10400h | 10400h | rSRVCC-RAN_UTRA | 27 | UTRA | Huawei | Rel-11 | 53 | Juha | rSRVCC-RAN_UTRA |  |  |  |  |
| 2923 | 746.4.1 | Core part: UTRAN aspects of Single Radio Voice Call Continuity from UTRAN/GERAN to E-UTRAN/HSPA | 325d? | 2011-09-19 A | 2012-12-07 A | 100% | 2011-09-19 | 2012-12-07 | 325d? | finish no earlier than 2012-12-07 | R3; R2 | 5200h | 5200h | rSRVCC-RAN_UTRA-Core | 27 | 25.331, 25.401, 25.413 | Huawei | Rel-11 | 53 | Juha | rSRVCC-RAN_UTRA-Core | RP-121553 |  |  |  |
| 2924 | 746.5 | Test part: Single Radio Voice Call Continuity from UTRAN/GERAN to E-UTRAN/HSPA | 196d? | 2014-06-15 A | 2015-03-15 A | 100% | 2014-06-13 | 2014-12-05 | 126d? | finish no earlier than 2015-03-15 | R5 | 1568h | 1568h | rSRVCC-UEConTest | 33 | 36.508, 36.523-1, 36.523-2, 36.523-3 | Ericsson | Rel-11 | 64 |  | rSRVCC-UEConTest | RP-150133 |  |  |  |
| 2925 | 747 | **S2a Mobility based On GTP and WLAN access to EPC** | 651d? | 2011-09-22 A | 2014-03-05 A | 100% | 2011-09-22 | 2014-03-05 | 651d? |  | S2; C4; C1; C3; IETF | 54000h | 54000h | SaMOG_WLAN | 27 | Stage 2/3 | ZTE | Rel-11 | 53 | Maurice | SaMOG_WLAN |  | WLAN |  |  |
| 2926 | 747.1 | Stage 2 for S2a Mobility based On GTP and WLAN access to EPC | 121d? | 2011-09-22 A | 2012-03-07 A | 100% | 2011-09-22 | 2012-03-07 | 121d? | finish no earlier than 2012-03-07 | S2 | 968h | 968h | SaMOG_WLAN | 27 | 23.002, 23.203, 23.402 | ZTE | Rel-11 | 53 | Maurice |  |  | WLAN |  |  |
| 2927 | 747.2 | **CN aspects of Mobility based On GTP & PMIPv6 for WLAN access to EPC** | 599d? | 2011-12-02 A | 2014-03-05 A | 100% | 2011-12-02 | 2014-03-05 | 599d? |  | C4; C1; C3; IETF | 26992h | 26992h | SaMOG_WLAN-CN | 28 | Stage 3 | Alcatel-Lucent | Rel-11 | 54 | Kimmo | SaMOG_WLAN-CN |  | WLAN |  |  |
| 2928 | 747.2.1 | CT4 part of CN aspects of Mobility based On GTP & PMIPv6 for WLAN access to EPC | 203d? | 2011-12-02 A | 2012-09-07 A | 100% | 2011-12-02 | 2012-09-07 | 203d? | finish no earlier than 2012-09-07 | C4 | 1608h | 1608h | SaMOG_WLAN-CN | 28 | 23.003, 23.007, 23.008, 29.273, 29.274, 29.281, 29.303 | Alcatel-Lucent | Rel-11 | 54 | Kimmo |  |  | WLAN |  |  |
| 2929 | 747.2.2 | Deleted - (IETF) CT4 part of CN aspects of Mobility based On GTP & PMIPv6 for WLAN access to EPC | 498d? | 2012-04-23 A | 2014-03-05 A | 100% | 2012-04-23 | 2014-03-05 | 498d? | finish no earlier than 2014-03-05 | C4-IETF | 3960h | 3960h | SaMOG_WLAN-CN | 29 | draft-ietf-radext-ieee802ext | Lionel Morand | Rel-11 | 56 | Kimmo |  |  | WLAN | PCG-32 | CP-53 |
| 2930 | 747.2.3 | Deleted - CT1 part of CN aspects of Mobility based On GTP & PMIPv6 for WLAN access to EPC | 142d? | 2011-12-02 A | 2012-06-15 A | 100% | 2011-12-02 | 2012-06-15 | 142d? | finish no earlier than 2012-06-15 | C1 | 1128h | 1128h | SaMOG_WLAN-CN | 28 | 24.302 | Alcatel-Lucent | Rel-11 | 54 | Frederic |  |  | WLAN | PCG-29 | CP-56 |
| 2931 | 747.2.4 | CT3 part of CN aspects of Mobility based On GTP & PMIPv6 for WLAN access to EPC | 142d? | 2011-12-02 A | 2012-06-15 A | 100% | 2011-12-02 | 2012-06-15 | 142d? | finish no earlier than 2012-09-07 | C3 | 1128h | 1128h | SaMOG_WLAN-CN | 28 | 29.212, 29.213, 29.215 | Alcatel-Lucent | Rel-11 | 54 | Adrian |  |  | WLAN |  |  |
| 2932 | 748 | **Roaming Architecture for Voice over IMS with Local Breakout** | 273d? | 2011-11-28 A | 2012-12-07 A | 100% | 2011-11-28 | 2012-12-07 | 273d? |  | S2; S5; C1; C3 | 16904h | 16904h | RAVEL | 28 | Stage 2/3 | Deutsche Telekom | Rel-11 | 54 | Maurice | RAVEL |  |  |  |  |
| 2933 | 748.1 | Stage 2 for Roaming Architecture for Voice over IMS with Local Breakout | 12d? | 2011-11-28 A | 2011-12-14 A | 100% | 2011-11-28 | 2011-12-14 | 12d? | finish no earlier than 2012-03-07 | S2 | 96h | 96h | RAVEL | 28 | 23.002, 23.228 | Deutsche Telekom | Rel-11 | 54 | Maurice |  |  |  |  |  |
| 2934 | 748.2 | Charging for Roaming Architecture for Voice over IMS with Local Breakout | 196d? | 2011-12-14 A | 2012-09-12 A | 100% | 2011-12-14 | 2012-09-12 | 196d? | finish no earlier than 2012-09-12 | S5 | 1568h | 1568h | RAVEL-CH | 28 | 32.240, 32.260, 32.298, 32.299 | Nokia Siemens Networks | Rel-11 | 54 | Mirko | RAVEL-CH |  |  |  |  |
| 2935 | 748.3 | **CT aspects of Roaming Architecture for Voice over IMS with Local Breakout (Stage 3)** | 205d? | 2012-03-02 A | 2012-12-07 A | 100% | 2012-03-02 | 2012-12-07 | 205d? |  | C1; C3 | 6504h | 6504h | RAVEL-CT | 28 | Stage 3 | Deutsche Telekom | Rel-11 | 55 | Frederic | RAVEL-CT |  |  |  |  |
| 2936 | 748.3.1 | CT1 part of CT aspects of Roaming Architecture for Voice over IMS with Local Breakout | 204d? | 2012-03-02 A | 2012-12-07 A | 100% | 2012-03-02 | 2012-12-07 | 204d? | finish no earlier than 2012-12-07 | C1 | 1608h | 1608h | RAVEL-CT | 28 | 24.229, 24.292, 24.237 | Deutsche Telekom | Rel-11 | 55 | Frederic |  |  |  |  |  |
| 2937 | 748.3.2 | CT3 part of CT aspects of Roaming Architecture for Voice over IMS with Local Breakout | 204d? | 2012-03-02 A | 2012-12-07 A | 100% | 2012-03-02 | 2012-12-07 | 204d? | finish no earlier than 2012-12-07 | C3 | 1616h | 1616h | RAVEL-CT | 28 | 29.165, 29.162, 29.079 | Deutsche Telekom | Rel-11 | 55 | Adrian |  |  |  |  |  |
| 2938 | 749 | **IMS Overload Control** | 659d? | 2012-06-18 A | 2014-12-09 A | 100% | 2012-06-18 | 2014-12-05 | 654d? |  | S2; C1; C3; IETF | 52408h | 52408h | IOC | 29 | Stage 2/3 | Orange, China Mobile | Rel-11 | 56 | Maurice | IOC |  |  |  |  |
| 2939 | 749.1 | Stage 2 for IMS Overload Control | 64d? | 2012-06-18 A | 2012-09-12 A | 100% | 2012-06-18 | 2012-09-12 | 64d? | finish no earlier than 2012-09-12 | S2 | 504h | 504h | IOC | 29 | 23.228 | Orange, China Mobile | Rel-11 | 56 | Maurice |  |  |  |  |  |
| 2940 | 749.2 | **Stage 3 for IMS Overload Control** | 601d? | 2012-09-05 A | 2014-12-09 A | 100% | 2012-09-05 | 2014-12-05 | 596d? |  | C1; C3; IETF | 30816h | 30816h | IOC | 29 |  | Alcatel-Lucent | Rel-11 | 57 | Frederic |  |  |  |  |  |
| 2941 | 749.2.1 | CT1 part of Stage 3 for IMS Overload Control | 70d? | 2012-09-05 A | 2012-12-07 A | 100% | 2012-09-05 | 2012-12-07 | 70d? | finish no earlier than 2012-12-07 | C1 | 544h | 544h | IOC | 29 | 24.229 | Alcatel-Lucent | Rel-11 | 57 | Frederic |  |  |  |  |  |
| 2942 | 749.2.2 | CT3 part of Stage 3 for IMS Overload Control | 70d? | 2012-09-05 A | 2012-12-07 A | 100% | 2012-09-05 | 2012-12-07 | 70d? | finish no earlier than 2012-12-07 | C3 | 552h | 552h | IOC | 29 | 29.165 | Alcatel-Lucent | Rel-11 | 57 | Adrian |  |  |  |  |  |
| 2943 | 749.2.3 | (IETF) CT part of Stage 3 for IMS Overload Control (soc-overload-control) | 361d? | 2013-07-29 A | 2014-12-09 A | 100% | 2013-07-29 | 2014-12-05 | 359d? | finish no earlier than 2014-12-09 | C1-IETF; C3-IETF | 5776h | 5776h | IOC | 29 | RFC 7339 | Keith Drage | Rel-11 | 57 | Frederic |  |  |  |  |  |
| 2944 | 749.2.4 | (IETF) CT part of Stage 3 for IMS Overload Control (soc-overload-rate-control) | 361d? | 2013-07-29 A | 2014-12-09 A | 100% | 2013-07-29 | 2014-12-05 | 359d? | finish no earlier than 2014-12-09 | C1-IETF; C3-IETF | 5776h | 5776h | IOC | 29 | RFC 7415 | Keith Drage | Rel-11 | 57 | Frederic |  |  |  |  |  |
| 2945 | 749.2.5 | (IETF) CT part of Stage 3 for IMS Overload Control (RFC 7200) | 234d? | 2013-07-29 A | 2014-06-13 A | 100% | 2013-07-29 | 2014-06-13 | 234d? | finish no earlier than 2014-06-13 | C1-IETF; C3-IETF | 3744h | 3744h | IOC | 29 | RFC 7200 (was draft-ietf-soc-load-control-event-package) | Keith Drage | Rel-11 | 57 | Frederic |  |  |  |  |  |
| 2946 | 750 | Rel-11 Security small Enhancements | 336d? | 2011-06-08 A | 2012-09-12 A | 100% | 2011-06-08 | 2012-09-12 | 336d? | finish no earlier than 2012-09-12 | S3 | 2680h | 2680h | SEC11 | 27 |  |  | Rel-11 | 52 | Mirko | SEC11 |  |  |  |  |
| 2947 | 751 | Lawful Interception in the 3GPP Rel-11 | 272d? | 2011-06-10 A | 2012-06-20 A | 100% | 2011-06-10 | 2012-06-20 | 272d? | finish no earlier than 2012-06-20 | S3 | 2176h | 2176h | LI11 | 27 | 33.106, 33.107, 33.108 | PIDS, Alcatel-Lucent | Rel-11 | 52 | Mirko | LI11 |  |  |  |  |

Notes:
- 2922: RP#58 completed / WI rapporteur e-mail: liwei.qiu@huawei.com
- 2923: RP#58 completed / WI rapporteur e-mail: liwei.qiu@huawei.com
- 2924: ; Stat Rep: RP-141167->RP-141771 1st Apr 15: Compl:40%->100% 1st Apr 15: Stat Rep: RP-141771->RP-150133 / WI rapporteur e-mail: calle.hagenfeldt@ericsson.com
- 2925: Triggered by Rel-11 TR 23.852 FS_SaMOG UID_510061, Rel-8 UID_350027 SAE for support for non-3GPP accesses (defines PMIP-S2a) / WI rapporteur e-mail: Chunhui Zhu (zhu.chunhui@zte.com.cn)
- 2926: SP#55 completed / WI rapporteur e-mail: zhu.chunhui@zte.com.cn
- 2927: - / WI rapporteur e-mail: bruno.landais@alcatel-lucent.com
- 2928: CP#57 completed / WI rapporteur e-mail: bruno.landais@alcatel-lucent.com
- 2929: CP#63 Draft removed from 3GPP documentation
- 2930: CP#56 stopped (no CT1 impact) / WI rapporteur e-mail: bruno.landais@alcatel-lucent.com
- 2931: CP#56 completed / WI rapporteur e-mail: bruno.landais@alcatel-lucent.com
- 2932: CP#58 completed. Triggered by Rel-11 TR 23.850 Study on Roaming Architecture for Voice over IMS with Local Breakout (FS_RAVEL). GSMA CPWP LS_in S5-102806 asked 3GPP SA5 to check if CS voice charging principles also apply to voice over IMS / WI rapporteur e-mail: michele.zarri@telekom.com
- 2933: SP#54 completed / WI rapporteur e-mail: michele.zarri@telekom.com
- 2934: Stage 2/3. SP#57 completed / WI rapporteur e-mail: Gerald.Goermer@nsn.com
- 2935: CP#58 completed / WI rapporteur e-mail: reinhard.lauster@)t-mobile.at
- 2936: CP#58 completed / WI rapporteur e-mail: reinhard.lauster@)t-mobile.at
- 2937: CP#58 completed / WI rapporteur e-mail: reinhard.lauster@)t-mobile.at
- 2938: SP#57 Stage 2 completed. Moved Rel-12=>Rel-11 as CT finished Stage 3. Linked to UID_410041 Study on IMS Evolution (TR 23.812). Solutions from IETF SOC WG and existing 3GPP procedures to be re-used if possible & backward compatibility ensured / WI rapporteur e-mail: Antoine MOUQUET, YU Qing
- 2939: SP#57 completed. Moved Rel-12=>Rel-11 as CT finished Stage 3. / WI rapporteur e-mail: antoine.mouquet@orange-ftgroup.com, YU Qing
- 2940: - / WI rapporteur e-mail: Keith Drage
- 2941: CP#58 completed / WI rapporteur e-mail: Keith Drage
- 2942: CP#58 completed / WI rapporteur e-mail: Keith Drage
- 2943: in RFC Ed-queue. Dec.14: 75->100. Mar15: impacted spec updated (was draft-ietf-soc-overload-control). Jun 15: RFC 7339 (was draft-ietf-soc-overload-control) / WI rapporteur e-mail: Keith Drage
- 2944: Submitted to IESG for publication. Dec14: 50->90%. Mar15: 100%. Impacted RFC updated (was draft-ietf-soc-overload-rate-control). Jun 15: RFC 7415 (was draft-ietf-soc-overload-rate-control) / WI rapporteur e-mail: Keith Drage
- 2945: CP#64 completed / WI rapporteur e-mail: Keith Drage
- 2946: SEC11 is an umbrella Feature for Security related TEI11 type of changes that are not part of any other dedicated feature
- 2947: Stage 1/2/3. SP#56 completed / WI rapporteur e-mail: Koen Jaspers (k.b.jaspers@minjus.nl), terry.jacobson@alcatel-lucent.com

| ID | WBS | Task | Duration | Start | Finish | Complete | Baseline start | Baseline finish | Baseline duration | Constraint | Resources | Work | Actual work | Acronym | PCG approved | WI rapporteur name | Release | TSG approved | MCC resp | Acronym_3GU_Export | Status Report | Special Focus Doc |
| --- | --- | --- | --- | --- | --- | --- | --- | --- | --- | --- | --- | --- | --- | --- | --- | --- | --- | --- | --- | --- | --- | --- |
| 2948 | 752 | **ZUC EEA3 and EIA3 (new Encryption & Integrity EPS security Algorithms)** | 857d? | 2009-06-04 A | 2012-09-07 A | 100% | 2009-06-04 | 2012-09-07 | 857d? |  | S3; R5 | 19488h | 19488h | EEA3_EIA3 | 23 | CATR | Rel-11 | 44 | Mirko | EEA3_EIA3 |  |  |
| 2949 | 752.1 | ZUC EEA3 and EIA3 | 663d? | 2009-06-04 A | 2011-12-14 A | 100% | 2009-06-04 | 2011-12-14 | 663d? | finish no earlier than 2011-09-21 | S3 | 5288h | 5288h | EEA3_EIA3 | 23 | CATR | Rel-11 | 44 | Mirko |  |  |  |
| 2950 | 752.2 | Conformance Test Aspects – ZUC (EEA3 and EIA3 Encryption & Integrity EPS security Algorithms) | 61d? | 2012-06-18 A | 2012-09-07 A | 100% | 2012-06-18 | 2012-09-07 | 61d? | finish no earlier than 2013-03-01 | R5 | 488h | 488h | EEA3_EIA3_UEConTest | 29 | CATR | Rel-11 | 56 | Ingbert | EEA3_EIA3_UEConTest | RP-120968 |  |
| 2951 | 753 | Specification of Protection against Unsolicited Communication for IMS (produced TR-only) | 456d? | 2010-06-10 A | 2012-03-07 A | 100% | 2010-06-10 | 2012-03-07 | 456d? | finish no earlier than 2012-03-07 | S3 | 3640h | 3640h | SPUCI | 25 | NEC | Rel-11 | 48 | Mirko | SPUCI |  |  |
| 2952 | 754 | H(e)NB security features for UE mobility scenarios (Stage 2) | 252d? | 2011-03-23 A | 2012-03-07 A | 100% | 2011-03-23 | 2012-03-07 | 252d? | finish no earlier than 2012-03-07 | S3 | 2008h | 2008h | HNB_mob_Sec | 26 | Huawei | Rel-11 | 51 | Mirko | HNB_mob_Sec |  | HNB |
| 2953 | 755 | **Generic Bootstrapping Architecture (GBA) extensions for re-use of SIP Digest credentials** | 203d? | 2011-12-02 A | 2012-09-07 A | 100% | 2011-12-02 | 2012-09-07 | 203d? |  | S3; C4; C1 | 11824h | 11824h | GBA-ext | 28 | Nokia | Rel-11 | 54 | Mirko | GBA-ext |  |  |
| 2954 | 755.1 | Stage 2 for GBA extensions for re-use of SIP Digest credentials | 61d? | 2011-12-14 A | 2012-03-07 A | 100% | 2011-12-14 | 2012-03-07 | 61d? | finish no earlier than 2012-02-28 | S3 | 488h | 488h | GBA-ext | 28 | Nokia | Rel-11 | 54 | Mirko |  |  |  |
| 2955 | 755.2 | **Stage 3 for GBA extensions for re-use of SIP Digest credentials** | 203d? | 2011-12-02 A | 2012-09-07 A | 100% | 2011-12-02 | 2012-09-07 | 203d? |  | C4; C1 | 6464h | 6464h | GBA-ext-St3 | 28 | Alcatel-Lucent | Rel-11 | 54 | Kimmo | GBA-ext-St3 |  |  |
| 2956 | 755.2.1 | CT4 part of Stage 3 for GBA extensions for re-use of SIP Digest credentials | 203d? | 2011-12-02 A | 2012-09-07 A | 100% | 2011-12-02 | 2012-09-07 | 203d? | finish no earlier than 2012-09-07 | C4 | 1608h | 1608h | GBA-ext-St3 | 28 | Alcatel-Lucent | Rel-11 | 54 | Kimmo |  |  |  |
| 2957 | 755.2.2 | CT1 part of Stage 3 for GBA extensions for re-use of SIP Digest credentials | 202d? | 2011-12-05 A | 2012-09-07 A | 100% | 2011-12-05 | 2012-09-07 | 202d? | finish no earlier than 2012-09-07 | C1 | 1608h | 1608h | GBA-ext-St3 | 28 | Alcatel-Lucent | Rel-11 | 54 | Frederic |  |  |  |
| 2958 | 756 | Extensions of Acoustic Test Specifications in TS 26.131 and TS 26.132 | 332d? | 2011-06-08 A | 2012-09-12 A | 100% | 2011-06-08 | 2012-09-12 | 332d? | finish no earlier than 2012-09-12 | S4 | 2648h | 2648h | Ext_ATS | 27 | Orange, Qualcomm | Rel-11 | 52 | Paolo | Ext_ATS |  |  |
| 2959 | 757 | **Enhancements to Multimedia: PSS, MMS, and MBMS Enhancements and Performance Improvements** | 397d? | 2011-09-07 A | 2013-03-06 A | 100% | 2011-09-07 | 2013-03-06 | 397d? |  | S4 | 10928.6h | 10928.6h | EMM | 27 | Qualcomm | Rel-11 | 53 | Paolo | EMM |  |  |
| 2960 | 757.1 | Enhancement to FEC for MBMS | 386d? | 2011-09-21 A | 2013-03-06 A | 100% | 2011-09-21 | 2013-03-06 | 386d? | finish no earlier than 2013-03-06 | S4 | 3048h | 3048h | EMM-EFEC | 27 | Qualcomm | Rel-11 | 53 | Paolo | EMM-EFEC |  |  |
| 2961 | 757.2 | Download Delivery Enhancements for MBMS | 325d? | 2011-09-21 A | 2012-12-12 A | 100% | 2011-09-21 | 2012-12-12 | 325d? | finish no earlier than 2012-12-12 | S4 | 2576.59h | 2576.59h | EMM-DDE | 27 | Qualcomm | Rel-11 | 53 | Paolo | EMM-DDE |  |  |
| 2962 | 757.3 | IMS-based PSS and MBMS Streaming Synchronization Enhancements | 268d? | 2011-09-07 A | 2012-09-12 A | 100% | 2011-09-07 | 2012-09-12 | 268d? | finish no earlier than 2012-09-12 | S4 | 2128h | 2128h | EMM-IPME | 27 | InterDigital Communications | Rel-11 | 53 | Paolo | EMM-IPME |  |  |
| 2963 | 758 | Mobile 3D Video Coding | 71d? | 2012-06-07 A | 2012-09-12 A | 100% | 2012-06-07 | 2012-09-12 | 71d? | finish no earlier than 2012-09-12 | S4 | 560h | 560h | M3DV | 29 | Orange | Rel-11 | 56 | Paolo | M3DV |  |  |
| 2964 | 759 | **Rel-11 Operations, Administration, Maintenance and Provisioning (OAM&P)** | 519d? | 2011-03-23 A | 2013-03-07 A | 100% | 2011-03-23 | 2013-03-06 | 519d? |  | S5 | 39394.5h | 39394.5h | OAM11 | 26 |  | Rel-11 | 51 | Mirko | OAM11 |  |  |
| 2965 | 759.1 | **Rel-11 Network Infrastructure Management** | 519d? | 2011-03-23 A | 2013-03-07 A | 100% | 2011-03-23 | 2013-03-06 | 519d? |  | S5 | 8256h | 8256h | OAM11-NIM | 26 |  | Rel-11 | 51 | Mirko | OAM11-NIM |  |  |
| 2966 | 759.1.1 | IRP framework enhancements to support Management of Converged Networks | 515d? | 2011-03-23 A | 2013-03-07 A | 100% | 2011-03-23 | 2013-03-06 | 515d? | finish no earlier than 2013-03-06 | S5 | 4104h | 4104h | OAM-FMC-IRP | 26 | Nokia Siemens Networks, Ericsson | Rel-11 | 51 | Mirko | OAM-FMC-IRP |  |  |
| 2967 | 759.2 | **Rel-11 Performance Management** | 458d? | 2011-03-23 A | 2012-12-12 A | 100% | 2011-03-23 | 2012-12-12 | 458d? |  | S5 | 14530.5h | 14530.5h | OAM11-PM | 26 |  | Rel-11 | 51 | Mirko | OAM11-PM |  |  |
| 2968 | 759.2.1 | IMS Performance Management enhancements | 252d? | 2011-03-23 A | 2012-03-07 A | 100% | 2011-03-23 | 2012-03-07 | 252d? | finish no earlier than 2012-09-12 | S5 | 2010.52h | 2010.52h | OAM-ePM-IMS | 26 | ZTE | Rel-11 | 51 | Mirko | OAM-ePM-IMS |  |  |
| 2969 | 759.2.2 | Enhanced Management of UE based network performance measurements | 455d? | 2011-03-23 A | 2012-12-12 A | 100% | 2011-03-23 | 2012-12-12 | 455d? | finish no earlier than 2012-12-12 | S5 | 3624h | 3624h | OAM-ePM-UE | 26 | Huawei, Ericsson, Nokia Siemens Networks | Rel-11 | 51 | Mirko | OAM-ePM-UE |  |  |
| 2970 | 759.2.3 | CN performance measurements enhancement | 334d? | 2011-06-08 A | 2012-09-12 A | 100% | 2011-06-08 | 2012-09-12 | 334d? | finish no earlier than 2012-09-12 | S5 | 2648h | 2648h | OAM-ePM-CN | 27 | China Mobile | Rel-11 | 52 | Mirko | OAM-ePM-CN |  |  |
| 2971 | 759.2.4 | Management of Carrier Aggregation for LTE | 325d? | 2011-09-21 A | 2012-12-12 A | 100% | 2011-09-21 | 2012-12-12 | 325d? | finish no earlier than 2012-12-12 | S5 | 2584h | 2584h | OAM-CA | 27 | Nokia Siemens Networks, Ericsson | Rel-11 | 53 | Mirko | OAM-CA |  | CA |

Notes:
- 2948: RP#57 completed testing / WI rapporteur e-mail: Yuan Qi (yuanqi@catr.cn)
- 2949: SP#53 completed new EPS algorithms e.g. for China / Impacted TSs and TRs: 33.401, New (35.221, 35.222, 35.223, 35.924) / WI rapporteur e-mail: Yuan Qi (yuanqi@catr.cn)
- 2950: RP#57 completed. Testing for SA3 TSs 33.401, new (35.221, 35.222, 35.223) / Impacted TSs and TRs: 36.523-1, 36.523-2, 36.523-3 / WI rapporteur e-mail: Ms Jun Chen (chenjun@catr.cn)
- 2951: SP#55 completed (No normative work). TR 33.838v200 for Approval & abandoned new TS 33.237. Continuation of Rel-9 UID_410027/410029. Builds on TR 33.937 Study of Mechanisms for PUCI / Impacted TSs and TRs: New TR 33.838, abandoned New TS 33.237 / WI rapporteur e-mail: Anand R. Prasad (anand@bq.jp.nec.com)
- 2952: SP#55 completed. Add HeNB Security extensions to Extended H(e)NB Features (EHNBF) UID_450053 / Impacted TSs and TRs: 33.320 / WI rapporteur e-mail: Marcus Wong (mwong@huawei.com)
- 2953: Stage 2/3. CP#57 completed / WI rapporteur e-mail: Silke.Holtmanns@nokia.com
- 2954: SP#55 completed / Impacted TSs and TRs: 33.220 / WI rapporteur e-mail: Silke.Holtmanns@nokia.com
- 2955: CP#57 completed / Impacted TSs and TRs: Stage 3 / WI rapporteur e-mail: jean-jacques.trottin@alcatel-lucent.com
- 2956: CP#57 completed / Impacted TSs and TRs: 29.109 / WI rapporteur e-mail: jean-jacques.trottin@alcatel-lucent.com
- 2957: CP#57 completed / Impacted TSs and TRs: 24.109 / WI rapporteur e-mail: jean-jacques.trottin@alcatel-lucent.com
- 2958: SP#57 completed / Impacted TSs and TRs: 26.131, 26.132 / WI rapporteur e-mail: stephane.ragot@orange-ftgroup.com, Andre Schevciw (aschevci@qualcomm.com)
- 2959: Stage 3. SP#59 completed / Impacted TSs and TRs: 26.140, 26.234, 26.247, New TR 26.951=>26.851 / WI rapporteur e-mail: Nikolai Leung (nleung@qualcomm.com)
- 2960: SP#59 completed / Impacted TSs and TRs: 26.346, new TR 26.947 / WI rapporteur e-mail: Thomas Stockhammer (c_tstock@qualcomm.com)
- 2961: SP#58 completed / Impacted TSs and TRs: 26.346, new TR 26.951=>26.851 / WI rapporteur e-mail: Nikolai Leung (nleung@qualcomm.com)
- 2962: SP#58 completed / Impacted TSs and TRs: 26.237, new TR 26.951=>26.851 / WI rapporteur e-mail: hang.liu@interdigital.com
- 2963: SP#57 completed. Triggered by UID_520036 Rel-11 Study on Mobile 3D Video Coding (FS_M3DVC) TR 26.905. / Impacted TSs and TRs: 26.140, 26.234, 26.244, 26.245, 26.247, 26.346, 26.430, 26.905 / WI rapporteur e-mail: gilles.teniou@orange.com
- 2964: OAM11 is an umbrella Feature also for OAM&P related TEI11 type of changes that are not part of any other dedicated feature/WI
- 2965: -
- 2966: SP#59 completed. Triggered by SA5 Studies TR 32.833, 32.828, 32.831 / Impacted TSs and TRs: 32.101/103/150, new (28.620/621/622/623/624/625/626/627/628/629/631/632/633/651/652/653/654/655/656/657/658/659/661/662/663/671/672/673/674/675/676/701/702/703/704/705/706/707/708/709/731/732/733/734/735/736/751/752/753, 32.107/156/157/853/854 / WI rapporteur e-mail: thomas.tovinger@ericsson.com, olaf.pollakowski@nsn.com
- 2967: -
- 2968: SP#55 completed / Impacted TSs and TRs: 32.409 / WI rapporteur e-mail: guo.wenjie1@zte.com.cn
- 2969: SP#58 completed / Impacted TSs and TRs: 32.421, 32.422, 32.423, 32.441, 32.442, 32.446 / WI rapporteur e-mail: Zou Lan (zlan@huawei.com), ulf.hubinette@ericsson.com, gyula.bodog@nsn.com
- 2970: SP#57 completed / Impacted TSs and TRs: 32.406, 32.407, 32.426 / WI rapporteur e-mail: Liang Shuangchun (liangshuangchun@cmdi.chinamobile.com), Li Jian (lijian@chinamobile.com)
- 2971: SP#58 completed. Updated WID SP-110636=>SP-120776. Stage 2 in Rel-10 RAN Feature UID_460007 Carrier Aggregation for LTE (LTE_CA) / Impacted TSs and TRs: 32.425 / WI rapporteur e-mail: yizhi.yao@nsn.com, per.elmdahl@ericsson.com

| ID | WBS | Task | Type | Duration | Start | Finish | Complete | Baseline start | Baseline finish | Baseline duration | Constraint | Resources | Work | Actual work | Acronym | PCG approved | Release | TSG approved | MCC resp | Special Focus Doc | Acronym_3GU_Export | WI rapporteur name | WI rapporteur e-mail |
| --- | --- | --- | --- | --- | --- | --- | --- | --- | --- | --- | --- | --- | --- | --- | --- | --- | --- | --- | --- | --- | --- | --- | --- |
| 2972 | 759.3 | **Rel-11 Self-Organizing Networks (SON) - OAM aspects** |  | 519d? | 2011-03-23 A | 2013-03-06 A | 100% | 2011-03-23 | 2013-03-06 | 519d? |  | S5 | 12456h | 12456h | OAM11-SON | 26 | Rel-11 | 51 | Mirko | SON | OAM11-SON |  |  |
| 2973 | 759.3.1 | UTRAN Self-Organizing Networks (SON) management |  | 388d? | 2011-03-23 A | 2012-09-12 A | 100% | 2011-03-23 | 2012-09-12 | 388d? | finish no earlier than 2012-09-12 | S5 | 3088h | 3088h | OAM-SON-UTRAN | 26 | Rel-11 | 51 | Mirko | SON | OAM-SON-UTRAN | Huawei | kai.zhangkai@huawei.com |
| 2974 | 759.3.2 | LTE Self-Organizing Networks (SON) coordination management |  | 387d? | 2011-09-21 A | 2013-03-06 A | 100% | 2011-09-21 | 2013-03-06 | 387d? | finish no earlier than 2013-03-06 | S5 | 3072h | 3072h | OAM-SON-LTE_COORD | 27 | Rel-11 | 53 | Mirko | SON | OAM-SON-LTE_COORD | Huawei, Nokia Siemens Networks | kai.zhangkai@huawei.com, clemens.suerbaum@nsn.com |
| 2975 | 759.3.3 | Inter-RAT Energy Saving Management |  | 269d? | 2011-12-07 A | 2012-12-12 A | 100% | 2011-12-07 | 2012-12-12 | 269d? | finish no earlier than 2012-12-12 | S5 | 2144h | 2144h | OAM-IRAT-ESM | 28 | Rel-11 | 54 | Mirko | SON | OAM-IRAT-ESM | Nokia Siemens Networks, Huawei | clemens.suerbaum@nsn.com, xiahaitao@huawei.com |
| 2976 | 760 | **Rel-11 Charging Management small Enhancements** |  | 717d? | 2010-03-25 A | 2012-12-12 A | 100% | 2010-03-25 | 2012-12-12 | 717d? |  | S5 | 11528h | 11528h | CH11 | 26 | Rel-11 | 51 | Mirko |  | CH11 |  |  |
| 2977 | 760.1 | Add solutions for Rc - reference point within the Online Charging System (OCS) |  | 392d? | 2010-03-25 A | 2011-09-21 A | 100% | 2010-03-25 | 2011-09-21 | 392d? | finish no earlier than 2011-08-26 | S5 | 3120h | 3120h | CH-Rc | 24 | Rel-11 | 47 | Mirko |  | CH-Rc | Huawei | shan.mingjun@huawei.com |
| 2978 | 760.2 | Charging for Policy Enhancements for Sponsored Connectivity and Coherent Access to Policy related Data Bases |  | 135d? | 2011-03-21 A | 2011-09-21 A | 100% | 2011-03-21 | 2011-09-21 | 135d? | finish no earlier than 2011-09-21 | S5 | 1064h | 1064h | PEST-CH | 26 | Rel-11 | 51 | Mirko |  | PEST-CH | Ericsson | patrik.teppo@@ericsson.com |
| 2979 | 760.3 | Unification of Charging session from SIP AS and SRVCC functions in IMS |  | 203d? | 2012-03-07 A | 2012-12-12 A | 100% | 2012-03-07 | 2012-12-12 | 203d? | finish no earlier than 2012-12-12 | S5 | 1608h | 1608h | UCHIMS_AS-SRVCC | 28 | Rel-11 | 55 | Mirko |  | UCHIMS_AS-SRVCC | Alcatel-Lucent | maryse.gardella@alcatel-lucent.com |
| 2980 | 761 | **Transit Inter Operator Identifier for IMS Interconnection Charging in multi operator environment** |  | 432d? | 2010-10-27 A | 2012-06-15 A | 100% | 2010-10-27 | 2012-06-15 | 432d? |  | S5; S1; C1 | 15921.1h | 15921.1h | IOI_IMS_CH | 26 | Rel-11 | 51 | Mirko |  | IOI_IMS_CH | Deutsche Telekom | matthias.seibel@telekom.de |
| 2981 | 761.1 | Stage 1 for Transit Inter Operator Identifier for IMS Interconnection Charging in multi operator environment |  | 237d? | 2010-10-27 A | 2011-09-21 A | 100% | 2010-10-27 | 2011-09-21 | 237d? |  | S1 | 1896h | 1896h | IOI_IMS_CH | 26 | Rel-11 | 51 | Dionisio |  |  | Deutsche Telekom | matthias.seibel@telekom.de |
| 2982 | 761.2 | Stage 2/3 SA5 part of Transit Inter Operator Identifier for IMS Interconnection Charging in multi operator environment |  | 187d? | 2010-10-27 A | 2011-12-07 A | 100% | 2010-10-27 | 2011-12-07 | 187d? | finish no earlier than 2012-03-21 | S5 | 1488h | 1488h | IOI_IMS_CH | 26 | Rel-11 | 51 | Mirko |  |  | Deutsche Telekom | matthias.seibel@telekom.de |
| 2983 | 761.3 | Stage 3 for Transit Inter Operator Identifier for IMS Interconnection Charging in multi operator environment |  | 273d? | 2011-06-07 A | 2012-06-15 A | 100% | 2011-06-07 | 2012-06-15 | 273d? | finish no earlier than 2012-06-01 | C1 | 2169.09h | 2169.09h | IOI_IMS_CH | 27 | Rel-11 | 52 | Frederic |  |  | Deutsche Telekom | martin.huelsemann@telekom.de] |
| 2984 | 762 | **User Data Convergence - Data Model** |  | 647d? | 2010-03-25 A | 2012-09-07 A | 100% | 2010-03-25 | 2012-09-07 | 647d? |  | C4; S1 | 22984h | 22984h | UDC_DM | 25 | Rel-11 | 48 | Kimmo |  | UDC_DM | Telecom Italia | mauro.ficaccio@telecomitalia.it |
| 2985 | 762.1 | Stage 1 for UDC Data Model |  | 392d? | 2010-03-25 A | 2011-09-21 A | 100% | 2010-03-25 | 2011-09-21 | 392d? | finish no earlier than 2010-06-10 | S1 | 3136h | 3136h | UDC_DM | 25 | Rel-11 | 48 | Alain |  |  | Telecom Italia | mauro.ficaccio@telecomitalia.it |
| 2986 | 762.2 | TR on User Data Convergence (UDC) Data Model |  | 593d? | 2010-06-04 A | 2012-09-07 A | 100% | 2010-06-04 | 2012-09-07 | 593d? | finish no earlier than 2012-09-07 | C4 | 4736h | 4736h | UDC_DM | 25 | Rel-11 | 48 | Kimmo |  |  | Telecom Italia | mauro.ficaccio@telecomitalia.it |
| 2987 | 762.3 | User Data Convergence (UDC) Data Model |  | 596d? | 2010-06-04 A | 2012-09-07 A | 100% | 2010-06-04 | 2012-09-07 | 596d? | finish no earlier than 2012-09-07 | C4 | 4760h | 4760h | UDC_DM | 25 | Rel-11 | 48 | Kimmo |  |  | Telecom Italia | mauro.ficaccio@telecomitalia.it |
| 2988 | 763 | Definition of the UICC Application for Hosting Party Module |  | 327d? | 2011-03-18 A | 2012-06-15 A | 100% | 2011-03-18 | 2012-06-15 | 327d? | finish no earlier than 2012-06-15 | C6 | 2608h | 2608h | HPM_UICC | 26 | Rel-11 | 51 | Xavier |  | HPM_UICC | Gemalto | Denis.Lheriteau@gemalto.com |
| 2989 | 764 | Usability improvement of Inter-IMS Network to Network Interface (II-NNI) specification for inter-connection by means of Option Item list |  | 273d? | 2011-06-07 A | 2012-06-15 A | 100% | 2011-06-07 | 2012-06-15 | 273d? | finish no earlier than 2012-06-01 | C3 | 2169.56h | 2169.56h | NNI_OI | 27 | Rel-11 | 52 | Adrian |  | NNI_OI | NTT | arai.kenjiro@lab.ntt.co.jp |
| 2990 | 765 | **enhanced Nodes Restoration for EPC (Stage 2/3)** |  | 668d? | 2011-06-03 A | 2013-12-06 A | 100% | 2011-06-03 | 2013-12-06 | 668d? |  | C4; C1; C3; IETF | 27728h | 27728h | eNR_EPC | 27 | Rel-11 | 52 | Kimmo |  | eNR_EPC | ZTE | lu.fei1@zte.com.cn |
| 2991 | 765.1 | CT4 part of enhanced Nodes Restoration for EPC |  | 402d? | 2011-06-03 A | 2012-12-07 A | 100% | 2011-06-03 | 2012-12-07 | 402d? | finish no earlier than 2012-12-07 | C4 | 3192h | 3192h | eNR_EPC | 27 | Rel-11 | 52 | Kimmo |  |  | ZTE | lu.fei1@zte.com.cn |
| 2992 | 765.2 | (IETF) CT4 part of enhanced Nodes Restoration for EPC (RFC 7077) |  | 266d? | 2012-12-07 A | 2013-12-06 A | 100% | 2012-12-07 | 2013-12-06 | 266d? | finish no earlier than 2013-12-06 | C4-IETF | 2104h | 2104h | eNR_EPC | 30 | Rel-11 | 58 | Kimmo |  |  | Lionel Morand | Lionel Morand |
| 2993 | 765.3 | CT1 part of enhanced Nodes Restoration for EPC |  | 66d? | 2011-12-02 A | 2012-03-02 A | 100% | 2011-12-02 | 2012-03-02 | 66d? | finish no earlier than 2012-06-15 | C1 | 528h | 528h | eNR_EPC | 28 | Rel-11 | 54 | Frederic |  |  | ZTE | lu.fei1@zte.com.cn |
| 2994 | 765.4 | CT3 part of enhanced Nodes Restoration for EPC |  | 67d? | 2012-09-10 A | 2012-12-07 A | 100% | 2012-09-10 | 2012-12-07 | 67d? | finish no earlier than 2012-12-07 | C3 | 528h | 528h | eNR_EPC | 29 | Rel-11 | 57 | Adrian |  |  | ZTE | lu.fei1@zte.com.cn |
| 2995 | 766 | **Reference Location Information (Stage 3)** |  | 78d? | 2011-06-03 A | 2011-09-16 A | 100% | 2011-06-03 | 2011-09-16 | 78d? |  | C4; C1 | 1860.74h | 1860.74h | RLI | 27 | Rel-11 | 52 | Kimmo |  | RLI | Huawei | susan.shishufeng@Huawei.com |
| 2996 | 766.1 | CT4 part of Reference Location Information (Stage 3) | milestone | 0d? | 2011-06-03 A | 2011-06-03 A | 100% | 2011-06-03 | 2011-06-03 | 0d? | finish no earlier than 2011-06-03 | C4 |  |  | RLI | 27 | Rel-11 | 52 | Kimmo |  |  | Huawei | susan.shishufeng@Huawei.com |
| 2997 | 766.2 | CT1 part of Reference Location Information (Stage 3) |  | 78d? | 2011-06-03 A | 2011-09-16 A | 100% | 2011-06-03 | 2011-09-16 | 78d? | finish no earlier than 2011-08-30 | C1 | 612.74h | 612.74h | RLI | 27 | Rel-11 | 52 | Frederic |  |  | Huawei | susan.shishufeng@Huawei.com |

Notes:
- 2972: -
- 2973: SP#57 completed. Updated WID SP-110518=>SP-120552 / Impacted TSs and TRs: UTRA 32.405, 32.500, 32.511, 32.521, 32.522, 32.526, 32.642, 32.646
- 2974: SP#59 completed / Impacted TSs and TRs: LTE 32.425, 32.500, 32.521, 32.522, 32.526, 32.762, 32.766
- 2975: SP#58 completed. Triggered by Rel-11 TR 32.834 (Study on OAM aspects of inter-RAT Energy Saving) UID_510045. Needs coordination with RAN WGs / Impacted TSs and TRs: 32.405, 32.551, 32.522, 32.526, 32.642, 32.646, 32.762, 32.766
- 2976: CH11 is an umbrella Feature also for OAM&P related TEI11 type of changes that are not part of any other dedicated feature/WI / Impacted TSs and TRs: TR 30.821
- 2977: SP#53 completed. Stage 3 (Stage 1 in 22.115). Triggered by Rel-10 TR 32.825 SA5 Study on Rc Reference Point Functionalities and Message Flows (UID_410044) / Impacted TSs and TRs: 32.296, 32.299
- 2978: SP#53 completed. Stage 3 / Impacted TSs and TRs: 32.251, 32.298, 32.299
- 2979: Stage 2/3. SP#58 completed / Impacted TSs and TRs: 32.260, 32.275, 32.298, 32.299
- 2980: Stage 2/3. CP#56 completed. Stage 1 in SA1 22.115
- 2981: SP#53 completed under IPXS / Impacted TSs and TRs: 22.115
- 2982: SP#54 completed / Impacted TSs and TRs: 32.240, 32.260, 32.298, 32.299
- 2983: CP#56 completed / Impacted TSs and TRs: 24.229
- 2984: CP#57 completed. SP#48 Stage 1 completed as Rel-10
- 2985: SP#53 completed under Rel-10 UDC / Impacted TSs and TRs: 22.101
- 2986: CP#57 completed / Impacted TSs and TRs: new TR 29.935
- 2987: CP#57 completed / Impacted TSs and TRs: 29.335
- 2988: CP#56 completed / Impacted TSs and TRs: 31.102, New TS 31.104
- 2989: CP#56 completed. Stage 3 (No architectural change, specify the list of selectable items related to control plane signalling directly for the same architecture) / Impacted TSs and TRs: 29.165
- 2990: Triggered by DRAFT TR 23.857 Study on EPC Nodes Restoration UID_490014
- 2991: CP#58 completed / Impacted TSs and TRs: 23.007, 23.008, 23.018, 29.274, 29.275
- 2992: CP#62 completed / Impacted TSs and TRs: RFC 7077 (was draft-ietf-netext-update-notifications)
- 2993: CP#55 completed / Impacted TSs and TRs: 29.118
- 2994: CP#58 completed / Impacted TSs and TRs: 29.212
- 2995: CP#53 completed. Stage 2 clause C.1.1 of SA2 TS 23.167 CR#0182 (WI code: TEI11)
- 2996: CP#52 completed / Impacted TSs and TRs: 23.008, 29.228, 29.328, 29.329
- 2997: CP#53 completed / Impacted TSs and TRs: 24.229

| ID | WBS | Task | Duration | Start | Finish | Complete | Baseline start | Baseline finish | Baseline duration | Constraint | Resources | Work | Actual work | Acronym | PCG approved | WI rapporteur name | WI rapporteur e-mail | Release | TSG approved | MCC resp | Acronym_3GU_Export | PCG stopped | TSG stopped | Special Focus Doc |
| --- | --- | --- | --- | --- | --- | --- | --- | --- | --- | --- | --- | --- | --- | --- | --- | --- | --- | --- | --- | --- | --- | --- | --- | --- |
| 2998 | 767 | **IMS Stage 3 IETF Protocol Alignment - phase 5** | 868d? | 2011-06-07 A | 2014-09-12 A | 100% | 2011-06-07 | 2014-12-05 | 927d? |  | C1; C3; IETF | 34260h | 34260h | IMSProtoc5 | 27 | Alcatel-Lucent | keith.drage@alcatel-lucent.com | Rel-11 | 52 | Frederic | IMSProtoc5 |  |  |  |
| 2999 | 767.1 | CT1 part of IMS Stage 3 IETF Protocol Alignment - phase 5 | 333d? | 2011-06-07 A | 2012-09-07 A | 100% | 2011-06-07 | 2012-09-07 | 333d? | finish no earlier than 2012-09-07 | C1 | 2648h | 2648h | IMSProtoc5 | 27 | Alcatel-Lucent | keith.drage@alcatel-lucent.com | Rel-11 | 52 | Frederic |  |  |  |  |
| 3000 | 767.2 | (IETF) CT1 part of IMS Stage 3 IETF Protocol Alignment - phase 5 (RFC 7315) | 356.5d? | 2013-03-01 A | 2014-09-12 A | 100% | 2013-03-01 | 2014-12-05 | 416.5d? | finish no earlier than 2014-09-12 | C1-IETF | 2812h | 2812h | IMSProtoc5 | 30 | Roland Jesske | Roland Jesske | Rel-11 | 59 | Frederic |  |  |  |  |
| 3001 | 767.3 | (IETF) CT1 part of IMS Stage 3 IETF Protocol Alignment - phase 5 (RFC 7135) | 203d? | 2013-09-06 A | 2014-06-13 A | 100% | 2013-09-06 | 2014-06-13 | 203d? | finish no earlier than 2014-06-13 | C1-IETF | 1608h | 1608h | IMSProtoc5 | 31 | Roland Jesske | Roland Jesske | Rel-11 | 61 |  |  |  |  |  |
| 3002 | 767.4 | CT3 part of IMS Stage 3 IETF Protocol Alignment - phase 5 | 333d? | 2011-06-07 A | 2012-09-07 A | 100% | 2011-06-07 | 2012-09-07 | 333d? | finish no earlier than 2012-09-07 | C3 | 2648h | 2648h | IMSProtoc5 | 27 | Alcatel-Lucent | keith.drage@alcatel-lucent.com | Rel-11 | 52 | Adrian |  |  |  |  |
| 3003 | 767.5 | Deleted - (IETF) CT3 part of IMS Stage 3 IETF Protocol Alignment - phase 5 (avasarala-dispatch-comm-div-notification) | 466d? | 2012-12-07 A | 2014-09-12 A | 100% | 2012-12-07 | 2014-12-05 | 526d? | finish no earlier than 2014-09-12 | C3-IETF | 3712h | 3712h | IMSProtoc5 | 30 | Andrew Allen | Andrew Allen | Rel-11 | 58 | Adrian |  | PCG-33 | CP-65 |  |
| 3004 | 768 | **Service Identification for RRC Improvements in GERAN (Stage 2/3)** | 258d? | 2011-09-19 A | 2012-09-07 A | 100% | 2011-09-19 | 2012-09-07 | 258d? |  | S2; C4; C3; G2 | 16216h | 16216h | SIRIG | 27 | China Mobile | zhanghao@chinamobile.com | Rel-11 | 51 | Maurice | SIRIG |  |  |  |
| 3005 | 768.1 | Stage 2 for Service Identification for RRC Improvements in GERAN | 61d? | 2012-06-18 A | 2012-09-07 A | 100% | 2012-06-18 | 2012-09-07 | 61d? | finish no earlier than 2012-09-07 | S2 | 480h | 480h | SIRIG | 29 |  |  | Rel-11 | 56 | Maurice |  |  |  |  |
| 3006 | 768.2 | **CN aspects of Service Identification for RRC Improvements in GERAN** | 203d? | 2011-12-02 A | 2012-09-07 A | 100% | 2011-12-02 | 2012-09-07 | 203d? |  | C4; C3 | 5464h | 5464h | SIRIG | 28 | China Mobile | zhanghao@chinamobile.com | Rel-11 | 54 | Kimmo |  |  |  |  |
| 3007 | 768.2.1 | CT4 part of CN aspects of Service Identification for RRC Improvements in GERAN | 203d? | 2011-12-02 A | 2012-09-07 A | 100% | 2011-12-02 | 2012-09-07 | 203d? | finish no earlier than 2012-09-07 | C4 | 1608h | 1608h | SIRIG | 28 | China Mobile | zhanghao@chinamobile.com | Rel-11 | 54 | Kimmo |  |  |  |  |
| 3008 | 768.2.2 | Deleted - CT3 part of CN aspects of Service Identification for RRC Improvements in GERAN | 77d? | 2012-03-02 A | 2012-06-15 A | 100% | 2012-03-02 | 2012-06-15 | 77d? | finish no earlier than 2012-06-01 | C3 | 608h | 608h | SIRIG | 28 | China Mobile | zhanghao@chinamobile.com | Rel-11 | 55 | Adrian |  | PCG-29 | CP-56 |  |
| 3009 | 768.3 | GERAN2 part of Service Identification for RRC Improvements in GERAN | 252d? | 2011-09-19 A | 2012-08-31 A | 100% | 2011-09-19 | 2012-08-31 | 252d? | finish no earlier than 2012-08-31 | G2 | 2016h | 2016h | SIRIG | 27 | China Mobile, Huawei | Juan Deng, Yang Zhao | Rel-11 | 51 | Gert |  |  |  |  |
| 3010 | 769 | **SAE Protocol Development - Phase 2** | 259d? | 2011-09-16 A | 2012-09-07 A | 100% | 2011-09-16 | 2012-09-07 | 259d? |  | C1 | 6168h | 6168h | SAES2 | 27 | Nokia Siemens Networks | robert.zaus@nsn.com | Rel-11 | 53 | Frederic | SAES2 |  |  |  |
| 3011 | 769.1 | SAE Protocol Development (Stage 3) - Phase 2 | 259d? | 2011-09-16 A | 2012-09-07 A | 100% | 2011-09-16 | 2012-09-07 | 259d? | finish no earlier than 2012-09-07 | C1 | 2048h | 2048h | SAES2 | 27 | Nokia Siemens Networks | robert.zaus@nsn.com | Rel-11 | 53 | Frederic |  |  |  |  |
| 3012 | 769.2 | CS Fallback in EPS - Phase 2 | 259d? | 2011-09-16 A | 2012-09-07 A | 100% | 2011-09-16 | 2012-09-07 | 259d? | finish no earlier than 2012-09-07 | C1 | 2048h | 2048h | SAES2-CSFB | 27 | Nokia Siemens Networks | robert.zaus@nsn.com | Rel-11 | 53 | Frederic | SAES2-CSFB |  |  |  |
| 3013 | 770 | **GCSMSC and GCR Redundancy for VGCS/VBS (Stage 2/3)** | 258d? | 2011-09-19 A | 2012-09-07 A | 100% | 2011-09-19 | 2012-09-07 | 258d? |  | C1 | 5680h | 5680h | RT_VGCS_Red | 27 | Nokia Siemens Networks | robert.zaus@nsn.com | Rel-11 | 53 | Frederic | RT_VGCS_Red |  |  |  |
| 3014 | 770.1 | CT1 part of GCSMSC and GCR Redundancy for VGCS/VBS | 258d? | 2011-09-19 A | 2012-09-07 A | 100% | 2011-09-19 | 2012-09-07 | 258d? | finish no earlier than 2012-09-07 | C1 | 2048h | 2048h | RT_VGCS_Red | 27 | Nokia Siemens Networks | robert.zaus@nsn.com | Rel-11 | 53 | Frederic |  |  |  |  |
| 3015 | 770.2 | Deleted - CT4 part of GCSMSC and GCR Redundancy for VGCS/VBS | 197d? | 2011-09-19 A | 2012-06-15 A | 100% | 2011-09-19 | 2012-06-15 | 197d? | finish no earlier than 2012-06-15 | C4 | 1568h | 1568h | RT_VGCS_Red | 27 | Nokia Siemens Networks | robert.zaus@nsn.com | Rel-11 | 53 | Kimmo |  | PCG-29 | CP-56 |  |
| 3016 | 771 | Support of RFC 6140 in IMS | 203d? | 2011-12-02 A | 2012-09-07 A | 100% | 2011-12-02 | 2012-09-07 | 203d? | finish no earlier than 2012-09-07 | C1 | 1608h | 1608h | GINI | 28 | Deutsche Telekom | martin.huelsemann@telekom.de | Rel-11 | 54 | Frederic | GINI |  |  |  |
| 3017 | 772 | **Enhancements for Multimedia Priority Service (MPS) – Gateway Control Priority** | 203d? | 2011-12-02 A | 2012-09-07 A | 100% | 2011-12-02 | 2012-09-07 | 203d? |  | C4; C3 | 6464h | 6464h | eMPS_Gateway | 28 | Telcordia | Viqar Shaikh | Rel-11 | 54 | Kimmo | eMPS_Gateway |  |  | Public Safety (I-A) |
| 3018 | 772.1 | CT4 part of Enhancements for Multimedia Priority Service (MPS) – Gateway Control Priority | 202d? | 2011-12-02 A | 2012-09-07 A | 100% | 2011-12-02 | 2012-09-07 | 202d? | finish no earlier than 2012-09-07 | C4 | 1608h | 1608h | eMPS_Gateway | 28 | Telcordia | Viqar Shaikh | Rel-11 | 54 | Kimmo |  |  |  | Public Safety (I-A) |
| 3019 | 772.2 | CT3 part of Enhancements for Multimedia Priority Service (MPS) – Gateway Control Priority | 202d? | 2011-12-02 A | 2012-09-07 A | 100% | 2011-12-02 | 2012-09-07 | 202d? | finish no earlier than 2012-09-07 | C3 | 1608h | 1608h | eMPS_Gateway | 28 | Telcordia | Viqar Shaikh | Rel-11 | 54 | Adrian |  |  |  | Public Safety (I-A) |
| 3020 | 773 | Inter-IMS Network to Network Interface (II-NNI) enhancements: SIP timers applicability (Stage 3) | 138d? | 2012-03-02 A | 2012-09-07 A | 100% | 2012-03-02 | 2012-09-07 | 138d? | start no earlier than 2012-03-02 | C3 | 1088h | 1088h | NNI_timers | 28 | Telecom Italia | antonio.ascolese@telecomitalia.it | Rel-11 | 55 | Adrian | NNI_timers |  |  |  |
| 3021 | 774 | AT commands for Universal Resource Identifier (URI) support | 188d? | 2012-06-15 A | 2013-03-01 A | 100% | 2012-06-15 | 2013-03-01 | 188d? | finish no earlier than 2013-03-01 | C1 | 1496h | 1496h | ATURI | 29 | Intel | frank.kowalewski@intel.com | Rel-11 | 56 | Frederic | ATURI |  |  |  |
| 3022 | 775 | PS Additional Number (Stage 3) | 62d? | 2012-06-15 A | 2012-09-07 A | 100% | 2012-06-15 | 2012-09-07 | 62d? | finish no earlier than 2012-09-07 | C4 | 488h | 488h | PSAN | 29 | Deutsche Telekom | Yvette.koza@t-mobile.at | Rel-11 | 56 | Kimmo | PSAN |  |  |  |
| 3023 | 776 | Generic IMS User Group Over Sh | 62d? | 2012-06-15 A | 2012-09-07 A | 100% | 2012-06-15 | 2012-09-07 | 62d? | finish no earlier than 2012-09-07 | C4 | 488h | 488h | GenUG_Sh | 29 | Alcatel-Lucent | jean-jacques.trottin@alcatel-lucent.com | Rel-11 | 56 | Kimmo | GenUG_Sh |  |  |  |

Notes:
- 2998: CP#57 completed
- 2999: CP#57 completed / Impacted TSs and TRs: 23.218, 24.229, 24.930
- 3000: CP#65 completed / Impacted TSs and TRs: RFC 7315 (was draft-drage-sipping-rfc3455bis), draft-mohali-dispatch-originating-cdiv-parameter
- 3001: CP#64 completed / Impacted TSs and TRs: RFC 7135 (was draft-polk-local-emergency-rph-namespace)
- 3002: CP#57 completed / Impacted TSs and TRs: 29.163, 29.165
- 3003: CP#64 Draft removed from 3GPP documentation / Impacted TSs and TRs: draft-avasarala-dispatch-comm-div-notification
- 3004: TSG#57, GP#55 completed. CT defined a generic solution (not only for GERAN) / Impacted TSs and TRs: GERAN
- 3005: SP#57 completed / Impacted TSs and TRs: 23.060, 23.251
- 3006: CP#57 completed
- 3007: CP#57 completed / Impacted TSs and TRs: 29.281
- 3008: CP#56 stopped (SA2 decided NO CT3 impact) / Impacted TSs and TRs: 29.212
- 3009: GP#55 completed. GP#51 approved WID / Impacted TSs and TRs: 48.018
- 3010: CP#57 completed. Stage 3 continuation of Rel-8 Feature SAES (3GPP System Architecture Evolution Specification - Evolved Packet System) UID_320005
- 3011: CP#57 completed / Impacted TSs and TRs: 23.122, 24.008, 24.167, 24.229, 24.301, 24.302, 24.303, 24.304, 24.305, 24.312, 29.018, 29.118
- 3012: CP#57 completed / Impacted TSs and TRs: 23.122, 24.008, 24.167, 24.229, 24.301, 24.302, 24.303, 24.304, 24.305, 24.312, 29.018, 29.118
- 3013: CP#57 completed. Stage 2/3 adding a CN internal functionality, not affecting Voice Group Call Service (VGCS)/VBS as perceived by service subscriber. Hence, no Stage 1 impact for VGCS/VBS (42.068, 42.069) / Impacted TSs and TRs: Stage 2/3
- 3014: CP#57 completed / Impacted TSs and TRs: 43.068, 43.069
- 3015: CP#56 stopped (no CT4 impact) / Impacted TSs and TRs: 29.002
- 3016: CP#57 completed. Stage 3. Support procedures and protocol extensions in RFC6140 "Registration for Multiple Phone Numbers in SIP" to IMS for complex UEs. Ensure co-existence with NGCN IP-PBX registration procedures already defined in IMS. / Impacted TSs and TRs: 24.229
- 3017: CP#57 completed. Stage 3. Stage 1 for MPS in 22.153. Details of any MGW actions for priority needs to be further studied within the scope of this WI. / Impacted TSs and TRs: Stage 3
- 3018: CP#57 completed / Impacted TSs and TRs: 23.333, 23.334, 29.232, 29.238, 29.332, 29.333, 29.334
- 3019: CP#57 completed / Impacted TSs and TRs: 29.162, 29.163, 29.292
- 3020: CP#57 completed / Impacted TSs and TRs: 29.165
- 3021: CP#59 completed. Define new AT cmd for URI addresses for IMS services (eg VoLTE). 27.007(AT cmd to control MT functions and GSM/UMTS/LTE network services from TE), 27.005(AT commands for SMS). Currently address types for AT cmd based on dialling# / Impacted TSs and TRs: 27.005, 27.007
- 3022: CP#57 completed. Stage 1 in Rel-11 SA1 TS 22.101 clause 17.7.3 (No Stage 2 needed since no architecture impact) / Impacted TSs and TRs: 23.003, 23.008, 29.002, 29.272, 29.230
- 3023: CP#57 completed / Impacted TSs and TRs: 29.364

| ID | WBS | Task | Duration | Start | Finish | Complete | Baseline start | Baseline finish | Baseline duration | Constraint | Resources | Work | Actual work | Acronym | PCG approved | WI rapporteur name | WI rapporteur e-mail | Release | TSG approved | MCC resp | Acronym_3GU_Export | PCG stopped | TSG stopped | Status Report |
| --- | --- | --- | --- | --- | --- | --- | --- | --- | --- | --- | --- | --- | --- | --- | --- | --- | --- | --- | --- | --- | --- | --- | --- | --- |
| 3024 | 777 | **IMS Operator Determined Call Barring** | 205d? | 2012-09-07 A | 2013-06-14 A | 100% | 2012-09-07 | 2013-06-14 | 205d? |  | C1; C4 | 5411.54h | 5411.54h | IODB | 29 | Orange | Youssef.Chadli@Orange.com | Rel-11 | 57 | Frederic | IODB |  |  |  |
| 3025 | 777.1 | CT1 part of IMS Operator Determined Call Barring | 203d? | 2012-09-10 A | 2013-06-14 A | 100% | 2012-09-10 | 2013-06-14 | 203d? | finish no earlier than 2013-06-14 | C1 | 1616h | 1616h | IODB | 29 | Orange | Youssef.Chadli@Orange.com | Rel-11 | 57 | Frederic |  |  |  |  |
| 3026 | 777.2 | CT4 part of IMS Operator Determined Call Barring | 69d? | 2012-09-07 A | 2013-03-12 A | 100% | 2012-09-07 | 2013-03-12 | 69d? | finish no earlier than 2012-12-07 | C4 | 515.54h | 515.54h | IODB | 29 | Orange | Youssef.Chadli@Orange.com | Rel-11 | 57 | Kimmo |  |  |  |  |
| 3027 | 778 | **Enhanced T.38 FAX support (Stage 3)** | 69d? | 2012-09-06 A | 2012-12-07 A | 100% | 2012-09-06 | 2012-12-07 | 69d? |  | C3; C1; C4 | 2728h | 2728h | MMTel_T.38_FAX | 29 | NEC | Naoaki Suzuki (n-suzuki@en.jp.nec.com) | Rel-11 | 57 | Adrian | MMTel_T.38_FAX |  |  |  |
| 3028 | 778.1 | CT3 part of Enhanced T.38 FAX support | 68d? | 2012-09-07 A | 2012-12-07 A | 100% | 2012-09-07 | 2012-12-07 | 68d? | finish no earlier than 2012-12-07 | C3 | 528h | 528h | MMTel_T.38_FAX | 29 | NEC | Naoaki Suzuki (n-suzuki@en.jp.nec.com) | Rel-11 | 57 | Adrian |  |  |  |  |
| 3029 | 778.2 | CT1 part of Enhanced T.38 FAX support | 67d? | 2012-09-07 A | 2012-12-07 A | 100% | 2012-09-07 | 2012-12-07 | 67d? | finish no earlier than 2012-12-07 | C1 | 528h | 528h | MMTel_T.38_FAX | 29 | NEC | Naoaki Suzuki (n-suzuki@en.jp.nec.com) | Rel-11 | 57 | Frederic |  |  |  |  |
| 3030 | 778.3 | CT4 part of Enhanced T.38 FAX support | 2d? | 2012-09-06 A | 2012-09-07 A | 100% | 2012-09-06 | 2012-09-07 | 2d? | finish no earlier than 2012-12-07 | C4 | 16h | 16h | MMTel_T.38_FAX | 29 | NEC | Naoaki Suzuki (n-suzuki@en.jp.nec.com) | Rel-11 | 57 | Kimmo |  |  |  |  |
| 3031 | 779 | **Deleted - Enhancement of the Protocols for SMS over SGs (Stage 3)** | 142d? | 2011-12-02 A | 2012-06-15 A | 100% | 2011-12-02 | 2012-06-15 | 142d? |  | C4; C1 | 5664h | 5664h | PROTOC_SMS_SGs | 28 | Alcatel-Lucent | jean-jacques.trottin@alcatel-lucent.com | Rel-11 | 54 | Kimmo | PROTOC_SMS_SGs | PCG-29 | CP-56 |  |
| 3032 | 779.1 | Deleted - TR Study on enhancement of protocols for SMS service over SGs | 142d? | 2011-12-02 A | 2012-06-15 A | 100% | 2011-12-02 | 2012-06-15 | 142d? | finish no earlier than 2012-06-15 | C4 | 1128h | 1128h | PROTOC_SMS_SGs | 28 | Alcatel-Lucent | jean-jacques.trottin@alcatel-lucent.com | Rel-11 | 54 | Kimmo |  | PCG-29 | CP-56 |  |
| 3033 | 779.2 | Deleted - CT4 part of Enhancement of the Protocols for SMS over SGs | 142d? | 2011-12-02 A | 2012-06-15 A | 100% | 2011-12-02 | 2012-06-15 | 142d? | finish no earlier than 2012-06-15 | C4 | 1128h | 1128h | PROTOC_SMS_SGs | 28 | Alcatel-Lucent | jean-jacques.trottin@alcatel-lucent.com | Rel-11 | 54 | Kimmo |  | PCG-29 | CP-56 |  |
| 3034 | 779.3 | Deleted - CT1 part of Enhancement of the Protocols for SMS over SGs | 142d? | 2011-12-02 A | 2012-06-15 A | 100% | 2011-12-02 | 2012-06-15 | 142d? | finish no earlier than 2012-06-15 | C1 | 1136h | 1136h | PROTOC_SMS_SGs | 28 | Alcatel-Lucent | jean-jacques.trottin@alcatel-lucent.com | Rel-11 | 54 | Frederic |  | PCG-29 | CP-56 |  |
| 3035 | 780 | **Full Support of Multi-Operator Core Network by GERAN** | 584d? | 2011-03-04 A | 2013-05-17 A | 100% | 2011-03-04 | 2013-05-17 | 584d? |  | G2; S2; C1 | 31293.3h | 31293.3h | Full_MOCN-GERAN | 26 | Alcatel-Lucent | michel.robert@alcatel-lucent.com | Rel-11 | 49 | Paolo | Full_MOCN-GERAN |  |  |  |
| 3036 | 780.1 | GERAN part of Full Support of Multi-Operator Core Network by GERAN | 584d? | 2011-03-04 A | 2013-05-17 A | 100% | 2011-03-04 | 2013-05-17 | 584d? | finish no earlier than 2013-06-07 | G2 | 4656.4h | 4656.4h | Full_MOCN-GERAN | 26 | Alcatel-Lucent | michel.robert@alcatel-lucent.com | Rel-11 | 49 | Gert |  |  |  |  |
| 3037 | 780.2 | Stage 2 for Full Support of Multi-Operator Core Network by GERAN | 160.8d? | 2011-06-08 A | 2012-03-07 A | 100% | 2011-06-08 | 2012-03-07 | 160.8d? | finish no earlier than 2012-03-07 | S2 | 1278.4h | 1278.4h | Full_MOCN-GERAN | 26 | Alcatel-Lucent | nicolas.drevon@alcatel-lucent.com | Rel-11 | 49 | Maurice |  |  |  |  |
| 3038 | 780.3 | **CN Stage 3 for Full Support of Multi-Operator Core Network by GERAN** | 403d? | 2011-06-03 A | 2012-12-07 A | 100% | 2011-06-03 | 2012-12-07 | 403d? |  | C1; C4 | 9838.51h | 9838.51h | Full_MOCN-GERAN | 26 | Alcatel-Lucent | jennifer.liu@alcatel-lucent.com | Rel-11 | 49 | Frederic |  |  |  |  |
| 3039 | 780.3.1 | CT1 part of CN Stage 3 for Full Support of Multi-Operator Core Network by GERAN | 362.8d? | 2011-06-03 A | 2012-12-07 A | 100% | 2011-06-03 | 2012-12-07 | 362.8d? | finish no earlier than 2012-12-07 | C1 | 2886.51h | 2886.51h | Full_MOCN-GERAN | 26 | Alcatel-Lucent | jennifer.liu@alcatel-lucent.com | Rel-11 | 49 | Frederic |  |  |  |  |
| 3040 | 780.3.2 | CT4 part of CN Stage 3 for Full Support of Multi-Operator Core Network by GERAN | 64d? | 2012-06-13 A | 2012-09-07 A | 100% | 2012-06-13 | 2012-09-07 | 64d? | finish no earlier than 2012-09-07 | C4 | 504h | 504h | Full_MOCN-GERAN | 29 | Alcatel-Lucent | michel.robert@alcatel-lucent.com | Rel-11 | 54 | Kimmo |  |  |  |  |
| 3041 | 780.4 | Stage 2 for Gateway Core Network Sharing for GERAN | 192d? | 2012-06-18 A | 2013-03-06 A | 100% | 2012-06-18 | 2013-03-06 | 192d? | finish no earlier than 2013-03-06 | S2 | 1504h | 1504h | Full_MOCN-GERAN-GWCN | 29 | Vodafone | chris.pudney@vodafone.com | Rel-11 | 56 | Maurice | Full_MOCN-GERAN-GWCN |  |  |  |
| 3042 | 781 | **Medium range/local area requirements for multicarrier BTS** | 264d? | 2011-11-25 A | 2012-11-23 A | 100% | 2011-11-25 | 2012-11-23 | 264d? |  | G1 | 6296h | 6296h | MRLA | 28 | Ericsson | Eric Nordström | Rel-11 | 52 | Paolo | MRLA |  |  |  |
| 3043 | 781.1 | Core part: Medium range/local area requirements for multicarrier BTS | 263d? | 2011-11-25 A | 2012-11-23 A | 100% | 2011-11-25 | 2012-11-23 | 263d? | finish no earlier than 2012-11-23 | G1 | 2096h | 2096h | MRLA-Core | 28 | Ericsson | Eric Nordström | Rel-11 | 52 | Paolo | MRLA-Core |  |  |  |
| 3044 | 781.2 | Perf. part: Medium range/local area requirements for multicarrier BTS | 262d? | 2011-11-28 A | 2012-11-23 A | 100% | 2011-11-28 | 2012-11-23 | 262d? | finish no earlier than 2012-11-23 | G1 | 2088h | 2088h | MRLA-Perf | 28 | Ericsson | Eric Nordström | Rel-11 | 52 | Paolo | MRLA-Perf |  |  |  |
| 3045 | 782 | Domain Specific Access Control in GERAN | 131d? | 2012-03-05 A | 2012-08-31 A | 100% | 2012-03-05 | 2012-08-31 | 131d? | finish no earlier than 2012-08-31 | G2 | 1048h | 1048h | GDSAC | 28 | Vodafone | chris.pudney@vodafone.com | Rel-11 | 53 | Gert | GDSAC |  |  |  |
| 3046 | 783 | **Extending 850 MHz Upper Band (814 – 849 MHz)** | 589d? | 2010-12-10 A | 2013-03-01 A | 100% | 2010-12-10 | 2013-03-01 | 589d? |  | R4; R2; R3; R5 | 33352h | 33352h | e850_UB | 26 | Sprint | John.J.Humbert@Sprint.com | Rel-11 | 50 | Issam | e850_UB |  |  |  |
| 3047 | 783.1 | Core part: Extending 850 MHz Upper Band (814 – 849 MHz) | 324d? | 2010-12-10 A | 2012-03-02 A | 100% | 2010-12-10 | 2012-03-02 | 324d? | finish no earlier than 2012-03-02 | R4; R2; R3 | 7776h | 7776h | e850_UB-Core | 26 | Sprint | John.J.Humbert@Sprint.com | Rel-11 | 50 | Issam | e850_UB-Core |  |  | RP-120075 |
| 3048 | 783.2 | Perf. part: Extending 850 MHz Upper Band (814 – 849 MHz) | 324d? | 2010-12-10 A | 2012-03-02 A | 100% | 2010-12-10 | 2012-03-02 | 324d? | finish no earlier than 2012-03-02 | R4 | 2592h | 2592h | e850_UB-Perf | 26 | Sprint | John.J.Humbert@Sprint.com | Rel-11 | 50 | Issam | e850_UB-Perf |  |  | RP-120076 |
| 3049 | 783.3 | Test part: Extending 850 MHz Upper Band (814 – 849 MHz) | 517d? | 2011-03-18 A | 2013-03-01 A | 100% | 2011-03-18 | 2013-03-01 | 517d? | finish no earlier than 2013-03-01 | R5 | 4136h | 4136h | e850_UB-UEConTest | 26 | Sprint | John.J.Humbert@Sprint.com | Rel-11 | 51 | Ingbert | e850_UB-UEConTest |  |  | RP-130043 |

Notes:
- 3024: LS_in C4-121615 GSMA IREG RILTE concluded that TS 22.041 clause 5.4 Stage 1 requirements are not covered by stage 3 specifications
- 3025: CP#60 completed. Handling of premium rate numbers remained OPEN in Rel-11 (shifted to Rel-12). CP-130384 LS_out sent to SA1 / GSMA informing this TSG CT decision. / Impacted TSs and TRs: New TS 24.315
- 3026: CP#58 completed / Impacted TSs and TRs: 23.008 , 23.015 , 29.328 , 29.329 , 29.364
- 3027: CP#58 completed. Linked to Rel-8 Feature: IMS Multimedia Telephony Service (IMS-MMTel) UID_7038. SA1 added FAX stage 1 requirement only in Rel-10 under TEI10 to TS 22.173 (CR#0064)
- 3028: CP#58 completed / Impacted TSs and TRs: 29.163
- 3029: CP#58 completed / Impacted TSs and TRs: 24.229
- 3030: CP#57 completed / Impacted TSs and TRs: 29.332
- 3031: CP#56 stopped. Reason: Protocols for SMS over SGs is replaced by the SIMTC SMS in MME solution (as solution not only for MTC user but for general subscribers) / Impacted TSs and TRs: Stage 3
- 3032: CP#56 stopped (abandonned new TR 29.818) / Impacted TSs and TRs: new TR 29.818
- 3033: CP#56 stopped (abandonned new TS 29.218 Diameter based protocols for SMS service over SGs) / Impacted TSs and TRs: 29.305, new TS 29.218
- 3034: CP#56 stopped / Impacted TSs and TRs: 23.040, 24.011, 43.068
- 3035: GP#58 completed. GP#49 approved WID. Standardization of management of MOCN supporting MSs/UES in CP-150GERAN. Continuation of Rel-10 MOCN-GERAN UID_490001 / Impacted TSs and TRs: GERAN
- 3036: GP#58 completed. GP#49 approved WID / Impacted TSs and TRs: 44.018, 44.060, 45.002, 45.008, 48.008, 48.018
- 3037: SP#55 completed / Impacted TSs and TRs: 23.251, 23.272
- 3038: CP#58 completed
- 3039: CP#58 completed / Impacted TSs and TRs: 24.008
- 3040: CP#57 completed / Impacted TSs and TRs: 23.003
- 3041: SP#59 completed. (23.251CR0062R2 as TEI11. TS 23.251 specifies both MOCN and GWCN for E-UTRAN and UTRAN, but GWCN is not yet supported on GERAN. Extend Full_MOCN-GERAN to also cover GWCN GERAN / Impacted TSs and TRs: 23.251
- 3042: GP#56 completed. GP#52 approved WID / Impacted TSs and TRs: GERAN
- 3043: Stage 3. GP#56 completed. GP#52 approved WID / Impacted TSs and TRs: 45.005
- 3044: Test spec. GP#56 completed. GP#52 approved WID / Impacted TSs and TRs: 51.021
- 3045: GP#55 completed. GP#53 approved WID. Work is dependent upon Full_MOCN-GERAN (UID_510001) / Impacted TSs and TRs: GERAN 44.018
- 3046: Stage 3. Triggered by R4 Rel-10 LTE TR 37.806 Study on Extending 850 MHz (UID_440016) / Impacted TSs and TRs: UTRA, LTE
- 3047: RP#55 completed / Impacted TSs and TRs: 25.101, 25.104, 25.113, 25.133, 25.141, 25.461, 25.466, 36.101, 36.104, 36.113, 36.124, 36.133, 36.141, 36.307, 36.331, 37.104, 37.113, 37.141
- 3048: RP#55 completed / Impacted TSs and TRs: 25.101, 25.104, 25.113, 25.133, 25.141, 25.461, 25.466, 36.101, 36.104, 36.124, 36.133, 36.141, 36.307, 36.331, 37.104, 37.113, 37.141
- 3049: RP#59 completed / Impacted TSs and TRs: 34.108, 34.121-1, 34.121-2, 34.123-1, 34.123-2, 34.123-3, 36.508, 36.521-1, 36.521-2, 36.521-3, 36.523-1, 36.523-2, 36.523-3

| ID | WBS | Task | Duration | Start | Finish | Complete | Baseline start | Baseline finish | Baseline duration | Constraint | Resources | Work | Actual work | Acronym | PCG approved | WI rapporteur name | WI rapporteur e-mail | Release | TSG approved | MCC resp | Special Focus Doc | Acronym_3GU_Export | Status Report |
| --- | --- | --- | --- | --- | --- | --- | --- | --- | --- | --- | --- | --- | --- | --- | --- | --- | --- | --- | --- | --- | --- | --- | --- |
| 3050 | 784 | **Further Self Optimizing Networks (SON) enhancements** | 325d? | 2011-09-19 A | 2012-12-07 A | 100% | 2011-09-19 | 2012-12-07 | 325d? |  | R3; R2 | 10400h | 10400h | SONenh2_LTE_UTRA | 27 | Nokia Siemens Networks | krzysztof.kordybach@nsn.com | Rel-11 | 53 | Juha | SON | SONenh2_LTE_UTRA |  |
| 3051 | 784.1 | Core part: Further Self Optimizing Networks (SON) enhancements | 325d? | 2011-09-19 A | 2012-12-07 A | 100% | 2011-09-19 | 2012-12-07 | 325d? | finish no earlier than 2012-12-07 | R3; R2 | 5200h | 5200h | SONenh2_LTE_UTRA-Core | 27 | Nokia Siemens Networks | krzysztof.kordybach@nsn.com | Rel-11 | 53 | Juha | SON | SONenh2_LTE_UTRA-Core | RP-121557 |
| 3052 | 785 | **Enhancement of Minimization of Drive Tests for E-UTRAN and UTRAN** | 590d? | 2011-09-19 A | 2013-12-06 A | 100% | 2011-09-19 | 2013-12-06 | 590d? |  | R2; R1; R3; R4; R5 | 35608h | 35608h | eMDT_UMTSLTE | 27 | MediaTek | Johan Johansson | Rel-11 | 53 | Yong-Jun |  | eMDT_UMTSLTE |  |
| 3053 | 785.1 | Core part: Enhancement of Minimization of Drive Tests for E-UTRAN and UTRAN | 325d? | 2011-09-19 A | 2012-12-07 A | 100% | 2011-09-19 | 2012-12-07 | 325d? | finish no earlier than 2012-12-07 | R2; R1; R3; R4 | 10400h | 10400h | eMDT_UMTSLTE-Core | 27 | MediaTek | Johan Johansson | Rel-11 | 53 | Yong-Jun |  | eMDT_UMTSLTE-Core | RP-121556 |
| 3054 | 785.2 | Test part: Enhancement of Minimization of Drive Tests for E-UTRAN and UTRAN | 202d? | 2013-03-04 A | 2013-12-06 A | 100% | 2013-03-04 | 2013-12-06 | 202d? | finish no earlier than 2013-12-06 | R5 | 1608h | 1608h | eMDT_UMTSLTE-UEConTest | 30 | NTT DoCoMo | masahiro.tamaoki.eu@nttdocomo.com | Rel-11 | 59 | Ingbert |  | eMDT_UMTSLTE-UEConTest | RP-131447 |
| 3055 | 786 | **Network Energy Saving for E-UTRAN** | 258d? | 2011-09-19 A | 2012-09-07 A | 100% | 2011-09-19 | 2012-09-07 | 258d? |  | R3; GP | 6224h | 6224h | Netw_Energy_LTE | 27 | China Mobile | yangning@chinamobile.com | Rel-11 | 53 | Juha |  | Netw_Energy_LTE |  |
| 3056 | 786.1 | Core part: Network Energy Saving for E-UTRAN | 257d? | 2011-09-19 A | 2012-09-07 A | 100% | 2011-09-19 | 2012-09-07 | 257d? | finish no earlier than 2012-09-07 | R3 | 2056h | 2056h | Netw_Energy_LTE-Core | 27 | China Mobile | yangning@chinamobile.com | Rel-11 | 53 | Juha |  | Netw_Energy_LTE-Core | RP-121016 |
| 3057 | 786.2 | GERAN part: Network Energy Saving for E-UTRAN | 5d? | 2012-08-27 A | 2012-08-31 A | 100% | 2012-08-27 | 2012-08-31 | 5d? | finish no earlier than 2012-08-31 | GP | 40h | 40h |  | 29 | Alcatel-Lucent | marguerite.woch@alcatel-lucent.com | Rel-11 | 55 | Paolo |  |  |  |
| 3058 | 787 | **E-UTRA medium range and MSR medium range/local area BS class requirements** | 325d? | 2011-09-19 A | 2012-12-07 A | 100% | 2011-09-19 | 2012-12-07 | 325d? |  | R4; G1 | 12432h | 12432h | medBS_class_LTE_MSR | 27 | Ericsson | johan.skold@ericsson.com | Rel-11 | 53 | Issam |  | medBS_class_LTE_MSR |  |
| 3059 | 787.1 | Core part: E-UTRA medium range and MSR medium range/local area BS class requirements | 323d? | 2011-09-19 A | 2012-12-07 A | 100% | 2011-09-19 | 2012-12-07 | 323d? | finish no earlier than 2012-12-07 | R4 | 2576h | 2576h | medBS_class_LTE_MSR-Core | 27 | Ericsson | johan.skold@ericsson.com | Rel-11 | 53 | Issam |  | medBS_class_LTE_MSR-Core | RP-121558 |
| 3060 | 787.2 | Perf. part: E-UTRA medium range and MSR medium range/local area BS class requirements | 321d? | 2011-09-23 A | 2012-12-07 A | 100% | 2011-09-23 | 2012-12-07 | 321d? | finish no earlier than 2012-12-07 | R4 | 2568h | 2568h | medBS_class_LTE_MSR-Perf | 27 | Ericsson | johan.skold@ericsson.com | Rel-11 | 53 | Issam |  | medBS_class_LTE_MSR-Perf | RP-121559 |
| 3061 | 787.3 | GERAN part: E-UTRA medium range and MSR medium range/local area BS class requirements | 261d? | 2011-11-28 A | 2012-11-23 A | 100% | 2011-11-28 | 2012-11-23 | 261d? | finish no earlier than 2012-11-23 | G1 | 2088h | 2088h | medBS_class_LTE_MSR-GERAN | 28 | Ericsson | Eric Nordström | Rel-11 | 52 | Paolo |  | medBS_class_LTE_MSR-GERAN |  |
| 3062 | 788 | **RF Requirements for Multi-Band and Multi-Standard Radio (MB-MSR) Base Station** | 553.1d? | 2012-02-06 A | 2014-03-06 A | 100% | 2012-02-06 | 2014-03-06 | 553.1d? |  | R4; G1 | 20915.2h | 20915.2h | MB_MSR_RF | 28 | Huawei | Liu Ye (leo.liuye@huawei.com) | Rel-11 | 55 | Issam |  | MB_MSR_RF |  |
| 3063 | 788.1 | Core part: RF Requirements for Multi-Band and Multi-Standard Radio (MB-MSR) Base Station | 223.1d? | 2012-02-06 A | 2012-12-07 A | 100% | 2012-02-06 | 2012-12-07 | 223.1d? | finish no earlier than 2012-12-07 | R4; G1 | 3569.6h | 3569.6h | MB_MSR_RF-Core | 28 | Huawei | Liu Ye (leo.liuye@huawei.com) | Rel-11 | 55 | Issam |  | MB_MSR_RF-Core | RP-121985 |
| 3064 | 788.2 | Perf. part: RF Requirements for Multi-Band and Multi-Standard Radio (MB-MSR) Base Station | 531d? | 2012-03-08 A | 2014-03-06 A | 100% | 2012-03-08 | 2014-03-06 | 531d? | finish no earlier than 2014-03-06 | R4; G1 | 8496h | 8496h | MB_MSR_RF-Perf | 28 | Huawei | Liu Ye (leo.liuye@huawei.com) | Rel-11 | 55 | Issam |  | MB_MSR_RF-Perf | RP-140064 |
| 3065 | 789 | **Further enhancements to H(e)NB mobility - Part 1** | 129d? | 2012-06-15 A | 2012-12-07 A | 100% | 2012-06-15 | 2012-12-07 | 129d? |  | R3; R2 | 4128h | 4128h | EHNB_enh1 | 29 | Alcatel-Lucent | Martin.Warner@alcatel-lucent.com | Rel-11 | 56 | Juha | HNB | EHNB_enh1 |  |
| 3066 | 789.1 | Core part: Further enhancements to H(e)NB mobility - Part 1 | 129d? | 2012-06-15 A | 2012-12-07 A | 100% | 2012-06-15 | 2012-12-07 | 129d? | finish no earlier than 2012-12-07 | R3; R2 | 2064h | 2064h | EHNB_enh1-Core | 29 | Alcatel-Lucent | Martin.Warner@alcatel-lucent.com | Rel-11 | 56 | Juha | HNB | EHNB_enh1-Core | RP-121563 |
| 3067 | 790 | **Further enhancements to H(e)NB mobility - Part 2** | 127d? | 2012-06-19 A | 2012-12-07 A | 100% | 2012-06-19 | 2012-12-07 | 127d? |  | R3; R2 | 4064h | 4064h | EHNB_enh2 | 29 | Alcatel-Lucent | Martin.Warner@alcatel-lucent.com | Rel-11 | 56 | Juha | HNB | EHNB_enh2 |  |
| 3068 | 790.1 | Core part: Further enhancements to H(e)NB mobility - Part 2 | 127d? | 2012-06-19 A | 2012-12-07 A | 100% | 2012-06-19 | 2012-12-07 | 127d? | finish no earlier than 2012-12-07 | R3; R2 | 2032h | 2032h | EHNB_enh2-Core | 29 | Alcatel-Lucent | Martin.Warner@alcatel-lucent.com | Rel-11 | 56 | Juha | HNB | EHNB_enh2-Core | RP-121564 |
| 3069 | 791 | **Network-Based Positioning Support for LTE** | 1391d? | 2009-03-05 A | 2014-06-13 A | 100% | 2009-03-05 | 2014-06-13 | 1391d? |  | R2; R1; R3; R4 | 91464h | 91464h | LCS_LTE-NBPS | 22 | TruePosition | terri.brooks@trueposition.com | Rel-11 | 43 | Yong-Jun |  | LCS_LTE-NBPS |  |
| 3070 | 791.1 | Core part: Network-Based Positioning Support for LTE | 1125d? | 2009-03-05 A | 2013-06-12 A | 100% | 2009-03-05 | 2013-06-12 | 1125d? | finish no earlier than 2013-06-12 | R2; R1; R3; R4 | 36000h | 36000h | LCS_LTE-NBPS-Core | 22 | TruePosition | terri.brooks@trueposition.com | Rel-11 | 43 | Yong-Jun |  | LCS_LTE-NBPS-Core | RP-130483 |
| 3071 | 791.2 | Perf. part: Network-Based Positioning Support for LTE | 1377d? | 2009-03-24 A | 2014-06-13 A | 100% | 2009-03-24 | 2014-06-13 | 1377d? | finish no earlier than 2014-06-13 | R4 | 11016h | 11016h | LCS_LTE-NBPS-Perf | 22 | TruePosition | terri.brooks@trueposition.com | Rel-11 | 43 | Yong-Jun |  | LCS_LTE-NBPS-Perf | RP-140626 |
| 3072 | 792 | **Service continuity improvements for MBMS for LTE** | 993d? | 2010-06-04 A | 2014-03-06 A | 100% | 2010-06-04 | 2014-03-06 | 993d? |  | R2; R3; R5 | 35496h | 35496h | MBMS_LTE_SC | 25 | Huawei | David.Lecompte@huawei.com | Rel-11 | 48 | Yong-Jun |  | MBMS_LTE_SC |  |
| 3073 | 792.1 | Core part: Service continuity improvements for MBMS for LTE | 596d? | 2010-06-04 A | 2012-09-07 A | 100% | 2010-06-04 | 2012-09-07 | 596d? | finish no earlier than 2012-09-07 | R2; R3 | 9536h | 9536h | MBMS_LTE_SC-Core | 25 | Huawei | David.Lecompte@huawei.com | Rel-11 | 48 | Yong-Jun |  | MBMS_LTE_SC-Core | RP-121001 |
| 3074 | 792.2 | Test part: Service continuity improvements for MBMS for LTE | 266d? | 2013-03-04 A | 2014-03-06 A | 100% | 2013-03-04 | 2014-03-06 | 266d? | finish no earlier than 2014-03-06 | R5 | 2128h | 2128h | MBMS_LTE_SC-UEConTest | 30 | Ericsson | leif.mattisson@ericsson.com | Rel-11 | 59 | Ingbert |  | MBMS_LTE_SC-UEConTest | RP-140074 |

Notes:
- 3050: Stage 1/2/3 / Impacted TSs and TRs: UTRA, LTE
- 3051: RP#58 completed / Impacted TSs and TRs: 25.331, 25.401, 25.410, 25.413, 25.423, 25.433, 36.300, 36.331, 36.413, 36.423
- 3052: Stage 2/3 / Impacted TSs and TRs: UTRA, LTE
- 3053: RP#58 completed / Impacted TSs and TRs: 25.133, 25.123, 25.304, 25.331, 25.413, 25.423, 36.133, 36.304, 36.306, 36.331, 36.413, 36.423, 37.320, 36.300
- 3054: RP#62 completed / Impacted TSs and TRs: 34.108, 34.109, 34.123-1, 34.123-2, 34.123-3, 36.508, 36.509, 36.523-1, 36.523-2, 36.523-3
- 3055: Stage 2/3 / Impacted TSs and TRs: LTE, GERAN
- 3056: RP#57 completed. Inter-RAT aspect can affect UTRA and GERAN as well / Impacted TSs and TRs: 25.413, 36.300, 36.413, 36.423
- 3057: GP#55 approved WID and completed. Stage 3. ChangES in CP-150RIM protocol and in SON Transfer RIM application to provide support for Energy Savings Indication feature / Impacted TSs and TRs: 48.018 [Serving GPRS Support Node (SGSN); BSS GPRS protocol (BSSGP)]
- 3058: Stage 3. GERAN BS RF requirements specs need aligned with RAN4 ongoing Rel-11 Feature UID_530037 E-UTRA medium range and MSR medium range/local area BS class requirements (medBS_class_LTE_MSR) / Impacted TSs and TRs: UTRA, LTE, GERAN
- 3059: RP#58 completed. TR 37.809 v200 for Approval / Impacted TSs and TRs: 25.104, 36.104, 37.104, new TR 37.809
- 3060: RP#58 completed / Impacted TSs and TRs: 25.141, 36.141, 37.141
- 3061: GP#56 completed. GP#52 approved WID / Impacted TSs and TRs: 45.005, 51.021
- 3062: - / Impacted TSs and TRs: UTRA, LTE, GERAN
- 3063: RP#58 completed / Impacted TSs and TRs: 25.104, 25.105, 36.104, 37.104, new TR 37.812
- 3064: RP#63 completed / Impacted TSs and TRs: 25.141, 25.142, 36.141, 37.141
- 3065: Stage 2/3. Triggered by FS_EHNB_enh (UTRA, LTE TR 37.803 under AI 12.3.2). Compare also Rel-10 WI HNB_HENB_mob_enh RP-110183 / Impacted TSs and TRs: UTRA, LTE
- 3066: RP#58 completed / Impacted TSs and TRs: 25.413, 25.467, 25.469, 36.300, 36.413, 36.423
- 3067: Stage 2/3. Legacy UE Handling (X2-GW, 20% complete, moved to Rel-12 UID_580030). Triggered by FS_EHNB_enh (UTRA, LTE TR 37.803 under AI 12.3.2) / Impacted TSs and TRs: UTRA, LTE
- 3068: RP#58 completed Legacy UE Handling (X2-GW, 20% complete, moved to Rel-12 UID_580030). Updated WID RP-121147=>RP-121712 / Impacted TSs and TRs: 25.413, 25.467, 25.469, 25.471
- 3069: - / Impacted TSs and TRs: LTE
- 3070: RP#60 completed / Impacted TSs and TRs: 36.214, 36.300, 36.305, 36.401, 36.413, 36.455, new TS (36.111, 36.456, 36.457, 36.458, 36.459)
- 3071: RP#64 completed. TS 36.112v100 for 1-step Approval / Impacted TSs and TRs: 36.111, new TS 36.112
- 3072: - / Impacted TSs and TRs: LTE
- 3073: RP#57 completed / Impacted TSs and TRs: 25.446, 36.300, 36.304, 36.321, 36.322, 36.323, 36.331, 36.440, 36.441, 36.442, 36.443, 36.444, 36.445
- 3074: RP#63 completed / Impacted TSs and TRs: 36.508, 36.523-1, 36.523-2, 36.523-3

| ID | WBS | Task | Duration | Start | Finish | Complete | Baseline start | Baseline finish | Baseline duration | Constraint | Resources | Work | Actual work | Acronym | PCG approved | WI rapporteur name | WI rapporteur e-mail | Release | TSG approved | MCC resp | Acronym_3GU_Export | Status Report | Special Focus Doc |
| --- | --- | --- | --- | --- | --- | --- | --- | --- | --- | --- | --- | --- | --- | --- | --- | --- | --- | --- | --- | --- | --- | --- | --- |
| 3075 | 793 | **Further Enhanced Non CA-based ICIC for LTE** | 991d? | 2011-03-22 A | 2014-12-15 A | 100% | 2011-03-22 | 2014-09-12 | 922d? |  | R1; R2; R3; R4; R5 | 63112h | 63112h | eICIC_enh_LTE | 26 | China Mobile | ShenXiaodong@chinamobile.com | Rel-11 | 51 | Patrick | eICIC_enh_LTE |  |  |
| 3076 | 793.1 | Core part: Further Enhanced Non CA-based ICIC for LTE | 456d? | 2011-03-22 A | 2012-12-07 A | 100% | 2011-03-22 | 2012-12-07 | 456d? | finish no earlier than 2012-12-07 | R1; R2; R3; R4 | 14592h | 14592h | eICIC_enh_LTE-Core | 26 | China Mobile | ShenXiaodong@chinamobile.com | Rel-11 | 51 | Patrick | eICIC_enh_LTE-Core | RP-121986 |  |
| 3077 | 793.2 | Perf. part: Further Enhanced Non CA-based ICIC for LTE | 715d? | 2011-03-23 A | 2013-12-06 A | 100% | 2011-03-23 | 2013-12-06 | 715d? | finish no earlier than 2013-12-06 | R4 | 5720h | 5720h | eICIC_enh_LTE-Perf | 26 | China Mobile | ShenXiaodong@chinamobile.com | Rel-11 | 51 | Issam | eICIC_enh_LTE-Perf | RP-131463 |  |
| 3078 | 793.3 | Test part: Further Enhanced Non CA-based ICIC for LTE | 395d? | 2013-06-15 A | 2014-12-15 A | 100% | 2013-06-18 | 2014-09-12 | 326d? | finish no earlier than 2014-12-15 | R5 | 3160h | 3160h | eICIC_enh_LTE-UEConTest | 31 | ZTE | Carolyn Taylor (carolyn.tayl@zte.com.cn) | Rel-11 | 60 | Ingbert | eICIC_enh_LTE-UEConTest | RP-141847 |  |
| 3079 | 794 | **New Band LTE Downlink FDD 716-728 MHz (Band 29, Carrier Aggregation of Band 2 and Band 29 and of Band 4 and Band 29)** | 456d? | 2011-03-22 A | 2012-12-07 A | 100% | 2011-03-22 | 2012-12-07 | 456d? |  | R4 | 10880h | 10880h | LTE_DL_FDD700 | 26 | AT&T | marc.grant@att.com | Rel-11 | 51 | Issam | LTE_DL_FDD700 |  | CA |
| 3080 | 794.1 | Core part: New Band LTE Downlink FDD 716-728 MHz (Band 29), Carrier Aggregation of Band 2 and Band 29 and of Band 4 and Band 29 | 453d? | 2011-03-22 A | 2012-12-07 A | 100% | 2011-03-22 | 2012-12-07 | 453d? | finish no earlier than 2012-12-07 | R4 | 3624h | 3624h | LTE_DL_FDD700-Core | 26 | AT&T | marc.grant@att.com | Rel-11 | 51 | Issam | LTE_DL_FDD700-Core | RP-121604 |  |
| 3081 | 794.2 | Perf. part: New Band LTE Downlink FDD 716-728 MHz (Band 29), Carrier Aggregation of Band 2 and Band 29 and of Band 4 and Band 29 | 451d? | 2011-03-29 A | 2012-12-07 A | 100% | 2011-03-29 | 2012-12-07 | 451d? | finish no earlier than 2012-12-07 | R4 | 3608h | 3608h | LTE_DL_FDD700-Perf | 26 | AT&T | marc.grant@att.com | Rel-11 | 51 | Issam | LTE_DL_FDD700-Perf | RP-121605 |  |
| 3082 | 795 | **LTE RAN Enhancements for Diverse Data Applications** | 657d? | 2011-03-18 A | 2013-09-06 A | 100% | 2011-03-18 | 2013-09-06 | 657d? |  | R2; R5 | 15248h | 15248h | LTE_eDDA | 26 | BlackBerry | Gordon Young (gyoung@rim.com) | Rel-11 | 51 | Yong-Jun | LTE_eDDA |  |  |
| 3083 | 795.1 | Core part: LTE RAN Enhancements for Diverse Data Applications | 456d? | 2011-03-18 A | 2012-12-07 A | 100% | 2011-03-18 | 2012-12-07 | 456d? | finish no earlier than 2012-12-07 | R2 | 3648h | 3648h | LTE_eDDA-Core | 26 | BlackBerry | Gordon Young (gyoung@rim.com) | Rel-11 | 51 | Yong-Jun | LTE_eDDA-Core | RP-121571 |  |
| 3084 | 795.2 | Test part: LTE RAN Enhancements for Diverse Data Applications | 136d? | 2013-03-04 A | 2013-09-06 A | 100% | 2013-03-04 | 2013-09-06 | 136d? | finish no earlier than 2013-09-06 | R5 | 1088h | 1088h | LTE_eDDA-UEConTest | 30 | BlackBerry | Enikő Sokondár (esokondar@rim.com) | Rel-11 | 59 | Ingbert | LTE_eDDA-UEConTest | RP-130946 |  |
| 3085 | 796 | **LTE E850 - Lower Band for Region 2 (non-US), Band 27** | 516d? | 2011-03-23 A | 2013-03-01 A | 100% | 2011-03-23 | 2013-03-01 | 516d? |  | R1; R2; R4; R5 | 28496h | 28496h | LTE_e850_LB | 26 | NII Holdings | bill.shvodian@nii.com | Rel-11 | 51 | Patrick | LTE_e850_LB |  |  |
| 3086 | 796.1 | Core part: LTE E850 - Lower Band for Region 2 (non-US), Band 27 | 328d? | 2011-06-15 A | 2012-09-07 A | 100% | 2011-06-15 | 2012-09-07 | 328d? | finish no earlier than 2012-09-07 | R1; R2; R4 | 7872h | 7872h | LTE_e850_LB-Core | 26 | NII Holdings | bill.shvodian@nii.com | Rel-11 | 51 | Patrick | LTE_e850_LB-Core | RP-120570 |  |
| 3087 | 796.2 | Perf. part: LTE E850 - Lower Band for Region 2 (non-US), Band 27 | 326d? | 2011-03-23 A | 2012-06-15 A | 100% | 2011-03-23 | 2012-06-15 | 326d? | finish no earlier than 2012-12-07 | R4 | 2608h | 2608h | LTE_e850_LB-Perf | 26 | NII Holdings | bill.shvodian@nii.com | Rel-11 | 51 | Issam | LTE_e850_LB-Perf | RP-120571 |  |
| 3088 | 796.3 | Test part: LTE E850 - Lower Band for Region 2 (non-US), Band 27 | 189d? | 2012-06-18 A | 2013-03-01 A | 100% | 2012-06-18 | 2013-03-01 | 189d? | finish no earlier than 2013-03-01 | R5 | 1504h | 1504h | LTE_e850_LB-UEConTest | 29 | NII Holdings | bill.shvodian@nii.com | Rel-11 | 56 | Ingbert | LTE_e850_LB-UEConTest | RP-130045 |  |
| 3089 | 797 | **LTE for 700 MHz Digital Dividend** | 538d? | 2011-06-07 A | 2013-06-14 A | 100% | 2011-06-07 | 2013-06-14 | 538d? |  | R4; R2; R3; R5 | 28032h | 28032h | LTE_APAC700 | 27 | Ericsson | olav.queseth@ericsson.com | Rel-11 | 52 | Issam | LTE_APAC700 |  |  |
| 3090 | 797.1 | Core part: LTE for 700 MHz Digital Dividend | 273d? | 2011-06-07 A | 2012-06-15 A | 100% | 2011-06-07 | 2012-06-15 | 273d? | finish no earlier than 2012-06-15 | R4; R2; R3 | 6552h | 6552h | LTE_APAC700-Core | 27 | Ericsson | olav.queseth@ericsson.com | Rel-11 | 52 | Issam | LTE_APAC700-Core | RP-120572 |  |
| 3091 | 797.2 | Perf. part: LTE for 700 MHz Digital Dividend | 271d? | 2011-06-09 A | 2012-06-15 A | 100% | 2011-06-09 | 2012-06-15 | 271d? | finish no earlier than 2012-06-15 | R4 | 2168h | 2168h | LTE_APAC700-Perf | 27 | Ericsson | olav.queseth@ericsson.com | Rel-11 | 52 | Issam | LTE_APAC700-Perf | RP-120573 |  |
| 3092 | 797.3 | Test part: LTE for 700 MHz Digital Dividend | 262d? | 2012-06-18 A | 2013-06-14 A | 100% | 2012-06-18 | 2013-06-14 | 262d? | finish no earlier than 2013-06-14 | R5 | 2096h | 2096h | LTE_APAC700-UEConTest | 29 | Ericsson | fredrik.sundstrom@ericsson.com | Rel-11 | 56 | Ingbert | LTE_APAC700-UEConTest | RP-130467 |  |
| 3093 | 798 | **Relays for LTE (part 2)** | 930d? | 2009-12-04 A | 2013-06-14 A | 100% | 2009-12-04 | 2013-06-14 | 930d? |  | R4 | 17496.4h | 17496.4h | LTE_Relay2 | 24 | Ericsson | christian.hoymann@ericsson.com | Rel-11 | 46 | Patrick | LTE_Relay2 |  |  |
| 3094 | 798.1 | Core part: Relays for LTE (part 2) | 333d? | 2011-06-07 A | 2012-09-07 A | 100% | 2011-06-07 | 2012-09-07 | 333d? | finish no earlier than 2012-09-07 | R4 | 2656.39h | 2656.39h | LTE_Relay2-Core | 27 | Ericsson | christian.hoymann@ericsson.com | Rel-11 | 52 | Issam | LTE_Relay2-Core | RP-121008 |  |
| 3095 | 798.2 | Perf. part: Relays for LTE (part 2) | 925d? | 2009-12-04 A | 2013-06-14 A | 100% | 2009-12-04 | 2013-06-14 | 925d? | finish no earlier than 2013-06-14 | R4 | 7400h | 7400h | LTE_Relay2-Perf | 24 | Ericsson | christian.hoymann@ericsson.com | Rel-11 | 46 | Issam | LTE_Relay2-Perf | RP-130487 |  |
| 3096 | 799 | **Signalling and Procedure for Interference Avoidance for in-device coexistence** | 325d? | 2011-09-19 A | 2012-12-07 A | 100% | 2011-09-19 | 2012-12-07 | 325d? |  | R2; R4 | 12976h | 12976h | SPIA_IDC_LTE | 27 | China Mobile | Zhenping HU | Rel-11 | 53 | Yong-Jun | SPIA_IDC_LTE |  |  |
| 3097 | 799.1 | Core part: Signalling and Procedure for Interference Avoidance for in-device coexistence | 325d? | 2011-09-19 A | 2012-12-07 A | 100% | 2011-09-19 | 2012-12-07 | 325d? | finish no earlier than 2012-12-07 | R2; R4 | 5200h | 5200h | SPIA_IDC_LTE-Core | 27 | China Mobile | Zhenping HU | Rel-11 | 53 | Yong-Jun | SPIA_IDC_LTE-Core | RP-121573 |  |
| 3098 | 799.2 | Perf. part: Signalling and Procedure for Interference Avoidance for in-device coexistence | 322d? | 2011-09-20 A | 2012-12-07 A | 100% | 2011-09-20 | 2012-12-07 | 322d? | finish no earlier than 2012-12-07 | R4 | 2576h | 2576h | SPIA_IDC_LTE-Perf | 27 | China Mobile | Zhenping HU | Rel-11 | 53 | Issam | SPIA_IDC_LTE-Perf | RP-121574 |  |

Notes:
- 3075: - / Impacted TSs and TRs: LTE
- 3076: RP#58 completed / Impacted TSs and TRs: 36.101, 36.133, 36.201, 36.211, 36.212, 36.213, 36.214, 36.300, 36.304, 36.321, 36.331, 36.413, 36.423
- 3077: RP#62 completed / Impacted TSs and TRs: 36.101, 36.104, 36.133, 36.141
- 3078: ; Stat Rep: RP-141131->RP-141847 / Impacted TSs and TRs: 36.508, 36.521-1, 36.521-2, 36.521-3, 36.523-1, 36.523-2, 36.523-3
- 3079: Stage 3 / Impacted TSs and TRs: LTE
- 3080: RP#58 completed / Impacted TSs and TRs: 36.101, 36.104, 36.141, 36.307
- 3081: RP#58 completed / Impacted TSs and TRs: 36.101, 36.104, 36.133, 36.141, 36.307
- 3082: Stage 2/3 / Impacted TSs and TRs: LTE
- 3083: RP#58 completed / Impacted TSs and TRs: 36.300, 36.321, 36.331, new TR 36.822
- 3084: RP#61 completed / Impacted TSs and TRs: 36.523-1, 36.523-2, 36.523-3
- 3085: Stage 3 / Impacted TSs and TRs: LTE
- 3086: RP#56 completed / Impacted TSs and TRs: 25.101, 25.104, 25.461, 25.466, 36.101, 36.104, 36.113, 36.124, 36.307, 37.104, 37.113
- 3087: RP#56 completed / Impacted TSs and TRs: 25.123, 25.133, 25.141, 36.133, 36.141, 37.141
- 3088: RP#59 completed / Impacted TSs and TRs: 36.508, 36.521-1, 36.521-2, 36.521-3, 36.523-2, 36.523-3, 37.571-1
- 3089: Stage 3. Asian Pacific American Caucus (APAC) Asia-Pacific Telecommunity (APT) Wireless Forum / Impacted TSs and TRs: LTE
- 3090: RP#56 completed. TR 36.820 v100 for Information and Approval / Impacted TSs and TRs: 25.461, 25.466, 36.101, 36.104, 36.113, 36.124, 36.133, 36.307, 37.104, 37.113, new TR 36.820
- 3091: RP#56 completed / Impacted TSs and TRs: 36.133, 36.141, 37.141
- 3092: RP#60 completed / Impacted TSs and TRs: 36.508, 36.521-1, 36.521-2, 36.521-3, 36.523-2, 36.523-3, 37.571-1
- 3093: Continuation of Rel-10 (open RAN4 Core & Perf parts) / Impacted TSs and TRs: LTE
- 3094: RP#57 completed. TS 36.116, TR 36.826 v100 for Information & Approval. RP#52 Core part not completed in Rel-10 / Impacted TSs and TRs: 36.133, new RAN4 (36.116, 36.826)
- 3095: RP#60 completed. New TS 36.117 v100 for 1-step Approval. RP#52 transferred completely from Rel-10 UID_460213 / Impacted TSs and TRs: 36.133, new TS 36.117 (E-UTRA Relay conformance testing)
- 3096: Stage 2/3 / Impacted TSs and TRs: LTE
- 3097: RP#58 completed / Impacted TSs and TRs: 36.133, 36.300, 36.306, 36.321, 36.331
- 3098: RP#58 completed / Impacted TSs and TRs: 36.133

| ID | WBS | Task | Duration | Start | Finish | Complete | Baseline start | Baseline finish | Baseline duration | Constraint | Resources | Work | Actual work | Acronym | PCG approved | WI rapporteur name | Release | TSG approved | MCC resp | Acronym_3GU_Export | Status Report | Special Focus Doc |
| --- | --- | --- | --- | --- | --- | --- | --- | --- | --- | --- | --- | --- | --- | --- | --- | --- | --- | --- | --- | --- | --- | --- |
| 3099 | 800 | **Coordinated Multi-Point Operation for LTE** | 860d? | 2011-09-19 A | 2014-12-15 A | 100% | 2011-09-19 | 2014-09-12 | 791d? |  | R1; R2; R3; R4; R5 | 66128h | 66128h | COMP_LTE | 27 | Huawei, Samsung | Rel-11 | 53 | Patrick | COMP_LTE |  |  |
| 3100 | 800.1 | Core part: Coordinated Multi-Point Operation for LTE – Uplink | 325d? | 2011-09-19 A | 2012-12-07 A | 100% | 2011-09-19 | 2012-12-07 | 325d? | finish no earlier than 2012-12-07 | R1; R2; R3; R4 | 10400h | 10400h | COMP_LTE_UL-Core | 27 | Huawei | Rel-11 | 53 | Patrick | COMP_LTE_UL-Core | RP-121575 |  |
| 3101 | 800.2 | Perf. part: Coordinated Multi-Point Operation for LTE – Uplink | 321d? | 2011-09-23 A | 2012-12-07 A | 100% | 2011-09-23 | 2012-12-07 | 321d? | finish no earlier than 2012-12-07 | R4 | 2568h | 2568h | COMP_LTE_UL-Perf | 27 | Huawei | Rel-11 | 53 | Issam | COMP_LTE_UL-Perf | RP-121576 |  |
| 3102 | 800.3 | Core part: Coordinated Multi-Point Operation for LTE – Downlink | 325d? | 2011-09-19 A | 2012-12-07 A | 100% | 2011-09-19 | 2012-12-07 | 325d? | finish no earlier than 2012-12-07 | R1; R2; R3; R4 | 10400h | 10400h | COMP_LTE_DL-Core | 27 | Samsung | Rel-11 | 53 | Patrick | COMP_LTE_DL-Core | RP-121577 |  |
| 3103 | 800.4 | Perf. part: Coordinated Multi-Point Operation for LTE – Downlink | 582d? | 2011-09-23 A | 2013-12-06 A | 100% | 2011-09-23 | 2013-12-06 | 582d? | finish no earlier than 2013-12-06 | R4 | 4656h | 4656h | COMP_LTE_DL-Perf | 27 | Samsung | Rel-11 | 53 | Issam | COMP_LTE_DL-Perf | RP-131465 |  |
| 3104 | 800.5 | Test part: Coordinated Multi-Point Operation for LTE | 463d? | 2013-03-15 A | 2014-12-15 A | 100% | 2013-03-04 | 2014-09-12 | 404d? | finish no earlier than 2014-12-15 | R5 | 3704h | 3704h | COMP_LTE-UEConTest | 30 | Samsung | Rel-11 | 59 | Ingbert | COMP_LTE-UEConTest | RP-141782 |  |
| 3105 | 801 | **Enhanced downlink control channel(s) for LTE Advanced** | 732d? | 2011-12-09 A | 2014-09-12 A | 100% | 2011-12-09 | 2014-09-12 | 731d? |  | R1; R2; R4; R5 | 38272h | 38272h | LTE_enh_dl_ctrl | 28 | Alcatel-Lucent | Rel-11 | 54 | Patrick | LTE_enh_dl_ctrl |  |  |
| 3106 | 801.1 | Core part: Enhanced downlink control channel(s) for LTE Advanced | 265d? | 2011-12-09 A | 2012-12-07 A | 100% | 2011-12-09 | 2012-12-07 | 265d? | finish no earlier than 2012-12-07 | R1; R2; R4 | 6360h | 6360h | LTE_enh_dl_ctrl-Core | 28 | Alcatel-Lucent | Rel-11 | 54 | Patrick | LTE_enh_dl_ctrl-Core | RP-121579 |  |
| 3107 | 801.2 | Perf. part: Enhanced downlink control channel(s) for LTE Advanced | 659d? | 2011-12-16 A | 2014-06-13 A | 100% | 2011-12-16 | 2014-06-13 | 659d? | finish no earlier than 2014-06-13 | R4 | 5272h | 5272h | LTE_enh_dl_ctrl-Perf | 28 | Alcatel-Lucent | Rel-11 | 54 | Issam | LTE_enh_dl_ctrl-Perf | RP-140651 |  |
| 3108 | 801.3 | Test part: Enhanced downlink control channel(s) for LTE Advanced | 402d? | 2013-03-04 A | 2014-09-12 A | 100% | 2013-03-04 | 2014-09-12 | 402d? | finish no earlier than 2014-09-12 | R5 | 3216h | 3216h | LTE_enh_dl_ctrl-UEConTest | 30 | Huawei | Rel-11 | 59 | Ingbert | LTE_enh_dl_ctrl-UEConTest | RP-141256 |  |
| 3109 | 802 | **Public Safety Broadband High Power UE for Band 14 for Region 2** | 403d? | 2012-03-05 A | 2013-09-06 A | 100% | 2012-03-05 | 2013-09-06 | 403d? |  | R4; R5 | 9144h | 9144h | LTE_B14_PSBB_HPUE | 28 | Motorola Solutions | Rel-11 | 55 | Issam | LTE_B14_PSBB_HPUE |  | Public Safety (A-A) |
| 3110 | 802.1 | Core part: Public Safety Broadband High Power UE for Band 14 for Region 2 | 201d? | 2012-03-05 A | 2012-12-07 A | 100% | 2012-03-05 | 2012-12-07 | 201d? | finish no earlier than 2012-12-07 | R4 | 1608h | 1608h | LTE_B14_PSBB_HPUE-Core | 28 | Motorola Solutions | Rel-11 | 55 | Issam | LTE_B14_PSBB_HPUE-Core | RP-121581 | Public Safety (A-A) |
| 3111 | 802.2 | Test part: Public Safety Broadband High Power UE for Band 14 for Region 2 | 138d? | 2013-03-04 A | 2013-09-06 A | 100% | 2013-03-04 | 2013-09-06 | 138d? | finish no earlier than 2013-09-06 | R5 | 1088h | 1088h | LTE_B14_PSBB_HPUE-UEConTest | 30 | Motorola Solutions | Rel-11 | 59 | Ingbert | LTE_B14_PSBB_HPUE-UEConTest | RP-130949 | Public Safety (A-A) |
| 3112 | 803 | **Improved Minimum Performance Requirements for E-UTRA: Interference Rejection** | 671d? | 2012-03-05 A | 2014-09-12 A | 100% | 2012-03-05 | 2014-09-12 | 670d? |  | R4; R5 | 14952h | 14952h | LTE_Interf_Rej | 28 | Renesas Mobile | Rel-11 | 55 | Issam | LTE_Interf_Rej |  |  |
| 3113 | 803.1 | Perf. part: Improved Minimum Performance Requirements for E-UTRA: Interference Rejection | 201d? | 2012-03-05 A | 2012-12-07 A | 100% | 2012-03-05 | 2012-12-07 | 201d? | finish no earlier than 2012-12-07 | R4 | 1608h | 1608h | LTE_Interf_Rej-Perf | 28 | Renesas Mobile | Rel-11 | 55 | Issam | LTE_Interf_Rej-Perf | RP-121582 |  |
| 3114 | 803.2 | Test part: Improved Minimum Performance Requirements for E-UTRA: Interference Rejection | 327d? | 2013-06-18 A | 2014-09-12 A | 100% | 2013-06-18 | 2014-09-12 | 327d? | finish no earlier than 2014-09-12 | R5 | 2608h | 2608h | LTE_Interf_Rej-UEConTest | 31 | Broadcom | Rel-11 | 60 | Ingbert | LTE_Interf_Rej-UEConTest | RP-141602 |  |
| 3115 | 804 | **Additional special subframe configuration for LTE TDD** | 341d? | 2012-03-05 A | 2013-06-14 A | 100% | 2012-03-05 | 2013-06-14 | 341d? |  | R4; R2; R3; R5 | 14808h | 14808h | LTE_TDD_add_subframe | 28 | China Mobile | Rel-11 | 55 | Issam | LTE_TDD_add_subframe |  |  |
| 3116 | 804.1 | Core part: Additional special subframe configuration for LTE TDD | 137d? | 2012-03-05 A | 2012-09-07 A | 100% | 2012-03-05 | 2012-09-07 | 137d? | finish no earlier than 2012-09-07 | R4; R2; R3 | 3288h | 3288h | LTE_TDD_add_subframe-Core | 28 | China Mobile | Rel-11 | 55 | Issam | LTE_TDD_add_subframe-Core | RP-121019 |  |
| 3117 | 804.2 | Test part: Additional special subframe configuration for LTE TDD | 76d? | 2013-03-04 A | 2013-06-14 A | 100% | 2013-03-04 | 2013-06-14 | 76d? | finish no earlier than 2013-09-13 | R5 | 608h | 608h | LTE_TDD_add_subframe-UEConTest | 30 | Huawei | Rel-11 | 59 | Ingbert | LTE_TDD_add_subframe-UEConTest | RP-130475 |  |
| 3118 | 805 | **Rel-11 LTE Carrier Aggregation** | 1062d? | 2010-12-10 A | 2014-12-15 A | 100% | 2010-12-10 | 2014-12-05 | 1054d? |  | R1; R2; R3; R4; R5 | 315760h | 315760h | LTE_CA_Rel-11 | 30 |  | Rel-11 | 58 | Patrick | LTE_CA_Rel-11 |  | CA |
| 3119 | 805.1 | **LTE Carrier Aggregation Enhancements** | 995d? | 2011-03-15 A | 2014-12-15 A | 100% | 2011-03-22 | 2014-12-05 | 982d? |  | R1; R2; R3; R4; R5 | 70824h | 70824h | LTE_CA_enh | 26 | Nokia | Rel-11 | 51 | Patrick | LTE_CA_enh |  | CA |
| 3120 | 805.1.1 | Core part: LTE Carrier Aggregation Enhancements | 646.25d? | 2011-03-22 A | 2013-08-27 A | 100% | 2011-03-22 | 2013-03-01 | 517d? | finish no earlier than 2013-03-01 | R1; R2; R4; R3 | 20680h | 20680h | LTE_CA_enh-Core | 26 | Nokia | Rel-11 | 51 | Patrick | LTE_CA_enh-Core | RP-130059 | CA |
| 3121 | 805.1.2 | Perf. part: LTE Carrier Aggregation Enhancements | 994d? | 2011-03-15 A | 2014-12-15 A | 100% | 2011-03-29 | 2014-12-05 | 977d? | finish no earlier than 2014-12-15 | R4 | 7936h | 7936h | LTE_CA_enh-Perf | 26 | Nokia | Rel-11 | 51 | Issam | LTE_CA_enh-Perf | RP-141969 | CA |
| 3122 | 805.1.3 | Test part: LTE Carrier Aggregation Enhancements | 326d? | 2013-06-18 A | 2014-09-12 A | 100% | 2013-06-18 | 2014-09-12 | 326d? | finish no earlier than 2014-09-12 | R5 | 2608h | 2608h | LTE_CA_enh-UEConTest | 31 | Microsoft | Rel-11 | 60 | Ingbert | LTE_CA_enh-UEConTest | RP-141443 | CA |
| 3123 | 805.2 | UE Conformance Test Aspects – LTE Advanced Carrier Aggregation of Intra-band contiguous and Inter-band configurations | 329d? | 2012-09-11 A | 2013-12-06 A | 100% | 2012-09-11 | 2013-12-06 | 329d? | finish no earlier than 2013-12-06 | R5 | 2624h | 2624h | LTE_CA_intraC_inter_UEConTest | 29 | Nokia | Rel-11 | 57 | Ingbert | LTE_CA_intraC_inter_UEConTest | RP-131446 | CA |

Notes:
- 3099: Stage 3. Triggered by Rel-11 TR 36.819 Study on Coordinated Multi-Point Operation for LTE (FS_CoMP_LTE) / Impacted TSs and TRs: LTE / WI rapporteur e-mail: Juho Lee (juho95.lee@samsung.com), david.mazzarese@huawei.com
- 3100: RP#58 completed / Impacted TSs and TRs: 36.101, 36.104, 36.133, 36.201, 36.211, 36.212, 36.213, 36.214, 36.300, 36.306, 36.321, 36.331, 36.423 / WI rapporteur e-mail: david.mazzarese@huawei.com
- 3101: RP#58 completed / Impacted TSs and TRs: 36.101, 36.104, 36.133, 36.141 / WI rapporteur e-mail: Xinwei Zhi (zhixinwei@huawei.com)
- 3102: RP#58 completed / Impacted TSs and TRs: 36.101, 36.104, 36.133, 36.201, 36.211, 36.212, 36.213, 36.214, 36.300, 36.306, 36.321, 36.331, 36.423 / WI rapporteur e-mail: Juho Lee (juho95.lee@samsung.com)
- 3103: RP#62 completed / Impacted TSs and TRs: 36.101, 36.104, 36.133, 36.141, 36.307 / WI rapporteur e-mail: xutao.zhou@samsung.com
- 3104: Impacted TSs and TRs: 36.508, 36.521-1, 36.521-2, 36.523-1, 36.523-2, 36.523-3 / WI rapporteur e-mail: Stoyan.Baev@partner.samsung.com
- 3105: Stage 3. RP#58 Core completed. Triggered by UID_510037 Rel-11 TR 36.871 Study on further Downlink MIMO enhancements for LTE-Advanced (FS_LTE_eDL_MIMO_enh) / Impacted TSs and TRs: LTE / WI rapporteur e-mail: sigen.ye@alcatel-lucent.com
- 3106: RP#58 completed / Impacted TSs and TRs: 36.101, 36.211, 36.212, 36.213, 36.331 / WI rapporteur e-mail: sigen.ye@alcatel-lucent.com
- 3107: RP#64 completed / Impacted TSs and TRs: 36.101, 36.104, 36.133, 36.141 / WI rapporteur e-mail: teck.hu@alcatel-lucent.com
- 3108: RP#65 completed / Impacted TSs and TRs: 36.508, 36.521-1, 36.521-2, 36.523-1, 36.523-2, 36.523-3 / WI rapporteur e-mail: Xu Kai (xk.xukai@huawei.com)
- 3109: Stage 3 / Impacted TSs and TRs: LTE / WI rapporteur e-mail: xiaowei.jin@motorolasolutions.com
- 3110: RP#58 completed. TR 36.837 v100 for Information and Approval / Impacted TSs and TRs: 36.101, new TR 36.837 / WI rapporteur e-mail: xiaowei.jin@motorolasolutions.com
- 3111: RP#61 completed / Impacted TSs and TRs: 36.521-1, 36.521-2 / WI rapporteur e-mail: xiaowei.jin@motorolasolutions.com
- 3112: RP#58 completed. Triggered by FS_enh_perf_UE_LTE. Adds Perf. requirements for demodulation of the already specified PDSCH with the transmission modes defined in Rel-8 to Rel-10 / Impacted TSs and TRs: LTE / WI rapporteur e-mail: Timo Roman
- 3113: RP#58 completed / Impacted TSs and TRs: 36.101 / WI rapporteur e-mail: Timo Roman
- 3114: RP#65 completed. TR 36.904 for 1-step Approval. Testing for 36.101 / Impacted TSs and TRs: 36.508, 36.521-1, 36.521-2, New TR 36.904 / WI rapporteur e-mail: jarkko.hellsten@kolumbus.fi
- 3115: Stage 3. Exists already for 1UL a WI LTE_CA_B3_B5 / Impacted TSs and TRs: LTE / WI rapporteur e-mail: Xiaodong Shen
- 3116: RP#57 completed / Impacted TSs and TRs: 36.211, 36.213, 36.331, 36.423 / WI rapporteur e-mail: Xiaodong Shen
- 3117: RP#60 completed / Impacted TSs and TRs: 36.508, 36.523-1, 36.523-2, 36.523-3 / WI rapporteur e-mail: Li Xiang (tricia.li@huawei.com)
- 3118: LTE_CA_Rel-11 / Impacted TSs and TRs: LTE
- 3119: Stage 3 / Impacted TSs and TRs: LTE / WI rapporteur e-mail: lars.e.lindh@nokia.com
- 3120: RP#59 completed. New TR 36.823 v100 for Information and Approval / Impacted TSs and TRs: 36.101, 36.104, 36.133, 36.201, 36.211, 36.212, 36.213, 36.300, 36.302, 36.306, 36.321, 36.331, 36.413, 36.423, new TR 36.823 / WI rapporteur e-mail: lars.e.lindh@nokia.com
- 3121: ; Stat Rep: RP-141377->RP-141969 / Impacted TSs and TRs: 36.101, 36.104, 36.133, 36.141 / WI rapporteur e-mail: lars.e.lindh@nokia.com
- 3122: SP#65 completed / Impacted TSs and TRs: 36.508, 36.521-1, 36.521-2, 36.521-3, 36.523-1, 36.523-2, 36.523-3 / WI rapporteur e-mail: jussi.kuusisto@microsoft.com
- 3123: RP#62 completed / Impacted TSs and TRs: 36.508, 36.521-1, 36.521-2, 36.521-3, 36.523-1, 36.523-2, 36.523-3, 37.571-1 / WI rapporteur e-mail: jussi.kuusisto@nokia.com

| ID | WBS | Task | Duration | Start | Finish | Complete | Baseline start | Baseline finish | Baseline duration | Constraint | Resources | Work | Actual work | PCG approved | Release | TSG approved | MCC resp | Special Focus Doc | Acronym | WI rapporteur name | WI rapporteur e-mail | Acronym_3GU_Export | Status Report |
| --- | --- | --- | --- | --- | --- | --- | --- | --- | --- | --- | --- | --- | --- | --- | --- | --- | --- | --- | --- | --- | --- | --- | --- |
| 3124 | 805.3 | **Rel-11 inter-band Carrier Aggregation** | 528d? | 2010-12-10 A | 2012-12-07 A | 100% | 2010-12-10 | 2012-12-07 | 528d? |  | R4 | 180968h | 180968h | 30 | Rel-11 | 58 | Issam | CA |  |  |  |  |  |
| 3125 | 805.3.1 | **LTE Advanced Carrier Aggregation of Band 3 and Band 7** | 528d? | 2010-12-10 A | 2012-12-07 A | 100% | 2010-12-10 | 2012-12-07 | 528d? |  | R4 | 12040h | 12040h | 25 | Rel-11 | 48 | Issam | CA | LTE_CA_B3_B7 | TeliaSonera | Ralf.Schuh@TeliaSonera.com | LTE_CA_B3_B7 |  |
| 3126 | 805.3.1.1 | Core part: LTE Advanced Carrier Aggregation of Band 3 and Band 7 | 456d? | 2010-12-10 A | 2012-09-07 A | 100% | 2010-12-10 | 2012-09-07 | 456d? | finish no earlier than 2012-09-07 | R4 | 3648h | 3648h | 25 | Rel-11 | 48 | Issam | CA | LTE_CA_B3_B7-Core | TeliaSonera | Ralf.Schuh@TeliaSonera.com | LTE_CA_B3_B7-Core | RP-121022 |
| 3127 | 805.3.1.2 | Perf. part: LTE Advanced Carrier Aggregation of Band 3 and Band 7 | 523d? | 2010-12-17 A | 2012-12-07 A | 100% | 2010-12-17 | 2012-12-07 | 523d? | finish no earlier than 2012-12-07 | R4 | 4168h | 4168h | 25 | Rel-11 | 48 | Issam | CA | LTE_CA_B3_B7-Perf | TeliaSonera | Ralf.Schuh@TeliaSonera.com | LTE_CA_B3_B7-Perf | RP-121023 |
| 3128 | 805.3.2 | **LTE Advanced Carrier Aggregation of Band 4 and Band 17** | 528d? | 2010-12-10 A | 2012-12-07 A | 100% | 2010-12-10 | 2012-12-07 | 528d? |  | R4 | 12064h | 12064h | 26 | Rel-11 | 50 | Issam | CA | LTE_CA_B4_B17 | AT&T | marc.grant@att.com | LTE_CA_B4_B17 |  |
| 3129 | 805.3.2.1 | Core part: LTE Advanced Carrier Aggregation of Band 4 and Band 17 | 459d? | 2010-12-10 A | 2012-09-07 A | 100% | 2010-12-10 | 2012-09-07 | 459d? | finish no earlier than 2012-09-07 | R4 | 3672h | 3672h | 26 | Rel-11 | 50 | Issam | CA | LTE_CA_B4_B17-Core | AT&T | marc.grant@att.com | LTE_CA_B4_B17-Core | RP-121024 |
| 3130 | 805.3.2.2 | Perf. part: LTE Advanced Carrier Aggregation of Band 4 and Band 17 | 521d? | 2010-12-17 A | 2012-12-07 A | 100% | 2010-12-17 | 2012-12-07 | 521d? | finish no earlier than 2012-12-07 | R4 | 4168h | 4168h | 26 | Rel-11 | 50 | Issam | CA | LTE_CA_B4_B17-Perf | AT&T | marc.grant@att.com | LTE_CA_B4_B17-Perf | RP-121595 |
| 3131 | 805.3.3 | **LTE Advanced Carrier Aggregation of Band 4 and Band 13** | 528d? | 2010-12-10 A | 2012-12-07 A | 100% | 2010-12-10 | 2012-12-07 | 528d? |  | R4 | 12040h | 12040h | 26 | Rel-11 | 50 | Issam | CA | LTE_CA_B4_B13 | Ericsson | christian.bergljung@ericsson.com | LTE_CA_B4_B13 |  |
| 3132 | 805.3.3.1 | Core part: LTE Advanced Carrier Aggregation of Band 4 and Band 13 | 456d? | 2010-12-10 A | 2012-09-07 A | 100% | 2010-12-10 | 2012-09-07 | 456d? | finish no earlier than 2012-09-07 | R4 | 3648h | 3648h | 26 | Rel-11 | 50 | Issam | CA | LTE_CA_B4_B13-Core | Ericsson | christian.bergljung@ericsson.com | LTE_CA_B4_B13-Core | RP-121026 |
| 3133 | 805.3.3.2 | Perf. part: LTE Advanced Carrier Aggregation of Band 4 and Band 13 | 521d? | 2010-12-21 A | 2012-12-07 A | 100% | 2010-12-21 | 2012-12-07 | 521d? | finish no earlier than 2012-12-07 | R4 | 4168h | 4168h | 26 | Rel-11 | 50 | Issam | CA | LTE_CA_B4_B13-Perf | Ericsson | christian.bergljung@ericsson.com | LTE_CA_B4_B13-Perf | RP-121594 |
| 3134 | 805.3.4 | **LTE Advanced Carrier Aggregation of Band 4 and Band 12** | 456d? | 2011-03-22 A | 2012-12-07 A | 100% | 2011-03-22 | 2012-12-07 | 456d? |  | R4; R2 | 18200h | 18200h | 26 | Rel-11 | 51 | Issam | CA | LTE_CA_B4_B12 | Leap Wireless | Bill Chandler (bchandler@cricketcommunications.com) | LTE_CA_B4_B12 |  |
| 3135 | 805.3.4.1 | Core part: LTE Advanced Carrier Aggregation of Band 4 and Band 12 | 456d? | 2011-03-22 A | 2012-12-07 A | 100% | 2011-03-22 | 2012-12-07 | 456d? | finish no earlier than 2012-12-07 | R4; R2 | 7296h | 7296h | 26 | Rel-11 | 51 | Issam | CA | LTE_CA_B4_B12-Core | Leap Wireless | Bill Chandler (bchandler@cricketcommunications.com) | LTE_CA_B4_B12-Core | RP-121592 |
| 3136 | 805.3.4.2 | Perf. part: LTE Advanced Carrier Aggregation of Band 4 and Band 12 | 451d? | 2011-03-29 A | 2012-12-07 A | 100% | 2011-03-29 | 2012-12-07 | 451d? | finish no earlier than 2012-12-07 | R4 | 3608h | 3608h | 26 | Rel-11 | 51 | Issam | CA | LTE_CA_B4_B12-Perf | Leap Wireless | Bill Chandler (bchandler@cricketcommunications.com) | LTE_CA_B4_B12-Perf | RP-121593 |
| 3137 | 805.3.5 | **LTE Advanced Carrier Aggregation of Band 5 and Band 12** | 456d? | 2011-03-22 A | 2012-12-07 A | 100% | 2011-03-22 | 2012-12-07 | 456d? |  | R4; R2 | 18200h | 18200h | 26 | Rel-11 | 51 | Issam | CA | LTE_CA_B5_B12 | US Cellular | sebastian.thalanany@uscellular.com | LTE_CA_B5_B12 |  |
| 3138 | 805.3.5.1 | Core part: LTE Advanced Carrier Aggregation of Band 5 and Band 12 | 456d? | 2011-03-22 A | 2012-12-07 A | 100% | 2011-03-22 | 2012-12-07 | 456d? | finish no earlier than 2012-12-07 | R4; R2 | 7296h | 7296h | 26 | Rel-11 | 51 | Issam | CA | LTE_CA_B5_B12-Core | US Cellular | sebastian.thalanany@uscellular.com | LTE_CA_B5_B12-Core | RP-121596 |
| 3139 | 805.3.5.2 | Perf. part: LTE Advanced Carrier Aggregation of Band 5 and Band 12 | 451d? | 2011-03-25 A | 2012-12-07 A | 100% | 2011-03-25 | 2012-12-07 | 451d? | finish no earlier than 2012-12-07 | R4 | 3608h | 3608h | 26 | Rel-11 | 51 | Issam | CA | LTE_CA_B5_B12-Perf | US Cellular | sebastian.thalanany@uscellular.com | LTE_CA_B5_B12-Perf | RP-121597 |
| 3140 | 805.3.6 | **LTE Advanced Carrier Aggregation of Band 7 and Band 20** | 389d? | 2011-03-22 A | 2012-09-07 A | 100% | 2011-03-22 | 2012-09-07 | 389d? |  | R4 | 9288h | 9288h | 26 | Rel-11 | 51 | Issam | CA | LTE_CA_B7_B20 | Huawei | Steven Chen | LTE_CA_B7_B20 |  |
| 3141 | 805.3.6.1 | Core part: LTE Advanced Carrier Aggregation of Band 7 and Band 20 | 386d? | 2011-03-22 A | 2012-09-07 A | 100% | 2011-03-22 | 2012-09-07 | 386d? | finish no earlier than 2012-09-07 | R4 | 3088h | 3088h | 26 | Rel-11 | 51 | Issam | CA | LTE_CA_B7_B20-Core | Huawei | Steven Chen | LTE_CA_B7_B20-Core | RP-121032 |
| 3142 | 805.3.6.2 | Perf. part: LTE Advanced Carrier Aggregation of Band 7 and Band 20 | 386d? | 2011-03-25 A | 2012-09-07 A | 100% | 2011-03-25 | 2012-09-07 | 386d? | finish no earlier than 2012-09-07 | R4 | 3088h | 3088h | 26 | Rel-11 | 51 | Issam | CA | LTE_CA_B7_B20-Perf | Huawei | Steven Chen | LTE_CA_B7_B20-Perf | RP-121033 |
| 3143 | 805.3.7 | **LTE Advanced Carrier Aggregation of Band 2 and Band 17** | 455d? | 2011-03-23 A | 2012-12-07 A | 100% | 2011-03-23 | 2012-12-07 | 455d? |  | R4 | 10336h | 10336h | 26 | Rel-11 | 51 | Issam | CA | LTE_CA_B2_B17 | AT&T | marc.grant@att.com | LTE_CA_B2_B17 |  |
| 3144 | 805.3.7.1 | Core part: LTE Advanced Carrier Aggregation of Band 2 and Band 17 | 386d? | 2011-03-23 A | 2012-09-07 A | 100% | 2011-03-23 | 2012-09-07 | 386d? | finish no earlier than 2012-09-07 | R4 | 3088h | 3088h | 26 | Rel-11 | 51 | Issam | CA | LTE_CA_B2_B17-Core | AT&T | marc.grant@att.com | LTE_CA_B2_B17-Core | RP-121034 |
| 3145 | 805.3.7.2 | Perf. part: LTE Advanced Carrier Aggregation of Band 2 and Band 17 | 451d? | 2011-03-25 A | 2012-12-07 A | 100% | 2011-03-25 | 2012-12-07 | 451d? | finish no earlier than 2012-12-07 | R4 | 3608h | 3608h | 26 | Rel-11 | 51 | Issam | CA | LTE_CA_B2_B17-Perf | AT&T | marc.grant@att.com | LTE_CA_B2_B17-Perf | RP-121585 |
| 3146 | 805.3.8 | **LTE Advanced Carrier Aggregation of Band 4 and Band 5** | 455d? | 2011-03-23 A | 2012-12-07 A | 100% | 2011-03-23 | 2012-12-07 | 455d? |  | R4 | 10856h | 10856h | 26 | Rel-11 | 51 | Issam | CA | LTE_CA_B4_B5 | AT&T | marc.grant@att.com | LTE_CA_B4_B5 |  |
| 3147 | 805.3.8.1 | Core part: LTE Advanced Carrier Aggregation of Band 4 and Band 5 | 451d? | 2011-03-23 A | 2012-12-07 A | 100% | 2011-03-23 | 2012-12-07 | 451d? | finish no earlier than 2012-12-07 | R4 | 3608h | 3608h | 26 | Rel-11 | 51 | Issam | CA | LTE_CA_B4_B5-Core | AT&T | marc.grant@att.com | LTE_CA_B4_B5-Core | RP-121757 |
| 3148 | 805.3.8.2 | Perf. part: LTE Advanced Carrier Aggregation of Band 4 and Band 5 | 451d? | 2011-03-25 A | 2012-12-07 A | 100% | 2011-03-25 | 2012-12-07 | 451d? | finish no earlier than 2012-12-07 | R4 | 3608h | 3608h | 26 | Rel-11 | 51 | Issam | CA | LTE_CA_B4_B5-Perf | AT&T | marc.grant@att.com | LTE_CA_B4_B5-Perf | RP-121589 |

Notes:
- 3124: LTE_CA_Rel-11 / Impacted TSs and TRs: LTE
- 3125: RP#57 completed. In Europe Band 3,7,20 are interesting for LTE and LTE-Advanced deployment. Different CA combinations for these bands are of high priority for Region 1 / Impacted TSs and TRs: LTE
- 3126: RP#57 completed. RP#59 new generic TR 36.850v100 for Information and Approval / Impacted TSs and TRs: 36.101, 36.104, 36.307, new generic TR 36.850
- 3127: RP#57 completed / Impacted TSs and TRs: 36.133, 36.141
- 3128: Stage 3. RP#57 Core completed. RP#58 Perf completed / Impacted TSs and TRs: LTE
- 3129: RP#57 completed. RP#59 new generic TR 36.850v100 for Information and Approval / Impacted TSs and TRs: 36.101, 36.104, 36.133, 36.141, 36.307, new generic TR 36.850
- 3130: RP#58 completed / Impacted TSs and TRs: 36.101, 36.104, 36.133, 36.307
- 3131: Stage 3. RP#57 Core completed. RP#58 Perf completed / Impacted TSs and TRs: LTE
- 3132: RP#57 completed / Impacted TSs and TRs: 36.101, 36.104, 36.133, 36.307, new generic TR 36.850
- 3133: RP#58 completed / Impacted TSs and TRs: 36.101, 36.133, 36.141
- 3134: Stage 3. RP#58 completed / Impacted TSs and TRs: LTE
- 3135: RP#58 completed. RP#59 new generic TR 36.850v100 for Information and Approval / Impacted TSs and TRs: 36.101, 36.104, 36.307, new generic TR 36.850
- 3136: RP#58 completed / Impacted TSs and TRs: 36.133, 36.141
- 3137: Stage 3. RP#58 completed / Impacted TSs and TRs: LTE
- 3138: RP#58 completed. RP#59 new generic TR 36.850v100 for Information and Approval / Impacted TSs and TRs: 36.101, 36.104, 36.133, 36.141, 36.307, new generic TR 36.850
- 3139: RP#58 completed / Impacted TSs and TRs: 36.101, 36.104, 36.133, 36.307
- 3140: Stage 3. RP#57 completed / Impacted TSs and TRs: LTE
- 3141: RP#57 completed. RP#59 new generic TR 36.850v100 for Information and Approval / Impacted TSs and TRs: 36.101, 36.104, 36.307, new generic TR 36.850
- 3142: RP#57 completed / Impacted TSs and TRs: 36.133, 36.141
- 3143: Stage 3. RP#57 Core completed. RP#58 Perf completed / Impacted TSs and TRs: LTE
- 3144: RP#57 completed. RP#59 new generic TR 36.850v100 for Information and Approval / Impacted TSs and TRs: 36.101, 36.104, 36.133, 36.141, 36.307, new generic TR 36.850
- 3145: RP#58 completed / Impacted TSs and TRs: 36.101, 36.104, 36.133, 36.307
- 3146: Stage 3. RP#58 completed / Impacted TSs and TRs: LTE
- 3147: RP#58 completed. RP#59 new generic TR 36.850v100 for Information and Approval / Impacted TSs and TRs: 36.101, 36.104, 36.133, 36.141, 36.307, new generic TR 36.850
- 3148: RP#58 completed / Impacted TSs and TRs: 36.101, 36.104, 36.133, 36.307

| ID | WBS | Task | Duration | Start | Finish | Complete | Baseline start | Baseline finish | Baseline duration | Constraint | Resources | Work | Actual work | Acronym | PCG approved | WI rapporteur name | WI rapporteur e-mail | Release | TSG approved | MCC resp | Special Focus Doc | Acronym_3GU_Export | Status Report |
| --- | --- | --- | --- | --- | --- | --- | --- | --- | --- | --- | --- | --- | --- | --- | --- | --- | --- | --- | --- | --- | --- | --- | --- |
| 3149 | 805.3.9 | **LTE Advanced Carrier Aggregation of Band 5 and Band 17** | 455d? | 2011-03-23 A | 2012-12-07 A | 100% | 2011-03-23 | 2012-12-07 | 455d? |  | R4 | 10856h | 10856h | LTE_CA_B5_B17 | 26 | AT&T | marc.grant@att.com | Rel-11 | 51 | Issam | CA | LTE_CA_B5_B17 |  |
| 3150 | 805.3.9.1 | Core part: LTE Advanced Carrier Aggregation of Band 5 and Band 17 | 451d? | 2011-03-23 A | 2012-12-07 A | 100% | 2011-03-23 | 2012-12-07 | 451d? | finish no earlier than 2012-12-07 | R4 | 3608h | 3608h | LTE_CA_B5_B17-Core | 26 | AT&T | marc.grant@att.com | Rel-11 | 51 | Issam | CA | LTE_CA_B5_B17-Core | RP-121598 |
| 3151 | 805.3.9.2 | Perf. part: LTE Advanced Carrier Aggregation of Band 5 and Band 17 | 451d? | 2011-03-25 A | 2012-12-07 A | 100% | 2011-03-25 | 2012-12-07 | 451d? | finish no earlier than 2012-12-07 | R4 | 3608h | 3608h | LTE_CA_B5_B17-Perf | 26 | AT&T | marc.grant@att.com | Rel-11 | 51 | Issam | CA | LTE_CA_B5_B17-Perf | RP-121599 |
| 3152 | 805.3.10 | **LTE Advanced Carrier Aggregation of Band 3 and Band 20** | 258d? | 2011-09-19 A | 2012-09-07 A | 100% | 2011-09-19 | 2012-09-07 | 258d? |  | R4 | 6168h | 6168h | LTE_CA_B3_B20 | 27 | Vodafone | tim.frost@vodafone.com | Rel-11 | 53 | Issam | CA | LTE_CA_B3_B20 |  |
| 3153 | 805.3.10.1 | Core part: LTE Advanced Carrier Aggregation of Band 3 and Band 20 | 256d? | 2011-09-19 A | 2012-09-07 A | 100% | 2011-09-19 | 2012-09-07 | 256d? | finish no earlier than 2012-09-07 | R4 | 2048h | 2048h | LTE_CA_B3_B20-Core | 27 | Vodafone | tim.frost@vodafone.com | Rel-11 | 53 | Issam | CA | LTE_CA_B3_B20-Core | RP-121046 |
| 3154 | 805.3.10.2 | Perf. part: LTE Advanced Carrier Aggregation of Band 3 and Band 20 | 257d? | 2011-09-20 A | 2012-09-07 A | 100% | 2011-09-20 | 2012-09-07 | 257d? | finish no earlier than 2012-09-07 | R4 | 2056h | 2056h | LTE_CA_B3_B20-Perf | 27 | Vodafone | tim.frost@vodafone.com | Rel-11 | 53 | Issam | CA | LTE_CA_B3_B20-Perf | RP-121047 |
| 3155 | 805.3.11 | **LTE Advanced Carrier Aggregation of Band 8 and Band 20** | 325d? | 2011-09-19 A | 2012-12-07 A | 100% | 2011-09-19 | 2012-12-07 | 325d? |  | R4 | 7752h | 7752h | LTE_CA_B8_B20 | 27 | Vodafone | Luis.Anaya@vodafone.com | Rel-11 | 53 | Issam | CA | LTE_CA_B8_B20 |  |
| 3156 | 805.3.11.1 | Core part: LTE Advanced Carrier Aggregation of Band 8 and Band 20 | 323d? | 2011-09-19 A | 2012-12-07 A | 100% | 2011-09-19 | 2012-12-07 | 323d? | finish no earlier than 2012-12-07 | R4 | 2584h | 2584h | LTE_CA_B8_B20-Core | 27 | Vodafone | Luis.Anaya@vodafone.com | Rel-11 | 53 | Issam | CA | LTE_CA_B8_B20-Core | RP-121600 |
| 3157 | 805.3.11.2 | Perf. part: LTE Advanced Carrier Aggregation of Band 8 and Band 20 | 321d? | 2011-09-23 A | 2012-12-07 A | 100% | 2011-09-23 | 2012-12-07 | 321d? | finish no earlier than 2012-12-07 | R4 | 2568h | 2568h | LTE_CA_B8_B20-Perf | 27 | Vodafone | Luis.Anaya@vodafone.com | Rel-11 | 53 | Issam | CA | LTE_CA_B8_B20-Perf | RP-121601 |
| 3158 | 805.3.12 | **LTE Advanced Carrier Aggregation of Band 3 and Band 5** | 258d? | 2011-09-19 A | 2012-09-07 A | 100% | 2011-09-19 | 2012-09-07 | 258d? |  | R4 | 6160h | 6160h | LTE_CA_B3_B5 | 27 | SK Telecom | Haesung Park | Rel-11 | 53 | Issam | CA | LTE_CA_B3_B5 |  |
| 3159 | 805.3.12.1 | Core part: LTE Advanced Carrier Aggregation of Band 3 and Band 5 | 256d? | 2011-09-19 A | 2012-09-07 A | 100% | 2011-09-19 | 2012-09-07 | 256d? | finish no earlier than 2012-09-07 | R4 | 2048h | 2048h | LTE_CA_B3_B5-Core | 27 | SK Telecom | Haesung Park | Rel-11 | 53 | Issam | CA | LTE_CA_B3_B5-Core | RP-121042 |
| 3160 | 805.3.12.2 | Perf. part: LTE Advanced Carrier Aggregation of Band 3 and Band 5 | 256d? | 2011-09-21 A | 2012-09-07 A | 100% | 2011-09-21 | 2012-09-07 | 256d? | finish no earlier than 2012-09-07 | R4 | 2048h | 2048h | LTE_CA_B3_B5-Perf | 27 | SK Telecom | Haesung Park | Rel-11 | 53 | Issam | CA | LTE_CA_B3_B5-Perf | RP-121043 |
| 3161 | 805.3.13 | **LTE Advanced Carrier Aggregation of Band 4 and Band 7** | 325d? | 2011-09-19 A | 2012-12-07 A | 100% | 2011-09-19 | 2012-12-07 | 325d? |  | R4 | 7744h | 7744h | LTE_CA_B4_B7 | 27 | Rogers Wireless | takwing.wan@rci.rogers.com | Rel-11 | 53 | Issam | CA | LTE_CA_B4_B7 |  |
| 3162 | 805.3.13.1 | Core part: LTE Advanced Carrier Aggregation of Band 4 and Band 7 | 322d? | 2011-09-19 A | 2012-12-07 A | 100% | 2011-09-19 | 2012-12-07 | 322d? | finish no earlier than 2012-12-07 | R4 | 2576h | 2576h | LTE_CA_B4_B7-Core | 27 | Rogers Wireless | takwing.wan@rci.rogers.com | Rel-11 | 53 | Issam | CA | LTE_CA_B4_B7-Core | RP-121590 |
| 3163 | 805.3.13.2 | Perf. part: LTE Advanced Carrier Aggregation of Band 4 and Band 7 | 321d? | 2011-09-23 A | 2012-12-07 A | 100% | 2011-09-23 | 2012-12-07 | 321d? | finish no earlier than 2012-12-07 | R4 | 2568h | 2568h | LTE_CA_B4_B7-Perf | 27 | Rogers Wireless | takwing.wan@rci.rogers.com | Rel-11 | 53 | Issam | CA | LTE_CA_B4_B7-Perf | RP-121591 |
| 3164 | 805.3.14 | **LTE Advanced Carrier Aggregation of Band 11 and Band 18** | 265d? | 2011-12-09 A | 2012-12-07 A | 100% | 2011-12-09 | 2012-12-07 | 265d? |  | R4; R2 | 10568h | 10568h | LTE_CA_B11_B18 | 28 | KDDI | Masaaki Obara (ms-obara@kddi.com) | Rel-11 | 54 | Issam | CA | LTE_CA_B11_B18 |  |
| 3165 | 805.3.14.1 | Core part: LTE Advanced Carrier Aggregation of Band 11 and Band 18 | 265d? | 2011-12-09 A | 2012-12-07 A | 100% | 2011-12-09 | 2012-12-07 | 265d? | finish no earlier than 2012-12-07 | R4; R2 | 4240h | 4240h | LTE_CA_B11_B18-Core | 28 | KDDI | Masaaki Obara (ms-obara@kddi.com) | Rel-11 | 54 | Issam | CA | LTE_CA_B11_B18-Core | RP-121602 |
| 3166 | 805.3.14.2 | Perf. part: LTE Advanced Carrier Aggregation of Band 11 and Band 18 | 261d? | 2011-12-15 A | 2012-12-07 A | 100% | 2011-12-15 | 2012-12-07 | 261d? | finish no earlier than 2012-12-07 | R4 | 2088h | 2088h | LTE_CA_B11_B18-Perf | 28 | KDDI | Masaaki Obara (ms-obara@kddi.com) | Rel-11 | 54 | Issam | CA | LTE_CA_B11_B18-Perf | RP-121603 |
| 3167 | 805.3.15 | **LTE Advanced Carrier Aggregation of Band 1 and Band 18** | 198d? | 2011-12-09 A | 2012-09-07 A | 100% | 2011-12-09 | 2012-09-07 | 198d? |  | R4; R2 | 7904h | 7904h | LTE_CA_B1_B18 | 28 | KDDI | Masaaki Obara (ms-obara@kddi.com) | Rel-11 | 54 | Issam | CA | LTE_CA_B1_B18 |  |
| 3168 | 805.3.15.1 | Core part: LTE Advanced Carrier Aggregation of Band 1 and Band 18 | 198d? | 2011-12-09 A | 2012-09-07 A | 100% | 2011-12-09 | 2012-09-07 | 198d? | finish no earlier than 2012-09-07 | R4; R2 | 3168h | 3168h | LTE_CA_B1_B18-Core | 28 | KDDI | Masaaki Obara (ms-obara@kddi.com) | Rel-11 | 54 | Issam | CA | LTE_CA_B1_B18-Core | RP-121052 |
| 3169 | 805.3.15.2 | Perf. part: LTE Advanced Carrier Aggregation of Band 1 and Band 18 | 196d? | 2011-12-13 A | 2012-09-07 A | 100% | 2011-12-13 | 2012-09-07 | 196d? | finish no earlier than 2012-12-07 | R4 | 1568h | 1568h | LTE_CA_B1_B18-Perf | 28 | KDDI | Masaaki Obara (ms-obara@kddi.com) | Rel-11 | 54 | Issam | CA | LTE_CA_B1_B18-Perf | RP-121053 |
| 3170 | 805.3.16 | **LTE Advanced Carrier Aggregation of Band 1 and Band 19** | 197d? | 2011-12-12 A | 2012-09-07 A | 100% | 2011-12-12 | 2012-09-07 | 197d? |  | R4; R2 | 6432h | 6432h | LTE_CA_B1_B19 | 28 | NTT DoCoMo | Hiromasa Umeda (umedah@nttdocomo.co.jp) | Rel-11 | 54 | Issam | CA | LTE_CA_B1_B19 |  |
| 3171 | 805.3.16.1 | Core part: LTE Advanced Carrier Aggregation of Band 1 and Band 19 | 137d? | 2012-03-05 A | 2012-09-07 A | 100% | 2012-03-05 | 2012-09-07 | 137d? | finish no earlier than 2012-09-07 | R4; R2 | 2192h | 2192h | LTE_CA_B1_B19-Core | 28 | NTT DoCoMo | Hiromasa Umeda (umedah@nttdocomo.co.jp) | Rel-11 | 54 | Issam | CA | LTE_CA_B1_B19-Core | RP-120552 |
| 3172 | 805.3.16.2 | Perf. part: LTE Advanced Carrier Aggregation of Band 1 and Band 19 | 136d? | 2011-12-12 A | 2012-06-15 A | 100% | 2011-12-12 | 2012-06-15 | 136d? | finish no earlier than 2012-12-07 | R4 | 1088h | 1088h | LTE_CA_B1_B19-Perf | 28 | NTT DoCoMo | Hiromasa Umeda (umedah@nttdocomo.co.jp) | Rel-11 | 54 | Issam | CA | LTE_CA_B1_B19-Perf | RP-120553 |

Notes:
- 3149: Stage 3. RP#58 completed / Impacted TSs and TRs: LTE
- 3150: RP#58 completed. RP#59 new generic TR 36.850v100 for Information and Approval / Impacted TSs and TRs: 36.101, 36.104, 36.133, 36.141, 36.307, new generic TR 36.850
- 3151: RP#58 completed / Impacted TSs and TRs: 36.101, 36.104, 36.133, 36.141, 36.307
- 3152: Stage 3. RP#57 completed / Impacted TSs and TRs: LTE
- 3153: RP#57 completed. RP#59 new generic TR 36.850v100 for Information and Approval / Impacted TSs and TRs: 36.101, 36.104, 36.133, 36.307, new generic TR 36.850
- 3154: RP#57 completed / Impacted TSs and TRs: 36.101, 36.104, 36.133, 36.141, 36.307
- 3155: Stage 3. RP#58 completed / Impacted TSs and TRs: LTE
- 3156: RP#58 completed. RP#59 new generic TR 36.850v100 for Information and Approval / Impacted TSs and TRs: 36.101, 36.104, 36.307, new generic TR 36.850
- 3157: RP#58 completed / Impacted TSs and TRs: 36.101, 36.104, 36.133, 36.141
- 3158: Stage 3. RP#57 completed / Impacted TSs and TRs: LTE
- 3159: RP#57 completed. RP#59 new generic TR 36.850v100 for Information and Approval / Impacted TSs and TRs: 36.101, 36.104, 36.133, 36.307, new generic TR 36.850
- 3160: RP#57 completed / Impacted TSs and TRs: 36.133, 36.141
- 3161: Stage 3. RP#58 completed / Impacted TSs and TRs: LTE
- 3162: RP#58 completed. RP#59 new generic TR 36.850v100 for Information and Approval / Impacted TSs and TRs: 36.101, 36.104, 36.133, 36.141, 36.307, 37.104, new generic TR 36.850
- 3163: RP#58 completed / Impacted TSs and TRs: 36.101, 36.104, 36.133, 36.141, 36.307
- 3164: Stage 3. RP#58 completed / Impacted TSs and TRs: LTE
- 3165: RP#58 completed. RP#59 new generic TR 36.850v100 for Information and Approval / Impacted TSs and TRs: 36.101, 36.104, 36.307, new generic TR 36.850
- 3166: RP#58 completed / Impacted TSs and TRs: 36.133
- 3167: Stage 3. RP#57 completed / Impacted TSs and TRs: LTE
- 3168: RP#57 completed. RP#59 new generic TR 36.850v100 for Information and Approval / Impacted TSs and TRs: 36.101, 36.104, 36.307, new generic TR 36.850
- 3169: RP#57 completed / Impacted TSs and TRs: 36.133, 36.141
- 3170: Stage 3. RP#56 completed. Updated WID RP-111765=>RP-120866 / Impacted TSs and TRs: LTE
- 3171: RP#56 completed. RP#59 new generic TR 36.850v100 for Information and Approval / Impacted TSs and TRs: 36.101, 36.104, 36.133, 36.307, new generic TR 36.850
- 3172: RP#56 completed / Impacted TSs and TRs: 36.133, 36.141

| ID | WBS | Task | Duration | Start | Finish | Complete | Baseline start | Baseline finish | Baseline duration | Constraint | Resources | Work | Actual work | Acronym | PCG approved | WI rapporteur name | Release | TSG approved | MCC resp | Special Focus Doc | Acronym_3GU_Export | Status Report |
| --- | --- | --- | --- | --- | --- | --- | --- | --- | --- | --- | --- | --- | --- | --- | --- | --- | --- | --- | --- | --- | --- | --- |
| 3173 | 805.3.17 | **LTE Advanced Carrier Aggregation of Band 1 and Band 21** | 265d? | 2011-12-09 A | 2012-12-07 A | 100% | 2011-12-09 | 2012-12-07 | 265d? |  | R4; R2 | 9496h | 9496h | LTE_CA_B1_B21 | 28 | NTT DoCoMo | Rel-11 | 54 | Issam | CA | LTE_CA_B1_B21 |  |
| 3174 | 805.3.17.1 | Core part: LTE Advanced Carrier Aggregation of Band 1 and Band 21 | 198d? | 2011-12-09 A | 2012-09-07 A | 100% | 2011-12-09 | 2012-09-07 | 198d? | finish no earlier than 2012-09-07 | R4; R2 | 3168h | 3168h | LTE_CA_B1_B21-Core | 28 | NTT DoCoMo | Rel-11 | 54 | Issam | CA | LTE_CA_B1_B21-Core | RP-121054 |
| 3175 | 805.3.17.2 | Perf. part: LTE Advanced Carrier Aggregation of Band 1 and Band 21 | 263d? | 2011-12-13 A | 2012-12-07 A | 100% | 2011-12-13 | 2012-12-07 | 263d? | finish no earlier than 2012-12-07 | R4 | 2088h | 2088h | LTE_CA_B1_B21-Perf | 28 | NTT DoCoMo | Rel-11 | 54 | Issam | CA | LTE_CA_B1_B21-Perf | RP-121055 |
| 3176 | 805.3.18 | **LTE Advanced Carrier Aggregation of Band 3 and Band 8** | 204d? | 2012-03-05 A | 2012-12-07 A | 100% | 2012-03-05 | 2012-12-07 | 204d? |  | R4 | 4864h | 4864h | LTE_CA_B3_B8 | 28 | KT | Rel-11 | 55 | Issam | CA | LTE_CA_B3_B8 |  |
| 3177 | 805.3.18.1 | Core part: LTE Advanced Carrier Aggregation of Band 3 and Band 8 | 201d? | 2012-03-05 A | 2012-12-07 A | 100% | 2012-03-05 | 2012-12-07 | 201d? | finish no earlier than 2012-12-07 | R4 | 1608h | 1608h | LTE_CA_B3_B8-Core | 28 | KT | Rel-11 | 55 | Issam | CA | LTE_CA_B3_B8-Core | RP-121586 |
| 3178 | 805.3.18.2 | Perf. part: LTE Advanced Carrier Aggregation of Band 3 and Band 8 | 203d? | 2012-03-06 A | 2012-12-07 A | 100% | 2012-03-06 | 2012-12-07 | 203d? | finish no earlier than 2012-12-07 | R4 | 1624h | 1624h | LTE_CA_B3_B8-Perf | 28 | KT | Rel-11 | 55 | Issam | CA | LTE_CA_B3_B8-Perf | RP-121587 |
| 3179 | 805.4 | **Rel-11 intra-band Carrier Aggregation** | 334d? | 2011-06-07 A | 2012-09-07 A | 100% | 2011-06-07 | 2012-09-07 | 334d? |  | RP | 18864h | 18864h |  | 30 |  | Rel-11 | 58 |  | CA |  |  |
| 3180 | 805.4.1 | **LTE Advanced Carrier Aggregation in Band 38** | 334d? | 2011-06-07 A | 2012-09-07 A | 100% | 2011-06-07 | 2012-09-07 | 334d? |  | R4 | 7976h | 7976h | LTE_CA_B38 | 27 | Huawei | Rel-11 | 52 | Issam | CA | LTE_CA_B38 |  |
| 3181 | 805.4.1.1 | Core part: LTE Advanced Carrier Aggregation in Band 38 | 331d? | 2011-06-07 A | 2012-09-07 A | 100% | 2011-06-07 | 2012-09-07 | 331d? | finish no earlier than 2012-09-07 | R4 | 2648h | 2648h | LTE_CA_B38-Core | 27 | Huawei | Rel-11 | 52 | Issam | CA | LTE_CA_B38-Core | RP-121060 |
| 3182 | 805.4.1.2 | Perf. part: LTE Advanced Carrier Aggregation in Band 38 | 333d? | 2011-06-08 A | 2012-09-07 A | 100% | 2011-06-08 | 2012-09-07 | 333d? | finish no earlier than 2012-09-07 | R4 | 2656h | 2656h | LTE_CA_B38-Perf | 27 | Huawei | Rel-11 | 52 | Issam | CA | LTE_CA_B38-Perf | RP-121061 |
| 3183 | 805.4.2 | **LTE Advanced Carrier Aggregation in Band 41** | 197d? | 2011-06-07 A | 2012-03-02 A | 100% | 2011-06-07 | 2012-03-02 | 197d? |  | R4 | 4720h | 4720h | LTE_CA_B41 | 27 | Clearwire | Rel-11 | 52 | Issam | CA | LTE_CA_B41 |  |
| 3184 | 805.4.2.1 | Core part: LTE Advanced Carrier Aggregation in Band 41 | 196d? | 2011-06-07 A | 2012-03-02 A | 100% | 2011-06-07 | 2012-03-02 | 196d? | finish no earlier than 2012-02-23 | R4 | 1568h | 1568h | LTE_CA_B41-Core | 27 | Clearwire | Rel-11 | 52 | Issam | CA | LTE_CA_B41-Core | RP-120126 |
| 3185 | 805.4.2.2 | Perf. part: LTE Advanced Carrier Aggregation in Band 41 | 197d? | 2011-06-07 A | 2012-03-02 A | 100% | 2011-06-07 | 2012-03-02 | 197d? | finish no earlier than 2012-03-02 | R4 | 1576h | 1576h | LTE_CA_B41-Perf | 27 | Clearwire | Rel-11 | 52 | Issam | CA | LTE_CA_B41-Perf | RP-120127 |
| 3186 | 805.4.3 | **LTE Advanced Carrier Aggregation in Band 7** | 258d? | 2011-09-19 A | 2012-09-07 A | 100% | 2011-09-19 | 2012-09-07 | 258d? |  | R4 | 6168h | 6168h | LTE_CA_B7 | 27 | China Unicom | Rel-11 | 53 | Issam | CA | LTE_CA_B7 |  |
| 3187 | 805.4.3.1 | Core part: LTE Advanced Carrier Aggregation in Band 7 | 256d? | 2011-09-19 A | 2012-09-07 A | 100% | 2011-09-19 | 2012-09-07 | 256d? | finish no earlier than 2012-09-07 | R4 | 2048h | 2048h | LTE_CA_B7-Core | 27 | China Unicom | Rel-11 | 53 | Issam | CA | LTE_CA_B7-Core | RP-121062 |
| 3188 | 805.4.3.2 | Perf. part: LTE Advanced Carrier Aggregation in Band 7 | 257d? | 2011-09-20 A | 2012-09-07 A | 100% | 2011-09-20 | 2012-09-07 | 257d? | finish no earlier than 2012-09-07 | R4 | 2056h | 2056h | LTE_CA_B7-Perf | 27 | China Unicom | Rel-11 | 53 | Issam | CA | LTE_CA_B7-Perf | RP-121063 |
| 3189 | 806 | **UE Over The Air (Antenna) conformance testing methodology - Laptop mounted equipment Free Space test** | 1842d? | 2009-09-18 A | 2016-09-15 A | 100% | 2009-09-18 | 2014-12-05 | 1374d? |  | R4; R5 | 45192h | 45192h | UEAnt_FSTest | 23 | CATR | Rel-11 | 45 | Issam |  | UEAnt_FSTest |  |
| 3190 | 806.1 | Core part: UE Over The Air (Antenna) conformance testing methodology - Laptop mounted equipment Free Space test | 583d? | 2009-09-18 A | 2011-12-09 A | 100% | 2009-09-18 | 2011-12-09 | 583d? | finish no earlier than 2011-12-09 | R4 | 4664h | 4664h | UEAnt_FSTest-Core | 23 | CATR | Rel-11 | 45 | Issam |  | UEAnt_FSTest-Core | RP-111456 |
| 3191 | 806.2 | Test part: UE Over The Air (Antenna) conformance testing methodology - Laptop mounted equipment Free Space test | 1388d? | 2011-06-15 A | 2016-09-15 A | 100% | 2011-06-07 | 2014-12-05 | 926d? | finish no earlier than 2016-09-15 | R5 | 11056h | 11056h | UEAnt_FSTest-UEConTest | 27 | ZTE | Rel-11 | 52 | Ingbert |  | UEAnt_FSTest-UEConTest | RP-151187 |
| 3192 | 807 | **Eight carrier HSDPA** | 589d? | 2010-09-15 A | 2012-12-07 A | 100% | 2010-09-15 | 2012-12-07 | 589d? |  | R1; R2; R3; R4 | 37768h | 37768h | 8C_HSDPA | 26 | Ericsson | Rel-11 | 50 | Patrick |  | 8C_HSDPA |  |
| 3193 | 807.1 | Core part: Eight carrier HSDPA | 461d? | 2010-09-15 A | 2012-06-15 A | 100% | 2010-09-15 | 2012-06-15 | 461d? | finish no earlier than 2012-06-15 | R1; R2; R3; R4 | 14752h | 14752h | 8C_HSDPA-Core | 26 | Ericsson | Rel-11 | 50 | Patrick |  | 8C_HSDPA-Core | RP-120971 |
| 3194 | 807.2 | Perf. part: Eight carrier HSDPA | 523d? | 2010-12-15 A | 2012-12-07 A | 100% | 2010-12-15 | 2012-12-07 | 523d? | finish no earlier than 2012-12-07 | R4 | 4168h | 4168h | 8C_HSDPA-Perf | 26 | Ericsson | Rel-11 | 50 | Issam |  | 8C_HSDPA-Perf | RP-120972 |
| 3195 | 808 | **UE demodulation performance requirements under multiple-cell scenario for 1.28Mcps TDD** | 324d? | 2010-12-10 A | 2012-03-02 A | 100% | 2010-12-10 | 2012-03-02 | 324d? |  | R4; R5 | 7760h | 7760h | LCR_TDD_UE_demod_mc | 26 | China Mobile | Rel-11 | 50 | Issam |  | LCR_TDD_UE_demod_mc |  |
| 3196 | 808.1 | Perf. part: UE demodulation performance requirements under multiple-cell scenario for 1.28Mcps TDD | 201d? | 2010-12-10 A | 2011-09-16 A | 100% | 2010-12-10 | 2011-09-16 | 201d? | finish no earlier than 2011-09-16 | R4 | 1608h | 1608h | LCR_TDD_UE_demod_mc-Perf | 26 | China Mobile | Rel-11 | 50 | Issam |  | LCR_TDD_UE_demod_mc-Perf | RP-110996 |
| 3197 | 808.2 | Test part: UE demodulation performance requirements under multiple-cell scenario for 1.28Mcps TDD | 121d? | 2011-09-19 A | 2012-03-02 A | 100% | 2011-09-19 | 2012-03-02 | 121d? | finish no earlier than 2012-02-23 | R5 | 968h | 968h | LCR_TDD_UE_demod_mc-UEConTest | 27 | China Mobile | Rel-11 | 53 | Ingbert |  | LCR_TDD_UE_demod_mc-UEConTest | RP-120052 |

Notes:
- 3173: Stage 3. RP#57 completed. Updated WID RP-111764=>RP-121173 / Impacted TSs and TRs: LTE / WI rapporteur e-mail: Hiromasa Umeda (umedah@nttdocomo.co.jp)
- 3174: RP#57 completed. RP#59 new generic TR 36.850v100 for Information and Approval / Impacted TSs and TRs: 36.101, 36.104, 36.133, 36.307, new generic TR 36.850 / WI rapporteur e-mail: Hiromasa Umeda (umedah@nttdocomo.co.jp)
- 3175: RP#57 completed / Impacted TSs and TRs: 36.133, 36.141 / WI rapporteur e-mail: Hiromasa Umeda (umedah@nttdocomo.co.jp)
- 3176: Stage 3. RP#58 completed / Impacted TSs and TRs: LTE / WI rapporteur e-mail: Chungwoo HWANG (cwhwang@kt.com)
- 3177: RP#58 completed. RP#59 new generic TR 36.850v100 for Information and Approval / Impacted TSs and TRs: 36.101, 36.104, 36.133, 36.307, new generic TR 36.850 / WI rapporteur e-mail: Chungwoo HWANG (cwhwang@kt.com)
- 3178: RP#58 completed / Impacted TSs and TRs: 36.133, 36.141 / WI rapporteur e-mail: Chungwoo HWANG (cwhwang@kt.com)
- 3179: LTE_CA_Rel-11 / Impacted TSs and TRs: LTE
- 3180: Stage 3. RP#57 completed. WI only covers intra-band contiguous and not non-contiguous aspects / Impacted TSs and TRs: LTE / WI rapporteur e-mail: ronnie.zhang@huawei.com
- 3181: RP#57 completed. TR 36.830 v100 for Information & Approval / Impacted TSs and TRs: 36.101, 36.104, 36.133, 36.141, 36.307, 37.104, 37.141, new TR 36.833-1-38 [instead of 36.830] / WI rapporteur e-mail: ronnie.zhang@huawei.com
- 3182: RP#57 completed / Impacted TSs and TRs: 36.101, 36.104, 36.133, 36.141, 36.307, 37.104, 37.141 / WI rapporteur e-mail: ronnie.zhang@huawei.com
- 3183: RP#55 completed. WI only covers intra-band contiguous and not non-contiguous aspects. / Impacted TSs and TRs: LTE / WI rapporteur e-mail: michael.hart@clearwire.com
- 3184: RP#55 completed. Updated WID RP-110673=>RP-120249. TR 36.827 v100 for Information + Approval / Impacted TSs and TRs: 36.101, 36.104, 36.133, 36.141, 36.307, 37.104, new TR 36.833-1-41 [instead of 36.827] / WI rapporteur e-mail: michael.hart@clearwire.com
- 3185: RP#55 completed / Impacted TSs and TRs: 36.101, 36.104, 36.133, 36.141, 36.307 / WI rapporteur e-mail: michael.hart@clearwire.com
- 3186: Stage 3. RP#57 completed. Updated WID RP-111356=>RP-121193. WI only covers intra-band contiguous and not non-contiguous aspects / Impacted TSs and TRs: LTE / WI rapporteur e-mail: Zhangchao Ma (mazc@chinaunicom.cn), Zhonghao Zhang (zhangzh306@chinaunicom.cn)
- 3187: RP#57 completed. TR 36.831 v100 for Information & Approval / Impacted TSs and TRs: 36.101, 36.104, 36.133, 36.141, 36.307, 37.104, 37.141, new TR 36.833-1-07 [instead of 36.831] / WI rapporteur e-mail: Zhangchao Ma (mazc@chinaunicom.cn), Zhonghao Zhang (zhangzh306@chinaunicom.cn)
- 3188: RP#57 completed / Impacted TSs and TRs: 36.101, 36.104, 36.133, 36.141, 36.307, 37.104, 37.141 / WI rapporteur e-mail: Zhangchao Ma (mazc@chinaunicom.cn), Zhonghao Zhang (zhangzh306@chinaunicom.cn)
- 3189: - / Impacted TSs and TRs: UTRA / WI rapporteur e-mail: Guo Lin (guolin@emcite.com)
- 3190: RP#54 completed / Impacted TSs and TRs: 25.144, 25.914, 34.114 / WI rapporteur e-mail: Guo Lin (guolin@emcite.com)
- 3191: 1st Apr 15: CD:Mon 15/06/15->Wed 15/06/16 1st Apr 15: Stat Rep: RP-141846->RP-150068 03/07/15: Stat Rep: RP-150068->RP-150603 29/09/15: Stat Rep: RP-150603->RP-151187 / Impacted TSs and TRs: 34.114 / WI rapporteur e-mail: carolyn.tayl@zte.com.cn
- 3192: Stage 3 / Impacted TSs and TRs: UTRA / WI rapporteur e-mail: johan.hultell@ericsson.com
- 3193: RP#57 completed / Impacted TSs and TRs: 25.101, 25.104, 25.133, 25.211, 25.212, 25.213, 25.214, 25.215, 25.308, 25.331, 25.423, 25.433, 26.306 / WI rapporteur e-mail: johan.hultell@ericsson.com
- 3194: RP#57 completed / Impacted TSs and TRs: 25.101, 25.104, 25.133, 25.141 / WI rapporteur e-mail: johan.hultell@ericsson.com
- 3195: Stage 3 / Impacted TSs and TRs: UTRA / WI rapporteur e-mail: Li Nan (linan@chinamobile.com)
- 3196: RP#53 completed. TR 25.873v100 for Approval / Impacted TSs and TRs: 25.102, new TR 25.873 / WI rapporteur e-mail: Li Nan (linan@chinamobile.com)
- 3197: RP#55 completed / Impacted TSs and TRs: 34.108, 34.122 / WI rapporteur e-mail: Ma Shuai (mashuai@chinamobile.com)

| ID | WBS | Task | Duration | Start | Finish | Complete | Baseline start | Baseline finish | Baseline duration | Constraint | Resources | Work | Actual work | Acronym | PCG approved | WI rapporteur name | WI rapporteur e-mail | Release | TSG approved | MCC resp | Acronym_3GU_Export | Status Report |
| --- | --- | --- | --- | --- | --- | --- | --- | --- | --- | --- | --- | --- | --- | --- | --- | --- | --- | --- | --- | --- | --- | --- |
| 3198 | 809 | **Uplink Transmit Diversity for HSPA** | 929d? | 2010-12-10 A | 2014-06-13 A | 100% | 2010-12-10 | 2014-06-13 | 929d? |  | R1; R4; R2; R3; R5 | 83568.3h | 83568.3h | HSPA_UL_TxDiv | 26 | Huawei | zongjie.wang@huawei.com | Rel-11 | 50 | Patrick | HSPA_UL_TxDiv |  |
| 3199 | 809.1 | Core part: Uplink Transmit Diversity for HSPA - Closed Loop | 528d? | 2010-12-10 A | 2012-12-07 A | 100% | 2010-12-10 | 2012-12-07 | 528d? | finish no earlier than 2012-12-07 | R1; R4; R2; R3 | 16896h | 16896h | HSPA_UL_TxDiv-CL-Core | 26 | Huawei | zongjie.wang@huawei.com | Rel-11 | 50 | Patrick | HSPA_UL_TxDiv-CL-Core | RP-121542 |
| 3200 | 809.2 | Perf. part: Uplink Transmit Diversity for HSPA - Closed Loop | 721d? | 2010-12-14 A | 2013-09-06 A | 100% | 2010-12-14 | 2013-09-06 | 721d? | finish no earlier than 2013-09-06 | R4 | 5760.31h | 5760.31h | HSPA_UL_TxDiv-CL-Perf | 26 | Huawei | zongjie.wang@huawei.com | Rel-11 | 50 | Issam | HSPA_UL_TxDiv-CL-Perf | RP-130477 |
| 3201 | 809.3 | Core part: Uplink Transmit Diversity for HSPA - Open Loop | 528d? | 2010-12-10 A | 2012-12-07 A | 100% | 2010-12-10 | 2012-12-07 | 528d? | finish no earlier than 2012-12-07 | R4; R1; R2; R3 | 16896h | 16896h | HSPA_UL_TxDiv-OL-Core | 26 | Huawei | zongjie.wang@huawei.com | Rel-11 | 50 | Patrick | HSPA_UL_TxDiv-OL-Core | RP-121544 |
| 3202 | 809.4 | Perf. part: Uplink Transmit Diversity for HSPA - Open Loop | 521d? | 2010-12-14 A | 2012-12-07 A | 100% | 2010-12-14 | 2012-12-07 | 521d? | finish no earlier than 2012-12-07 | R4 | 4168h | 4168h | HSPA_UL_TxDiv-OL-Perf | 26 | Huawei | zongjie.wang@huawei.com | Rel-11 | 50 | Issam | HSPA_UL_TxDiv-OL-Perf | RP-121545 |
| 3203 | 809.5 | Test part: Uplink Transmit Diversity for HSPA | 336d? | 2013-03-04 A | 2014-06-13 A | 100% | 2013-03-04 | 2014-06-13 | 336d? | finish no earlier than 2014-06-13 | R5 | 2688h | 2688h | HSPA_UL_TxDiv-UEConTest | 30 | Qualcomm | Shubhang Vora (svora@qti.qualcomm.com) | Rel-11 | 59 | Ingbert | HSPA_UL_TxDiv-UEConTest | RP-140767 |
| 3204 | 810 | **Introduction of New Configuration for 4C-HSDPA** | 328d? | 2011-03-22 A | 2012-06-15 A | 100% | 2011-03-22 | 2012-06-15 | 328d? |  | R4; R2 | 10928h | 10928h | 4C_HSDPA_Config | 26 | Telus Communications | jorge.delrio@telus.com | Rel-11 | 51 | Issam | 4C_HSDPA_Config |  |
| 3205 | 810.1 | Core part: Introduction of New Configuration for 4C-HSDPA | 192d? | 2011-03-22 A | 2011-12-09 A | 100% | 2011-03-22 | 2011-12-09 | 192d? | finish no earlier than 2011-12-09 | R4; R2 | 3072h | 3072h | 4C_HSDPA_Config-Core | 26 | Telus Communications | jorge.delrio@telus.com | Rel-11 | 51 | Issam | 4C_HSDPA_Config-Core | RP-111463 |
| 3206 | 810.2 | Perf. part: Introduction of New Configuration for 4C-HSDPA | 326d? | 2011-03-24 A | 2012-06-15 A | 100% | 2011-03-24 | 2012-06-15 | 326d? | finish no earlier than 2012-06-15 | R4 | 2608h | 2608h | 4C_HSDPA_Config-Perf | 26 | Telus Communications | jorge.delrio@telus.com | Rel-11 | 51 | Issam | 4C_HSDPA_Config-Perf | RP-120475 |
| 3207 | 811 | **Non-contiguous 4C-HSDPA operation** | 516d? | 2011-03-23 A | 2013-03-01 A | 100% | 2011-03-23 | 2013-03-01 | 516d? |  | R4; R2; R3 | 24360h | 24360h | NC_4C_HSDPA | 26 | Ericsson | muhammad.kazmi@ericsson.com | Rel-11 | 51 | Issam | NC_4C_HSDPA |  |
| 3208 | 811.1 | Core part: Non-contiguous 4C-HSDPA operation | 328d? | 2011-06-15 A | 2012-09-07 A | 100% | 2011-06-15 | 2012-09-07 | 328d? | finish no earlier than 2012-09-07 | R4; R2; R3 | 7872h | 7872h | NC_4C_HSDPA-Core | 26 | Ericsson | muhammad.kazmi@ericsson.com | Rel-11 | 51 | Issam | NC_4C_HSDPA-Core | RP-120842 |
| 3209 | 811.2 | Perf. part: Non-contiguous 4C-HSDPA operation | 513d? | 2011-03-23 A | 2013-03-01 A | 100% | 2011-03-23 | 2013-03-01 | 513d? | finish no earlier than 2013-03-01 | R4 | 4104h | 4104h | NC_4C_HSDPA-Perf | 26 | Ericsson | muhammad.kazmi@ericsson.com | Rel-11 | 51 | Issam | NC_4C_HSDPA-Perf | RP-130049 |
| 3210 | 812 | **Further Enhancements to CELL_FACH** | 1057d? | 2011-03-18 A | 2015-03-15 A | 100% | 2011-03-18 | 2014-09-12 | 924d? |  | R1; R2; R3; R4; R5 | 66320h | 66320h | Cell_FACH_enh | 26 | Qualcomm | Ravi Agarwal | Rel-11 | 51 | Patrick | Cell_FACH_enh |  |
| 3211 | 812.1 | Core part: Further Enhancements to CELL_FACH | 458d? | 2011-03-18 A | 2012-12-07 A | 100% | 2011-03-18 | 2012-12-07 | 458d? | finish no earlier than 2012-12-07 | R2; R1; R3; R4 | 14656h | 14656h | Cell_FACH_enh-Core | 26 | Qualcomm | Ravi Agarwal | Rel-11 | 51 | Yong-Jun | Cell_FACH_enh-Core | RP-121547 |
| 3212 | 812.2 | Perf. part: Further Enhancements to CELL_FACH | 717d? | 2011-03-24 A | 2013-12-06 A | 100% | 2011-03-24 | 2013-12-06 | 717d? | finish no earlier than 2013-12-06 | R4 | 5728h | 5728h | Cell_FACH_enh-Perf | 26 | Qualcomm | Heechoon Lee (heechoon@qti.qualcomm.com) | Rel-11 | 51 | Issam | Cell_FACH_enh-Perf | RP-131459 |
| 3213 | 812.3 | Test part: Further Enhancements to CELL_FACH | 457d? | 2013-06-15 A | 2015-03-15 A | 100% | 2013-06-18 | 2014-09-12 | 327d? | finish no earlier than 2015-03-15 | R5 | 3656h | 3656h | Cell_FACH_enh-UEConTest | 31 | Ericsson | leif.mattisson@ericsson.com | Rel-11 | 60 | Ingbert | Cell_FACH_enh-UEConTest | RP-150132 |
| 3214 | 813 | **HSDPA Multiflow Data Transmission** | 924d? | 2011-09-19 A | 2015-03-15 A | 100% | 2011-09-19 | 2014-12-05 | 851d? |  | R2; R1; R3; R4; R5 | 54136h | 54136h | HSDPA_MFTX | 27 | Nokia Siemens Networks | Alexander Sayenko | Rel-11 | 53 | Yong-Jun | HSDPA_MFTX |  |
| 3215 | 813.1 | Core part: HSDPA Multiflow Data Transmission | 325d? | 2011-09-19 A | 2012-12-07 A | 100% | 2011-09-19 | 2012-12-07 | 325d? | finish no earlier than 2012-12-07 | R2; R1; R3; R4 | 10400h | 10400h | HSDPA_MFTX-Core | 27 | Nokia Siemens Networks | Alexander Sayenko | Rel-11 | 53 | Yong-Jun | HSDPA_MFTX-Core | RP-121551 |
| 3216 | 813.2 | Perf. part: HSDPA Multiflow Data Transmission | 519d? | 2011-09-20 A | 2013-09-06 A | 100% | 2011-09-20 | 2013-09-06 | 519d? | finish no earlier than 2013-09-06 | R4 | 4152h | 4152h | HSDPA_MFTX-Perf | 27 | Nokia Siemens Networks | kamil.bechta@nsn.com | Rel-11 | 53 | Issam | HSDPA_MFTX-Perf | RP-130959 |
| 3217 | 813.3 | Test part: HSDPA Multiflow Data Transmission | 328d? | 2013-12-15 A | 2015-03-15 A | 100% | 2013-12-06 | 2014-12-05 | 262d? | finish no earlier than 2015-03-15 | R5 | 2624h | 2624h | HSDPA_MFTX-UEConTest | 32 | Qualcomm | Shubhang Vora (svora@qti.qualcomm.com) | Rel-11 | 62 | Ingbert | HSDPA_MFTX-UEConTest | RP-150126 |
| 3218 | 814 | **Four Branch MIMO transmission for HSDPA** | 590d? | 2011-09-19 A | 2013-12-06 A | 100% | 2011-09-19 | 2013-12-06 | 590d? |  | R1; R2; R3; R4 | 33968h | 33968h | 4Tx_HSDPA | 27 | Ericsson | johan.hultell@ericsson.com | Rel-11 | 53 | Patrick | 4Tx_HSDPA |  |
| 3219 | 814.1 | Core part: Four Branch MIMO transmission for HSDPA | 325d? | 2011-09-19 A | 2012-12-07 A | 100% | 2011-09-19 | 2012-12-07 | 325d? | finish no earlier than 2012-12-07 | R1; R2; R3; R4 | 10400h | 10400h | 4Tx_HSDPA-Core | 27 | Ericsson | johan.hultell@ericsson.com | Rel-11 | 53 | Patrick | 4Tx_HSDPA-Core | RP-121549 |
| 3220 | 814.2 | Perf. part: Four Branch MIMO transmission for HSDPA | 586d? | 2011-09-21 A | 2013-12-06 A | 100% | 2011-09-21 | 2013-12-06 | 586d? | finish no earlier than 2013-12-06 | R4 | 4688h | 4688h | 4Tx_HSDPA-Perf | 27 | Ericsson | johan.hultell@ericsson.com | Rel-11 | 53 | Issam | 4Tx_HSDPA-Perf | RP-131460 |
| 3221 | 815 | **MIMO with 64QAM for HSUPA** | 464d? | 2011-12-09 A | 2013-09-06 A | 100% | 2011-12-09 | 2013-09-06 | 464d? |  | R1; R2; R3; R4 | 26984h | 26984h | MIMO_64QAM_HSUPA | 28 | Nokia Siemens Networks | Karri Ranta-aho | Rel-11 | 54 | Patrick | MIMO_64QAM_HSUPA |  |
| 3222 | 815.1 | Core part: MIMO with 64QAM for HSUPA | 265d? | 2011-12-09 A | 2012-12-07 A | 100% | 2011-12-09 | 2012-12-07 | 265d? | finish no earlier than 2012-12-07 | R1; R2; R3; R4 | 8480h | 8480h | MIMO_64QAM_HSUPA-Core | 28 | Nokia Siemens Networks | Karri Ranta-aho | Rel-11 | 54 | Patrick | MIMO_64QAM_HSUPA-Core | RP-121554 |
| 3223 | 815.2 | Perf. part: MIMO with 64QAM for HSUPA | 457d? | 2011-12-13 A | 2013-09-06 A | 100% | 2011-12-13 | 2013-09-06 | 457d? | finish no earlier than 2013-09-06 | R4 | 3656h | 3656h | MIMO_64QAM_HSUPA-Perf | 28 | Nokia Siemens Networks | kamil.bechta@nsn.com | Rel-11 | 54 | Issam | MIMO_64QAM_HSUPA-Perf | RP-130960 |

Notes:
- 3198: Stage 2/3 / Impacted TSs and TRs: UTRA
- 3199: RP#58 completed / Impacted TSs and TRs: 25.101, 25.104, 25.133, 25.211, 25.212, 25.213, 25.214, 25.215, 25.306, 25.319, 25.321, 25.331, 25.423, 25.433
- 3200: RP#61 completed / Impacted TSs and TRs: 25.101, 25.104, 25.133, 25.141
- 3201: RP#58 completed / Impacted TSs and TRs: 25.101, 25.133, 25.306, 25.319, 25.321, 25.331, 25.423, 25.433
- 3202: RP#58 completed / Impacted TSs and TRs: 25.101, 25.133
- 3203: RP#64 completed / Impacted TSs and TRs: 34.121-1, 34.121-2, 34.123-1, 34.123-2, 34.123-3
- 3204: - / Impacted TSs and TRs: UTRA
- 3205: RP#54 completed. RP#62 existing TS 25.317 replaced by new TS 25.327 / Impacted TSs and TRs: 25.101, 25.104, 25.141, 25.317 replaced by new TS 25.327
- 3206: RP#56 completed. RP#62 existing TS 25.317 replaced by new TS 25.327 / Impacted TSs and TRs: 25.101, 25.104, 25.141, 25.317 replaced by new TS 25.327
- 3207: - / Impacted TSs and TRs: UTRA
- 3208: RP#56 completed / Impacted TSs and TRs: 25.101, 25.104, 25.133, 25.331, 25.423, 25.433
- 3209: RP#59 completed / Impacted TSs and TRs: 25.101, 25.104, 25.133, 25.141
- 3210: - / Impacted TSs and TRs: UTRA
- 3211: RP#58 completed / Impacted TSs and TRs: 25.101, 25.104, 25.133, 25.211, 25.212, 25.213, 25.214, 25.306, 25.308, 25.319, 25.321, 25.331, 25.423, 25.433
- 3212: RP#62 completed / Impacted TSs and TRs: 25.101, 25.104, 25.133, 25.141
- 3213: ; Stat Rep: RP-141164->RP-141770 1st Apr 15: Compl:92%->100% 1st Apr 15: Stat Rep: RP-141770->RP-150132 / Impacted TSs and TRs: 34.108, 34.121-1, 34.121-2, 34.123-1, 34.123-2, 34.123-3, 36.508, 36.523-1, 36.523-2, 36.523-3
- 3214: Stage 2,3 / Impacted TSs and TRs: UTRA
- 3215: RP#58 completed / Impacted TSs and TRs: 25.101, 25.104, 25.133, 25.211, 25.212, 25.214, 25.306, 25.308, 25.321, 25.331, 25.423, 25.433
- 3216: RP#61 completed / Impacted TSs and TRs: 25.101, 25.104, 25.133, 25.141
- 3217: ; Stat Rep: RP-141136->RP-141961 1st Apr 15: Compl:90%->100% 1st Apr 15: Stat Rep: RP-141961->RP-150126 / Impacted TSs and TRs: 34.108, 34.121-1, 34.121-2, 34.123-1, 34.123-2, 34.123-3
- 3218: Stage 3 / Impacted TSs and TRs: UTRA
- 3219: RP#58 completed / Impacted TSs and TRs: 25.101, 25.104, 25.133, 25.211, 25.212, 25.213, 25.214, 25.215, 25.308, 25.331, 25.423, 25.433, 26.306
- 3220: RP#62 completed / Impacted TSs and TRs: 25.101, 25.104, 25.133, 25.141
- 3221: Specified UE and BS performance requirements for uplink MIMO together with QPSK and 16QAM modulations for E-DCH/HSUPA. 64QAM is for future releases / Impacted TSs and TRs: UTRA
- 3222: RP#58 completed / Impacted TSs and TRs: 25.101, 25.104, 25.133, 25.211, 25.212, 25.213, 25.214, 25.215, 25.308, 25.321, 25.331, 25.423, 25.433, 26.306
- 3223: RP#61 completed / Impacted TSs and TRs: 25.101, 25.104, 25.133, 25.141

| ID | WBS | Task | Type | Duration | Start | Finish | Complete | Baseline start | Baseline finish | Baseline duration | Constraint | Resources | Work | Actual work | Acronym | PCG approved | Impacted TSs and TRs | WI rapporteur name | Release | TSG approved | MCC resp | Acronym_3GU_Export | Status Report | Special Focus Doc | PCG stopped | TSG stopped |
| --- | --- | --- | --- | --- | --- | --- | --- | --- | --- | --- | --- | --- | --- | --- | --- | --- | --- | --- | --- | --- | --- | --- | --- | --- | --- | --- |
| 3224 | 816 | **HSDPA Dual-Band Multi-Carrier combinations** |  | 198d? | 2011-12-09 A | 2012-09-07 A | 100% | 2011-12-09 | 2012-09-07 | 198d? |  | R4; R2 | 7920h | 7920h | HSDPA_DB_MC | 28 | UTRA | Ericsson | Rel-11 | 54 | Issam | HSDPA_DB_MC |  |  |  |  |
| 3225 | 816.1 | Core part: HSDPA Dual-Band Multi-Carrier combinations |  | 198d? | 2011-12-09 A | 2012-09-07 A | 100% | 2011-12-09 | 2012-09-07 | 198d? | finish no earlier than 2012-09-07 | R4; R2 | 3168h | 3168h | HSDPA_DB_MC-Core | 28 | 25.101, 25.104, 25.141, 25.317 replaced by new TS 25.327 | Ericsson | Rel-11 | 54 | Issam | HSDPA_DB_MC-Core | RP-120987 |  |  |  |
| 3226 | 816.2 | Perf. part: HSDPA Dual-Band Multi-Carrier combinations |  | 198d? | 2011-12-09 A | 2012-09-07 A | 100% | 2011-12-09 | 2012-09-07 | 198d? | finish no earlier than 2012-09-07 | R4 | 1584h | 1584h | HSDPA_DB_MC-Perf | 28 | 25.101, 25.104, 25.141 | Ericsson | Rel-11 | 54 | Issam | HSDPA_DB_MC-Perf | RP-120988 |  |  |  |
| 3227 | 817 | Split TTCN Test Models for IMS testing in TS 34.229-3 |  | 201d? | 2013-12-09 A | 2014-09-12 A | 100% | 2013-12-09 | 2014-09-12 | 201d? | finish no earlier than 2014-09-12 | R5 | 1608h | 1608h | IMS-CCR_Test2 | 32 | 34.229-3, New TS 34.229-4 | Spirent | Rel-11 | 62 | Ingbert | IMS-CCR_Test2 | RP-141155 |  |  |  |
| 3228 | 818 | (Small) Technical Enhancements and Improvements for Rel-11 |  | 595d? | 2010-06-18 A | 2012-09-20 A | 100% | 2010-06-18 | 2012-09-20 | 595d? | finish no earlier than 2012-09-20 | SP; CP; RP; GP | 19040h | 19040h | TEI11 | 25 |  |  | Rel-11 | 48 | All | TEI11 |  |  |  |  |
| 3229 | 819 | Test - (Small) Technical Enhancements and Improvements for Rel-11 |  | 397d? | 2012-06-15 A | 2013-12-11 A | 100% | 2012-06-15 | 2013-12-11 | 397d? | finish no earlier than 2013-12-11 | R5; G3new | 6352h | 6352h | TEI11_Test | 29 |  |  | Rel-11 | 56 | Ingbert | TEI11_Test |  |  |  |  |
| 3230 | 820 | (IETF) (Small) Technical Enhancements and Improvements for Rel-11 (RFC 7077) |  | 333d? | 2012-09-07 A | 2013-12-06 A | 100% | 2012-09-07 | 2013-12-06 | 333d? | finish no earlier than 2013-11-28 | C4-IETF | 2632.95h | 2632.95h | TEI11_IETF | 29 | RFC 7077 (was draft-ietf-netext-update-notifications) | Lionel Morand | Rel-11 | 57 | Kimmo | TEI11_IETF |  |  |  |  |
| 3231 | 821 | Release 11 Studies | milestone | 0d? | 2009-12-10 A | 2009-12-10 A | 100% | 2009-12-10 | 2012-09-14 | 727d? | finish no earlier than 2012-12-07 | SP; CP; GP; RP |  |  |  |  |  |  | Rel-11 |  | All |  |  |  |  |  |
| 3232 | 822 | Study on IMS based Peer-to-Peer Content Distribution Services |  | 195d? | 2009-09-11 A | 2010-06-10 A | 100% | 2009-05-12 | 2010-06-10 | 284d? | finish no earlier than 2010-06-10 | S1; S2 | 3120h | 3120h | FS_IMS_P2P | 23 | 22.906 | China Mobile | Rel-11 | 45 | Alain | FS_IMS_P2P |  |  |  |  |
| 3233 | 823 | Study on Non Voice Emergency Services |  | 467d? | 2009-12-10 A | 2011-09-21 A | 100% | 2009-12-10 | 2011-09-21 | 467d? | finish no earlier than 2011-09-21 | S1 | 3720h | 3720h | FS_NOVES | 24 | 22.871 | Qualcomm | Rel-11 | 46 | Alain | FS_NOVES |  |  |  |  |
| 3234 | 824 | Study on Support for 3GPP Voice Interworking with Enterprise IP-PBX |  | 130d? | 2010-09-23 A | 2011-03-23 A | 100% | 2010-09-23 | 2011-03-23 | 130d? | finish no earlier than 2011-02-21 | S1; S2 | 2080h | 2080h | FS_VINE | 25 | 22.809 | Tatara Systems | Rel-11 | 48 | Alain | FS_VINE |  |  |  |  |
| 3235 | 825 | Study on IMS Network-Independent Public User Identities |  | 185d? | 2010-09-23 A | 2011-06-08 A | 100% | 2010-09-23 | 2011-06-08 | 185d? | finish no earlier than 2011-06-08 | S1 | 1480h | 1480h | FS_INIPUI | 25 | 22.894 | Vodafone | Rel-11 | 49 | Alain | FS_INIPUI |  |  |  |  |
| 3236 | 826 | Study on IMS Evolution |  | 849d? | 2008-09-18 A | 2011-12-14 A | 100% | 2008-09-18 | 2011-12-14 | 849d? | finish no earlier than 2011-12-07 | S2 | 6784h | 6784h | FS_eIMS | 21 | 23.812 | China Mobile | Rel-11 | 41 | Maurice | FS_eIMS |  |  |  |  |
| 3237 | 827 | Study on Policy solutions and enhancements |  | 521d? | 2009-06-12 A | 2011-06-10 A | 100% | 2000-01-03 | 2002-01-03 | 525d? | finish no earlier than 2011-06-10 | S2; S1 | 8336h | 8336h | FS_PP | 23 | 23.813 | AT&T | Rel-11 | 44 | Maurice | FS_PP |  |  |  |  |
| 3238 | 828 | Study on IPv6 Migration |  | 525d? | 2009-06-04 A | 2011-06-08 A | 100% | 2009-06-04 | 2011-06-08 | 525d? | finish no earlier than 2011-06-08 | S2 | 4200h | 4200h | FS_IP6M | 23 | 23.975 | China Mobile | Rel-11 | 44 | Maurice | FS_IP6M |  |  |  |  |
| 3239 | 829 | Study on Single Radio Voice Call Continuity from UTRAN/GERAN to E-UTRAN/HSPA |  | 528d? | 2009-12-10 A | 2011-12-14 A | 100% | 2009-12-10 | 2011-12-14 | 528d? | finish no earlier than 2011-09-21 | S2 | 4208h | 4208h | FS_rSRVCC | 24 | 23.885 | Orange | Rel-11 | 46 | Maurice | FS_rSRVCC |  |  |  |  |
| 3240 | 830 | Study on Roaming Architecture for Voice over IMS with Local Breakout |  | 194d? | 2011-03-23 A | 2011-12-14 A | 100% | 2011-03-23 | 2011-12-14 | 194d? | finish no earlier than 2011-12-07 | S2 | 1535.79h | 1535.79h | FS_RAVEL | 26 | 23.850 | Deutsche Telekom | Rel-11 | 51 | Maurice | FS_RAVEL |  |  |  |  |
| 3241 | 831 | Study on UTRAN key management enhancements |  | 1102d? | 2007-12-20 A | 2012-03-07 A | 100% | 2007-12-20 | 2012-03-07 | 1102d? | finish no earlier than 2012-02-20 | S3 | 8808.12h | 8808.12h | FS_UKM | 21 | 33.859 | Ericsson | Rel-11 | 38 | Mirko | FS_UKM |  |  |  |  |
| 3242 | 832 | Study on Single Sign On (SSO) Application Security for IMS - based on SIP Digest |  | 532d? | 2010-06-10 A | 2012-06-20 A | 100% | 2010-06-10 | 2012-06-20 | 532d? | finish no earlier than 2012-06-20 | S3 | 4247.09h | 4247.09h | FS_SSO_APS | 25 | 33.914 converted to 33.804 | Nokia | Rel-11 | 48 | Mirko | FS_SSO_APS |  |  |  |  |
| 3243 | 833 | Study on Mobile 3D Video Coding |  | 273d? | 2011-06-08 A | 2012-06-20 A | 100% | 2011-06-08 | 2012-06-20 | 273d? | finish no earlier than 2012-06-20 | S4 | 2168h | 2168h | FS_M3DVC | 27 | 26.905 | Orange | Rel-11 | 52 | Paolo | FS_M3DVC |  |  |  |  |
| 3244 | 834 | Study on Management of Converged Networks |  | 591d? | 2010-06-10 A | 2012-09-12 A | 100% | 2010-06-10 | 2012-09-12 | 591d? | finish no earlier than 2012-09-12 | S5 | 4720h | 4720h | FS_ManCon | 25 | 32.833 | Nokia Siemens Networks | Rel-11 | 48 | Mirko | FS_ManCon |  |  |  |  |
| 3245 | 835 | Study on User Data Convergence (UDC) information model handling and provisioning: Example Use Cases |  | 321d? | 2010-09-23 A | 2011-12-14 A | 100% | 2010-09-23 | 2011-12-14 | 321d? | finish no earlier than 2011-12-14 | S5 | 2560h | 2560h | FS_UDC_AppUseCase | 25 | 32.901 | Alcatel-Lucent | Rel-11 | 49 | Mirko | FS_UDC_AppUseCase |  |  |  |  |
| 3246 | 836 | Study on OAM aspects of inter-RAT Energy Saving |  | 194d? | 2011-03-23 A | 2011-12-14 A | 100% | 2011-03-23 | 2011-12-14 | 194d? | start no earlier than 2011-03-23 | S5 | 1528h | 1528h | FS_OAM_ES_iRAT | 26 | 32.834 | Nokia Siemens Networks | Rel-11 | 51 | Mirko | FS_OAM_ES_iRAT |  | SON |  |  |
| 3247 | 837 | Study on impacts on UE-Core Network signalling from Energy Saving |  | 261d? | 2010-06-04 A | 2011-06-03 A | 100% | 2010-06-04 | 2011-06-03 | 261d? | finish no earlier than 2011-06-03 | C1 | 2088h | 2088h | FS_UE-CN_ES | 25 | 24.826 | NEC | Rel-11 | 48 | Frederic | FS_UE-CN_ES |  |  |  |  |
| 3248 | 838 | Study on EPC Nodes Restoration |  | 588d? | 2010-09-17 A | 2012-12-07 A | 100% | 2010-09-17 | 2012-12-07 | 588d? | finish no earlier than 2012-12-07 | C4 | 4664h | 4664h | FS_EPC_NR | 25 | 23.857 | ZTE | Rel-11 | 49 | Kimmo | FS_EPC_NR |  |  |  |  |
| 3249 | 839 | Study on Signal Precoding enhancements for EGPRS2 DL |  | 394d? | 2010-09-03 A | 2012-03-02 A | 100% | 2010-09-03 | 2012-03-02 | 394d? | finish no earlier than 2012-03-02 | G1; G2 | 6304h | 6304h | FS_SPEED | 25 | GERAN 45.860 | Ericsson | Rel-11 | 46 | Paolo | FS_SPEED |  |  |  |  |
| 3250 | 840 | Study on Coordinated Multi-Point operation for LTE |  | 203d? | 2010-12-10 A | 2011-09-16 A | 100% | 2010-12-10 | 2011-09-16 | 203d? | finish no earlier than 2011-09-16 | R1; R2; R3 | 4872h | 4872h | FS_CoMP_LTE | 24 | LTE 36.819 | Samsung | Rel-11 | 47 | Patrick | FS_CoMP_LTE | RP-111343 |  |  |  |
| 3251 | 841 | Study on Signalling and procedure for interference avoidance for in-device coexistence |  | 338d? | 2010-06-04 A | 2011-09-16 A | 100% | 2010-06-04 | 2011-09-16 | 338d? | finish no earlier than 2011-09-16 | R2; R4 | 5408h | 5408h | FS_SPIA_IDC | 25 | LTE 36.816 | China Mobile | Rel-11 | 48 | Yong-Jun | FS_SPIA_IDC | RP-111057 |  |  |  |
| 3252 | 842 | Study on HetNet mobility enhancements for LTE |  | 391d? | 2011-03-18 A | 2012-09-07 A | 100% | 2011-03-18 | 2012-09-07 | 391d? | finish no earlier than 2012-09-07 | R2; R1; R3; R4 | 12512h | 12512h | FS_HetNet_eMOB_LTE | 26 | LTE 36.839 | Alcatel-Lucent | Rel-11 | 51 | Yong-Jun | FS_HetNet_eMOB_LTE | RP-121085 |  |  |  |
| 3253 | 843 | Study on further Downlink MIMO enhancements for LTE-Advanced |  | 193d? | 2011-03-18 A | 2011-12-09 A | 100% | 2011-03-18 | 2011-12-09 | 193d? | finish no earlier than 2011-12-09 | R1 | 1544h | 1544h | FS_LTE_eDL_MIMO_enh | 26 | LTE 36.871 | Alcatel-Lucent | Rel-11 | 51 | Patrick | FS_LTE_eDL_MIMO_enh | RP-111550 |  |  |  |
| 3254 | 844 | Study on Further Enhancements to LTE TDD for DL-UL Interference Management and Traffic Adaptation |  | 328d? | 2011-03-22 A | 2012-06-15 A | 100% | 2011-03-22 | 2012-06-15 | 328d? | finish no earlier than 2012-06-15 | R1; R4 | 5248h | 5248h | FS_LTE_TDD_eIMTA | 26 | LTE 36.828 | CATT | Rel-11 | 51 | Patrick | FS_LTE_TDD_eIMTA | RP-120587 | Small cell |  |  |
| 3255 | 845 | Study on LTE Coverage Enhancements |  | 197d? | 2011-09-19 A | 2012-06-15 A | 100% | 2011-09-19 | 2012-06-15 | 197d? | finish no earlier than 2012-06-15 | R1; R2 | 3152h | 3152h | FS_Cov_Enh_LTE | 27 | LTE 36.824 | China Telecom | Rel-11 | 53 | Patrick | FS_Cov_Enh_LTE | RP-120589 |  |  |  |
| 3256 | 846 | Study on Enhanced performance requirement for LTE UE |  | 121d? | 2011-09-19 A | 2012-03-02 A | 100% | 2011-09-19 | 2012-03-02 | 121d? | finish no earlier than 2012-03-02 | R4; R1 | 1936h | 1936h | FS_enh_perf_UE_LTE | 27 | LTE 36.829 | NTT DoCoMo | Rel-11 | 53 | Issam | FS_enh_perf_UE_LTE | RP-120167 |  |  |  |
| 3257 | 847 | Study on Measurements of radio performances for LTE terminals - Total Radiated Power (TRP) and Total Radiated Sensitivity (TRS) test methodology |  | 136d? | 2012-03-05 A | 2012-09-07 A | 100% | 2012-03-05 | 2012-09-07 | 136d? | finish no earlier than 2012-09-07 | R4 | 1088h | 1088h | FS_LTE_OTA | 28 | LTE 25.914, New TR 37.902 | CATR | Rel-11 | 55 | Issam | FS_LTE_OTA | RP-121083 |  |  |  |
| 3258 | 848 | Study on Measurement of Radiated Performance for MIMO and multi-antenna reception for HSPA and LTE terminals |  | 712.8d? | 2009-03-06 A | 2012-03-02 A | 100% | 2009-03-06 | 2012-03-02 | 712.8d? | finish no earlier than 2012-03-02 | R4 | 5702.4h | 5702.4h | FS_HSPA_LTE_measRP_MIMO_multi-antenna | 22 | UTRA, LTE 37.976 | Vodafone | Rel-11 | 43 | Issam | FS_HSPA_LTE_measRP_MIMO_multi-antenna | RP-120154 |  |  |  |
| 3259 | 849 | Study on Extending 850 MHz |  | 860d? | 2009-05-30 A | 2012-09-07 A | 100% | 2009-05-30 | 2012-09-07 | 860d? | finish no earlier than 2012-09-07 | R4 | 6880h | 6880h | FS_e850 | 23 | UTRA, LTE 37.806 | Ericsson | Rel-11 | 44 | Issam | FS_e850 | RP-121080 |  |  |  |
| 3260 | 850 | Study on RAN improvements for Machine-Type Communications |  | 523d? | 2009-09-18 A | 2011-09-16 A | 100% | 2009-09-18 | 2011-09-16 | 523d? | finish no earlier than 2011-09-16 | R2; R1; R3; R4 | 16736h | 16736h | FS_NIMTC_RAN | 23 | UTRA, LTE 37.868 | Huawei | Rel-11 | 45 | Yong-Jun | FS_NIMTC_RAN | RP-111052 | MTC, M2M |  |  |
| 3261 | 851 | Study on UE Application Layer Data Throughput Performance |  | 264d? | 2010-09-16 A | 2011-09-16 A | 100% | 2010-09-16 | 2011-09-16 | 264d? | finish no earlier than 2011-09-16 | R5; R4 | 4224h | 4224h | FS_UE_App_Data_Perf | 26 | UTRA, LTE 37.901 | Spirent | Rel-11 | 50 | Ingbert | FS_UE_App_Data_Perf | RP-111543 |  |  |  |
| 3262 | 852 | Study on further enhancements for HNB and HeNB |  | 330d? | 2011-03-18 A | 2012-06-15 A | 100% | 2011-03-18 | 2012-06-15 | 330d? | finish no earlier than 2012-06-15 | R3; R2 | 5280h | 5280h | FS_EHNB_enh | 26 | UTRA, LTE 37.803 | Alcatel-Lucent | Rel-11 | 51 | Juha | FS_EHNB_enh | RP-120579 | HNB |  |  |
| 3263 | 853 | Study on Interference analysis between 800~900 MHz bands |  | 326d? | 2011-03-23 A | 2012-06-15 A | 100% | 2011-03-23 | 2012-06-15 | 326d? | finish no earlier than 2012-06-15 | R4 | 2608h | 2608h | FS_B800_B900_Interf_LTE | 26 | UTRA, LTE impacts TR 37.804 | LG Uplus | Rel-11 | 51 | Issam | FS_B800_B900_Interf_LTE | RP-120586 |  |  |  |
| 3264 | 854 | Study on UMTS/LTE in 900 MHz band (Japan, Korea) |  | 272d? | 2011-06-07 A | 2012-06-15 A | 100% | 2011-06-07 | 2012-06-15 | 272d? | finish no earlier than 2012-06-15 | R4 | 2176h | 2176h | FS_UTRA_LTE_900MHz | 27 | UTRA, LTE 37.804 | NTT DoCoMo | Rel-11 | 52 | Issam | FS_UTRA_LTE_900MHz | RP-120580 |  |  |  |
| 3265 | 855 | Study on Uplink MIMO |  | 203d? | 2010-12-10 A | 2011-09-16 A | 100% | 2010-12-10 | 2011-09-16 | 203d? | finish no earlier than 2011-09-16 | R1 | 1624h | 1624h | FS_UTRA_UL_MIMO | 26 | UTRA 25.871 | Qualcomm | Rel-11 | 50 | Patrick | FS_UTRA_UL_MIMO | RP-111048 |  |  |  |
| 3266 | 856 | Study on HSDPA Multipoint Transmission |  | 203d? | 2010-12-10 A | 2011-09-16 A | 100% | 2010-12-10 | 2011-09-16 | 203d? | finish no earlier than 2011-09-16 | R1; R2; R3 | 4872h | 4872h | FS_HSDPA_MP_TX | 26 | UTRA 25.872 | Nokia Siemens Networks | Rel-11 | 50 | Patrick | FS_HSDPA_MP_TX | RP-111049 |  |  |  |
| 3267 | 857 | Study on UE Over The Air (OTA) test method with Head and Hand Phantoms |  | 258d? | 2011-09-19 A | 2012-09-07 A | 100% | 2011-09-19 | 2012-09-07 | 258d? | finish no earlier than 2012-09-07 | R4; R5 | 4128h | 4128h | FS_OTA_phantoms_UTRA | 27 | UTRA 25.914 | Nokia | Rel-11 | 53 | Issam | FS_OTA_phantoms_UTRA | RP-121078 |  |  |  |
| 3268 | 858 | Study on HSPA feedback and signalling efficiency enhancements for LCR TDD |  | 199d? | 2011-12-07 A | 2012-09-07 A | 100% | 2011-12-07 | 2012-09-07 | 199d? | finish no earlier than 2012-09-07 | R1 | 1584h | 1584h | FS_LCRTDD_HSPAenh | 28 | UTRA 25.874 | TD Tech | Rel-11 | 54 | Patrick | FS_LCRTDD_HSPAenh | RP-121079 |  |  |  |
| 3269 | 859 | Deleted - Study on Enhanced Uplink Transmission for LTE |  | 328d? | 2011-03-22 A | 2012-06-15 A | 100% | 2011-03-22 | 2012-06-15 | 328d? | finish no earlier than 2012-06-15 | R1 | 2624h | 2624h | FS_eUL_TX_LTE | 26 | LTE 36.8xy | Huawei | Rel-11 | 51 | Patrick | FS_eUL_TX_LTE | RP-120585 |  | PCG-29 | RP-56 |
| 3270 | 860 | Release 10 Features |  | 728d? | 2008-12-11 A | 2011-09-21 A | 100% | 2008-12-11 | 2011-09-21 | 728d? | finish no earlier than 2011-09-21 | CP; GP; RP; SP | 23296h | 23296h |  |  |  |  | Rel-10 |  |  |  |  |  |  |  |

Notes:
- 3224: Stage 3 / WI rapporteur e-mail: muhammad.kazmi@ericsson.com
- 3225: RP#57 completed. RP#62 existing TS 25.317 replaced by new TS 25.327 / WI rapporteur e-mail: muhammad.kazmi@ericsson.com
- 3226: RP#57 completed / WI rapporteur e-mail: muhammad.kazmi@ericsson.com
- 3227: SP#65 completed. TS 34.229-4 for Approval. Split out of old TS 34.229-3 a new TS 34.229-4 / WI rapporteur e-mail: richard.catmur@spirent.com
- 3228: SP#50 EU-Alert is introduced under Public Warning System in parallel with the already existing ETWS and CMAS. SA1 22.268 CR#9r1 adds EU-ALERT specific requirements & CT1 23.041 CRs#
- 3229: -
- 3230: CP#62 completed / WI rapporteur e-mail: Lionel Morand
- 3231: -
- 3232: SP#48 completed. 3/3/15: start date corrected (was 05/09) / WI rapporteur e-mail: Li Gang (ligangyf@chinamobile.com)
- 3233: SP#53 completed. Spin-off Feature UID_500030 Non Voice Emergency Services (NOVES) / WI rapporteur e-mail: dwilliams@qualcomm.com
- 3234: SP#51 completed. Support Interworking between 3GPP networks and Enterprise environments to provide enterprise voice services via 3GPP mobile devices / WI rapporteur e-mail: Phillip Brown (pbrown@tatarasystems.com)
- 3235: SP#52 completed / WI rapporteur e-mail: mona.mustapha@vodafone.com
- 3236: SP#54 completed / WI rapporteur e-mail: Li Gang (ligangyf@chinamobile.com), Yu Qing (yuqing@chinamobile.com)
- 3237: SP#52 completed. 3/3/15: start and finish dates corrected (was start on Jan-00, ends on Jan-02) / WI rapporteur e-mail: farooq.bari@att.com
- 3238: SP#52 completed / WI rapporteur e-mail: Li Lianyuan (lilianyuan@chinamobile.com), Liu Hong (liuhongyfw@chinamobile.com)
- 3239: SP#54 completed. Study on "reverse direction" from UTRAN/GERAN to E-UTRAN/HSPA (Rel-8 SRVCC was in the other direction E-UTRAN/HSPA to GERAN/UTRAN) / WI rapporteur e-mail: delphin.barankanira@orange-ftgroup.com
- 3240: SP#54 completed. Linked to Rel-11 OSCAR (Optimized Service Charging and Allocation of ResourcES in CP-150IMS whilst Roaming) UID_490032. Related to LBO/home routing decision / WI rapporteur e-mail: michele.zarri@telekom.com
- 3241: SP#55 completed / WI rapporteur e-mail: karl.norrman@ericsson.com
- 3242: SP#56 completed. SP#55 TR 33.914v200 approved (converted 33.804). Study reuse of non-UICC credentials (in particular SIP Digest) to provide security for access to applications. Provide reference material for IMS based non-UICC based SSO to applications / WI rapporteur e-mail: Silke.Holtmanns@nokia.com
- 3243: SP#56 completed. Extends Rel-10 work on 3D video formats UID_480044 Improved Video Coding Support for PSS and MBMS / WI rapporteur e-mail: gilles.teniou@orange-ftgroup.com
- 3244: SP#57 completed. TR 32.833v200 for Approval / WI rapporteur e-mail: Jörg Schmidt (J.Schmidt@nsn.com)
- 3245: SP#54 completed / WI rapporteur e-mail: Nick Mazzarella (njmazzarella@alcatel-lucent.com)
- 3246: SP#54 completed. Triggered by Rel-10 UID_430044 TR 32.826 Study on Energy Savings Management (FS_OAM_ESM) and UID_470037 OAM aspects of Energy Saving in Radio Networks (OAM-ES) / WI rapporteur e-mail: clemens.suerbaum@nsn.com
- 3247: CP#52 completed. Linked to SA5 UID_430044 (FS_OAM-ESM) & UID_470037 (OAM-ES), RAN3 UID_470015 (FS_Energy_LTE), RAN1 UID_460016 (FS_Energy_UMTS) / WI rapporteur e-mail: gottfried.punz@nw.neclab.eu
- 3248: CP#58 completed. Continue work in Rel-11 especially to cover handling of Idle mode Signalling Reduction (ISR). Linked to SA2 UID_490036 Study on Core Network Overload solutions / WI rapporteur e-mail: lu.fei1@zte.com.cn
- 3249: GP#53 completed (03/12). GP#46 approved WID. / WI rapporteur e-mail: marten.sundberg@ericsson.com
- 3250: RP#53 completed / WI rapporteur e-mail: bruno.clerckx@samsung.com
- 3251: RP#53 completed. Studied coexistence scenario of LTE and Industrial, Scientific and Medical (ISM) Radio within the same device working in adjacent frequencies / WI rapporteur e-mail: Zhenping Hu (huzhenping@chinamobile.com)
- 3252: RP#57 completed. TR 36.839 v100 for Information & Approval / WI rapporteur e-mail: sudeep.palat@alcatel-lucent.com
- 3253: RP#54 completed / WI rapporteur e-mail: federico.boccardi@alcatel-lucent.com
- 3254: RP#56 completed. TR 36.828 for Information and Approval / WI rapporteur e-mail: Zukang Shen (shenzukang@catt.cn)
- 3255: RP#56 completed. TR 36.824 v200 for Approval / WI rapporteur e-mail: Peng Chen (chenpeng@ctbri.com.cn)
- 3256: RP#55 completed. TR 36.829 v100 for Information + Approval / WI rapporteur e-mail: Yuta Sagae
- 3257: RP#57 completed / WI rapporteur e-mail: Xudong An (anxudong@emcite.com)
- 3258: RP#55 completed. TR 37.976 v200 for Approval / WI rapporteur e-mail: Tim.frost@vodafone.com
- 3259: RP#57 completed. TR 37.806 v200 for Approval / WI rapporteur e-mail: christian.bergljung@ericsson.com
- 3260: RP#53 completed. TR 37.868v100 for Approval (No WID change: RAN overload only). Triggered by TR 22.868 Study on Facilitating Machine to Machine Communication in GSM and UMTS (M2M) UID_7027 and Rel-10 NIMTC UID_410030 / WI rapporteur e-mail: Jeff Gao (gaoyq@huawei.com)
- 3261: RP#54 completed / WI rapporteur e-mail: ron.borsato@spirent.com
- 3262: RP#56 completed. TR 37.803 v200 for Approval / WI rapporteur e-mail: Martin.Warner@alcatel-lucent.com
- 3263: RP#56 completed. Impacts TR 37.804 Study on UMTS/LTE in 900 MHz band (Japan, Korea) UID_520018 / WI rapporteur e-mail: Koo Yeon Sang (yskoo@lguplus.co.kr)
- 3264: RP#56 completed. Updated WID RP-111751=>RP-120617. TR 37.804 v100 for Information and Approval. Linked to Study on Interference analysis between 800~900 MHz bands UID_510038 / WI rapporteur e-mail: Masahiro Fujii (fujiima@nttdocomo.co.jp)
- 3265: RP#53 completed (1-step Approval) / WI rapporteur e-mail: Sharad Sambhwani
- 3266: RP#53 completed / WI rapporteur e-mail: karri.ranta-aho@nsn.com
- 3267: RP#57 completed / WI rapporteur e-mail: petri.j.vasenkari@nokia.com
- 3268: RP#57 completed. TR 25.874 v100 for Information & Approval / WI rapporteur e-mail: limei.wei@td-tech.com
- 3269: RP#56 stopped. RP-120856 discussion: most content moved to Rel-11 Coordinated Multi-Point Operation for LTE Uplink (COMP_LTE_UL) and RAN1 has no time to look at it / WI rapporteur e-mail: Yongxing Zhou
- 3270: -

| ID | WBS | Task | Duration | Start | Finish | Complete | Baseline start | Baseline finish | Baseline duration | Constraint | Resources | Work | Actual work | Acronym | PCG approved | WI rapporteur name | WI rapporteur e-mail | Release | TSG approved | MCC resp | Special Focus Doc | Acronym_3GU_Export | PCG stopped | TSG stopped | Status Report |
| --- | --- | --- | --- | --- | --- | --- | --- | --- | --- | --- | --- | --- | --- | --- | --- | --- | --- | --- | --- | --- | --- | --- | --- | --- | --- |
| 3271 | 861 | **Enhancements for Multimedia Priority Service** | 1311d? | 2006-03-13 A | 2011-03-18 A | 100% | 2006-03-13 | 2011-03-18 | 1311d? |  | S1; S2; C4; C3; C1 | 72120h | 72120h | eMPS | 21 | Telcordia | jgarraha@telcordia.com | Rel-10 | 39 | Alain | Public Safety (I-A) | eMPS |  |  |  |
| 3272 | 861.1 | Stage 1 on enhancements for Multimedia Priority Service | 584d? | 2006-03-13 A | 2008-06-05 A | 100% | 2006-03-13 | 2008-06-05 | 584d? | start no earlier than 2006-03-12 | S1 | 4672h | 4672h | ePRIOR-St1 | 21 | Telcordia | jgarraha@telcordia.com | Rel-10 | 39 | Alain | Public Safety (I-A) | ePRIOR |  |  |  |
| 3273 | 861.2 | **Stage 2 on enhancements for Multimedia Priority Service** | 206d? | 2009-12-10 A | 2010-09-23 A | 100% | 2009-12-10 | 2010-09-23 | 206d? |  | S2 | 6592h | 6592h | ePRIOR-St2 | 24 | Telcordia, NTT DoCoMo | Vijay Varma, Katsutoshi Nishida | Rel-10 | 46 | Maurice | Public Safety (I-A) |  |  |  |  |
| 3274 | 861.2.1 | Stage 2 on eMPS for CSFB | 206d? | 2009-12-10 A | 2010-09-23 A | 100% | 2009-12-10 | 2010-09-23 | 206d? | finish no earlier than 2010-09-24 | S2 | 1648h | 1648h | ePRIOR-St2 | 24 | Telcordia, NTT DoCoMo | Vijay Varma, Katsutoshi Nishida | Rel-10 | 46 | Maurice | Public Safety (I-A) |  |  |  |  |
| 3275 | 861.2.2 | Stage 2 on eMPS for EPS Bearer Service | 206d? | 2009-12-10 A | 2010-09-23 A | 100% | 2009-12-10 | 2010-09-23 | 206d? | finish no earlier than 2010-12-09 | S2 | 1648h | 1648h | ePRIOR-St2 | 24 | Telcordia, NTT DoCoMo | Vijay Varma, Katsutoshi Nishida | Rel-10 | 46 | Maurice | Public Safety (I-A) |  |  |  |  |
| 3276 | 861.2.3 | Stage 2 on eMPS for IMS Aspects | 206d? | 2009-12-10 A | 2010-09-23 A | 100% | 2009-12-10 | 2010-09-23 | 206d? | finish no earlier than 2010-12-09 | S2 | 1648h | 1648h | ePRIOR-St2 | 24 | Telcordia, NTT DoCoMo | Vijay Varma, Katsutoshi Nishida | Rel-10 | 46 | Maurice | Public Safety (I-A) |  |  |  |  |
| 3277 | 861.3 | Deleted - TR 23.854 on Stage 2 on enhancements for Multimedia Priority Service | 266d? | 2009-12-10 A | 2010-12-16 A | 100% | 2009-12-10 | 2010-12-16 | 266d? | finish no earlier than 2011-03-17 | S2 | 2128h | 2128h |  | 24 | Telcordia, NTT DoCoMo | Vijay Varma, Katsutoshi Nishida | Rel-10 | 46 | Maurice | Public Safety (I-A) |  | PCG-27 | SP-50 |  |
| 3278 | 861.4 | **Stage 3 on enhancements for Multimedia Priority Service** | 131d? | 2010-09-17 A | 2011-03-18 A | 100% | 2010-09-17 | 2011-03-18 | 131d? |  | C4; C3; C1 | 6288h | 6288h | eMPS-CN | 25 | Ericsson | Philip.hodges@ericsson.com | Rel-10 | 49 | Kimmo | Public Safety (I-A) | eMPS-CN |  |  |  |
| 3279 | 861.4.1 | CT4 part on Stage 3 on enhancements for Multimedia Priority Service | 131d? | 2010-09-17 A | 2011-03-18 A | 100% | 2010-09-17 | 2011-03-18 | 131d? | start no earlier than 2010-09-17 | C4 | 1048h | 1048h | eMPS-CN | 25 | Ericsson | Philip.hodges@ericsson.com | Rel-10 | 49 | Kimmo | Public Safety (I-A) |  |  |  |  |
| 3280 | 861.4.2 | CT3 part on Stage 3 on enhancements for Multimedia Priority Service | 131d? | 2010-09-17 A | 2011-03-18 A | 100% | 2010-09-17 | 2011-03-18 | 131d? | start no earlier than 2010-09-17 | C3 | 1048h | 1048h | eMPS-CN | 25 | Ericsson | Philip.hodges@ericsson.com | Rel-10 | 49 | Adrian | Public Safety (I-A) |  |  |  |  |
| 3281 | 861.4.3 | CT1 part on Stage 3 on enhancements for Multimedia Priority Service | 131d? | 2010-09-17 A | 2011-03-18 A | 100% | 2010-09-17 | 2011-03-18 | 131d? | start no earlier than 2010-09-17 | C1 | 1048h | 1048h | eMPS-CN | 25 | Ericsson | Philip.hodges@ericsson.com | Rel-10 | 49 | Frederic | Public Safety (I-A) |  |  |  |  |
| 3282 | 862 | **Network Improvements for Machine-Type Communications** | 1365d? | 2008-09-18 A | 2013-11-22 A | 100% | 2008-09-18 | 2013-11-22 | 1365d? |  | S1; S2; S5; C1; C4; C6; G2; R2; R3; R5; G3new | 149017h | 149017h | NIMTC | 21 | KPN | toon.norp@tno.nl | Rel-10 | 41 | Alain | MTC, M2M | NIMTC |  |  |  |
| 3283 | 862.1 | Stage 1 for Network Improvements for Machine-Type Communications | 397d? | 2008-09-18 A | 2010-03-25 A | 100% | 2008-09-18 | 2010-03-25 | 397d? | finish no earlier than 2009-12-10 | S1 | 3176h | 3176h | NIMTC | 21 | KPN | toon.norp@tno.nl | Rel-10 | 41 | Alain | MTC, M2M |  |  |  |  |
| 3284 | 862.2 | Deleted - TR on Stage 2 for Network Improvements for Machine-Type Communications | 321d? | 2009-09-24 A | 2010-12-16 A | 100% | 2009-09-24 | 2010-12-16 | 321d? | finish no earlier than 2010-11-30 | S2 | 2568h | 2568h | NIMTC | 23 | Samsung | erik.guttman@partner.samsung.com | Rel-10 | 45 | Maurice | MTC, M2M |  | PCG-26 | SP-50 |  |
| 3285 | 862.3 | Stage 2 for Network Improvements for Machine-Type Communications | 19d? | 2010-08-30 A | 2010-09-23 A | 100% | 2010-08-30 | 2010-09-23 | 19d? | finish no earlier than 2010-09-17 | S2 | 152h | 152h | NIMTC | 23 | Samsung | erik.guttman@partner.samsung.com | Rel-10 | 45 | Maurice | MTC, M2M |  |  |  |  |
| 3286 | 862.4 | Deleted - Security for Network Improvements for Machine-Type Communications | 193.15d? | 2009-12-10 A | 2010-09-23 A | 100% | 2009-12-10 | 2010-09-23 | 193.15d? | finish no earlier than 2010-09-23 | S3 | 1545.2h | 1545.2h | NIMTC | 24 | Samsung | Rajavelsamy R (rajvel@samsung.com) | Rel-10 | 46 | Mirko | MTC, M2M |  | PCG-25 | SP-49 |  |
| 3287 | 862.5 | Charging for Network Improvements for Machine-Type Communication | 3d? | 2011-03-21 A | 2011-03-23 A | 100% | 2011-03-21 | 2011-03-23 | 3d? | start no earlier than 2011-03-21 | S5 | 24h | 24h | NIMTC-CH | 26 | Ericsson | patrik.teppo@@ericsson.com | Rel-10 | 51 | Mirko | MTC, M2M | NIMTC-CH |  |  |  |
| 3288 | 862.6 | **CN part of Stage 3 for Network Improvements for Machine-Type Communications** | 261d? | 2010-06-04 A | 2011-06-03 A | 100% | 2010-06-04 | 2011-06-03 | 261d? |  | C1; C4; C6 | 12976h | 12976h | NIMTC-CN | 25 | Ericsson | mikael.wass@ericsson.com | Rel-10 | 48 | Frederic | MTC, M2M | NIMTC-CN |  |  |  |
| 3289 | 862.6.1 | CT1 part of Stage 3 for Network Improvements for Machine-Type Communications | 261d? | 2010-06-04 A | 2011-06-03 A | 100% | 2010-06-04 | 2011-06-03 | 261d? | finish no earlier than 2011-06-03 | C1 | 2088h | 2088h | NIMTC-CN | 25 | Ericsson | mikael.wass@ericsson.com | Rel-10 | 48 | Frederic | MTC, M2M |  |  |  |  |
| 3290 | 862.6.2 | Deleted - CT3 part of Stage 3 for Network Improvements for Machine-Type Communications | 261d? | 2010-06-04 A | 2011-06-03 A | 100% | 2010-06-04 | 2011-06-03 | 261d? | finish no earlier than 2010-12-10 | C3 | 2088h | 2088h | NIMTC-CN | 25 | Ericsson | mikael.wass@ericsson.com | Rel-10 | 48 | Adrian | MTC, M2M |  | PCG-27 | CP-52 |  |
| 3291 | 862.6.3 | CT4 part of Stage 3 for Network Improvements for Machine-Type Communications | 261d? | 2010-06-04 A | 2011-06-03 A | 100% | 2010-06-04 | 2011-06-03 | 261d? | finish no earlier than 2011-03-18 | C4 | 2088h | 2088h | NIMTC-CN | 25 | Ericsson | mikael.wass@ericsson.com | Rel-10 | 48 | Kimmo | MTC, M2M |  |  |  |  |
| 3292 | 862.6.4 | CT6 part of Stage 3 for Network Improvements for Machine-Type Communications | 56d? | 2011-03-18 A | 2011-06-03 A | 100% | 2011-03-18 | 2011-06-03 | 56d? | finish no earlier than 2011-06-03 | C6 | 448h | 448h | NIMTC-CN | 26 | Sagem-Orga | heiko.kruse@sagem-orga.com | Rel-10 | 51 | Xavier | MTC, M2M |  |  |  |  |
| 3293 | 862.7 | GERAN part of Network Improvements for Machine-Type Communications (Stage 3) | 261d? | 2010-09-03 A | 2011-09-02 A | 100% | 2010-09-03 | 2011-09-02 | 261d? | finish no earlier than 2011-09-02 | G2 | 2088h | 2088h | NIMTC | 25 | Vodafone, Ericsson | leo.patanapongpibul@vodafone.com, john.diachina@ericsson.com | Rel-10 | 47 | Gert | MTC, M2M |  |  |  |  |
| 3294 | 862.8 | MS Conformance Test Aspects for GERAN - Network Improvements for Machine-Type Communications | 333d? | 2012-08-27 A | 2013-11-22 A | 100% | 2012-08-27 | 2013-11-22 | 333d? | finish no earlier than 2013-11-22 | G3new | 2656h | 2656h | NIMTC_GERAN-MSTest | 29 | ST-Ericsson | hakan.e.grunditz@stericsson.com | Rel-10 | 55 | Ingbert | MTC, M2M | NIMTC_GERAN-MSTest |  |  |  |
| 3295 | 862.9 | RAN mechanisms to avoid CN overload due to Machine-Type Communications | 131d? | 2010-09-17 A | 2011-03-18 A | 100% | 2010-09-17 | 2011-03-18 | 131d? | finish no earlier than 2011-03-18 | R2; R3 | 2096h | 2096h | NIMTC-RAN_overload | 25 | Huawei | Jeff Gao (gaoyq@huawei.com) | Rel-10 | 49 | Yong-Jun | MTC, M2M | NIMTC-RAN_overload |  |  | RP-110063 |
| 3296 | 862.10 | UE Conformance Test Aspects - Network Improvements for Machine-Type Communications | 202d? | 2012-09-11 A | 2013-06-14 A | 100% | 2012-09-11 | 2013-06-14 | 202d? | finish no earlier than 2013-06-14 | R5 | 1616h | 1616h | NIMTC-UEConTest | 29 | Ericsson | calle.hagenfeldt@ericsson.com | Rel-10 | 57 | Ingbert | MTC, M2M | NIMTC-UEConTest |  |  | RP-130465 |

Notes:
- 3271: CP#51 completed. SP#49 moved Stage 1 from Rel-9 & Completed Stage 2. SP#40 Stage 1 completed. Continuation of Rel-8 Feature PRIOR (UID_340044)
- 3272: 22/01: acronym modified / Impacted TSs and TRs: 22.153, 22.278
- 3273: 22/01: acronym modified
- 3274: 22/01: acronym modified / Impacted TSs and TRs: 23.002, 23.203, 23.221, 23.228, 23.272, 23.401
- 3275: 22/01: acronym modified / Impacted TSs and TRs: 23.002, 23.203, 23.221, 23.228, 23.272, 23.401
- 3276: 22/01: acronym modified / Impacted TSs and TRs: 23.002, 23.203, 23.221, 23.228, 23.272, 23.401
- 3277: SP#49 TR 23.854 v100 for Information. SP#50 moved to Rel-11 SRVCC aspect of enhancements for Multimedia Priority Service UID_480135 (place holder for solution alternatives and agreed functions to be reflected in affected existing TS) / Impacted TSs and TRs: new TR 23.854
- 3278: CP#51 completed / Impacted TSs and TRs: Stage 3
- 3279: CP#51 completed / Impacted TSs and TRs: 23.008, 29.002, 29.228, 29.229, 29.272, 29.274, 29.277, 29.328, 29.329
- 3280: CP#51 completed / Impacted TSs and TRs: 29.212, 29.213, 29.214
- 3281: CP#51 completed / Impacted TSs and TRs: 24.008, 24.229, 24.301
- 3282: Triggered by Rel-8 UID_7027 Study on Facilitating Machine to Machine Communication in GSM and UMTS (FS_M2M) TR 22.868
- 3283: SP#47 completed / Impacted TSs and TRs: 22.011, New 22.368
- 3284: SP#50 updated WID SP-090832=>SP-100863 (TR 23.888 not submitted for approval to conclude Rel-10 NIMTC as it will continue to serve as basis for Rel-11 SIMTC work item) / Impacted TSs and TRs: New TR 23.888
- 3285: SP#49 completed / Impacted TSs and TRs: 23.060, 23.236, 23.401
- 3286: SP#49 stopped (activity transferred to Rel-11 Feature SIMTC under UID_490028 "TR on Security aspects of Machine-Type Communications". / Impacted TSs and TRs: New TR 33.868
- 3287: SP#51 completed / Impacted TSs and TRs: 32.251, 32.298, 32.299
- 3288: CP#52 completed / Impacted TSs and TRs: Stage 3
- 3289: CP#52 completed / Impacted TSs and TRs: 23.122, 24.008, 24.301, New 24.368
- 3290: CP#52 stopped (SA2 decided to move impact from CT3 to CT4). Updated WID CP-110147=>CP-110442 (no CT3 impact) / Impacted TSs and TRs: 29.212, 29.213, 29.215
- 3291: CP#52 completed / Impacted TSs and TRs: 23.003, 23.008, 29.002, 29.060, 29.230, 29.272, 29.274, 29.275, 29.282
- 3292: CP#52 completed / Impacted TSs and TRs: 31.102
- 3293: GP#51 completed. GP#47 approved WID / Impacted TSs and TRs: 44.018, 44.060
- 3294: GP#60 completed. GP#55 approved WID. Testing for CT1 part of Stage 3 for NIMTC UID_480105, GERAN part of NIMTC (Stage 3) UID_490003 / Impacted TSs and TRs: 51.010-1, 51.010-2
- 3295: RP#51 completed / Impacted TSs and TRs: UTRA, LTE 25.331, 25.413, 36.331, 36.413
- 3296: RP#60 completed. Testing for CT1 part of Stage 3 UID_480105, RAN mechanisms to avoid CN overload due to MTC UID_490024 / Impacted TSs and TRs: 34.123-1, 34.123-2, 34.123-3, 36.523-1, 36.523-2, 36.523-3

| ID | WBS | Task | Duration | Start | Finish | Complete | Baseline start | Baseline finish | Baseline duration | Constraint | Resources | Work | Actual work | Acronym | PCG approved | WI rapporteur name | Release | TSG approved | MCC resp | Acronym_3GU_Export | Special Focus Doc |
| --- | --- | --- | --- | --- | --- | --- | --- | --- | --- | --- | --- | --- | --- | --- | --- | --- | --- | --- | --- | --- | --- |
| 3297 | 863 | **Multi Access PDN Connectivity** | 527d? | 2009-03-13 A | 2011-03-18 A | 100% | 2009-03-13 | 2011-03-18 | 527d? |  | S2; C4; C1; C3 | 23680h | 23680h | MAPCON | 22 | Telecom Italia | Rel-10 | 43 | Maurice | MAPCON |  |
| 3298 | 863.1 | Stage 2 for Multi Access PDN Connectivity | 401d? | 2009-03-13 A | 2010-09-23 A | 100% | 2009-03-13 | 2010-09-23 | 401d? |  | S2 | 3208h | 3208h | MAPCON |  | Telecom Italia | Rel-10 | 43 | Maurice |  |  |
| 3299 | 863.2 | **CT aspects of Multi Access PDN Connectivity** | 90d? | 2010-11-15 A | 2011-03-18 A | 100% | 2010-11-15 | 2011-03-18 | 90d? |  | C4; C1; C3 | 3608h | 3608h | MAPCON-St3 | 26 | ZTE | Rel-10 | 50 | Kimmo | MAPCON-St3 |  |
| 3300 | 863.2.1 | CT4 aspects of Multi Access PDN Connectivity | 20d? | 2010-11-15 A | 2010-12-10 A | 100% | 2010-11-15 | 2010-12-10 | 20d? | start no earlier than 2010-12-10 | C4 | 160h | 160h | MAPCON-St3 | 26 | ZTE | Rel-10 | 50 | Kimmo |  |  |
| 3301 | 863.2.2 | CT1 aspects of Multi Access PDN Connectivity | 71d? | 2010-12-10 A | 2011-03-18 A | 100% | 2010-12-10 | 2011-03-18 | 71d? | start no earlier than 2010-12-10 | C1 | 568h | 568h | MAPCON-St3 | 26 | ZTE | Rel-10 | 50 | Frederic |  |  |
| 3302 | 863.2.3 | CT3 aspects of Multi Access PDN Connectivity | 90d? | 2010-11-15 A | 2011-03-18 A | 100% | 2010-11-15 | 2011-03-18 | 90d? | finish no earlier than 2011-03-18 | C3 | 720h | 720h | MAPCON-St3 | 26 | ZTE | Rel-10 | 50 | Adrian |  |  |
| 3303 | 864 | **IMS Service Continuity – Inter Device Transfer enhancements** | 924d? | 2009-06-04 A | 2012-12-07 A | 100% | 2009-06-04 | 2012-12-07 | 924d? |  | S1; S2; C1; IETF | 41168h | 41168h | IMS_SC_eIDT | 23 | Huawei | Rel-10 | 44 | Alain | IMS_SC_eIDT |  |
| 3304 | 864.1 | Stage 1 - IMS Service Continuity – Inter Device Transfer enhancements | 211d? | 2009-06-04 A | 2010-03-25 A | 100% | 2009-06-04 | 2010-03-25 | 211d? | finish no earlier than 2010-03-25 | S1 | 1688h | 1688h | IMS_SC_eIDT | 23 | Huawei | Rel-10 | 44 | Alain |  |  |
| 3305 | 864.2 | Stage 2 - IMS Inter-UE Transfer enhancements | 261d? | 2009-09-24 A | 2010-09-23 A | 100% | 2009-09-24 | 2010-09-23 | 261d? | finish no earlier than 2010-09-23 | S2 | 2088h | 2088h | IMS_SC_eIDT | 23 | Huawei | Rel-10 | 45 | Maurice |  |  |
| 3306 | 864.3 | Stage 3 - IMS Inter-UE Transfer enhancements | 261d? | 2010-03-19 A | 2011-03-18 A | 100% | 2010-03-19 | 2011-03-18 | 261d? | start no earlier than 2010-03-19 | C1 | 2088h | 2088h | IMS_SC_eIDT | 24 | Huawei | Rel-10 | 47 | Frederic |  |  |
| 3307 | 864.4 | (IETF) Stage 3 - IMS Inter-UE Transfer enhancements | 717d? | 2010-03-19 A | 2012-12-07 A | 100% | 2010-03-19 | 2012-12-07 | 717d? | finish no earlier than 2012-12-04 | C1-IETF | 5736h | 5736h | IMS_SC_eIDT | 27 | christer.holmberg@ericsson.com | Rel-10 | 52 | Frederic |  |  |
| 3308 | 865 | **IP-Short-Message-Gateway enhancements for CPM-SMS Interworking** | 257d? | 2009-09-24 A | 2010-09-17 A | 100% | 2009-09-24 | 2010-09-17 | 257d? |  | S1; S2; C3 | 9904.8h | 9904.8h | CPM-SMS | 23 | China Mobile | Rel-10 | 45 | Alain | CPM-SMS |  |
| 3309 | 865.1 | Stage 1 for CPM-SMS | 131d? | 2009-09-24 A | 2010-03-25 A | 100% | 2009-09-24 | 2010-03-25 | 131d? | finish no earlier than 2010-03-25 | S1 | 1048h | 1048h | CPM-SMS | 23 | China Mobile | Rel-10 | 45 | Alain |  |  |
| 3310 | 865.2 | Stage 2 for CPM-SMS | 130.1d? | 2009-09-24 A | 2010-03-25 A | 100% | 2009-09-24 | 2010-03-25 | 130.1d? | finish no earlier than 2010-03-25 | S2 | 1040.8h | 1040.8h | CPM-SMS | 23 | Orange | Rel-10 | 45 | Maurice |  |  |
| 3311 | 865.3 | Stage 3 for IP-Short-Message-Gateway enhancements for CPM-SMS Interworking | 206d? | 2009-12-04 A | 2010-09-17 A | 100% | 2009-12-04 | 2010-09-17 | 206d? | finish no earlier than 2010-09-17 | C3 | 1648h | 1648h | CPM-SMS | 24 | Ericsson | Rel-10 | 46 | Adrian |  |  |
| 3312 | 866 | **Completion of Communications on Not Logged-in** | 387d? | 2009-09-24 A | 2011-03-18 A | 100% | 2009-09-24 | 2011-03-18 | 387d? |  | S1; C1; C3 | 11992h | 11992h | CCNL | 23 | Deutsche Telekom | Rel-10 | 45 | Alain | CCNL |  |
| 3313 | 866.1 | Stage 1 for Completion of Communications on Not Logged-in | 1d? | 2009-09-24 A | 2009-09-24 A | 100% | 2009-09-24 | 2009-09-24 | 1d? | start no earlier than 2009-09-24 | S1 | 8h | 8h | CCNL | 23 | Deutsche Telekom | Rel-10 | 45 | Alain |  |  |
| 3314 | 866.2 | CT1 part of Stage 3 for Completion of Communications on Not Logged-in | 261d? | 2010-03-19 A | 2011-03-18 A | 100% | 2010-03-19 | 2011-03-18 | 261d? | finish no earlier than 2011-03-18 | C1 | 2088h | 2088h | CCNL | 24 | Deutsche Telekom | Rel-10 | 47 | Frederic |  |  |
| 3315 | 866.3 | CT3 part of Stage 3 for Completion of Communications on Not Logged-in | 76d? | 2010-06-04 A | 2010-09-17 A | 100% | 2010-06-04 | 2010-09-17 | 76d? | finish no earlier than 2010-09-17 | C3 | 608h | 608h | CCNL | 25 | Deutsche Telekom | Rel-10 | 48 | Adrian |  |  |
| 3316 | 867 | **Local IP Access and Selected Internet IP Traffic Offload** | 390d? | 2009-09-24 A | 2011-03-23 A | 100% | 2009-09-24 | 2011-03-23 | 390d? |  | S2; S1; S3; S5; C4; C1 | 66128h | 66128h | LIPA_SIPTO | 23 | Huawei, China Mobile | Rel-10 | 45 | Maurice | LIPA_SIPTO | HNB |
| 3317 | 867.1 | Stage 1 for Local IP Access and Selected Internet IP Traffic Offload | 131d? | 2009-09-24 A | 2010-03-25 A | 100% | 2009-09-24 | 2010-03-25 | 131d? | finish no earlier than 2010-03-25 | S1 | 1048h | 1048h | LIPA_SIPTO | 23 | Huawei, China Mobile | Rel-10 | 45 | Alain |  | HNB |
| 3318 | 867.2 | TR on Local IP Access and Selected Internet IP Traffic Offload | 387d? | 2009-09-24 A | 2011-03-18 A | 100% | 2009-09-24 | 2011-03-18 | 387d? | finish no earlier than 2011-03-18 | S2 | 3096h | 3096h | LIPA_SIPTO | 23 | Huawei, China Mobile | Rel-10 | 45 | Maurice |  | HNB |
| 3319 | 867.3 | Security for Local IP Access and Selected Internet IP Traffic Offload | 261d? | 2009-09-24 A | 2010-09-23 A | 100% | 2009-09-24 | 2010-09-23 | 261d? | finish no earlier than 2010-09-23 | S3 | 2088h | 2088h | LIPA_SIPTO | 23 | Huawei, Qualcomm | Rel-10 | 45 | Mirko |  | HNB |
| 3320 | 867.4 | OAM&P for Local IP Access and Selected Internet IP Traffic Offload | 390d? | 2009-09-24 A | 2011-03-23 A | 100% | 2009-09-24 | 2011-03-23 | 390d? | finish no earlier than 2011-03-23 | S5 | 3120h | 3120h | LIPA_SIPTO | 23 | Huawei, China Mobile | Rel-10 | 45 | Mirko |  | HNB |
| 3321 | 867.5 | Charging for Local IP Access and Selected Internet IP Traffic Offload | 335d? | 2009-12-10 A | 2011-03-23 A | 100% | 2009-12-10 | 2011-03-23 | 335d? | finish no earlier than 2011-03-23 | S5 | 2680h | 2680h | LIPA_SIPTO | 24 | Huawei, China Mobile | Rel-10 | 46 | Mirko |  | HNB |

Notes:
- 3297: CP#51 completed. SP#49 Stage 2 completed. Triggered by TR 23.861 UID_410043 FS_MAPIM. Stage 1 in Rel-9 22.278 (6.2 - IP session control) / WI rapporteur e-mail: ivano.guardini@telecomitalia.it
- 3298: SP#49 completed. Triggered by TR 23.861 UID_410043 FS_MAPIM. Stage 1 in Rel-9 22.278 (6.2 - IP session control) / Impacted TSs and TRs: 23.237, 23.401, 23.402 / WI rapporteur e-mail: ivano.guardini@telecomitalia.it
- 3299: CP#51 completed / WI rapporteur e-mail: Xingyue (Joy) Zhou (zhou.xingyue@zte.com.cn)
- 3300: CP#50 completed / Impacted TSs and TRs: 29.273, 29.272, 29.002, 23.008 / WI rapporteur e-mail: Xingyue (Joy) Zhou (zhou.xingyue@zte.com.cn)
- 3301: CP#51 completed / Impacted TSs and TRs: 24.302, 24.312 / WI rapporteur e-mail: Xingyue (Joy) Zhou (zhou.xingyue@zte.com.cn)
- 3302: CP#51 completed / Impacted TSs and TRs: 29.215 / WI rapporteur e-mail: Xingyue (Joy) Zhou (zhou.xingyue@zte.com.cn)
- 3303: CP#51 completed. SP#47 Stage 1 completed. Rel-9 set Inter-Device Transfer requirements UID_410033 (IMS_SCC-IDT). Adds IDT scenarios and requirements / WI rapporteur e-mail: Amar Deol (adeol@huawei.com)
- 3304: SP#47 completed / Impacted TSs and TRs: 22.228 / WI rapporteur e-mail: Amar Deol (adeol@huawei.com)
- 3305: SP#49 completed / Impacted TSs and TRs: 23.237, 23.292, new 23.831 / WI rapporteur e-mail: Lee Valerius (lvalerius@huawei.com)
- 3306: CP#51 completed. WID updated CP-100334=>CP-110285 / Impacted TSs and TRs: 24.216, 24.229, 24.237, new (24.837, 24.337) / WI rapporteur e-mail: georg.mayer@huawei.com
- 3307: CP#58 completed / Impacted TSs and TRs: RFC 6809 (was draft-ietf-sipcore-proxy-feature) / WI rapporteur e-mail: christer.holmberg@ericsson.com
- 3308: CP#49 completed. SP#47 Stage 1 completed. IP-SM-GW enhancements for interworking with OMA CPM / WI rapporteur e-mail: Qing Huang (huangqing@chinamobile.com)
- 3309: SP#47 completed. External requirements (Stage 1 in OMA-RD-CPM-V1_0-20090310-C) / Impacted TSs and TRs: 22.340 / WI rapporteur e-mail: Qing Huang
- 3310: SP#47 completed / Impacted TSs and TRs: 23.204, new TR 23.824 / WI rapporteur e-mail: antoine.mouquet@orange-ftgroup.com
- 3311: CP#49 completed. Linked to Rel-8 UID_340031 Service-Level Interworking for Messaging Services (MESSIW) 23.204 / Impacted TSs and TRs: 29.311 / WI rapporteur e-mail: Jan Holm
- 3312: CP#51 completed. SP#45 Stage 1 completed / WI rapporteur e-mail: Kurt Bischinger
- 3313: SP#45 completed / Impacted TSs and TRs: 22.173 CR#0056r1 / WI rapporteur e-mail: Kurt Bischinger
- 3314: CP#51 completed / Impacted TSs and TRs: 24.173, 24.642 / WI rapporteur e-mail: martin.huelsemann@telekom.de
- 3315: CP#49 completed / Impacted TSs and TRs: 29.165 / WI rapporteur e-mail: martin.huelsemann@telekom.de
- 3316: TSG#51 completed. Updated WID SP-100696=>SP-110131. SP#49 Stage 2 & Security completed. UID_400035 Enhanced Home NodeB/eNodeB (EHNB) formerly covered Local IP Access to Internet and Local access to Home Network from the Home NodeB/eNodeB / WI rapporteur e-mail: patrice.hede@huawei.com, Tao Sun (suntao@chinamobile.com)
- 3317: SP#47 completed / Impacted TSs and TRs: 22.101, 22.220 / WI rapporteur e-mail: Amar Deol (adeolf@huawei.com), Gang Li (ligangyf@chinamobile.com)
- 3318: SP#51 completed. TR 23.829 for Approval / Impacted TSs and TRs: New TR 23.829 / WI rapporteur e-mail: patrice.hede@huawei.com, Tao Sun (suntao@chinamobile.com)
- 3319: SP#49 completed / Impacted TSs and TRs: 33.102, 33.107, 33.108, 33.320, 33.401 / WI rapporteur e-mail: Marcus Wong (mwong@huawei.com), Brian Rosenberg (bmr@qualcomm.com)
- 3320: SP#51 completed. Updated WID SP-100696=>SP-110131 / Impacted TSs and TRs: 32.581, 32.582, 32.584, 32.591, 32.592, 32.642, 32.646, 32.772, 32.782 / WI rapporteur e-mail: Zou Lan (zlan@huawei.com), Chen Gang (chengang@chinamobile.com)
- 3321: SP#51 completed. Updated WID SP-100696=>SP-110131 / Impacted TSs and TRs: 32.251 / WI rapporteur e-mail: shan.mingjun@huawei.com, Ai Chen (chenai@chinamobile.com)

| ID | WBS | Task | Duration | Start | Finish | Complete | Baseline start | Baseline finish | Baseline duration | Constraint | Resources | Work | Actual work | Acronym | PCG approved | WI rapporteur name | WI rapporteur e-mail | Release | TSG approved | MCC resp | Special Focus Doc | Acronym_3GU_Export |
| --- | --- | --- | --- | --- | --- | --- | --- | --- | --- | --- | --- | --- | --- | --- | --- | --- | --- | --- | --- | --- | --- | --- |
| 3322 | 867.6 | **Stage 2/3 for Local IP Access** | 387d? | 2009-09-24 A | 2011-03-18 A | 100% | 2009-09-24 | 2011-03-18 | 387d? |  | S2; C4; C1 | 17968h | 17968h | LIPA | 23 | Huawei, China Mobile | patrice.hede@huawei.com, Tao Sun (suntao@chinamobile.com) | Rel-10 | 45 | Maurice | HNB | LIPA |
| 3323 | 867.6.1 | Stage 2 for Local IP Access | 261d? | 2009-09-24 A | 2010-09-23 A | 100% | 2009-09-24 | 2010-09-23 | 261d? | finish no earlier than 2010-08-10 | S2 | 2088h | 2088h | LIPA | 23 | Huawei, China Mobile | patrice.hede@huawei.com, Tao Sun (suntao@chinamobile.com) | Rel-10 | 45 | Maurice | HNB |  |
| 3324 | 867.6.2 | **Stage 3 for Local IP Access** | 206d? | 2010-06-04 A | 2011-03-18 A | 100% | 2010-06-04 | 2011-03-18 | 206d? |  | C4; C1 | 6592h | 6592h | LIPA | 25 | China Mobile | Zhang Hao (zhanghao@chinamobile.com) | Rel-10 | 48 | Kimmo | HNB |  |
| 3325 | 867.6.2.1 | CT4 part of Stage 3 for Local IP Access | 206d? | 2010-06-04 A | 2011-03-18 A | 100% | 2010-06-04 | 2011-03-18 | 206d? | finish no earlier than 2011-03-18 | C4 | 1648h | 1648h | LIPA | 25 | China Mobile | Zhang Hao (zhanghao@chinamobile.com) | Rel-10 | 48 | Kimmo | HNB |  |
| 3326 | 867.6.2.2 | CT1 part of Stage 3 for Local IP Access | 206d? | 2010-06-04 A | 2011-03-18 A | 100% | 2010-06-04 | 2011-03-18 | 206d? | finish no earlier than 2011-03-18 | C1 | 1648h | 1648h | LIPA | 25 | China Mobile | Zhang Hao (zhanghao@chinamobile.com) | Rel-10 | 48 | Frederic | HNB |  |
| 3327 | 867.7 | **Stage 2/3 for SIPTO for macro networks** | 387d? | 2009-09-24 A | 2011-03-18 A | 100% | 2009-09-24 | 2011-03-18 | 387d? |  | S2; C4; C1 | 17408h | 17408h | SIPTO | 23 | Huawei, China Mobile | patrice.hede@huawei.com, Tao Sun (suntao@chinamobile.com) | Rel-10 | 45 | Maurice | HNB | SIPTO |
| 3328 | 867.7.1 | Stage 2 for SIPTO for macro networks | 261d? | 2009-09-24 A | 2010-09-23 A | 100% | 2009-09-24 | 2010-09-23 | 261d? | finish no earlier than 2010-09-23 | S2 | 2088h | 2088h | SIPTO | 23 | Huawei, China Mobile | patrice.hede@huawei.com, Tao Sun (suntao@chinamobile.com) | Rel-10 | 45 | Maurice | HNB |  |
| 3329 | 867.7.2 | **Stage 3 for SIPTO for macro networks** | 206d? | 2010-06-04 A | 2011-03-18 A | 100% | 2010-06-04 | 2011-03-18 | 206d? |  | C4; C1 | 6032h | 6032h | SIPTO | 25 | Huawei | Caixia Qi (qcxmay@huawei.com) | Rel-10 | 48 | Kimmo | HNB |  |
| 3330 | 867.7.2.1 | CT4 part of Stage 3 for SIPTO for macro networks | 206d? | 2010-06-04 A | 2011-03-18 A | 100% | 2010-06-04 | 2011-03-18 | 206d? | finish no earlier than 2011-03-18 | C4 | 1648h | 1648h | SIPTO | 25 | Huawei | Caixia Qi (qcxmay@huawei.com) | Rel-10 | 48 | Kimmo | HNB |  |
| 3331 | 867.7.2.2 | CT1 part of Stage 3 for SIPTO for macro networks | 136d? | 2010-06-04 A | 2010-12-10 A | 100% | 2010-06-04 | 2010-12-10 | 136d? | finish no earlier than 2011-03-18 | C1 | 1088h | 1088h | SIPTO | 25 | Huawei | Caixia Qi (qcxmay@huawei.com) | Rel-10 | 48 | Frederic | HNB |  |
| 3332 | 868 | **IP Flow Mobility and seamless WLAN offload** | 390d? | 2009-09-24 A | 2011-03-23 A | 100% | 2009-09-24 | 2011-03-23 | 390d? |  | S2; S1; S5; C1; C3 | 26808h | 26808h | IFOM | 23 | Qualcomm | Gerardo Giaretta (gerardo@qualcomm.com) | Rel-10 | 45 | Maurice | WLAN | IFOM |
| 3333 | 868.1 | Stage 1 for IP Flow Mobility and seamless WLAN offload | 56d? | 2009-09-24 A | 2009-12-10 A | 100% | 2009-09-24 | 2009-12-10 | 56d? | finish no earlier than 2009-12-10 | S1 | 448h | 448h | IFOM | 23 | Qualcomm | David Williams (dwilliam@qualcomm.com) | Rel-10 | 45 | Alain | WLAN |  |
| 3334 | 868.2 | Stage 2 for IP Flow Mobility and seamless WLAN offload | 261d? | 2009-09-24 A | 2010-09-23 A | 100% | 2009-09-24 | 2010-09-23 | 261d? | finish no earlier than 2010-09-23 | S2 | 2088h | 2088h | IFOM | 23 | Qualcomm | Gerardo Giaretta (gerardo@qualcomm.com) | Rel-10 | 45 | Maurice | WLAN |  |
| 3335 | 868.3 | Charging for IP Flow Mobility and seamless WLAN offload | 260d? | 2010-03-25 A | 2011-03-23 A | 100% | 2010-03-25 | 2011-03-23 | 260d? | finish no earlier than 2011-03-23 | S5 | 2080h | 2080h | IFOM | 24 | Alcatel-Lucent | maryse.gardella@alcatel-lucent.com | Rel-10 | 47 | Mirko | WLAN |  |
| 3336 | 868.4 | **Stage 3 for IP Flow Mobility and seamless WLAN offload** | 206d? | 2010-06-04 A | 2011-03-18 A | 100% | 2010-06-04 | 2011-03-18 | 206d? |  | C1; C3 | 6592h | 6592h | IFOM-CT | 25 | Qualcomm | Patrick Stupar (pstupar@qualcomm.com) | Rel-10 | 48 | Frederic | WLAN | IFOM-CT |
| 3337 | 868.4.1 | CT1 part of Stage 3 for IP Flow Mobility and seamless WLAN offload | 206d? | 2010-06-04 A | 2011-03-18 A | 100% | 2010-06-04 | 2011-03-18 | 206d? | finish no earlier than 2011-03-18 | C1 | 1648h | 1648h | IFOM-CT | 25 | Qualcomm | Patrick Stupar (pstupar@qualcomm.com) | Rel-10 | 48 | Frederic | WLAN |  |
| 3338 | 868.4.2 | CT3 part of Stage 3 for IP Flow Mobility and seamless WLAN offload | 206d? | 2010-06-04 A | 2011-03-18 A | 100% | 2010-06-04 | 2011-03-18 | 206d? | finish no earlier than 2011-03-18 | C3 | 1648h | 1648h | IFOM-CT | 25 | Qualcomm | Patrick Stupar (pstupar@qualcomm.com) | Rel-10 | 48 | Adrian | WLAN |  |
| 3339 | 869 | **Enabling Coder Selection and Rate Adaptation for UTRAN and E-UTRAN for Load Adaptive Applications** | 827.4d? | 2009-07-15 A | 2012-09-07 A | 100% | 2009-07-15 | 2012-09-07 | 827.4d? |  | S2; S4; C4; C3; C1; IETF | 85939.2h | 85939.2h | ECSRA_LAA | 23 | Qualcomm | AC Mahendran (ac@qualcomm.com) | Rel-10 | 45 | Maurice |  | ECSRA_LAA |
| 3340 | 869.1 | TR on Enabling Coder Selection and Rate Adaptation for UTRAN and E-UTRAN for Load Adaptive Applications | 186d? | 2010-01-07 A | 2010-09-23 A | 100% | 2010-01-07 | 2010-09-23 | 186d? | finish no earlier than 2010-09-23 | S2; S4 | 2976h | 2976h | ECSRA_LAA | 23 | Qualcomm | AC Mahendran (ac@qualcomm.com) | Rel-10 | 45 | Maurice |  |  |
| 3341 | 869.2 | SA4 review of TR on Enabling Coder Selection and Rate Adaptation for UTRAN and E-UTRAN for Load Adaptive Applications | 320d? | 2009-09-24 A | 2010-12-15 A | 100% | 2009-09-24 | 2010-12-15 | 320d? | finish no earlier than 2010-12-15 | S4 | 2560h | 2560h | ECSRA_LAA | 23 | Qualcomm | AC Mahendran (ac@qualcomm.com) | Rel-10 | 45 | Paolo |  |  |
| 3342 | 869.3 | Stage 2 for Enabling Coder Selection and Rate Adaptation for UTRAN and E-UTRAN for Load Adaptive Applications | 261d? | 2009-09-24 A | 2010-09-23 A | 100% | 2009-09-24 | 2010-09-23 | 261d? | finish no earlier than 2010-09-23 | S2 | 2088h | 2088h | ECSRA_LAA | 23 | Qualcomm | AC Mahendran (ac@qualcomm.com) | Rel-10 | 45 | Maurice |  |  |
| 3343 | 869.4 | SA4 aspects of Enabling Coder Selection and Rate Adaptation for UTRAN and E-UTRAN for Load Adaptive Applications | 130d? | 2010-09-23 A | 2011-03-23 A | 100% | 2010-09-23 | 2011-03-23 | 130d? | finish no earlier than 2011-03-23 | S4 | 1040h | 1040h | ECSRA_LAA | 25 | Qualcomm | AC Mahendran (ac@qualcomm.com) | Rel-10 | 49 | Paolo |  |  |
| 3344 | 869.5 | **CN aspects of Enabling Coder Selection and Rate Adaptation for UTRAN and E-UTRAN for Load Adaptive Applications** | 827.4d? | 2009-07-15 A | 2012-09-07 A | 100% | 2009-07-15 | 2012-09-07 | 827.4d? |  | C4; C3; C1 | 37560h | 37560h | ECSRA_LAA-CN | 25 | Ericsson | philip.hodges@ericsson.com | Rel-10 | 49 | Kimmo |  | ECSRA_LAA-CN |
| 3345 | 869.5.1 | CT4 part of CN aspects of Enabling Coder Selection and Rate Adaptation for UTRAN and E-UTRAN for Load Adaptive Applications | 186d? | 2010-09-17 A | 2011-06-03 A | 100% | 2010-09-17 | 2011-06-03 | 186d? | start no earlier than 2010-09-17 | C4 | 1488h | 1488h | ECSRA_LAA-CN | 25 | Ericsson | philip.hodges@ericsson.com | Rel-10 | 49 | Kimmo |  |  |
| 3346 | 869.5.2 | (IETF) CT3, CT4 part of CN aspects of Enabling Coder Selection and Rate Adaptation for UTRAN and E-UTRAN for Load Adaptive Applications | 827.4d? | 2009-07-15 A | 2012-09-07 A | 100% | 2009-07-15 | 2012-09-07 | 827.4d? | finish no earlier than 2012-09-07 | C3-IETF; C4-IETF | 13238.4h | 13238.4h | ECSRA_LAA-CN | 27 | Lionel Morand |  | Rel-10 | 53 | Adrian |  |  |
| 3347 | 869.5.3 | CT3 part of CN aspects of Enabling Coder Selection and Rate Adaptation for UTRAN and E-UTRAN for Load Adaptive Applications | 186d? | 2010-09-17 A | 2011-06-03 A | 100% | 2010-09-17 | 2011-06-03 | 186d? | finish no earlier than 2011-06-03 | C3 | 1488h | 1488h | ECSRA_LAA-CN | 25 | Ericsson | philip.hodges@ericsson.com | Rel-10 | 49 | Adrian |  |  |
| 3348 | 869.5.4 | CT1 part of CN aspects of Enabling Coder Selection and Rate Adaptation for UTRAN and E-UTRAN for Load Adaptive Applications | 186d? | 2010-09-17 A | 2011-06-03 A | 100% | 2010-09-17 | 2011-06-03 | 186d? | start no earlier than 2010-09-17 | C1 | 1488h | 1488h | ECSRA_LAA-CN | 25 | Ericsson | philip.hodges@ericsson.com | Rel-10 | 49 | Frederic |  |  |

Notes:
- 3322: -
- 3323: SP#49 completed (has impacts to RAN) / Impacted TSs and TRs: 23.060, 23.401
- 3324: CP#51 completed
- 3325: CP#51 completed / Impacted TSs and TRs: 23.008, 23.015, 29.002, 29.060, 29.272, 29.274, 29.281, 29.303
- 3326: CP#51 completed / Impacted TSs and TRs: 24.008, 24.301
- 3327: -
- 3328: SP#49 completed (SIPTO GW selection for wild card APN and for GERAN. Serving-GW selection for SIPTO. Corrections and Clarifications of the SIPTO procedure) / Impacted TSs and TRs: 23.060, 23.401
- 3329: CP#51 completed. Updated WID CP-100419=>CP-110091
- 3330: CP#51 completed. Updated WID CP-100419=>CP-110091 / Impacted TSs and TRs: 23.003, 23.008, 29.002, 29.272, 29.303
- 3331: CP#50 completed / Impacted TSs and TRs: 24.008, 24.301
- 3332: SP#51 completed. Triggered by Rel-10 TR 23.861 (UID_410043 Study on Multi Access PDN connectivity and IP flow mobility - MAPIM)
- 3333: SP#46 completed / Impacted TSs and TRs: 22.278
- 3334: SP#49 completed / Impacted TSs and TRs: 23.203, 23.402, new 23.261
- 3335: SP#51 completed / Impacted TSs and TRs: 32.240, 32.251, 32.252, 32.298, 32.299
- 3336: CP#51 completed / Impacted TSs and TRs: Stage 3
- 3337: CP#51 completed / Impacted TSs and TRs: 24.008, 24.301, 24.302, 24.303, 24.312, 24.327
- 3338: CP#51 completed / Impacted TSs and TRs: 29.212, 29.213, 29.214, 29.215
- 3339: CP#52 completed. Triggered by Rel-9 UID_440013 Vocoder rate adaptation for LTE / Impacted TSs and TRs: UTRA, LTE
- 3340: SP#48 completed / Impacted TSs and TRs: new 23.860
- 3341: SP#50 completed / Impacted TSs and TRs: new 23.860
- 3342: SP#49 completed / Impacted TSs and TRs: 23.060, 23.203, 23.228, 23.401
- 3343: SP#51 completed / Impacted TSs and TRs: 26.114
- 3344: CP#52 completed / Impacted TSs and TRs: Stage 2/3
- 3345: CP#52 completed / Impacted TSs and TRs: 23.334, 29.334, 29.238, 23.333, 29.333, 29.232, 29.332
- 3346: CP#57 completed / Impacted TSs and TRs: RFC 6679 (was draft-ietf-avtcore-ecn-for-rtp)
- 3347: CP#52 completed / Impacted TSs and TRs: 29.162, 29.163, 29.213, 29.235, 29.292
- 3348: CP#52 completed / Impacted TSs and TRs: 24.229

| ID | WBS | Task | Type | Duration | Start | Finish | Complete | Baseline start | Baseline finish | Baseline duration | Constraint | Resources | Work | Actual work | Acronym | PCG approved | Impacted TSs and TRs | WI rapporteur name | WI rapporteur e-mail | Release | TSG approved | MCC resp | Special Focus Doc | Acronym_3GU_Export | PCG stopped | TSG stopped |
| --- | --- | --- | --- | --- | --- | --- | --- | --- | --- | --- | --- | --- | --- | --- | --- | --- | --- | --- | --- | --- | --- | --- | --- | --- | --- | --- |
| 3349 | 870 | **Extended H(e)NB features** |  | 467d? | 2008-12-11 A | 2010-09-23 A | 100% | 2008-12-11 | 2010-09-23 | 467d? |  | S1; S2; S3 | 15552h | 15552h | EHNBF | 23 | UTRA, LTE | NEC | joerg.swetina@neclab.eu | Rel-10 | 45 | Alain | HNB | EHNBF |  |  |
| 3350 | 870.1 | Stage 1 of Extended H(e)NB features |  | 131d? | 2009-09-24 A | 2010-03-25 A | 100% | 2009-09-24 | 2010-03-25 | 131d? | finish no earlier than 2010-03-25 | S1 | 1048h | 1048h | EHNBF | 23 | 22.220 | NEC | joerg.swetina@neclab.eu | Rel-10 | 45 | Alain | HNB |  |  |  |
| 3351 | 870.2 | IMS aspects of Architecture for Home NodeB |  | 336d? | 2008-12-11 A | 2010-03-25 A | 100% | 2008-12-11 | 2010-03-25 | 336d? | finish no earlier than 2010-03-25 | S2 | 2688h | 2688h | EHNB-IMS | 22 | New 23.832 | Alcatel-Lucent | Nicolas Drevon | Rel-10 | 42 | Maurice | HNB | EHNB-IMS |  |  |
| 3352 | 870.3 | Extended H(e)NB Security features (Stage 2) |  | 76d? | 2010-06-10 A | 2010-09-23 A | 100% | 2010-06-10 | 2010-09-23 | 76d? | finish no earlier than 2010-09-23 | S3 | 608h | 608h | EHNBF-Sec | 25 | 33.320 | Huawei | Marcus Wong (mwong@huawei.com) | Rel-10 | 48 | Mirko | HNB | EHNBF-Sec |  |  |
| 3353 | 871 | **Optimal Media Routing** |  | 314d? | 2010-03-25 A | 2011-06-08 A | 100% | 2010-03-25 | 2011-06-08 | 314d? |  | S2; S5; C3; C1 | 22696h | 22696h | OMR | 24 |  | Alcatel-Lucent | andy.bennett@alcatel-lucent.com | Rel-10 | 46 | Maurice |  | OMR |  |  |
| 3354 | 871.1 | Stage 2 for Optimal Media Routing | milestone | 0d? | 2010-03-25 A | 2010-03-25 A | 100% | 2010-03-25 | 2010-03-25 | 0d? |  | S2 |  |  | OMR | 24 | 23.228 | Alcatel-Lucent | andy.bennett@alcatel-lucent.com | Rel-10 | 46 | Maurice |  |  |  |  |
| 3355 | 871.2 | **Stage 3 for Optimal Media Routing** |  | 261d? | 2010-06-04 A | 2011-06-03 A | 100% | 2010-06-04 | 2011-06-03 | 261d? |  | C3; C1; C4 | 11648h | 11648h | OMR | 25 |  | Alcatel-Lucent | jim.calme@alcatel-lucent.com | Rel-10 | 48 | Adrian |  |  |  |  |
| 3356 | 871.2.1 | CT3 part of Stage 3 for Optimal Media Routeing |  | 261d? | 2010-06-04 A | 2011-06-03 A | 100% | 2010-06-04 | 2011-06-03 | 261d? | finish no earlier than 2011-06-03 | C3 | 2088h | 2088h | OMR | 25 | 29.162, 29.163, 29.165, 29.235, new TS 29.079 | Alcatel-Lucent | jim.calme@alcatel-lucent.com | Rel-10 | 48 | Adrian |  |  |  |  |
| 3357 | 871.2.2 | CT1 part of Stage 3 for Optimal Media Routeing |  | 206d? | 2010-06-04 A | 2011-03-18 A | 100% | 2010-06-04 | 2011-03-18 | 206d? | finish no earlier than 2011-03-18 | C1 | 1648h | 1648h | OMR | 25 | 24.229 | Alcatel-Lucent | jim.calme@alcatel-lucent.com | Rel-10 | 48 | Frederic |  |  |  |  |
| 3358 | 871.2.3 | Deleted - CT4 part of Stage 3 for Optimal Media Routeing |  | 206d? | 2010-06-04 A | 2011-03-18 A | 100% | 2010-06-04 | 2011-03-18 | 206d? | finish no earlier than 2011-03-18 | C4 | 1648h | 1648h | OMR | 25 |  | Alcatel-Lucent | jim.calme@alcatel-lucent.com | Rel-10 | 48 | Kimmo |  |  | PCG-26 | CP-51 |
| 3359 | 871.3 | Charging for Optimal Media Routing |  | 125d? | 2010-12-16 A | 2011-06-08 A | 100% | 2010-12-16 | 2011-06-08 | 125d? | finish no earlier than 2011-06-08 | S5 | 1000h | 1000h | OMR | 26 | 32.260, 32.298, 32.299 | Alcatel-Lucent | maryse.gardella@alcatel-lucent.com | Rel-10 | 50 | Mirko |  |  |  |  |
| 3360 | 872 | **IMS Emergency Session Enhancements** |  | 312d? | 2010-03-25 A | 2011-06-03 A | 100% | 2010-03-25 | 2011-06-03 | 312d? |  | S1; S2; C1 | 9552h | 9552h | IESE | 24 |  | Deutsche Telekom, T-Mobile | michele.zarri@t-mobile.co.uk | Rel-10 | 47 | Maurice | Public Safety (I-A) | IESE |  |  |
| 3361 | 872.1 | Stage 1 for IMS Emergency Session Enhancements |  | 1d? | 2010-03-25 A | 2010-03-25 A | 100% | 2010-03-25 | 2010-03-25 | 1d? | start no earlier than 2010-03-25 | S1 | 8h | 8h | IESE | 24 | 22.101 CR#0343 | Deutsche Telekom, T-Mobile | Kurt Bischinger | Rel-10 | 47 | Alain | Public Safety (I-A) |  |  |  |
| 3362 | 872.2 | Stage 2 for IMS Emergency Session Enhancements |  | 131d? | 2010-03-25 A | 2010-09-23 A | 100% | 2010-03-25 | 2010-09-23 | 131d? | finish no earlier than 2010-09-23 | S2 | 1048h | 1048h | IESE | 24 | 23.167 | Deutsche Telekom, T-Mobile | michele.zarri@t-mobile.co.uk | Rel-10 | 47 | Maurice | Public Safety (I-A) |  |  |  |
| 3363 | 872.3 | Stage 3 for IMS Emergency Session Enhancements |  | 126d? | 2010-12-10 A | 2011-06-03 A | 100% | 2010-12-10 | 2011-06-03 | 126d? | finish no earlier than 2011-06-03 | C1 | 1008h | 1008h | IESE | 26 | 24.229 | Deutsche Telekom | reinhard.lauster@t-mobile.at | Rel-10 | 50 | Frederic | Public Safety (I-A) |  |  |  |
| 3364 | 873 | **S2b Mobility based on GTP** |  | 202d? | 2010-06-10 A | 2011-03-18 A | 100% | 2010-06-10 | 2011-03-18 | 202d? |  | S2; C4; C3; C1 | 12800h | 12800h | SMOG | 25 |  | Alcatel-Lucent | bruno.landais@alcatel-lucent.com | Rel-10 | 48 | Maurice | WLAN | SMOG |  |  |
| 3365 | 873.1 | Stage 2 for S2b Mobility based on GTP |  | 76d? | 2010-06-10 A | 2010-09-23 A | 100% | 2010-06-10 | 2010-09-23 | 76d? | finish no earlier than 2010-09-23 | S2 | 608h | 608h | SMOG | 25 | 23.002, 23.203, 23.402 | Alcatel-Lucent | bruno.landais@alcatel-lucent.com | Rel-10 | 48 | Maurice | WLAN |  |  |  |
| 3366 | 873.2 | **Stage 3 for S2b Mobility based on GTP** |  | 131d? | 2010-09-17 A | 2011-03-18 A | 100% | 2010-09-17 | 2011-03-18 | 131d? |  | C4; C3; C1 | 5728h | 5728h | SMOG-St3 | 25 |  | Alcatel-Lucent | bruno.landais@alcatel-lucent.com | Rel-10 | 49 | Kimmo | WLAN | SMOG-St3 |  |  |
| 3367 | 873.2.1 | CT4 part of Stage 3 for S2b Mobility based on GTP |  | 131d? | 2010-09-17 A | 2011-03-18 A | 100% | 2010-09-17 | 2011-03-18 | 131d? | finish no earlier than 2011-03-18 | C4 | 1048h | 1048h | SMOG-St3 | 25 | 23.003, 23.007, 23.008, 29.273, 29.274, 29.281, 29.303 | Alcatel-Lucent | bruno.landais@alcatel-lucent.com | Rel-10 | 49 | Kimmo | WLAN |  |  |  |
| 3368 | 873.2.2 | CT3 part of Stage 3 for S2b Mobility based on GTP |  | 131d? | 2010-09-17 A | 2011-03-18 A | 100% | 2010-09-17 | 2011-03-18 | 131d? | finish no earlier than 2011-03-18 | C3 | 1048h | 1048h | SMOG-St3 | 25 | 29.212, 29.213, 29.215 | Alcatel-Lucent | bruno.landais@alcatel-lucent.com | Rel-10 | 49 | Adrian | WLAN |  |  |  |
| 3369 | 873.2.3 | CT1 part of Stage 3 for S2b Mobility based on GTP |  | 61d? | 2010-09-17 A | 2010-12-10 A | 100% | 2010-09-17 | 2010-12-10 | 61d? | finish no earlier than 2010-12-10 | C1 | 488h | 488h | SMOG-St3 | 25 | 24.302 | Alcatel-Lucent | bruno.landais@alcatel-lucent.com | Rel-10 | 49 | Frederic | WLAN |  |  |  |
| 3370 | 874 | **Policy Enhancements for Sponsored Connectivity and Coherent Access to Policy related Databases** |  | 113.15d? | 2010-10-12 A | 2011-03-18 A | 100% | 2010-10-12 | 2011-03-18 | 113.15d? |  | S2; C3 | 2378.4h | 2378.4h | PEST | 26 |  | Qualcomm | AC Mahendran (ac@qualcomm.com) | Rel-10 | 50 | Maurice |  | PEST |  |  |
| 3371 | 874.1 | Stage 2 for Policy Enhancements for Sponsored Connectivity and Coherent Access to Policy related Databases | milestone | 0d? | 2010-10-12 A | 2010-12-15 A | 100% | 2010-10-12 | 2010-12-15 | 0d? | finish no earlier than 2010-12-15 | S2 |  |  | PEST | 26 | 23.002, 23.203 | Qualcomm | AC Mahendran (ac@qualcomm.com) | Rel-10 | 50 | Maurice |  |  |  |  |
| 3372 | 874.2 | CT3 aspects of Policy Enhancements for Sponsored Connectivity and Coherent Access to Policy related Databases |  | 71d? | 2010-12-10 A | 2011-03-18 A | 100% | 2010-12-10 | 2011-03-18 | 71d? | finish no earlier than 2011-03-18 | C3 | 568h | 568h | PEST-CT3 | 26 | 29.212, 29.213, 29.214, 29.215 | ZTE | zhou.xiaoyun@zte.com.cn | Rel-10 | 50 | Adrian |  | PEST-CT3 |  |  |

Notes:
- 3349: SP#49 completed. Adds extensions to Rel-9 functionality in UID_400035 Enhanced Home NodeB / eNodeB (EHNB)
- 3350: SP#47 completed
- 3351: SP#47 completed. Chosen solution has no normative impacts
- 3352: SP#49 completed
- 3353: CP#52 completed. SP#47 Stage 2 completed. Triggered by TR 23.894 (UID_370050 Study on System enhancements for the use of IMS servicES in CP-150local breakout)
- 3354: SP#47 completed
- 3355: CP#51 completion 03/11=>06/11. WID updated CP-100327=>CP-110134
- 3356: CP#52 completed
- 3357: CP#51 completed. WID updated CP-100327=>CP-110134
- 3358: CP#51 stopped (CT4 specs not impacted). WID updated CP-100327=>CP-110134
- 3359: SP#52 completed. Stage 3: Linked to CT3 TS 29.079 OMR within the IMS; Stage 3 (UID_480110)
- 3360: CP#52 completed. SP#49 completed. Source of external requirements: ETSI TISPAN TS 181.019 (Business Communication Requirements)
- 3361: SP#47 completed
- 3362: SP#49 completed
- 3363: CP#52 completed
- 3364: CP#51 completed. SP#49 Stage 2 completed. Related to Rel-10 UID_470049 Study on S2b mobility based on GTP (TR23.834), UID_350027 SAE for support for non-3GPP accesses. Stage1 in Rel-8 UID_320022 Reqs for evolution of 3GPP system architecture (AIPN-SAE)
- 3365: SP#49 completed
- 3366: CP#51 Stage 3 completed
- 3367: CP#51 completed
- 3368: CP#51 completed
- 3369: CP#50 completed
- 3370: CP#51 completed. SP#50 Stage 2 completed. Triggered by the SA1,SA2 Rel-10 TR 23.813 Study on Policy solutions and enhancements (FS_PP) UID_440047. Provides Video Call seamless service continuity for 3G/LTE terminal user
- 3371: SP#51 updated WID SP-100702=>SP-110196. SP#49 work completed as SA2 CRs approved under TEI10 (SP-10557)
- 3372: CP#51 completed

| ID | WBS | Task | Duration | Start | Finish | Complete | Baseline start | Baseline finish | Baseline duration | Constraint | Resources | Work | Actual work | Acronym | PCG approved | WI rapporteur name | WI rapporteur e-mail | Release | TSG approved | MCC resp | Acronym_3GU_Export | PCG stopped | TSG stopped |
| --- | --- | --- | --- | --- | --- | --- | --- | --- | --- | --- | --- | --- | --- | --- | --- | --- | --- | --- | --- | --- | --- | --- | --- |
| 3373 | 875 | **Lawful Interception in the 3GPP Rel-10** | 315d? | 2010-03-25 A | 2011-06-08 A | 100% | 2010-03-25 | 2011-06-08 | 315d? |  | S3 | 20480h | 20480h | LI10 | 24 | PIDS, BT | Koen Jaspers (k.b.jaspers@minjus.nl), alex.leadbeater@bt.com | Rel-10 | 47 | Mirko | LI10 |  |  |
| 3374 | 875.1 | LI for CAT (Customer Alerting Tones) | 315d? | 2010-03-25 A | 2011-06-08 A | 100% | 2010-03-25 | 2011-06-08 | 315d? | finish no earlier than 2011-03-23 | S3 | 2520h | 2520h | LI10 | 24 | PIDS, BT | Koen Jaspers (k.b.jaspers@minjus.nl), alex.leadbeater@bt.com | Rel-10 | 47 | Mirko |  |  |  |
| 3375 | 875.2 | LI for CRS (Customized Ringing Signal) | 315d? | 2010-03-25 A | 2011-06-08 A | 100% | 2010-03-25 | 2011-06-08 | 315d? | finish no earlier than 2011-03-23 | S3 | 2520h | 2520h | LI10 | 24 | PIDS, BT | Koen Jaspers (k.b.jaspers@minjus.nl), alex.leadbeater@bt.com | Rel-10 | 47 | Mirko |  |  |  |
| 3376 | 875.3 | LI for EPS enhancements | 315d? | 2010-03-25 A | 2011-06-08 A | 100% | 2010-03-25 | 2011-06-08 | 315d? | finish no earlier than 2011-03-23 | S3 | 2520h | 2520h | LI10 | 24 | PIDS, BT | Koen Jaspers (k.b.jaspers@minjus.nl), alex.leadbeater@bt.com | Rel-10 | 47 | Mirko |  |  |  |
| 3377 | 875.4 | LI for VCC (Voice Call Continuity) | 260d? | 2010-03-25 A | 2011-03-23 A | 100% | 2010-03-25 | 2011-03-23 | 260d? | finish no earlier than 2011-03-23 | S3 | 2080h | 2080h | LI10 | 24 | PIDS, BT | Koen Jaspers (k.b.jaspers@minjus.nl), alex.leadbeater@bt.com | Rel-10 | 47 | Mirko |  |  |  |
| 3378 | 875.5 | LI for MEDIASEC (IMS Media security) | 260d? | 2010-03-25 A | 2011-03-23 A | 100% | 2010-03-25 | 2011-03-23 | 260d? | finish no earlier than 2011-03-23 | S3 | 2080h | 2080h | LI10 | 24 | PIDS, BT | Koen Jaspers (k.b.jaspers@minjus.nl), alex.leadbeater@bt.com | Rel-10 | 47 | Mirko |  |  |  |
| 3379 | 875.6 | LI for H(e)NB also with Local IP Access and Selected IP Traffic Offload (LIPA, SIPTO) | 260d? | 2010-03-25 A | 2011-03-23 A | 100% | 2010-03-25 | 2011-03-23 | 260d? | finish no earlier than 2011-03-23 | S3 | 2080h | 2080h | LI10 | 24 | PIDS, BT | Koen Jaspers (k.b.jaspers@minjus.nl), alex.leadbeater@bt.com | Rel-10 | 47 | Mirko |  |  |  |
| 3380 | 875.7 | LI for MBMS enhancements | 260d? | 2010-03-25 A | 2011-03-23 A | 100% | 2010-03-25 | 2011-03-23 | 260d? | finish no earlier than 2011-03-23 | S3 | 2080h | 2080h | LI10 | 24 | PIDS, BT | Koen Jaspers (k.b.jaspers@minjus.nl), alex.leadbeater@bt.com | Rel-10 | 47 | Mirko |  |  |  |
| 3381 | 875.8 | LI for LCLS (Local Call Local Switch) | 260d? | 2010-03-25 A | 2011-03-23 A | 100% | 2010-03-25 | 2011-03-23 | 260d? | finish no earlier than 2011-03-23 | S3 | 2080h | 2080h | LI10 | 24 | PIDS, BT | Koen Jaspers (k.b.jaspers@minjus.nl), alex.leadbeater@bt.com | Rel-10 | 47 | Mirko |  |  |  |
| 3382 | 876 | Optimization of IMS based PSS and MBMS User Service | 260d? | 2010-03-25 A | 2011-03-23 A | 100% | 2010-03-25 | 2011-03-23 | 260d? | finish no earlier than 2011-03-23 | S4 | 2080h | 2080h | OPT_IMS_PSS_MBMS_US | 24 | Ericsson | markus.kampmann@ericsson.com | Rel-10 | 47 | Paolo | OPT_IMS_PSS_MBMS_US |  |  |
| 3383 | 877 | **HTTP-based Streaming and Download Services** | 392d? | 2010-03-25 A | 2011-09-21 A | 100% | 2010-03-25 | 2011-09-21 | 392d? |  | S4; IETF | 10468.8h | 10468.8h | HTTP_SDS | 24 | Qualcomm | Thomas Stockhammer (c_tstock@qualcomm.com) | Rel-10 | 47 | Paolo | HTTP_SDS |  |  |
| 3384 | 877.1 | HTTP-based Streaming and Download Services in 3GPP | 315d? | 2010-03-25 A | 2011-06-08 A | 100% | 2010-03-25 | 2011-06-08 | 315d? | finish no earlier than 2011-05-26 | S4 | 2520h | 2520h | HTTP_SDS | 24 | Qualcomm | Thomas Stockhammer (c_tstock@qualcomm.com) | Rel-10 | 47 | Paolo |  |  |  |
| 3385 | 877.2 | (IETF) HTTP-based Streaming and Download Services in 3GPP | 211.6d? | 2010-03-25 A | 2011-09-21 A | 100% | 2010-03-25 | 2011-09-21 | 211.6d? | start no earlier than 2010-03-25 | S4-IETF | 1676.8h | 1676.8h | HTTP_SDS | 27 |  |  | Rel-10 | 52 | Paolo |  |  |  |
| 3386 | 878 | PSS and MBMS enhancements | 205d? | 2010-06-10 A | 2011-03-23 A | 100% | 2010-06-10 | 2011-03-23 | 205d? | finish no earlier than 2011-03-23 | S4 | 1640h | 1640h | MBS_Enh | 25 | Ericsson | Markus.Kampmann@ericsson.com | Rel-10 | 48 | Paolo | MBS_Enh |  |  |
| 3387 | 879 | Enhancements and Addition of Audio Tests to 26.131 and 26.132 | 260d? | 2010-06-10 A | 2011-06-08 A | 100% | 2010-06-10 | 2011-06-08 | 260d? | finish no earlier than 2011-06-08 | S4 | 2080h | 2080h | EAAT | 25 | Vodafone | ramin.afchar@vodafone.com | Rel-10 | 48 | Paolo | EAAT |  |  |
| 3388 | 880 | Video Coding Enhancements in MTSI | 3d? | 2011-03-21 A | 2011-03-23 A | 100% | 2011-03-21 | 2011-03-23 | 3d? | start no earlier than 2011-03-21 | S4 | 24h | 24h | VCEM | 26 | Ericsson | frederic.gabin@ericsson.com | Rel-10 | 51 | Paolo | VCEM |  |  |
| 3389 | 881 | **Rel-10 Operations, Administration, Maintenance and Provisioning (OAM&P)** | 467d? | 2009-12-10 A | 2011-09-21 A | 100% | 2009-12-10 | 2011-09-21 | 467d? |  | S5; C4 | 54144h | 54144h | OAM10 | 24 |  |  | Rel-10 | 46 | Mirko | OAM10 |  |  |
| 3390 | 881.1 | **Rel-10 Network Infrastructure Management** | 467d? | 2009-12-10 A | 2011-09-21 A | 100% | 2009-12-10 | 2011-09-21 | 467d? |  | S5 | 14592h | 14592h | OAM10-NIM | 24 |  |  | Rel-10 | 46 | Mirko | OAM10-NIM |  |  |
| 3391 | 881.1.1 | Common RAT Network Resource Model (NRM) | 390d? | 2009-12-10 A | 2011-06-08 A | 100% | 2009-12-10 | 2011-06-08 | 390d? | finish no earlier than 2011-06-08 | S5 | 3120h | 3120h | RAT_NRM_common | 24 | Ericsson | robert.petersen@ericsson.com | Rel-10 | 46 | Mirko | RAT_NRM_common |  |  |
| 3392 | 881.1.2 | IRP Solution Set specification organisation improvements | 260d? | 2010-03-25 A | 2011-03-23 A | 100% | 2010-03-25 | 2011-03-23 | 260d? | finish no earlier than 2011-03-23 | S5 | 2080h | 2080h | OAM-IRP-SS | 24 | Nokia Siemens Networks, Huawei | Jörg Schmidt (J.Schmidt@nsn.com), Lan Zou (zlan@huawei.com) | Rel-10 | 47 | Mirko | OAM-IRP-SS |  |  |
| 3393 | 881.1.3 | Deleted - Service Oriented Architecture (SOA) for IRP continuation from Rel-9 | 260d? | 2010-03-25 A | 2011-03-23 A | 100% | 2010-03-25 | 2011-03-23 | 260d? | finish no earlier than 2011-06-08 | S5 | 2080h | 2080h | OAM-SOA-IRP | 24 | Nokia Siemens Networks, Ericsson | Jörg Schmidt (J.Schmidt@NSN.com), edwin.tse@ericsson.com | Rel-10 | 47 | Mirko | OAM-SOA-IRP | PCG-26 | SP-51 |
| 3394 | 881.1.4 | IRP Overview, Profiles & Usage Guide | 260d? | 2010-06-10 A | 2011-06-08 A | 100% | 2010-06-10 | 2011-06-08 | 260d? | finish no earlier than 2011-06-08 | S5 | 2080h | 2080h | OAM-NIM-IRP_OPU | 25 | Nokia Siemens Networks | Jörg Schmidt (J.Schmidt@NSN.com) | Rel-10 | 48 | Mirko | OAM-NIM-IRP_OPU |  |  |
| 3395 | 881.1.5 | Alarm Correlation and Root Cause Analysis | 133d? | 2011-03-23 A | 2011-09-21 A | 100% | 2011-03-23 | 2011-09-21 | 133d? | finish no earlier than 2011-09-21 | S5 | 1048h | 1048h | OAM-AC-RCA | 26 | Ericsson | brendan.hassett@ericsson.com | Rel-10 | 51 | Mirko | OAM-AC-RCA |  |  |
| 3396 | 881.1.6 | Inventory Management Network Resource Model enhancements | 56d? | 2011-03-23 A | 2011-06-08 A | 100% | 2011-03-23 | 2011-06-08 | 56d? | start no earlier than 2011-03-23 | S5 | 448h | 448h | OAM-IM-NMR | 26 | Nokia Siemens Networks | olaf.pollakowski@nsn.com | Rel-10 | 51 | Mirko | OAM-IM-NMR |  |  |

Notes:
- 3373: SP#52 completed / Impacted TSs and TRs: 33.106 (LI requirements), 33.107 (LI architecture and functions), 33.108 (Handover interface for LI)
- 3374: SP#52 completed / Impacted TSs and TRs: 33.106, 33.107, 33.108
- 3375: SP#52 completed / Impacted TSs and TRs: 33.106, 33.107, 33.108
- 3376: SP#52 completed / Impacted TSs and TRs: 33.106, 33.107, 33.108
- 3377: SP#51 completed / Impacted TSs and TRs: 33.106, 33.107, 33.108
- 3378: SP#51 completed / Impacted TSs and TRs: 33.106, 33.107, 33.108
- 3379: SP#51 completed / Impacted TSs and TRs: 33.106, 33.107, 33.108
- 3380: SP#51 completed / Impacted TSs and TRs: 33.106, 33.107, 33.108
- 3381: SP#51 completed / Impacted TSs and TRs: 33.106, 33.107, 33.108
- 3382: SP#51 completed. Work to enhance UID_430046 Rel-9 IMS_PSS_MBMS_US_EXT / Impacted TSs and TRs: 26.237
- 3383: SP#52 completed. Work to enhance UID_430038 Rel-9 PSS and MBMS extensions
- 3384: SP#52 completed / Impacted TSs and TRs: 26.234, 26.244, 26.346, new TS 26.247
- 3385: SP#53/IETF#81: Draft not included in 3GPP documentation. Dec.14: IETF RFC added / Impacted TSs and TRs: RFC 6381 (was draft-gellens-mime-bucket-bis)
- 3386: SP#51 completed. Linked to Rel-9 Feature UID_430038 PSS and MBMS extensions (PMA-MBS_Ext). / Impacted TSs and TRs: 26.234, 26.346
- 3387: SP#52 completed. Reduce fragmentation in acoustic testing (3GPP SA4, ETSI STQ, GCF CAG, CTIA) & Review existing acoustic tests to determine need for new spec / Impacted TSs and TRs: 26.131, 26.132
- 3388: SP#51 completed. Linked to Rel-7 UID_7040 Multimedia Telephony Service for IMS - Media handling and interaction in MTSI (MTSI-MHI) / Impacted TSs and TRs: 26.114
- 3389: OAM10 is an umbrella Feature also for OAM&P related TEI10 type of changes that are not part of any other dedicated feature/WI / Impacted TSs and TRs: TR 30.820
- 3390: umbrella BB
- 3391: SP#52 completed. Share equipment btw several RATs (RET,TMA,repeaters) to reduce costs. With existing modelling is difficult to see that several cells are affected when an antenna tilt is changed etc / Impacted TSs and TRs: 32.616, 32.642, 32.646, 32.652, 32.656, 32.762, 32.766 new (32.791, 32.792, 32.796)
- 3392: SP#51 completed / Impacted TSs and TRs: 32.153, new (32.111-6,32.126,32.176,32.306,32.316,32.326,32.336,32.346,32.356,32.366,32.376,32.386,32.396,32.416,32.446,32.506/26/36,32.606,32.616,32.626,32.636,32.646,32.656,32.666,32.676,32.696,32.716,32.726,32.736,32.746,32.756,32.766,32.776,32.786)
- 3393: SP#51 work stopped (Reason: lack of progress). Continuation of Rel-9 UID_440065 SOA for IRP (covering SOA Architecture & SOA-supporting Solution Set) to address SOA conforming Registration & Discovery capabilities / Impacted TSs and TRs: 32.101, 32.150
- 3394: SP#52 completed. Updated WID SP-100777=>SP-110277 / Impacted TSs and TRs: new TS 32.103
- 3395: SP#53 completed. Triggered by Rel-10 TR 32.832 Study on Alarm Correlation and Alarm Root Cause Analysis UID_480045 & TR 32.829 Study on Harmonization of 3GPP Alarm IRP and TMF Interface Program Fault Management UID_460038 / Impacted TSs and TRs: 32.111-1, 32.111-2, 32.111-6
- 3396: SP#52 completed. Inventory NRM specified in Rel-6 is mainly hardware related. Rel-10 TR 32.828 recommends extending the scope of inventory NRM. Additionally, NGMN Top OPE Recs, v1.0 sets inventory enhancements as one of top 10 priority items / Impacted TSs and TRs: 32.690, 32.691, 32.692, 32.696

| ID | WBS | Task | Duration | Start | Finish | Complete | Baseline start | Baseline finish | Baseline duration | Constraint | Resources | Work | Actual work | Acronym | PCG approved | Release | TSG approved | MCC resp | Special Focus Doc | Acronym_3GU_Export | WI rapporteur name |
| --- | --- | --- | --- | --- | --- | --- | --- | --- | --- | --- | --- | --- | --- | --- | --- | --- | --- | --- | --- | --- | --- |
| 3397 | 881.2 | **Rel-10 Self-Organizing Networks (SON) - OAM aspects** | 390d? | 2009-12-10 A | 2011-06-08 A | 100% | 2009-12-10 | 2011-06-08 | 390d? |  | S5 | 11000h | 11000h | OAM10-SON | 24 | Rel-10 | 46 | Mirko | SON | OAM10-SON |  |
| 3398 | 881.2.1 | SON Self-optimization management continuation | 390d? | 2009-12-10 A | 2011-06-08 A | 100% | 2009-12-10 | 2011-06-08 | 390d? | finish no earlier than 2011-03-23 | S5 | 3120h | 3120h | LTE-SON-OAM_SO | 24 | Rel-10 | 46 | Mirko | SON | LTE-SON-OAM_SO | Huawei |
| 3399 | 881.2.2 | SON Self-healing management | 335d? | 2009-12-10 A | 2011-03-23 A | 100% | 2009-12-10 | 2011-03-23 | 335d? | finish no earlier than 2011-03-23 | S5 | 2680h | 2680h | LTE-SON-OAM_SH | 24 | Rel-10 | 46 | Mirko | SON | LTE-SON-OAM_SH | ZTE |
| 3400 | 881.2.3 | OAM aspects of Energy Saving in Radio Networks | 260d? | 2010-03-25 A | 2011-03-23 A | 100% | 2010-03-25 | 2011-03-23 | 260d? | finish no earlier than 2011-03-23 | S5 | 2080h | 2080h | OAM-ES | 24 | Rel-10 | 47 | Mirko | SON | OAM-ES | Nokia Siemens Networks |
| 3401 | 881.3 | Rel-10 Subscription Management (SuM) evolution | 260d? | 2010-03-25 A | 2011-03-23 A | 100% | 2010-03-25 | 2011-03-23 | 260d? | finish no earlier than 2011-03-23 | S5 | 2080h | 2080h | OAM10-SuM | 24 | Rel-10 | 47 | Mirko |  | OAM10-SuM | Ericsson |
| 3402 | 881.4 | **Rel-10 Performance Management** | 315d? | 2010-03-25 A | 2011-06-08 A | 100% | 2010-03-25 | 2011-06-08 | 315d? |  | S5; C4 | 19000h | 19000h |  | 24 | Rel-10 | 47 | Mirko |  |  |  |
| 3403 | 881.4.1 | Key Performance Indicators (KPIs) for IMS | 260d? | 2010-03-25 A | 2011-03-23 A | 100% | 2010-03-25 | 2011-03-23 | 260d? | finish no earlier than 2011-03-23 | S5 | 2080h | 2080h | OAM-PM-KPI_IMS | 24 | Rel-10 | 47 | Mirko |  | OAM-PM-KPI_IMS | China Mobile |
| 3404 | 881.4.2 | Key Performance Indicators (KPIs) for EPC | 260d? | 2010-03-25 A | 2011-03-23 A | 100% | 2010-03-25 | 2011-03-23 | 260d? | finish no earlier than 2011-03-23 | S5 | 2080h | 2080h | OAM-PM-KPI_EPC | 24 | Rel-10 | 47 | Mirko |  | OAM-PM-KPI_EPC | China Mobile |
| 3405 | 881.4.3 | **Management of UE based network performance measurements** | 315d? | 2010-03-25 A | 2011-06-08 A | 100% | 2010-03-25 | 2011-06-08 | 315d? |  | S5; C4 | 7720h | 7720h | OAM-PM-UE | 24 | Rel-10 | 47 | Mirko |  | OAM-PM-UE | Huawei, Nokia Siemens Networks, Ericsson |
| 3406 | 881.4.3.1 | SA5 aspects of Management of UE based network performance measurements | 315d? | 2010-03-25 A | 2011-06-08 A | 100% | 2010-03-25 | 2011-06-08 | 315d? | finish no earlier than 2011-06-08 | S5 | 2520h | 2520h |  | 24 | Rel-10 | 47 | Mirko |  |  | Huawei, Nokia Siemens Networks, Ericsson |
| 3407 | 881.4.3.2 | CN aspects of Management of UE based network performance measurements | 20d? | 2011-02-21 A | 2011-03-18 A | 100% | 2011-02-21 | 2011-03-18 | 20d? | start no earlier than 2011-02-21 | C4 | 160h | 160h |  | 26 | Rel-10 | 51 | Kimmo |  |  | Nokia Siemens Networks |
| 3408 | 881.4.4 | 3G HNB and LTE HeNB Subsystem performance measurements | 260d? | 2010-03-25 A | 2011-03-23 A | 100% | 2010-03-25 | 2011-03-23 | 260d? | finish no earlier than 2011-03-23 | S5 | 2080h | 2080h | OAM-PM-HeNS | 24 | Rel-10 | 47 | Mirko | HNB | OAM-PM-HeNS | China Mobile |
| 3409 | 882 | **Rel-10 Charging Management small Enhancements** | 470d? | 2009-06-04 A | 2011-03-23 A | 100% | 2009-06-04 | 2011-03-23 | 470d? |  | S5 | 7520h | 7520h | CH10 | 24 | Rel-10 | 47 | Mirko | WLAN | CH10 |  |
| 3410 | 882.1 | IWLAN mobility charging | 470d? | 2009-06-04 A | 2011-03-23 A | 100% | 2009-06-04 | 2011-03-23 | 470d? | finish no earlier than 2011-03-23 | S5 | 3760h | 3760h | eIWLAN_Mob | 23 | Rel-10 | 44 | Mirko | WLAN | eIWLAN_Mob | Orange |
| 3411 | 883 | **Advice of Charge (AoC) service support enhancements** | 312d? | 2010-03-25 A | 2011-06-03 A | 100% | 2010-03-25 | 2011-06-03 | 312d? |  | S5; C1 | 8560h | 8560h | eAoC | 24 | Rel-10 | 47 | Mirko |  | eAoC | Deutsche Telekom |
| 3412 | 883.1 | SA5 part - AoC enhancements | 260d? | 2010-03-25 A | 2011-03-23 A | 100% | 2010-03-25 | 2011-03-23 | 260d? | finish no earlier than 2011-03-23 | S5 | 2080h | 2080h | eAoC | 24 | Rel-10 | 47 | Mirko |  |  | Deutsche Telekom |
| 3413 | 883.2 | CT1 part - AoC enhancements (Stage 3) | 186d? | 2010-09-17 A | 2011-06-03 A | 100% | 2010-09-17 | 2011-06-03 | 186d? | finish no earlier than 2011-06-03 | C1 | 1488h | 1488h | eAoC | 25 | Rel-10 | 49 | Frederic |  |  | Deutsche Telekom |
| 3414 | 884 | IMS Stage 3 IETF Protocol Alignment - phase 4 | 261d? | 2010-03-19 A | 2011-03-18 A | 100% | 2010-03-19 | 2011-03-18 | 261d? | finish no earlier than 2011-03-18 | C1 | 2088h | 2088h | IMSProtoc4 | 24 | Rel-10 | 47 | Frederic |  | IMSProtoc4 | Alcatel-Lucent |
| 3415 | 885 | Enhanced User Data Convergence (UDC) Model | 206d? | 2010-06-04 A | 2011-03-18 A | 100% | 2010-06-04 | 2011-03-18 | 206d? | finish no earlier than 2011-03-18 | C4 | 1648h | 1648h | eUDC | 25 | Rel-10 | 48 | Kimmo |  | eUDC | China Mobile |
| 3416 | 886 | **Further improvements of II-NNI Stage 3 based on operational feedback and evolution of other specifications** | 724d? | 2010-06-04 A | 2013-03-01 A | 100% | 2010-06-04 | 2013-03-01 | 724d? |  | C3 | 10625.9h | 10625.9h | II-NNI2 | 25 | Rel-10 | 48 | Adrian |  | II-NNI2 | Orange |
| 3417 | 886.1 | Further improvements of II-NNI Stage 3 | 206d? | 2010-06-04 A | 2011-03-18 A | 100% | 2010-06-04 | 2011-03-18 | 206d? | start no earlier than 2010-06-04 | C3 | 1648h | 1648h | II-NNI2 | 25 | Rel-10 | 48 | Adrian |  |  | Orange |
| 3418 | 886.2 | (IETF) Further improvements of II-NNI Stage 3 (RFC 6794) | 230d? | 2012-04-20 A | 2013-03-01 A | 100% | 2012-04-20 | 2013-03-01 | 230d? | finish no earlier than 2013-03-01 | C3-IETF | 1832h | 1832h | II-NNI2 | 29 | Rel-10 | 56 | Adrian |  |  | Lionel Morand |
| 3419 | 886.3 | (IETF) Further improvements of II-NNI Stage 3 (RFC 6809) | 170d? | 2012-04-20 A | 2012-12-07 A | 100% | 2012-04-20 | 2012-12-07 | 170d? | finish no earlier than 2012-12-04 | C3-IETF | 1353.89h | 1353.89h | II-NNI2 | 29 | Rel-10 | 56 | Adrian |  |  | christer.holmberg@ericsson.com |
| 3420 | 887 | AT Commands for IMS-configuration | 206d? | 2010-06-04 A | 2011-03-18 A | 100% | 2010-06-04 | 2011-03-18 | 206d? |  | C1 | 1648h | 1648h | AT_IMS | 25 | Rel-10 | 48 | Frederic |  | AT_IMS | Ericsson |
| 3421 | 888 | AT Commands for USIM Application Toolkit (USAT) | 131d? | 2010-09-17 A | 2011-03-18 A | 100% | 2010-09-17 | 2011-03-18 | 131d? |  | C1 | 52.4h | 52.4h | AT_UICC | 25 | Rel-10 | 49 | Frederic |  | AT_UICC | ST-Ericsson |
| 3422 | 889 | Communication Control for IMS by USIM (Stage 3) | 131d? | 2010-09-17 A | 2011-03-18 A | 100% | 2010-09-17 | 2011-03-18 | 131d? | start no earlier than 2010-09-17 | C6 | 1048h | 1048h | CC_IMS_USIM | 25 | Rel-10 | 49 | Xavier |  | CC_IMS_USIM | Gemalto |
| 3423 | 890 | Dynamic view of SIP message for Inter-IMS Network to Network Interface (II-NNI) (Stage 3) | 126d? | 2010-12-10 A | 2011-06-03 A | 100% | 2010-12-10 | 2011-06-03 | 126d? | finish no earlier than 2011-06-03 | C3 | 1008h | 1008h | NNI_DV | 26 | Rel-10 | 50 | Adrian |  | NNI_DV | NTT |
| 3424 | 891 | Introduction of Smart Card Web Server launch functionality | 71d? | 2010-12-10 A | 2011-03-18 A | 100% | 2010-12-10 | 2011-03-18 | 71d? | finish no earlier than 2011-03-18 | C6 | 568h | 568h | SCWS_L | 26 | Rel-10 | 50 | Xavier |  | SCWS_L | Telecom Italia |
| 3425 | 892 | USAT using AT Commands | 71d? | 2010-12-10 A | 2011-03-18 A | 100% | 2010-12-10 | 2011-03-18 | 71d? | finish no earlier than 2011-03-18 | C6 | 568h | 568h | USAT_AT | 26 | Rel-10 | 50 | Xavier |  | USAT_AT | Giesecke & Devrient |

Notes:
- 3397: umbrella BB
- 3398: SP#52 completed. Cont'd Rel-9 SON self-optimization management UID_390007 / Impacted TSs and TRs: 32.425, 32.521, 32.522, 32.526, 32.762, 32.766 / WI rapporteur e-mail: Lan Zou (zlan@huawei.com)
- 3399: SP#51 completed. WID updated SP-100776=>SP-110150. Work moved to Rel-10 after split of the Rel-9 UID_390007 SON self-optimization (removed Self-Healing handling) / Impacted TSs and TRs: 32.522, 32.526, 32.762, 32.766, new TS 32.541 / WI rapporteur e-mail: zhu.weihong@zte.com.cn
- 3400: SP#51 completed. WID updated SP-100226=>SP-110128. Triggered by Rel-10 TR 32.826 Study on Telecommunication Management; Energy Savings Management (FS_OAM_ESM) UID_430044 / Impacted TSs and TRs: 32.425, 32.522, 32.526, 32.626, 32.762, 32.766, new TS 32.551 / WI rapporteur e-mail: clemens.suerbaum@nsn.com
- 3401: SP#51 completed / Impacted TSs and TRs: 32.172, 32.175, 32.176 / WI rapporteur e-mail: leo.yang@ericsson.com
- 3402: umbrella BB
- 3403: SP#51 completed / Impacted TSs and TRs: new 32.454 / WI rapporteur e-mail: Li Jian (lijian@chinamobile.com), Liang Shuangchun (liangshuangchun@cmdi.chinamobile.com)
- 3404: SP#51 completed / Impacted TSs and TRs: new 32.455 / WI rapporteur e-mail: Li Jian (lijian@chinamobile.com), Liang Shuangchun (liangshuangchun@cmdi.chinamobile.com)
- 3405: SP#52 completed. Stage 2/3. Linked to UID_460003 Minimization of drive tests for E-UTRAN and UTRAN (MDT_UMTSLTE) / WI rapporteur e-mail: Zou Lan (zlan@huawei.com), gyula.bodog@nsn.com, ulf.hubinette@ericsson.com
- 3406: SP#52 completed / Impacted TSs and TRs: 32.421, 32.422, 32.423, 32.441, 32.442, 32.446 / WI rapporteur e-mail: Zou Lan (zlan@huawei.com), gyula.bodog@nsn.com, ulf.hubinette@ericsson.com
- 3407: CP#51 completed under the SA5 WI code / Impacted TSs and TRs: 23.008 (CR#0330), 29.002 (CR#1007), 29.230 (CR#0207), 29.272 (CR#0329) / WI rapporteur e-mail: ulrich.wiehe@nsn.com
- 3408: SP#51 completed / Impacted TSs and TRs: 32.582, 32.592, new (32.452, 32.453) / WI rapporteur e-mail: Chen Gang (chengang@chinamobile.com)
- 3409: CH10 is an umbrella Feature also for OAM&P related TEI10 type of changes that are not part of any other dedicated feature/WI / Impacted TSs and TRs: TR 30.820
- 3410: SP#51 completed. RAT differentiation for charging. Completes Rel-8 Feature IWLAN_Mob UID_370049 Mobility between 3GPP-WLAN Interworking and 3GPP Systems. Cooperation with CT1,CT3 on affected protocols / Impacted TSs and TRs: 32.240, 32.252, 32.298, 32.299 / WI rapporteur e-mail: Jean-Luc Garcia (jl.garcia@orange-ftgroup.com)
- 3411: CP#52 completed. SP#51 completed SA5. Continuation of Rel-8 BB UID_80042: Advice of Charge (AoC) support in IMS Charging (IMSTSS). Stage 2/3 work / WI rapporteur e-mail: matthias.seibel@telekom.de
- 3412: SP#51 completed. SA1 Stage 1 in 22.115 / Impacted TSs and TRs: 32.275, 32.280, 32.298, 32.299 / WI rapporteur e-mail: matthias.seibel@telekom.de
- 3413: CP#52 completed. SA1 Stage 1 in 22.115, 22.173, 22.024. Add mobile-specific CAI format and volume charging elements. Extensions to existing AoC XML / Impacted TSs and TRs: 24.647 / WI rapporteur e-mail: reinhard.lauster@t-mobile.at
- 3414: CP#51 completed. Ensure protocol alignment between 3GPP Stage 3 IMS work and IETF. Review capabilities provided in SIP by IETF and document whether these capabilities are supported in the IM CN Subsystem or not / Impacted TSs and TRs: 23.218, 24.229, 24.930 / WI rapporteur e-mail: keith.drage@alcatel-lucent.com
- 3415: CP#51 completed. Specify CRUD (Create/Read/Update/Delete) operations based on SOAP protocol, which may be used by the applications having no high real-time requirement to the data access operations / Impacted TSs and TRs: 29.335 / WI rapporteur e-mail: Lan Sizhong (lansizhong@chinamobile.com)
- 3416: Improvements of Rel-9 Feature UID_440027 Operational description of the Inter-IMS Network to Network Interface (II-NNI) / WI rapporteur e-mail: beata.dobrowolska@orange-ftgroup.com
- 3417: CP#51 completed / Impacted TSs and TRs: 29.165 / WI rapporteur e-mail: beata.dobrowolska@orange-ftgroup.com
- 3418: CP#59 completed AUTH 48 RFC-to-be-6794 / Impacted TSs and TRs: RFC 6794 (was draft-ietf-sip-session-policy-framework) / WI rapporteur e-mail: Lionel Morand
- 3419: CP#58 completed / Impacted TSs and TRs: RFC 6809 (was draft-ietf-sipcore-proxy-feature) / WI rapporteur e-mail: Christer Holmberg
- 3420: CP#51 completed. Specify 1) IMS-related AT-commands to configure MT and 2) IMS-related unsolicited response codes from MT to present to end-user / Impacted TSs and TRs: 27.007 / WI rapporteur e-mail: atle.monrad@ericsson.com
- 3421: CP#51 completed / Impacted TSs and TRs: 27.007 / WI rapporteur e-mail: magnus.mk.karlsson@stericsson.com
- 3422: CP#51 completed. Stage 1 in TS 22.038 USAT service description. Linked to CT6's UID_1273 Rel-5 BB Provisioning of IP-based multimedia services (24.229, 31.103) and UID_390021 Rel-8 BB CT6 aspects of SAE (31.102, 31.111) / Impacted TSs and TRs: 31.102, 31.103, 31.111 / WI rapporteur e-mail: Denis.Lheriteau@gemalto.com
- 3423: CP#52 completed. Linked to CT3 Rel-10 Feature UID_480014 Further improvements of II-NNI Stage 3 based on operational feedback and evolution of other specifications (II-NNI2) / Impacted TSs and TRs: 29.165 / WI rapporteur e-mail: arai.kenjiro@lab.ntt.co.jp
- 3424: CP#51 completed. Define a solution which allows enabling to launch Smart Card Web Server servicES in CP-150an easy and simple manner / Impacted TSs and TRs: 31.102 / WI rapporteur e-mail: davide.pratone@telecomitalia.it
- 3425: CP#51 completed. Stage 3 based on SA1 22.038CR#37r1 (Make USAT proactive capability reqs applicable to ME as a whole without regard to any particular configuration; e.g. a modem connected to an external display) / Impacted TSs and TRs: Stage 3 31.102, 31.111 / WI rapporteur e-mail: enric.fort@gi-de.com

| ID | WBS | Task | Type | Duration | Start | Finish | Complete | Baseline start | Baseline finish | Baseline duration | Constraint | Resources | Work | Actual work | Acronym | PCG approved | WI rapporteur name | WI rapporteur e-mail | Release | TSG approved | MCC resp | Acronym_3GU_Export | Status Report | Special Focus Doc | PCG stopped | TSG stopped |
| --- | --- | --- | --- | --- | --- | --- | --- | --- | --- | --- | --- | --- | --- | --- | --- | --- | --- | --- | --- | --- | --- | --- | --- | --- | --- | --- |
| 3426 | 893 | **Single Radio Voice Call Continuity (SRVCC) enhancements (Stage 3)** |  | 528d? | 2010-12-10 A | 2012-12-07 A | 100% | 2010-12-10 | 2012-12-07 | 528d? |  | C1; C4; IETF | 17295.4h | 17295.4h | eSRVCC | 26 | China Mobile | Jiang Y (jiangyi@chinamobile.com) | Rel-10 | 50 | Frederic | eSRVCC |  |  |  |  |
| 3427 | 893.1 | CT1 part of Stage 3 for SRVCC enhancements |  | 71d? | 2010-12-10 A | 2011-03-18 A | 100% | 2010-12-10 | 2011-03-18 | 71d? | finish no earlier than 2011-03-18 | C1 | 568h | 568h | eSRVCC | 26 | China Mobile | Jiang Y (jiangyi@chinamobile.com) | Rel-10 | 50 | Frederic |  |  |  |  |  |
| 3428 | 893.2 | CT4 part of Stage 3 for SRVCC enhancements |  | 71d? | 2010-12-10 A | 2011-03-18 A | 100% | 2010-12-10 | 2011-03-18 | 71d? | finish no earlier than 2011-03-18 | C4 | 568h | 568h | eSRVCC | 26 | China Mobile | Jiang Y (jiangyi@chinamobile.com) | Rel-10 | 50 | Kimmo |  |  |  |  |  |
| 3429 | 893.3 | (IETF) CT1 part of Stage 3 for SRVCC enhancements (RFC 6809) |  | 436.8d? | 2010-12-10 A | 2012-12-07 A | 100% | 2010-12-10 | 2012-12-07 | 436.8d? | finish no earlier than 2013-03-01 | C1-IETF | 3487.38h | 3487.38h | eSRVCC | 27 | christer.holmberg@ericsson.com | christer.holmberg@ericsson.com | Rel-10 | 52 | Frederic |  |  |  |  |  |
| 3430 | 894 | **Single Radio Voice Call Continuity (SRVCC) in alerting phase (Stage 3)** |  | 589d? | 2010-12-10 A | 2013-03-01 A | 100% | 2010-12-10 | 2013-03-01 | 589d? |  | C1; R5 | 11440h | 11440h | aSRVCC | 26 | ZTE | li.shitao@zte.com.cn | Rel-10 | 50 | Frederic | aSRVCC |  |  |  |  |
| 3431 | 894.1 | CT aspects of Single Radio Voice Call Continuity (SRVCC) in alerting phase (Stage 3) |  | 126d? | 2010-12-10 A | 2011-06-03 A | 100% | 2010-12-10 | 2011-06-03 | 126d? | finish no earlier than 2011-06-03 | C1 | 1008h | 1008h | aSRVCC | 26 | ZTE | li.shitao@zte.com.cn | Rel-10 | 50 | Frederic |  |  |  |  |  |
| 3432 | 894.2 | Conformance test aspects SRVCC in alerting phase |  | 126d? | 2012-09-11 A | 2013-03-01 A | 100% | 2012-09-11 | 2013-03-01 | 126d? | finish no earlier than 2013-03-01 | R5 | 1008h | 1008h | aSRVCC-UEConTest | 29 | NTT DoCoMo | Takao.Shimizu.rp@nttdocomo.com | Rel-10 | 57 | Ingbert | aSRVCC-UEConTest | RP-130042 |  |  |  |
| 3433 | 895 | **PCRF failure and restoration** |  | 71d? | 2010-12-10 A | 2011-03-18 A | 100% | 2010-12-10 | 2011-03-18 | 71d? |  | C4; C3 | 2130h | 2130h | PCRF_FR | 26 | NEC | Toshiyuki Tamura (tamurato@aj.jp.nec.com) | Rel-10 | 50 | Kimmo | PCRF_FR |  |  |  |  |
| 3434 | 895.1 | CT4 part of PCRF failure and restoration |  | 71d? | 2010-12-10 A | 2011-03-18 A | 100% | 2010-12-10 | 2011-03-18 | 71d? | finish no earlier than 2011-03-18 | C4 | 568h | 568h | PCRF_FR | 26 | NEC | Toshiyuki Tamura (tamurato@aj.jp.nec.com) | Rel-10 | 50 | Kimmo |  |  |  |  |  |
| 3435 | 895.2 | CT3 part of PCRF failure and restoration |  | 53.25d? | 2010-12-10 A | 2011-03-18 A | 100% | 2010-12-10 | 2011-03-18 | 53.25d? | start no earlier than 2010-12-10 | C3 | 426h | 426h | PCRF_FR | 26 | NEC | Toshiyuki Tamura (tamurato@aj.jp.nec.com) | Rel-10 | 50 | Adrian |  |  |  |  |  |
| 3436 | 896 | Formalization of WLAN Files | milestone | 0d? | 2011-02-23 A | 2011-03-18 A | 100% | 2011-02-23 | 2011-03-18 | 0d? | start no earlier than 2011-03-16 | C1 |  |  | FoWF | 26 | Deutsche Telekom | dieter.jacobsohn@telekom.de | Rel-10 | 51 | Frederic | FoWF |  | WLAN |  |  |
| 3437 | 897 | CS and IMS Interworking for CAT service - Early Session model |  | 58d? | 2011-03-16 A | 2011-06-03 A | 100% | 2011-03-16 | 2011-06-03 | 58d? |  | C3 | 464h | 464h | CIIC_ES | 26 | ZTE | li.shitao@zte.com.cn | Rel-10 | 51 | Adrian | CIIC_ES |  |  |  |  |
| 3438 | 898 | EPC Node Restoration without Idle mode Signalling Reduction (ISR) activated |  | 3d? | 2011-03-16 A | 2011-03-18 A | 100% | 2011-03-16 | 2011-03-18 | 3d? | finish no earlier than 2011-03-18 | C4 | 24h | 24h | EPC_NR | 26 | Alcatel-Lucent | bruno.landais@alcatel-lucent.com | Rel-10 | 51 | Kimmo | EPC_NR |  |  |  |  |
| 3439 | 899 | EPC Node Restoration with Idle mode Signalling Reduction (ISR) activated |  | 58d? | 2011-03-16 A | 2011-06-03 A | 100% | 2011-03-16 | 2011-06-03 | 58d? | finish no earlier than 2011-03-18 | C4 | 464h | 464h | EPC_NR_ISR | 26 | NEC | Toshiyuki Tamura (tamurato@aj.jp.nec.com) | Rel-10 | 51 | Kimmo | EPC_NR_ISR |  |  |  |  |
| 3440 | 900 | Mobile Terminating Roaming Forwarding with pre-paging |  | 58d? | 2011-03-16 A | 2011-06-03 A | 100% | 2011-03-16 | 2011-06-03 | 58d? | finish no earlier than 2011-03-18 | C4 | 464h | 464h | MTRF | 26 | Ericsson | philip.hodges@ericsson.com | Rel-10 | 51 | Kimmo | MTRF |  |  |  |  |
| 3441 | 901 | **UICC access to IMS Specification** |  | 58d? | 2011-03-16 A | 2011-06-03 A | 100% | 2011-03-16 | 2011-06-03 | 58d? |  | C6; C1 | 1416h | 1416h | IMS-UICC-S | 26 | Gemalto | Denis.Lheriteau@gemalto.com | Rel-10 | 51 | Xavier | IMS-UICC-S |  |  |  |  |
| 3442 | 901.1 | CT6 part of UICC access to IMS Specification |  | 3d? | 2011-03-16 A | 2011-03-18 A | 100% | 2011-03-16 | 2011-03-18 | 3d? | start no earlier than 2011-03-16 | C6 | 24h | 24h | IMS-UICC-S | 26 | Gemalto | Denis.Lheriteau@gemalto.com | Rel-10 | 51 | Xavier |  |  |  |  |  |
| 3443 | 901.2 | CT1 part of UICC access to IMS Specification |  | 58d? | 2011-03-16 A | 2011-06-03 A | 100% | 2011-03-16 | 2011-06-03 | 58d? | start no earlier than 2011-03-16 | C1 | 464h | 464h | IMS-UICC-S | 26 | Gemalto | Denis.Lheriteau@gemalto.com | Rel-10 | 51 | Frederic |  |  |  |  |  |
| 3444 | 902 | Deleted - Testing for Terminal support of Rel-10 USIM, ISIM and USAT features |  | 463d? | 2012-03-05 A | 2013-12-03 A | 100% | 2012-03-05 | 2013-12-03 | 463d? | finish no earlier than 2013-06-14 | C6 | 3704h | 3704h | USIM_R10_Test | 28 | Gemalto | Denis.Praca@gemalto.com | Rel-10 | 55 | Xavier | USIM_R10_Test |  |  | PCG-32 | CP-62 |
| 3445 | 903 | **CN aspects of Local Call Local Switch** |  | 472d? | 2009-05-29 A | 2011-03-18 A | 100% | 2009-05-29 | 2011-03-18 | 472d? |  | C4 | 13008h | 13008h | LCLS-CN | 23 | Vodafone | David.Hutton@vodafone.com | Rel-10 | 44 | Kimmo | LCLS-CN |  |  |  |  |
| 3446 | 903.1 | TR on CN aspects of Local Call Local Switch |  | 341d? | 2009-05-29 A | 2010-09-16 A | 100% | 2009-05-29 | 2010-09-16 | 341d? | finish no earlier than 2010-09-17 | C4 | 2728h | 2728h | LCLS-CN | 23 | Vodafone | David.Hutton@vodafone.com | Rel-10 | 44 | Kimmo |  |  |  |  |  |
| 3447 | 903.2 | Stage 2/3 for CN aspects of Local Call Local Switch |  | 131d? | 2010-09-17 A | 2011-03-18 A | 100% | 2010-09-17 | 2011-03-18 | 131d? | finish no earlier than 2011-03-18 | C4 | 1048h | 1048h | LCLS-CN | 25 | Vodafone | David.Hutton@vodafone.com | Rel-10 | 49 | Kimmo |  |  |  |  |  |
| 3448 | 903.3 | Deleted - CT3 aspects of Local Call Local Switch |  | 341d? | 2009-05-29 A | 2010-09-16 A | 100% | 2009-05-29 | 2010-09-16 | 341d? | finish no earlier than 2010-09-17 | C3 | 2728h | 2728h | LCLS-CN | 23 | Vodafone | David.Hutton@vodafone.com | Rel-10 | 44 | Adrian |  |  |  | PCG-25 | CP-49 |
| 3449 | 903.4 | Deleted - CT1 aspects of Local Call Local Switch |  | 341d? | 2009-05-29 A | 2010-09-16 A | 100% | 2009-05-29 | 2010-09-16 | 341d? | finish no earlier than 2010-09-17 | C1 | 2728h | 2728h | LCLS-CN | 23 | Vodafone | David.Hutton@vodafone.com | Rel-10 | 44 | Frederic |  |  |  | PCG-25 | CP-49 |
| 3450 | 904 | Local Call Local Switch | milestone | 0d? | 2007-05-07 A | 2007-05-07 A | 100% | 2007-05-07 | 2011-05-20 | 1055.8d? |  | GP; G2 |  |  | LCLS | 22 | Huawei | wang_zhixi@huawei.com | Rel-10 | 41 | Paolo | LCLS |  |  |  |  |

Notes:
- 3426: Triggered by SA2 TR 23.856 Study on Single Radio Voice Call Continuity enhancements (FS_eSRVCC) UID_440049
- 3427: CP#51 completed / Impacted TSs and TRs: 24.229, 24.237
- 3428: CP#51 completed / Impacted TSs and TRs: 23.003, 23.008, 29.002, 29.230, 29.272, 29.305, 29.328, 29.329
- 3429: CP#58 completed / Impacted TSs and TRs: RFC 6809 (was draft-ietf-sipcore-proxy-feature)
- 3430: Builds on Rel-8 UID_390057 (IMS-Cont) TS 23.216 Stage 2. Provide Stage 3 for SRVCC PS-CS transfer of a call in alerting phase. Stage 2 TEI10 in TS 23.237 (6.3.2.1.4c/d, 6.3.2.1.7a/b)
- 3431: CP#52 completed / Impacted TSs and TRs: 24.008, 24.237
- 3432: RP#59 completed / Impacted TSs and TRs: 36.523-1, 36.523-2, 36.523-3, 34.229-1, 34.229-2, 34.229-3
- 3433: CP#51 completed. Triggered by CT3 TR 29.816 Study on Policy and Charging Rules Function (PCRF) failure and restoration (FS_PCRF-FR) UID_450013 / Impacted TSs and TRs: Stage 2/3 work
- 3434: CP#51 completed / Impacted TSs and TRs: Stage 2 23.007, Stage 3 29.230
- 3435: CP#51 completed / Impacted TSs and TRs: Stage 3 29.212, 29.213, 29.214, 29.215
- 3436: CP#51 completed. TS 24.235 for Info+Approval. Define the ME files as specified in 24.234 in OMA Device Management structure / Impacted TSs and TRs: Stage 3: 24.234, New 24.235
- 3437: CP#52 completed. Stage 1 in Rel-8 TS 22.182 Customized Alerting Tones (CAT) service. Stage 3 TS 24.182 defines 3 impl models: Gateway, Forking, Early Session. Specify missing CAT service interworking procedures btw CS & IMS networks / Impacted TSs and TRs: Stage 3 29.163, 29.235, 29.292
- 3438: CP#51 completed. Triggered by DRAFT TR 23.857 Study on EPC Nodes Restoration (FS_EPC_NR) UID_490014 / Impacted TSs and TRs: Stage 2/3: 23.007, 29.274
- 3439: CP#52 completed. Triggered by DRAFT TR 23.857 Study on EPC Nodes Restoration (FS_EPC_NR) UID_490014 / Impacted TSs and TRs: Stage 2/3: 23.007, 29.274
- 3440: CP#52 completed. Provides Stage 2/3 alternative solution to Mobile Terminating Roaming Retry to solve roaming events during paging, in particular to support CSFB. Hence, no new Stage 1 requirements exist / Impacted TSs and TRs: Stage 2/3: 23.012, 23.018, 23.116, 29.002
- 3441: CP#52 completed. Triggered by Rel-10 TR 31.828 Study on UICC access to IMS (FS_IMS-UICC) UID_480017. Specify mechanism in UICC and ME to make use of IMS functionality implemented in ME for case a) an ISIM is present b) no ISIM is present in UICC
- 3442: CP#51 completed / Impacted TSs and TRs: 31.102, 31.103, 31.111
- 3443: CP#52 completed / Impacted TSs and TRs: 24.229
- 3444: CP#62 stopped (at 70% completion 06/13). Testing for New featurES in CP-150Rel-10 specifications for USIM, ISIM applications and USIM Application Toolkit (USAT) in TS 31.102, 31.103, 31.111 / Impacted TSs and TRs: 31.121, 31.124, New TS 31.ABC (Conformance Testing of specific features)
- 3445: CP#51 completed / Impacted TSs and TRs: GERAN Stage 2/3
- 3446: CP#49 completed / Impacted TSs and TRs: new TR 23.889
- 3447: CP#51 completed / Impacted TSs and TRs: 23.003, 23.009, 23.205, 23.231, 29.002, 29.205, 29.232, new TS 23.284
- 3448: CP#49 stopped. Result of study TR 23.889: no CT3 specification impact
- 3449: CP#49 stopped. Result of study TR 23.889: no CT1 specification impact
- 3450: GP#50 completed. GP#41 WID approved / Impacted TSs and TRs: GERAN Stage 3: 48.008, 48.103

| ID | WBS | Task | Duration | Start | Finish | Complete | Baseline start | Baseline finish | Baseline duration | Constraint | Resources | Work | Actual work | Acronym | PCG approved | WI rapporteur name | Release | TSG approved | MCC resp | Acronym_3GU_Export | Status Report | Special Focus Doc |
| --- | --- | --- | --- | --- | --- | --- | --- | --- | --- | --- | --- | --- | --- | --- | --- | --- | --- | --- | --- | --- | --- | --- |
| 3451 | 905 | **Tightened Link Level Performance Requirements for Single Antenna MS** | 659d? | 2010-09-03 A | 2013-03-01 A | 100% | 2010-09-03 | 2013-03-01 | 659d? |  | G1; G2; C1; G3new | 30856h | 30856h | TIGHTER | 25 | Renesas Mobile | Rel-10 | 46 | Paolo | TIGHTER |  |  |
| 3452 | 905.1 | CT1 part for TIGHTER | 196d? | 2010-09-03 A | 2011-06-03 A | 100% | 2010-09-03 | 2011-06-03 | 196d? | finish no earlier than 2011-06-03 | C1 | 1568h | 1568h | TIGHTER | 25 | Renesas Mobile | Rel-10 | 46 | Frederic |  |  |  |
| 3453 | 905.2 | TIGHTER Performance Requirements | 186d? | 2010-09-03 A | 2011-05-20 A | 100% | 2010-09-03 | 2011-05-20 | 186d? | finish no earlier than 2011-05-20 | G1; G2 | 2976h | 2976h | TIGHTER | 25 | Renesas Mobile | Rel-10 | 46 | Paolo |  |  |  |
| 3454 | 905.3 | TIGHTER Testing | 654d? | 2010-09-08 A | 2013-03-01 A | 100% | 2010-09-08 | 2013-03-01 | 654d? | finish no earlier than 2013-03-01 | G3new | 5224h | 5224h | TIGHTER | 25 | Renesas Mobile | Rel-10 | 46 | Ingbert |  |  |  |
| 3455 | 906 | **Support of Multi-Operator Core Network by GERAN** | 206d? | 2010-05-21 A | 2011-03-04 A | 100% | 2010-05-21 | 2011-03-04 | 206d? |  | G2; S2; C1 | 8392h | 8392h | MOCN-GERAN | 25 | Alcatel-Lucent | Rel-10 | 47 | Gert | MOCN-GERAN |  |  |
| 3456 | 906.1 | Stage 2 for Support of Multi-Operator Core Network by GERAN | 150d? | 2010-05-21 A | 2010-12-16 A | 100% | 2010-05-21 | 2010-12-16 | 150d? | finish no earlier than 2010-12-15 | S2 | 1200h | 1200h | MOCN-GERAN | 25 | Alcatel-Lucent | Rel-10 | 47 | Maurice |  |  |  |
| 3457 | 906.2 | CT1 part of Stage 3 for Support of Multi-Operator Core Network by GERAN | 146d? | 2010-05-21 A | 2010-12-10 A | 100% | 2010-05-21 | 2010-12-10 | 146d? | finish no earlier than 2010-12-10 | C1 | 1168h | 1168h | MOCN-GERAN | 25 | Alcatel-Lucent | Rel-10 | 47 | Frederic |  |  |  |
| 3458 | 906.3 | GERAN2 part of Stage 3 for Support of Multi-Operator Core Network by GERAN | 135d? | 2010-08-30 A | 2011-03-04 A | 100% | 2010-08-30 | 2011-03-04 | 135d? | finish no earlier than 2011-03-04 | G2 | 1080h | 1080h | MOCN-GERAN | 25 | Alcatel-Lucent | Rel-10 | 47 | Gert |  |  |  |
| 3459 | 907 | **Enhancements of Iur-g interface** | 196d? | 2010-09-03 A | 2011-06-03 A | 100% | 2010-09-03 | 2011-06-03 | 196d? |  | G2; R3 | 5752h | 5752h | eIurg | 25 | China Mobile, ZTE | Rel-10 | 47 | Gert | eIurg |  |  |
| 3460 | 907.1 | GERAN part for Enhancements of Iur-g interface (Stage 2/3) | 131d? | 2010-09-03 A | 2011-03-04 A | 100% | 2010-09-03 | 2011-03-04 | 131d? | finish no earlier than 2011-03-04 | G2 | 1048h | 1048h | eIurg-GERAN | 25 | China Mobile, ZTE | Rel-10 | 47 | Gert | eIurg-GERAN |  |  |
| 3461 | 907.2 | Core part: Enhancements of Iur-g interface (Stage 2/3) | 196d? | 2010-09-03 A | 2011-06-03 A | 100% | 2010-09-03 | 2011-06-03 | 196d? | finish no earlier than 2011-06-03 | R3 | 1568h | 1568h | eIurg-RAN | 25 | ZTE | Rel-10 | 49 | Juha | eIurg-RAN | RP-110526 |  |
| 3462 | 908 | 1.28 Mcps TDD Repeater | 599d? | 2007-12-04 A | 2010-03-19 A | 100% | 2007-12-04 | 2010-03-19 | 599d? | finish no earlier than 2010-03-19 | R4 | 4792h | 4792h | RANimp-Repeaters1.28TDD | 21 | RITT | Rel-10 | 38 | Issam | RANimp-Repeaters1.28TDD | RP-100039 |  |
| 3463 | 909 | 1.28 Mcps TDD Multi-carrier HSUPA | 321d? | 2009-09-18 A | 2010-12-10 A | 100% | 2009-09-18 | 2010-12-10 | 321d? | finish no earlier than 2010-12-10 | R1; R2; R3; R4 | 10272h | 10272h | TDD_MC_HSUPA | 23 | CATR | Rel-10 | 45 | Patrick | TDD_MC_HSUPA | RP-101079 |  |
| 3464 | 910 | **1.28 Mcps TDD Home NodeB RF requirements** | 266d? | 2009-12-04 A | 2010-12-10 A | 100% | 2009-12-04 | 2010-12-10 | 266d? |  | R4 | 5304h | 5304h | HNB_LCRTDD_RF | 24 | TD Tech | Rel-10 | 46 | Issam | HNB_LCRTDD_RF |  | HNB |
| 3465 | 910.1 | Core part: 1.28Mcps TDD Home NodeB RF requirements | 131d? | 2009-12-04 A | 2010-06-04 A | 100% | 2009-12-04 | 2010-06-04 | 131d? | finish no earlier than 2010-12-10 | R4 | 1048h | 1048h | HNB_LCRTDD_RF-Core | 24 | TD Tech | Rel-10 | 46 | Issam | HNB_LCRTDD_RF-Core | RP-100446 | HNB |
| 3466 | 910.2 | Perf. part: 1.28Mcps TDD Home NodeB RF requirements | 266d? | 2009-12-04 A | 2010-12-10 A | 100% | 2009-12-04 | 2010-12-10 | 266d? | finish no earlier than 2010-12-10 | R4 | 2128h | 2128h | HNB_LCRTDD_RF-Perf | 24 | TD Tech | Rel-10 | 46 | Issam | HNB_LCRTDD_RF-Perf | RP-101081 | HNB |
| 3467 | 911 | **Multi-User Multiple-Input and Multiple-Output (MU-MIMO) for 1.28Mcps TDD** | 316d? | 2010-03-19 A | 2011-06-03 A | 100% | 2010-03-19 | 2011-06-03 | 316d? |  | R1; R2; R3; R4 | 17224h | 17224h | MUMIMO_LCR_TDD | 24 | CATT | Rel-10 | 47 | Patrick | MUMIMO_LCR_TDD |  |  |
| 3468 | 911.1 | Core part: MU-MIMO for 1.28Mcps TDD | 191d? | 2010-03-19 A | 2010-12-10 A | 100% | 2010-03-19 | 2010-12-10 | 191d? | finish no earlier than 2010-12-10 | R1; R2; R3 | 4584h | 4584h | MUMIMO_LCR_TDD-Core | 24 | CATT | Rel-10 | 47 | Patrick | MUMIMO_LCR_TDD-Core | RP-101085 |  |
| 3469 | 911.2 | Perf. part: MU-MIMO for 1.28Mcps TDD | 316d? | 2010-03-19 A | 2011-06-03 A | 100% | 2010-03-19 | 2011-06-03 | 316d? | finish no earlier than 2011-06-03 | R4 | 2528h | 2528h | MUMIMO_LCR_TDD-Perf | 24 | CATT | Rel-10 | 47 | Issam | MUMIMO_LCR_TDD-Perf | RP-110520 |  |
| 3470 | 912 | **AGNSS Minimum Performance for UTRAN** | 523d? | 2009-09-18 A | 2011-09-16 A | 100% | 2009-09-18 | 2011-09-16 | 523d? |  | R4; R5 | 13624h | 13624h | AGNSSPerf_UTRAN | 23 | Thales | Rel-10 | 45 | Issam | AGNSSPerf_UTRAN |  |  |
| 3471 | 912.1 | AGNSS Minimum Performance Specification Development | 321d? | 2009-09-18 A | 2010-12-10 A | 100% | 2009-09-18 | 2010-12-10 | 321d? | finish no earlier than 2010-12-10 | R4 | 2568h | 2568h | AGNSSPerf_UTRAN | 23 | Thales | Rel-10 | 45 | Issam | AGNSSPerf_UTRAN | RP-101078 |  |
| 3472 | 912.2 | AGNSS test case development for UMTS | 336d? | 2010-06-04 A | 2011-09-16 A | 100% | 2010-06-04 | 2011-09-16 | 336d? | finish no earlier than 2011-09-16 | R5 | 2688h | 2688h | AGNSSPerf_UTRAN | 25 | Thales | Rel-10 | 48 | Ingbert | AGNSSPerf_UTRAN | RP-110979 |  |
| 3473 | 913 | **Inclusion of RF Pattern Matching Technologies as positioning method in the UTRAN** | 336d? | 2009-12-04 A | 2011-03-18 A | 100% | 2009-12-04 | 2011-03-18 | 336d? |  | R2; R3 | 10752h | 10752h | LCS_UMTS_RFPMT | 24 | Polaris Wireless | Rel-10 | 46 | Yong-Jun | LCS_UMTS_RFPMT | RP-110048 |  |
| 3474 | 913.1 | Core part: Inclusion of RF Pattern Matching Technologies as positioning method in the UTRAN | 336d? | 2009-12-04 A | 2011-03-18 A | 100% | 2009-12-04 | 2011-03-18 | 336d? | finish no earlier than 2011-03-18 | R2; R3 | 5376h | 5376h | LCS_UMTS_RFPMT-Core | 24 | Polaris Wireless | Rel-10 | 46 | Yong-Jun | LCS_UMTS_RFPMT-Core | RP-110048 |  |

Notes:
- 3451: GP#46 approved WID / Impacted TSs and TRs: GERAN / WI rapporteur e-mail: carsten.juncker@renesasmobile.com
- 3452: CP#52 completed / Impacted TSs and TRs: 24.008 / WI rapporteur e-mail: marko.niemi@renesasmobile.com
- 3453: GP#50 completed / Impacted TSs and TRs: 45.005, 45.015 / WI rapporteur e-mail: carsten.juncker@renesasmobile.com
- 3454: GP#57 completed / Impacted TSs and TRs: 51.010 / WI rapporteur e-mail: carsten.juncker@renesasmobile.com
- 3455: GP#47 approved WID. 900 MHz spectrum re-farming to other RATs lead operators to reduce GSM capacity and therefore share their GSM networks. Hence the need for the most suitable (GE)RAN sharing method / Impacted TSs and TRs: GERAN / WI rapporteur e-mail: michel.robert@alcatel-lucent.com
- 3456: SP#50 completed / Impacted TSs and TRs: 23.251 / WI rapporteur e-mail: michel.robert@alcatel-lucent.com
- 3457: CP#50 completed / Impacted TSs and TRs: 24.008 CR#1644 / WI rapporteur e-mail: michel.robert@alcatel-lucent.com
- 3458: GP#49 completed / Impacted TSs and TRs: 48.008 CR#0325, 48.018 CR#0303 / WI rapporteur e-mail: michel.robert@alcatel-lucent.com
- 3459: GP#47 approved WID / Impacted TSs and TRs: GERAN,UTRA / WI rapporteur e-mail: Ms Juan Deng (dengjuan@chinamobile.com), Xinhui Wang (wangxinhui@zte.com.cn)
- 3460: GP#49 completed. GP#48 updated WID GP-101659=>GP-101758 (restricting the scope to GERAN BSC and TD-SCDMA RNC only). GP#47 approved WID / Impacted TSs and TRs: 43.130, 48.008 / WI rapporteur e-mail: Ms Juan Deng (dengjuan@chinamobile.com), Xinhui Wang (wangxinhui@zte.com.cn)
- 3461: RP#52 completed / Impacted TSs and TRs: UTRA Stage 2 (25.401, 25.420), Stage 3 (25.423) / WI rapporteur e-mail: Liu Junqiang (liu.junqiang@zte.com.cn)
- 3462: RP#47 completed / Impacted TSs and TRs: UTRA 25.113, New 25.116, 25.153 (testing) / WI rapporteur e-mail: qinyan@chinattl.com
- 3463: RP#50 completed / Impacted TSs and TRs: UTRA 25.102, 25.105, 25.123, 25.221, 25.222, 25.223, 25.224, 25.225, 25.306, 25.319, 25.321, 25.331, 25.423, 25.427, 25.433 / WI rapporteur e-mail: Aihui Song (songaihui@mail.ritt.com.cn)
- 3464: RP#50 completed. Triggered by FS_RAN-HNBLCRTDD UID_410016 Study on 1.28 Mcps TDD Home NodeB (TR 25.866) / Impacted TSs and TRs: UTRA / WI rapporteur e-mail: Li Rong (lirong@td-tech.com)
- 3465: RP#48 completed / Impacted TSs and TRs: 25.105 / WI rapporteur e-mail: Li Rong (lirong@td-tech.com)
- 3466: RP#50 completed. TR 25.968 v100 for Approval / Impacted TSs and TRs: 25.142, new TR 25.968 / WI rapporteur e-mail: Li Rong (lirong@td-tech.com)
- 3467: RP#52 completed / Impacted TSs and TRs: UTRA / WI rapporteur e-mail: Yanping Xing (xingyanping@datangmobile.cn)
- 3468: RP#50 completed / Impacted TSs and TRs: 25.221, 25.222, 25.224, 25.306, 25.308, 25.319, 25.331, 25.423, 25.425, 25.433, 25.435 / WI rapporteur e-mail: Yanping Xing (xingyanping@datangmobile.cn)
- 3469: RP#52 completed / Impacted TSs and TRs: 25.102, 25.105, 25.142 / WI rapporteur e-mail: Sanjun Feng (fengsanjun@datangmobile.cn)
- 3470: RP#53 completed. Triggered by Rel-7 UID_20050 (GNSS in UTRAN) and Rel-8 UID_400051 (Support for Additional NSS). Linked to GERAN Rel-9 UID_38002 (AGNSS Performances and Testing Procedures) / Impacted TSs and TRs: UTRA / WI rapporteur e-mail: Michel.monnerat@thalesaleniaspace.com
- 3471: RP#50 completed / Impacted TSs and TRs: new 25.172 / WI rapporteur e-mail: Michel.monnerat@thalesaleniaspace.com
- 3472: RP#53 completed / Impacted TSs and TRs: 34.108, 34.109, 34.123-1, 34.123-2, 34.123-3, 36.37.571-5, new 34.172 / WI rapporteur e-mail: Michel.monnerat@thalesaleniaspace.com
- 3473: RP#51 completed. Triggered by Study UID_380079 Evaluation of the inclusion of Path Loss Based Technology in the UTRAN (25.907) / Impacted TSs and TRs: UTRA / WI rapporteur e-mail: Norman Shaw (nshaw@polariswireless.com)
- 3474: RP#51 completed / Impacted TSs and TRs: 25.305, 25.453 / WI rapporteur e-mail: Norman Shaw (nshaw@polariswireless.com)

| ID | WBS | Task | Duration | Start | Finish | Complete | Baseline start | Baseline finish | Baseline duration | Constraint | Resources | Work | Actual work | Acronym | PCG approved | WI rapporteur name | WI rapporteur e-mail | Release | TSG approved | MCC resp | Acronym_3GU_Export | Status Report | PCG stopped | TSG stopped | Special Focus Doc |
| --- | --- | --- | --- | --- | --- | --- | --- | --- | --- | --- | --- | --- | --- | --- | --- | --- | --- | --- | --- | --- | --- | --- | --- | --- | --- |
| 3475 | 914 | **Four carrier HSDPA** | 992d? | 2009-12-04 A | 2013-09-06 A | 100% | 2009-12-04 | 2013-09-06 | 992d? |  | R1; R2; R3; R4; R5 | 57872h | 57872h | 4C_HSDPA | 24 | Qualcomm | Arjun Bharadwaj (arjunb@qualcomm.com) | Rel-10 | 46 | Patrick | 4C_HSDPA |  |  |  |  |
| 3476 | 914.1 | Core part: Four carrier HSDPA | 336d? | 2009-12-04 A | 2011-03-18 A | 100% | 2009-12-04 | 2011-03-18 | 336d? | finish no earlier than 2011-03-18 | R1; R2; R3; R4 | 10752h | 10752h | 4C_HSDPA-Core | 24 | Qualcomm | Arjun Bharadwaj (arjunb@qualcomm.com) | Rel-10 | 46 | Patrick | 4C_HSDPA-Core | RP-110046 |  |  |  |
| 3477 | 914.2 | Perf. part: Four carrier HSDPA | 466d? | 2009-12-04 A | 2011-09-16 A | 100% | 2009-12-04 | 2011-09-16 | 466d? | finish no earlier than 2011-09-16 | R4 | 3728h | 3728h | 4C_HSDPA-Perf | 24 | Qualcomm | Arjun Bharadwaj (arjunb@qualcomm.com) | Rel-10 | 46 | Issam | 4C_HSDPA-Perf | RP-110986 |  |  |  |
| 3478 | 914.3 | Test part: Four carrier HSDPA | 464d? | 2011-12-02 A | 2013-09-06 A | 100% | 2011-12-02 | 2013-09-06 | 464d? | finish no earlier than 2013-09-06 | R5 | 3712h | 3712h | 4C_HSDPA-UEConTest | 28 | Qualcomm | Shubhang Vora (svora@qualcomm.com) | Rel-10 | 54 | Ingbert | 4C_HSDPA-UEConTest | RP-130940 |  |  |  |
| 3479 | 915 | **Performance Requirements for two-antenna 1.28Mcps TDD Type 1 and Type 2 UE receiver** | 316d? | 2010-03-19 A | 2011-06-03 A | 100% | 2010-03-19 | 2011-06-03 | 316d? |  | R4 | 5504h | 5504h | 2ant_UE_LCR_TDD | 24 | TD Tech | dafei.wang@td-tech.com | Rel-10 | 47 | Issam | 2ant_UE_LCR_TDD |  |  |  |  |
| 3480 | 915.1 | Core part: Performance Requirements for two-antenna 1.28Mcps TDD Type 1 and Type 2 UE receiver | 56d? | 2010-03-19 A | 2010-06-04 A | 100% | 2010-03-19 | 2010-06-04 | 56d? | finish no earlier than 2010-06-04 | R4 | 448h | 448h | 2ant_UE_LCR_TDD-Core | 24 | TD Tech | dafei.wang@td-tech.com | Rel-10 | 47 | Issam | 2ant_UE_LCR_TDD-Core | RP-100454 |  |  |  |
| 3481 | 915.2 | Perf. part: Performance Requirements for two-antenna 1.28Mcps TDD Type 1 and Type 2 UE receiver | 316d? | 2010-03-19 A | 2011-06-03 A | 100% | 2010-03-19 | 2011-06-03 | 316d? | finish no earlier than 2011-06-03 | R4 | 2528h | 2528h | 2ant_UE_LCR_TDD-Perf | 24 | TD Tech | dafei.wang@td-tech.com | Rel-10 | 47 | Issam | 2ant_UE_LCR_TDD-Perf | RP-110521 |  |  |  |
| 3482 | 916 | **Automatic Neighbour Relation (ANR) for UTRAN** | 663d? | 2010-06-04 A | 2012-12-07 A | 100% | 2010-06-04 | 2012-12-07 | 663d? |  | R3; R2; R5 | 22672h | 22672h | ANR_UTRAN | 25 | ZTE | Zhai.hengxing@zte.com.cn | Rel-10 | 48 | Juha | ANR_UTRAN |  |  |  |  |
| 3483 | 916.1 | Core part: Automatic Neighbour Relation (ANR) for UTRAN | 261d? | 2010-06-04 A | 2011-06-03 A | 100% | 2010-06-04 | 2011-06-03 | 261d? | finish no earlier than 2011-06-03 | R3; R2 | 4176h | 4176h | ANR_UTRAN-Core | 25 | ZTE | Zhai.hengxing@zte.com.cn | Rel-10 | 48 | Juha | ANR_UTRAN-Core | RP-110522 |  |  |  |
| 3484 | 916.2 | Test part: Automatic Neighbour Relation (ANR) for UTRAN | 323d? | 2011-09-19 A | 2012-12-07 A | 100% | 2011-09-19 | 2012-12-07 | 323d? | finish no earlier than 2012-12-07 | R5 | 2584h | 2584h | ANR_UTRAN-UEConTest | 27 | Ericsson | leif.mattisson@ericsson.com | Rel-10 | 53 | Ingbert | ANR_UTRAN-UEConTest | RP-121529 |  |  |  |
| 3485 | 917 | **Support of New Band Combinations for Dual-Band Dual Cell HSDPA** | 261d? | 2010-06-04 A | 2011-06-03 A | 100% | 2010-06-04 | 2011-06-03 | 261d? |  | R4; R2 | 9568h | 9568h | DB_DC_HSDPA | 25 | AT&T | Vince Spatafora (vs5785@att.com) | Rel-10 | 48 | Issam | DB_DC_HSDPA |  |  |  |  |
| 3486 | 917.1 | Core part: Support of New Band Combinations for Dual-Band Dual Cell HSDPA | 261d? | 2010-06-04 A | 2011-06-03 A | 100% | 2010-06-04 | 2011-06-03 | 261d? | finish no earlier than 2011-06-03 | R4; R2 | 4176h | 4176h | DB_DC_HSDPA-Core | 25 | AT&T | Vince Spatafora (vs5785@att.com) | Rel-10 | 48 | Issam | DB_DC_HSDPA-Core | RP-110523 |  |  |  |
| 3487 | 917.2 | Deleted - Perf. part: Support of New Band Combinations for Dual-Band Dual Cell HSDPA | 76d? | 2010-06-04 A | 2010-09-17 A | 100% | 2010-06-04 | 2010-09-17 | 76d? | finish no earlier than 2010-09-17 | R4; R2 | 1216h | 1216h | DB_DC_HSDPA-Perf | 25 | AT&T | Vince Spatafora (vs5785@att.com) | Rel-10 | 48 | Issam | DB_DC_HSDPA-Perf | RP-100759 | PCG-25 | RP-49 |  |
| 3488 | 918 | **MIMO operation with non-MIMO coexistence in HSDPA** | 459d? | 2010-06-04 A | 2012-03-02 A | 100% | 2010-06-04 | 2012-03-02 | 459d? |  | R4; R5 | 12936h | 12936h | MIMO_HSDPA | 25 | Qualcomm | Heechoon Lee | Rel-10 | 48 | Issam | MIMO_HSDPA |  |  |  |  |
| 3489 | 918.1 | Core part: MIMO operation with non-MIMO coexistence in HSDPA | 186d? | 2010-09-17 A | 2011-06-03 A | 100% | 2010-09-17 | 2011-06-03 | 186d? | finish no earlier than 2011-06-03 | R4 | 1488h | 1488h | MIMO_HSDPA-Core | 25 | Qualcomm | Heechoon Lee | Rel-10 | 49 | Issam | MIMO_HSDPA-Core | RP-110524 |  |  |  |
| 3490 | 918.2 | Perf. part: MIMO operation with non-MIMO coexistence in HSDPA | 261d? | 2010-06-04 A | 2011-06-03 A | 100% | 2010-06-04 | 2011-06-03 | 261d? | finish no earlier than 2011-06-03 | R4 | 2088h | 2088h | MIMO_HSDPA-Perf | 25 | Qualcomm | Heechoon Lee | Rel-10 | 48 | Issam | MIMO_HSDPA-Perf | RP-110525 |  |  |  |
| 3491 | 918.3 | Test part: MIMO operation with non-MIMO coexistence in HSDPA | 252d? | 2011-03-18 A | 2012-03-02 A | 100% | 2011-03-18 | 2012-03-02 | 252d? | finish no earlier than 2012-03-02 | R5 | 2016h | 2016h | MIMO_HSDPA-UEConTest | 26 | Qualcomm | Shubhang Vora (svora@qualcomm.com) | Rel-10 | 51 | Ingbert | MIMO_HSDPA-UEConTest | RP-120042 |  |  |  |
| 3492 | 919 | Interfrequency detected set measurements for UMTS | 61d? | 2010-09-17 A | 2010-12-10 A | 100% | 2010-09-17 | 2010-12-10 | 61d? | finish no earlier than 2010-12-10 | R2; R4 | 976h | 976h | Interf_dset_meas_UMTS | 25 | Nokia | Chris.callender@nokia.com | Rel-10 | 49 | Yong-Jun | Interf_dset_meas_UMTS | RP-101093 |  |  |  |
| 3493 | 920 | **Carrier Aggregation for LTE** | 793d? | 2009-12-04 A | 2012-12-07 A | 100% | 2009-12-04 | 2012-12-07 | 793d? |  | R1; R2; R3; R4; R5 | 51024h | 51024h | LTE_CA | 24 | Nokia | Asbjorn.grovlen@nokia.com | Rel-10 | 46 | Patrick | LTE_CA |  |  |  | CA |
| 3494 | 920.1 | Core part: Carrier Aggregation for LTE | 391d? | 2009-12-04 A | 2011-06-03 A | 100% | 2009-12-04 | 2011-06-03 | 391d? | finish no earlier than 2011-06-03 | R1; R2; R3; R4 | 12512h | 12512h | LTE_CA-Core | 24 | Nokia | lars.e.lindh@nokia.com | Rel-10 | 46 | Patrick | LTE_CA-Core | RP-110535 |  |  | CA |
| 3495 | 920.2 | Perf. part: Carrier Aggregation for LTE | 528d? | 2009-12-04 A | 2011-12-09 A | 100% | 2009-12-04 | 2011-12-09 | 528d? | finish no earlier than 2011-12-09 | R4 | 4224h | 4224h | LTE_CA-Perf | 24 | Nokia | lars.e.lindh@nokia.com | Rel-10 | 46 | Issam | LTE_CA-Perf | RP-111452 |  |  | CA |
| 3496 | 920.3 | Test part: Carrier Aggregation for LTE | 321d? | 2011-09-19 A | 2012-12-07 A | 100% | 2011-09-19 | 2012-12-07 | 321d? | finish no earlier than 2012-12-07 | R5 | 2568h | 2568h | LTE_CA-UEConTest | 27 | Nokia | jussi.kuusisto@nokia.com | Rel-10 | 53 | Ingbert | LTE_CA-UEConTest | RP-121528 |  |  | CA |
| 3497 | 921 | **Enhanced Downlink Multiple Antenna Transmission for LTE** | 930d? | 2009-12-04 A | 2013-06-14 A | 100% | 2009-12-04 | 2013-06-14 | 930d? |  | R1; R2; R4; R5 | 44624h | 44624h | LTE_eDL_MIMO | 24 | NTT DoCoMo | Hidekazu Taoka (taoka@nttdocomo.com) | Rel-10 | 46 | Patrick | LTE_eDL_MIMO |  |  |  |  |
| 3498 | 921.1 | Core part: Enhanced Downlink Multiple Antenna Transmission for LTE | 336d? | 2009-12-04 A | 2011-03-18 A | 100% | 2009-12-04 | 2011-03-18 | 336d? | finish no earlier than 2011-03-18 | R1; R2; R4 | 8064h | 8064h | LTE_eDL_MIMO-Core | 24 | NTT DoCoMo | Hidekazu Taoka (taoka@nttdocomo.com) | Rel-10 | 46 | Patrick | LTE_eDL_MIMO-Core | RP-110067 |  |  |  |
| 3499 | 921.2 | Perf. part: Enhanced Downlink Multiple Antenna Transmission for LTE | 589d? | 2009-12-04 A | 2012-03-02 A | 100% | 2009-12-04 | 2012-03-02 | 589d? | finish no earlier than 2012-03-02 | R4 | 4712h | 4712h | LTE_eDL_MIMO-Perf | 24 | NTT DoCoMo | Hidekazu Taoka (taoka@nttdocomo.com) | Rel-10 | 46 | Issam | LTE_eDL_MIMO-Perf | RP-120053 |  |  |  |
| 3500 | 921.3 | Test part: Enhanced Downlink Multiple Antenna Transmission for LTE | 261d? | 2012-06-18 A | 2013-06-14 A | 100% | 2012-06-18 | 2013-06-14 | 261d? | finish no earlier than 2013-06-14 | R5 | 2088h | 2088h | LTE_eDL_MIMO-UEConTest | 29 | ZTE | Carolyn Taylor (carolyn.tayl@zte.com.cn) | Rel-10 | 56 | Ingbert | LTE_eDL_MIMO-UEConTest | RP-130464 |  |  |  |

Notes:
- 3475: RP#53 completed / Impacted TSs and TRs: UTRA
- 3476: RP#51 completed. RP#52 TR 25.864 v200 for Approval / Impacted TSs and TRs: 25.101, 25.104, 25.133, 25.211, 25.212, 25.213, 25.214, 25.215, 25.308, 25.331, 25.423, 25.433, 26.306, new TR 25.864
- 3477: RP#53 completed / Impacted TSs and TRs: 25.101, 25.104, 25.133, 25.141
- 3478: RP#61 completed / Impacted TSs and TRs: 34.108, 34.121-1, 34.121-2, 34.123-1, 34.123-2, 34.123-3
- 3479: Stage 3. RP#52 completed / Impacted TSs and TRs: UTRA
- 3480: RP#48 completed / Impacted TSs and TRs: 25.102
- 3481: RP#52 completed / Impacted TSs and TRs: 25.102
- 3482: RP#52 Core completed. Automatic Neighbour Relation (ANR) function for UTRAN relieves operators from the burden of manually managing the Neighbour cell Relations (NRs) / Impacted TSs and TRs: UTRA
- 3483: RP#52 completed / Impacted TSs and TRs: 25.331, 25.413, 25.423, new TS 25.484 (Stage 2)
- 3484: RP#58 completed / Impacted TSs and TRs: 34.108, 34.123-1, 34.123-2, 34.123-3
- 3485: RP#52 completed. Rel-9 Dual-Band Dual-Cell HSDPA (UID_430015 Support for different bands for Dual-Cell HSDPA) has one combination per region in principle. This work adds additional combinations: Band I and XI (Region 3) and Band II and V (Region 2) / Impacted TSs and TRs: UTRA
- 3486: RP#52 completed. RP#62 existing TS 25.317 replaced by new TS 25.327 / Impacted TSs and TRs: 25.101, 25.104, 25.141, 25.317 replaced by new TS 25.327
- 3487: RP#49 stopped (Reason: no need for Performance work) / Impacted TSs and TRs: 25.101, 25.104, 25.141, 25.317
- 3488: RP#52 completed. RP#49 updated WID RP-100687=>RP-100993 (changed Title: MIMO Testing in HSDPA => MIMO operation with non-MIMO coexistence in HSDPA) / Impacted TSs and TRs: UTRA
- 3489: RP#52 completed / Impacted TSs and TRs: 25.104
- 3490: RP#52 completed / Impacted TSs and TRs: 25.101, 25.141
- 3491: RP#55 completed / Impacted TSs and TRs: 34.108, 34.121-1, 34.121-2, 34.123-1, 34.123-2, 34.123-3
- 3492: RP#50 completed / Impacted TSs and TRs: UTRA 25.133, 25.331
- 3493: - / Impacted TSs and TRs: LTE
- 3494: RP#52 completed. RP#56 new RAN4 TR (36.807, 36.808) v200 for Approval / Impacted TSs and TRs: 36.101, 36.104, 36.133, 36.211, 36.212, 36.213, 36.300, 36.302, 36.306, 36.321, 36.331, 36.413, 36.423, 37.104, new RAN4 TR (36.807, 36.808)
- 3495: RP#54 completed / Impacted TSs and TRs: 36.101, 36.104, 36.133, 36.141, 37.141
- 3496: RP#58 completed / Impacted TSs and TRs: 36.508, 36.521-1, 36.521-2, 36.521-3, 36.523-1, 36.523-2, 36.523-3, 37.571-1, 37.571-3, 37.571-5
- 3497: - / Impacted TSs and TRs: LTE
- 3498: RP#51 completed. RP#56 new RAN4 TR 36.807 v200 for Approval / Impacted TSs and TRs: 36.101, 36.104, 36.133, 36.201, 36.211, 36.212, 36.213, 36.300, 36.306, 36.321, 36.331, new RAN4 TR 36.807
- 3499: RP#55 completed / Impacted TSs and TRs: 36.101, 36.104, 36.133, 36.141
- 3500: RP#60 completed. Testing for 36.101, 36.133 / Impacted TSs and TRs: 36.508, 36.521-1, 36.521-2

| ID | WBS | Task | Duration | Start | Finish | Complete | Baseline start | Baseline finish | Baseline duration | Constraint | Resources | Work | Actual work | Acronym | PCG approved | WI rapporteur name | WI rapporteur e-mail | Release | TSG approved | MCC resp | Acronym_3GU_Export | Status Report | PCG stopped | TSG stopped |
| --- | --- | --- | --- | --- | --- | --- | --- | --- | --- | --- | --- | --- | --- | --- | --- | --- | --- | --- | --- | --- | --- | --- | --- | --- |
| 3501 | 922 | **Uplink Multiple Antenna Transmission for LTE** | 3445d? | 2000-01-03 A | 2013-03-01 A | 100% | 2000-01-03 | 2013-03-01 | 3445d? |  | R1; R2; R4; R5 | 125976h | 125976h | LTE_UL_MIMO | 24 | Huawei | Mattias.wennstrom@huawei.com | Rel-10 | 46 | Patrick | LTE_UL_MIMO |  |  |  |
| 3502 | 922.1 | Core part: UL multiple antenna transmission for LTE | 391d? | 2000-01-03 A | 2001-06-29 A | 100% | 2000-01-03 | 2001-06-29 | 391d? |  | R1; R2; R4 | 9384h | 9384h | LTE_UL_MIMO-Core | 24 | Huawei | Mattias.wennstrom@huawei.com | Rel-10 | 46 | Patrick | LTE_UL_MIMO-Core | RP-110537 |  |  |
| 3503 | 922.2 | Perf. part: UL multiple antenna transmission for LTE | 466d? | 2009-12-04 A | 2011-09-16 A | 100% | 2009-12-04 | 2011-09-16 | 466d? | finish no earlier than 2011-09-16 | R4 | 3728h | 3728h | LTE_UL_MIMO-Perf | 24 | Huawei | Mattias.wennstrom@huawei.com | Rel-10 | 46 | Issam | LTE_UL_MIMO-Perf | RP-110992 |  |  |
| 3504 | 922.3 | Test part: UL multiple antenna transmission for LTE | 328d? | 2011-12-02 A | 2013-03-01 A | 100% | 2011-12-02 | 2013-03-01 | 328d? | finish no earlier than 2013-03-01 | R5 | 2624h | 2624h | LTE_UL_MIMO-UEConTest | 28 | Huawei | Zhang Xin (suzanna.zhang@huawei.com) | Rel-10 | 54 | Ingbert | LTE_UL_MIMO-UEConTest | RP-130038 |  |  |
| 3505 | 923 | **Relays for LTE** | 394d? | 2009-12-04 A | 2011-06-08 A | 100% | 2009-12-04 | 2011-06-08 | 394d? |  | R1; R2; R4; S2; S3; C4; C6 | 36856h | 36856h | LTE_Relay | 24 | Ericsson | christian.hoymann@ericsson.com | Rel-10 | 46 | Patrick | LTE_Relay |  |  |  |
| 3506 | 923.1 | Core part: Relays for LTE | 391d? | 2009-12-04 A | 2011-06-03 A | 100% | 2009-12-04 | 2011-06-03 | 391d? | finish no earlier than 2011-06-03 | R1; R2; R4 | 9384h | 9384h | LTE_Relay-Core | 24 | Ericsson | christian.hoymann@ericsson.com | Rel-10 | 46 | Patrick | LTE_Relay-Core | RP-110540 |  |  |
| 3507 | 923.2 | Deleted - Perf. part: Relays for LTE | 391d? | 2009-12-04 A | 2011-06-03 A | 100% | 2009-12-04 | 2011-06-03 | 391d? | finish no earlier than 2011-09-16 | R4 | 3128h | 3128h | LTE_Relay-Perf | 24 | Ericsson | christian.hoymann@ericsson.com | Rel-10 | 46 | Issam | LTE_Relay-Perf | RP-110541 | PCG-27 | RP-52 |
| 3508 | 923.3 | Stage 2 for Relays for LTE | 3d? | 2011-06-06 A | 2011-06-08 A | 100% | 2011-06-06 | 2011-06-08 | 3d? | start no earlier than 2011-06-06 | S2 | 24h | 24h | LTE_Relay | 27 | Vodafone | chris.pudney@vodafone.com | Rel-10 | 52 | Maurice | LTE_Relay |  |  |  |
| 3509 | 923.4 | **LTE Relay Nodes Security** | 69d? | 2010-12-16 A | 2011-03-22 A | 100% | 2010-12-16 | 2011-03-22 | 69d? |  | S3; C6 | 2232h | 2232h | LTE_Relay-Sec | 26 | Qualcomm | Adrian Escott (aescott@qualcomm.com) | Rel-10 | 50 | Mirko | LTE_Relay-Sec |  |  |  |
| 3510 | 923.4.1 | TR on LTE Relay Nodes Security | 69d? | 2010-12-16 A | 2011-03-22 A | 100% | 2010-12-16 | 2011-03-22 | 69d? | finish no earlier than 2011-03-23 | S3 | 552h | 552h | LTE_Relay-Sec | 26 | Qualcomm | Adrian Escott (aescott@qualcomm.com) | Rel-10 | 50 | Mirko |  |  |  |  |
| 3511 | 923.4.2 | Security for LTE Relay Nodes (Stage 2) | 69d? | 2010-12-16 A | 2011-03-22 A | 100% | 2010-12-16 | 2011-03-22 | 69d? | finish no earlier than 2011-03-23 | S3 | 552h | 552h | LTE_Relay-Sec | 26 | Qualcomm | Adrian Escott (aescott@qualcomm.com) | Rel-10 | 50 | Mirko |  |  |  |  |
| 3512 | 923.4.3 | CT6 aspects of LTE Relay Node Security | 3d? | 2011-03-16 A | 2011-03-18 A | 100% | 2011-03-16 | 2011-03-18 | 3d? | start no earlier than 2011-03-16 | C6 | 24h | 24h | LTE_Relay-Sec | 26 | n/a | n/a | Rel-10 | 51 | Xavier |  |  |  |  |
| 3513 | 923.5 | Core Network Impacts for Relay Nodes | 3d? | 2011-03-16 A | 2011-03-18 A | 100% | 2011-03-16 | 2011-03-18 | 3d? | finish no earlier than 2011-03-18 | C4 | 24h | 24h | LTE_Relay-CN | 26 | Vodafone | David.Hutton@vodafone.com | Rel-10 | 51 | Kimmo | LTE_Relay-CN |  |  |  |
| 3514 | 924 | **Enhanced Inter-Cell Interference Control (ICIC) for non-Carrier Aggregation (CA) based deployments of heterogeneous networks for LTE** | 1119d? | 2010-03-19 A | 2014-06-13 A | 100% | 2010-03-19 | 2014-06-13 | 1119d? |  | R1; R2; R3; R4; R5 | 64384h | 64384h | eICIC_LTE | 24 | China Mobile | Xiaodong XU (xuxiaodong@chinamobile.com) | Rel-10 | 47 | Patrick | eICIC_LTE |  |  |  |
| 3515 | 924.1 | Core part: Enhanced Inter-Cell Interference Control (ICIC) for non-Carrier Aggregation (CA) based deployments of heterogeneous networks for LTE | 316d? | 2010-03-19 A | 2011-06-03 A | 100% | 2010-03-19 | 2011-06-03 | 316d? | finish no earlier than 2011-06-03 | R1; R2; R3; R4 | 10112h | 10112h | eICIC_LTE-Core | 24 | China Mobile | Xiaodong XU (xuxiaodong@chinamobile.com) | Rel-10 | 47 | Patrick | eICIC_LTE-Core | RP-110543 |  |  |
| 3516 | 924.2 | Perf. part: Enhanced Inter-Cell Interference Control (ICIC) for non-Carrier Aggregation (CA) based deployments of heterogeneous networks for LTE | 589d? | 2010-03-19 A | 2012-06-15 A | 100% | 2010-03-19 | 2012-06-15 | 589d? | finish no earlier than 2012-06-15 | R4 | 4712h | 4712h | eICIC_LTE-Perf | 24 | China Mobile | Xiaodong XU (xuxiaodong@chinamobile.com) | Rel-10 | 47 | Issam | eICIC_LTE-Perf | RP-120461 |  |  |
| 3517 | 924.3 | Test part: Enhanced Inter-Cell Interference Control (ICIC) for non-Carrier Aggregation (CA) based deployments of heterogeneous networks for LTE | 600d? | 2012-03-05 A | 2014-06-13 A | 100% | 2012-03-05 | 2014-06-13 | 600d? | finish no earlier than 2014-06-13 | R5 | 4800h | 4800h | eICIC_LTE-UEConTest | 28 | Qualcomm | Anjali Mishra (ajha@qualcomm.com) | Rel-10 | 55 | Ingbert | eICIC_LTE-UEConTest | RP-140766 |  |  |
| 3518 | 925 | **LTE TDD in 2600MHz for US** | 191d? | 2010-03-19 A | 2010-12-10 A | 100% | 2010-03-19 | 2010-12-10 | 191d? |  | R4; R2; R3; R5 | 11344h | 11344h | LTE_TDD_2600_US | 24 | Clearwire | michael.hart@clearwire.com | Rel-10 | 47 | Issam | LTE_TDD_2600_US |  |  |  |
| 3519 | 925.1 | Core part: LTE TDD in 2600MHz for US | 129d? | 2010-03-19 A | 2010-09-15 A | 100% | 2010-03-19 | 2010-09-17 | 131d? | finish no earlier than 2010-09-17 | R4; R2; R3 | 3096h | 3096h | LTE_TDD_2600_US-Core | 24 | Clearwire | michael.hart@clearwire.com | Rel-10 | 47 | Issam | LTE_TDD_2600_US-Core | RP-100782 |  |  |
| 3520 | 925.2 | Perf. part: LTE TDD in 2600MHz for US | 131d? | 2010-03-19 A | 2010-09-17 A | 100% | 2010-03-19 | 2010-09-17 | 131d? | finish no earlier than 2010-09-17 | R4 | 1048h | 1048h | LTE_TDD_2600_US-Perf | 24 | Clearwire | michael.hart@clearwire.com | Rel-10 | 47 | Issam | LTE_TDD_2600_US-Perf | RP-100783 |  |  |
| 3521 | 925.3 | UE conformance test part: LTE TDD in 2600MHz for US | 136d? | 2010-06-04 A | 2010-12-10 A | 100% | 2010-06-04 | 2010-12-10 | 136d? | finish no earlier than 2010-12-10 | R5 | 1088h | 1088h | LTE_TDD_2600_US-UEConTest | 25 | Clearwire | michael.hart@clearwire.com | Rel-10 | 48 | Ingbert | LTE_TDD_2600_US-UEConTest | RP-101071 |  |  |
| 3522 | 926 | **Adding 2 GHz band LTE FDD (Band 23) for Ancillary Terrestrial Component (ATC) of Mobile Satellite Service (MSS) in North America** | 454d? | 2010-03-19 A | 2011-12-09 A | 100% | 2010-03-19 | 2011-12-09 | 454d? |  | R2; R4; R5 | 19568h | 19568h | S_Band_LTE_ATC_MSS | 24 | DBSD | Mariam.Sorond@ico.com | Rel-10 | 47 | Yong-Jun | S_Band_LTE_ATC_MSS |  |  |  |
| 3523 | 926.1 | Core part: Adding 2 GHz band LTE FDD (Band 23) for ATC of MSS in North America | 316d? | 2010-03-19 A | 2011-06-03 A | 100% | 2010-03-19 | 2011-06-03 | 316d? | finish no earlier than 2011-06-03 | R4; R2 | 5056h | 5056h | S_Band_LTE_ATC_MSS-Core | 24 | DBSD | Mariam.Sorond@ico.com | Rel-10 | 47 | Issam | S_Band_LTE_ATC_MSS-Core | RP-110545 |  |  |
| 3524 | 926.2 | Perf. part: Adding 2 GHz band LTE FDD (Band 23) for ATC of MSS in North America | 316d? | 2010-03-19 A | 2011-06-03 A | 100% | 2010-03-19 | 2011-06-03 | 316d? | finish no earlier than 2011-06-03 | R4 | 2528h | 2528h | S_Band_LTE_ATC_MSS-Perf | 24 | DBSD | Mariam.Sorond@ico.com | Rel-10 | 47 | Issam | S_Band_LTE_ATC_MSS-Perf | RP-110546 |  |  |
| 3525 | 926.3 | Test part: Adding 2 GHz band LTE FDD (Band 23) for ATC of MSS in North America | 137d? | 2011-06-07 A | 2011-12-09 A | 100% | 2011-06-07 | 2011-12-09 | 137d? | finish no earlier than 2011-12-09 | R5 | 1088h | 1088h | S_Band_LTE_ATC_MSS-UEConTest | 27 | DBSD | Mariam.Sorond@ico.com | Rel-10 | 52 | Ingbert | S_Band_LTE_ATC_MSS-UEConTest | RP-111444 |  |  |

Notes:
- 3501: - / Impacted TSs and TRs: LTE
- 3502: RP#52 completed. TR 36.817 v110 for Approval. RP#56 new TR 36.807 v200 for Approval / Impacted TSs and TRs: 36.101, 36.104, 36.133, 36.201, 36.211, 36.212, 36.213, 36.300, 36.306, 36.321, 36.331, new RAN4 (TR 36.807, 36.817)
- 3503: RP#53 completed / Impacted TSs and TRs: 36.101, 36.104, 36.133, 36.141, 36.817
- 3504: RP#59 completed / Impacted TSs and TRs: 36.508, 36.521-1, 36.521-2, 36.521-3, 36.523-1, 36.523-2, 36.523-3
- 3505: RP#52 completed (open RAN4 Core & Perf parts moved to new Rel-11) / Impacted TSs and TRs: LTE
- 3506: RP#52 completed. Updated WID RP-101417=>RP-101911 (contains only Core part completed in Rel-10). Open RAN4 Core & Perf parts moved to new Rel-11 / Impacted TSs and TRs: 36.201, 36.211, 36.212, 36.213, 36.300, 36.321, 36.323, 36.331, New RAN1 TS 36.216
- 3507: RP#52 stopped at 30% (no CRs so far) . Transferred completely to Rel-11 together with remaining core part / Impacted TSs and TRs: 36.133, New TS 36.117 (E-UTRA Relay conformance testing)
- 3508: SP#52 SP-110338 (S2-85/S2-112851) 23.401 Cat F CR#2128 Completion of Relay procedure overview / Impacted TSs and TRs: 23.401
- 3509: -
- 3510: SP#51 completed / Impacted TSs and TRs: 33.816
- 3511: SP#51 completed (impacting Stage 3 in CT and RAN) / Impacted TSs and TRs: 33.401 (CR#0437,0438), CT1 24.301, CT4 (29.272, 29.274), CT6 31.102, RAN2 (36.331, 36.323), RAN3 36.413
- 3512: CP#51 completed / Impacted TSs and TRs: 31.101, 31.102
- 3513: CP#51 completed / Impacted TSs and TRs: 23.003, 23.008, 29.303, 29.230, 29.272
- 3514: RP#56 completed / Impacted TSs and TRs: LTE
- 3515: RP#52 completed / Impacted TSs and TRs: 36.101, 36.133, 36.201, 36.211, 36.212, 36.213, 36.214, 36.300, 36.321, 36.331, 36.413, 36.423
- 3516: RP#56 completed / Impacted TSs and TRs: 36.101, 36.133
- 3517: RP#64 completed / Impacted TSs and TRs: 36.508, 36.521-1, 36.521-2, 36.521-3, 36.523-1, 36.523-2, 36.523-3
- 3518: RP#50 Testing completed. RP#49 Core+Perf completed / Impacted TSs and TRs: LTE
- 3519: RP#49 completed 1st Apr 15: CD:Fri 17/09/10->Wed 15/09/10 / Impacted TSs and TRs: 25.461, 25.466, 36.101, 36.104, 36.113, 36.124, 36.133, 36.141, 36.307, 36.331, 37.104, 37.113, 37.141, new TR 36.812
- 3520: RP#49 completed / Impacted TSs and TRs: 36.101, 36.104, 36.133, 36.141, 36.307, 37.104, 37.141, new TR 36.812
- 3521: RP#50 completed / Impacted TSs and TRs: 36.508, 36.521-1, 36.521-2, 36.521-3, 36.523-1, 36.523-2, 36.523-3
- 3522: RP#52 completed. Updated WID RP-101401=>RP-110775 (changed in Title "LTE" to "LTE FDD (Band 23)" / Impacted TSs and TRs: LTE
- 3523: RP#52 completed / Impacted TSs and TRs: 25.101, 25.104, 25.141, 25.461, 25.466, 36.101, 36.104, 36.113, 36.124, 36.133, 36.307, 37.104, 37.141, new TR 36.811
- 3524: RP#52 completed / Impacted TSs and TRs: 36.101, 36.104, 36.113, 36.124, 36.133, 36.141, 36.307, 36.811
- 3525: RP#54 completed / Impacted TSs and TRs: 36.508, 36.521-1, 36.521-2, 36.521-3, 36.523-1, 36.523-2, 36.523-3

| ID | WBS | Task | Duration | Start | Finish | Complete | Baseline start | Baseline finish | Baseline duration | Constraint | Resources | Work | Actual work | Acronym | PCG approved | WI rapporteur name | WI rapporteur e-mail | Release | TSG approved | MCC resp | Acronym_3GU_Export | Status Report | Special Focus Doc |
| --- | --- | --- | --- | --- | --- | --- | --- | --- | --- | --- | --- | --- | --- | --- | --- | --- | --- | --- | --- | --- | --- | --- | --- |
| 3526 | 927 | **Adding L-Band (Band 24) LTE for Ancillary Terrestrial Component (ATC) of Mobile Satellite Service (MSS) in North America** | 463d? | 2009-12-11 A | 2011-09-16 A | 100% | 2009-12-11 | 2011-09-16 | 463d? |  | R4; R2; R5 | 18864h | 18864h | L_Band_LTE_ATC_MSS | 24 | LightSquared | Eric.Jacks@lightsquared.com, Maqbool.Aliani@lightsquared.com | Rel-10 | 47 | Issam | L_Band_LTE_ATC_MSS |  |  |
| 3527 | 927.1 | Core part: Adding L-Band (Band 24) LTE for ATC of MSS in North America | 261d? | 2009-12-11 A | 2010-12-10 A | 100% | 2009-12-11 | 2010-12-10 | 261d? | finish no earlier than 2010-12-10 | R4; R2 | 4176h | 4176h | L_Band_LTE_ATC_MSS-Core | 24 | LightSquared | Eric.Jacks@lightsquared.com, Maqbool.Aliani@lightsquared.com | Rel-10 | 47 | Issam | L_Band_LTE_ATC_MSS-Core | RP-101117 |  |
| 3528 | 927.2 | Perf. part: Adding L-Band (Band 24) LTE for ATC of MSS in North America | 316d? | 2010-03-19 A | 2011-06-03 A | 100% | 2010-03-19 | 2011-06-03 | 316d? | finish no earlier than 2011-06-03 | R4 | 2528h | 2528h | L_Band_LTE_ATC_MSS-Perf | 24 | LightSquared | Eric.Jacks@lightsquared.com, Maqbool.Aliani@lightsquared.com | Rel-10 | 47 | Issam | L_Band_LTE_ATC_MSS-Perf | RP-110548 |  |
| 3529 | 927.3 | Test part: Adding L-Band (Band 24) LTE for ATC of MSS in North America | 131d? | 2011-03-18 A | 2011-09-16 A | 100% | 2011-03-18 | 2011-09-16 | 131d? | finish no earlier than 2011-09-16 | R5 | 1048h | 1048h | L_Band_LTE_ATC_MSS-UEConTest | 26 | LightSquared | masoud.olfat@lightsquared.com | Rel-10 | 51 | Ingbert | L_Band_LTE_ATC_MSS-UEConTest | RP-110980 |  |
| 3530 | 928 | **LTE Self Optimizing Networks (SON) enhancements** | 316d? | 2010-03-19 A | 2011-06-03 A | 100% | 2010-03-19 | 2011-06-03 | 316d? |  | R3; R2; R4 | 15168h | 15168h | SONenh_LTE | 24 | Nokia Siemens Networks | krzysztof.kordybach@nsn.com | Rel-10 | 47 | Juha | SONenh_LTE |  | SON |
| 3531 | 928.1 | Core part: LTE Self Optimizing Networks (SON) enhancements | 316d? | 2010-03-19 A | 2011-06-03 A | 100% | 2010-03-19 | 2011-06-03 | 316d? | finish no earlier than 2011-06-03 | R3; R2; R4 | 7584h | 7584h | SONenh_LTE-Core | 24 | Nokia Siemens Networks | krzysztof.kordybach@nsn.com | Rel-10 | 47 | Juha | SONenh_LTE-Core | RP-110547 | SON |
| 3532 | 929 | **Further enhancements to MBMS for LTE** | 459d? | 2010-06-04 A | 2012-03-02 A | 100% | 2010-06-04 | 2012-03-02 | 459d? |  | R2; R3; R5 | 14840h | 14840h | MBMS_LTE_enh | 25 | Huawei | Ms Zhao Junhui (zhaojh@huawei.com) | Rel-10 | 48 | Yong-Jun | MBMS_LTE_enh |  |  |
| 3533 | 929.1 | Core part: Further enhancements to MBMS for LTE | 206d? | 2010-06-04 A | 2011-03-18 A | 100% | 2010-06-04 | 2011-03-18 | 206d? | finish no earlier than 2011-03-18 | R2; R3 | 3296h | 3296h | MBMS_LTE_enh-Core | 25 | Huawei | Ms Zhao Junhui (zhaojh@huawei.com) | Rel-10 | 48 | Yong-Jun | MBMS_LTE_enh-Core | RP-110083 |  |
| 3534 | 929.2 | Test part: Further enhancements to MBMS for LTE | 66d? | 2011-12-02 A | 2012-03-02 A | 100% | 2011-12-02 | 2012-03-02 | 66d? | finish no earlier than 2012-03-02 | R5 | 528h | 528h | MBMS_LTE_enh-UEConTest | 28 | Huawei | Zhang Xin (suzanna.zhang@huawei.com) | Rel-10 | 54 | Ingbert | MBMS_LTE_enh-UEConTest | RP-120049 |  |
| 3535 | 930 | **UMTS/LTE 3500 MHz** | 1456d? | 2007-11-30 A | 2013-06-14 A | 100% | 2007-11-30 | 2013-06-14 | 1456d? |  | R4; R2; R3; R5 | 87360h | 87360h | RInImp8-UMTSLTE3500 | 21 | Ericsson | johan.skold@ericsson.com | Rel-10 | 38 | Issam | RInImp8-UMTSLTE3500 |  |  |
| 3536 | 930.1 | Core part: UMTS/LTE 3500 MHz | 994d? | 2007-11-30 A | 2011-09-16 A | 100% | 2007-11-30 | 2011-09-16 | 994d? | finish no earlier than 2011-09-16 | R4; R2; R3 | 23856h | 23856h | RInImp8-UMTSLTE3500 | 21 | Ericsson | johan.skold@ericsson.com | Rel-10 | 38 | Issam | RInImp8-UMTSLTE3500 | RP-110987 |  |
| 3537 | 930.2 | Conformance Test Aspects – LTE 3500 | 1189d? | 2008-12-05 A | 2013-06-14 A | 100% | 2008-12-05 | 2013-06-14 | 1189d? | finish no earlier than 2013-06-14 | R5 | 9512h | 9512h | LTE-UEConTest_LTE3500 | 22 | Ericsson | fredrik.sundstrom@ericsson.com | Rel-10 | 42 | Ingbert | LTE-UEConTest_LTE3500 | RP-130461 |  |
| 3538 | 930.3 | Conformance Test Aspects – UMTS 3500 | 925d? | 2008-12-05 A | 2012-06-15 A | 100% | 2008-12-05 | 2012-06-15 | 925d? | finish no earlier than 2012-06-15 | R5 | 7400h | 7400h | RInImp-UEConTest_UMTS3500 | 22 | Ericsson | fredrik.sundstrom@ericsson.com | Rel-10 | 42 | Ingbert | RInImp-UEConTest_UMTS3500 | RP-120450 |  |
| 3539 | 931 | **Minimization of Drive Tests for E-UTRAN and UTRAN** | 854d? | 2009-12-04 A | 2013-03-01 A | 100% | 2009-12-04 | 2013-03-01 | 854d? |  | R2; R4; R3; R5 | 39784h | 39784h | MDT_UMTSLTE | 24 | Nokia Siemens Networks | malgorzata.tomala@nsn.com | Rel-10 | 46 | Yong-Jun | MDT_UMTSLTE |  |  |
| 3540 | 931.1 | Core part: Minimization of Drive Tests for E-UTRAN and UTRAN | 391d? | 2009-12-04 A | 2011-06-03 A | 100% | 2009-12-04 | 2011-06-03 | 391d? | finish no earlier than 2011-06-03 | R2; R4; R3 | 9384h | 9384h | MDT_UMTSLTE-Core | 24 | Nokia Siemens Networks | malgorzata.tomala@nsn.com | Rel-10 | 46 | Yong-Jun | MDT_UMTSLTE-Core | RP-110528 |  |
| 3541 | 931.2 | Test part: Minimization of Drive Tests for E-UTRAN | 384d? | 2011-09-19 A | 2013-03-01 A | 100% | 2011-09-19 | 2013-03-01 | 384d? | finish no earlier than 2013-03-01 | R5 | 3072h | 3072h | MDT_UMTSLTE-UEConTest | 27 | Ericsson | leif.mattisson@ericsson.com | Rel-10 | 53 | Ingbert | MDT_UMTSLTE-UEConTest | RP-130036 |  |
| 3542 | 932 | **HNB and HeNB Mobility Enhancements** | 718d? | 2010-03-19 A | 2012-12-07 A | 100% | 2010-03-19 | 2012-12-07 | 718d? |  | R3; R2; R5 | 23016h | 23016h | HNB_HENB_mob_enh | 24 | Alcatel-Lucent | Martin,Warner@alcatel-lucent.com | Rel-10 | 47 | Juha | HNB_HENB_mob_enh |  | HNB |
| 3543 | 932.1 | Core part: HNB and HeNB Mobility Enhancements | 261d? | 2010-03-19 A | 2011-03-18 A | 100% | 2010-03-19 | 2011-03-18 | 261d? | start no earlier than 2010-03-19 | R3; R2 | 4176h | 4176h | HNB_HENB_mob_enh-Core | 24 | Alcatel-Lucent | Martin.Warner@alcatel-lucent.com | Rel-10 | 47 | Juha | HNB_HENB_mob_enh-Core | RP-110058 | HNB |
| 3544 | 932.2 | Test part: HeNB Mobility Enhancements | 201d? | 2012-03-05 A | 2012-12-07 A | 100% | 2012-03-05 | 2012-12-07 | 201d? | finish no earlier than 2012-12-07 | R5 | 1608h | 1608h | HNB_HENB_mob_enh-UEConTest_LTE | 28 | Qualcomm | Anjali Mishra (ajha@qualcom.com) | Rel-10 | 55 | Ingbert | HNB_HENB_mob_enh-UEConTest_LTE | RP-121533 | HNB |
| 3545 | 933 | **Expanded 1900 MHz Band for UTRA and LTE** | 596d? | 2010-06-04 A | 2012-09-07 A | 100% | 2010-06-04 | 2012-09-07 | 596d? |  | R4; R2; R5 | 25312h | 25312h | E1900 | 25 | Sprint | nick.j.baustert@sprint.com | Rel-10 | 48 | Issam | E1900 |  |  |
| 3546 | 933.1 | Core part: Expanded 1900 MHz Band for UTRA and LTE | 261d? | 2010-06-04 A | 2011-06-03 A | 100% | 2010-06-04 | 2011-06-03 | 261d? | finish no earlier than 2011-06-03 | R4; R2 | 4176h | 4176h | E1900-Core | 25 | Sprint | nick.j.baustert@sprint.com | Rel-10 | 48 | Issam | E1900-Core | RP-110529 |  |
| 3547 | 933.2 | Perf. part: Expanded 1900 MHz Band for UTRA and LTE | 261d? | 2010-06-04 A | 2011-06-03 A | 100% | 2010-06-04 | 2011-06-03 | 261d? | finish no earlier than 2011-06-03 | R4; R2 | 4176h | 4176h | E1900-Perf | 25 | Sprint | nick.j.baustert@sprint.com | Rel-10 | 48 | Issam | E1900-Perf | RP-110530 |  |
| 3548 | 933.3 | Test part: Expanded 1900 MHz Band for UTRA and LTE | 333d? | 2011-06-07 A | 2012-09-07 A | 100% | 2011-06-07 | 2012-09-07 | 333d? | finish no earlier than 2012-09-07 | R5 | 2656h | 2656h | E1900-UEConTest | 27 | Sprint | nick.j.baustert@sprint.com | Rel-10 | 52 | Ingbert | E1900-UEConTest | RP-120957 |  |
| 3549 | 934 | **Multi-Standard Radio Base Station RF requirements for non-contiguous spectrum deployments** | 389d? | 2010-06-04 A | 2011-11-25 A | 100% | 2010-06-04 | 2011-11-25 | 389d? |  | R4; G1 | 16160h | 16160h | MSR_NC | 25 | Ericsson | johan.skold@ericsson.com | Rel-10 | 48 | Issam | MSR_NC |  |  |
| 3550 | 934.1 | Core part: Multi-Standard Radio BS RF requirements for non-contiguous spectrum deployments | 261d? | 2010-06-04 A | 2011-06-03 A | 100% | 2010-06-04 | 2011-06-03 | 261d? | finish no earlier than 2011-06-03 | R4 | 2088h | 2088h | MSR_NC-Core | 25 | Ericsson | johan.skold@ericsson.com | Rel-10 | 48 | Issam | MSR_NC-Core | RP-110531 |  |
| 3551 | 934.2 | Perf. part: Multi-Standard Radio BS RF requirements for non-contiguous spectrum deployments | 336d? | 2010-06-04 A | 2011-09-16 A | 100% | 2010-06-04 | 2011-09-16 | 336d? | finish no earlier than 2011-09-16 | R4 | 2688h | 2688h | MSR_NC-Perf | 25 | Ericsson | johan.skold@ericsson.com | Rel-10 | 48 | Issam | MSR_NC-Perf | RP-110988 |  |

Notes:
- 3526: RP#53 completed / Impacted TSs and TRs: LTE
- 3527: RP#51 completed / Impacted TSs and TRs: 25.101, 25.104, 25.141, 25.461, 25.466, 34.124, 36.101, 36.104, 36.113, 36.124, 36.133, 36.307, 37.104, 37.141, new RAN4 TR 36.813
- 3528: RP#52 completed / Impacted TSs and TRs: 34.121-1, 36.101, 36.104, 36.113, 36.124, 36.133, 36.141, 36.307, 36.521-1, 36.813
- 3529: RP#53 completed / Impacted TSs and TRs: 36.508, 36.521-1, 36.521-2, 36.521-3, 36.523-2
- 3530: RP#52 completed / Impacted TSs and TRs: LTE
- 3531: RP#52 completed (Stage 1,2,3) / Impacted TSs and TRs: 36.300, 36.331, 36.413, 36.423
- 3532: RP#51 completed. SA2 decided not to support MBR>GBR in Rel-10 MBMS. For SA2, MBR=GBR in Rel-10 MBMS. Hence RAN removed enabling statistical multiplexing gains for variable bit rate services in Objectives / Impacted TSs and TRs: LTE
- 3533: RP#51 completed / Impacted TSs and TRs: 25.446, 36.300, 36.321, 36.322, 36.323, 36.331, 36.440, 36.441, 36.442, 36.443, 36.444, 36.445
- 3534: RP#55 completed / Impacted TSs and TRs: 36.508, 36.523-1, 36.523-2, 36.523-3
- 3535: - / Impacted TSs and TRs: UTRA, LTE
- 3536: RP#53 completed. TR 37.801v200 for Approval / Impacted TSs and TRs: 25.101, 25.104, 25.113, 25.133, 25.141, 25.307, 25.307, 25.331, 25.461, 25.463, 34.124, 36.101, 36.104, 36.113, 36.141, 36.331, new 37.801
- 3537: RP#60 completed / Impacted TSs and TRs: 36.508, 36.521-1, 36.521-2, 36.521-3
- 3538: RP#56 completed / Impacted TSs and TRs: 34.108, 34.121-1, 34.121-2
- 3539: Triggered by UID_430021 TR 36.805 (Study on Minimization of drive-tests in NGN) / Impacted TSs and TRs: UTRA, LTE
- 3540: RP#52 completed / Impacted TSs and TRs: 25.133, 25.215, 25.304, 25.331, 25.423, 36.133, 36.214, 36.300, 36.304, 36.331, 36.413, 36.423, new 37.320 (Stage 2)
- 3541: RP#59 completed. Testing for LTE only / Impacted TSs and TRs: LTE 34.108, 34.109, 34.123-1, 34.123-2, 34.123-3, 36.508, 36.509, 36.523-1, 36.523-2, 36.523-3
- 3542: - / Impacted TSs and TRs: UTRA, LTE
- 3543: RP#51 completed / Impacted TSs and TRs: 25.413, 25.467, 25.469, 36.300, 36.413, 36.423, new 25.471
- 3544: RP#58 completed / Impacted TSs and TRs: 34.108, 34.123-1, 34.123-2, 34.123-3, 36.508, 36.523-1, 36.523-2, 36.523-3
- 3545: Expand UTRA and E-UTRA band 2 to include frequencies between 1910 1915 MHz and 1990-1995 MHz (US FCC allocation) / Impacted TSs and TRs: UTRA, LTE
- 3546: RP#52 completed / Impacted TSs and TRs: 25.101, 25.104, 25.113, 25.133, 25.141, 25.461, 25.466, 36.101, 36.104, 36.113, 36.124, 36.133, 36.141, 36.307, 36.331, new TR 36.818
- 3547: RP#52 completed / Impacted TSs and TRs: 25.101, 25.104, 25.113, 25.133, 25.141, 25.461, 25.466, 36.101, 36.104, 36.113, 36.124, 36.133, 36.141, 36.307, 36.331, new TR 36.818
- 3548: RP#57 completed / Impacted TSs and TRs: 34.108, 34.121-1, 34.121-2, 34.123-1, 34.123-2, 34.123-3, 36.508, 36.521-1, 36.521-2, 36.521-3, 36.523-1, 36.523-2, 36.523-3
- 3549: - / Impacted TSs and TRs: UTRA, LTE, GERAN
- 3550: RP#52 completed / Impacted TSs and TRs: 25.104, 36.104, 37.104, new TR 37.802
- 3551: RP#53 completed / Impacted TSs and TRs: 25.141, 36.141, 37.141, 37.802

| ID | WBS | Task | Type | Duration | Start | Finish | Complete | Remaining | Baseline start | Baseline finish | Baseline duration | Total slack | Constraint | Resources | Work | Actual work | Acronym | PCG approved | WI rapporteur name | WI rapporteur e-mail | Release | TSG approved | MCC resp | Acronym_3GU_Export | Impacted TSs and TRs | PCG stopped | TSG stopped | Status Report | Special Focus Doc |
| --- | --- | --- | --- | --- | --- | --- | --- | --- | --- | --- | --- | --- | --- | --- | --- | --- | --- | --- | --- | --- | --- | --- | --- | --- | --- | --- | --- | --- | --- |
| 3552 | 934.3 | **GERAN part: Multi-Standard Radio BS RF requirements for non-contiguous spectrum deployments** |  | 324d? | 2010-09-03 A | 2011-11-25 A | 100% |  | 2010-09-03 | 2011-11-25 | 324d? |  |  | G1 | 5160h | 5160h | MSR_NC-GERAN | 25 | Ericsson | mats.y.samuelsson@ericsson.com | Rel-10 | 47 | Paolo | MSR_NC-GERAN |  |  |  |  |  |
| 3553 | 934.3.1 | GERAN Core part: Multi-Standard Radio BS RF requirements for non-contiguous spectrum deployments |  | 261d? | 2010-09-03 A | 2011-09-02 A | 100% |  | 2010-09-03 | 2011-09-02 | 261d? |  | finish no earlier than 2011-09-02 | G1 | 2088h | 2088h | MSR_NC-GERAN | 25 | Ericsson | mats.y.samuelsson@ericsson.com | Rel-10 | 47 | Paolo |  | 45.005 |  |  |  |  |
| 3554 | 934.3.2 | GERAN BS Test part: Multi-Standard Radio BS RF requirements for non-contiguous spectrum deployments |  | 62d? | 2011-09-02 A | 2011-11-25 A | 100% |  | 2011-09-02 | 2011-11-25 | 62d? |  | finish no earlier than 2011-11-25 | G1 | 496h | 496h | MSR_NC-GERAN | 28 | Ericsson | mats.y.samuelsson@ericsson.com | Rel-10 | 52 | Paolo |  | 51.021 |  |  |  |  |
| 3555 | 935 | (Small) Technical Enhancements and Improvements for Rel-10 |  | 470d? | 2009-06-04 A | 2011-03-23 A | 100% |  | 2009-06-04 | 2011-03-23 | 470d? |  | finish no earlier than 2011-03-23 | SP; CP; RP; GP | 15040h | 15040h | TEI10 | 23 |  |  | Rel-10 | 44 |  | TEI10 |  |  |  |  |  |
| 3556 | 936 | (IETF) (Small) Technical Enhancements and Improvements for Rel-10 (draft-atarius) |  | 1244d? | 2009-06-04 A | 2014-12-09 | 75% | 312.5d? | 2009-06-04 | 2014-12-05 | 1242d? | 5480d | finish no earlier than 2014-12-09 | C1-IETF | 9952h | 7452h | TEI10_IETF | 27 | Andrew Allen | Andrew Allen | Rel-10 | 52 | Frederic | TEI10_IETF | draft-atarius-dispatch-meid-urn |  |  |  |  |
| 3557 | 937 | (IETF) (Small) Technical Enhancements and Improvements for Rel-10 (RFC6275) |  | 562d? | 2009-06-04 A | 2011-07-29 A | 100% |  | 2009-06-04 | 2011-07-29 | 562d? |  | finish no earlier than 2011-07-29 | C1-IETF | 4496h | 4496h | TEI10_IETF1 | 27 |  |  | Rel-10 | 53 | Frederic | TEI10_IETF1 | RFC 6275 (was draft-ietf-mext-rfc3775bis) |  |  |  |  |
| 3558 | 938 | Test - (Small) Technical Enhancements and Improvements for Rel-10 |  | 271d? | 2011-12-01 A | 2012-12-07 A | 100% |  | 2011-12-01 | 2012-12-07 | 271d? |  | finish no earlier than 2012-12-07 | R5; G3new | 4336h | 4336h | TEI10_Test | 28 | n/a |  | Rel-10 | 54 | Ingbert | TEI10_Test |  |  |  |  |  |
| 3559 | 939 | **Deleted - Registration in Densely-populated area (RED)** |  | 665d? | 2007-03-12 A | 2009-09-24 A | 100% |  | 2007-03-12 | 2009-09-24 | 665d? |  |  | S1 | 9544h | 9544h | RED |  | NTT DoCoMo | tanakai@nttdocomo.co.jp | Rel-10 | 35 | Alain | RED |  | PCG-24 | SP-46 |  |  |
| 3560 | 939.1 | Deleted - Stage 1 for RED |  | 4d? | 2007-03-12 A | 2007-03-15 A | 100% |  | 2007-03-12 | 2007-03-15 | 4d? |  | start no earlier than 2007-03-12 | S1 | 32h | 32h | RED |  | NTT DoCoMo | takakurat@s1.nttdocomo.co.jp | Rel-10 | 35 | Alain |  | 22.101 CR#0207 | PCG-24 | SP-46 |  |  |
| 3561 | 939.2 | Deleted - Stage 2 for RED |  | 524d? | 2007-09-25 A | 2009-09-24 A | 100% |  | 2007-09-25 | 2009-09-24 | 524d? |  | finish no earlier than 2009-09-24 | S2 | 4192h | 4192h | RED |  | NTT DoCoMo | tanakai@nttdocomo.co.jp | Rel-10 | 37 | Maurice |  | draft TR 23.880 withdrawn, 23.002, 23.060, 23.221, 23.236 | PCG-23 | SP-45 |  |  |
| 3562 | 940 | **Deleted - Network Selection for non-3GPP Access** |  | 471d? | 2007-12-07 A | 2009-09-24 A | 100% |  | 2007-12-07 | 2009-09-24 | 471d? |  |  | S1; C6 | 15072h | 15072h | N3GtoNSP | 21 | Telefónica O2 | chris.friel@O2.com | Rel-10 | 38 | Alain | N3GtoNSP |  | PCG-23 | SP-45 |  |  |
| 3563 | 940.1 | Deleted - Stage 1 for N3GtoNSP |  | 471d? | 2007-12-07 A | 2009-09-24 A | 100% |  | 2007-12-07 | 2009-09-24 | 471d? |  | finish no earlier than 2009-12-10 | S1 | 3768h | 3768h | N3GtoNSP | 21 | Telefónica O2 | chris.friel@O2.com | Rel-10 | 38 | Alain |  | 22.011 | PCG-23 | SP-45 |  |  |
| 3564 | 940.2 | Deleted - CT6 issues for N3GtoNSP |  | 471d? | 2007-12-07 A | 2009-09-24 A | 100% |  | 2007-12-07 | 2009-09-24 | 471d? |  | finish no earlier than 2009-12-04 | C6 | 3768h | 3768h | N3GtoNSP | 21 | Telefónica O2 | chris.friel@O2.com | Rel-10 | 38 | Xavier |  | 36.300 | PCG-23 | CP-45 |  |  |
| 3565 | 941 | **Deleted - GTP-based S8 chaining** |  | 337d? | 2008-12-11 A | 2010-03-25 A | 100% |  | 2008-12-11 | 2010-03-25 | 337d? |  |  | S2 | 5392h | 5392h | GTPchaining | 22 | Huawei | Haining Wang (wanghaining@huawei.com) | Rel-10 | 42 | Maurice | GTPchaining |  | PCG-24 | SP-47 |  |  |
| 3566 | 941.1 | Deleted - Stage 2 for GTPchaining |  | 337d? | 2008-12-11 A | 2010-03-25 A | 100% |  | 2008-12-11 | 2010-03-25 | 337d? |  | finish no earlier than 2010-03-25 | S2 | 2696h | 2696h | GTPchaining | 22 | Huawei | Haining Wang (wanghaining@huawei.com) | Rel-10 | 42 | Maurice |  | 23.402 | PCG-24 | SP-47 |  |  |
| 3567 | 942 | Deleted - UTRAN 2 ms TTI uplink range improvement |  | 272d? | 2009-03-06 A | 2010-03-19 A | 100% |  | 2009-03-06 | 2010-03-19 | 272d? |  | finish no earlier than 2010-03-19 | R1; R2; R3; R4 | 8704h | 8704h | RANimp-2mTTI_ULimp | 22 | Nokia Siemens Networks | Karri Ranta-aho (karri.ranta-aho@nsn.com) | Rel-10 | 43 | Patrick | RANimp-2mTTI_ULimp | 25.133, 25.212, 25.214, 25.321, 25.331 | PCG-24 | RP-47 | RP-100040 |  |
| 3568 | 943 | Deleted - Enhanced Home NodeB / eNodeB continuation of Rel-9 |  | 337d? | 2008-12-11 A | 2010-03-25 A | 100% |  | 2008-12-11 | 2010-03-25 | 337d? |  |  | S2 | 2696h | 2696h | eEHNB | 23 | Alcatel-Lucent | Nicolas Drevon | Rel-10 | 44 | Maurice | eEHNB |  | PCG-24 | SP-47 |  | HNB |
| 3569 | 944 | **Deleted - Fixed Wireless Customer-Premises Equipment (CPE) RF Requirements** |  | 391d? | 2009-12-04 A | 2011-06-03 A | 100% |  | 2009-12-04 | 2011-06-03 | 391d? |  |  | R4; R5 | 12512h | 12512h | FW_CPE_RF | 24 | Verizon Wireless | zheng.zhao@verizonwireless.com | Rel-10 | 46 | Issam | FW_CPE_RF | LTE | PCG-27 | RP-52 |  |  |
| 3570 | 944.1 | Deleted - Core part: Fixed Wireless Customer-Premises Equipment (CPE) RF Requirements |  | 391d? | 2009-12-04 A | 2011-06-03 A | 100% |  | 2009-12-04 | 2011-06-03 | 391d? |  | finish no earlier than 2011-06-03 | R4 | 3128h | 3128h | FW_CPE_RF-Core | 24 | Verizon Wireless | zheng.zhao@verizonwireless.com | Rel-10 | 46 | Issam | FW_CPE_RF-Core | 36.101 | PCG-27 | RP-52 | RP-110539 |  |
| 3571 | 944.2 | Deleted - Test part: Fixed Wireless Customer-Premises Equipment (CPE) RF Requirements |  | 391d? | 2009-12-04 A | 2011-06-03 A | 100% |  | 2009-12-04 | 2011-06-03 | 391d? |  | finish no earlier than 2011-06-03 | R5 | 3128h | 3128h | FW_CPE_RF-UEConTest | 24 | Verizon Wireless | zheng.zhao@verizonwireless.com | Rel-10 | 46 | Ingbert | FW_CPE_RF-UEConTest | 36.521-1 | PCG-27 | RP-52 | RP-110504 |  |
| 3572 | 945 | **Deleted - Latency reductions for LTE** |  | 266d? | 2009-12-04 A | 2010-12-10 A | 100% |  | 2009-12-04 | 2010-12-10 | 266d? |  |  | R2; R1 | 8512h | 8512h | LTE_LATRED | 24 | Ericsson | henrik.enbuske@ericsson.com | Rel-10 | 46 | Yong-Jun | LTE_LATRED | LTE | PCG-26 | RP-50 |  |  |
| 3573 | 945.1 | Deleted - Core part: Latency reductions for LTE |  | 266d? | 2009-12-04 A | 2010-12-10 A | 100% |  | 2009-12-04 | 2010-12-10 | 266d? |  | finish no earlier than 2010-12-10 | R2; R1 | 4256h | 4256h | LTE_LATRED-Core | 24 | Ericsson | henrik.enbuske@ericsson.com | Rel-10 | 46 | Yong-Jun | LTE_LATRED-Core | 36.213, 36.300, 36.306, 36.321, 36.331 | PCG-26 | RP-50 | RP-101112 |  |
| 3574 | 946 | **Deleted - Enhanced Interference Management for Home NodeBs** |  | 131d? | 2010-03-19 A | 2010-09-17 A | 100% |  | 2010-03-19 | 2010-09-17 | 131d? |  |  | R3 | 2096h | 2096h | HNB_IM | 24 | Qualcomm | Andrei Radulescu (aradules@qualcomm.com) | Rel-10 | 47 | Juha | HNB_IM | UTRA | PCG-25 | RP-49 | RP-100754 | HNB |
| 3575 | 946.1 | Deleted - Core part: Enhanced Interference Management for Home NodeBs |  | 131d? | 2010-03-19 A | 2010-09-17 A | 100% |  | 2010-03-19 | 2010-09-17 | 131d? |  | finish no earlier than 2010-09-17 | R3 | 1048h | 1048h | HNB_IM-Core | 24 | Qualcomm | Andrei Radulescu (aradules@qualcomm.com) | Rel-10 | 47 | Juha | HNB_IM-Core | 25.413, 25.467, 25.469 | PCG-25 | RP-49 | RP-100754 | HNB |
| 3576 | 947 | Release 10 Studies | milestone | 0d? | 2009-03-12 A | 2009-03-12 A | 100% |  | 2009-03-12 | 2011-03-23 | 531d? |  | finish no earlier than 2011-03-23 | CP; GP; RP; SP |  |  |  |  |  |  | Rel-10 |  |  |  |  |  |  |  |  |

Notes:
- 3552: -
- 3553: GP#51 completed. GP#47 approved WID
- 3554: GP#52 completed
- 3555: -
- 3556: Not completed internet-draft, waiting for draft-montemurro to complete
- 3557: SP#53/IETF#81: RFC 6275 completed
- 3558: -
- 3559: SP#35 Stage 1 completed. SP#45 Stage 2 work stopped. SP#46 work stopped/abandoned
- 3560: SP#35 completed. SP#46 work stopped/abandoned
- 3561: SP#45 Stage 2 work stopped
- 3562: SP#45 work stopped/abandoned
- 3563: SP#45 work stopped/abandoned
- 3564: SP#45 work stopped/abandoned
- 3565: SP#47 work stopped (depending on ongoing related CT4 work). Stage 1 in UID_320022 Rel-8 Requirements for evolution of the 3GPP system architecture (AIPN-SAE): 22.278, 22.011, 22.246
- 3566: SP#47 work stopped
- 3567: RP#47 work stopped/abandoned (no CR approved). Cell sets the TTI (Transmission Time Interval) to 2 ms
- 3568: SP#47 deleted (SA2 work moved under SA1 UID_450053). SP#44 Umbrella Feature created to host WIs moved out of Rel-9 (SA2 UID_420034 on IMS aspects of Architecture for Home NodeB)
- 3569: RP#52 work stopped (lack of contributions). Add new power classES in CP-150E-UTRAN UL to allow CPE type applications to be operated at higher max output power
- 3570: RP#52 work stopped at 55% (lack of contributions)
- 3571: RP#52 work stopped (lack of contributions)
- 3572: RP#50 work stopped (RP-101266)
- 3573: RP#50 work stopped (RP-101266)
- 3574: RP#49 stopped (no further standardization needed). Ensure that Enhanced Interference Management methods identified in Rel-9 for HNBs do not fail in deployments with a large penetration of CSG-aware UEs
- 3575: RP#49 stopped (no further standardization needed)
- 3576: -

| ID | WBS | Task | Type | Duration | Start | Finish | Complete | Baseline start | Baseline finish | Baseline duration | Constraint | Resources | Work | Actual work | Acronym | Impacted TSs and TRs | WI rapporteur name | Release | TSG approved | MCC resp | Acronym_3GU_Export | PCG approved | Status Report | PCG stopped | TSG stopped |
| --- | --- | --- | --- | --- | --- | --- | --- | --- | --- | --- | --- | --- | --- | --- | --- | --- | --- | --- | --- | --- | --- | --- | --- | --- | --- |
| 3577 | 948 | **Study on enhanced voice service requirements for the Evolved Packet System (EPS)** |  | 670d? | 2007-09-03 A | 2010-03-25 A | 100% | 2007-09-03 | 2010-03-25 | 670d? |  | S1; S4 | 18744h | 18744h | FS_EV_EPS | 22.813 | France Telecom | Rel-10 | 37 | Alain | FS_EV_EPS |  |  |  |  |
| 3578 | 948.1 | Use cases definition and service and system requirements |  | 334d? | 2007-09-03 A | 2008-12-11 A | 100% | 2007-09-03 | 2008-12-11 | 334d? | finish no earlier than 2008-12-11 | S1 | 2672h | 2672h | FS_EV_EPS-S1 | 22.813 | France Telecom | Rel-10 | 37 | Alain | FS_EV_EPS-S1 |  |  |  |  |
| 3579 | 948.2 | Codec specific part of FS_EV_EPS |  | 669d? | 2007-09-03 A | 2010-03-25 A | 100% | 2007-09-03 | 2010-03-25 | 669d? | finish no earlier than 2010-03-25 | S4 | 5352h | 5352h | FS_EV_EPS-S4 | 22.813 | Ericsson | Rel-10 | 37 | Paolo | FS_EV_EPS-S4 |  |  |  |  |
| 3580 | 949 | Study on advanced requirements for IP interconnect |  | 528d? | 2007-12-04 A | 2009-12-10 A | 100% | 2007-12-04 | 2009-12-10 | 528d? | finish no earlier than 2009-12-10 | S1 | 4224h | 4224h | FS_IPXS | 22.893 | Telefónica O2 | Rel-10 | 38 | Alain | FS_IPXS | 21 |  |  |  |
| 3581 | 950 | Study on Personal Broadcast Service |  | 397d? | 2008-09-18 A | 2010-03-25 A | 100% | 2008-09-18 | 2010-03-25 | 397d? | finish no earlier than 2010-03-25 | S1 | 3168h | 3168h | FS_PBS | 22.947 | ETRI | Rel-10 | 41 | Alain | FS_PBS | 21 |  |  |  |
| 3582 | 951 | Study on LCS support in SAE for non-3GPP accesses |  | 397d? | 2008-09-18 A | 2010-03-25 A | 100% | 2008-09-18 | 2010-03-25 | 397d? | finish no earlier than 2010-03-25 | S1 | 3168h | 3168h | FS_LCS_n3GPP | 22.814 | SK Telecom | Rel-10 | 41 | Alain | FS_LCS_n3GPP | 21 |  |  |  |
| 3583 | 952 | Study on Haptic Services |  | 272d? | 2009-03-12 A | 2010-03-25 A | 100% | 2009-03-12 | 2010-03-25 | 272d? | finish no earlier than 2010-03-25 | S1 | 2168h | 2168h | FS_Haptics | 22.987 | SK Telecom | Rel-10 | 43 | Alain | FS_Haptics | 22 |  |  |  |
| 3584 | 953 | Study on System enhancements for the use of IMS services in Local BreakOut and Optimal Routing of Media |  | 575d? | 2007-10-01 A | 2009-12-10 A | 100% | 2007-10-01 | 2009-12-10 | 575d? | finish no earlier than 2009-12-10 | S2 | 4600h | 4600h | FS_IMS_LBO_ORM | 23.894 | Telecom Italia, BT | Rel-10 | 37 | Maurice | FS_IMS_LBO_ORM |  |  |  |  |
| 3585 | 954 | Study on Intra Domain Connection of RAN Nodes to Multiple CN Nodes |  | 533d? | 2008-03-12 A | 2010-03-25 A | 100% | 2008-03-12 | 2010-03-25 | 533d? | finish no earlier than 2010-03-25 | S2 | 4264h | 4264h | FS_IDC | 23.924 (was 23.823) | China Mobile | Rel-10 | 39 | Maurice | FS_IDC | 21 |  |  |  |
| 3586 | 955 | Study on Single Radio Voice Call Continuity enhancements |  | 341d? | 2009-06-04 A | 2010-09-23 A | 100% | 2009-06-04 | 2010-09-23 | 341d? | finish no earlier than 2010-09-23 | S2 | 2728h | 2728h | FS_eSRVCC | 23.856 | China Mobile | Rel-10 | 44 | Maurice | FS_eSRVCC | 23 |  |  |  |
| 3587 | 956 | Study on Single Radio Video Call Continuity for 3G-CS |  | 131d? | 2010-03-25 A | 2010-09-23 A | 100% | 2010-03-25 | 2010-09-23 | 131d? | finish no earlier than 2010-09-23 | S2 | 1048h | 1048h | FS_vSRVCC | 23.886 | Samsung | Rel-10 | 47 | Maurice | FS_vSRVCC | 24 |  |  |  |
| 3588 | 957 | Study on S2b Mobility based on GTP |  | 56d? | 2010-03-25 A | 2010-06-10 A | 100% | 2010-03-25 | 2010-06-10 | 56d? | finish no earlier than 2010-06-07 | S2 | 448h | 448h | FS_SMOG | 23.834 | Alcatel-Lucent | Rel-10 | 47 | Maurice | FS_SMOG | 24 |  |  |  |
| 3589 | 958 | Study on Surround Sound codec extension for PSS and MBMS |  | 530d? | 2009-03-12 A | 2011-03-23 A | 100% | 2009-03-12 | 2011-03-23 | 530d? | finish no earlier than 2011-03-23 | S4 | 4240h | 4240h | FS_SS_PSS_MBMS | 26.950 | Fraunhofer Gesellschaft | Rel-10 | 43 | Paolo | FS_SS_PSS_MBMS | 22 |  |  |  |
| 3590 | 959 | Study on Improved Video Coding Support |  | 205d? | 2010-06-10 A | 2011-03-23 A | 100% | 2010-06-10 | 2011-03-23 | 205d? | finish no earlier than 2011-03-23 | S4 | 1640h | 1640h | FS_IVCS | 26.904 | Nokia, ETRI | Rel-10 | 48 | Paolo | FS_IVCS | 25 |  |  |  |
| 3591 | 960 | Study on Rc Reference Point Functionalities and Message Flows |  | 397d? | 2008-09-18 A | 2010-03-25 A | 100% | 2008-09-18 | 2010-03-25 | 397d? | finish no earlier than 2010-03-23 | S5 | 3170.08h | 3170.08h | FS_OAM_Rc | 32.825 | Huawei | Rel-10 | 41 | Mirko | FS_OAM_Rc | 21 |  |  |  |
| 3592 | 961 | Study on Telecommunication Management; Energy Savings Management |  | 271d? | 2009-03-12 A | 2010-03-25 A | 100% | 2009-03-12 | 2010-03-25 | 271d? | finish no earlier than 2010-03-25 | S5 | 2168h | 2168h | FS_OAM_ESM | 32.826 | Orange, Vodafone | Rel-10 | 43 | Mirko | FS_OAM_ESM | 22 |  |  |  |
| 3593 | 962 | Study on Integration of Device Management Information with Itf-N |  | 211d? | 2009-06-04 A | 2010-03-25 A | 100% | 2009-06-04 | 2010-03-25 | 211d? | finish no earlier than 2010-03-25 | S5 | 1688h | 1688h | FS_IDMI_Itf-N | 32.827 | Motorola | Rel-10 | 44 | Mirko | FS_IDMI_Itf-N | 23 |  |  |  |
| 3594 | 963 | Study on Alignment of 3GPP Generic NRM IRP and TMF Shared Information Data (SID) model |  | 335d? | 2009-12-10 A | 2011-03-23 A | 100% | 2009-12-10 | 2011-03-23 | 335d? | finish no earlier than 2011-03-23 | S5 | 2680h | 2680h | FS_3GNRM_TMFSID | 32.828 | Nokia Siemens Networks | Rel-10 | 46 | Mirko | FS_3GNRM_TMFSID | 24 |  |  |  |
| 3595 | 964 | Study on Harmonization of 3GPP Alarm IRP and TMF Interface Program (TIP) Fault Management |  | 335d? | 2009-12-10 A | 2011-03-23 A | 100% | 2009-12-10 | 2011-03-23 | 335d? | finish no earlier than 2011-03-23 | S5 | 2680h | 2680h | FS_3G_TMF_FM | 32.829 | Nokia Siemens Networks, Alcatel-Lucent | Rel-10 | 46 | Mirko | FS_3G_TMF_FM | 24 |  |  |  |
| 3596 | 965 | Study on Alarm Correlation and Alarm Root Cause Analysis |  | 205d? | 2010-06-10 A | 2011-03-23 A | 100% | 2010-06-10 | 2011-03-23 | 205d? | finish no earlier than 2011-03-23 | S5 | 1640h | 1640h | FS_AC_ARCA | 32.832 | Ericsson | Rel-10 | 48 | Mirko | FS_AC_ARCA | 25 |  |  |  |
| 3597 | 966 | Study on Alignment of 3GPP PM IRP and TMF Interface Program (TIP) PM |  | 205d? | 2010-06-10 A | 2011-03-23 A | 100% | 2010-06-10 | 2011-03-23 | 205d? | finish no earlier than 2011-03-23 | S5 | 1640h | 1640h | FS_3G_TMF_PM | 32.831 | Alcatel-Lucent | Rel-10 | 48 | Mirko | FS_3G_TMF_PM | 25 |  |  |  |
| 3598 | 967 | Study on Policy and Charging Rules Function (PCRF) failure and restoration |  | 261d? | 2009-08-18 A | 2010-09-17 A | 100% | 2009-08-18 | 2010-09-17 | 261d? | finish no earlier than 2010-09-17 | C3 | 2088h | 2088h | FS_PCRF-FR | 29.816 | NEC | Rel-10 | 45 | Adrian | FS_PCRF-FR | 23 |  |  |  |
| 3599 | 968 | Study on User Data Convergence (UDC) evolution |  | 206d? | 2010-06-04 A | 2011-03-18 A | 100% | 2010-06-04 | 2011-03-18 | 206d? | finish no earlier than 2011-03-18 | C4 | 1648h | 1648h | FS_UDCe | 23.845 | Alcatel-Lucent | Rel-10 | 48 | Kimmo | FS_UDCe | 25 |  |  |  |
| 3600 | 969 | Study on UICC access to IMS |  | 206d? | 2010-06-04 A | 2011-03-18 A | 100% | 2010-06-04 | 2011-03-18 | 206d? | finish no earlier than 2011-03-18 | C6 | 1648h | 1648h | FS_IMS-UICC | 31.828 | Gemalto | Rel-10 | 48 | Xavier | FS_IMS-UICC | 25 |  |  |  |
| 3601 | 970 | Study on Uplink Tx Diversity for HSPA |  | 208.4d? | 2009-08-18 A | 2010-06-04 A | 100% | 2009-08-18 | 2010-06-04 | 208.4d? | finish no earlier than 2010-06-04 | R4 | 1667.2h | 1667.2h | FS_UL-TxDiv-HSPA | UTRA 25.863 | Qualcomm | Rel-10 | 45 | Issam | FS_UL-TxDiv-HSPA | 23 | RP-100499 |  |  |
| 3602 | 971 | Study on Solutions for Energy Saving within UTRA Node B |  | 206d? | 2009-12-04 A | 2010-09-17 A | 100% | 2009-12-04 | 2010-09-17 | 206d? | finish no earlier than 2010-09-17 | R1; R3 | 3296h | 3296h | FS_Energy_UMTS | UTRA 25.927 | Vodafone | Rel-10 | 46 | Patrick | FS_Energy_UMTS | 24 | RP-100796 |  |  |
| 3603 | 972 | Study on Potential solutions for energy saving for E-UTRAN |  | 348.75d? | 2010-02-02 A | 2011-06-03 A | 100% | 2010-02-02 | 2011-06-03 | 348.75d? | finish no earlier than 2011-06-03 | R3; R2 | 5580h | 5580h | FS_Energy_LTE | LTE 36.927 | China Mobile | Rel-10 | 47 | Juha | FS_Energy_LTE | 24 | RP-110597 |  |  |
| 3604 | 973 | Study on Improvements of distributed antenna for 1.28Mcps TDD |  | 200.55d? | 2010-03-05 A | 2010-12-10 A | 100% | 2010-03-05 | 2010-12-10 | 200.55d? | finish no earlier than 2010-12-10 | R1; R2; R3 | 4813.2h | 4813.2h | FS_distr_ant_LCR_TDD | UTRA 25.865 | ZTE | Rel-10 | 47 | Patrick | FS_distr_ant_LCR_TDD | 24 | RP-101287 |  |  |
| 3605 | 974 | Deleted - Study on Unauthenticated PS Emergency Calls |  | 471d? | 2008-06-05 A | 2010-03-25 A | 100% | 2008-06-05 | 2010-03-25 | 471d? | finish no earlier than 2010-03-25 | S1 | 3768h | 3768h | FS_UAPSEC | 22.984 | Nokia Siemens Networks | Rel-10 | 40 | Alain | FS_UAPSEC | 21 |  | PCG-24 | SP-47 |
| 3606 | 975 | Deleted - Study on enhancements to IMS border functions for IMS Interconnection of services |  | 586d? | 2008-09-18 A | 2010-12-15 A | 100% | 2008-09-18 | 2010-12-15 | 586d? | finish no earlier than 2010-12-15 | S2 | 4688h | 4688h | FS_eIMS_IBCF | 23.848 | Starent Networks | Rel-10 | 41 | Maurice | FS_eIMS_IBCF | 21 |  | PCG-26 | SP-50 |
| 3607 | 976 | Deleted - Study on EPC Charging enhancement |  | 211d? | 2009-06-04 A | 2010-03-25 A | 100% | 2009-06-04 | 2010-03-25 | 211d? | finish no earlier than 2010-03-25 | S5 | 1688h | 1688h | FS_EPCcharg |  | Nokia Siemens Networks | Rel-10 | 44 | Mirko | FS_EPCcharg | 23 |  | PCG-24 | SP-47 |
| 3608 | 977 | Deleted - Study on Interworking Proxy between GTP based and PMIP based interfaces |  | 186d? | 2009-09-18 A | 2010-06-04 A | 100% | 2009-09-18 | 2010-06-04 | 186d? | finish no earlier than 2010-06-04 | C4 | 1488h | 1488h | FS_GTP-MIP-IW | 29.875 | NTT DoCoMo | Rel-10 | 45 | Kimmo | FS_GTP-MIP-IW | 23 |  | PCG-25 | CP-48 |
| 3609 | 978 | Release 9 Features | milestone | 0d? | 2000-01-01 A | 2000-01-01 A | 100% | 2000-01-01 | 2000-01-01 | 0d? |  | CP; GP; RP; SP |  |  |  |  |  | Rel-9 |  |  |  |  |  |  |  |

Notes:
- 3577: SP#47 completed. TR 22.813-100 for Approval. Spin-off Feature UID_470030 Codec for Enhanced Voice Services / WI rapporteur e-mail: philippe.lottin@orange.com
- 3578: SP#47 completed. TR 22.813-100 for Approval / WI rapporteur e-mail: philippe.lottin@orange.com
- 3579: SP#47 completed. TR 22.813-100 for Approval / WI rapporteur e-mail: stefan.bruhn@ericson.com
- 3580: SP#46 completed. Linked to Rel-8 Feature UID_380060 IP Interconnection of Services (IPinterc). Spin-off Feature Rel-11 UID_470051 Advanced IP Interconnection of Services / WI rapporteur e-mail: chris.friel@O2.com
- 3581: SP#47 completed / WI rapporteur e-mail: Jaihyung Cho
- 3582: SP#47 completed / WI rapporteur e-mail: jinhan.song@sktelecom.com
- 3583: SP#47 completed. Covers Mobile/Fixed/Cordless/etc terminals. Haptic (human-machine tactile communication) extend service offering & richness of user experience beyond current visual & auditory senses / WI rapporteur e-mail: jinhan.song@sktelecom.com
- 3584: SP#46 completed. Spin-off Feature UID_460028 Optimal Media Routeing (OMR). Linked to Study on Multimedia Session Continuity UID_350051, Study on Centralized IMS Service Control UID_330012, IMS inter-operator service interconnection interface UID_360011 / WI rapporteur e-mail: mario.madella@telecomitalia.it, victor.kueh@bt.com
- 3585: SP#47 completed. Concluded no further normative work expected. Linked to 23.236 / WI rapporteur e-mail: LIU HONG (liuhongyfw@chinamobile.com)
- 3586: SP#49 completed (Conclusion: select the SIP anchoring based solution for normative work CR (TEI10) introducing and completing stage-2). Analyzed performance of Rel-8 SRVCC solution from E-UTRAN/HSPA to UTRAN/GERAN / WI rapporteur e-mail: Hou zhiqiang (houzhiqiang@chinamobile.com), Jiang Yi (jiangyi@chinamobile.com)
- 3587: SP#49 completed. TR 23.886v100 for Approval. Related to Rel-8 UID_350030 Single Radio Voice Call Continuity for 3GPP (SAES-SRVCC). Study how to provide Video Call seamless service continuity for 3G/LTE terminal user / WI rapporteur e-mail: Haris Zisimopoulos (haris.z@samsung.com)
- 3588: SP#48 completed. Triggered by Rel-8 UID_350027 SAE for support for non-3GPP accesses. Nature of relationship: S2b one of the interfaces defined for non-3GPP accesses support in EPS. Stage 1 in Rel-8 UID_320022 (AIPN-SAE) 22.278,22.101 / WI rapporteur e-mail: bruno.landais@alcatel-lucent.com
- 3589: SP#51 completed. Extend Rel-8 UID_34043 (Extending PSS and MBMS User Services for optimized Mobile TV) / WI rapporteur e-mail: jan.plogsties@iis.franhofer.de
- 3590: SP#51 completed. Extends Rel-9 Improved Video Support for PSS and MBMS (UID_430039) / WI rapporteur e-mail: imed.bouazizi@nokia.com, jaihyung@etri.re.kr
- 3591: SP#47 completed / WI rapporteur e-mail: shan.mingjun@huawei.com
- 3592: SP#47 completed. Study result might impact Feature UID_420011 Self Organising Networks (SON) / WI rapporteur e-mail: Jean-Michel Cornilly (Orange)
- 3593: SP#47 completed / WI rapporteur e-mail: Yizhi Yao (yzyao@motorola.com)
- 3594: SP#51 completed / WI rapporteur e-mail: olaf.pollakowski@nsn.com
- 3595: SP#51 completed / WI rapporteur e-mail: olaf.pollakowski@nsn.com, Padma.Sudarsan@alcatel-lucent.com
- 3596: SP#51 completed / WI rapporteur e-mail: edwin.tse@ericsson.com
- 3597: SP#51 completed / WI rapporteur e-mail: Padma.Sudarsan@alcatel-lucent.com
- 3598: CP#49 completed / WI rapporteur e-mail: gottfried.punz@nw.neclab.eu
- 3599: CP#51 completed. Study UDC evolution from FeaturES in CP-150Rel-9 UID_400034 and Rel-10 UID_480011 UDC Data Model / WI rapporteur e-mail: jean-jacques.trottin@alcatel-lucent.com
- 3600: CP#51 completed / WI rapporteur e-mail: Denis.Lheriteau@gemalto.com
- 3601: RP#48 completed / WI rapporteur e-mail: Heechoon Lee (heechoon@qualcomm.com)
- 3602: RP#49 completed. Based on ETSI EE TS 102 706. / WI rapporteur e-mail: Prakash.bhat@vodafone.com
- 3603: RP#52 completed / WI rapporteur e-mail: Yang Ning (yangning@chinamobile.com)
- 3604: RP#50 completed. TR 25.865 v101 for Approval / WI rapporteur e-mail: huang.he4@zte.com.cn
- 3605: SP#47 work stopped/abandoned / WI rapporteur e-mail: Juergen.Merkel@nsn.com
- 3606: SP#50 work stopped. Additional work may be addressed as part of the Rel-11 Feature UID_470051 Advanced IP Interconnection of Services (IPXS) / WI rapporteur e-mail: Rajat Ghai (rghai@starentnetworks.com)
- 3607: SP#47 work stopped. Issue covered by Rel-10 UID_460039 Charging for LIPA_SIPTO and UID_4700xy Charging for IFOM / WI rapporteur e-mail: Gerald.Goermer@nsn.com
- 3608: CP#48 work stopped/abandoned / WI rapporteur e-mail: takaaki.matsuura.sp@s1.nttdocomo.com
- 3609: -

| ID | WBS | Task | Duration | Start | Finish | Complete | Baseline start | Baseline finish | Baseline duration | Constraint | Resources | Work | Actual work | Acronym | PCG approved | WI rapporteur name | WI rapporteur e-mail | Release | TSG approved | MCC resp | Special Focus Doc | Acronym_3GU_Export | Status Report |
| --- | --- | --- | --- | --- | --- | --- | --- | --- | --- | --- | --- | --- | --- | --- | --- | --- | --- | --- | --- | --- | --- | --- | --- |
| 3610 | 979 | **Enhanced Home NodeB / eNodeB** | 921d? | 2008-06-05 A | 2011-12-09 A | 100% | 2008-06-05 | 2011-12-09 | 921d? |  | S1; S2; S3; S5; C1; C6; R2; R3; R4; R5; GP | 113136h | 113136h | EHNB | 21 | T-Mobile | michael.kurz@t-mobile.at | Rel-9 | 40 | Alain | HNB | EHNB |  |
| 3611 | 979.1 | Stage 1 for EHNB | 261d? | 2008-06-05 A | 2009-06-04 A | 100% | 2008-06-05 | 2009-06-04 | 261d? | finish no earlier than 2009-06-04 | S1 | 2088h | 2088h | EHNB | 21 | T-Mobile | michael.kurz@t-mobile.at | Rel-9 | 40 | Alain | HNB |  |  |
| 3612 | 979.2 | Architecture aspects of EHNB | 266d? | 2008-09-18 A | 2009-09-24 A | 100% | 2008-09-18 | 2009-09-24 | 266d? | finish no earlier than 2009-09-22 | S2 | 2128h | 2128h | EHNB | 21 | T-Mobile | sebastian.speicher@telekom.de | Rel-9 | 41 | Maurice | HNB |  |  |
| 3613 | 979.3 | Security aspects of Enhanced Home NodeB / eNodeB | 262d? | 2008-12-11 A | 2009-12-10 A | 100% | 2008-12-11 | 2009-12-10 | 262d? | finish no earlier than 2009-12-10 | S3 | 2096h | 2096h | EHNB-Sec | 22 | Huawei | Marcus Wong (mwong@huawei.com) | Rel-9 | 42 | Mirko | HNB | EHNB-Sec |  |
| 3614 | 979.4 | CT1 aspects - Support of Home NB and Home eNB enhancements | 321d? | 2009-09-18 A | 2010-12-10 A | 100% | 2009-09-18 | 2010-12-10 | 321d? | finish no earlier than 2010-12-10 | C1 | 2568h | 2568h | EHNB-CT1 | 23 | Qualcomm | Ramachandran Subramanian (rsubrama@qualcomm.com) | Rel-9 | 45 | Frederic | HNB | EHNB-CT1 |  |
| 3615 | 979.5 | CT6 aspects - Support of Home NB and Home eNB enhancements | 131d? | 2009-09-18 A | 2010-03-19 A | 100% | 2009-09-18 | 2010-03-19 | 131d? | finish no earlier than 2010-03-19 | C6 | 1048h | 1048h | EHNB-CT6 | 23 | Qualcomm | Ramachandran Subramanian (rsubrama@qualcomm.com) | Rel-9 | 45 | Xavier | HNB | EHNB-CT6 |  |
| 3616 | 979.6 | 3G HNB Gateway and LTE HeNB Gateway OAM&P | 336d? | 2008-12-11 A | 2010-03-25 A | 100% | 2008-12-11 | 2010-03-25 | 336d? | finish no earlier than 2010-03-25 | S5 | 2688h | 2688h | HNB-OAM_GW | 22 | China Mobile | GangChen (chengang@chinamobile.com) | Rel-9 | 42 | Mirko | HNB | HNB-OAM_GW |  |
| 3617 | 979.7 | 3G HNB and LTE HeNB OAM&P Type 1 Interface | 272d? | 2009-03-12 A | 2010-03-25 A | 100% | 2009-03-12 | 2010-03-25 | 272d? | finish no earlier than 2010-03-25 | S5 | 2168h | 2168h | HNB_eHNB-OAM_Type1 | 22 | Huawei | Zou Lan (zlan@huawei.com) | Rel-9 | 43 | Mirko | HNB | HNB_eHNB-OAM_Type1 |  |
| 3618 | 979.8 | 3G HNB and LTE HeNB OAM&P Type 2 Interface | 225d? | 2009-05-15 A | 2010-03-25 A | 100% | 2009-05-15 | 2010-03-25 | 225d? | finish no earlier than 2010-03-25 | S5 | 1800h | 1800h | HNB_eHNB-OAM_Type2 | 23 | Ericsson | edwin.tse@ericsson.com | Rel-9 | 44 | Mirko | HNB | HNB_eHNB-OAM_Type2 |  |
| 3619 | 979.9 | LTE FDD Home eNodeB RF Requirements | 336d? | 2008-12-05 A | 2010-03-19 A | 100% | 2008-12-05 | 2010-03-19 | 336d? | finish no earlier than 2010-03-19 | R4 | 2688h | 2688h | HeNB-RF_FDD | 22 | Motorola | Ying Cai (yingcai@motorola.com) | Rel-9 | 42 | Issam | HNB | HeNB-RF_FDD | RP-100035 |
| 3620 | 979.10 | LTE TDD Home eNodeB RF Requirements | 271d? | 2009-03-06 A | 2010-03-19 A | 100% | 2009-03-06 | 2010-03-19 | 271d? | finish no earlier than 2010-03-19 | R4 | 2168h | 2168h | HeNB-RF_TDD | 22 | China Mobile | Nan Li (linan@chinamobile.com) | Rel-9 | 43 | Issam | HNB | HeNB-RF_TDD | RP-100036 |
| 3621 | 979.11 | Home NB and Home eNB enhancements - RAN3 aspects | 197d? | 2009-03-06 A | 2009-12-04 A | 100% | 2009-03-06 | 2009-12-04 | 197d? | finish no earlier than 2009-12-04 | R3 | 1576h | 1576h | EHNB-RAN3 | 22 | Alcatel-Lucent | Martin Warner (mw15@alcatel-lucent.com) | Rel-9 | 43 | Juha | HNB | EHNB-RAN3 | RP-091050 |
| 3622 | 979.12 | Home NB and Home eNB enhancements - RAN2 aspects | 271d? | 2009-03-06 A | 2010-03-19 A | 100% | 2009-03-06 | 2010-03-19 | 271d? | finish no earlier than 2010-03-19 | R2 | 2168h | 2168h | EHNB-RAN2 | 22 | Huawei | Yang Xudong (yangxudong@huawei.com) | Rel-9 | 43 | Yong-Jun | HNB | EHNB-RAN2 | RP-100037 |
| 3623 | 979.13 | Conformance Test Aspects – Home NB enhancements for FDD | 322d? | 2010-09-17 A | 2011-12-09 A | 100% | 2010-09-17 | 2011-12-09 | 322d? | finish no earlier than 2011-12-09 | R5 | 2568h | 2568h | EHNB-UTRA_FDD_UEConTest | 25 | Huawei | trica_li@huawei.com | Rel-9 | 49 | Ingbert | HNB | EHNB-UTRA_FDD_UEConTest | RP-111679 |
| 3624 | 979.14 | Conformance Test Aspects – Home eNB enhancements | 201d? | 2010-12-10 A | 2011-09-16 A | 100% | 2010-12-10 | 2011-09-16 | 201d? | finish no earlier than 2011-09-16 | R5 | 1608h | 1608h | EHNB-LTE_UEConTest | 26 | Qualcomm | Mrs Lena Chaponniere (lchaponn@qualcomm.com) | Rel-9 | 50 | Ingbert | HNB | EHNB-LTE_UEConTest | RP-110972 |
| 3625 | 979.15 | Home NB and Home eNB enhancements - GERAN aspects | 341d? | 2009-05-18 A | 2010-09-03 A | 100% | 2009-05-18 | 2010-09-03 | 341d? | finish no earlier than 2010-09-03 | GP | 2728h | 2728h | EHNB-GERAN | 23 | Nokia Siemens Networks | leonardo.provvedi@roke.co.uk | Rel-9 | 42 | Paolo | HNB | EHNB-GERAN |  |
| 3626 | 980 | **Value-Added Services for Short Message Service** | 586d? | 2007-09-10 A | 2009-12-04 A | 100% | 2007-09-10 | 2009-12-04 | 586d? |  | S1; C4; C1 | 20264h | 20264h | VAS4SMS |  | China Mobile | Wu Bin (wubin@chinamobile.com) | Rel-9 | 37 | Alain |  | VAS4SMS |  |
| 3627 | 980.1 | Stage 1 for VAS4SMS | 133d? | 2007-09-10 A | 2008-03-12 A | 100% | 2007-09-10 | 2008-03-12 | 133d? | finish no earlier than 2008-03-21 | S1 | 1064h | 1064h | VAS4SMS |  | China Mobile | Wu Bin (wubin@chinamobile.com) | Rel-9 | 37 | Alain |  |  |  |
| 3628 | 980.2 | CT4 aspects of VAS4SMS Interface and Signalling Flow | 322d? | 2008-09-12 A | 2009-12-04 A | 100% | 2008-09-12 | 2009-12-04 | 322d? | finish no earlier than 2009-12-04 | C4 | 2568h | 2568h | VAS4SMS | 21 | China Mobile | Wu Bin (wubin@chinamobile.com) | Rel-9 | 41 | Kimmo |  |  |  |
| 3629 | 980.3 | CT1 aspects of VAS4SMS Interface and Signalling Flow | 321d? | 2008-09-09 A | 2009-12-04 A | 100% | 2008-09-09 | 2009-12-04 | 321d? | finish no earlier than 2009-12-04 | C1 | 2568h | 2568h | VAS4SMS | 21 | China Mobile | Wu Bin (wubin@chinamobile.com) | Rel-9 | 41 | Frederic |  |  |  |
| 3630 | 981 | **Definition of End-User Identity** | 334d? | 2007-09-03 A | 2008-12-11 A | 100% | 2007-09-03 | 2008-12-11 | 334d? |  | S1 | 5344h | 5344h | EUI |  | Nokia Siemens Networks | Juergen.Merkel@nsn.com | Rel-9 | 38 | Alain |  | EUI |  |
| 3631 | 981.1 | Stage 1 for Definition of End-User Identity | 334d? | 2007-09-03 A | 2008-12-11 A | 100% | 2007-09-03 | 2008-12-11 | 334d? | finish no earlier than 2008-12-11 | S1 | 2672h | 2672h | EUI | 21 | Nokia Siemens Networks | Juergen.Merkel@nsn.com | Rel-9 | 38 | Alain |  |  |  |
| 3632 | 982 | **Customized Ringing Signal** | 522d? | 2007-12-06 A | 2009-12-03 A | 100% | 2007-12-06 | 2009-12-03 | 522d? |  | S1; C1 | 11296h | 11296h | CRS | 21 | SK Telecom, China Mobile | Donghee Shim (SK Telecom), Jianping Zheng (China Mobile) | Rel-9 | 38 | Alain |  | CRS |  |
| 3633 | 982.1 | Stage 1 for Customized Ringing Signal | 266d? | 2007-12-06 A | 2008-12-11 A | 100% | 2007-12-06 | 2008-12-11 | 266d? | finish no earlier than 2008-12-11 | S1 | 2128h | 2128h | CRS | 21 | SK Telecom, China Mobile | Donghee Shim (SK Telecom), Jianping Zheng (China Mobile) | Rel-9 | 38 | Alain |  |  |  |
| 3634 | 982.2 | Stage 3 for IMS Customized Ringing Signal (CRS) Service | 136d? | 2009-05-29 A | 2009-12-03 A | 100% | 2009-05-29 | 2009-12-03 | 136d? | finish no earlier than 2010-06-04 | C1 | 816h | 816h | CRS | 23 | China Mobile | wangzhao | Rel-9 | 44 | Frederic |  |  |  |

Notes:
- 3610: RP#54 Testing completed / Impacted TSs and TRs: UTRA, LTE
- 3611: CP#49 the SA1-reqs are moving. CT1 will align when the work in SA1 is clear. (was SP#44 completed.) / Impacted TSs and TRs: 22.220, 22.011
- 3612: SP#45 completed / Impacted TSs and TRs: 23.401, 23.402, 23.060, New 23.830
- 3613: SP#46 completed / Impacted TSs and TRs: New 33.320
- 3614: CP#50 completed (Roaming aspects for manual CSG selection, Support of temporary users and CSG membership changes, Support of user controlled and operator controlled lists) / Impacted TSs and TRs: 23.122, 24.008, 24.285, 24.301
- 3615: CP#47 completed. Storing of CSG related data items on the USIM / Impacted TSs and TRs: 31.102
- 3616: SP#47 completed / Impacted TSs and TRs: 32.632, 32.633, 32.635, New (32.771, 32.772, 32.773, 32.775, 32.781, 32.782, 32.783, 32.785)
- 3617: SP#47 completed / Impacted TSs and TRs: 32.581, 32.582, 32.583, 32.584, New (32.591, 32.592, 32.593, 32.594)
- 3618: SP#47 completed / Impacted TSs and TRs: New (32.571, 32.572)
- 3619: RP#47 completed / Impacted TSs and TRs: 36.104, 36.141, New TR 36.921
- 3620: RP#47 completed / Impacted TSs and TRs: 36.104, 36.141, 36.300, 36.331, 36.413, New TR 36.922
- 3621: RP#46 completed (based on high priority items specified in RP-090995) / Impacted TSs and TRs: 25.413, 25.467, 25.467, 25.468, 25.469, 25.469, 36.401, 36.413, New 25.444
- 3622: RP#47 completed / Impacted TSs and TRs: 25.304, 25.331, 25.367, 36.300, 36.304, 36.331
- 3623: UTRA. RP#54 completed. Testing for UID_430026 Support of Home NB and Home eNB enhancements RAN2 aspects (25.304, 25.331, 25.367) / Impacted TSs and TRs: 34.108, 34.121-1, 34.121-2, 34.123-1, 34.123-2, 34.123-3
- 3624: RP#53 completed / Impacted TSs and TRs: 36.508, 36.523-1, 36.523-2, 36.523-3
- 3625: GP#47 completed. GP#42 WID approved / Impacted TSs and TRs: 43.055, 43.129, 44.018, 44.060, 45.008, 48.008, 48.018
- 3626: CP#46 completed
- 3627: SP#39 completed. SP#43 Feature moved to Rel-9 / Impacted TSs and TRs: new 22.142
- 3628: CP#46 completed / Impacted TSs and TRs: new 23.142
- 3629: CP#46 completed / Impacted TSs and TRs: 23.040
- 3630: SP#42 closed. Stage 1 work closed at 5% completion due to lack of input (added only the EUI definition in 21.905)
- 3631: SP#42 closed. Stage 1 work closed at 5% completion due to lack of input (added only the EUI definition in 21.905) / Impacted TSs and TRs: 21.905
- 3632: CP#48 completed
- 3633: SP#42 completed. / Impacted TSs and TRs: 22.173, new 22.183
- 3634: CP#48 completed / Impacted TSs and TRs: 24.173, new 24.183

| ID | WBS | Task | Type | Duration | Start | Finish | Complete | Baseline start | Baseline finish | Baseline duration | Constraint | Resources | Work | Actual work | Acronym | PCG approved | Impacted TSs and TRs | WI rapporteur name | Release | TSG approved | MCC resp | Special Focus Doc | Acronym_3GU_Export | Status Report |
| --- | --- | --- | --- | --- | --- | --- | --- | --- | --- | --- | --- | --- | --- | --- | --- | --- | --- | --- | --- | --- | --- | --- | --- | --- |
| 3635 | 983 | **Public Warning System** |  | 1315d? | 2007-12-06 A | 2012-12-07 A | 100% | 2007-12-06 | 2012-12-07 | 1315d? |  | S1; C1; C4; R2; R3; R5 | 73920h | 73920h | PWS | 21 | LTE | T-Mobile | Rel-9 | 38 | Alain | Public Safety (I-A) | PWS |  |
| 3636 | 983.1 | Stage 1 for Public Warning System |  | 266d? | 2007-12-06 A | 2008-12-11 A | 100% | 2007-12-06 | 2008-12-11 | 266d? | finish no earlier than 2008-12-11 | S1 | 2128h | 2128h | PWS | 21 | 22.268 | T-Mobile | Rel-9 | 38 | Alain | Public Safety (I-A) |  |  |
| 3637 | 983.2 | **Stage 3 for Public Warning System** |  | 137d? | 2009-05-29 A | 2009-12-04 A | 100% | 2009-05-29 | 2009-12-04 | 137d? |  | C1; C4 | 4368h | 4368h | PWS-St3 | 23 |  | Qualcomm | Rel-9 | 44 | Frederic | Public Safety (I-A) | PWS-St3 |  |
| 3638 | 983.2.1 | CT1 aspects of Stage 3 for Public Warning System |  | 137d? | 2009-05-29 A | 2009-12-04 A | 100% | 2009-05-29 | 2009-12-04 | 137d? | finish no earlier than 2009-12-04 | C1 | 1088h | 1088h | PWS-St3 | 23 | 23.041 | Qualcomm | Rel-9 | 44 | Frederic | Public Safety (I-A) |  |  |
| 3639 | 983.2.2 | CT4 aspects of Stage 3 for Public Warning System |  | 136d? | 2009-05-30 A | 2009-12-04 A | 100% | 2009-05-30 | 2009-12-04 | 136d? | finish no earlier than 2009-12-04 | C4 | 1088h | 1088h | PWS-St3 | 23 | 29.168 | Qualcomm | Rel-9 | 44 | Kimmo | Public Safety (I-A) |  |  |
| 3640 | 983.3 | Public Warning System (PWS) – RAN aspects |  | 136d? | 2009-05-30 A | 2009-12-04 A | 100% | 2009-05-30 | 2009-12-04 | 136d? | finish no earlier than 2009-12-04 | R2; R3 | 2176h | 2176h | PWS-RAN | 23 | LTE 36.300, 36.302, 36.331, 36.413 | AT&T | Rel-9 | 44 | Yong-Jun | Public Safety (I-A) | PWS-RAN | RP-091052 |
| 3641 | 983.4 | Conformance Test Aspects – Public Warning System (PWS) – RAN aspects for LTE |  | 267d? | 2011-12-02 A | 2012-12-07 A | 100% | 2011-12-02 | 2012-12-07 | 267d? | finish no earlier than 2012-12-07 | R5 | 2128h | 2128h | PWS-RAN_UEConTest | 28 | 36.508, 36.523-1, 36.523-2, 36.523-3 | Qualcomm | Rel-9 | 54 | Ingbert | Public Safety (I-A) | PWS-RAN_UEConTest | RP-121525 |
| 3642 | 984 | **Support of Personal Area Networks and Enhancements to Personal Network Management** |  | 523d? | 2008-06-05 A | 2010-06-04 A | 100% | 2008-06-05 | 2010-06-04 | 523d? |  | S1; C1 | 12544h | 12544h | PAN_EPNM | 21 |  | Vodafone | Rel-9 | 40 | Alain |  | PAN_EPNM |  |
| 3643 | 984.1 | Stage 1 for Support of Personal Area Networks and Enhancements to Personal Network Management | milestone | 0d? | 2008-06-05 A | 2008-06-05 A | 100% | 2008-06-05 | 2008-06-05 | 0d? | finish no earlier than 2008-06-05 | S1 |  |  | PAN_EPNM | 21 | 22.259 | Vodafone | Rel-9 | 40 | Alain |  |  |  |
| 3644 | 984.2 | Stage 2 for Support of Personal Area Networks and Enhancements to Personal Network Management |  | 196d? | 2009-03-06 A | 2009-12-04 A | 100% | 2009-03-06 | 2009-12-04 | 196d? | finish no earlier than 2009-12-04 | C1 | 1568h | 1568h | PAN_EPNM | 22 | 23.259 | Huawei | Rel-9 | 43 | Frederic |  |  |  |
| 3645 | 984.3 | Stage 3 for Support of Personal Area Networks and Enhancements to Personal Network Management |  | 326d? | 2009-03-09 A | 2010-06-04 A | 100% | 2009-03-09 | 2010-06-04 | 326d? | finish no earlier than 2010-06-04 | C1 | 2608h | 2608h | PAN_EPNM | 22 | 24.259 | Huawei | Rel-9 | 43 | Frederic |  |  |  |
| 3646 | 985 | **Multi-Media Telephony Service enhancements** |  | 472d? | 2008-06-05 A | 2010-03-25 A | 100% | 2008-06-05 | 2010-03-25 | 472d? |  | S1; S5; C1 | 17840h | 17840h | eMMTel | 21 |  | France Telecom | Rel-9 | 40 | Alain |  | eMMTel |  |
| 3647 | 985.1 | Stage 1 for eMMTel |  | 136d? | 2008-06-05 A | 2008-12-11 A | 100% | 2008-06-05 | 2008-12-11 | 136d? | start no earlier than 2008-06-05 | S1 | 1088h | 1088h | eMMTel | 21 | 22.173 | France Telecom | Rel-9 | 40 | Alain |  |  |  |
| 3648 | 985.2 | Multimedia Telephony (MMTel) Service and Supplementary Services - Online Charging and completion for Offline Charging (all supplementary services) |  | 272d? | 2009-03-12 A | 2010-03-25 A | 100% | 2009-03-12 | 2010-03-25 | 272d? | finish no earlier than 2010-03-25 | S5 | 2168h | 2168h | eMMTel-SS-CH | 22 | 32.275, 32.298, 32.299 | Alcatel-Lucent | Rel-9 | 43 | Mirko |  | eMMTel-SS-CH |  |
| 3649 | 985.3 | Support of Real-time Transfer of Tariff Information (RTTI) in IMS charging |  | 271d? | 2009-03-12 A | 2010-03-25 A | 100% | 2009-03-12 | 2010-03-25 | 271d? | finish no earlier than 2010-03-25 | S5 | 2168h | 2168h | IMSTSS-RTTI-CH | 22 | 32.240, 32.280, 32.298, 32.299 | Orange | Rel-9 | 43 | Mirko |  | IMSTSS-RTTI-CH |  |
| 3650 | 985.4 | Stage 3 - Enhancements for Completion of Communications Supplementary service |  | 136d? | 2009-05-30 A | 2009-12-04 A | 100% | 2009-05-30 | 2009-12-04 | 136d? | finish no earlier than 2009-12-04 | C1 | 1088h | 1088h | eMMTel-CC | 23 | 24.642 | France Telecom | Rel-9 | 44 | Frederic |  | eMMTel-CC |  |
| 3651 | 986 | **User Data Convergence (UDC)** |  | 527d? | 2008-06-05 A | 2010-06-10 A | 100% | 2008-06-05 | 2010-06-10 | 527d? |  | S1; S5; C4 | 25056h | 25056h | UDC | 21 |  | Nokia Siemens Networks | Rel-9 | 40 | Alain |  | UDC |  |
| 3652 | 986.1 | Stage 1 for User Data Convergence (UDC) |  | 136d? | 2008-06-05 A | 2008-12-11 A | 100% | 2008-06-05 | 2008-12-11 | 136d? | start no earlier than 2008-06-05 | S1 | 1088h | 1088h | UDC | 21 | 22.101, new 22.985 | Nokia Siemens Networks | Rel-9 | 40 | Alain |  |  |  |
| 3653 | 986.2 | **Stage 2/3 for User Data Convergence (UDC) Technical Realization** |  | 272d? | 2009-03-06 A | 2010-03-19 A | 100% | 2009-03-06 | 2010-03-19 | 272d? |  | C4 | 5376h | 5376h | UDC-CN | 22 |  | Ericsson | Rel-9 | 43 | Kimmo |  | UDC-CN |  |
| 3654 | 986.2.1 | User Data Convergence (UDC) Technical Realization (Stage 2) |  | 271d? | 2009-03-06 A | 2010-03-19 A | 100% | 2009-03-06 | 2010-03-19 | 271d? | finish no earlier than 2010-03-19 | C4 | 2168h | 2168h | UDC-CN | 22 | new 23.335 | Ericsson | Rel-9 | 43 | Kimmo |  |  |  |
| 3655 | 986.2.2 | User Data Convergence (UDC) Protocol Description |  | 130d? | 2009-09-18 A | 2010-03-19 A | 100% | 2009-09-18 | 2010-03-19 | 130d? | finish no earlier than 2010-03-19 | C4 | 1040h | 1040h | UDC-CN | 23 | new 29.335 | China Mobile, Ericsson | Rel-9 | 45 | Kimmo |  |  |  |
| 3656 | 986.3 | **User Data Convergence (UDC) Modelling and Management** |  | 266d? | 2009-06-04 A | 2010-06-10 A | 100% | 2009-06-04 | 2010-06-10 | 266d? |  | S5 | 5944h | 5944h | UDC-MMAN | 23 |  | T-Mobile, China Mobile, Ericsson | Rel-9 | 44 | Mirko |  | UDC-MMAN |  |
| 3657 | 986.3.1 | UDC – Framework for Model Handling and Management |  | 266d? | 2009-06-04 A | 2010-06-10 A | 100% | 2009-06-04 | 2010-06-10 | 266d? | finish no earlier than 2010-06-10 | S5 | 2128h | 2128h | UDC-MMAN-MFRM | 23 | 32.172, new 32.181 | T-Mobile | Rel-9 | 44 | Mirko |  | UDC-MMAN-MFRM |  |
| 3658 | 986.3.2 | UDC – Common Baseline Information Model |  | 211d? | 2009-06-04 A | 2010-03-25 A | 100% | 2009-06-04 | 2010-03-25 | 211d? | finish no earlier than 2010-03-25 | S5 | 1688h | 1688h | UDC-MMAN-CBIM | 23 | 32.172, new 32.182 | China Mobile, Ericsson | Rel-9 | 44 | Mirko |  | UDC-MMAN-CBIM |  |

Notes:
- 3635: TSG#46 completed. Larger scope than Rel-8 Feature UID_370051 (ETWS). Triggered by TR 22.968 Study UID_320025 (FS_PWS) / WI rapporteur e-mail: Mark.Younge@t-mobile.com
- 3636: SP#42 completed / WI rapporteur e-mail: Mark.Younge@t-mobile.com
- 3637: RP#46 completed / WI rapporteur e-mail: Ramachandran Subramanian (rsubrama@qualcomm.com)
- 3638: CP#46 completed / WI rapporteur e-mail: Ramachandran Subramanian (rsubrama@qualcomm.com)
- 3639: CP#46 completed / WI rapporteur e-mail: Ramachandran Subramanian (rsubrama@qualcomm.com)
- 3640: RP#46 completed / WI rapporteur e-mail: don.zelmer@att.com
- 3641: RP#58 completed / WI rapporteur e-mail: Shubhang Vora (svora@qualcomm.com)
- 3642: CP#48 completed / WI rapporteur e-mail: armin.toepfer@vodafone.com
- 3643: SP#40 completed / WI rapporteur e-mail: armin.toepfer@vodafone.com
- 3644: CP#46 completed / WI rapporteur e-mail: Lili Yang (kadyyang@huawei.com)
- 3645: CP#48 completed / WI rapporteur e-mail: Lili Yang (kadyyang@huawei.com)
- 3646: SP#47 completed / WI rapporteur e-mail: philippe.lottin@orange.com
- 3647: SP#42 completed / WI rapporteur e-mail: philippe.lottin@orange.com
- 3648: SP#47 completed / WI rapporteur e-mail: maryse.gardella@alcatel-lucent.com
- 3649: SP#47 completed. Linked to SA5 Rel-8 UID_380042 AoC support in IMS Charging (IMSTSS) / WI rapporteur e-mail: Jean-Luc Garcia (jl.garcia@orange-ftgroup.com)
- 3650: CP#46 completed / WI rapporteur e-mail: Youssef.chadli@orange-ftgroup.com
- 3651: SP#48 completed. Triggered by Rel-8 SA5 Study of Common Profile Storage Framework of User Data for network services and management (UID_320006) TR 32.808 / WI rapporteur e-mail: juergen.merkel@nsn.com
- 3652: SP#42 completed / WI rapporteur e-mail: juergen.merkel@nsn.com
- 3653: - / WI rapporteur e-mail: emiliano.merino@ericsson.com
- 3654: CP#47 completed / WI rapporteur e-mail: emiliano.merino@ericsson.com
- 3655: CP#47 completed / WI rapporteur e-mail: Lan Si Zhong (lansizhong@chinamobile.com), emiliano.merino@ericsson.com
- 3656: SP#48 completed / WI rapporteur e-mail: istvan.aba@t-mobile.at, lansizhong@chinamobile.com, miguel.a.garcia@ericsson.com
- 3657: SP#48 completed / WI rapporteur e-mail: istvan.aba@t-mobile.at
- 3658: SP#47 completed / WI rapporteur e-mail: Lan Si Zhong, Miguel Garcia

| ID | WBS | Task | Duration | Start | Finish | Complete | Baseline start | Baseline finish | Baseline duration | Constraint | Resources | Work | Actual work | Acronym | PCG approved | WI rapporteur name | WI rapporteur e-mail | Release | TSG approved | MCC resp | Acronym_3GU_Export | Status Report | Special Focus Doc |
| --- | --- | --- | --- | --- | --- | --- | --- | --- | --- | --- | --- | --- | --- | --- | --- | --- | --- | --- | --- | --- | --- | --- | --- |
| 3659 | 987 | **IMS Services Centralization and Continuity** | 393d? | 2008-09-18 A | 2010-03-19 A | 100% | 2008-09-18 | 2010-03-19 | 393d? |  | S1; S2; C1 | 30992h | 30992h | IMS_SCC | 21 | NEC | joerg.swetina@neclab.eu | Rel-9 | 41 | Alain | IMS_SCC |  |  |
| 3660 | 987.1 | Stage 1 - Inter-Device Transfer – Requirements | 61d? | 2008-09-18 A | 2008-12-11 A | 100% | 2008-09-18 | 2008-12-11 | 61d? | finish no earlier than 2009-06-18 | S1 | 488h | 488h | IMS_SCC-IDT | 21 | NEC | joerg.swetina@neclab.eu | Rel-9 | 41 | Alain | IMS_SCC-IDT |  |  |
| 3661 | 987.2 | **Stage 2/3 for IMS Service Continuity Enhancements: Service, Policy and Interactions** | 393d? | 2008-09-18 A | 2010-03-19 A | 100% | 2008-09-18 | 2010-03-19 | 393d? |  | S2; C1 | 9456h | 9456h | IMS_SCC-SPI | 21 | Huawei | HengLiang Zhang (hl_zhang@huawei.com) | Rel-9 | 41 | Maurice | IMS_SCC-SPI |  |  |
| 3662 | 987.2.1 | Stage 2 for IMS Service Continuity Enhancements: Service, Policy and Interactions | 186d? | 2008-09-18 A | 2009-06-04 A | 100% | 2008-09-18 | 2009-06-04 | 186d? | finish no earlier than 2009-06-04 | S2 | 1488h | 1488h | IMS_SCC-SPI | 21 | Huawei | HengLiang Zhang (hl_zhang@huawei.com) | Rel-9 | 41 | Maurice |  |  |  |
| 3663 | 987.2.2 | Stage 3 for IMS Service Continuity Enhancements: Service, Policy, Interactions and Inter UE Transfer | 212d? | 2009-05-29 A | 2010-03-19 A | 100% | 2009-05-29 | 2010-03-19 | 212d? | finish no earlier than 2010-03-19 | C1 | 1696h | 1696h | IMS_SCC-SPI | 23 | Qualcomm | Roozbeh Atarius (ratarius@qualcomm.com) | Rel-9 | 44 | Frederic |  |  |  |
| 3664 | 987.3 | **Stage 2/3 for IMS Centralized Services** | 393d? | 2008-09-18 A | 2010-03-19 A | 100% | 2008-09-18 | 2010-03-19 | 393d? |  | S2; C1 | 9448h | 9448h | IMS_SCC-ICS | 21 | Alcatel-Lucent | andy.bennett@alcatel-lucent.com | Rel-9 | 41 | Maurice | IMS_SCC-ICS |  |  |
| 3665 | 987.3.1 | Stage 2 for IMS Centralized Services | 186d? | 2008-09-18 A | 2009-06-04 A | 100% | 2008-09-18 | 2009-06-04 | 186d? | finish no earlier than 2009-06-04 | S2 | 1488h | 1488h | IMS_SCC-ICS | 21 | Alcatel-Lucent | andy.bennett@alcatel-lucent.com | Rel-9 | 41 | Maurice |  |  |  |
| 3666 | 987.3.2 | Stage 3 for Enhancements to IMS Centralized Services | 212d? | 2009-05-29 A | 2010-03-19 A | 100% | 2009-05-29 | 2010-03-19 | 212d? | finish no earlier than 2010-03-19 | C1 | 1688h | 1688h | IMS_SCC-ICS | 23 | Nokia Siemens Networks | Peter.Leis@nsn.com | Rel-9 | 44 | Frederic |  |  |  |
| 3667 | 987.4 | Stage 3 - IMS Centralized Services support via I1 interface | 271d? | 2009-03-06 A | 2010-03-19 A | 100% | 2009-03-06 | 2010-03-19 | 271d? | finish no earlier than 2010-03-19 | C1 | 2168h | 2168h | IMS_SCC-ICS_I1 | 22 | Huawei | Lili Yang(kadyyang@huawei.com) | Rel-9 | 43 | Frederic | IMS_SCC-ICS_I1 |  |  |
| 3668 | 988 | **Service Specific Access Control in EPS** | 922d? | 2008-12-11 A | 2012-06-15 A | 100% | 2008-12-11 | 2012-06-15 | 922d? |  | S1; C1; R5 | 26000h | 26000h | SSAC | 22 | NTT DoCoMo | Frederic Thepot (thepot@docomolab-euro.com) | Rel-9 | 42 | Alain | SSAC |  |  |
| 3669 | 988.1 | Stage 1 for Service Specific Access Control in EPS | 1d? | 2008-12-11 A | 2008-12-11 A | 100% | 2008-12-11 | 2008-12-11 | 1d? | start no earlier than 2008-12-11 | S1 | 8h | 8h | SSAC | 22 | NTT DoCoMo | Frederic Thepot (thepot@docomolab-euro.com) | Rel-9 | 42 | Alain |  |  |  |
| 3670 | 988.2 | Stage 3 for Service Specific Access Control in EPS | 212d? | 2009-05-29 A | 2010-03-19 A | 100% | 2009-05-29 | 2010-03-19 | 212d? | finish no earlier than 2010-03-19 | C1 | 1696h | 1696h | SSAC | 23 | NTT DoCoMo | Hideyuki Yamashita (yamashitahi@s1.nttdocomo.co.jp) | Rel-9 | 44 | Frederic |  |  |  |
| 3671 | 988.3 | Conformance Test Aspects - Service Specific Access Control | 272d? | 2011-06-07 A | 2012-06-15 A | 100% | 2011-06-07 | 2012-06-15 | 272d? | finish no earlier than 2012-06-15 | R5 | 2168h | 2168h | SSAC_UEConTest | 27 | NTT DoCoMo | Takao.Shimizu.rp@nttdocomo.com | Rel-9 | 52 | Ingbert | SSAC_UEConTest | RP-120447 |  |
| 3672 | 989 | **Support for IMS Emergency Calls over GPRS and EPS** | 3785d? | 2000-01-03 A | 2014-06-13 A | 100% | 2000-01-03 | 2014-06-13 | 3785d? |  | S1; S2; S3; C1; C3; C4; R2; R3; R5; IETF | 293512h | 293512h | IMS_EMER_GPRS_EPS | 21 | Alcatel-Lucent | Deborah Barclay | Rel-9 | 38 | Maurice | IMS_EMER_GPRS_EPS |  | Public Safety (I-A) |
| 3673 | 989.1 | Stage 1 for IMS Emergency Calls over GPRS and EPS | 239d? | 2008-01-14 A | 2008-12-11 A | 100% | 2008-01-14 | 2008-12-11 | 239d? | finish no earlier than 2008-12-11 | S1 | 1912h | 1912h | IMS_EMER_GPRS_EPS | 21 | Alcatel-Lucent | Deborah Barclay | Rel-9 | 38 | Alain |  |  | Public Safety (I-A) |
| 3674 | 989.2 | Stage 2 for IMS Emergency Calls over GPRS and EPS | 364d? | 2008-01-14 A | 2009-06-04 A | 100% | 2008-01-14 | 2009-06-04 | 364d? | finish no earlier than 2009-06-04 | S2 | 2912h | 2912h | IMS_EMER_GPRS_EPS | 21 | Alcatel-Lucent | Deborah Barclay | Rel-9 | 38 | Maurice |  |  | Public Safety (I-A) |
| 3675 | 989.3 | Security aspects for IMS Emergency Calls over GPRS and EPS | 391d? | 2008-12-12 A | 2010-06-10 A | 100% | 2008-12-12 | 2010-06-10 | 391d? | finish no earlier than 2010-03-25 | S3 | 3128h | 3128h | IMS_EMER_GPRS_EPS-Sec | 22 | Alcatel-Lucent | Deborah Barclay | Rel-9 | 42 | Mirko | IMS_EMER_GPRS_EPS-Sec |  | Public Safety (I-A) |
| 3676 | 989.4 | **Stage 3 for IMS Emergency Calls over GPRS and EPS** | 801d? | 2009-05-29 A | 2012-06-15 A | 100% | 2009-05-29 | 2012-06-15 | 801d? |  | C1; C3; C4; R5 | 33331.7h | 33331.7h | IMS_EMER_GPRS_EPS | 23 | Alcatel-Lucent | Frank Alfano (falfano@alcatel-lucent.com) | Rel-9 | 44 | Frederic |  |  | Public Safety (I-A) |
| 3677 | 989.4.1 | CT1 aspects - Stage 3 for IMS Emergency Calls over GPRS and EPS | 212d? | 2009-05-29 A | 2010-03-19 A | 100% | 2009-05-29 | 2010-03-19 | 212d? | finish no earlier than 2010-03-19 | C1 | 1696h | 1696h | IMS_EMER_GPRS_EPSC1 | 23 | Alcatel-Lucent | Frank Alfano (falfano@alcatel-lucent.com) | Rel-9 | 44 | Frederic |  |  | Public Safety (I-A) |
| 3678 | 989.4.2 | Conformance Test Aspects - CT1 aspects for IMS Emergency Calls over GPRS and EPS | 532d? | 2010-06-04 A | 2012-06-15 A | 100% | 2010-06-04 | 2012-06-15 | 532d? | finish no earlier than 2012-06-15 | R5 | 4256h | 4256h | IMS_EMER_GPRS_EPS_UEConTest | 25 | Samsung | stoyan.baev@partner.samsung.com | Rel-9 | 48 | Ingbert | IMS_EMER_GPRS_EPS_UEConTest | RP-120445 | Public Safety (I-A) |
| 3679 | 989.4.3 | CT3 aspects - Stage 3 for IMS Emergency Calls over GPRS and EPS | 82d? | 2009-05-29 A | 2009-09-18 A | 100% | 2009-05-29 | 2009-09-18 | 82d? | start no earlier than 2009-05-29 | C3 | 651.68h | 651.68h | IMS_EMER_GPRS_EPSC3 | 23 | Alcatel-Lucent | Frank Alfano (falfano@alcatel-lucent.com) | Rel-9 | 44 | Adrian |  |  | Public Safety (I-A) |
| 3680 | 989.4.4 | CT4 aspects - Stage 3 for IMS Emergency Calls over GPRS and EPS | 137d? | 2009-05-29 A | 2009-12-04 A | 100% | 2009-05-29 | 2009-12-04 | 137d? | finish no earlier than 2009-12-04 | C4 | 1096h | 1096h | IMS_EMER_GPRS_EPSC4 | 23 | Alcatel-Lucent | Frank Alfano (falfano@alcatel-lucent.com) | Rel-9 | 44 | Kimmo |  |  | Public Safety (I-A) |
| 3681 | 989.5 | Support for IMS Emergency Calls over LTE | 207d? | 2000-01-03 A | 2000-10-16 A | 100% | 2000-01-03 | 2000-10-16 | 207d? |  | R2; R3 | 3312h | 3312h | IMS_EMER_LTE | 22 | Alcatel-Lucent | Sudeep Palat (spalat@alcatel-lucent.com) | Rel-9 | 42 | Yong-Jun | IMS_EMER_LTE | RP-090698 | Public Safety (I-A) |
| 3682 | 989.6 | Conformance Test Aspects – Support for IMS Emergency Calls over LTE | 187d? | 2010-03-25 A | 2010-12-10 A | 100% | 2010-03-25 | 2010-12-10 | 187d? | finish no earlier than 2010-12-10 | R5 | 1496h | 1496h | IMS_EMER_LTE_UEConTest | 24 | Ericsson | leif.mattisson@ericsson.com | Rel-9 | 47 | Ingbert | IMS_EMER_LTE_UEConTest | RP-101068 | Public Safety (I-A) |

Notes:
- 3659: CP#47 completed
- 3660: SP#42 completed / Impacted TSs and TRs: 22.101, 22.228
- 3661: -
- 3662: SP#57 Removal of the MSC server assisted mid-call feature from Rel-9 by 23.237CR#0433 (CT1 proposed moving this feature to Rel-10). SP#44 completed. TR 23.838 for Approval / Impacted TSs and TRs: 23.237, 23.292, 23.216, new 23.838
- 3663: CP#47 completed / Impacted TSs and TRs: 24.216, 24.229, 24.237
- 3664: -
- 3665: SP#44 completed. TR 23.883 for Information + Approval / Impacted TSs and TRs: 23.292, new 23.883
- 3666: CP#47 completed / Impacted TSs and TRs: 24.292, 24.604, 24.607, 24.608, 24.611, 24.623
- 3667: CP#47 completed / Impacted TSs and TRs: 24.237, 24.292, new 24.294
- 3668: CP#47 completed. Triggered by TR 22.986 Study on Service Specific Access Control in EPS. As EPS is a PS-Domain only system, Domain Specific Access Control (DSAC) doesn't apply, hence SSAC allows restriction of voice and non-voice calls separately
- 3669: SP#42 completed. If UE supports E-UTRA and IMS, SSAC is a mandatory Rel-9 function (during congestion in emergency case earthquake/tsunami improves mobile communications). / Impacted TSs and TRs: 22.011 CR0136
- 3670: CP#47 completed / Impacted TSs and TRs: 24.173, 27.007
- 3671: RP#56 completed. Testing for Stage 3 for Service Specific Access Control in EPS (24.173, 27.007) UID_440040 / Impacted TSs and TRs: 34.229-1, 34.229-2, 34.229-3
- 3672: RP#56 completed testing. CP#47 completed. SP#48 completed / Impacted TSs and TRs: GERAN, LTE
- 3673: SP#42 completed / Impacted TSs and TRs: 22.101
- 3674: SP#44 completed / Impacted TSs and TRs: 23.869, 23.060, 23.167, 23.203, 23.221, 23.228, 23.271, 23.401, 23.402
- 3675: SP#48 completed / Impacted TSs and TRs: 33.401, 33.402
- 3676: RP#56 completed testing. CP#47 completed / Impacted TSs and TRs: GERAN, LTE
- 3677: CP#47 completed / Impacted TSs and TRs: 23.122, 24.008, 24.229, 24.301, 24.302
- 3678: RP#56 completed / Impacted TSs and TRs: 34.108, 34.123-1, 34.123-2, 34.123-3, 34.229-1, 34.229-2, 34.229-3, 36.508, 36.523-1, 36.523-2, 36.523-3
- 3679: CP#45 completed / Impacted TSs and TRs: 29.212, 29.213, 29.214, 29.215
- 3680: CP#46 completed / Impacted TSs and TRs: 23.003, 23.008, 29.060, 29.272, 29.273, 29.274, 29.275, 29.276
- 3681: RP#45 completed / Impacted TSs and TRs: 36.331, 36.413
- 3682: RP#50 completed / Impacted TSs and TRs: 36.508, 36.523-1, 36.523-2, 36.523-3

| ID | WBS | Task | Type | Duration | Start | Finish | Complete | Baseline start | Baseline finish | Baseline duration | Constraint | Resources | Work | Actual work | Acronym | PCG approved | WI rapporteur name | WI rapporteur e-mail | Release | TSG approved | MCC resp | Special Focus Doc | Acronym_3GU_Export | Status Report |
| --- | --- | --- | --- | --- | --- | --- | --- | --- | --- | --- | --- | --- | --- | --- | --- | --- | --- | --- | --- | --- | --- | --- | --- | --- |
| 3683 | 989.7 | **Single Radio Voice Call Continuity (SRVCC) support for IMS Emergency Calls** |  | 1511d? | 2008-09-18 A | 2014-06-13 A | 100% | 2008-09-18 | 2014-06-13 | 1511d? |  | S2; C1; C4; C3; IETF | 112300h | 112300h | IMS_EMER_GPRS_EPS-SRVCC | 21 | China Mobile | Yu Qing (Yuqing@chinamobile.com) | Rel-9 | 41 | Maurice | Public Safety (I-A) | IMS_EMER_GPRS_EPS-SRVCC |  |
| 3684 | 989.7.1 | SRVCC support for IMS Emergency Calls |  | 322d? | 2008-09-18 A | 2009-12-10 A | 100% | 2008-09-18 | 2009-12-10 | 322d? | finish no earlier than 2009-12-10 | S2 | 2576h | 2576h | IMS_EMER_GPRS_EPS-SRVCC | 21 | China Mobile | Yu Qing (Yuqing@chinamobile.com) | Rel-9 | 41 | Maurice | Public Safety (I-A) |  |  |
| 3685 | 989.7.2 | **CT aspects of SRVCC support for IMS Emergency Calls** |  | 1330d? | 2009-05-29 A | 2014-06-13 A | 100% | 2009-05-29 | 2014-06-13 | 1330d? |  | C1; C4; C3; IETF | 49284h | 49284h | IMS_EMER_GPRS_EPS-SRVCC | 24 | China Mobile | jiangyi@chinamobile.com | Rel-9 | 46 | Frederic | Public Safety (I-A) |  |  |
| 3686 | 989.7.2.1 | CT1 aspects of SRVCC support for IMS Emergency Calls |  | 137d? | 2009-05-29 A | 2009-12-04 A | 100% | 2009-05-29 | 2009-12-04 | 137d? | finish no earlier than 2009-12-04 | C1 | 1096h | 1096h | IMS_EMER_GPRS_EPS-SRVCC | 23 | China Mobile | jiangyi@chinamobile.com | Rel-9 | 44 | Frederic | Public Safety (I-A) |  |  |
| 3687 | 989.7.2.2 | CT4 aspects of SRVCC support for IMS Emergency Calls |  | 137d? | 2009-05-29 A | 2009-12-04 A | 100% | 2009-05-29 | 2009-12-04 | 137d? | finish no earlier than 2009-12-04 | C4 | 1096h | 1096h | IMS_EMER_GPRS_EPS-SRVCC | 23 | China Mobile | jiangyi@chinamobile.com | Rel-9 | 44 | Kimmo | Public Safety (I-A) |  |  |
| 3688 | 989.7.2.3 | CT3 aspects of SRVCC support for IMS Emergency Calls |  | 1d? | 2009-12-04 A | 2009-12-04 A | 100% | 2009-12-04 | 2009-12-04 | 1d? | finish no earlier than 2009-12-04 | C3 | 8h | 8h | IMS_EMER_GPRS_EPS-SRVCC | 24 | China Mobile | jiangyi@chinamobile.com | Rel-9 | 46 | Kimmo | Public Safety (I-A) |  |  |
| 3689 | 989.7.2.4 | (IETF) CT3 aspects of SRVCC support for IMS Emergency Calls (RFC 7254) |  | 568d? | 2012-04-20 A | 2014-06-13 A | 100% | 2012-04-20 | 2014-06-13 | 568d? | finish no earlier than 2014-06-13 | C3-IETF | 4524h | 4524h | IMS_EMER_GPRS_EPS-SRVCC | 29 | Andrew Allen | Andrew Allen | Rel-9 | 56 | Adrian | Public Safety (I-A) |  |  |
| 3690 | 990 | **LCS for LTE and EPS** |  | 981d? | 2008-06-05 A | 2012-03-02 A | 100% | 2008-06-05 | 2012-03-02 | 981d? |  | S2; C1; C4; R2; R1; R3; R4; R5 | 83592h | 83592h | LCS_LTE_EPS | 22 |  |  | Rel-9 | 43 | Maurice | Public Safety (I-A) | LCS_LTE_EPS |  |
| 3691 | 990.1 | **LCS Control Plane Solution for EPS** |  | 468d? | 2008-06-05 A | 2010-03-19 A | 100% | 2008-06-05 | 2010-03-19 | 468d? |  | S2; C4; C1 | 16712h | 16712h | LCS_EPS-CPS | 21 | Polaris Wireless | Robert Gross (rgross@polariswireless.com) | Rel-9 | 40 | Maurice | Public Safety (I-A) | LCS_EPS-CPS |  |
| 3692 | 990.1.1 | Stage 2 for LCS Control Plane Solution for EPS |  | 261d? | 2008-06-05 A | 2009-06-04 A | 100% | 2008-06-05 | 2009-06-04 | 261d? | finish no earlier than 2009-06-04 | S2 | 2088h | 2088h | LCS_EPS-CPS | 21 | Polaris Wireless | Robert Gross (rgross@polariswireless.com) | Rel-9 | 40 | Maurice | Public Safety (I-A) |  |  |
| 3693 | 990.1.2 | CT4 aspects of Control Plane LCS in the EPC |  | 212d? | 2009-05-29 A | 2010-03-19 A | 100% | 2009-05-29 | 2010-03-19 | 212d? | finish no earlier than 2010-03-19 | C4 | 1696h | 1696h | LCS_EPS-CPS | 23 | Polaris Wireless | Robert Gross (rgross@polariswireless.com) | Rel-9 | 44 | Kimmo | Public Safety (I-A) |  |  |
| 3694 | 990.1.3 | CT1 aspects of Control Plane LCS in the EPC |  | 212d? | 2009-05-29 A | 2010-03-19 A | 100% | 2009-05-29 | 2010-03-19 | 212d? | finish no earlier than 2010-03-19 | C1 | 1696h | 1696h | LCS_EPS-CPS | 23 | Polaris Wireless | Robert Gross (rgross@polariswireless.com) | Rel-9 | 44 | Frederic | Public Safety (I-A) |  |  |
| 3695 | 990.2 | Positioning Support for LTE | milestone | 0d? | 2008-12-05 A | 2008-12-05 A | 100% | 2008-12-05 | 2010-06-04 | 392d? | finish no earlier than 2010-06-04 | R2; R1; R3; R4 |  |  | LCS_LTE | 22 | Qualcomm | Nathan Tenny (ntenny@qualcomm.com) | Rel-9 | 42 | Yong-Jun | Public Safety (I-A) | LCS_LTE | RP-100442 |
| 3696 | 990.3 | Conformance Test Aspects – Positioning Support for LTE |  | 512d? | 2010-03-19 A | 2012-03-02 A | 100% | 2010-03-19 | 2012-03-02 | 512d? | finish no earlier than 2012-03-02 | R5 | 4096h | 4096h | LCS_LTE_UEConTest | 24 | Qualcomm | Shubhang Vora (svoral@qualcomm.com) | Rel-9 | 47 | Ingbert | Public Safety (I-A) | LCS_LTE_UEConTest | RP-120034 |
| 3697 | 991 | **MBMS support in EPS** |  | 921d? | 2008-06-05 A | 2011-12-09 A | 100% | 2008-06-05 | 2011-12-09 | 921d? |  | S2; S3; S5; C3; C4; R2; R3; R4; R5 | 82896h | 82896h | MBMS_EPS | 21 | China Mobile | Liu Hong (liuhongyfw@chinamobile.com) | Rel-9 | 40 | Maurice |  | MBMS_EPS |  |
| 3698 | 991.1 | Stage 2 for MBMS support in EPS |  | 261d? | 2008-06-05 A | 2009-06-04 A | 100% | 2008-06-05 | 2009-06-04 | 261d? | finish no earlier than 2009-06-04 | S2 | 2088h | 2088h | MBMS_EPS | 21 | China Mobile | Liu Hong (liuhongyfw@chinamobile.com) | Rel-9 | 40 | Maurice |  |  |  |
| 3699 | 991.2 | Security for MBMS support in EPS |  | 261d? | 2008-12-11 A | 2009-12-10 A | 100% | 2008-12-11 | 2009-12-10 | 261d? | finish no earlier than 2009-12-10 | S3 | 2088h | 2088h | MBMS_EPS | 22 | China Mobile | Liu Hong (liuhongyfw@chinamobile.com) | Rel-9 | 42 | Mirko |  |  |  |
| 3700 | 991.3 | MBMS Charging in EPS |  | 201d? | 2009-03-06 A | 2009-12-10 A | 100% | 2009-03-06 | 2009-12-10 | 201d? | finish no earlier than 2009-12-10 | S5 | 1600h | 1600h | MBMS_EPS | 22 | ZTE | guo.wenjie1@zte.com.cn | Rel-9 | 43 | Mirko |  |  |  |
| 3701 | 991.4 | CT4 aspects of MBMS support in EPS (Stage 3) |  | 137d? | 2009-05-29 A | 2009-12-04 A | 100% | 2009-05-29 | 2009-12-04 | 137d? | finish no earlier than 2009-12-04 | C4 | 1096h | 1096h | MBMS_EPS | 23 | China Mobile, ZTE | wangjingyf@chinamobile.com, lu.fei1@zte.com.cn | Rel-9 | 44 | Kimmo |  |  |  |
| 3702 | 991.5 | CT3 aspects of MBMS support in EPS (Stage 3) |  | 137d? | 2009-05-29 A | 2009-12-04 A | 100% | 2009-05-29 | 2009-12-04 | 137d? | start no earlier than 2009-05-29 | C3 | 1096h | 1096h | MBMS_EPS | 23 | ZTE, China Mobile | zhou.xiaoyun@zte.com.cn, wangjingyf@chinamobile.com | Rel-9 | 44 | Adrian |  |  |  |
| 3703 | 991.6 | MBMS support in LTE |  | 272d? | 2009-03-06 A | 2010-03-19 A | 100% | 2009-03-06 | 2010-03-19 | 272d? | finish no earlier than 2010-03-19 | R2; R3; R4 | 6528h | 6528h | MBMS_LTE | 22 | Huawei | arnaud.meylan@huawei.com | Rel-9 | 43 | Yong-Jun |  | MBMS_LTE | RP-100033 |
| 3704 | 991.7 | Conformance Test Aspects – MBMS support in LTE |  | 262d? | 2010-12-10 A | 2011-12-09 A | 100% | 2010-12-10 | 2011-12-09 | 262d? | finish no earlier than 2011-12-09 | R5 | 2088h | 2088h | MBMS_LTE-UEConTest | 26 | Huawei | Zhang Xin (zhangxin0208@huawei.com) | Rel-9 | 50 | Ingbert |  | MBMS_LTE-UEConTest | RP-111437 |
| 3705 | 992 | **Access Network Discovery and Selection Function enhancements** |  | 333d? | 2008-12-11 A | 2010-03-19 A | 100% | 2008-12-11 | 2010-03-19 | 333d? |  | S2; C1 | 7384h | 7384h | eANDSF | 22 | Motorola | Apostolis Salkintzis (salki@motorola.com) | Rel-9 | 42 | Maurice |  | eANDSF |  |
| 3706 | 992.1 | Stage 2 for Access Network Discovery and Selection Function enhancements |  | 126d? | 2008-12-11 A | 2009-06-04 A | 100% | 2008-12-11 | 2009-06-04 | 126d? | finish no earlier than 2009-06-04 | S2 | 1008h | 1008h | eANDSF | 22 | Motorola | Apostolis Salkintzis (salki@motorola.com) | Rel-9 | 42 | Maurice |  |  |  |
| 3707 | 992.2 | CT1 aspects of Access Network Discovery and Selection Function enhancements |  | 131d? | 2009-09-18 A | 2010-03-19 A | 100% | 2009-09-18 | 2010-03-19 | 131d? | finish no earlier than 2010-03-19 | C1 | 1048h | 1048h | eANDSF | 23 | Panasonic | benjamin.limck@sg.panasonic.com | Rel-9 | 45 | Frederic |  |  |  |

Notes:
- 3683: CP#56 added IETF dependency
- 3684: SP#46 completed / Impacted TSs and TRs: 23.870, 23.216, 23.237
- 3685: CP#46 completed
- 3686: CP#46 completed / Impacted TSs and TRs: 24.229, 24.237
- 3687: CP#46 completed / Impacted TSs and TRs: 29.205, 29.280
- 3688: CP#46 completed / Impacted TSs and TRs: 29.163
- 3689: CP#64 completed / Impacted TSs and TRs: RFC 7254 (was draft-montemurro-gsma-imei-urn)
- 3690: - / Impacted TSs and TRs: LTE
- 3691: Triggered by abandoned Study UID_380068 (FS_LCS_EPS). Linked to Feature UID_380064 Support for IMS Emergency Calls over GPRS and EPS
- 3692: SP#44 completed / Impacted TSs and TRs: 23.891, 23.271, 23.401, 23.402
- 3693: CP#47 completed (IANA registrations outstanding). Stage 3 SLs and SLg interfaces & transport of positioning messages between E-SMLC and MME in the scope of UID_420006 (Positioning Support for LTE) / Impacted TSs and TRs: 24.080, 29.002, 29.272, 29.230, new 24.171, 29.171, 29.172, 29.173
- 3694: CP#47 completed / Impacted TSs and TRs: 24.301
- 3695: RP#48 completed. UID_400038 (LCS Control Plane Solution for EPS) depends on this WI / Impacted TSs and TRs: 34.213, 36.133, 36.211, 36.214, 36.300, 36.305, 36.331, 36.355, 36.410, 36.413, 36.455, new 36.171
- 3696: RP#55 completed. RP#56 TS 37.571-4 v200 for Approval / Impacted TSs and TRs: 36.508, 36.509, new (37.571-1, 37.571-2, 37.571-3, 37.571-4, 37.571-5)
- 3697: RP#47 completed. SP#46, CP#46 completed / Impacted TSs and TRs: LTE
- 3698: SP#44 completed / Impacted TSs and TRs: 23.246
- 3699: SP#46 completed / Impacted TSs and TRs: 33.246
- 3700: SP#46 completed / Impacted TSs and TRs: 32.273, 32.251, 32.298, 32.299
- 3701: CP#46 completed / Impacted TSs and TRs: 29.274, 29.281, 23.007, 23.008
- 3702: CP#46 completed / Impacted TSs and TRs: 29.061
- 3703: RP#47 completed / Impacted TSs and TRs: 25.446, 36.101, 36.104, 36.141, 36.300, 36.304, 36.321, 36.322, 36.323, 36.331, 36.440, 36.441, 36.442, 36.444, 36.445
- 3704: RP#54 completed / Impacted TSs and TRs: 36.508, 36.521-1, 36.521-2, 36.523-1, 36.523-2, 36.523-3
- 3705: CP#47 completed. No new Rel-9 use cases defined. Implement service requirements not covered in Rel-8 / Impacted TSs and TRs: 22.278, SA3 33.402 CR#0055
- 3706: SP#44 completed / Impacted TSs and TRs: 23.402, 23.002
- 3707: CP#47 completed / Impacted TSs and TRs: 24.302, 24.312

| ID | WBS | Task | Duration | Start | Finish | Complete | Baseline start | Baseline finish | Baseline duration | Constraint | Resources | Work | Actual work | Acronym | PCG approved | WI rapporteur name | WI rapporteur e-mail | Release | TSG approved | MCC resp | Acronym_3GU_Export | Impacted TSs and TRs | Status Report |
| --- | --- | --- | --- | --- | --- | --- | --- | --- | --- | --- | --- | --- | --- | --- | --- | --- | --- | --- | --- | --- | --- | --- | --- |
| 3708 | 993 | **Multiple PDN Connection to the Same APN for PMIP-based Interfaces** | 267d? | 2009-03-13 A | 2010-03-19 A | 100% | 2009-03-13 | 2010-03-19 | 267d? |  | S2; C4; C1 | 8392h | 8392h | MUPSAP | 22 | Samsung | erik.guttman@partner.samsung.com | Rel-9 | 43 | Maurice | MUPSAP |  |  |
| 3709 | 993.1 | Stage 2 for Multiple PDN Connection to the Same APN for PMIP-based Interfaces | 61d? | 2009-03-13 A | 2009-06-04 A | 100% | 2009-03-13 | 2009-06-04 | 61d? | finish no earlier than 2009-06-04 | S2 | 488h | 488h | MUPSAP | 22 | Samsung | erik.guttman@partner.samsung.com | Rel-9 | 43 | Maurice |  | 23.060, 23.203, 23.401, 23.402 |  |
| 3710 | 993.2 | CT4 aspects of Multiple PDN Connection to the Same APN for PMIP-based Interfaces | 56d? | 2009-09-18 A | 2009-12-04 A | 100% | 2009-09-18 | 2009-12-04 | 56d? | finish no earlier than 2009-12-04 | C4 | 448h | 448h | MUPSAP | 23 | Samsung | Surjyakanta Mohapatra (surjya.kanta@samsung.com) | Rel-9 | 45 | Kimmo |  | 29.275, 23.008, 29.282 |  |
| 3711 | 993.3 | CT1 aspects of Multiple PDN Connection to the Same APN for PMIP-based Interfaces | 131d? | 2009-09-18 A | 2010-03-19 A | 100% | 2009-09-18 | 2010-03-19 | 131d? | finish no earlier than 2010-03-19 | C1 | 1048h | 1048h | MUPSAP | 23 | Samsung | Surjyakanta Mohapatra (surjya.kanta@samsung.com) | Rel-9 | 45 | Frederic |  | 24.302 |  |
| 3712 | 994 | **System aspects of vocoder rate adaptation for LTE** | 1403.68d? | 2007-05-07 A | 2012-09-12 A | 100% | 2007-05-07 | 2012-09-12 | 1403.68d? |  | S2; S4; C1; C3; R2; IETF | 108798h | 108798h | LTEimp-Vocoder | 23 | Qualcomm | AC Mahendran (ac@qualcomm.com) | Rel-9 | 45 | Maurice | LTEimp-Vocoder | LTE |  |
| 3713 | 994.1 | SA2 system aspects of vocoder rate adaptation for LTE | 81d? | 2009-06-04 A | 2009-09-24 A | 100% | 2009-06-04 | 2009-09-24 | 81d? | start no earlier than 2009-06-04 | S2 | 648h | 648h | LTEimp-Vocoder | 23 | Qualcomm | AC Mahendran (ac@qualcomm.com) | Rel-9 | 45 | Maurice |  | 23.401 CR#1103r3 |  |
| 3714 | 994.2 | SA4 system aspects of vocoder rate adaptation for LTE | 136d? | 2009-06-04 A | 2009-12-10 A | 100% | 2009-06-04 | 2009-12-10 | 136d? | finish no earlier than 2009-12-07 | S4 | 1088h | 1088h | LTEimp-Vocoder | 23 | Qualcomm | Nikolai Leung | Rel-9 | 45 | Paolo |  | 26.114 |  |
| 3715 | 994.3 | Vocoder rate adaptation for LTE | 81d? | 2009-05-30 A | 2009-09-18 A | 100% | 2009-05-30 | 2009-09-18 | 81d? | finish no earlier than 2009-09-18 | R2 | 648h | 648h | LTEimp-Vocoder | 23 | Alcatel-Lucent | Sudeep Palat (spalat@alcatel-lucent.com) | Rel-9 | 44 | Yong-Jun |  | 36.300 CR#0114 | RP-090704 |
| 3716 | 994.4 | (IETF) SA4 system aspects of vocoder rate adaptation for LTE | 677.6d? | 2009-06-04 A | 2012-09-12 A | 100% | 2009-06-04 | 2012-09-12 | 677.6d? | finish no earlier than 2012-09-14 | S4-IETF | 5420.8h | 5420.8h | LTEimp-Vocoder | 27 | Lionel Morand |  | Rel-9 | 52 | Paolo |  | RFC 6679 (was draft-ietf-avtcore-ecn-for-rtp) |  |
| 3717 | 994.5 | (IETF) CT aspects of vocoder rate adaptation for LTE | 1400.68d? | 2007-05-07 A | 2012-09-07 A | 100% | 2007-05-07 | 2012-09-07 | 1400.68d? | finish no earlier than 2012-09-07 | C1-IETF; C3-IETF; C4-IETF | 33616.3h | 33616.3h | LTEimp-Vocoder | 27 | Lionel Morand |  | Rel-9 | 52 | Frederic |  | RFC 6679 (was draft-ietf-avtcore-ecn-for-rtp) |  |
| 3718 | 995 | Access Security Enhancements | 505d? | 2007-07-02 A | 2009-06-04 A | 100% | 2007-07-02 | 2009-06-04 | 505d? | finish no earlier than 2009-06-03 | S3 | 4040h | 4040h | ACCSEC2 |  | Ericsson | Bengt.Sahlin@ericsson.com | Rel-9 | 26 | Mirko | ACCSEC2 | 33.102, 43.020 |  |
| 3719 | 996 | **Protection against Unsolicited Communication for IMS (PUCI)** | 322d? | 2008-09-18 A | 2009-12-10 A | 100% | 2008-09-18 | 2009-12-10 | 322d? |  | S3; S1 | 8216h | 8216h | PUCI | 21 | NEC | Anand R. Prasad (anand@bq.jp.nec.com) | Rel-9 | 41 | Alain | PUCI |  |  |
| 3720 | 996.1 | Stage 1 for PUCI | 61d? | 2008-09-18 A | 2008-12-11 A | 100% | 2008-09-18 | 2008-12-11 | 61d? | finish no earlier than 2009-06-18 | S1 | 488h | 488h | PUCI | 21 | NEC | Anand R. Prasad (anand@bq.jp.nec.com) | Rel-9 | 41 | Alain |  | 22.228 |  |
| 3721 | 996.2 | SA3 work on PUCI | 322d? | 2008-09-18 A | 2009-12-10 A | 100% | 2008-09-18 | 2009-12-10 | 322d? | finish no earlier than 2009-12-10 | S3 | 2576h | 2576h | PUCI | 21 | NEC | Anand R. Prasad (anand@bq.jp.nec.com) | Rel-9 | 41 | Mirko |  | New 33.937 |  |
| 3722 | 997 | **IMS Media Plane Security** | 922d? | 2009-03-13 A | 2012-09-14 A | 100% | 2009-03-13 | 2012-09-14 | 922d? |  | S3; C1; C4; C3; IETF | 67928h | 67928h | MEDIASEC | 22 | Vodafone | Peter.Howard@vodafone.com | Rel-9 | 43 | Mirko | MEDIASEC |  |  |
| 3723 | 997.1 | SA3 aspects of IMS Media Plane Security | 271d? | 2009-03-13 A | 2010-03-25 A | 100% | 2009-03-13 | 2010-03-25 | 271d? | finish no earlier than 2010-03-25 | S3 | 2168h | 2168h | MEDIASEC | 22 | Vodafone | Peter.Howard@vodafone.com | Rel-9 | 43 | Mirko |  | New 33.828, 33.328 |  |
| 3724 | 997.2 | (IETF) SA3, CT1, CT3 aspects of IMS Media Plane Security | 919d? | 2009-03-18 A | 2012-09-14 A | 100% | 2009-03-18 | 2012-09-14 | 919d? | finish no earlier than 2012-09-14 | S3-IETF; C1-IETF; C3-IETF | 22056h | 22056h | MEDIASEC | 27 | Peter Dawes |  | Rel-9 | 52 | Mirko |  | draft-dawes-dispatch-mediasec-parameter |  |
| 3725 | 997.3 | **CN aspects of IMS Media Plane Security** | 186d? | 2009-09-18 A | 2010-06-04 A | 100% | 2009-09-18 | 2010-06-04 | 186d? |  | C1; C4; C3 | 6824h | 6824h | MEDIASEC_CORE | 23 | Vodafone | peter.dawes@vodafone.com | Rel-9 | 45 | Frederic | MEDIASEC_CORE |  |  |
| 3726 | 997.3.1 | CT1 aspects of IMS Media Plane Security | 33d? | 2009-09-18 A | 2010-03-19 A | 100% | 2009-09-18 | 2010-03-19 | 33d? | finish no earlier than 2010-03-19 | C1 | 264h | 264h | MEDIASEC_CORE | 23 | Vodafone | peter.dawes@vodafone.com | Rel-9 | 45 | Frederic |  | 23.218, 24.229 |  |
| 3727 | 997.3.2 | CT4 aspects of IMS Media Plane Security | 131d? | 2009-09-18 A | 2010-03-19 A | 100% | 2009-09-18 | 2010-03-19 | 131d? | finish no earlier than 2010-03-19 | C4 | 1048h | 1048h | MEDIASEC_CORE | 23 | Vodafone | peter.dawes@vodafone.com | Rel-9 | 45 | Kimmo |  | 29.238, 23.334, 29.334 |  |
| 3728 | 997.3.3 | CT3 aspects of IMS Media Plane Security | 131d? | 2009-12-04 A | 2010-06-04 A | 100% | 2009-12-04 | 2010-06-04 | 131d? | finish no earlier than 2010-06-04 | C3 | 1048h | 1048h | MEDIASEC_CORE | 24 | Vodafone | peter.dawes@vodafone.com | Rel-9 | 46 | Adrian |  | 29.162 |  |
| 3729 | 998 | **GBAPush enhancements (Generic push layer)** | 533d? | 2008-03-12 A | 2010-03-25 A | 100% | 2008-03-12 | 2010-03-25 | 533d? |  | S3 | 8528h | 8528h | eGBAPush | 23 | Ericsson | Rolf Blom | Rel-9 | 44 | Mirko | eGBAPush | New 33.224 |  |
| 3730 | 998.1 | SA3 part of eGBAPush (Generic push layer) | 533d? | 2008-03-12 A | 2010-03-25 A | 100% | 2008-03-12 | 2010-03-25 | 533d? | finish no earlier than 2010-03-25 | S3 | 4264h | 4264h | eGBAPush | 21 | Ericsson | Rolf Blom | Rel-9 | 39 | Mirko |  | New 33.224 |  |
| 3731 | 999 | Extended Identity Management | 136d? | 2009-06-04 A | 2009-12-10 A | 100% | 2009-06-04 | 2009-12-10 | 136d? | finish no earlier than 2009-12-10 | S3 | 1088h | 1088h | GBA-IdM | 23 | Nokia | Silke.Holtmanns@nokia.com | Rel-9 | 44 | Mirko | GBA-IdM | New 33.924, CT4 29.109 (added service code) |  |

Notes:
- 3708: CP#47 completed. Continues Rel-8 SAES Stage 2 UID_320005. Stage 1 in 22.278 (EPS Service requirements)
- 3709: SP#44 completed
- 3710: CP#46 completed
- 3711: CP#47 completed
- 3712: Triggered by RAN2 UID_440013 Vocoder rate adaptation for LTE
- 3713: SP#45 completed (CR adding support for Explicit Congestion Notification)
- 3714: SP#46 completed
- 3715: RP#45 completed
- 3716: SP#57 completed
- 3717: CP#57 completed
- 3718: SP#44 completed. Stopped TR 33.801. CRs 33.102,43.020 on A5/2 removal done long time ago. A5/4 introduction CRs will be done under UID_440057 128 bit encryption for GSM and GPRS. SP#26 approved WID (improved GERAN security)
- 3719: SP#46 TR 33.937 completed but no specification work done in Rel-9. Related work in OMA Categorization Based Content Screening
- 3720: SP#42 completed
- 3721: SP#46 completed. No normative work done in Rel-9
- 3722: -
- 3723: SP#47 completed
- 3724: CP#57 completed, ietf-draft discontinued, documented within 3GPP
- 3725: CP#48 completed
- 3726: CP#47 completed
- 3727: CP#47 completed
- 3728: CP#48 completed
- 3729: SP#43 umbrella to host 33.224, moved from Rel-8 to Rel-9. SP#47 completed
- 3730: SP#47 completed
- 3731: SP#46 completed. Stage 1 not identified (GBA Liberty Interworking has been outlined and GBAOpenID interworking is analogous)

| ID | WBS | Task | Duration | Start | Finish | Complete | Baseline start | Baseline finish | Baseline duration | Constraint | Resources | Work | Actual work | Acronym | PCG approved | WI rapporteur name | Release | TSG approved | MCC resp | Acronym_3GU_Export | PCG stopped | TSG stopped |
| --- | --- | --- | --- | --- | --- | --- | --- | --- | --- | --- | --- | --- | --- | --- | --- | --- | --- | --- | --- | --- | --- | --- |
| 3732 | 1000 | **Network Domain Security (NDS) enhancements to support backhaul security** | 924d? | 2009-06-04 A | 2012-12-07 A | 100% | 2009-06-04 | 2012-12-07 | 924d? |  | S3; IETF | 23452.8h | 23452.8h | NDS_Backhaul | 23 | Vodafone | Rel-9 | 44 | Mirko | NDS_Backhaul |  |  |
| 3733 | 1000.1 | SA3 part of Network Domain Security (NDS) enhancements to support backhaul security | 211d? | 2009-06-04 A | 2010-03-25 A | 100% | 2009-06-04 | 2010-03-25 | 211d? | finish no earlier than 2010-03-25 | S3 | 1688h | 1688h | NDS_Backhaul | 23 | Vodafone | Rel-9 | 44 | Mirko |  |  |  |
| 3734 | 1000.2 | (IETF) SA3 part of Network Domain Security (NDS) enhancements to support backhaul security | 740.6d? | 2009-06-04 A | 2012-12-07 A | 100% | 2009-06-04 | 2012-12-07 | 740.6d? | finish no earlier than 2012-12-07 | S3-IETF | 5924.8h | 5924.8h | NDS_Backhaul | 27 | Bengt Sahlin | Rel-9 | 52 | Mirko |  |  |  |
| 3735 | 1000.3 | Deleted - CT4 part of Network Domain Security (NDS) enhancements to support backhaul security | 132d? | 2009-06-04 A | 2009-12-04 A | 100% | 2009-06-04 | 2009-12-04 | 132d? | finish no earlier than 2009-12-04 | C4 | 1056h | 1056h | NDS_Backhaul | 23 | Vodafone | Rel-9 | 44 | Kimmo |  | PCG-24 | CP-46 |
| 3736 | 1001 | **128 bit encryption for GSM and GPRS** | 136d? | 2009-06-04 A | 2009-12-10 A | 100% | 2009-06-04 | 2009-12-10 | 136d? |  | S3; C1; C4; G2; G3new | 10392h | 10392h | A5/4-GEA4 | 23 | Ericsson | Rel-9 | 44 | Mirko | A5/4-GEA4 |  |  |
| 3737 | 1001.1 | SA3 part of 128 bit encryption for GSM and GPRS | 136d? | 2009-06-04 A | 2009-12-10 A | 100% | 2009-06-04 | 2009-12-10 | 136d? | finish no earlier than 2010-01-06 | S3 | 1088h | 1088h | A5/4-GEA4 | 23 | Ericsson | Rel-9 | 44 | Mirko |  |  |  |
| 3738 | 1001.2 | CT1 part of 128 bit encryption for GSM and GPRS | 77d? | 2009-06-04 A | 2009-09-18 A | 100% | 2009-06-04 | 2009-09-18 | 77d? | start no earlier than 2009-06-04 | C1 | 616h | 616h | A5/4-GEA4 | 23 | Ericsson | Rel-9 | 44 | Frederic |  |  |  |
| 3739 | 1001.3 | CT4 part of 128 bit encryption for GSM and GPRS | 136d? | 2009-06-04 A | 2009-12-10 A | 100% | 2009-06-04 | 2009-12-10 | 136d? | start no earlier than 2009-06-04 | C4 | 1088h | 1088h | A5/4-GEA4 | 23 | Ericsson | Rel-9 | 44 | Kimmo |  |  |  |
| 3740 | 1001.4 | GERAN2 part of 128 bit encryption for GSM and GPRS | 67d? | 2009-06-04 A | 2009-09-04 A | 100% | 2009-06-04 | 2009-09-04 | 67d? | finish no earlier than 2009-09-04 | G2 | 536h | 536h | A5/4-GEA4 | 23 | Ericsson | Rel-9 | 44 | Gert |  |  |  |
| 3741 | 1001.5 | GERAN3new (testing) part of 128 bit encryption for GSM and GPRS | 122d? | 2009-06-04 A | 2009-11-20 A | 100% | 2009-06-04 | 2009-11-20 | 122d? | finish no earlier than 2009-11-20 | G3new | 976h | 976h | A5/4-GEA4 | 23 | Ericsson | Rel-9 | 44 | Ingbert |  |  |  |
| 3742 | 1001.6 | Deleted - SA2 part of 128 bit encryption for GSM and GPRS | 81d? | 2009-06-04 A | 2009-09-24 A | 100% | 2009-06-04 | 2009-09-24 | 81d? | finish no earlier than 2009-09-24 | S2 | 648h | 648h | A5/4-GEA4 | 23 | Ericsson | Rel-9 | 44 | Maurice |  | PCG-23 | SP-45 |
| 3743 | 1002 | Timed Graphics | 337d? | 2008-12-11 A | 2010-03-25 A | 100% | 2008-12-11 | 2010-03-25 | 337d? | finish no earlier than 2010-03-25 | S4 | 2696h | 2696h | TG | 22 | Ericsson | Rel-9 | 42 | Paolo | TG |  |  |
| 3744 | 1003 | Managing MTSI Media Adaptation | 197d? | 2009-03-12 A | 2009-12-10 A | 100% | 2009-03-12 | 2009-12-10 | 197d? | finish no earlier than 2009-12-10 | S4 | 1568h | 1568h | M3A | 22 | Samsung | Rel-9 | 43 | Paolo | M3A |  |  |
| 3745 | 1004 | **PSS and MBMS Aspects** | 272d? | 2009-03-12 A | 2010-03-25 A | 100% | 2009-03-12 | 2010-03-25 | 272d? |  | S4 | 6512h | 6512h | PMA | 23 | Ericsson, Nokia | Rel-9 | 44 | Paolo | PMA |  |  |
| 3746 | 1004.1 | PSS and MBMS extensions | 271d? | 2009-03-12 A | 2010-03-25 A | 100% | 2009-03-12 | 2010-03-25 | 271d? | finish no earlier than 2010-03-25 | S4 | 2168h | 2168h | PMA-MBS_Ext | 22 | Ericsson | Rel-9 | 43 | Paolo | PMA-MBS_Ext |  |  |
| 3747 | 1004.2 | Improved Video Support for PSS and MBMS | 271d? | 2009-03-12 A | 2010-03-25 A | 100% | 2009-03-12 | 2010-03-25 | 271d? | finish no earlier than 2010-03-25 | S4 | 2168h | 2168h | PMA-IVS | 22 | Nokia | Rel-9 | 43 | Paolo | PMA-IVS |  |  |
| 3748 | 1005 | IMS based PSS and MBMS User Service extensions | 197d? | 2009-03-12 A | 2009-12-10 A | 100% | 2009-03-12 | 2009-12-10 | 197d? | finish no earlier than 2009-12-10 | S4 | 1576h | 1576h | IMS_PSS_MBMS_US_EXT | 22 | Ericsson | Rel-9 | 43 | Paolo | IMS_PSS_MBMS_US_EXT |  |  |
| 3749 | 1006 | Syndicated Feed Reception within 3GPP environments | 136d? | 2009-06-04 A | 2009-12-10 A | 100% | 2009-06-04 | 2009-12-10 | 136d? | start no earlier than 2009-06-04 | S4 | 1088h | 1088h | SFR | 23 | Ericsson | Rel-9 | 44 | Paolo | SFR |  |  |
| 3750 | 1007 | Distortion Measurement Test Methods and Requirements | 131d? | 2009-09-24 A | 2010-03-25 A | 100% | 2009-09-24 | 2010-03-25 | 131d? | finish no earlier than 2010-03-25 | S4 | 1048h | 1048h | DTMR | 23 | Motorola | Rel-9 | 45 | Paolo | DTMR |  |  |
| 3751 | 1008 | **Rel-9 Operations, Administration, Maintenance and Provisioning (OAM&P)** | 601d? | 2008-02-22 A | 2010-06-10 A | 100% | 2008-02-22 | 2010-06-10 | 601d? |  | S5 | 36890.4h | 36890.4h | OAM9 | 22 |  | Rel-9 | 42 | Mirko | OAM9 |  |  |
| 3752 | 1008.1 | **Rel-9 Network Infrastructure Management** | 337d? | 2008-12-11 A | 2010-03-25 A | 100% | 2008-12-11 | 2010-03-25 | 337d? |  | S5 | 8760h | 8760h | OAM9-NIM | 22 |  | Rel-9 | 42 | Mirko | OAM9-NIM |  |  |
| 3753 | 1008.1.1 | Software Management for Network Elements | 336d? | 2008-12-11 A | 2010-03-25 A | 100% | 2008-12-11 | 2010-03-25 | 336d? | finish no earlier than 2010-03-25 | S5 | 2688h | 2688h | OAM9-NE_SWM | 22 | Huawei, Nokia Siemens Networks | Rel-9 | 42 | Mirko | OAM9-NE_SWM |  |  |
| 3754 | 1008.1.2 | Service Oriented Architecture (SOA) for IRP | 211d? | 2009-06-04 A | 2010-03-25 A | 100% | 2009-06-04 | 2010-03-25 | 211d? | finish no earlier than 2010-03-25 | S5 | 1688h | 1688h |  | 23 | Ericsson, Nokia Siemens Networks | Rel-9 | 44 | Mirko |  |  |  |
| 3755 | 1008.1.3 | IRP SOAP Solution Sets continuation from Rel-8 | 211d? | 2009-06-04 A | 2010-03-25 A | 100% | 2009-06-04 | 2010-03-25 | 211d? | finish no earlier than 2010-03-25 | S5 | 1688h | 1688h |  | 23 | Ericsson | Rel-9 | 44 | Mirko |  |  |  |

Notes:
- 3732: Continuation of Rel-8 UID_390044 SAE security architecture. Covers gaps in backhaul security in SAE (also applicable to UTRAN and GERAN backhaul) / WI rapporteur e-mail: Peter.Howard@vodafone.com
- 3733: SP#47 completed / Impacted TSs and TRs: 33.102, 33.210, 33.310, 33.401, 33.402 / WI rapporteur e-mail: Peter.Howard@vodafone.com
- 3734: CP#58 completed / Impacted TSs and TRs: RFC 6712 (was draft-ietf-pkix-cmp-transport-protocols)
- 3735: CP#46 completed. No impact on CT4 specs / WI rapporteur e-mail: Peter.Howard@vodafone.com
- 3736: Allow 128 as an alternative to 64 bit keys (Stage 2/3 + Test spec) / WI rapporteur e-mail: Karl Norrman
- 3737: SP#46 completed / Impacted TSs and TRs: 33.102,43.020, New 55.226 / WI rapporteur e-mail: Karl Norrman
- 3738: CP#45 completed / Impacted TSs and TRs: 24.008,44.064 / WI rapporteur e-mail: Karl Norrman
- 3739: CP#46 completed. Kc128 enhancements are carried as UMTS keys => no impact on CT4 29.002, 29.060 / WI rapporteur e-mail: Karl Norrman
- 3740: GP#43 WID approved + completed / Impacted TSs and TRs: 44.018,48.008,48.018,48.058 / WI rapporteur e-mail: Karl Norrman
- 3741: GP#44 completed. GP#43 WID approved / Impacted TSs and TRs: 51.010 / WI rapporteur e-mail: Karl Norrman
- 3742: SP#45 work stopped/abandoned / Impacted TSs and TRs: 23.060 / WI rapporteur e-mail: Karl Norrman
- 3743: SP#47 completed. Provide graphics in parallel to a video stream (without requiring an umbrella scene descriptor such as 3GPP DIMS in TS 26.142) / Impacted TSs and TRs: 26.114, 26.140, 26.234, 26.244, 26.245, 26.346, New 26.430 / WI rapporteur e-mail: clinton.priddle@ericsson.com
- 3744: SP#46 completed. Work extending Rel-8 UID_34041 MTSI Video - Dynamic Rate Adaptation/Signalling of Image Size. Update speech/video adaptation algorithms used by network to control MTSI client terminal in congestion or poor transmission conditions. / Impacted TSs and TRs: 26.114 / WI rapporteur e-mail: kyunghun.jung@samsung.com
- 3745: Umbrella WI / WI rapporteur e-mail: Clinton.Priddle@ericsson.com, imed.bouazizi@nokia.com
- 3746: SP#47 completed. Extends Rel-8 UID_34043 (PSS_MBMS_OMTV) & ensures compatibility with UID_34046 (IMS_PSS_MBMS_US) / Impacted TSs and TRs: 26.234, 26.346 / WI rapporteur e-mail: Clinton.Priddle@ericsson.com
- 3747: SP#47 completed / Impacted TSs and TRs: 26.234, 26.244, 26.346, new 26.903 / WI rapporteur e-mail: imed.bouazizi@nokia.com
- 3748: SP#46 completed. Work extending Rel-8 UID_34046 (IMS_PSS_MBMS_US), SA2 UID_410034 IMSSCC-SPI (IMS Service Continuity Enhancements: Service, Policy and Interactions) / Impacted TSs and TRs: 26.237 / WI rapporteur e-mail: Markus Kampmann
- 3749: SP#46 completed. TS 26.150v100 for Approval. RSS optimized for mobile use. Reuse/reference OMA's enabler DCD. / Impacted TSs and TRs: New 26.150 / WI rapporteur e-mail: Thorsten.Lohmar@ericsson.com
- 3750: SP#47 completed / Impacted TSs and TRs: 26.131, 26.132 / WI rapporteur e-mail: Stephen Kendall (wcsk01@motorola.com)
- 3751: OAM9 is an umbrella Feature also for OAM&P related TEI9 type of changes that are not part of any other dedicated feature/WI / Impacted TSs and TRs: TR 30.819
- 3752: SP#42 umbrella BB created to host OAM WIs
- 3753: SP#47 completed / Impacted TSs and TRs: 32.531, 32.532, 32.533, new 32.537 / WI rapporteur e-mail: Bidipta Das (bidipta@huawei.com), Clemens Suerbaum (clemens.suerbaum@nsn.com)
- 3754: SP#47 completed (covering SOA Architecture & SOA-supporting Solution Set). Triggered by UID_400029 Study on Service Oriented Architecture (SOA) for IRP (TR 32.824) / Impacted TSs and TRs: 32.101, 32.102, 32.150 / WI rapporteur e-mail: edwin.tse@ericsson.com, Jörg Schmidt (joerg@cox.net)
- 3755: SP#47 completed. Continuation of Rel-8 UID_400030 IRP SOAP Solution Sets / Impacted TSs and TRs: New (32.127/ 327/ 337/ 357/ 387/ 397/ 447/ 397/ 447/ 507/ 537), 32.121,32.122,32.123,32,32.321,32.322,32.323,32.325,32.331,32.332,32.333,32.335,32.351,32.352,32.353,32.381,32.382,32.383,32.385,32.391,32.392,32.393,32.395,32.441,32.442,32.443 / WI rapporteur e-mail: John Power

| ID | WBS | Task | Duration | Start | Finish | Complete | Baseline start | Baseline finish | Baseline duration | Constraint | Resources | Work | Actual work | Acronym | PCG approved | Release | TSG approved | MCC resp | Acronym_3GU_Export | Impacted TSs and TRs | WI rapporteur name | Special Focus Doc | PCG stopped | TSG stopped |
| --- | --- | --- | --- | --- | --- | --- | --- | --- | --- | --- | --- | --- | --- | --- | --- | --- | --- | --- | --- | --- | --- | --- | --- | --- |
| 3756 | 1008.2 | **Rel-9 Performance Management** | 327d? | 2009-03-12 A | 2010-06-10 A | 100% | 2009-03-12 | 2010-06-10 | 327d? |  | S5 | 7890.41h | 7890.41h | OAM9-PM | 22 | Rel-9 | 42 | Mirko | OAM9-PM |  |  |  |  |  |
| 3757 | 1008.2.1 | Enhancement of UTRAN Performance Measurements | 136d? | 2009-06-04 A | 2009-12-10 A | 100% | 2009-06-04 | 2009-12-10 | 136d? | start no earlier than 2009-06-04 | S5 | 1088h | 1088h |  | 23 | Rel-9 | 44 | Mirko |  | 32.405 | China Mobile |  |  |  |
| 3758 | 1008.2.2 | Enhancement of E-UTRAN Performance Measurements | 327d? | 2009-03-12 A | 2010-06-10 A | 100% | 2009-03-12 | 2010-06-10 | 327d? | finish no earlier than 2010-06-10 | S5 | 2616h | 2616h |  | 22 | Rel-9 | 43 | Mirko |  | 32.425 | Motorola, Huawei |  |  |  |
| 3759 | 1008.2.3 | Enhancement of EPC Performance Measurements | 197d? | 2009-03-12 A | 2009-12-10 A | 100% | 2009-03-12 | 2009-12-10 | 197d? | finish no earlier than 2010-03-25 | S5 | 1570.41h | 1570.41h |  | 22 | Rel-9 | 43 | Mirko |  | 32.426 | China Mobile |  |  |  |
| 3760 | 1008.3 | **Rel-9 Self-Organizing Networks (SON) - OAM aspects** | 601d? | 2008-02-22 A | 2010-06-10 A | 100% | 2008-02-22 | 2010-06-10 | 601d? |  | S5 | 11736h | 11736h | OAM9-SON | 22 | Rel-9 | 43 | Mirko | OAM9-SON |  |  | SON |  |  |
| 3761 | 1008.3.1 | SON self-optimization management (moved from Rel-8 LTE_SON-OAM) | 600d? | 2008-02-22 A | 2010-06-10 A | 100% | 2008-02-22 | 2010-06-10 | 600d? | finish no earlier than 2010-06-10 | S5 | 4800h | 4800h |  | 21 | Rel-9 | 39 | Mirko |  | 32.425, new (32.521, 32.522, 32.523, 32.525) | Huawei | SON |  |  |
| 3762 | 1008.3.2 | Automatic Radio Network Configuration Data Preparation | 266d? | 2009-06-04 A | 2010-06-10 A | 100% | 2009-06-04 | 2010-06-10 | 266d? | finish no earlier than 2010-06-10 | S5 | 2128h | 2128h |  | 23 | Rel-9 | 44 | Mirko |  | 32.501, 32.502, 32.503, 32.505, new 32.507 | Nokia Siemens Networks | SON |  |  |
| 3763 | 1008.4 | Rel-9 Subscription Management (SuM) evolution | 266d? | 2009-06-04 A | 2010-06-10 A | 100% | 2009-06-04 | 2010-06-10 | 266d? | finish no earlier than 2010-06-10 | S5 | 2128h | 2128h | OAM9-SuM | 23 | Rel-9 | 44 | Mirko | OAM9-SuM | 32.140, 32.141, 32.152, 32.172, 32.175 | Ericsson |  |  |  |
| 3764 | 1008.5 | Deleted - Rel-9 Trace | 196d? | 2009-03-13 A | 2009-12-10 A | 100% | 2009-03-13 | 2009-12-10 | 196d? | finish no earlier than 2009-12-10 | S5 | 1568h | 1568h | OAM9-Trace | 22 | Rel-9 | 42 | Mirko | OAM9-Trace |  |  |  | PCG-24 | SP-46 |
| 3765 | 1009 | Rel-9 Charging Management small Enhancements | 211d? | 2009-06-04 A | 2010-03-25 A | 100% | 2009-06-04 | 2010-03-25 | 211d? |  | S5 | 1688h | 1688h | CH9 | 23 | Rel-9 | 44 | Mirko | CH9 | TR 30.819 |  |  |  |  |
| 3766 | 1010 | **CS-IBCF and CS-TrGW definition in 3GPP specifications** | 472d? | 2008-05-30 A | 2010-03-19 A | 100% | 2008-05-30 | 2010-03-19 | 472d? |  | C3; C4 | 14490.3h | 14490.3h | CS-IBCF | 21 | Rel-9 | 40 | Adrian | CS-IBCF |  | Telecom Italia |  |  |  |
| 3767 | 1010.1 | CT3 aspects of CS-IBCF and CS-TrGW definition in 3GPP specifications | 472d? | 2008-05-30 A | 2010-03-19 A | 100% | 2008-05-30 | 2010-03-19 | 472d? | finish no earlier than 2009-12-04 | C3 | 3770.34h | 3770.34h | CS-IBCF | 21 | Rel-9 | 40 | Adrian |  | 29.235 | Telecom Italia |  |  |  |
| 3768 | 1010.2 | CT4 aspects of CS-IBCF and CS-TrGW definition in 3GPP specifications | 396d? | 2008-05-30 A | 2009-12-04 A | 100% | 2008-05-30 | 2009-12-04 | 396d? | finish no earlier than 2009-12-04 | C4 | 3168h | 3168h | CS-IBCF | 21 | Rel-9 | 40 | Kimmo |  | 23.231, 29.232, new 29.238 | Telecom Italia |  |  |  |
| 3769 | 1011 | **IMS – Interconnection Border Control Function (IBCF) – Transition Gateway (TrGW); Ix Interface; Stage 3** | 322d? | 2008-09-12 A | 2009-12-04 A | 100% | 2008-09-12 | 2009-12-04 | 322d? |  | C4; C3 | 10086.4h | 10086.4h | IMS_IBCF | 21 | Rel-9 | 41 | Kimmo | IMS_IBCF |  | Alcatel-Lucent |  |  |  |
| 3770 | 1011.1 | CT4 part of IMS – Interconnection Border Control Function (IBCF) – Transition Gateway (TrGW); Ix Interface; Stage 3 | 321d? | 2008-09-12 A | 2009-12-04 A | 100% | 2008-09-12 | 2009-12-04 | 321d? | finish no earlier than 2009-12-04 | C4 | 2568h | 2568h | IMS_IBCF | 21 | Rel-9 | 41 | Kimmo |  | new 29.238 | Alcatel-Lucent |  |  |  |
| 3771 | 1011.2 | CT3 part of IMS – Interconnection Border Control Function (IBCF) – Transition Gateway (TrGW); Ix Interface; Stage 3 | 295.8d? | 2008-09-12 A | 2009-12-04 A | 100% | 2008-09-12 | 2009-12-04 | 295.8d? | finish no earlier than 2010-03-19 | C3 | 2366.4h | 2366.4h | IMS_IBCF | 21 | Rel-9 | 41 | Adrian |  | 29.162, 29.235 | Alcatel-Lucent |  |  |  |
| 3772 | 1012 | IMS Application Level Gateway Control Function (ALGCF) – IMS Access Media Gateway (IMA-MGW); Iq Interface; Stage 2 and Stage 3 | 321d? | 2008-09-12 A | 2009-12-04 A | 100% | 2008-09-12 | 2009-12-04 | 321d? | finish no earlier than 2009-12-04 | C4 | 2568h | 2568h | IMS_AGCF | 21 | Rel-9 | 41 | Kimmo | IMS_AGCF | New 23.334, 29.334 | Alcatel-Lucent |  |  |  |
| 3773 | 1013 | **Enhancements of IMS Customized Alerting Tone (CAT) Service** | 392d? | 2008-12-05 A | 2010-06-04 A | 100% | 2008-12-05 | 2010-06-04 | 392d? |  | C1 | 5846.4h | 5846.4h | eCAT | 22 | Rel-9 | 42 | Frederic | eCAT |  | China Mobile |  |  |  |
| 3774 | 1013.1 | Stage 3 for Enhancements of IMS Customized Alerting Tone (CAT) Service | 391d? | 2008-12-05 A | 2010-06-04 A | 100% | 2008-12-05 | 2010-06-04 | 391d? | finish no earlier than 2010-06-04 | C1 | 3128h | 3128h | eCAT-SS | 22 | Rel-9 | 42 | Frederic | eCAT-SS | 24.182 | China Mobile |  |  |  |
| 3775 | 1014 | **Completion of IMS Restoration Procedures** | 212d? | 2009-05-29 A | 2010-03-19 A | 100% | 2009-05-29 | 2010-03-19 | 212d? |  | C3; C4; C1 | 10176h | 10176h | eIMS_RP | 23 | Rel-9 | 44 | Kimmo | eIMS_RP |  | Ericsson |  |  |  |
| 3776 | 1014.1 | CT4 aspects of Completion of IMS Restoration Procedures | 212d? | 2009-05-29 A | 2010-03-19 A | 100% | 2009-05-29 | 2010-03-19 | 212d? | finish no earlier than 2010-03-19 | C4 | 1696h | 1696h | eIMS_RP | 23 | Rel-9 | 44 | Kimmo |  | 23.380, 23.820 | Ericsson |  |  |  |
| 3777 | 1014.2 | CT1 aspects of Completion of IMS Restoration Procedures | 212d? | 2009-05-29 A | 2010-03-19 A | 100% | 2009-05-29 | 2010-03-19 | 212d? | finish no earlier than 2010-03-19 | C1 | 1696h | 1696h | eIMS_RP | 23 | Rel-9 | 44 | Kimmo |  | 24.229 | Ericsson |  |  |  |
| 3778 | 1014.3 | CT3 aspects of Completion of IMS Restoration Procedures | 212d? | 2009-05-29 A | 2010-03-19 A | 100% | 2009-05-29 | 2010-03-19 | 212d? | finish no earlier than 2010-03-19 | C3 | 1696h | 1696h | eIMS_RP | 24 | Rel-9 | 46 | Kimmo |  | 29.061, 29.212, 29.213, 29.214, 29.215 | Ericsson |  |  |  |
| 3779 | 1015 | **IMS Stage 3 IETF Protocol Alignment - phase 3** | 1458d? | 2009-05-29 A | 2014-12-05 A | 100% | 2009-05-29 | 2014-12-05 | 1455d? |  | C1; IETF | 40216h | 40216h | IMSProtoc3 | 23 | Rel-9 | 44 | Frederic | IMSProtoc3 |  | Alcatel-Lucent |  |  |  |
| 3780 | 1015.1 | CT1 aspects of IMS Stage 3 - IETF Protocol Alignment - phase 3 | 212d? | 2009-05-29 A | 2010-03-19 A | 100% | 2009-05-29 | 2010-03-19 | 212d? | finish no earlier than 2010-03-19 | C1 | 1696h | 1696h | IMSProtoc3 | 23 | Rel-9 | 44 | Frederic |  | 23.218, 24.229, 24.930 | Alcatel-Lucent |  |  |  |
| 3781 | 1015.2 | (IETF) CT1 IMS Stage 3 - IETF Protocol Alignment (RFC 7329) | 1242d? | 2009-05-29 A | 2014-12-05 A | 100% | 2009-05-29 | 2014-12-05 | 1240d? | finish no earlier than 2014-12-09 | C1-IETF | 9936h | 9936h | IMSProtoc3 | 27 | Rel-9 | 52 | Frederic |  | RFC 7329 (was draft-kaplan-insipid-session-id) | christer.holmberg@ericsson.com |  |  |  |
| 3782 | 1015.3 | (IETF) CT1 IMS Stage 3 - IETF Protocol Alignment (RFC 7044) | 659d? | 2011-09-13 A | 2014-03-07 A | 100% | 2011-09-13 | 2014-03-07 | 659d? | finish no earlier than 2014-02-10 | C1-IETF | 5256h | 5256h | IMSProtoc3 | 27 | Rel-9 | 53 | Frederic |  | RFC 7044 (was draft-ietf-sipcore-rfc4244bis) | christer.holmberg@ericsson.com |  |  |  |

Notes:
- 3756: SP#42 umbrella BB created to host OAM WIs
- 3757: SP#46 completed / WI rapporteur e-mail: liangshuangchun@cmdi.chinamobile.com, lijian@chinamobile.com, Bao Haitao
- 3758: SP#48 completed / WI rapporteur e-mail: Yizhi Yao (yzyao@motorola.com),Lan Zou (zlan@huawei.com)
- 3759: SP#46 completed / WI rapporteur e-mail: Li Jian (lijian@chinamobile.com), Liang Shuangchun (liangshuangchun@cmdi.chinamobile.com)
- 3760: SP#43 umbrella BB created to host OAM WIs
- 3761: SP#48 completed / WI rapporteur e-mail: Lan Zou (zlan@huawei.com)
- 3762: SP#48 completed / WI rapporteur e-mail: clemens.suerbaum@nsn.com
- 3763: SP#48 completed / WI rapporteur e-mail: frode.nergard@ericsson.com
- 3764: SP#46 stopped (no work in Rel-9)
- 3765: CH9 is an umbrella Feature also for OAM&P related TEI9 type of changes that are not part of any other dedicated feature/WI
- 3766: CP#47 completed. Rel-8 UID_380061 (Ipinterc) covers Stage 1 in SA1 22.101, 22.228 / WI rapporteur e-mail: mauro.ficaccio@telecomitalia.it
- 3767: CP#47 completed / WI rapporteur e-mail: mauro.ficaccio@telecomitalia.it
- 3768: CP#46 completed / WI rapporteur e-mail: mauro.ficaccio@telecomitalia.it
- 3769: CP#46 completed / WI rapporteur e-mail: bruno.landais@alcatel-lucent.fr
- 3770: CP#46 completed / WI rapporteur e-mail: bruno.landais@alcatel-lucent.fr
- 3771: CP#46 completed / WI rapporteur e-mail: bruno.landais@alcatel-lucent.fr
- 3772: CP#46 completed / WI rapporteur e-mail: bruno.landais@alcatel-lucent.fr
- 3773: CP#48 completed. Stage 1 in 22.182 / WI rapporteur e-mail: Jiang Yi
- 3774: CP#48 completed / WI rapporteur e-mail: Jiang Yi
- 3775: CP#47 completed. Continuation of Rel-8 Feature UID_400012 IMS Restoration Procedures / WI rapporteur e-mail: Emiliano Merino (emiliano.merino@ericsson.com)
- 3776: CP#47 completed / WI rapporteur e-mail: Emiliano Merino (emiliano.merino@ericsson.com)
- 3777: CP#47 completed / WI rapporteur e-mail: Emiliano Merino (emiliano.merino@ericsson.com)
- 3778: CP#47 completed / WI rapporteur e-mail: Emiliano Merino (emiliano.merino@ericsson.com)
- 3779: CP#47 completed / WI rapporteur e-mail: Keith Drage (drage@alcatel-lucent.com)
- 3780: CP#47 completed / WI rapporteur e-mail: Keith Drage (drage@alcatel-lucent.com)
- 3781: CP#65 completed / WI rapporteur e-mail: christer.holmberg@ericsson.com
- 3782: CP#63 completed / WI rapporteur e-mail: christer.holmberg@ericsson.com

| ID | WBS | Task | Type | Duration | Start | Finish | Complete | Baseline start | Baseline finish | Baseline duration | Constraint | Resources | Work | Actual work | Acronym | PCG approved | WI rapporteur name | WI rapporteur e-mail | Release | TSG approved | MCC resp | Acronym_3GU_Export | TSG stopped | Special Focus Doc | Status Report |
| --- | --- | --- | --- | --- | --- | --- | --- | --- | --- | --- | --- | --- | --- | --- | --- | --- | --- | --- | --- | --- | --- | --- | --- | --- | --- |
| 3783 | 1016 | **Operational description of the Inter-IMS Network to Network Interface (II-NNI)** |  | 1460d? | 2009-05-29 A | 2014-12-09 A | 100% | 2009-05-29 | 2014-12-05 | 1455d? |  | C3; IETF | 58408h | 58408h | II-NNI | 23 | Orange | sebastien.daudet@orange-ftgroup.com | Rel-9 | 44 | Adrian | II-NNI |  |  |  |
| 3784 | 1016.1 | Operational description of the Inter-IMS Network to Network Interface |  | 267d? | 2009-05-29 A | 2010-06-04 A | 100% | 2009-05-29 | 2010-06-04 | 267d? | start no earlier than 2009-05-29 | C3 | 2136h | 2136h | II-NNI | 23 | Orange |  | Rel-9 | 44 | Adrian |  |  |  |  |
| 3785 | 1016.2 | (IETF) Operational description of the Inter-IMS Network to Network Interface (RFC 7329) |  | 633d? | 2012-04-20 A | 2014-09-12 A | 100% | 2012-04-20 | 2014-12-05 | 693d? | finish no earlier than 2014-09-12 | C3-IETF | 5040h | 5040h | II-NNI | 29 | christer.holmberg@ericsson.com | christer.holmberg@ericsson.com | Rel-9 | 56 | Adrian |  |  |  |  |
| 3786 | 1016.3 | (IETF) Operational description of the Inter-IMS Network to Network Interface (RFC 7316) |  | 634d? | 2012-04-20 A | 2014-09-12 A | 100% | 2012-04-20 | 2014-12-05 | 694d? | finish no earlier than 2014-12-09 | C3-IETF | 5064h | 5064h | II-NNI | 29 | Keith Drage | Keith Drage | Rel-9 | 56 | Adrian |  |  |  |  |
| 3787 | 1016.4 | (IETF) Operational description of the Inter-IMS Network to Network Interface |  | 696d? | 2012-04-20 A | 2014-12-09 A | 100% | 2012-04-20 | 2014-12-05 | 694d? | finish no earlier than 2014-12-09 | C3-IETF | 5560h | 5560h | II-NNI | 29 | Roland Jesske | Roland Jesske | Rel-9 | 56 | Adrian |  |  |  |  |
| 3788 | 1016.5 | (IETF) Operational description of the Inter-IMS Network to Network Interface |  | 696d? | 2012-04-20 A | 2014-12-09 A | 100% | 2012-04-20 | 2014-12-05 | 694d? | finish no earlier than 2014-12-09 | C3-IETF | 5536h | 5536h | II-NNI | 29 | Roland Jesske | Roland Jesske | Rel-9 | 56 | Adrian |  |  |  |  |
| 3789 | 1016.6 | (IETF) Operational description of the Inter-IMS Network to Network Interface |  | 697d? | 2012-04-20 A | 2014-12-09 A | 100% | 2012-04-20 | 2014-12-05 | 695d? | finish no earlier than 2014-12-09 | C3-IETF | 5560h | 5560h | II-NNI | 29 | Keith Drage | Keith Drage | Rel-9 | 56 | Adrian |  |  |  |  |
| 3790 | 1016.7 | Deleted - (IETF) Operational description of the Inter-IMS Network to Network Interface |  | 433d? | 2012-04-20 A | 2013-12-06 A | 100% | 2012-04-20 | 2014-12-05 | 694d? | finish no earlier than 2013-12-06 | C3-IETF | 3456h | 3456h | II-NNI | 29 | Peter Dawes | peter.dawes@vodafone.com | Rel-9 | 56 | Adrian |  | SP-69 |  |  |
| 3791 | 1016.8 | Deleted - (IETF) Operational description of the Inter-IMS Network to Network Interface (avasarala-dispatch-comm-div-notification) |  | 340d? | 2013-03-01 A | 2014-06-13 A | 100% | 2013-03-01 | 2014-06-13 | 340d? | finish no earlier than 2014-06-13 | C3-IETF | 2696h | 2696h | II-NNI | 30 | Andrew Allen | Andrew Allen | Rel-9 | 59 | Adrian |  | SP-69 |  |  |
| 3792 | 1017 | Definition of Ml interface for Control Plane LCS (Stage 3) |  | 131d? | 2009-09-18 A | 2010-03-19 A | 100% | 2009-09-18 | 2010-03-19 | 131d? | finish no earlier than 2010-03-19 | C1 | 1048h | 1048h | EMC2 | 23 | Alcatel-Lucent | Keith Drage (drage@alcatel-lucent.com) | Rel-9 | 45 | Frederic | EMC2 |  | Public Safety (I-A) |  |
| 3793 | 1018 | PCC enhancements |  | 56d? | 2009-09-18 A | 2009-12-04 A | 100% | 2009-09-18 | 2009-12-04 | 56d? | finish no earlier than 2009-12-04 | C3 | 448h | 448h | PCC-Enh | 23 | Huawei | Wei Weihua (weiwh@huawei.com) | Rel-9 | 45 | Adrian | PCC-Enh |  |  |  |
| 3794 | 1019 | 3GPP IMS Conferencing Management Object (MO) |  | 2d? | 2009-12-03 A | 2009-12-04 A | 100% | 2009-12-03 | 2009-12-04 | 2d? | start no earlier than 2009-12-03 | C1 | 16h | 16h | IMS_ConfMO | 24 |  |  | Rel-9 | 46 | Frederic | IMS_ConfMO |  |  |  |
| 3795 | 1020 | In Case of Emergency (ICE) Graphics |  | 3d? | 2010-03-17 A | 2010-03-19 A | 100% | 2010-03-17 | 2010-03-19 | 3d? | finish no earlier than 2010-03-19 | C6 | 24h | 24h | ICE_Graphics | 24 | Sagem-Orga | heiko.kruse@sagem-orga.com | Rel-9 | 47 | Xavier | ICE_Graphics |  |  |  |
| 3796 | 1021 | **Rel-9 Improvements of the Radio Interface** |  | 397d? | 2008-09-12 A | 2010-03-19 A | 100% | 2008-09-12 | 2010-03-19 | 397d? |  | RP; GP | 19744h | 19744h | RInImp9 | 21 |  |  | Rel-9 | 41 | Issam | RInImp9 |  |  |  |
| 3797 | 1021.1 | LCR TDD UE OTA Performance Requirements |  | 186d? | 2008-09-12 A | 2009-05-29 A | 100% | 2008-09-12 | 2009-05-29 | 186d? | finish no earlier than 2009-05-29 | R4 | 1488h | 1488h | RInImp9-RFLCROTA | 21 | RITT | Wu Xiang (wuxiang@chinattl.com) | Rel-9 | 41 | Issam | RInImp9-RFLCROTA |  |  | RP-090389 |
| 3798 | 1021.2 | **RF requirements for Multicarrier and Multi-RAT BS** |  | 347d? | 2008-11-21 A | 2010-03-19 A | 100% | 2008-11-21 | 2010-03-19 | 347d? |  | R4; G1 | 10336h | 10336h | RInImp9-RFmulti | 21 | Ericsson | Johan.skold@ericsson.com | Rel-9 | 41 | Issam | RInImp9-RFmulti |  |  |  |
| 3799 | 1021.2.1 | RAN4 part of RF requirements for Multicarrier and Multi RAT BS |  | 337d? | 2008-12-05 A | 2010-03-19 A | 100% | 2008-12-05 | 2010-03-19 | 337d? | finish no earlier than 2010-03-19 | R4 | 2696h | 2696h | RInImp9-Rfmulti | 22 | Ericsson | johan.skold@ericsson.com | Rel-9 | 42 | Issam |  |  |  | RP-100027 |
| 3800 | 1021.2.2 | GERAN part of RF requirements for Multicarrier and Multi RAT BS |  | 261d? | 2008-11-21 A | 2009-11-20 A | 100% | 2008-11-21 | 2009-11-20 | 261d? | finish no earlier than 2009-11-20 | G1 | 2088h | 2088h | RInImp9-RFmulti-GERAN | 22 | Ericsson | mats.y.samuelsson@ericsson.com | Rel-9 | 40 | Paolo | RInImp9-RFmulti-GERAN |  |  |  |
| 3801 | 1021.3 | Extended UMTS/LTE 800 MHz | milestone | 0d? | 2008-12-05 A | 2008-12-05 A | 100% | 2008-12-05 | 2009-09-18 | 207d? |  | R4; R2; R3 |  |  | RInImp9-UMTSLTE800 | 22 | NTT DoCoMo | Shingo Suwa (suwas@nttdocomo.co.jp) | Rel-9 | 42 | Issam | RInImp9-UMTSLTE800 |  |  | RP-090687 |
| 3802 | 1021.4 | UMTS/LTE 800 MHz for Europe | milestone | 0d? | 2009-03-06 A | 2009-03-06 A | 100% | 2009-03-06 | 2010-03-19 | 272d? | finish no earlier than 2010-03-19 | R4; R2; R3 |  |  | RInImp9-UMTSLTE800EU | 22 | Ericsson | olav.queseth@ericsson.com | Rel-9 | 43 | Issam | RInImp9-UMTSLTE800EU |  |  | RP-100028 |
| 3803 | 1021.5 | Performance requirement for LCR TDD with UE speeds up to 350 km/h |  | 196d? | 2009-03-06 A | 2009-12-04 A | 100% | 2009-03-06 | 2009-12-04 | 196d? | finish no earlier than 2009-12-04 | R4 | 1568h | 1568h | RInImp9-LCRTDD350 | 22 | CATT | Yuexia Song (songyuexia@catt.cn) | Rel-9 | 43 | Issam | RInImp9-LCRTDD350 |  |  | RP-091035 |
| 3804 | 1021.6 | Extended UMTS/LTE 1500 MHz | milestone | 0d? | 2009-05-30 A | 2009-05-30 A | 100% | 2009-05-30 | 2010-03-19 | 211d? | finish no earlier than 2010-03-19 | R4; R2; R3 |  |  | UMTSLTE1500 | 23 | NTT DoCoMo | Shingo Suwa (suwas@nttdocomo.co.jp) | Rel-9 | 44 | Issam | UMTSLTE1500 |  |  | RP-100029 |
| 3805 | 1022 | **Rel-9 Improvements of the Radio Interface - UE Conformance Testing** |  | 350d? | 2009-05-19 A | 2010-09-17 A | 100% | 2009-05-19 | 2010-09-17 | 350d? |  | R5 | 8184h | 8184h |  | 23 |  |  | Rel-9 | 44 | Ingbert |  |  |  |  |
| 3806 | 1022.1 | Conformance Test Aspects – UMTS/LTE in 800 MHz for Europe |  | 350d? | 2009-05-19 A | 2010-09-17 A | 100% | 2009-05-19 | 2010-09-17 | 350d? | finish no earlier than 2010-09-17 | R5 | 2800h | 2800h | RInImp-UEConTest-UMTSLTE800EU | 23 | Ericsson | fredrik.sundstrom@ericsson.com | Rel-9 | 44 | Ingbert | RInImp-UEConTest-UMTSLTE800EU |  |  | RP-100736 |
| 3807 | 1022.2 | Conformance Test Aspects – Extended UMTS/LTE 1500 MHz |  | 186d? | 2009-09-18 A | 2010-06-04 A | 100% | 2009-09-18 | 2010-06-04 | 186d? | finish no earlier than 2010-06-04 | R5 | 1488h | 1488h | UMTSLTE1500_UEConTest | 23 | NTT DoCoMo | Nguyen Dung Dao (dao@nttdocomo.co.jp) | Rel-9 | 45 | Ingbert | UMTSLTE1500_UEConTest |  |  | RP-100487 |
| 3808 | 1022.3 | TDD UE Over The Air (Antenna) conformance testing methodology |  | 81d? | 2009-05-30 A | 2009-09-18 A | 100% | 2009-05-30 | 2009-09-18 | 81d? | finish no earlier than 2009-09-18 | R5 | 648h | 648h | UEAnt_TDDTest | 23 | CATR | Qu Yan (quyan@emcite.com) | Rel-9 | 44 | Ingbert | UEAnt_TDDTest |  |  | RP-090727 |
| 3809 | 1022.4 | Conformance Test Aspects – Performance requirement for LCR TDD with UE speeds up to 350 km/h |  | 56d? | 2010-03-19 A | 2010-06-04 A | 100% | 2010-03-19 | 2010-06-04 | 56d? | finish no earlier than 2010-06-04 | R5 | 448h | 448h | RInImp9-LCRTDD350_UEConTest | 24 | CATT | Xiaozhong Chen (chexiaozhong@datangmobile.cn) | Rel-9 | 47 | Ingbert | RInImp9-LCRTDD350_UEConTest |  |  | RP-100496 |
| 3810 | 1023 | Conformance Test Aspects – SMS over IMS in E-UTRAN |  | 131d? | 2009-09-18 A | 2010-03-19 A | 100% | 2009-09-18 | 2010-03-19 | 131d? | finish no earlier than 2010-06-18 | R5 | 1048h | 1048h | SMSoverIMS_UEConTest | 23 | Alcatel-Lucent | Nidal Khrais (khrais@alcatel-lucent.com) | Rel-9 | 45 | Ingbert | SMSoverIMS_UEConTest |  |  | RP-100072 |

Notes:
- 3783: -
- 3784: CP#48 completed / Impacted TSs and TRs: 29.165
- 3785: CP#65 complete / Impacted TSs and TRs: RFC 7329 (was draft-kaplan-insipid-session-id)
- 3786: CP#65 complete / Impacted TSs and TRs: RFC 7316 (was draft-vanelburg-dispatch-private-network-ind)
- 3787: In RFC Editors Queue. Dec.14: 75->90; 7/3/16: 90%->100 / Impacted TSs and TRs: draft-ietf-salud-alert-info-urns
- 3788: In RFC Editors Queue. Mar15: 90->100%. RFC updated (was draft-ietf-cuss-sip-uui). Jun 15: RFC 7433 (was draft-ietf-cuss-sip-uui) / Impacted TSs and TRs: RFC 7433
- 3789: In RFC Editors Queue. Dec.14: 75->90. Mar15: 90->100%. RFC updated (was draft-ietf-cuss-sip-uui-isdni). June 15: RFC 7434 (was draft-ietf-cuss-sip-uui-isdn) / Impacted TSs and TRs: RFC 7434
- 3790: CP#62 removed from Rel-8 to Rel-11. Not completed internet-draft / Impacted TSs and TRs: Rel-12 remains draft-dawes-sipping-debug
- 3791: CP#64 Draft removed from 3GPP documentation / Impacted TSs and TRs: draft-avasarala-dispatch-comm-div-notification
- 3792: CP#47 completed [Stage 3 for Rel-7 Emergency Calls (EMC1)]. Related to Rel-9 UID_400038 LCS Control Plane Solution for EPS. Stage 2 in Rel-9 UID_400038 (23.271), UID_410037 (23.167) / Impacted TSs and TRs: 24.229
- 3793: CP#46 completed / Impacted TSs and TRs: 29.212, 29.213, 29.215
- 3794: CP#46 completed. Linked to Rel-6 UID_11051 (IMS Management objects) under the Feature UID_32021 (IMS Phase 2). MO compatible with OMA DM v1.2 & upwards and defined using OMA DM Device Description Framework (OMA-ERELD _DM-V1_2) / Impacted TSs and TRs: New 24.166
- 3795: CP#47 approved WID and completed. Added capability to store ICE graphical information (picture). Linked to CT6 Rel-8 ICE Feature UID_380059 In Case of Emergency numbers storage and easy access on UICC / Impacted TSs and TRs: 31.102 CR#0433
- 3796: RP#41 umbrella Feature created to host Rel-9 WIs / Impacted TSs and TRs: GERAN, UTRA, LTE
- 3797: RP#44 completed technical work (RAN4 internal TR abandoned) / Impacted TSs and TRs: UTRA (no TR 25.8xy produced)
- 3798: RP#47 completed. RF requirements specification applicable to Multi-Standard Radio (MSR) Base Station with multiple carriers and/or multiple 3GPP Radio Access Technologies (RAT) / Impacted TSs and TRs: GERAN, UTRA, LTE
- 3799: RP#48 completed / Impacted TSs and TRs: UTRA, LTE 25.104, 25.105, 36.104, new 37.104, 37.113, 37.141, 37.900
- 3800: GP#44 Core spec completed. GP#40 WID approved / Impacted TSs and TRs: GERAN 45.005, 51.021
- 3801: RP#45 completed / Impacted TSs and TRs: UTRA, LTE 25.101, 25.104, 25.113, 25.133, 34.124, 36.101, 36.104, 36.113, 36.124, 36.133, 36.141, 25.306, 25.307, 25.331, 36.331, 25.461, 25.466, new 36.800
- 3802: RP#47 completed / Impacted TSs and TRs: UTRA, LTE 25.101, 25.104, 25.113, 25.133, 25.141, 34.124, 36.101, 36.104, 36.113, 36.124, 36.133, 36.141, new 36.810, 25.306, 25.307, 25.331, 36.331, 25.461, 25.466
- 3803: RP#46 completed / Impacted TSs and TRs: UTRA 25.102, 25.105, 25.142
- 3804: RP#47 completed. For potential deployment in Japan / Impacted TSs and TRs: UTRA, LTE 25.101, 25.104, 25.113, 25.133, 25.141, 25.306, 25.307, 25.331, 25.461, 25.466, 34.124, 36.101, 36.104, 36.113, 36.124, 36.133, 36.141, 36.331, new (36.821, 36.307)
- 3805: - / Impacted TSs and TRs: UTRA, LTE
- 3806: RP#49 completed. Testing for UID_430009 UMTS/LTE 800 MHz for Europe / Impacted TSs and TRs: UTRA, LTE 34.108, 34.121-1, 34.121-2, 36.508, 36.521-1, 36.521-2, 36.521-3
- 3807: RP#48 completed / Impacted TSs and TRs: UTRA, LTE 34.108, 34.121-1, 34.121-2, 34.123-1, 34.123-2, 36.508, 36.521-1, 36.521-2, 36.521-3, 36.523-1, 36.523-2, 36.523-3
- 3808: RP#45 completed. Finalized TDD UE test methodology based on R4 TR 25.914 (UE and MS antenna performance evaluation method) and TS 25.144 Over the Air (Antenna) minimum performance requirements for the speech mode (terminal close to head) / Impacted TSs and TRs: UTRA 34.114
- 3809: RP#48 completed. Testing for UID_430010 Performance requirement for LCR TDD with UE speeds up to 350 km/h / Impacted TSs and TRs: UTRA 34.122
- 3810: RP#47 completed / Impacted TSs and TRs: LTE 34.229-1, 34.229-2, 34.229-3

| ID | WBS | Task | Type | Duration | Start | Finish | Complete | Baseline start | Baseline finish | Baseline duration | Constraint | Resources | Work | Actual work | PCG approved | Release | TSG approved | MCC resp | Acronym | WI rapporteur name | WI rapporteur e-mail | Status Report | Acronym_3GU_Export | Special Focus Doc |
| --- | --- | --- | --- | --- | --- | --- | --- | --- | --- | --- | --- | --- | --- | --- | --- | --- | --- | --- | --- | --- | --- | --- | --- | --- |
| 3811 | 1024 | **Rel-9 RAN improvements** |  | 395d? | 2009-03-06 A | 2010-09-08 A | 100% | 2000-01-03 | 2010-03-19 | 2667d? |  | RP | 12640h | 12640h | 22 | Rel-9 | 43 | Issam |  |  |  |  |  |  |
| 3812 | 1024.1 | Dual-Cell HSUPA | milestone | 0d? | 2009-03-06 A | 2009-03-06 A | 100% | 2009-03-06 | 2010-03-19 | 272d? | finish no earlier than 2010-03-19 | R1; R2; R3; R4 |  |  | 22 | Rel-9 | 43 | Patrick | RANimp-DC_HSUPA | Nokia Siemens Networks | Karri Ranta-aho (karri.ranta-aho@nsn.com) | RP-100030 | RANimp-DC_HSUPA |  |
| 3813 | 1024.2 | Support for different bands for Dual-Cell HSDPA | milestone | 0d? | 2009-03-06 A | 2009-03-06 A | 100% | 2009-03-06 | 2009-12-04 | 197d? |  | R4; R2; R3 |  |  | 22 | Rel-9 | 43 | Issam | RANimp-MultiBand_DC_HSDPA | Nokia Siemens Networks | Tuomo Säynäjäkangas (tuomo.saynajakangas@nsn.com) | RP-091038 | RANimp-MultiBand_DC_HSDPA |  |
| 3814 | 1024.3 | Combination of DC-HSDPA with MIMO | milestone | 0d? | 2009-03-06 A | 2009-03-06 A | 100% | 2009-03-06 | 2009-12-04 | 197d? |  | R1; R2; R3; R4 |  |  | 22 | Rel-9 | 43 | Patrick | RANimp-DC_MIMO | Ericsson | johan.bergman@ericsson.com | RP-091039 | RANimp-DC_MIMO |  |
| 3815 | 1024.4 | Transmit Antenna Array (TxAA) extension for non-MIMO UEs | milestone | 0d? | 2009-03-06 A | 2009-03-06 A | 100% | 2009-03-06 | 2009-12-04 | 197d? |  | R1; R2; R3; R4 |  |  | 22 | Rel-9 | 43 | Patrick | RANimp-TxAA_nonMIMO | Nokia | Arto Lehti (arto.lehti@nokia.com) | RP-091040 | RANimp-TxAA_nonMIMO |  |
| 3816 | 1024.5 | Cell Portion for 1.28 Mcps TDD |  | 395d? | 2009-03-06 A | 2010-09-08 A | 100% | 2000-01-03 | 2000-07-07 | 136d? | finish no earlier than 2009-03-06 | R3; R1; R4 | 9480h | 9480h | 23 | Rel-9 | 44 | Juha | CP_LCRTDD | CATT | Ying Zhang (zhangying2@datangmobile.cn) | RP-091041 | CP_LCRTDD |  |
| 3817 | 1025 | **Rel-9 RAN improvements - UE Conformance Testing** |  | 588d? | 2010-09-17 A | 2012-12-07 A | 100% | 2010-09-17 | 2012-12-07 | 588d? |  | R5 | 11848h | 11848h | 25 | Rel-9 | 49 | Ingbert |  |  |  |  |  |  |
| 3818 | 1025.1 | Conformance Test Aspects – Combination of DC-HSDPA with MIMO |  | 186d? | 2010-09-17 A | 2011-06-03 A | 100% | 2010-09-17 | 2011-06-03 | 186d? | finish no earlier than 2011-06-03 | R5 | 1488h | 1488h | 25 | Rel-9 | 49 | Ingbert | RANimp-DC_MIMO_UEConTest | Ericsson | leif.mattisson@ericsson.com | RP-110510 | RANimp-DC_MIMO_UEConTest |  |
| 3819 | 1025.2 | Conformance Test Aspects – Dual-Cell HSUPA |  | 453d? | 2011-03-18 A | 2012-12-07 A | 100% | 2011-03-18 | 2012-12-07 | 453d? | finish no earlier than 2012-12-07 | R5 | 3624h | 3624h | 26 | Rel-9 | 51 | Ingbert | RANimp-DC_HSUPA_UEConTest | Ericsson | leif.mattisson@ericsson.com | RP-121524 | RANimp-DC_HSUPA_UEConTest |  |
| 3820 | 1025.3 | Conformance Test Aspects – Support for different bands for Dual-Cell HSDPA |  | 254d? | 2011-03-18 A | 2012-03-02 A | 100% | 2011-03-18 | 2012-03-02 | 254d? | finish no earlier than 2012-03-02 | R5 | 2032h | 2032h | 26 | Rel-9 | 51 | Ingbert | RANimp-MultiBand_DC_HSDPA_UEConTest | Ericsson | leif.mattisson@ericsson.com | RP-120036 | RANimp-MultiBand_DC_HSDPA_UEConTest |  |
| 3821 | 1026 | **LTE improvements** |  | 587d? | 2009-03-06 A | 2011-06-03 A | 100% | 2009-03-06 | 2011-06-03 | 587d? |  | R1; R2; R4; R5 | 21840h | 21840h | 22 | Rel-9 | 42 | Patrick | LTEimp |  |  |  | LTEimp |  |
| 3822 | 1026.1 | LTE Pico NodeB RF Requirements |  | 196d? | 2009-03-06 A | 2009-12-04 A | 100% | 2009-03-06 | 2009-12-04 | 196d? | finish no earlier than 2010-03-05 | R4 | 1568h | 1568h | 22 | Rel-9 | 43 | Issam | LTEimp-Pico_eNB-RF | Huawei | Liyan Yin (yinliyan@huawei.com) | RP-091045 | LTEimp-Pico_eNB-RF |  |
| 3823 | 1026.2 | Enhanced Dual-Layer transmission for LTE | milestone | 0d? | 2009-03-06 A | 2009-03-06 A | 100% | 2009-03-06 | 2010-03-19 | 272d? | finish no earlier than 2010-03-18 | R1; R2; R4 |  |  | 22 | Rel-9 | 43 | Patrick | LTEimp-eDL | China Mobile | Xu Xiaodong (xuxiaodong@chinamobile.com) | RP-100034 | LTEimp-eDL |  |
| 3824 | 1026.3 | UE Conformance Test Aspects – Enhanced Dual-layer transmission for LTE TDD |  | 186d? | 2010-09-17 A | 2011-06-03 A | 100% | 2010-09-17 | 2011-06-03 | 186d? | finish no earlier than 2011-06-03 | R5 | 1488h | 1488h | 25 | Rel-9 | 49 | Ingbert | LTEimp-eDL_UEConTest | China Mobile | Shanpeng Xiao (xiaoshanpeng@chinamobile.com) | RP-110509 | LTEimp-eDL_UEConTest |  |
| 3825 | 1027 | Rel-9 Self-Organizing Networks (SON) | milestone | 0d? | 2009-03-06 A | 2009-03-06 A | 100% | 2009-03-06 | 2010-03-19 | 272d? | finish no earlier than 2010-03-19 | R3; R2 |  |  | 22 | Rel-9 | 42 | Juha | SON | Nokia Siemens Networks | krzysztof.kordybach@nsn.com | RP-100038 | SON | SON |
| 3826 | 1028 | **AGNSS Performances and Testing Procedures** |  | 787d? | 2008-05-16 A | 2011-05-20 A | 100% | 2008-05-16 | 2011-05-20 | 787d? |  | G1; G3new | 22664h | 22664h |  | Rel-9 |  | Paolo | AGNSSPTP | Thales | Michel.monnerat@thalesaleniaspace.com |  | AGNSSPTP |  |
| 3827 | 1028.1 | AGNSS Minimum Performances |  | 472d? | 2008-05-16 A | 2010-03-05 A | 100% | 2008-05-16 | 2010-03-05 | 472d? | finish no earlier than 2010-03-05 | G1 | 3776h | 3776h |  | Rel-9 |  | Paolo | AGNSSPTP-Perfreq | Thales | Michel.monnerat@thalesaleniaspace.com |  | AGNSSPTP-Perfreq |  |
| 3828 | 1028.2 | AGNSS Testing Procedures |  | 787d? | 2008-05-16 A | 2011-05-20 A | 100% | 2008-05-16 | 2011-05-20 | 787d? | finish no earlier than 2011-05-20 | G3new | 6296h | 6296h |  | Rel-9 |  | Ingbert | AGNSSPTP-MStest | Thales | Michel.monnerat@thalesaleniaspace.com |  | AGNSSPTP-MStest |  |
| 3829 | 1029 | **Voice services over Adaptive Multi-user channels on One Slot** |  | 860d? | 2008-11-21 A | 2012-03-02 A | 100% | 2008-11-21 | 2012-03-02 | 860d? |  | GP; G1; G2; G3new | 71592h | 71592h | 22 | Rel-9 | 42 | Paolo | VAMOS | Nokia Siemens Networks, China Mobile | juergen.hofmann@nsn.com, liuxiaoyu@chinamobile.com |  | VAMOS |  |
| 3830 | 1029.1 | Stage 2 for Voice services over Adaptive Multi-user channels on One Slot |  | 392d? | 2008-11-21 A | 2010-05-21 A | 100% | 2008-11-21 | 2010-05-21 | 392d? | finish no earlier than 2010-05-21 | GP; G1; G2 | 9408h | 9408h | 22 | Rel-9 | 40 | Paolo | VAMOS | Nokia Siemens Networks, China Mobile | juergen.hofmann@nsn.com, liuxiaoyu@chinamobile.com |  |  |  |
| 3831 | 1029.2 | Stage 3 for Voice services over Adaptive Multi-user channels on One Slot |  | 596d? | 2008-11-24 A | 2011-03-04 A | 100% | 2008-11-24 | 2011-03-04 | 596d? | finish no earlier than 2011-03-04 | GP; G1; G2 | 14304h | 14304h | 22 | Rel-9 | 40 | Paolo | VAMOS | Nokia Siemens Networks, China Mobile | juergen.hofmann@nsn.com, liuxiaoyu@chinamobile.com |  |  |  |
| 3832 | 1029.3 | VAMOS Radio Performance Requirements |  | 651d? | 2008-11-24 A | 2011-05-20 A | 100% | 2008-11-24 | 2011-05-20 | 651d? | finish no earlier than 2011-05-20 | GP; G1; G2 | 15624h | 15624h | 22 | Rel-9 | 40 | Paolo | VAMOS | Nokia Siemens Networks, China Mobile | juergen.hofmann@nsn.com, liuxiaoyu@chinamobile.com |  |  |  |
| 3833 | 1029.4 | VAMOS - MS conformance testing |  | 392d? | 2010-09-03 A | 2012-03-02 A | 100% | 2010-09-03 | 2012-03-02 | 392d? | finish no earlier than 2012-03-02 | G3new | 3128h | 3128h | 25 | Rel-9 | 47 | Ingbert | VAMOS_MStest | BlackBerry | Raveendra Seetharam (rseetharam@rim.com) |  | VAMOS_MStest |  |
| 3834 | 1029.5 | VAMOS - BTS conformance testing |  | 201d? | 2010-11-26 A | 2011-09-02 A | 100% | 2010-11-26 | 2011-09-02 | 201d? | finish no earlier than 2011-09-02 | G1 | 1608h | 1608h | 26 | Rel-9 | 48 | Paolo | VAMOS_BTStest | Nokia Siemens Networks | eddie.riddington@nsn.com |  | VAMOS_BTStest |  |

Notes:
- 3811: RP#47 completed / Impacted TSs and TRs: UTRA
- 3812: RP#47 completed / Impacted TSs and TRs: 25.101, 25.104, 25.133, 25.211, 25.212, 25.213, 25.214, 25.215, 25.319, 25.306, 25.321, 25.331, 25.423, 25.433
- 3813: RP#46 completed. RP#62 existing TS 25.317 replaced by new TS 25.327 / Impacted TSs and TRs: 25.101, 25.104, 25.133, 25.306, 25.308, 25.331, 25.423, 25.433, new 25.317 replaced by new TS 25.327
- 3814: RP#46 completed / Impacted TSs and TRs: 25.101, 25.104, 25.133, 25.211, 25.212, 25.213, 25.214, 25.215, 25.308, 25.321, 25.331, 26.306, 25.423, 25.433
- 3815: RP#46 completed / Impacted TSs and TRs: 25.101, 25.104, 25.211, 25.212, 25.213, 25.214, 25.215, 25.308, 25.306, 25.321, 25.331, 25.423, 25.433
- 3816: RP#46 completed / Impacted TSs and TRs: 25.102, 25.105, 25.123, 25.225, 25.423, 25.433
- 3817: -
- 3818: UTRA. RP#52 completed. Testing for Rel-9 UID_430016 Combination of DC-HSDPA with MIMO / Impacted TSs and TRs: UTRA 34.108, 34.121-1, 34.121-2, 34.123-1, 34.123-2, 34.123-3
- 3819: RP#58 completed. Testing for Rel-9 UID_430014 Dual-Cell HSUPA / Impacted TSs and TRs: UTRA 34.108, 34.121-1, 34.121-2, 34.123-1, 34.123-2, 34.123-3
- 3820: RP#55 completed. Testing for Rel-9 UID_430015 Support for different bands for Dual-Cell HSDPA / Impacted TSs and TRs: UTRA 34.108, 34.121-1, 34.121-2, 34.123-1, 34.123-2, 34.123-3
- 3821: - / Impacted TSs and TRs: LTE
- 3822: RP#46 completed / Impacted TSs and TRs: 36.104, 36.141, new 36.931
- 3823: RP#47 completed / Impacted TSs and TRs: 36.101, 36.211, 36.212, 36.213, 36.331
- 3824: RP#52 completed. Testing for UID_430029 (Enhanced Dual-Layer transmission for LTE) / Impacted TSs and TRs: 36.508, 36.521-1, 36.521-2
- 3825: RP#47 completed / Impacted TSs and TRs: LTE 25.413, 36.300, 36.413, 36.423, 48.018, New 36.902
- 3826: GP#46 still ongoing MS testing. Linked to Rel-10 RAN4 UID_450027 (AGNSS Minimum Performance for UTRAN)
- 3827: GP#45 completed (open performance requirements alignment GPS/Galileo) / Impacted TSs and TRs: 45.005
- 3828: GP#50 completed / Impacted TSs and TRs: 51.010-1, new 51.010-7
- 3829: Triggered by UID_50590 (MUROS) Study on Multi-User Reusing-One-Slot
- 3830: GP#46 completed. GP#40 WID approved / Impacted TSs and TRs: 45.001
- 3831: GP#49 completed. GP#40 WID approved / Impacted TSs and TRs: 24.008, 44.018, 45.002, 45.003, 45.004, 45.008, 48.008, 48.058
- 3832: GP#50 completed. GP#40 WID approved / Impacted TSs and TRs: 45.005
- 3833: GP#53 completed. GP#47 WID approved / Impacted TSs and TRs: 51.010-1, 51.010-2
- 3834: GP#51 completed. GP#48 WID approved / Impacted TSs and TRs: 51.021

| ID | WBS | Task | Type | Duration | Start | Finish | Complete | Baseline start | Baseline finish | Baseline duration | Constraint | Resources | Work | Actual work | Acronym | PCG approved | WI rapporteur name | WI rapporteur e-mail | Release | TSG approved | MCC resp | Acronym_3GU_Export | PCG stopped | TSG stopped | Special Focus Doc | Status Report |
| --- | --- | --- | --- | --- | --- | --- | --- | --- | --- | --- | --- | --- | --- | --- | --- | --- | --- | --- | --- | --- | --- | --- | --- | --- | --- | --- |
| 3835 | 1030 | **Cell Broadcast protocol Base Station Controller – Cell Broadcast Centre (BSC-CBC)** |  | 222d? | 2009-05-15 A | 2010-03-19 A | 100% | 2009-05-15 | 2010-03-19 | 222d? |  | GP; C1 | 7024h | 7024h | CEBRO | 23 | Ericsson | claes-goran.persson@ericsson.com | Rel-9 | 42 | Paolo | CEBRO |  |  |  |  |
| 3836 | 1030.1 | GERAN part of Cell Broadcast protocol Base Station Controller – Cell Broadcast Centre |  | 212d? | 2009-05-15 A | 2010-03-05 A | 100% | 2009-05-15 | 2010-03-05 | 212d? | finish no earlier than 2010-03-05 | GP | 1696h | 1696h | CEBRO | 23 | Ericsson | claes-goran.persson@ericsson.com | Rel-9 | 42 | Paolo |  |  |  |  |  |
| 3837 | 1030.2 | CT1 part of Cell Broadcast protocol Base Station Controller – Cell Broadcast Centre |  | 222d? | 2009-05-15 A | 2010-03-19 A | 100% | 2009-05-15 | 2010-03-19 | 222d? | finish no earlier than 2010-03-19 | C1 | 1776h | 1776h | CEBRO | 23 | Ericsson | claes-goran.persson@ericsson.com | Rel-9 | 42 | Frederic |  |  |  |  |  |
| 3838 | 1031 | Hybrid Location |  | 136d? | 2009-05-18 A | 2009-11-20 A | 100% | 2009-05-18 | 2009-11-20 | 136d? | finish no earlier than 2009-11-20 | GP | 1088h | 1088h | HILT | 23 | TruePosition | Matt Ward (mward@trueposition.com) | Rel-9 | 42 | Paolo | HILT |  |  |  |  |
| 3839 | 1032 | (Small) Technical Enhancements and Improvements for Rel-9 |  | 325d? | 2008-09-15 A | 2009-12-10 A | 100% | 2008-09-15 | 2009-12-10 | 325d? | finish no earlier than 2009-12-10 | SP; CP; RP; GP | 10400h | 10400h | TEI9 | 22 |  |  | Rel-9 | 42 | All | TEI9 |  |  |  |  |
| 3840 | 1033 | Test - (Small) Technical Enhancements and Improvements for Rel-9 |  | 286d? | 2009-11-20 A | 2010-12-24 A | 100% | 2009-11-20 | 2010-12-24 | 286d? | finish no earlier than 2010-12-24 | R5; G3new | 4576h | 4576h | TEI9_Test | 24 |  |  | Rel-9 | 44 | Ingbert | TEI9_Test |  |  |  |  |
| 3841 | 1034 | **Deleted - Services Alignment and Migration** |  | 467d? | 2006-12-06 A | 2008-09-18 A | 100% | 2006-12-06 | 2008-09-18 | 467d? |  | S1 | 7472h | 7472h | ServAl |  | Telefónica O2 | chris.friel@O2.com | Rel-9 | 33 | Alain | ServAl | PCG-21 | SP-41 |  |  |
| 3842 | 1034.1 | Deleted - Stage 1 for ServAl |  | 467d? | 2006-12-06 A | 2008-09-18 A | 100% | 2006-12-06 | 2008-09-18 | 467d? | finish no earlier than 2008-12-11 | S1 | 3736h | 3736h |  | 21 | Telefónica O2 | chris.friel@O2.com | Rel-9 | 33 | Alain |  | PCG-21 | SP-41 |  |  |
| 3843 | 1035 | Deleted - Harmonization of Gq'/Rx for Common IMS |  | 304d? | 2008-01-14 A | 2009-03-12 A | 100% | 2008-01-14 | 2009-03-12 | 304d? | finish no earlier than 2009-03-12 | S2 | 2432h | 2432h | IMS_Comm_GqRx_Harm | 21 | Alcatel-Lucent | geoffrey.cristallo@alcatel-lucent.be | Rel-9 | 38 | Maurice | IMS_Comm_GqRx_Harm | PCG-22 | SP-43 |  |  |
| 3844 | 1036 | Deleted - Support of WiMAX - LTE Mobility |  | 407d? | 2008-06-06 A | 2009-12-25 A | 100% | 2008-06-06 | 2009-12-25 | 407d? | start no earlier than 2008-06-06 | R2 | 3248h | 3248h | WiMAX_LTE_Mobility | 21 | Samsung |  | Rel-9 | 38 | Yong-Jun | WiMAX_LTE_Mobility | PCG-21 | SP-39 |  |  |
| 3845 | 1037 | Deleted - Support of WiMAX - UMTS Mobility |  | 407d? | 2008-06-06 A | 2009-12-25 A | 100% | 2008-06-06 | 2009-12-25 | 407d? | start no earlier than 2008-06-06 | R2 | 3248h | 3248h | WiMAX_UMTS_Mobility | 21 | Intel |  | Rel-9 | 38 | Yong-Jun | WiMAX_UMTS_Mobility | PCG-21 | SP-39 |  |  |
| 3846 | 1038 | Deleted - Definition of 3GPP UICC services over the new high-speed interface | milestone | 0d? | 2010-03-19 A | 2010-03-19 A | 100% | 2010-03-19 | 2010-03-19 | 0d? |  | C6 |  |  | UICCHS | 21 | Gemalto | Denis.Lheriteau@gemalto.com | Rel-9 | 38 | Xavier | UICCHS | PCG-24 | CP-47 |  |  |
| 3847 | 1039 | **Deleted - SAES Enhancements (non RAN aspects)** |  | 381d? | 2007-06-25 A | 2008-12-08 A | 100% | 2007-06-25 | 2008-12-08 | 381d? |  | S2 | 11664h | 11664h | SAES_Ph2 | 21 | Nokia Siemens Networks |  | Rel-9 | 39 | Maurice | SAES_Ph2 | PCG-21 | SP-39 |  |  |
| 3848 | 1039.1 | Deleted - Functions and procedures for SAE to support LTE MBMS |  | 381d? | 2007-06-25 A | 2008-12-08 A | 100% | 2007-06-25 | 2008-12-08 | 381d? | finish no earlier than 2008-12-08 | S2 | 3048h | 3048h | SAES_Ph2 |  |  |  | Rel-9 | 35 | Maurice |  | PCG-21 | SP-39 |  |  |
| 3849 | 1039.2 | Deleted - CS over EPS |  | 194d? | 2008-03-12 A | 2008-12-08 A | 100% | 2008-03-12 | 2008-12-08 | 194d? | finish no earlier than 2008-12-08 | S2 | 1552h | 1552h | SAES_Ph2 | 21 |  |  | Rel-9 | 39 | Maurice |  | PCG-21 | SP-39 |  |  |
| 3850 | 1039.3 | **Deleted - SAE for generic support for non-3GPP accesses** |  | 251d? | 2007-06-25 A | 2008-06-09 A | 100% | 2007-06-25 | 2008-06-09 | 251d? |  | S2 | 4016h | 4016h | SAES_Ph2 | 21 |  |  | Rel-9 | 39 | Maurice |  | PCG-21 | SP-39 |  |  |
| 3851 | 1039.3.1 | Deleted - Single Radio Aspects of SAE for Optimized Handover with WiMAX |  | 251d? | 2007-06-25 A | 2008-06-09 A | 100% | 2007-06-25 | 2008-06-09 | 251d? | finish no earlier than 2008-06-09 | S2 | 2008h | 2008h | SAES_Ph2 | 21 |  |  | Rel-9 | 39 | Maurice |  | PCG-21 | SP-39 |  |  |
| 3852 | 1040 | Deleted - Lawful Interception in the 3GPP Rel-9 |  | 211d? | 2009-06-04 A | 2010-03-25 A | 100% | 2009-06-04 | 2010-03-25 | 211d? | finish no earlier than 2010-03-25 | S3 | 1688h | 1688h | LI9 | 23 | PIDS, Nortel | Koen Jaspers, Ronald Ryan | Rel-9 | 44 | Mirko | LI9 | PCG-24 | SP-47 |  |  |
| 3853 | 1041 | Release 9 Studies | milestone | 0d? | 2008-06-05 A | 2008-06-05 A | 100% | 2008-06-05 | 2010-03-19 | 468d? |  | CP; RP; SP |  |  |  |  |  |  | Rel-9 |  |  |  |  |  |  |  |
| 3854 | 1042 | Study on Service Specific Access Control in EPS |  | 136d? | 2008-06-05 A | 2008-12-11 A | 100% | 2008-06-05 | 2008-12-11 | 136d? | start no earlier than 2008-06-05 | S1 | 1088h | 1088h | FS_SSAC | 21 | NTT DoCoMo | Shin-ichi Isobe (isobes@nttdocomo.co.jp) | Rel-9 | 40 | Alain | FS_SSAC |  |  |  |  |
| 3855 | 1043 | Study on CS Domain Services over EPS access |  | 492d? | 2007-04-25 A | 2009-03-12 A | 100% | 2007-04-25 | 2009-03-12 | 492d? | finish no earlier than 2009-03-12 | S2 | 3936h | 3936h | FS_CSoPS |  | T-Mobile | Karl-Heinz.Nenner@T-Mobile.net | Rel-9 | 35 | Maurice | FS_CSoPS |  |  |  |  |
| 3856 | 1044 | Study on Extended Support of IMS Emergency Calls |  | 319d? | 2007-09-24 A | 2008-12-11 A | 100% | 2007-09-24 | 2008-12-11 | 319d? | finish no earlier than 2009-06-18 | S2 | 2552h | 2552h | FS_IMS-eCall |  | Qualcomm | Stephen Edge | Rel-9 | 37 | Maurice | FS_IMS-eCall |  |  | Public Safety (I-A) |  |
| 3857 | 1045 | Study on Service Continuity for Emergency Voice Calls |  | 721d? | 2006-06-08 A | 2009-03-12 A | 100% | 2006-06-08 | 2009-03-12 | 721d? | finish no earlier than 2009-03-12 | S2 | 5768h | 5768h | FS_VCCEm |  | Nortel | Ricky Kaura (rkaura@nortel.com) | Rel-9 | 32 | Maurice | FS_VCCEm |  |  | Public Safety (I-A) |  |
| 3858 | 1046 | Study on Security Aspects of Remote Provisioning and Change of Subscription for M2M Equipment |  | 1483.15d? | 2004-04-06 A | 2009-12-10 A | 100% | 2004-04-06 | 2009-12-10 | 1483.15d? | finish no earlier than 2009-12-10 | S3; C6 | 23730.4h | 23730.4h | FS_UM2M |  | Ericsson | vesa.lehtovirta@ericsson.com | Rel-9 | 37 | Mirko | FS_UM2M |  |  | MTC, M2M |  |
| 3859 | 1047 | Study on System Maintenance over Itf-N |  | 602d? | 2007-06-07 A | 2009-09-24 A | 100% | 2007-06-07 | 2009-09-24 | 602d? | finish no earlier than 2009-09-24 | S5 | 4808h | 4808h | FS_OAM-Maint-Itf-N |  | ZTE | Shuqiang Huang (huangsq@zte.com.cn) | Rel-9 | 36 | Mirko | FS_OAM-Maint-Itf-N |  |  |  |  |
| 3860 | 1048 | Study on Self-Organizing Networks (SON) related OAM interfaces for Home NodeB |  | 522d? | 2007-06-07 A | 2009-06-04 A | 100% | 2007-06-07 | 2009-06-04 | 522d? | finish no earlier than 2009-12-10 | S5 | 4168h | 4168h | FS_OAM-SON-HNB |  | Huawei | Zou Lan (zlan@huawei.com) | Rel-9 | 36 | Mirko | FS_OAM-SON-HNB |  |  | HNB, SON |  |
| 3861 | 1049 | Study on Self-healing of Self-Organizing Networks (SON) |  | 416d? | 2008-02-22 A | 2009-09-24 A | 100% | 2008-02-22 | 2009-09-24 | 416d? | finish no earlier than 2009-09-24 | S5 | 3320.15h | 3320.15h | FS_OAM-SON-SH | 21 | ZTE | zhu.weihong@zte.com.cn | Rel-9 | 39 | Mirko | FS_OAM-SON-SH |  |  | SON |  |
| 3862 | 1050 | Study on Service Oriented Architecture (SOA) for IRP |  | 262d? | 2008-06-05 A | 2009-06-04 A | 100% | 2008-06-05 | 2009-06-04 | 262d? | finish no earlier than 2009-05-20 | S5 | 2088h | 2088h | FS_OAM_SOA_IRP | 21 | Ericsson | edwin.tse@ericsson.com | Rel-9 | 40 | Mirko | FS_OAM_SOA_IRP |  |  |  |  |
| 3863 | 1051 | Study on Evaluation of the inclusion of Path Loss Based Technology in the UTRAN |  | 516d? | 2007-12-17 A | 2009-12-04 A | 100% | 2007-12-17 | 2009-12-04 | 516d? | finish no earlier than 2009-09-18 | R4 | 4120h | 4120h | FS_RAN-Pathloss | 21 | Polaris Wireless | Norman Shaw (nshaw@polariswireless.com) | Rel-9 | 38 | Issam | FS_RAN-Pathloss |  |  |  | RP-091080 |
| 3864 | 1052 | Study on LTE-Advanced |  | 781.2d? | 2007-03-23 A | 2010-03-19 A | 100% | 2007-03-23 | 2010-03-19 | 781.2d? | finish no earlier than 2010-03-19 | R1; R2; R3; R4 | 24998.4h | 24998.4h | FS_RAN_LTEA | 21 | NTT DoCoMo | Tetsushi Abe | Rel-9 | 39 | Patrick | FS_RAN_LTEA |  |  | CA | RP-100080 |
| 3865 | 1053 | Study on 1.28 Mcps TDD Home NodeB |  | 387d? | 2008-02-20 A | 2009-12-04 A | 100% | 2008-02-20 | 2009-12-04 | 387d? | finish no earlier than 2009-12-04 | R4 | 3096h | 3096h | FS_RAN-HNBLCRTDD | 21 | TD Tech | Li Rong (lirong@td-tech.com) | Rel-9 | 41 | Issam | FS_RAN-HNBLCRTDD |  |  | HNB | RP-091081 |
| 3866 | 1054 | Study on E-UTRAN Mobility Evaluation and Enhancement |  | 126d? | 2008-12-05 A | 2009-05-29 A | 100% | 2008-12-05 | 2009-05-29 | 126d? | finish no earlier than 2009-05-29 | R1 | 1008h | 1008h | FS_EUTRAN_mob | 22 | Qualcomm | Rajat Prakash (rprakash@qualcomm.com) | Rel-9 | 42 | Patrick | FS_EUTRAN_mob |  |  |  | RP-090426 |
| 3867 | 1055 | Study on Minimization of drive-tests in Next Generation Networks |  | 196d? | 2009-03-06 A | 2009-12-04 A | 100% | 2009-03-06 | 2009-12-04 | 196d? | finish no earlier than 2009-12-04 | R2 | 1568h | 1568h | FS_NGN_min_drive-tests | 22 | Qualcomm | Masato Kitazoe (mkitazoe@qualcomm.com) | Rel-9 | 43 | Yong-Jun | FS_NGN_min_drive-tests |  |  |  | RP-091084 |
| 3868 | 1056 | Study on Enhanced Interference Management for HNBs |  | 61d? | 2009-03-06 A | 2009-05-29 A | 100% | 2009-03-06 | 2009-05-29 | 61d? | start no earlier than 2009-03-06 | R4 | 488h | 488h | FS_eInterfMgmt_HNB | 22 | Qualcomm | Farhad Meshkati (fmeshkat@qualcomm.com) | Rel-9 | 43 | Issam | FS_eInterfMgmt_HNB |  |  | HNB | RP-090429 |
| 3869 | 1057 | Study on Enhanced Interference Management Mechanisms for HNBs |  | 81d? | 2009-05-30 A | 2009-09-18 A | 100% | 2009-05-30 | 2009-09-18 | 81d? | finish no earlier than 2009-09-18 | R3 | 648h | 648h | FS_eInterfMgmtMchsm_HNB | 23 | Qualcomm | Farhad Meshkati (fmeshkat@qualcomm.com) | Rel-9 | 44 | Juha | FS_eInterfMgmtMchsm_HNB |  |  | HNB | RP-090733 |
| 3870 | 1058 | Deleted - Study on Protection against SMS and MMS spam |  | 862d? | 2006-06-08 A | 2009-09-24 A | 100% | 2006-06-08 | 2009-09-24 | 862d? | finish no earlier than 2009-09-24 | S3 | 6896h | 6896h | FS_CPSMal |  | Orange | eric.gauthier@orange.ch | Rel-9 | 32 | Mirko | FS_CPSMal | PCG-23 | SP-45 |  |  |
| 3871 | 1059 | Release 8 Features |  | 914.3d? | 2006-09-19 A | 2010-03-19 A | 100% | 2006-09-19 | 2010-03-19 | 914.3d? | start no earlier than 2000-01-03 | CP; GP; RP; SP | 29257.6h | 29257.6h |  |  |  |  | Rel-8 |  |  |  |  |  |  |  |

Notes:
- 3835: CP#47 completed. GP#45 completed. GP#42 WID approved
- 3836: GP#45 completed. GP#42 WID approved / Impacted TSs and TRs: new 48.049
- 3837: CP#47 completed / Impacted TSs and TRs: 23.041
- 3838: GP#44 completed. GP#42 WID approved (Hybrid Integrated Location Technology=HILT) / Impacted TSs and TRs: 43.059, 48.071
- 3839: SP#46 completed
- 3840: GP#44 created
- 3841: SP#41 closed (no tangible result of this work; no CR against TR 22.983). Triggered by Study UID_370086 (FSServAl)
- 3842: SP#41 closed (no tangible result of this work; no CR against TR 22.983) / Impacted TSs and TRs: 22.983
- 3843: SP#43 stopped. LS_out to TISPAN informs about stopping this activity / Impacted TSs and TRs: 23.822, 23.203
- 3844: RP#39: No agreed WID / Impacted TSs and TRs: 36.306, 36.331, 36.413, 36.300, 36.214, 36.133, 36.304
- 3845: RP#39: No agreed WID / Impacted TSs and TRs: 25.306, 25.331, 25.413
- 3846: CP#47 work stopped/abandoned / Impacted TSs and TRs: 31.xyz
- 3847: SP#39 created to host Rel-9 Wis. BUT no agreed WID
- 3848: SP#39 SAE functionality moved to Rel-9. WID returned to SA2 for re-consideration & remove MBMS for EPS from Rel 8
- 3849: SP#39 SAE functionality moved to Rel-9. BUT no agreed WID
- 3850: SP#39 SAE functionality moved to Rel-9. BUT no agreed WID
- 3851: SP#39 SAE functionality moved to Rel-9. BUT no agreed WID
- 3852: SP#47 stopped. WI + new topics moved to Rel-10 / Impacted TSs and TRs: 33.106, 33.107, 33.108
- 3853: -
- 3854: SP#42 completed. Spin-off Feature UID_420020 (SSAC) / Impacted TSs and TRs: 22.986
- 3855: SP#43 completed. Linked to Combinational Services UID_31064, Services Alignment and Migration (ServAl) UID_330017 and 3GPP System Architecture Evolution (SAES) UID_3208 / Impacted TSs and TRs: 23.879
- 3856: SP#42 completed / Impacted TSs and TRs: 23.868
- 3857: SP#43 completed / Impacted TSs and TRs: 23.826
- 3858: SP#46 completed. Triggered by the SA1 Rel-8 Study on Facilitating Machine to Machine Communication in GSM and UMTS (FS_M2M) UID_7027 in TR 22.868. / Impacted TSs and TRs: 33.812
- 3859: SP#45 completed / Impacted TSs and TRs: 32.822
- 3860: SP#44 completed. Linked to SA5 TR 32.816 Study of Management for LTE and SAE (UID_340036) / Impacted TSs and TRs: 32.821
- 3861: SP#45 completed. Linked to SA5 TR 32.816 Study of Management for LTE and SAE (UID_340036) / Impacted TSs and TRs: 32.823
- 3862: SP#44 completed. Spin-off implementation WI UID_440064 Service Oriented Architecture (SOA) for IRP / Impacted TSs and TRs: 32.824
- 3863: RP#46 completed / Impacted TSs and TRs: 25.907
- 3864: RP#47 completed / Impacted TSs and TRs: 36.913 , New 36.814, 36.912, R2 36.806 (Relay architectures for E-UTRA), R4 36.815 (LTE-Advanced feasibility studies in RAN4)
- 3865: RP#46 completed / Impacted TSs and TRs: 25.866
- 3866: RP#44 closed (RP-090452 R1 LS to RAN on Conclusions for LTE Mobility Study Item - no further Rel-9 action / no TR needed) / Impacted TSs and TRs: none
- 3867: RP#46 completed / Impacted TSs and TRs: 36.805
- 3868: RP#44 completed. Linked to UID_420008 LTE FDD Home eNodeB RF Requirements. Spin-off RAN3 UID_440015 Study on Enhanced Interference Management Mechanisms for HNBs / Impacted TSs and TRs: 25.967
- 3869: RP#45 completed. Triggered by RAN4 UID_430027 Study on Enhanced Interference Management for HNBs / Impacted TSs and TRs: 25.967
- 3870: SP#45 work stopped/abandoned / Impacted TSs and TRs: 33.9xx
- 3871: -

| ID | WBS | Task | Duration | Start | Finish | Complete | Remaining | Baseline start | Baseline finish | Baseline duration | Total slack | Constraint | Resources | Work | Actual work | Acronym | WI rapporteur name | WI rapporteur e-mail | Release | TSG approved | MCC resp | Acronym_3GU_Export | PCG approved |
| --- | --- | --- | --- | --- | --- | --- | --- | --- | --- | --- | --- | --- | --- | --- | --- | --- | --- | --- | --- | --- | --- | --- | --- |
| 3872 | 1060 | **3GPP System Architecture Evolution Specification - Evolved Packet System (non RAN aspects)** | 1618d? | 2006-04-12 A | 2012-06-15 | 99% | 0d? | 2006-04-12 | 2012-06-15 | 1618d? | 0d |  | S1; S2; S3; S5; C1; C3; C4; C6; IETF | 512323h | 510115h | SAES | T-Mobile | michael.kurz@t-mobile.at | Rel-8 | 32 | Alain | SAES |  |
| 3873 | 1060.1 | Requirements for evolution of the 3GPP system architecture | 395d? | 2006-06-08 A | 2007-12-12 A | 100% |  | 2006-06-08 | 2007-12-12 | 395d? |  | finish no earlier than 2007-11-30 | S1 | 3160h | 3160h | AIPN-SAE | T-Mobile | michael.kurz@t-mobile.at | Rel-8 | 32 | Alain | AIPN-SAE |  |
| 3874 | 1060.2 | **High level and common (for all accesses) functions** | 629d? | 2007-01-02 A | 2009-05-29 A | 100% |  | 2007-01-02 | 2009-05-29 | 629d? |  |  | S2; S3; C1; C3; C4 | 62664h | 62664h | EPS-ComF | Nokia Siemens Networks | balazs.bertenyi@nsn.com | Rel-8 | 37 | Maurice | EPS-ComF |  |
| 3875 | 1060.2.1 | Stage 2 for High level functions | 370d? | 2007-01-02 A | 2008-06-02 A | 100% |  | 2007-01-02 | 2008-06-02 | 370d? |  | finish no earlier than 2008-06-02 | S2 | 2960h | 2960h | SAES-SA-HLF | Motorola | Irfan.Ali@motorola.com | Rel-8 | 35 | Maurice | SAES-SA-HLF |  |
| 3876 | 1060.2.2 | Stage 2 Security Architecture | 197d? | 2008-03-12 A | 2008-12-11 A | 100% |  | 2008-03-12 | 2008-12-11 | 197d? |  | finish no earlier than 2008-12-11 | S3 | 1576h | 1576h | SAES | Nokia Siemens Networks | marc.blommaert.ext@nsn.com | Rel-8 | 39 | Mirko |  | 21 |
| 3877 | 1060.2.3 | Stage 3 (CT1) for SAE impact on services, network functions and capabilities | 545d? | 2007-02-05 A | 2009-03-06 A | 100% |  | 2007-02-05 | 2009-03-06 | 545d? |  | finish no earlier than 2009-03-06 | C1 | 4360h | 4360h | SAES | Nokia Siemens Networks | robert.zaus@nsn.com | Rel-8 | 34 | Frederic |  |  |
| 3878 | 1060.2.4 | Stage 3 SAE impact on existing capabilities | 480d? | 2007-02-05 A | 2008-12-05 A | 100% |  | 2007-02-05 | 2008-12-05 | 480d? |  | finish no earlier than 2008-12-12 | C3 | 3840h | 3840h | SAES | Huawei | Wei Weihua (weiwh@huawei.com) | Rel-8 | 34 | Adrian |  |  |
| 3879 | 1060.2.5 | Stage 3 (CT4) of SAE impact on existing capabilities | 545d? | 2007-02-05 A | 2009-03-06 A | 100% |  | 2007-02-05 | 2009-03-06 | 545d? |  | finish no earlier than 2009-03-06 | C4 | 4360h | 4360h | SAES | Huawei | shahab.lavasani@huawei.com | Rel-8 | 34 | Kimmo |  |  |
| 3880 | 1060.2.6 | Stage 2/3 for Network selection procedures | 480d? | 2007-02-05 A | 2008-12-05 A | 100% |  | 2007-02-05 | 2008-12-05 | 480d? |  | finish no earlier than 2009-03-06 | C1 | 3840h | 3840h | SAES | Nokia Siemens Networks | robert.zaus@nsn.com | Rel-8 | 34 | Frederic |  |  |
| 3881 | 1060.2.7 | Stage 3 EPC interworking with external PDNs (SGi) | 605d? | 2007-02-05 A | 2009-05-29 A | 100% |  | 2007-02-05 | 2009-05-29 | 605d? |  | finish no earlier than 2009-05-29 | C3 | 4840h | 4840h | SAES-St3-intwk | Huawei | Wei Weihua (weiwh@huawei.com) | Rel-8 | 34 | Adrian | SAES-St3-intwk |  |
| 3882 | 1060.2.8 | Stage 3 PCC within SAE | 605d? | 2007-02-05 A | 2009-05-29 A | 100% |  | 2007-02-05 | 2009-05-29 | 605d? |  | finish no earlier than 2009-05-29 | C3 | 4840h | 4840h | SAES-St3-PCC | Ericsson | j.javier.pastor@ericsson.com | Rel-8 | 34 | Adrian | SAES-St3-PCC |  |
| 3883 | 1060.2.9 | Stage 3 for SAE / LTE identities | 545d? | 2007-02-05 A | 2009-03-06 A | 100% |  | 2007-02-05 | 2009-03-06 | 545d? |  | finish no earlier than 2009-03-06 | C4 | 4360h | 4360h | SAES | Huawei | shahab.lavasani@huawei.com | Rel-8 | 34 | Kimmo |  |  |
| 3884 | 1060.2.10 | Unified guidelines for Diameter usage within 3GPP | 316d? | 2007-09-21 A | 2008-12-05 A | 100% |  | 2007-09-21 | 2008-12-05 | 316d? |  | finish no earlier than 2008-12-05 | C3 | 2528h | 2528h | SAES-DIAM | Huawei | Javier Gonzalez Gallego | Rel-8 | 37 | Adrian | SAES-DIAM |  |
| 3885 | 1060.3 | **SAE for LTE access** | 569d? | 2007-01-02 A | 2009-03-06 A | 100% |  | 2007-01-02 | 2009-03-06 | 569d? |  |  | S2; C1; C3; C4 | 80584h | 80584h | SAES-LTE | Motorola | Irfan.Ali@motorola.com | Rel-8 | 35 | Maurice | SAES-LTE |  |
| 3886 | 1060.3.1 | CT4 Stage 3 for protocol between EPCs | 545d? | 2007-02-05 A | 2009-03-06 A | 100% |  | 2007-02-05 | 2009-03-06 | 545d? |  | finish no earlier than 2009-03-06 | C4 | 4360h | 4360h | SAES-LTE | Huawei | shahab.lavasani@huawei.com | Rel-8 | 34 | Kimmo |  |  |
| 3887 | 7.2.2.1 | **SAES-SA-FP_LTE with GTP variant** | 569d? | 2007-01-02 A | 2009-03-06 A | 100% |  | 2007-01-02 | 2009-03-06 | 569d? |  |  | S2; C4 | 16448h | 16448h | SAES-SA-FP_LTE-GTP | Nokia Siemens Networks | balazs.bertenyi@nsn.com | Rel-8 | 35 | Maurice | SAES-SA-FP_LTE-GTP |  |
| 3888 | 1060.3.2.1 | Stage 2 for SAES-SA-FP_LTE with GTP variant | 373d? | 2007-01-02 A | 2008-06-05 A | 100% |  | 2007-01-02 | 2008-06-05 | 373d? |  | finish no earlier than 2008-06-02 | S2 | 2984h | 2984h | SAES-SA-FP_LTE-GTP-St2 | Nokia Siemens Networks | balazs.bertenyi@nsn.com | Rel-8 | 37 | Maurice | SAES-SA-FP_LTE-GTP-St2 |  |
| 3889 | 1060.3.2.2 | CT4 Stage 3 for GTP v2 protocol | 545d? | 2007-02-05 A | 2009-03-06 A | 100% |  | 2007-02-05 | 2009-03-06 | 545d? |  | finish no earlier than 2009-03-06 | C4 | 4360h | 4360h | SAES-SA-FP_LTE-GTP | Huawei | shahab.lavasani@huawei.com | Rel-8 | 34 | Kimmo | SAES-SA-FP_LTE-GTP |  |
| 3890 | 7.2.2.2 | **SAES-SA-FP_LTE with PMIP variant** | 569d? | 2007-01-02 A | 2009-03-06 A | 100% |  | 2007-01-02 | 2009-03-06 | 569d? |  |  | S2; C4 | 20288h | 20288h | SAES-SA-FP_LTE-IETF | Nokia Siemens Networks | balazs.bertenyi@nsn.com | Rel-8 | 34 | Maurice | SAES-SA-FP_LTE-IETF |  |
| 3891 | 1060.3.3.1 | Stage 2 for SAES-SA-FP_LTE with PMIP variant | 373d? | 2007-01-02 A | 2008-06-05 A | 100% |  | 2007-01-02 | 2008-06-05 | 373d? |  | finish no earlier than 2008-06-02 | S2 | 2984h | 2984h | SAES-SA-FP_LTE-IETF-St2 | Nokia Siemens Networks | balazs.bertenyi@nsn.com | Rel-8 | 37 | Maurice | SAES-SA-FP_LTE-IETF-St2 |  |
| 3892 | 1060.3.3.2 | CT4 Stage 3 for PMIP protocol within EPC | 545d? | 2007-02-05 A | 2009-03-06 A | 100% |  | 2007-02-05 | 2009-03-06 | 545d? |  | finish no earlier than 2009-03-06 | C4 | 4360h | 4360h | SAES-SA-FP_LTE-IETF | Huawei | shahab.lavasani@huawei.com | Rel-8 | 37 | Kimmo | SAES-SA-FP_LTE-IETF |  |
| 3893 | 1060.3.3.3 | Mobile IPv4 (MIPv4) based Mobility protocols | 480d? | 2007-02-05 A | 2008-12-05 A | 100% |  | 2007-02-05 | 2008-12-05 | 480d? |  | finish no earlier than 2008-12-05 | C4 | 3840h | 3840h | SAES-SA-FP_LTE-IETF | Motorola | Lewis Milton | Rel-8 | 41 | Kimmo |  |  |
| 3894 | 1060.3.4 | Stage 3 for UE Non-Access-Stratum (NAS) mobility procedures in idle and active mode | 545d? | 2007-02-05 A | 2009-03-06 A | 100% |  | 2007-02-05 | 2009-03-06 | 545d? |  | finish no earlier than 2009-03-06 | C1 | 4360h | 4360h | SAES-LTE | Nokia Siemens Networks | robert.zaus@nsn.com | Rel-8 | 34 | Frederic |  |  |
| 3895 | 1060.3.5 | Stage 3 for Session management, bearer control and QoS aspects | 545d? | 2007-02-05 A | 2009-03-06 A | 100% |  | 2007-02-05 | 2009-03-06 | 545d? |  | finish no earlier than 2009-03-06 | C1 | 4360h | 4360h | SAES-LTE | Nokia Siemens Networks | robert.zaus@nsn.com | Rel-8 | 34 | Frederic |  |  |
| 3896 | 1060.3.6 | Stage 3 for security aspects of LTE Access | 545d? | 2007-02-05 A | 2009-03-06 A | 100% |  | 2007-02-05 | 2009-03-06 | 545d? |  | finish no earlier than 2009-03-06 | C1 | 4360h | 4360h | SAES-LTE | Nokia Siemens Networks | robert.zaus@nsn.com | Rel-8 | 34 | Frederic |  |  |
| 3897 | 1060.3.7 | Stage 3 for QoS mechanisms | 480d? | 2007-02-05 A | 2008-12-05 A | 100% |  | 2007-02-05 | 2008-12-05 | 480d? |  | finish no earlier than 2008-12-12 | C3 | 3840h | 3840h | SAES-LTE | Ericsson | j.javier.pastor@ericsson.com | Rel-8 | 34 | Adrian |  |  |
| 3898 | 1060.3.8 | Stage 3 for EPC - HSS interface | 545d? | 2007-02-05 A | 2009-03-06 A | 100% |  | 2007-02-05 | 2009-03-06 | 545d? |  | finish no earlier than 2009-03-06 | C4 | 4360h | 4360h | SAES-LTE | Huawei | shahab.lavasani@huawei.com | Rel-8 | 34 | Kimmo |  |  |

Notes:
- 3872: Role model for SAE/LTE system wide project management by SA2 in SP-060166
- 3873: SP#38 completed / Impacted TSs and TRs: 22.011, 22.246, New 22.278
- 3874: CP#44 completed
- 3875: SP#40 completed / Impacted TSs and TRs: New 23.402
- 3876: SP#42 completed / Impacted TSs and TRs: 33.210, 33.310, New 33.401
- 3877: CP#43 completed / Impacted TSs and TRs: 24.229, 27.007, New 24.305
- 3878: CP#42 completed / Impacted TSs and TRs: 29.061
- 3879: CP#43 completed / Impacted TSs and TRs: New (29.274, 29.275)
- 3880: CP#42 completed / Impacted TSs and TRs: 23.122, New 24.302
- 3881: CP#44 completed / Impacted TSs and TRs: 29.061
- 3882: CP#44 completed / Impacted TSs and TRs: 29.212, 29.213, 29.214, New 29.215
- 3883: CP#43 completed / Impacted TSs and TRs: 23.003
- 3884: CP#42 completed / Impacted TSs and TRs: New 29.909
- 3885: CP#43 completed
- 3886: CP#43 completed / Impacted TSs and TRs: 29.274, 29.275
- 3887: CP#43 completed
- 3888: SP#40 completed / Impacted TSs and TRs: 23.401, 23.060, 23.002, 23.246, 23.203, 23.107, 23.234, 23.271
- 3889: CP#43 completed / Impacted TSs and TRs: 29.274
- 3890: CP#43 completed
- 3891: SP#40 completed
- 3892: CP#43 completed / Impacted TSs and TRs: 29.275, 29.282
- 3893: CP#42 completed / Impacted TSs and TRs: 29.279
- 3894: CP#43 completed / Impacted TSs and TRs: 24.007, 24.301
- 3895: CP#43 completed / Impacted TSs and TRs: 24.007, 24.301
- 3896: CP#43 completed / Impacted TSs and TRs: 24.008, 24.301
- 3897: CP#42 completed / Impacted TSs and TRs: 29.213
- 3898: CP#43 completed / Impacted TSs and TRs: 29.272

| ID | WBS | Task | Type | Duration | Start | Finish | Complete | Baseline start | Baseline finish | Baseline duration | Constraint | Resources | Work | Actual work | Acronym | WI rapporteur name | WI rapporteur e-mail | Release | TSG approved | MCC resp | Acronym_3GU_Export | Impacted TSs and TRs | PCG approved | TSG stopped |
| --- | --- | --- | --- | --- | --- | --- | --- | --- | --- | --- | --- | --- | --- | --- | --- | --- | --- | --- | --- | --- | --- | --- | --- | --- |
| 3899 | 1060.4 | **SAE for Interoperation between LTE and legacy cellular PS accesses** |  | 545d? | 2007-02-05 A | 2009-03-06 A | 100% | 2007-02-05 | 2009-03-06 | 545d? |  | S2; C1; C4 | 48872h | 48872h | SAES-SA-FP_3GPP | Motorola | Irfan.Ali@motorola.com | Rel-8 | 35 | Maurice | SAES-SA-FP_3GPP |  |  |  |
| 3900 | 1060.4.1 | Stage 2 for Interoperation between LTE and 2G/3G |  | 424d? | 2007-02-05 A | 2008-09-18 A | 100% | 2007-02-05 | 2008-09-18 | 424d? | finish no earlier than 2008-09-11 | S2 | 3392h | 3392h | EPSto2_3G | Motorola | Irfan.Ali@motorola.com | Rel-8 | 37 | Maurice | EPSto2_3G | 23.401, 23.402 |  |  |
| 3901 | 1060.4.2 | Stage 3 for Inter-system mobility between E-UTRAN and 2G/3G |  | 545d? | 2007-02-05 A | 2009-03-06 A | 100% | 2007-02-05 | 2009-03-06 | 545d? | finish no earlier than 2009-03-06 | C1 | 4360h | 4360h | SAES-SA-FP_3GPP | Nokia Siemens Networks | robert.zaus@nsn.com | Rel-8 | 38 | Frederic | SAES-SA-FP_3GPP | 24.008, 24.301 | 21 |  |
| 3902 | 1060.4.3 | Stage 2 GPRS enhancements for LTE access |  | 272d? | 2007-09-04 A | 2008-09-18 A | 100% | 2007-09-04 | 2008-09-18 | 272d? | start no earlier than 2007-09-04 | S2 | 2176h | 2176h | SAES-GPRS_LTE | Vodafone | chris.pudney@vodafone.com | Rel-8 | 34 | Maurice | SAES-GPRS_LTE | 23.401 |  |  |
| 3903 | 1060.4.4 | Stage 2 GPRS for EPC (23.060, etc.) |  | 179d? | 2008-01-14 A | 2008-09-18 A | 100% | 2008-01-14 | 2008-09-18 | 179d? | finish no earlier than 2008-09-18 | S2 | 1432h | 1432h | SAES-SA-FP_3GPP | Nokia Siemens Networks | balazs.bertenyi@nsn.com | Rel-8 | 39 | Maurice |  | 23.060 | 21 |  |
| 3904 | 1060.4.5 | Stage 3 for EPC - GPRS |  | 545d? | 2007-02-05 A | 2009-03-06 A | 100% | 2007-02-05 | 2009-03-06 | 545d? | finish no earlier than 2009-03-06 | C4 | 4360h | 4360h | SAES-SA-FP_3GPP | Huawei | shahab.lavasani@huawei.com | Rel-8 | 34 | Kimmo |  | 29.274, 29.275, 29.281 |  |  |
| 3905 | 1060.4.6 | Stage 3 for EPC to UTRAN |  | 545d? | 2007-02-05 A | 2009-03-06 A | 100% | 2007-02-05 | 2009-03-06 | 545d? | finish no earlier than 2009-03-06 | C4 | 4360h | 4360h | SAES-SA-FP_3GPP | Huawei | shahab.lavasani@huawei.com | Rel-8 | 38 | Kimmo |  | 29.274, 29.275, 29.281 | 21 |  |
| 3906 | 1060.4.7 | Stage 3 for EPC to 3GPP2 |  | 545d? | 2007-02-05 A | 2009-03-06 A | 100% | 2007-02-05 | 2009-03-06 | 545d? | finish no earlier than 2009-03-06 | C4 | 4360h | 4360h | SAES-SA-FP_3GPP | Huawei | shahab.lavasani@huawei.com | Rel-8 | 38 | Kimmo |  | 29.277, 29.276 | 21 |  |
| 3907 | 1060.4.8 | Stage 2 for Interoperation between LTE and CDMA2000 |  | 329d? | 2007-06-18 A | 2008-09-18 A | 100% | 2007-06-18 | 2008-09-18 | 329d? | finish no earlier than 2008-04-25 | S2 | 2632h | 2632h | EPStoC2k | Motorola, Vodafone | Irfan.Ali@motorola.com, chris.pudney@vodafone.com | Rel-8 | 37 | Maurice | EPStoC2k | 23.401, 23.402 |  |  |
| 3908 | 1060.4.9 | Stage 3 for Inter-system mobility between E-UTRAN and CDMA2000 |  | 545d? | 2007-02-05 A | 2009-03-06 A | 100% | 2007-02-05 | 2009-03-06 | 545d? | finish no earlier than 2009-03-06 | C1 | 4360h | 4360h | SAES-SA-FP_3GPP | Nokia Siemens Networks | robert.zaus@nsn.com | Rel-8 |  | Frederic |  | 24.301, 24.302 |  |  |
| 3909 | 1060.4.10 | Stage 3 for MME - SGSN signalling free protocol |  | 545d? | 2007-02-05 A | 2009-03-06 A | 100% | 2007-02-05 | 2009-03-06 | 545d? | finish no earlier than 2009-03-06 | C4 | 4360h | 4360h | SAES-SA-FP_3GPP | Huawei | shahab.lavasani@huawei.com | Rel-8 | 34 | Kimmo |  | 29.272, 29.274 |  |  |
| 3910 | 1060.5 | **SAE for support for non-3GPP accesses** |  | 1429d? | 2007-01-02 A | 2012-06-15 A | 100% | 2007-01-02 | 2012-06-15 | 1429d? |  | S2; S3; C1; C4; IETF | 123829h | 123829h | SAES-SA-FP_n3GPP | Motorola | Irfan.Ali@motorola.com | Rel-8 | 35 | Maurice | SAES-SA-FP_n3GPP |  |  |  |
| 3911 | 7.2.4.1 | Stage 2 for Host-based Mobility aspects |  | 373d? | 2007-01-02 A | 2008-06-05 A | 100% | 2007-01-02 | 2008-06-05 | 373d? | finish no earlier than 2008-04-11 | S2 | 2984h | 2984h | SAES-SA-FP_n3GPP-HBMob | Motorola | Irfan.Ali@motorola.com | Rel-8 |  | Maurice | SAES-SA-FP_n3GPP-HBMob | 23.402 |  |  |
| 3912 | 7.2.4.2 | Stage 2 for Network-based Mobility aspects |  | 448d? | 2007-01-02 A | 2008-09-18 A | 100% | 2007-01-02 | 2008-09-18 | 448d? | finish no earlier than 2008-09-18 | S2 | 3584h | 3584h | SAES-SA-FP_n3GPP-NBMob | Motorola | Irfan.Ali@motorola.com | Rel-8 |  | Maurice | SAES-SA-FP_n3GPP-NBMob | 23.402 |  |  |
| 3913 | 1060.5.3 | Stage 3 for Mobility management based on DSMIPv6 |  | 480d? | 2007-02-05 A | 2008-12-05 A | 100% | 2007-02-05 | 2008-12-05 | 480d? | finish no earlier than 2008-12-05 | C1 | 3840h | 3840h | SAES-SA-FP_n3GPP | Nokia Siemens Networks | robert.zaus@nsn.com | Rel-8 |  | Frederic |  | 24.303 |  |  |
| 3914 | 1060.5.4 | (IETF) Stage 3 for Mobility management based on DSMIPv6 (draft-ietf-mip6-hiopt) |  | 589d? | 2007-02-05 A | 2012-06-15 A | 100% | 2007-02-05 | 2012-06-15 | 589d? | finish no earlier than 2012-09-14 | C1-IETF | 4712h | 4712h | SAES-SA-FP_n3GPP | Mark Jones |  | Rel-8 | 52 | Frederic |  | RFC 6610 (was draft-ietf-mip6-hiopt) | 27 |  |
| 3915 | 1060.5.5 | (IETF) Stage 3 for Mobility management based on DSMIPv6 (RFC6275) |  | 356d? | 2007-02-05 A | 2011-07-29 A | 100% | 2007-02-05 | 2011-07-29 | 356d? | finish no earlier than 2011-07-29 | C1-IETF | 2848h | 2848h | SAES-SA-FP_n3GPP |  |  | Rel-8 | 52 | Frederic |  | RFC 6275 (was draft-ietf-mext-rfc3775bis) | 27 |  |
| 3916 | 1060.5.6 | Stage 3 for Mobility management based on MIP v4 |  | 480d? | 2007-02-05 A | 2008-12-05 A | 100% | 2007-02-05 | 2008-12-05 | 480d? | start no earlier than 2007-02-05 | C1 | 3840h | 3840h | SAES-SA-FP_n3GPP | Nokia Siemens Networks | robert.zaus@nsn.com | Rel-8 | 39 | Frederic |  | 24.304 | 21 |  |
| 3917 | 1060.5.7 | Stage 3 for Inter-system mobility between E-UTRAN and non 3GPP accesses |  | 545d? | 2007-02-05 A | 2009-03-06 A | 100% | 2007-02-05 | 2009-03-06 | 545d? | finish no earlier than 2009-03-06 | C1 | 4360h | 4360h | SAES-SA-FP_n3GPP | Nokia Siemens Networks | robert.zaus@nsn.com | Rel-8 | 38 | Frederic |  | 24.008, 24.301 | 21 |  |
| 3918 | 1060.5.8 | Stage 2 for Optimized Dual-Radio Handover with WiMAX |  | 249d? | 2007-06-25 A | 2008-06-05 A | 100% | 2007-06-25 | 2008-06-05 | 249d? | finish no earlier than 2008-06-09 | S2 | 1992h | 1992h | SAES-SA-FP_n3GPP-OptWIMAX | Motorola | Irfan.Ali@motorola.com | Rel-8 |  | Maurice | SAES-SA-FP_n3GPP-OptWIMAX | 23.402 |  |  |
| 3919 | 1060.5.9 | Stage 2 Security aspects for non-3GPP Access |  | 197d? | 2008-03-12 A | 2008-12-11 A | 100% | 2008-03-12 | 2008-12-11 | 197d? | finish no earlier than 2008-12-11 | S3 | 1576h | 1576h | SAES-SA-FP_n3GPP | Nokia Siemens Networks | marc.blommaert.ext@nsn.com | Rel-8 | 39 | Mirko |  | 33.402, 33.210, 33.310 | 21 |  |
| 3920 | 1060.5.10 | Stage 3 security aspects for DSMIPv6 Access |  | 480d? | 2007-02-05 A | 2008-12-05 A | 100% | 2007-02-05 | 2008-12-05 | 480d? | finish no earlier than 2008-12-05 | C1 | 3840h | 3840h | SAES-SA-FP_n3GPP | Nokia Siemens Networks | robert.zaus@nsn.com | Rel-8 | 37 | Frederic |  | 24.303 |  |  |
| 3921 | 1060.5.11 | Stage 3 security aspects for MIPv4 Access |  | 480d? | 2007-02-05 A | 2008-12-05 A | 100% | 2007-02-05 | 2008-12-05 | 480d? | finish no earlier than 2008-12-05 | C1 | 3840h | 3840h | SAES-SA-FP_n3GPP | Nokia Siemens Networks | robert.zaus@nsn.com | Rel-8 | 39 | Frederic |  | 24.304 | 21 |  |
| 3922 | 1060.5.12 | Stage 3 for Access to the EPC via non-3GPP access networks |  | 545d? | 2007-02-05 A | 2009-03-06 A | 100% | 2007-02-05 | 2009-03-06 | 545d? | finish no earlier than 2009-03-06 | C1 | 4360h | 4360h | SAES-SA-FP_n3GPP | Nokia Siemens Networks | robert.zaus@nsn.com | Rel-8 |  | Frederic |  | 24.302, 24.312 |  |  |
| 3923 | 1060.5.13 | Stage 3 for interfaces within EPC |  | 383d? | 2007-09-19 A | 2009-03-06 A | 100% | 2007-09-19 | 2009-03-06 | 383d? | finish no earlier than 2009-03-06 | C4 | 3064h | 3064h | SAES-SA-FP_n3GPP | Huawei | shahab.lavasani@huawei.com | Rel-8 | 37 | Kimmo |  | 29.274, 29.281 |  |  |
| 3924 | 1060.5.14 | Stage 3 for Interfaces EPC - non-3GPP IP access |  | 545d? | 2007-02-05 A | 2009-03-06 A | 100% | 2007-02-05 | 2009-03-06 | 545d? | finish no earlier than 2009-03-06 | C4 | 4360h | 4360h | SAES-SA-FP_n3GPP | Huawei | shahab.lavasani@huawei.com | Rel-8 | 34 | Kimmo |  | 29.273, 29.275 |  |  |
| 3925 | 1060.5.15 | (IETF) Stage 3 for Interfaces EPC - non-3GPP IP access |  | 1224.6d? | 2007-02-05 A | 2012-06-15 A | 100% | 2007-02-05 | 2012-06-15 | 1224.6d? | finish no earlier than 2012-06-15 | C4-IETF | 9788.8h | 9788.8h | SAES-SA-FP_n3GPP | Lionel Morand |  | Rel-8 | 52 | Kimmo |  | RFC 6611 (was draft-ietf-mip6-bootstrapping-integrated) | 27 |  |
| 3926 | 1060.5.16 | Stage 3 for AAA/HSS related |  | 480d? | 2007-02-05 A | 2008-12-05 A | 100% | 2007-02-05 | 2008-12-05 | 480d? | finish no earlier than 2008-12-05 | C4 | 3840h | 3840h | SAES-SA-FP_n3GPP | Huawei | shahab.lavasani@huawei.com | Rel-8 | 34 | Kimmo |  | 29.273 |  |  |
| 3927 | 1060.5.17 | Stage 3 for EPC - AAA interface |  | 480d? | 2007-02-05 A | 2008-12-05 A | 100% | 2007-02-05 | 2008-12-05 | 480d? | finish no earlier than 2008-12-05 | C4 | 3840h | 3840h | SAES-SA-FP_n3GPP | Huawei | shahab.lavasani@huawei.com | Rel-8 | 34 | Kimmo |  | 29.273 |  |  |
| 3928 | 1060.5.18 | Deleted (already covered) SAES-SA-FP_n3GPP Optimized Handover with CDMA | milestone | 0d? | 2007-06-25 A | 2007-06-25 A | 100% | 2007-06-25 | 2007-06-25 | 0d? | finish no earlier than 2007-06-25 | S2 |  |  | SAES-SA-FP_n3GPP-OptCDMA | Nokia Siemens Networks |  | Rel-8 |  | Maurice | SAES-SA-FP_n3GPP-OptCDMA |  |  | SP-37 |

Notes:
- 3899: CP#43 completed
- 3900: SP#41 completed
- 3901: CP#43 completed
- 3902: SP#41 completed
- 3903: SP#41 completed
- 3904: CP#43 completed
- 3905: CP#43 completed
- 3906: CP#43 completed
- 3907: SP#41 completed (except: Handover of multiple PDNs=>Rel-9)
- 3908: CP#43 completed
- 3909: CP#43 completed
- 3910: CP#43 completed. SP#39 retained in Rel-8 (in addition to the essential functionality defined in SP-070699). Replaces UID_340037
- 3911: SP#40 completed
- 3912: SP#41 completed
- 3913: CP#42 completed
- 3914: CP#56 completed
- 3915: SP#53/IETF#81 completed
- 3916: CP#42 completed
- 3917: CP#43 completed
- 3918: SP#40 completed
- 3919: SP#42 completed
- 3920: CP#42 completed
- 3921: CP#42 completed
- 3922: CP#43 completed
- 3923: CP#43 completed
- 3924: CP#43 completed
- 3925: CP#56 completed
- 3926: CP#42 completed
- 3927: CP#42 completed
- 3928: SP#37 stopped

| ID | WBS | Task | Type | Duration | Start | Finish | Complete | Baseline start | Baseline finish | Baseline duration | Constraint | Resources | Work | Actual work | Acronym | WI rapporteur name | Release | MCC resp | Acronym_3GU_Export | Impacted TSs and TRs | PCG approved | TSG approved | PCG stopped | TSG stopped | Special Focus Doc |
| --- | --- | --- | --- | --- | --- | --- | --- | --- | --- | --- | --- | --- | --- | --- | --- | --- | --- | --- | --- | --- | --- | --- | --- | --- | --- |
| 3929 | 1060.6 | **Single Radio Voice Call Continuity for 3GPP (SRVCC)** |  | 569d? | 2007-01-02 A | 2009-03-06 A | 100% | 2007-01-02 | 2009-03-06 | 569d? |  | S2; C1; C4 | 19856h | 19856h | SAES-SRVCC | Nokia Siemens Networks | Rel-8 | Maurice | SAES-SRVCC |  |  |  |  |  |  |
| 3930 | 1060.6.1 | Stage 2 for 2G/3G SRVCC |  | 448d? | 2007-01-02 A | 2008-09-18 A | 100% | 2007-01-02 | 2008-09-18 | 448d? | finish no earlier than 2008-09-15 | S2 | 3584h | 3584h | SAES-SRVCC | Nokia Siemens Networks | Rel-8 | Maurice |  | New 23.216 |  |  |  |  |  |
| 3931 | 1060.6.2 | Stage 3 for SRVCC in EPS |  | 201d? | 2008-05-30 A | 2009-03-06 A | 100% | 2008-05-30 | 2009-03-06 | 201d? | finish no earlier than 2009-03-06 | C1 | 1608h | 1608h | SAES-SRVCC | Nokia Siemens Networks | Rel-8 | Frederic |  | 23.009, 24.008, New 24.301 | 21 | 41 |  |  |  |
| 3932 | 1060.6.3 | MME to MSC interface for SRVCC |  | 126d? | 2008-09-12 A | 2009-03-06 A | 100% | 2008-09-12 | 2009-03-06 | 126d? | finish no earlier than 2009-03-06 | C4 | 1008h | 1008h | SAES-SRVCC | Nokia Siemens Networks | Rel-8 | Kimmo |  | 23.003, 23.008, New (29.274, 29.277, 29.280) | 21 | 41 |  |  |  |
| 3933 | 1060.7 | Voice Call Continuity for CDMA2000 1X |  | 249d? | 2007-06-25 A | 2008-06-05 A | 100% | 2007-06-25 | 2008-06-05 | 249d? | finish no earlier than 2008-06-13 | S2 | 1992h | 1992h | SAES-VCC_1X | Nokia Siemens Networks | Rel-8 | Maurice | SAES-VCC_1X |  |  |  |  |  |  |
| 3934 | 1060.8 | SAE impacts on IMS |  | 373d? | 2007-01-02 A | 2008-06-05 A | 100% | 2007-01-02 | 2008-06-05 | 373d? | finish no earlier than 2008-06-13 | S2 | 2984h | 2984h | SAES-SA_IMS | Nokia Siemens Networks | Rel-8 | Maurice | SAES-SA_IMS |  |  |  |  |  |  |
| 3935 | 1060.9 | **CS Fallback in EPS** |  | 258d? | 2008-03-12 A | 2009-03-06 A | 100% | 2008-03-12 | 2009-03-06 | 258d? |  | S2; C1; C4 | 9384h | 9384h | SAES-CSFB | T-Mobile, Vodafone | Rel-8 | Maurice | SAES-CSFB |  | 21 | 39 |  |  |  |
| 3936 | 1060.9.1 | Stage 2 for CS Fallback in EPS |  | 62d? | 2008-03-12 A | 2008-06-05 A | 100% | 2008-03-12 | 2008-06-05 | 62d? | finish no earlier than 2008-12-05 | S2 | 496h | 496h | SAES-CSFB | T-Mobile, Vodafone | Rel-8 | Maurice |  | New (23.272, 23.401) | 21 | 40 |  |  |  |
| 3937 | 1060.9.2 | CT1 part of Stage 3 for CS Fallback in EPS |  | 201d? | 2008-05-30 A | 2009-03-06 A | 100% | 2008-05-30 | 2009-03-06 | 201d? | finish no earlier than 2009-03-06 | C1 | 1608h | 1608h | SAES-CSFB | NEC | Rel-8 | Frederic |  | 24.007, 24.008, 24.011, 29.018, New (24.301, 24.801, 29.118) | 21 | 40 |  |  |  |
| 3938 | 1060.9.3 | CT4 part of Stage 3 for CS Fallback in EPS |  | 136d? | 2008-05-30 A | 2008-12-05 A | 100% | 2008-05-30 | 2008-12-05 | 136d? | finish no earlier than 2008-12-05 | C4 | 1088h | 1088h | SAES-CSFB | NEC | Rel-8 | Kimmo |  | 23.007, 23.008, 29.274, New 29.277 | 21 | 40 |  |  |  |
| 3939 | 1060.10 | System enhancements for the use of IMS services in local breakout |  | 62d? | 2008-03-12 A | 2008-06-05 A | 100% | 2008-03-12 | 2008-06-05 | 62d? | finish no earlier than 2008-06-05 | S2 | 496h | 496h | SAES-IMS_LBO | Telecom Italia | Rel-8 | Maurice | SAES-IMS_LBO | 23.228, 23.221, 23.203 | 21 | 39 |  |  |  |
| 3940 | 1060.11 | **EPC Data Definitions** |  | 309d? | 2008-01-07 A | 2009-03-12 A | 100% | 2008-01-07 | 2009-03-12 | 309d? |  | S5 | 7144h | 7144h | EPC-OAM |  | Rel-8 | Mirko | EPC-OAM |  | 21 | 39 |  |  |  |
| 3941 | 1060.11.1 | EPC Network Resource Model (NRM) Integration Reference Point (IRP) |  | 309d? | 2008-01-07 A | 2009-03-12 A | 100% | 2008-01-07 | 2009-03-12 | 309d? | finish no earlier than 2009-03-12 | S5 | 2472h | 2472h | EPC-OAM | Huawei | Rel-8 | Mirko |  | New (32.751, 32.752, 32.753, 32.755) | 21 | 38 |  |  |  |
| 3942 | 1060.11.2 | Performance measurements for EPC |  | 275d? | 2008-02-22 A | 2009-03-12 A | 100% | 2008-02-22 | 2009-03-12 | 275d? | finish no earlier than 2009-03-12 | S5 | 2200h | 2200h | EPC-OAM | China Mobile | Rel-8 | Mirko |  | New 32.426 | 21 | 39 |  |  |  |
| 3943 | 1060.12 | EPC Charging |  | 309d? | 2008-01-07 A | 2009-03-12 A | 100% | 2008-01-07 | 2009-03-12 | 309d? | finish no earlier than 2009-03-12 | S5 | 2472h | 2472h | EPC-CH | Nokia Siemens Networks | Rel-8 | Mirko | EPC-CH | 32.240, 32.296, 32.251, 32.252, 32.298, 32.299 | 21 | 38 |  |  |  |
| 3944 | 1060.13 | Domain Name System Procedures for Evolved Packet System (DEPS) |  | 179.75d? | 2008-05-30 A | 2009-03-06 A | 100% | 2008-05-30 | 2009-03-06 | 179.75d? | finish no earlier than 2009-03-06 | C4 | 1438h | 1438h | SAES-DEPS | TeliaSonera | Rel-8 | Kimmo | SAES-DEPS | 23.003, New 29.303 | 21 | 40 |  |  |  |
| 3945 | 1060.14 | InterWorking Function (IWF) between MAP based and Diameter based interfaces |  | 126d? | 2008-09-12 A | 2009-03-06 A | 100% | 2008-09-12 | 2009-03-06 | 126d? | finish no earlier than 2009-03-06 | C4 | 1008h | 1008h | SAES-MAP2Diam | Huawei | Rel-8 | Kimmo | SAES-MAP2Diam | New 29.305 | 21 | 41 |  |  |  |
| 3946 | 1060.15 | **CT6 aspects of SAE** |  | 847d? | 2008-03-07 A | 2011-06-03 A | 100% | 2008-03-07 | 2011-06-03 | 847d? |  | C6 | 13480h | 13480h | SAES | Nokia | Rel-8 | Xavier |  |  | 21 | 39 |  |  |  |
| 3947 | 1060.15.1 | Core specification for CT6 aspects of SAE |  | 321d? | 2008-03-07 A | 2009-05-29 A | 100% | 2008-03-07 | 2009-05-29 | 321d? | finish no earlier than 2009-05-29 | C6 | 2568h | 2568h | SAES | Nokia | Rel-8 | Xavier |  | 31.102, 31.111 | 21 | 39 |  |  |  |
| 3948 | 1060.15.2 | Test interworking of LTE Terminals with the USIM |  | 526d? | 2008-12-05 A | 2010-12-10 A | 100% | 2008-12-05 | 2010-12-10 | 526d? | finish no earlier than 2010-12-10 | C6 | 4208h | 4208h | SAES-USIM_LTE-Test | Comprion | Rel-8 | Xavier | SAES-USIM_LTE-Test | 31.121, 31.124 | 22 | 42 |  |  |  |
| 3949 | 1060.15.3 | Test interworking of IP Multimedia Services Identity Module (ISIM) terminals with IP Multimedia Subsystem (IMS) |  | 186d? | 2010-09-17 A | 2011-06-03 A | 100% | 2010-09-17 | 2011-06-03 | 186d? | finish no earlier than 2011-06-03 | C6 | 1488h | 1488h | SAES-ISIM_IMS_Test | Comprion | Rel-8 | Xavier | SAES-ISIM_IMS_Test | 31.121, 31.124, New TS 31.134 | 25 | 49 |  |  |  |
| 3950 | 1060.16 | Issues for CT1 TR 24.801 |  | 420d? | 2007-01-04 A | 2008-12-05 A | 100% | 2007-01-04 | 2008-12-05 | 420d? | finish no earlier than 2008-12-05 | C1 | 3360h | 3360h | SAES | Nokia Siemens Networks | Rel-8 | Frederic |  | 24.801 | 21 | 39 |  |  |  |
| 3951 | 1060.17 | Issues for CT3 TR 29.804 |  | 420d? | 2007-02-05 A | 2008-09-12 A | 100% | 2007-02-05 | 2008-09-12 | 420d? | finish no earlier than 2008-12-12 | C3 | 3360h | 3360h | SAES | Ericsson | Rel-8 | Adrian |  | 29.804 | 21 | 39 |  |  |  |
| 3952 | 1060.18 | Deleted - Issues for CT4 TR 29.803 |  | 420d? | 2007-01-04 A | 2008-09-12 A | 100% | 2007-01-04 | 2008-09-12 | 420d? | finish no earlier than 2008-12-11 | C4 | 3360h | 3360h | SAES | Huawei | Rel-8 | Kimmo |  | 29.803 | 21 | 39 | PCG-21 | CP-41 |  |
| 3953 | 1060.19 | Deleted (covered by 380068): Functions and procedures for SAE to support LCS | milestone | 0d? | 2008-03-03 A | 2008-03-03 A | 100% | 2008-03-03 | 2008-03-03 | 0d? | finish no earlier than 2008-03-03 | S2 |  |  | SAES-SA-FP_LCS | Nokia Siemens Networks | Rel-8 | Maurice | SAES-SA-FP_LCS |  |  |  |  | SP-37 |  |
| 3954 | 1060.20 | Deleted (covered by 380064): SAE aspects of Emergency Calls | milestone | 0d? | 2008-03-03 A | 2008-03-03 A | 100% | 2008-03-03 | 2008-03-03 | 0d? | start no earlier than 2008-03-03 | S2 |  |  | SAES-SA-EmCall | Nokia Siemens Networks | Rel-8 | Maurice | SAES-SA-EmCall |  |  |  |  | SP-37 | Public Safety (I-A) |

Notes:
- 3929: CP#43 completed. SP#38 WID approved (extract from SAE WID SP-070817). / WI rapporteur e-mail: curt.c.wong@nokia.com
- 3930: SP#41 completed. SP#38 WID approved / WI rapporteur e-mail: curt.c.wong@nokia.com
- 3931: CP#43 completed / WI rapporteur e-mail: robert.zaus@nsn.com
- 3932: CP#43 completed / WI rapporteur e-mail: Giorgi Gulbani
- 3933: SP#40 completed / WI rapporteur e-mail: balazs.bertenyi@nsn.com
- 3934: SP#40 completed / WI rapporteur e-mail: balazs.bertenyi@nsn.com
- 3935: CP#43 completed / WI rapporteur e-mail: sabine.demel@t-mobile.at, chris.pudney@vodafone.com
- 3936: SP#40 completed / WI rapporteur e-mail: sabine.demel@t-mobile.at, chris.pudney@vodafone.com
- 3937: CP#43 completed / WI rapporteur e-mail: yannick.lair@nectech.fr
- 3938: CP#42 completed / WI rapporteur e-mail: yannick.lair@nectech.fr
- 3939: SP#40 completed / WI rapporteur e-mail: mario.madella@telecomitalia.it
- 3940: SP#43 completed
- 3941: SP#43 completed / WI rapporteur e-mail: WANG, Xuelong
- 3942: SP#43 completed / WI rapporteur e-mail: Li Jian (lijian@chinamobile.com), Liang Shuangchun (liangshuangchun@cmdi.chinamobile.com)
- 3943: SP#43 completed / WI rapporteur e-mail: Gerald.Goermer@nsn.com
- 3944: CP#43 completed / WI rapporteur e-mail: jouni.korhonen@teliasonera.com
- 3945: CP#43 completed. Triggered by UID_380023 (FS_MAP2Diam) / WI rapporteur e-mail: liming49985@huawei.com
- 3946: CP#44 completed core specification / WI rapporteur e-mail: Rune Lindholm
- 3947: CP#44 completed (specified Network Measurement Results collection via USAT) / WI rapporteur e-mail: Rune Lindholm
- 3948: CP#50 completed. Steering of Roaming test cases have been introduced. Remaining issues CSG display testing (Provide Local Information, Call Control for EPS/PDN, Event Download (Access Technology Change - Multiple Access Technologies) / WI rapporteur e-mail: Udo Willenbrink (uwillenbrink@comprion.com )
- 3949: CP#52 completed. Linked to R5 UID_1273 Provisioning of IP-based multimedia services (24.229, 31.103), R8 UID_390021 CT6 aspects of SAE, UID_420018 Test interworking of LTE Terminals with the USIM, R UID_450018 Testing SMS over IMS in E-UTRAN (34.229). / WI rapporteur e-mail: Udo Willenbrink (uwillenbrink@comprion.com )
- 3950: CP#43 completed / WI rapporteur e-mail: robert.zaus@nsn.com
- 3951: CP#41 completed / WI rapporteur e-mail: j.javier.pastor@ericsson.com
- 3952: CP#41 Work stopped and continued in Normative specifications
- 3953: SP#37 stopped
- 3954: SP#37 stopped

| ID | WBS | Task | Type | Duration | Start | Finish | Complete | Remaining | Baseline start | Baseline finish | Baseline duration | Total slack | Constraint | Resources | Work | Actual work | Acronym | Release | TSG approved | MCC resp | TSG stopped | Acronym_3GU_Export | WI rapporteur name | WI rapporteur e-mail | PCG approved | Status Report | PCG stopped |
| --- | --- | --- | --- | --- | --- | --- | --- | --- | --- | --- | --- | --- | --- | --- | --- | --- | --- | --- | --- | --- | --- | --- | --- | --- | --- | --- | --- |
| 3955 | 1060.21 | **Deleted - CT aspects of SAES** |  | 138d? | 2007-09-04 A | 2008-03-14 | 100% | 0d? | 2007-09-04 | 2008-03-14 | 138d? | 0d |  | C3; C1; C4 | 3312h | 1104h | SAES-St3 | Rel-8 | 34 | Frederic | SP-37 | SAES-St3 |  |  |  |  |  |
| 3956 | 1060.21.1 | Deleted - CT1 aspects of SAES | milestone | 0d? | 2007-09-04 A | 2007-09-04 A | 100% |  | 2007-09-04 | 2007-09-04 | 0d? |  | start no earlier than 2007-09-04 | C1 |  |  | SAES-St3 | Rel-8 |  | Frederic | SP-37 |  |  |  |  |  |  |
| 3957 | 1060.21.2 | Deleted - Interoperability | milestone | 0d? | 2008-03-14 A | 2008-03-14 A | 100% |  | 2008-03-14 | 2008-03-14 | 0d? |  | start no earlier than 2008-03-14 | C1 |  |  | SAES-St3-interop | Rel-8 | 34 | Frederic | SP-37 | SAES-St3-interop |  |  |  |  |  |
| 3958 | 1060.21.3 | Deleted - CT3 aspects of SAES | milestone | 0d? | 2007-09-04 A | 2007-09-04 A | 100% |  | 2007-09-04 | 2007-09-04 | 0d? |  | start no earlier than 2007-09-04 | C3 |  |  | SAES | Rel-8 |  | Adrian | SP-37 |  |  |  |  |  |  |
| 3959 | 1060.21.4 | Deleted - CT4 aspects of SAES | milestone | 0d? | 2007-09-04 A | 2007-09-04 A | 100% |  | 2007-09-04 | 2007-09-04 | 0d? |  | start no earlier than 2007-09-04 | C4 |  |  | SAES | Rel-8 |  | Kimmo | SP-37 |  |  |  |  |  |  |
| 3960 | 1060.21.5 | Deleted - UE to EPC NAS signalling (incl. MBMS and QoS aspects) | milestone | 0d? | 2008-03-14 A | 2008-03-14 A | 100% |  | 2008-03-14 | 2008-03-14 | 0d? |  | start no earlier than 2008-03-14 | C1 |  |  | SAES-St3-sig | Rel-8 | 34 | Frederic | SP-37 | SAES-St3-sig |  |  |  |  |  |
| 3961 | 1060.21.6 | Deleted - User and Control plane protocols | milestone | 0d? | 2007-09-21 A | 2007-09-21 A | 100% |  | 2007-09-21 | 2007-09-21 | 0d? |  | start no earlier than 2007-09-21 | C4 |  |  | SAES-St3-prot | Rel-8 | 34 | Kimmo | SP-37 | SAES-St3-prot |  |  |  |  |  |
| 3962 | 1060.22 | Deleted - Architecture enhancements for non-3GPP accesses | milestone | 0d? | 2007-09-04 A | 2007-09-04 A | 100% |  | 2007-09-04 | 2007-09-04 | 0d? |  | start no earlier than 2007-09-04 | S2 |  |  | SAES-non_3GPP | Rel-8 | 34 | Maurice | SP-34 | SAES-non_3GPP | Motorola | Irfan.Ali@motorola.com |  |  |  |
| 3963 | 1060.23 | Deleted - Stage 2 of architecture for the 3GPP System Architecture Evolution | milestone | 0d? | 2007-10-02 A | 2007-10-02 A | 100% |  | 2007-10-02 | 2007-10-02 | 0d? |  | start no earlier than 2007-10-02 | S2 |  |  | SAES-St2 | Rel-8 |  | Maurice | SP-34 | SAES-St2 | Vodafone | chris.pudney@vodafone.com |  |  |  |
| 3964 | 1060.24 | Deleted - SA aspects of System Architecture Evolution |  | 384d? | 2006-04-12 A | 2007-10-01 A | 100% |  | 2006-04-12 | 2007-10-01 | 384d? |  | finish no earlier than 2007-10-02 | S2 | 3072h | 3072h | SAES-SA | Rel-8 |  | Maurice | SP-34 | SAES-SA |  |  |  |  |  |
| 3965 | 1061 | Conformance Test Aspects – Mobility management based on DSMIPv6 (Dual-Stack Mobile IPv6) |  | 261d? | 2009-09-18 A | 2010-09-17 A | 100% |  | 2009-09-18 | 2010-09-17 | 261d? |  | finish no earlier than 2010-09-17 | R5 | 2088h | 2088h | DSMIPv6_UEConTest | Rel-8 | 45 | Ingbert |  | DSMIPv6_UEConTest | Qualcomm | Lena Chaponniere (lchaponn@qualcomm.com) | 23 | RP-100738 |  |
| 3966 | 1062 | **IMS Centralized Service control** |  | 2392.1d? | 2005-11-01 A | 2014-12-09 A | 100% |  | 2005-11-01 | 2014-12-05 | 2387.1d? |  |  | S1; S2; C1; C3; C4; IETF | 239598h | 239598h | ICSRA | Rel-8 | 37 | Alain |  | ICSRA | AT&T | Randolph Wohlert (rwohlert@tri.sbc.com) |  |  |  |
| 3967 | 1062.1 | Stage 1 for ICS Requirement and Architecture |  | 138d? | 2007-09-03 A | 2008-03-12 A | 100% |  | 2007-09-03 | 2008-03-12 | 138d? |  | finish no earlier than 2007-12-14 | S1 | 1104h | 1104h | ICSRA | Rel-8 | 38 | Alain |  |  | AT&T | Randolph Wohlert (rwohlert@tri.sbc.com) | 21 |  |  |
| 3968 | 1062.2 | Stage 2 for ICS Requirement and Architecture |  | 125d? | 2007-12-14 A | 2008-06-05 A | 100% |  | 2007-12-14 | 2008-06-05 | 125d? |  | start no earlier than 2007-12-14 | S2 | 1000h | 1000h | ICSRA-St2 | Rel-8 | 38 | Maurice |  | ICSRA-St2 | Alcatel-Lucent |  | 21 |  |  |
| 3969 | 1062.3 | **Stage 3 for ICSRA – Protocol, Addressing, Subscriber Data** |  | 2392.1d? | 2005-11-01 A | 2014-12-09 A | 100% |  | 2005-11-01 | 2014-12-05 | 2387.1d? |  |  | C1; C3; C4; IETF | 122674h | 122674h | ICSRA | Rel-8 |  | Frederic |  |  | Ericsson | sean.schneyer@ericsson.com |  |  |  |
| 3970 | 1062.3.1 | CT1 aspects - Stage 3 for ICSRA |  | 201d? | 2008-05-30 A | 2009-03-06 A | 100% |  | 2008-05-30 | 2009-03-06 | 201d? |  | finish no earlier than 2009-03-06 | C1 | 1608h | 1608h | ICSRA | Rel-8 | 40 | Frederic |  |  | Ericsson | Sean Schneyer | 21 |  |  |
| 3971 | 1062.3.2 | (IETF) CT1 aspects - Stage 3 for ICSRA (draft-ietf-salud-alert-info-urns) |  | 1244d? | 2008-05-30 A | 2014-12-09 A | 100% |  | 2008-05-30 | 2014-12-05 | 1242d? |  | finish no earlier than 2014-12-09 | C1-IETF | 9952h | 9952h | ICSRA | Rel-8 | 52 | Frederic |  |  | Roland Jesske | Roland Jesske | 27 |  |  |
| 3972 | 1062.3.3 | (IETF) CT1 aspects - Stage 3 for ICSRA (RFC 6871) |  | 779d? | 2008-05-30 A | 2013-03-01 A | 100% |  | 2008-05-30 | 2013-03-01 | 779d? |  | finish no earlier than 2013-02-28 | C1-IETF | 6232h | 6232h | ICSRA | Rel-8 | 52 | Frederic |  |  | Andrew Allen |  | 27 |  |  |
| 3973 | 1062.3.4 | (IETF) CT1 aspects - Stage 3 for ICSRA (RFC 7195) |  | 1117d? | 2008-05-30 A | 2014-06-13 A | 100% |  | 2008-05-30 | 2014-06-13 | 1117d? |  | finish no earlier than 2014-06-13 | C1-IETF | 8936h | 8936h | ICSRA | Rel-8 | 52 | Frederic |  |  | Andrew Allen |  | 27 |  |  |
| 3974 | 1062.3.5 | (IETF) CT1 aspects - Stage 3 for ICSRA (RFC 7006) |  | 977d? | 2008-06-03 A | 2013-12-06 A | 100% |  | 2008-06-03 | 2013-12-06 | 977d? |  | finish no earlier than 2013-12-06 | C1-IETF | 7816h | 7816h | ICSRA | Rel-8 | 52 | Frederic |  |  | Andrew Allen |  | 27 |  |  |
| 3975 | 1062.3.6 | CT3 aspects - Stage 3 for ICSRA |  | 201d? | 2008-05-30 A | 2009-03-06 A | 100% |  | 2008-05-30 | 2009-03-06 | 201d? |  | finish no earlier than 2009-03-06 | C3 | 1608h | 1608h | ICSRA | Rel-8 | 40 | Adrian |  |  | Mavenir | Brett Wallis ( brett@mavenir.com) | 21 |  |  |
| 3976 | 1062.3.7 | CT4 aspects - Stage 3 for ICSRA |  | 136d? | 2008-05-30 A | 2008-12-05 A | 100% |  | 2008-05-30 | 2008-12-05 | 136d? |  | start no earlier than 2008-05-30 | C4 | 1088h | 1088h | ICSRA | Rel-8 | 40 | Kimmo |  |  | Ericsson | Sean Schneyer | 21 |  |  |
| 3977 | 1062.3.8 | (IETF) CT4 aspects - Stage 3 for ICSRA (RFC 7254) |  | 1034.8d? | 2005-11-01 A | 2014-06-13 A | 100% |  | 2005-11-01 | 2014-06-13 | 1034.8d? |  | finish no earlier than 2014-06-13 | C4-IETF | 8278.4h | 8278.4h | ICSRA | Rel-8 | 52 | Kimmo |  |  | Andrew Allen |  | 27 |  |  |
| 3978 | 1062.3.9 | Deleted - Stage 3 for ICSRA – I1 interface |  | 76d? | 2008-05-30 A | 2008-09-12 A | 100% |  | 2008-05-30 | 2008-09-12 | 76d? |  | finish no earlier than 2008-09-12 | C1 | 608h | 608h | ICSRA | Rel-8 | 40 | Frederic | CP-41 |  | Huawei | xupeili@huawei.com | 21 |  | PCG-21 |

Notes:
- 3955: SP#37 stopped
- 3956: SP#37 stopped
- 3957: SP#37 stopped
- 3958: SP#37 stopped
- 3959: SP#37 stopped / Impacted TSs and TRs: 29.803
- 3960: SP#37 stopped
- 3961: SP#37 stopped
- 3962: SP#34 stopped. Replaced by UID_350027 and its children / Impacted TSs and TRs: 23.402
- 3963: SP#34 stopped. Replaced by UIDs 340018 and 340037. (SP#34 report discussion of SP-060917.) / Impacted TSs and TRs: 23.002, 23.060, 23.107, 23.203, 23.228, 23.234, 23.246, 23.271, 23.279
- 3964: SP#34 stopped
- 3965: RP#49 completed. Testing for CT1's UID_360022 (24.303) under Rel-8 Feature SAES / Impacted TSs and TRs: 36.508, 36.523-1, 36.523-2, 36.523-3
- 3966: CP#46 completed
- 3967: SP#39 completed / Impacted TSs and TRs: 22.101
- 3968: SP#40 completed / Impacted TSs and TRs: 23.292, 23.206
- 3969: CP#46 completed
- 3970: CP#46 completed / Impacted TSs and TRs: 24.229, new (24.292, 24.286)
- 3971: In RFC Editors Queue. Dec.14: 75->90; 7/3/16: 90%->100 / Impacted TSs and TRs: draft-ietf-salud-alert-info-urns
- 3972: CP#59 completed / Impacted TSs and TRs: RFC 6871 (was draft-ietf-mmusic-sdp-media-capabilities)
- 3973: CP#64 complete / Impacted TSs and TRs: RFC 7195 (was draft-ietf-mmusic-sdp-cs)
- 3974: CP#62 completed / Impacted TSs and TRs: RFC7006 (was draft-ietf-mmusic-sdp-miscellaneous-caps)
- 3975: CP#43 completed / Impacted TSs and TRs: new 29.292
- 3976: CP#42 completed / Impacted TSs and TRs: 23.003, 29.232, 23.018, 29.002
- 3977: CP#64 complete / Impacted TSs and TRs: RFC 7254 (was draft-montemurro-gsma-imei-urn)
- 3978: CP#41 work stopped / Impacted TSs and TRs: 24.293

| ID | WBS | Task | Duration | Start | Finish | Complete | Baseline start | Baseline finish | Baseline duration | Constraint | Resources | Work | Actual work | Acronym | Release | TSG approved | MCC resp | Acronym_3GU_Export | WI rapporteur name | WI rapporteur e-mail | PCG approved |
| --- | --- | --- | --- | --- | --- | --- | --- | --- | --- | --- | --- | --- | --- | --- | --- | --- | --- | --- | --- | --- | --- |
| 3979 | 1063 | **IMS Multimedia Telephony and Supplementary Services** | 2002d? | 2007-05-02 A | 2014-12-09 A | 100% | 2007-05-02 | 2014-12-05 | 1997d? |  | S1; S5; C1; C3; C4; IETF | 272222h | 272222h | IMSTSS | Rel-8 | 37 | Alain | IMSTSS |  |  |  |
| 3980 | 1063.1 | **General aspects of IMS Sup Services** | 395d? | 2007-09-03 A | 2009-03-06 A | 100% | 2007-09-03 | 2009-03-06 | 395d? |  | S1; C1; C3; C4 | 19232h | 19232h | IMSSS-Gal | Rel-8 | 37 | Alain | IMSSS-Gal | Ericsson | Susana Sabater |  |
| 3981 | 1063.1.1 | Service and Capability for Core IMS - inclusion of TISPAN requirements | 75d? | 2007-09-03 A | 2007-12-14 A | 100% | 2007-09-03 | 2007-12-14 | 75d? | finish no earlier than 2007-12-14 | S1 | 600h | 600h | TISCAPR8 | Rel-8 | 37 | Alain | TISCAPR8 | Ericsson | Susana Sabater |  |
| 3982 | 1063.1.2 | Documentation of TISPAN R1 and R2 in CT1 | 208d? | 2007-11-28 A | 2008-09-12 A | 100% | 2007-11-28 | 2008-09-12 | 208d? | finish no earlier than 2008-09-12 | C1 | 1664h | 1664h | REDOC_TIS-C1 | Rel-8 | 38 | Frederic | REDOC_TIS-C1 | Nokia Siemens Networks | peter.leis@nsn.com | 21 |
| 3983 | 1063.1.3 | Documentation of TISPAN R1 and R2 in CT3 | 333d? | 2007-11-28 A | 2009-03-06 A | 100% | 2007-11-28 | 2009-03-06 | 333d? | finish no earlier than 2009-03-06 | C3 | 2664h | 2664h | REDOC_TIS-C3 | Rel-8 | 38 | Adrian | REDOC_TIS-C3 | Nokia Siemens Networks | peter.leis@nsn.com | 21 |
| 3984 | 1063.1.4 | Documentation of TISPAN R1 and R2 in CT4 | 208d? | 2007-11-28 A | 2008-09-12 A | 100% | 2007-11-28 | 2008-09-12 | 208d? | finish no earlier than 2008-09-12 | C4 | 1664h | 1664h | REDOC_TIS-C4 | Rel-8 | 38 | Kimmo | REDOC_TIS-C4 | Nokia Siemens Networks | peter.leis@nsn.com | 21 |
| 3985 | 1063.2 | **IMS Multimedia Telephony Service** | 394d? | 2007-09-10 A | 2009-03-12 A | 100% | 2007-09-10 | 2009-03-12 | 394d? |  | S1; S5 | 9296h | 9296h | IMS-MMTel | Rel-8 | 37 | Alain | IMS-MMTel |  |  |  |
| 3986 | 1063.2.1 | Merging TISPAN MMTel [requirements] for Common IMS | 65d? | 2007-09-10 A | 2007-12-07 A | 100% | 2007-09-10 | 2007-12-07 | 65d? | finish no earlier than 2007-12-07 | S1 | 520h | 520h | TMMTEL | Rel-8 | 37 | Alain | TMMTEL | Nokia Siemens Networks |  |  |
| 3987 | 1063.2.2 | Multimedia Telephony Service and Supplementary Services (MMTel) offline Charging | 309d? | 2008-01-07 A | 2009-03-12 A | 100% | 2008-01-07 | 2009-03-12 | 309d? | finish no earlier than 2009-03-12 | S5 | 2472h | 2472h | MMTel-CH | Rel-8 | 38 | Mirko | MMTel-CH | Alcatel-Lucent | maryse.gardella@alcatel-lucent.com | 21 |
| 3988 | 1063.3 | **Call Completion on Busy Subscriber (CCBS)/Call Completion on Non-Reachable (CCNR) on IMS** | 1608d? | 2007-05-02 A | 2013-06-14 A | 100% | 2007-05-02 | 2013-06-14 | 1608d? |  | C1; C3; IETF | 71528h | 71528h | CCBS_CCNR | Rel-8 | 38 | Frederic | CCBS_CCNR | Deutsche Telekom | martin.huelsemann@telekom.de | 21 |
| 3989 | 1063.3.1 | CT1 part of Stage 3 CCBS_CCNR | 483d? | 2007-05-02 A | 2009-03-06 A | 100% | 2007-05-02 | 2009-03-06 | 483d? | finish no earlier than 2009-03-06 | C1 | 3864h | 3864h | CCBS_CCNR | Rel-8 | 38 | Frederic |  | Deutsche Telekom | martin.huelsemann@telekom.de | 21 |
| 3990 | 1063.3.2 | CT3 part of Stage 3 CCBS_CCNR | 418d? | 2007-05-02 A | 2008-12-05 A | 100% | 2007-05-02 | 2008-12-05 | 418d? | finish no earlier than 2008-12-05 | C3 | 3344h | 3344h | CCBS_CCNR | Rel-8 | 38 | Adrian |  | Deutsche Telekom | martin.huelsemann@telekom.de | 21 |
| 3991 | 1063.3.3 | (IETF) Stage 3 CCBS_CCNR [RFC 6910 (was draft-ietf-bliss-call-completion)] | 1608d? | 2007-05-02 A | 2013-06-14 A | 100% | 2007-05-02 | 2013-06-14 | 1608d? | finish no earlier than 2013-06-10 | C1-IETF; C3-IETF | 25728h | 25728h | CCBS_CCNR | Rel-8 | 52 | Frederic |  | Roland Jesske |  | 27 |
| 3992 | 1063.4 | **Flexible Alerting** | 288d? | 2008-01-30 A | 2009-03-06 A | 100% | 2008-01-30 | 2009-03-06 | 288d? |  | S1; C1 | 7582.4h | 7582.4h | FA | Rel-8 | 39 | Alain | FA | Nortel | milanpa@nortel.com | 21 |
| 3993 | 1063.4.1 | Stage 1 FA | 92d? | 2008-01-30 A | 2008-06-05 A | 100% | 2008-01-30 | 2008-06-05 | 92d? |  | S1 | 670.4h | 670.4h | FA | Rel-8 | 39 | Alain |  | Telecom Italia |  | 21 |
| 3994 | 1063.4.2 | Stage 3 FA | 288d? | 2008-01-30 A | 2009-03-06 A | 100% | 2008-01-30 | 2009-03-06 | 288d? | finish no earlier than 2009-03-06 | C1 | 2304h | 2304h | FA | Rel-8 | 39 | Frederic |  | Nortel | milanpa@nortel.com | 21 |
| 3995 | 1063.5 | **Communication Wait on IMS** | 1965d? | 2007-06-22 A | 2014-12-09 A | 100% | 2007-06-22 | 2014-12-05 | 1960d? |  | C1; C3; IETF | 61880h | 61880h | CW_IMS | Rel-8 | 38 | Frederic | CW_IMS | Deutsche Telekom | martin.huelsemann@telekom.de | 21 |
| 3996 | 1063.5.1 | CT1 part of Stage 3 CW-IMS | 331d? | 2007-11-30 A | 2009-03-06 A | 100% | 2007-11-30 | 2009-03-06 | 331d? | finish no earlier than 2009-03-06 | C1 | 2648h | 2648h | CW_IMS | Rel-8 | 38 | Frederic |  | Deutsche Telekom | martin.huelsemann@telekom.de | 21 |
| 3997 | 1063.5.2 | (IETF) Stage 3 CW-IMS (salud-alert-info-urns) | 1244d? | 2007-06-22 A | 2014-12-09 A | 100% | 2007-06-22 | 2014-12-05 | 1242d? | finish no earlier than 2014-12-09 | C1-IETF | 9952h | 9952h | CW_IMS | Rel-8 | 52 | Frederic |  | Roland Jesske | Roland Jesske | 27 |
| 3998 | 1063.5.3 | CT3 part of Stage 3 CW-IMS | 265d? | 2007-11-30 A | 2008-12-04 A | 100% | 2007-11-30 | 2008-12-04 | 265d? | finish no earlier than 2008-12-05 | C3 | 2120h | 2120h | CW_IMS | Rel-8 | 38 | Adrian |  | Deutsche Telekom | martin.huelsemann@telekom.de | 21 |
| 3999 | 1063.6 | **IMS Charging** | 389d? | 2007-09-17 A | 2009-03-12 A | 100% | 2007-09-17 | 2009-03-12 | 389d? |  | S5 | 6608h | 6608h | CH8_IMS | Rel-8 | 37 | Mirko | CH8 | Alcatel-Lucent | maryse.gardella@alcatel-lucent.com |  |
| 4000 | 1063.6.1 | Add Interconnection Border Control Function (IBCF) to IMS Charging | 128d? | 2007-09-17 A | 2008-03-12 A | 100% | 2007-09-17 | 2008-03-12 | 128d? | finish no earlier than 2008-03-12 | S5 | 1024h | 1024h | CH8_IMS | Rel-8 | 37 | Mirko |  | Alcatel-Lucent | maryse.gardella@alcatel-lucent.com |  |
| 4001 | 1063.6.2 | Advice of Charge (AoC) support in IMS Charging | 309d? | 2008-01-07 A | 2009-03-12 A | 100% | 2008-01-07 | 2009-03-12 | 309d? | finish no earlier than 2009-03-12 | S5 | 2472h | 2472h | CH8_IMS | Rel-8 | 38 | Mirko |  | Nokia Siemens Networks | Gerald.Goermer@nsn.com | 21 |
| 4002 | 1064 | **3GPP2 Input to Common IMS** | 200d? | 2008-03-07 A | 2008-12-11 A | 100% | 2008-03-07 | 2008-12-11 | 200d? |  | S1; S2; S3; C1; C3; C4 | 21453.2h | 21453.2h | CIMS_3GPP2 | Rel-8 | 39 | Alain | CIMS_3GPP2, IMS_Common | Nortel | Amar Deol (deola@nortelnetworks.com) | 21 |
| 4003 | 1064.1 | Stage 1 CIMS_3GPP2 | 30.65d? | 2008-03-12 A | 2008-06-05 A | 100% | 2008-03-12 | 2008-06-05 | 30.65d? | finish no earlier than 2008-06-12 | S1 | 245.2h | 245.2h | CIMS_3GPP2 | Rel-8 | 39 | Alain |  | Nortel | Amar Deol (deola@nortelnetworks.com) | 21 |
| 4004 | 1064.2 | Stage 2 CIMS_3GPP2 | 62d? | 2008-03-12 A | 2008-06-05 A | 100% | 2008-03-12 | 2008-06-05 | 62d? | finish no earlier than 2008-09-11 | S2 | 496h | 496h | CIMS_3GPP2 | Rel-8 | 39 | Maurice |  | Nortel | Amar Deol (deola@nortelnetworks.com) | 21 |
| 4005 | 1064.3 | Security CIMS_3GPP2 | 197d? | 2008-03-12 A | 2008-12-11 A | 100% | 2008-03-12 | 2008-12-11 | 197d? | finish no earlier than 2008-12-11 | S3 | 1576h | 1576h | CIMS_3GPP2 | Rel-8 | 39 | Mirko |  | Nortel | Amar Deol (deola@nortelnetworks.com) | 21 |

Notes:
- 3979: SP#43 completed
- 3980: CP#43 completed
- 3981: SP#39 completed / Impacted TSs and TRs: 22.228, 22.115, 22.101
- 3982: CP#41 completed / Impacted TSs and TRs: 24.141, 24.147, 24.173, 24.229, 24.247, 24.341, 24.604, 24.605, 24.606, 24.607, 24.608, 24.610, 24.611, 24.616, 24.623, 24.628, 24.629, 24.647, 24.654
- 3983: CP#43 completed / Impacted TSs and TRs: 29.162, 29.163, 29.658
- 3984: CP#41 completed / Impacted TSs and TRs: 29.228, 29.229
- 3985: SP#43 completed
- 3986: SP#38 completed / Impacted TSs and TRs: 22.173
- 3987: CP#43 completed / Impacted TSs and TRs: 32.275, 32.298/299
- 3988: CP#43 completed
- 3989: CP#43 completed / Impacted TSs and TRs: 24.642, 24.229, 24.173
- 3990: CP#42 completed / Impacted TSs and TRs: 29.163
- 3991: CP#60 completed / Impacted TSs and TRs: RFC 6910 (was draft-ietf-bliss-call-completion)
- 3992: CP#43 completed
- 3993: SP#40 completed / Impacted TSs and TRs: 22.173
- 3994: CP#43 completed / Impacted TSs and TRs: 24.239, 24.173
- 3995: CP#43 completed
- 3996: CP#43 completed / Impacted TSs and TRs: 24.615, 24.229, 24.173
- 3997: In RFC Editors Queue. Dec.14: 75->90; 7/3/16: 90%->100 / Impacted TSs and TRs: draft-ietf-salud-alert-info-urns
- 3998: CP#42 completed / Impacted TSs and TRs: 29.163
- 3999: SP#39 completed / Impacted TSs and TRs: 32.260, 32.298
- 4000: SP#39 completed / Impacted TSs and TRs: 32.260, 32.298
- 4001: SP#43 completed / Impacted TSs and TRs: 32.240, 32.260, 32.296, 32.298, 32.299, new 32.280
- 4002: TSG#42 completed. Acronym changed from "CIMS_3GPP2, IMS_Common"
- 4003: SP#40 completed. Acronym changed from "CIMS_3GPP2, IMS_Common" / Impacted TSs and TRs: 22.228, 22.173, 22.101, 22.153
- 4004: SP#40 completed. Acronym changed from "CIMS_3GPP2, IMS_Common" / Impacted TSs and TRs: 23.002, 23.141, 23.203, 23.167, 23.228
- 4005: SP#42 completed [issues addressed under UID_370078 (IMS-Sec)]. Acronym changed from "CIMS_3GPP2, IMS_Common" / Impacted TSs and TRs: 33.141, 33.203, 33.210

| ID | WBS | Task | Duration | Start | Finish | Complete | Baseline start | Baseline finish | Baseline duration | Constraint | Resources | Work | Actual work | Acronym | PCG approved | WI rapporteur name | WI rapporteur e-mail | Release | TSG approved | MCC resp | Acronym_3GU_Export | TSG stopped |
| --- | --- | --- | --- | --- | --- | --- | --- | --- | --- | --- | --- | --- | --- | --- | --- | --- | --- | --- | --- | --- | --- | --- |
| 4006 | 1064.4 | **Stage 3 CIMS_3GPP2** | 200d? | 2008-03-07 A | 2008-12-11 A | 100% | 2008-03-07 | 2008-12-11 | 200d? |  | C1; C3; C4 | 9536h | 9536h | REDOC_3GPP2 | 21 | Alcatel-Lucent | orsic@alcatel-lucent.com | Rel-8 | 39 | Frederic | REDOC_3GPP2 |  |
| 4007 | 1064.4.1 | Stage 3 CIMS_3GPP2 (CT1) | 196d? | 2008-03-07 A | 2008-12-05 A | 100% | 2008-03-07 | 2008-12-05 | 196d? | finish no earlier than 2008-12-11 | C1 | 1568h | 1568h | REDOC_3GPP2 | 21 | Alcatel-Lucent | orsic@alcatel-lucent.com | Rel-8 | 39 | Frederic |  |  |
| 4008 | 1064.4.2 | Stage 3 CIMS_3GPP2 (CT3) | 196d? | 2008-03-07 A | 2008-12-05 A | 100% | 2008-03-07 | 2008-12-05 | 196d? | finish no earlier than 2008-12-05 | C3 | 1568h | 1568h | REDOC_3GPP2 | 21 | Alcatel-Lucent | orsic@alcatel-lucent.com | Rel-8 | 39 | Adrian |  |  |
| 4009 | 1064.4.3 | Stage 3 CIMS_3GPP2 (CT4) | 200d? | 2008-03-07 A | 2008-12-11 A | 100% | 2008-03-07 | 2008-12-11 | 200d? | finish no earlier than 2008-12-11 | C4 | 1600h | 1600h | REDOC_3GPP2 | 21 | Alcatel-Lucent | orsic@alcatel-lucent.com | Rel-8 | 39 | Kimmo |  |  |
| 4010 | 1065 | **IMS Enhancements for support of Packet Cable access** | 388d? | 2006-12-06 A | 2008-05-30 A | 100% | 2006-12-06 | 2008-05-30 | 388d? |  | S2; S3; C1; C3; C4 | 58616h | 58616h | PktCbl |  | Cablelabs | Bernie McKibben (b.mckibben@cablelabs.com) | Rel-8 | 35 | Maurice | PktCbl |  |
| 4011 | 1065.1 | **IMS Enhancements for Cable Client Types and Deployment Models** | 345d? | 2007-02-05 A | 2008-05-30 A | 100% | 2007-02-05 | 2008-05-30 | 345d? |  | S2; C1 | 9752h | 9752h | PktCbl-Deploy |  | Cablelabs | Bernie McKibben (b.mckibben@cablelabs.com) | Rel-8 |  | Maurice | PktCbl-Deploy |  |
| 4012 | 1065.1.1 | Architecture aspects of PktCbl-Deploy | 219d? | 2007-02-05 A | 2007-12-06 A | 100% | 2007-02-05 | 2007-12-06 | 219d? | finish no earlier than 2007-12-03 | S2 | 1752h | 1752h | PktCbl-Deploy |  | Cablelabs | Bernie McKibben (b.mckibben@cablelabs.com) | Rel-8 |  | Maurice |  |  |
| 4013 | 1065.1.2 | CT1 aspects of PktCbl-Deploy | 310d? | 2007-03-26 A | 2008-05-30 A | 100% | 2007-03-26 | 2008-05-30 | 310d? | finish no earlier than 2008-06-15 | C1 | 2480h | 2480h | PktCbl-Deploy |  | Cablelabs | D.Hancock@CableLabs.com | Rel-8 |  | Frederic |  |  |
| 4014 | 1065.2 | **IMS Inter-working aspects in Support of Cable Regulatory requirements** | 290d? | 2007-02-05 A | 2008-03-14 A | 100% | 2007-02-05 | 2008-03-14 | 290d? |  | S2; C1; C3 | 12320h | 12320h | PktCbl-Intw |  | Cablelabs | B.McKibben@CableLabs.com | Rel-8 |  | Maurice | PktCbl-Intw |  |
| 4015 | 1065.2.1 | Architecture aspects of PktCbl-Interwork | 160d? | 2007-02-05 A | 2007-09-14 A | 100% | 2007-02-05 | 2007-09-14 | 160d? | start no earlier than 2007-02-05 | S2 | 1280h | 1280h | PktCbl-Intw |  | Cablelabs | B.McKibben@CableLabs.com | Rel-8 |  | Maurice |  |  |
| 4016 | 1065.2.2 | CT1,CT3 aspects of PktCbl-Interwork | 255d? | 2007-03-26 A | 2008-03-14 A | 100% | 2007-03-26 | 2008-03-14 | 255d? | finish no earlier than 2008-03-15 | C1; C3 | 4080h | 4080h | PktCbl-Intw |  | Cablelabs | D.Hancock@CableLabs.com | Rel-8 |  | Frederic |  |  |
| 4017 | 1065.3 | **IMS Enhancements for Security Requirements in Support of Cable Deployments** | 388d? | 2006-12-06 A | 2008-05-30 A | 100% | 2006-12-06 | 2008-05-30 | 388d? |  | S3; C1; C3; C4 | 21024h | 21024h | PktCbl-Sec |  | Cablelabs | s.dotson@cablelabs.com | Rel-8 | 34 | Mirko | PktCbl-Sec |  |
| 4018 | 1065.3.1 | SA3 aspects of PktCbl-Sec | 331d? | 2006-12-06 A | 2008-03-12 A | 100% | 2006-12-06 | 2008-03-12 | 331d? | finish no earlier than 2007-12-20 | S3 | 2648h | 2648h | PktCbl-Sec |  | Cablelabs | s.dotson@cablelabs.com | Rel-8 |  | Mirko |  |  |
| 4019 | 1065.3.2 | CT1 aspects of PktCbl-Sec | 310d? | 2007-03-26 A | 2008-05-30 A | 100% | 2007-03-26 | 2008-05-30 | 310d? | finish no earlier than 2008-06-06 | C1 | 2480h | 2480h | PktCbl-Sec |  | Cablelabs | D.Hancock@CableLabs.com | Rel-8 |  | Frederic |  |  |
| 4020 | 1065.3.3 | CT3 aspects of PktCbl-Sec | 180d? | 2007-03-26 A | 2007-11-30 A | 100% | 2007-03-26 | 2007-11-30 | 180d? | finish no earlier than 2008-03-15 | C3 | 1440h | 1440h | PktCbl-Sec | 21 | Cablelabs | D.Hancock@CableLabs.com | Rel-8 | 38 | Adrian |  |  |
| 4021 | 1065.3.4 | CT4 aspects of PktCbl-Sec | 255d? | 2007-03-26 A | 2008-03-14 A | 100% | 2007-03-26 | 2008-03-14 | 255d? | finish no earlier than 2008-03-14 | C4 | 2040h | 2040h | PktCbl-Sec |  | Cablelabs | D.Hancock@CableLabs.com | Rel-8 |  | Kimmo |  |  |
| 4022 | 1066 | **IMS System enhancements for corporate network access** | 1901d? | 2007-06-22 A | 2014-09-12 A | 100% | 2007-06-22 | 2014-12-05 | 1960d? |  | S2; S1; C1; C4; IETF | 91240.9h | 91240.9h | IMS_Corp |  | Orange | Delphin Barankanira | Rel-8 |  | Maurice | IMS_Corp |  |
| 4023 | 1066.1 | SA1 aspects of IMS_Corp | 23.6d? | 2008-03-12 A | 2008-06-05 A | 100% | 2008-03-12 | 2008-06-05 | 23.6d? | finish no earlier than 2008-06-05 | S1 | 188.8h | 188.8h | IMS_Corp | 21 | Telecom Italia |  | Rel-8 | 39 | Alain |  |  |
| 4024 | 1066.2 | SA2 aspects of IMS_Corp | 325d? | 2007-06-22 A | 2008-09-18 A | 100% | 2007-06-22 | 2008-09-18 | 325d? | finish no earlier than 2008-12-25 | S2 | 2600h | 2600h | IMS_Corp |  | Orange | Delphin Barankanira | Rel-8 |  | Maurice |  |  |
| 4025 | 1066.3 | CT1 aspects of IMS_Corp | 532d? | 2008-03-07 A | 2010-03-19 A | 100% | 2008-03-07 | 2010-03-19 | 532d? | finish no earlier than 2010-03-19 | C1 | 4244.09h | 4244.09h | IMS_Corp | 21 | Alcatel-Lucent | Keith Drage (drage@alcatel-lucent.com) | Rel-8 | 39 | Frederic |  |  |
| 4026 | 1066.4 | (IETF) CT1 aspects of IMS_Corp (RFC 7316) | 825d? | 2011-06-29 A | 2014-09-12 A | 100% | 2011-06-29 | 2014-12-05 | 885d? | finish no earlier than 2014-09-12 | C1-IETF | 6600h | 6600h | IMS_Corp | 27 | Keith Drage | Keith Drage (drage@alcatel-lucent.com) | Rel-8 | 53 | Frederic |  |  |
| 4027 | 1066.5 | CT4 aspects of IMS_Corp | 196d? | 2008-02-26 A | 2008-12-05 A | 100% | 2008-02-26 | 2008-12-05 | 196d? | finish no earlier than 2008-12-11 | C4 | 1568h | 1568h | IMS_Corp | 21 | Alcatel-Lucent | Keith Drage (drage@alcatel-lucent.com) | Rel-8 | 39 | Kimmo |  |  |
| 4028 | 1067 | **Maintenance of TISPAN documentation** | 1829d? | 2007-07-02 A | 2014-06-13 A | 100% | 2007-07-02 | 2014-06-13 | 1829d? |  | S2; C1; C3; C4; IETF | 85904h | 85904h | MAINTISP | 21 |  |  | Rel-8 | 38 | Maurice | MAINTISP |  |
| 4029 | 1067.1 | Maintenance of TISPAN R2 | 86d? | 2007-11-09 A | 2008-03-07 A | 100% | 2007-11-09 | 2008-03-07 | 86d? | start no earlier than 2007-11-09 | C1; C3; C4 | 2064h | 2064h | MAINT_R2 | 21 | Alcatel-Lucent | Keith Drage (drage@alcatel-lucent.com) | Rel-8 | 38 | Frederic | MAINT_R2 |  |
| 4030 | 1067.2 | Deleted - (IETF) Maintenance of TISPAN R2 (avasarala-dispatch-comm-div-notification) | 1117d? | 2007-11-09 A | 2014-06-13 A | 100% | 2007-11-09 | 2014-06-13 | 1117d? | finish no earlier than 2014-06-13 | C1-IETF | 8936h | 8936h | MAINT_R2_IETF | 27 | Andrew Allen |  | Rel-8 | 52 | Frederic | MAINT_R2_IETF | SP-69 |
| 4031 | 1067.3 | Documentation of TISPAN NGN R1 and R2 in 3GPP SA2 | 104d? | 2008-01-14 A | 2008-06-05 A | 100% | 2008-01-14 | 2008-06-05 | 104d? | finish no earlier than 2008-06-20 | S2 | 832h | 832h | IMS_Comm_Doc | 21 | Nokia Siemens Networks | jozsef.varga@nsn.com | Rel-8 | 38 | Maurice | IMS_Comm_Doc |  |
| 4032 | 1067.4 | Maintenance of TISPAN release 2 common IMS | 114d? | 2007-07-02 A | 2007-12-06 A | 100% | 2007-07-02 | 2007-12-06 | 114d? | finish no earlier than 2007-12-06 | S2 | 912h | 912h | IMS_Comm_Mtce8 | 21 | Telecom Italia | antonio.ascolese@telecomitalia.it | Rel-8 | 38 | Maurice | IMS_Comm_Mtce8 |  |

Notes:
- 4006: -
- 4007: CP#42 completed / Impacted TSs and TRs: 23.218, 24.141, 24.147, 24.173, 24.229, 24.238, 24.247, 24.604, 24.605, 24.606, 24.607, 24.608, 24.610, 24.611, 24.629, 24.930
- 4008: CP#42 completed / Impacted TSs and TRs: 29.163, 29.212, 29.213, 29.214
- 4009: CP#42 completed / Impacted TSs and TRs: 29.228, 29.229, 29.328, 29.329
- 4010: CP#40 completed
- 4011: CP#40 completed
- 4012: SP#38 completed / Impacted TSs and TRs: 23.228
- 4013: CP#40 completed
- 4014: CP#39 completed
- 4015: SP#37 completed / Impacted TSs and TRs: 23.228
- 4016: CP#39 completed / Impacted TSs and TRs: 24.229
- 4017: CP#40 completed
- 4018: SP#39 completed / Impacted TSs and TRs: 33.203, 33.210, 33.220
- 4019: CP#40 completed / Impacted TSs and TRs: 24.229
- 4020: CP#38 completed / Impacted TSs and TRs: 29.163
- 4021: CP#39 completed / Impacted TSs and TRs: 29.228, 29.229, 23.008
- 4022: CP#47 completed
- 4023: SP#40 completed
- 4024: no Stage 2 impacts / Impacted TSs and TRs: 23.228
- 4025: CP#47 completed / Impacted TSs and TRs: 24.229, 24.503
- 4026: CP#65 completed / Impacted TSs and TRs: RFC 7316 (was draft-vanelburg-dispatch-private-network-ind)
- 4027: CP#42 completed / Impacted TSs and TRs: 29.228, 29.229, 23.003, 23.008, 29.433
- 4028: SP#40 completed
- 4029: CP#39 completed / Impacted TSs and TRs: 24.406, 24.407, 24.410, 24.411, 24.423, 24.430, 24.447, 24.451, 24.454, 24.503, 24.505, 24.508, 24.516, 24.528, 24.529, 29.412, 29.421, 29.433, 29.458, 29.527, 29.624
- 4030: CP#64 Draft removed from 3GPP documentation / Impacted TSs and TRs: draft-avasarala-dispatch-comm-div-notification
- 4031: SP#40 completed / Impacted TSs and TRs: 23.228, 23.204, 23.167
- 4032: SP#38 completed / Impacted TSs and TRs: 23.506, 23.507,23.517, 23.521

| ID | WBS | Task | Type | Duration | Start | Finish | Complete | Baseline start | Baseline finish | Baseline duration | Constraint | Resources | Work | Actual work | Acronym | PCG approved | WI rapporteur name | WI rapporteur e-mail | Release | TSG approved | MCC resp | Acronym_3GU_Export | Impacted TSs and TRs |
| --- | --- | --- | --- | --- | --- | --- | --- | --- | --- | --- | --- | --- | --- | --- | --- | --- | --- | --- | --- | --- | --- | --- | --- |
| 4033 | 1068 | **IMS Service Continuity** |  | 318d? | 2008-03-12 A | 2009-05-29 A | 100% | 2008-03-12 | 2009-05-29 | 318d? |  | S2; S1; C1 | 10712h | 10712h | IMS-Cont | 21 | LG Electronics | JaeSeung SONG (anthonys@lge.com) | Rel-8 | 39 | Maurice | IMS-Cont |  |
| 4034 | 1068.1 | Stage 1 IMS Service Continuity |  | 62d? | 2008-03-12 A | 2008-06-05 A | 100% | 2008-03-12 | 2008-06-05 | 62d? | start no earlier than 2008-03-12 | S1 | 496h | 496h | IMS-Cont | 21 | LG Electronics | JaeSeung SONG (anthonys@lge.com) | Rel-8 | 39 | Alain |  |  |
| 4035 | 1068.2 | Stage 2 IMS Service Continuity |  | 62d? | 2008-03-12 A | 2008-06-05 A | 100% | 2008-03-12 | 2008-06-05 | 62d? | finish no earlier than 2008-06-05 | S2 | 496h | 496h | IMS-Cont | 21 | LG Electronics | JaeSeung SONG (anthonys@lge.com) | Rel-8 | 39 | Maurice |  | 23.237, 23.292 |
| 4036 | 1068.3 | Stage 3 IMS Service Continuity |  | 261d? | 2008-05-30 A | 2009-05-29 A | 100% | 2008-05-30 | 2009-05-29 | 261d? | finish no earlier than 2009-05-29 | C1 | 2088h | 2088h | IMS-Cont | 21 | Huawei | Lili Yang (kadyyang@huawei.com) | Rel-8 | 40 | Frederic |  | 24.237, 24.229, 24.216 |
| 4037 | 1069 | **Security Enhancements for IMS** |  | 643.3d? | 2006-09-19 A | 2009-03-06 A | 100% | 2006-09-19 | 2009-03-06 | 643.3d? |  | S3; C1; C4 | 29847.2h | 29847.2h | IMS-Sec |  | Ericsson | Bengt.Sahlin@ericsson.com | Rel-8 | 37 | Mirko | IMS-Sec |  |
| 4038 | 1069.1 | Stage 2 for IMS-Sec |  | 466d? | 2007-03-01 A | 2008-12-11 A | 100% | 2007-03-01 | 2008-12-11 | 466d? | finish no earlier than 2008-12-11 | S3 | 3728h | 3728h | IMS-Sec |  | Ericsson | Bengt.Sahlin@ericsson.com | Rel-8 |  | Mirko |  | 33.203, 33.141, 33.803 |
| 4039 | 1069.2 | CT1 part of Stage 3 for IMS-Sec |  | 392d? | 2006-09-19 A | 2008-12-05 A | 100% | 2006-09-19 | 2008-12-05 | 392d? | finish no earlier than 2008-12-05 | C1 | 3136h | 3136h | IMS-Sec | 21 | Ericsson |  | Rel-8 | 39 | Frederic |  |  |
| 4040 | 1069.3 | CT4 part of Stage 3 for IMS-Sec |  | 457d? | 2007-06-07 A | 2009-03-06 A | 100% | 2007-06-07 | 2009-03-06 | 457d? | finish no earlier than 2009-03-06 | C4 | 3656h | 3656h | IMS-Sec | 21 | Ericsson |  | Rel-8 | 39 | Kimmo |  |  |
| 4041 | 1069.4 | CT1 part of Network Attachment Subsystem (NASS) Bundled Authentication |  | 343d? | 2007-11-14 A | 2009-03-06 A | 100% | 2007-11-14 | 2009-03-06 | 343d? | finish no earlier than 2009-03-06 | C1 | 2744h | 2744h | NBA | 21 | Alcatel-Lucent | Keith Drage (drage@alcatel-lucent.com) | Rel-8 | 39 | Frederic | NBA | 24.229 |
| 4042 | 1069.5 | CT4 part of Network Attachment Subsystem (NASS) Bundled Authentication |  | 143d? | 2007-11-14 A | 2008-05-30 A | 100% | 2007-11-14 | 2008-05-30 | 143d? | start no earlier than 2007-11-14 | C4 | 1144h | 1144h | NBA-CT4 | 21 | Alcatel-Lucent |  | Rel-8 | 39 | Kimmo | NBA-CT4 | 29.229, 29.228, 23.008 |
| 4043 | 1070 | **IMS initiated and controlled PSS and MBMS User Service** |  | 924d? | 2008-03-12 A | 2011-09-21 A | 100% | 2008-03-12 | 2011-09-21 | 924d? |  | S4; S3; IETF | 28108.8h | 28108.8h | IMS_PSS_MBMS_US |  | FT, Ericsson | olle.franceschi@ericsson.com | Rel-8 |  | Paolo | IMS_PSS_MBMS_US |  |
| 4044 | 1070.1 | SA4, SA3 part of IMS initiated and controlled PSS and MBMS User Service | milestone | 0d? | 2008-03-12 A | 2008-03-12 A | 100% | 2008-03-12 | 2008-03-12 | 0d? | finish no earlier than 2009-03-12 | S4; S3 |  |  | IMS_PSS_MBMS_US |  | FT, Ericsson | olle.franceschi@ericsson.com | Rel-8 |  | Paolo |  | 26.234, 26.346, 33.246, New 26.237 |
| 4045 | 1070.2 | (IETF) IMS initiated and controlled PSS and MBMS User Service (RFC 6080) |  | 743.6d? | 2008-03-12 A | 2011-09-21 A | 100% | 2008-03-12 | 2011-09-21 | 743.6d? | finish no earlier than 2011-09-21 | S4-IETF | 5932.8h | 5932.8h | IMS_PSS_MBMS_US | 27 | Ericsson |  | Rel-8 | 52 | Paolo |  | RFC 6080 (was draft-ietf-sipping-config-framework) |
| 4046 | 1071 | **Multimedia interworking between IMS and CS networks** |  | 836d? | 2005-09-23 A | 2008-12-05 A | 100% | 2005-09-23 | 2008-12-05 | 836d? |  | C3; C4 | 22800h | 22800h | MIW-IMS | 36 | Vodafone | nico.gabriele@vodafone.com | Rel-8 | 71 | Adrian | MIW-IMS |  |
| 4047 | 1071.1 | Stage 1 and 2 defined in earlier Releases |  | 49d? | 2005-09-23 A | 2005-11-30 A | 100% | 2005-09-23 | 2005-11-30 | 49d? | start no earlier than 2005-09-23 | S2 | 392h | 392h | MIW-IMS |  | Vodafone | nico.gabriele@vodafone.com | Rel-8 |  | Maurice |  |  |
| 4048 | 1071.2 | Stage 3 of MW-IMS |  | 571d? | 2005-09-23 A | 2007-11-30 A | 100% | 2005-09-23 | 2007-11-30 | 571d? | finish no earlier than 2007-09-14 | C3 | 4568h | 4568h | MIW-IMS-St3C3 |  | Vodafone | nico.gabriele@vodafone.com | Rel-8 |  | Adrian | MIW-IMS-St3 | 29.863, 29.163 |
| 4049 | 1071.3 | Stage 3 for MW-IMS, MONA extension |  | 285d? | 2007-11-05 A | 2008-12-05 A | 100% | 2007-11-05 | 2008-12-05 | 285d? | finish no earlier than 2008-12-05 | C3 | 2280h | 2280h | MIW-IMS-St3C3_MONA | 21 | Vodafone | Christer.Holmberg@ericsson.com | Rel-8 | 38 | Adrian |  | 29.863, 29.163 |
| 4050 | 1071.4 | Mn interface (MGCF – IM MGW) |  | 273d? | 2007-11-21 A | 2008-12-05 A | 100% | 2007-11-21 | 2008-12-05 | 273d? | finish no earlier than 2008-12-19 | C4 | 2184h | 2184h | MIW-IMS-St3C4 | 21 | Vodafone | Christer.Holmberg@ericsson.com | Rel-8 | 38 | Kimmo |  | 29.332 |
| 4051 | 1072 | **IMS Stage 3 IETF Protocol Alignment - phase 2** |  | 1965d? | 2007-06-22 A | 2014-12-09 A | 100% | 2007-06-22 | 2014-12-05 | 1960d? |  | C1; IETF | 55368h | 55368h | IMSProtoc2 |  | Alcatel-Lucent | Keith Drage (drage@alcatel-lucent.com) | Rel-8 |  | Frederic | IMSProtoc2 |  |
| 4052 | 1072.1 | CT1 aspects of IMS Stage 3 IETF Protocol Alignment - phase 2 |  | 446d? | 2007-06-22 A | 2009-03-06 A | 100% | 2007-06-22 | 2009-03-06 | 446d? | finish no earlier than 2009-03-06 | C1 | 3568h | 3568h | IMSProtoc2 |  | Alcatel-Lucent | Keith Drage (drage@alcatel-lucent.com) | Rel-8 |  | Frederic |  | 23.218, 24.229, 24.930 |
| 4053 | 1072.2 | (IETF) IMS Stage 3 IETF Protocol Alignment (draft-bakker-sipping-3gpp-ims-xml-body-handling) |  | 715d? | 2007-06-22 A | 2012-12-07 A | 100% | 2007-06-22 | 2012-12-07 | 715d? | finish no earlier than 2012-12-07 | C1-IETF | 5720h | 5720h | IMSProtoc2 | 27 | Andrew Allen |  | Rel-8 | 52 | Frederic |  | draft-bakker-sipping-3gpp-ims-xml-body-handling |
| 4054 | 1072.3 | (IETF) IMS Stage 3 IETF Protocol Alignment (RFC 6544) |  | 587d? | 2007-06-22 A | 2012-06-15 A | 100% | 2007-06-22 | 2012-06-15 | 587d? | finish no earlier than 2012-04-20 | C1-IETF | 4688h | 4688h | IMSProtoc2 | 27 | Keith Drage |  | Rel-8 | 52 | Frederic |  | RFC 6544 (was draft-ietf-mmusic-ice-tcp) |
| 4055 | 1072.4 | (IETF) IMS Stage 3 IETF Protocol Alignment (draft-ietf-salud-alert-info-urns) |  | 1244d? | 2007-06-22 A | 2014-12-09 A | 100% | 2007-06-22 | 2014-12-05 | 1242d? | finish no earlier than 2014-12-09 | C1-IETF | 9952h | 9952h | IMSProtoc2 | 27 | Roland Jesske | Roland Jesske | Rel-8 | 52 | Frederic |  | draft-ietf-salud-alert-info-urns |
| 4056 | 1073 | **Interworking between User-to-User Signalling (UUS) and SIP** |  | 1850d? | 2007-11-30 A | 2014-12-09 A | 100% | 2007-11-30 | 2014-12-05 | 1845d? |  | C1; C3; IETF | 68624.4h | 68624.4h | UUSIW | 21 | Huawei | Lili Yang (kadyyang@huawei.com) | Rel-8 | 38 | Kimmo | UUSIW |  |
| 4057 | 1073.1 | CT1 part of Stage 3 MGCF UUSIW |  | 266d? | 2007-11-30 A | 2008-12-05 A | 100% | 2007-11-30 | 2008-12-05 | 266d? | finish no earlier than 2008-12-05 | C1 | 2128h | 2128h | UUSIW | 21 | Huawei | Lili Yang (kadyyang@huawei.com) | Rel-8 | 38 | Frederic |  | 24.279, 24.229 |
| 4058 | 1073.2 | (IETF) Stage 3 MGCF UUSIW (cuss-sip-uui) |  | 227.03d? | 2007-11-30 A | 2014-12-09 A | 100% | 2007-11-30 | 2014-12-05 | 225.03d? | finish no earlier than 2014-12-09 | C1-IETF; C3-IETF | 3632.4h | 3632.4h | UUSIW | 27 | Roland Jesske | Roland Jesske | Rel-8 | 52 | Frederic |  | RFC 7433 |
| 4059 | 1073.3 | (IETF) Stage 3 MGCF UUSIW (cuss-sip-uui-isdn) |  | 986.5d? | 2011-03-17 A | 2014-12-09 A | 100% | 2011-03-17 | 2014-12-05 | 984.5d? | finish no earlier than 2014-12-09 | C1-IETF; C3-IETF | 15784h | 15784h | UUSIW | 28 | Keith Drage | Keith Drage (drage@alcatel-lucent.com) | Rel-8 | 55 | Frederic |  | RFC 7434 |
| 4060 | 1073.4 | CT3 part of Stage 3 MGCF UUSIW |  | 335d? | 2007-11-30 A | 2009-03-12 A | 100% | 2007-11-30 | 2009-03-12 | 335d? | finish no earlier than 2009-03-12 | C3 | 2680h | 2680h | UUSIW | 21 | Huawei | Lili Yang (kadyyang@huawei.com) | Rel-8 | 38 | Adrian |  | 29.163 |

Notes:
- 4033: CP#44 completed
- 4034: SP#40 completed
- 4035: SP#40 completed
- 4036: CP#44 completed
- 4037: CP#43 completed
- 4038: SP#42 completed. SP#46 withdrawn draft 33.178-100 and 33.978 from Rel-8 onwards
- 4039: CP#42 completed
- 4040: CP#43 completed
- 4041: CP#43 completed
- 4042: CP#40 completed
- 4043: SP#39 WID approved
- 4044: SP#43 completed
- 4045: SP#53/IETF#81 completed
- 4046: CP#42 completed
- 4047: SP#31 Moved from FS section Feb 2006
- 4048: Moved from Rel-7. Feature extended in Rel-8 by including Stage 3 covering MONA UID_380021
- 4049: CP#42 completed
- 4050: CP#42 completed
- 4051: CP#43 completed
- 4052: CP#43 completed
- 4053: CP#58 completed. ietf-draft discontinued. Documented within 3GPP
- 4054: CP#56 completed
- 4055: In RFC Editors Queue. Dec.14: 75->90; 7/3/16: 90%->100
- 4056: CP#43 completed
- 4057: CP#42 completed
- 4058: In RFC Editors Queue. Mar15: 90->100%. RFC updated (was draft-ietf-cuss-sip-uui). June 2015: RFC 7433 (was draft-ietf-cuss-sip-uui)
- 4059: In RFC Editors Queue. Dec.14: 75->90. Mar15: 90->100%. RFC updated (was draft-ietf-cuss-sip-uui-isdn). June 2015: RFC 7434 (was draft-ietf-cuss-sip-uui-isdn)
- 4060: CP#43 completed

| ID | WBS | Task | Type | Duration | Start | Finish | Complete | Baseline start | Baseline finish | Baseline duration | Constraint | Resources | Work | Actual work | Acronym | PCG approved | WI rapporteur name | WI rapporteur e-mail | Release | TSG approved | MCC resp | Acronym_3GU_Export | Impacted TSs and TRs | Special Focus Doc | Status Report |
| --- | --- | --- | --- | --- | --- | --- | --- | --- | --- | --- | --- | --- | --- | --- | --- | --- | --- | --- | --- | --- | --- | --- | --- | --- | --- |
| 4061 | 1074 | **Support of Overlap signalling** |  | 331d? | 2007-11-30 A | 2009-03-06 A | 100% | 2007-11-30 | 2009-03-06 | 331d? |  | C3; C1; C4 | 15304.2h | 15304.2h | Overlap | 21 | Deutsche Telekom | r.jesske@telekom.de | Rel-8 | 38 | Adrian | Overlap |  |  |  |
| 4062 | 1074.1 | Stage 3 Overlap (CT1) |  | 331d? | 2007-11-30 A | 2009-03-06 A | 100% | 2007-11-30 | 2009-03-06 | 331d? | finish no earlier than 2009-03-06 | C1 | 2648h | 2648h | Overlap | 21 | Deutsche Telekom | r.jesske@telekom.de | Rel-8 | 38 | Frederic |  | 24.229 |  |  |
| 4063 | 1074.2 | Stage 3 Overlap (CT3) |  | 331d? | 2007-11-30 A | 2009-03-06 A | 100% | 2007-11-30 | 2009-03-06 | 331d? | finish no earlier than 2009-03-06 | C3 | 2648h | 2648h | Overlap | 21 | Deutsche Telekom | r.jesske@telekom.de | Rel-8 | 38 | Adrian |  | 29.163 |  |  |
| 4064 | 1074.3 | Stage 3 Overlap (CT4) |  | 258.02d? | 2007-11-30 A | 2008-12-05 A | 100% | 2007-11-30 | 2008-12-05 | 258.02d? | start no earlier than 2007-11-30 | C4 | 2064.16h | 2064.16h | Overlap | 21 | Deutsche Telekom | r.jesske@telekom.de | Rel-8 | 38 | Kimmo |  | 29.228, 29.229 |  |  |
| 4065 | 1075 | **AS/MRFC Stage 2 and 3** |  | 1203d? | 2007-11-14 A | 2012-06-15 A | 100% | 2007-11-14 | 2012-06-15 | 1203d? |  | C1; IETF | 28384h | 28384h | MRFC_TS | 21 | Hewlett-Packard | mark.syrett@hp.com | Rel-8 | 38 | Frederic | MRFC_TS |  |  |  |
| 4066 | 1075.1 | AS/MRFC Stage 2 |  | 278d? | 2007-11-14 A | 2008-12-05 A | 100% | 2007-11-14 | 2008-12-05 | 278d? | finish no earlier than 2008-12-05 | C1 | 2224h | 2224h | MRFC_TS | 21 | Hewlett-Packard | mark.syrett@hp.com | Rel-8 | 38 | Frederic |  | 23.218 |  |  |
| 4067 | 1075.2 | AS/MRFC Stage 3 |  | 278d? | 2007-11-14 A | 2008-12-05 A | 100% | 2007-11-14 | 2008-12-05 | 278d? | finish no earlier than 2008-12-05 | C1 | 2224h | 2224h | MRFC_TS | 21 | Hewlett-Packard | mark.syrett@hp.com | Rel-8 | 38 | Frederic |  | 24.229, 24.147, 24.247 |  |  |
| 4068 | 1075.3 | (IETF) AS/MRFC Stage 2 and 3 (RFC 6505) |  | 590d? | 2007-11-14 A | 2012-06-15 A | 100% | 2007-11-14 | 2012-06-15 | 590d? | finish no earlier than 2012-06-15 | C1-IETF | 4688h | 4688h | MRFC_TS | 27 | Keith Drage |  | Rel-8 | 52 | Frederic |  | RFC 6505 (was draft-ietf-mediactrl-mixer-control-package) |  |  |
| 4069 | 1076 | **IMS Restoration Procedures** |  | 201d? | 2008-05-30 A | 2009-03-06 A | 100% | 2008-05-30 | 2009-03-06 | 201d? |  | C4; C1 | 6432h | 6432h | IMS_RP | 21 | Ericsson | german.blanco@ericsson.com | Rel-8 | 40 | Kimmo | IMS_RP |  |  |  |
| 4070 | 1076.1 | IMS Restoration Procedures (CT4) |  | 201d? | 2008-05-30 A | 2009-03-06 A | 100% | 2008-05-30 | 2009-03-06 | 201d? | finish no earlier than 2009-03-06 | C4 | 1608h | 1608h | IMS_RP | 21 | Ericsson | german.blanco@ericsson.com | Rel-8 | 40 | Kimmo |  | 23.380, 29.228, 29.229, 29.230, 23.008 |  |  |
| 4071 | 1076.2 | IMS Restoration Procedures (CT1) |  | 201d? | 2008-05-30 A | 2009-03-06 A | 100% | 2008-05-30 | 2009-03-06 | 201d? | finish no earlier than 2009-03-06 | C1 | 1608h | 1608h | IMS_RP | 21 | Ericsson | german.blanco@ericsson.com | Rel-8 | 40 | Frederic |  | 24.229 |  |  |
| 4072 | 1077 | IMS Application Server Service Data Descriptions for AS interoperability |  | 125d? | 2008-09-12 A | 2009-03-06 A | 100% | 2008-09-12 | 2009-03-06 | 125d? | finish no earlier than 2009-03-06 | C4 | 1000h | 1000h | IMS_ASIO | 21 | Alcatel-Lucent | nhberry@alcatel-lucent.com | Rel-8 | 41 | Kimmo | IMS_ASIO | 29.328, 29.329, 29.364 |  |  |
| 4073 | 1078 | **I-WLAN Network Selection Principle (NSP)** |  | 451d? | 2007-06-14 A | 2009-03-06 A | 100% | 2007-06-14 | 2009-03-06 | 451d? |  | S1; C1; C6 | 13859.2h | 13859.2h | IWLANNSP |  | Telefónica O2 | chris.friel@O2.com | Rel-8 | 34 | Alain | IWLANNSP |  | WLAN |  |
| 4074 | 1078.1 | Stage 1 for I-WLAN NSP | milestone | 0d? | 2007-06-14 A | 2007-06-14 A | 100% | 2007-06-14 | 2007-06-14 | 0d? |  | S1 |  |  | IWLANNSP | 21 | Telefónica O2 | chris.friel@O2.com | Rel-8 | 39 | Alain |  | 22.234 | WLAN |  |
| 4075 | 1078.2 | CT1 part of Stage 3 for I-WLAN NSP |  | 261d? | 2008-03-07 A | 2009-03-06 A | 100% | 2008-03-07 | 2009-03-06 | 261d? | finish no earlier than 2008-12-05 | C1 | 2088h | 2088h | IWLANNSP | 21 | Research In Motion | Adrian Buckley (abuckley@rim.com) | Rel-8 | 39 | Frederic |  | 24.234 | WLAN |  |
| 4076 | 1078.3 | CT6 part of Stage 3 for I-WLAN NSP |  | 118.4d? | 2008-03-07 A | 2008-12-11 A | 100% | 2008-03-07 | 2008-12-11 | 118.4d? | finish no earlier than 2008-12-11 | C6 | 947.2h | 947.2h | IWLANNSP | 21 | Research In Motion | Adrian Buckley (abuckley@rim.com) | Rel-8 | 39 | Xavier |  | 31.102, 31.111 | WLAN |  |
| 4077 | 1079 | **Mobility between 3GPP-WLAN Interworking and 3GPP Systems** |  | 386d? | 2007-09-14 A | 2009-03-06 A | 100% | 2007-09-14 | 2009-03-06 | 386d? |  | S2; C1 | 9304h | 9304h | IWLAN_Mob |  | Orange | xiaobao.chen@orange-ftgroup.com | Rel-8 | 37 | Maurice | IWLAN_Mob |  | WLAN |  |
| 4078 | 1079.1 | Stage 2 for Mobility between 3GPP-WLAN Interworking and 3GPP Systems |  | 190d? | 2007-09-14 A | 2008-06-05 A | 100% | 2007-09-14 | 2008-06-05 | 190d? | finish no earlier than 2008-09-08 | S2 | 1520h | 1520h | IWLAN_Mob | 21 | Orange | xiaobao.chen@orange-ftgroup.com | Rel-8 | 38 | Maurice |  | new 23.327 | WLAN |  |
| 4079 | 1079.2 | CT1 aspects of Mobility between 3GPP-WLAN Interworking and 3GPP Systems |  | 201d? | 2008-05-30 A | 2009-03-06 A | 100% | 2008-05-30 | 2009-03-06 | 201d? | finish no earlier than 2009-03-06 | C1 | 1608h | 1608h | IWLAN_Mob | 21 | Orange | reina.nader@orange-ftgroup.com | Rel-8 | 40 | Frederic |  | 24.303, new 24.327 | WLAN |  |
| 4080 | 1080 | Conformance Test Aspects – Mobility between 3GPP WLAN Interworking and 3GPP Systems |  | 206d? | 2009-12-04 A | 2010-09-17 A | 100% | 2009-12-04 | 2010-09-17 | 206d? | finish no earlier than 2010-09-17 | R5 | 1648h | 1648h | IWLAN_Mob_UEConTest | 24 | Qualcomm | Patrick Stupar (pstupar@qualcomm.com) | Rel-8 | 46 | Ingbert | IWLAN_Mob_UEConTest | 34.108, 34.123-1, 34.123-2, 34.123-3 | WLAN | RP-100740 |
| 4081 | 1081 | **Enhancements for Voice Group Call Service (VGCS) Applications (EVA)** |  | 919d? | 2006-03-15 A | 2009-09-18 A | 100% | 2006-03-15 | 2009-09-18 | 919d? |  | S1; C1; C4; G2 | 45559.5h | 45559.5h | EVA |  | Nortel | Amar Deol (deola@nortelnetworks.com) | Rel-8 |  | Alain | EVA |  |  |  |
| 4082 | 1081.1 | SA1 aspects of EVA |  | 191d? | 2006-03-15 A | 2006-12-06 A | 100% | 2006-03-15 | 2006-12-06 | 191d? | finish no earlier than 2006-12-06 | S1 | 1528h | 1528h | EVA |  | Nortel | Amar Deol (deola@nortelnetworks.com) | Rel-8 |  | Alain |  | 42.068 |  |  |
| 4083 | 1081.2 | VGCS/VBS and GPRS Interactions |  | 145d? | 2007-09-03 A | 2008-03-21 A | 100% | 2007-09-03 | 2008-03-21 | 145d? | finish no earlier than 2008-03-21 | S1 | 1160h | 1160h | EVA |  | Huawei | Ling Liu | Rel-8 | 37 | Alain |  | 42.068, 42.069 |  |  |
| 4084 | 1081.3 | CT1 aspects of EVA |  | 862d? | 2006-06-02 A | 2009-09-18 A | 100% | 2006-06-02 | 2009-09-18 | 862d? | finish no earlier than 2009-12-04 | C1 | 6887.53h | 6887.53h | EVA |  | Nortel | milanpa@nortel.com | Rel-8 |  | Frederic |  | 43.068, 44.068 |  |  |
| 4085 | 1081.4 | CT4 aspects of EVA |  | 391d? | 2006-06-02 A | 2007-11-30 A | 100% | 2006-06-02 | 2007-11-30 | 391d? | finish no earlier than 2007-06-01 | C4 | 3128h | 3128h | EVA |  | Nortel |  | Rel-8 |  | Kimmo |  | 29.002 |  |  |
| 4086 | 1081.5 | GERAN2 aspects of EVA |  | 431d? | 2006-06-30 A | 2008-02-22 A | 100% | 2006-06-30 | 2008-02-22 | 431d? | finish no earlier than 2008-02-22 | G2 | 3448h | 3448h | EVA |  | Nortel | frank.billenkamp@nortel.com | Rel-8 |  | Gert |  | 44.018, 48.008 |  |  |

Notes:
- 4061: CP#43 completed
- 4062: CP#43 completed
- 4063: CP#43 completed
- 4064: CP#42 completed
- 4065: Triggered by Study UID_7048 (MRFC)
- 4066: CP#42 completed
- 4067: CP#42 completed
- 4068: CP#56 completed
- 4069: CP#43 completed. Triggered by Study TR 23.820 (FS_IMS_RP) UID_350018
- 4070: CP#43 completed
- 4071: CP#43 completed
- 4072: CP#43 completed. Triggered by UID_360030 (FS_IMS_ASIO)
- 4073: CP#43 completed
- 4074: SP#36 completed
- 4075: CP#43 completed
- 4076: CP#42 completed
- 4077: CP#43 completed
- 4078: SP#40 completed
- 4079: CP#43 completed
- 4080: RP#49 completed. Testing for Rel-8 UID_400013 CT1 aspects of mobility between 3GPP WLAN Interworking and 3GPP Systems (24.327)
- 4081: CP#45 completed
- 4082: SP#38 completed
- 4083: SP#39 completed
- 4084: CP#45 completed
- 4085: CP#38 completed
- 4086: GP#37 completed

| ID | WBS | Task | Type | Duration | Start | Finish | Complete | Baseline start | Baseline finish | Baseline duration | Constraint | Resources | Work | Actual work | Acronym | WI rapporteur name | WI rapporteur e-mail | Release | MCC resp | Acronym_3GU_Export | Impacted TSs and TRs | TSG stopped | Special Focus Doc | TSG approved | PCG approved | Status Report |
| --- | --- | --- | --- | --- | --- | --- | --- | --- | --- | --- | --- | --- | --- | --- | --- | --- | --- | --- | --- | --- | --- | --- | --- | --- | --- | --- |
| 4087 | 1082 | **Personal Network Management** |  | 955d? | 2005-07-11 A | 2009-03-06 A | 100% | 2005-07-11 | 2009-03-06 | 955d? |  | S1; C1; S3 | 46368h | 46368h | PNM | Vodafone | armin.toepfer@vodafone.com | Rel-8 | Alain | PNM |  |  |  |  |  |  |
| 4088 | 1082.1 | Stage 1 for PNM |  | 276d? | 2005-07-11 A | 2006-07-31 A | 100% | 2005-07-11 | 2006-07-31 | 276d? | start no earlier than 2005-07-11 | S1 | 2208h | 2208h | PNM | Vodafone | armin.toepfer@vodafone.com | Rel-8 | Alain |  | 22.259 |  |  |  |  |  |
| 4089 | 1082.2 | Stage 2 for PNM |  | 445d? | 2007-03-26 A | 2008-12-05 A | 100% | 2007-03-26 | 2008-12-05 | 445d? | finish no earlier than 2008-12-05 | C1 | 3560h | 3560h | PNM | Vodafone | yang.lu@vodafone.com | Rel-8 | Frederic |  | 23.259 |  |  |  |  |  |
| 4090 | 1082.3 | **Stage 3 for PNM** |  | 510d? | 2007-03-26 A | 2009-03-06 A | 100% | 2007-03-26 | 2009-03-06 | 510d? |  | C1; C4 | 15800h | 15800h | PNM | Vodafone | yang.lu@vodafone.com | Rel-8 | Frederic |  |  |  |  |  |  |  |
| 4091 | 1082.3.1 | CT1 aspects of Stage 3 PNM |  | 510d? | 2007-03-26 A | 2009-03-06 A | 100% | 2007-03-26 | 2009-03-06 | 510d? | finish no earlier than 2008-12-05 | C1 | 4080h | 4080h | PNM | Vodafone | yang.lu@vodafone.com | Rel-8 | Frederic |  | 24.259, 24.229 |  |  |  |  |  |
| 4092 | 1082.3.2 | Deleted - CT4 aspects of Stage 3 PNM |  | 445d? | 2007-03-26 A | 2008-12-05 A | 100% | 2007-03-26 | 2008-12-05 | 445d? | finish no earlier than 2008-12-11 | C4 | 3560h | 3560h | PNM | Vodafone | yang.lu@vodafone.com | Rel-8 | Kimmo |  |  | CP-42 |  |  |  |  |
| 4093 | 1082.4 | Key establishment between a UICC hosting device and a remote device |  | 235d? | 2006-12-06 A | 2007-10-30 A | 100% | 2006-12-06 | 2007-10-30 | 235d? | finish no earlier than 2007-10-30 | S3 | 1880h | 1880h | PNM | Ericsson | Vesa.Lehtovirta@ericsson.com | Rel-8 | Mirko |  | 33.259 |  |  |  |  |  |
| 4094 | 1082.5 | Deleted - Actual Requirements of PNM | milestone | 0d? | 2007-03-26 A | 2007-03-26 A | 100% | 2007-03-26 | 2007-03-26 | 0d? | finish no earlier than 2007-03-26 | C1 |  |  | PNM | Ericsson |  | Rel-8 | Frederic |  |  | SP-37 |  |  |  |  |
| 4095 | 1083 | **eCall Data Transfer** |  | 637d? | 2006-09-28 A | 2009-03-06 A | 100% | 2006-09-28 | 2009-03-06 | 637d? |  | S1; C1 | 14840h | 14840h | EData | Airbiquity | rrobinson@airbiquity.com | Rel-8 | Alain | EData |  |  | Public Safety (I-A) |  |  |  |
| 4096 | 1083.1 | eData Requirements |  | 380d? | 2006-09-28 A | 2008-03-12 A | 100% | 2006-09-28 | 2008-03-12 | 380d? | finish no earlier than 2006-12-07 | S1 | 3040h | 3040h | EData | Airbiquity | rrobinson@airbiquity.com | Rel-8 | Alain |  | 22.101, 22.105 |  | Public Safety (I-A) | 37 |  |  |
| 4097 | 1083.2 | Transfer of data during an emergency call |  | 201d? | 2008-05-30 A | 2009-03-06 A | 100% | 2008-05-30 | 2009-03-06 | 201d? | finish no earlier than 2009-03-06 | C1 | 1608h | 1608h | EData | T-Mobile | Dieter Jacobsohn | Rel-8 | Frederic |  | 24.008 |  | Public Safety (I-A) | 40 | 21 |  |
| 4098 | 1084 | eCall data transfer Phase 2: Comparison of alternative in-band modem solutions and standardization of one in-band modem solution |  | 472d? | 2007-12-06 A | 2009-09-24 A | 100% | 2007-12-06 | 2009-09-24 | 472d? | finish no earlier than 2009-09-24 | S4 | 3768.09h | 3768.09h | eCall_Phase2 | Airbiquity | lhong@airbiquity.com & rrobinson@airbiquity.com | Rel-8 | Paolo | eCall_Phase2 | 26.267, 26.268, 26.269, 26.967, 26.969 |  | Public Safety (I-A) |  |  |  |
| 4099 | 1085 | eCall Conformance Testing |  | 261d? | 2009-09-04 A | 2010-09-03 A | 100% | 2009-09-04 | 2010-09-03 | 261d? | finish no earlier than 2010-09-03 | G3new | 2088h | 2088h | eCall_MSTest | Ericsson, Qualcomm | Vikrant Jain (vikrantj@qualcomm.com) | Rel-8 | Ingbert | eCall_MSTest | 51.010-1, 51.010-2 |  | Public Safety (I-A) | 45 | 23 |  |
| 4100 | 1086 | Conformance Test Aspects – non-modem procedures of eCall sessions in UTRA |  | 186d? | 2009-09-18 A | 2010-06-04 A | 100% | 2009-09-18 | 2010-06-04 | 186d? | finish no earlier than 2010-06-04 | R5 | 1488h | 1488h | UMTS_eCall_UEConTest | Ericsson, Qualcomm | Shubhang Vora (svora@qualcomm.com) | Rel-8 | Ingbert | UMTS_eCall_UEConTest | 34.108, 34.123-1, 34.123-2, 34.123-3 |  | Public Safety (I-A) | 45 | 23 | RP-100489 |
| 4101 | 1087 | **IP Interconnection of Services** |  | 668d? | 2006-08-16 A | 2009-03-06 A | 100% | 2006-08-16 | 2009-03-06 | 668d? |  | S1; S2; S5; C3 | 44240h | 44240h | IPinterc | Telefónica O2 | chris.friel@O2.com | Rel-8 | Alain | IPinterc |  |  |  | 38 | 21 |  |
| 4102 | 1087.1 | Stage 1 for IPinterc |  | 70d? | 2007-12-06 A | 2008-03-12 A | 100% | 2007-12-06 | 2008-03-12 | 70d? | start no earlier than 2007-12-06 | S1 | 560h | 560h | IPinterc | Telefónica O2 | chris.friel@O2.com | Rel-8 | Alain |  | 22.101, 22.228 |  |  | 38 | 21 |  |
| 4103 | 1087.2 | **System enhancements for interconnection interfaces between two IMSs** |  | 668d? | 2006-08-16 A | 2009-03-06 A | 100% | 2006-08-16 | 2009-03-06 | 668d? |  | S2; S5; C3 | 22304h | 22304h | IMS_NNI | Telecom Italia | Mario Madella (mario.madella@telecomitalia.it) | Rel-8 | Maurice | IMS_NNI |  |  |  |  |  |  |
| 4104 | 1087.2.1 | Stage 2 for IMS_NNI |  | 120d? | 2007-06-22 A | 2007-12-06 A | 100% | 2007-06-22 | 2007-12-06 | 120d? | finish no earlier than 2007-12-21 | S2 | 960h | 960h | IMS_NNI | Telecom Italia | Mario Madella (mario.madella@telecomitalia.it) | Rel-8 | Maurice |  | 23.002, 23.228 |  |  |  |  |  |
| 4105 | 1087.2.2 | IMS inter-operator service interconnection interface |  | 461d? | 2007-06-01 A | 2009-03-06 A | 100% | 2007-06-01 | 2009-03-06 | 461d? | finish no earlier than 2009-03-06 | C3 | 3688h | 3688h | FBI2-IOPSI | Telecom Italia | antonio.ascolese@telecomitalia.it | Rel-8 | Adrian | FBI2-IOPSI | 29.865, 29.165 |  |  |  |  |  |
| 4106 | 1087.2.3 | Charging harmonization for NGN between 3GPP and ATIS-TMOC |  | 51d? | 2006-09-28 A | 2006-12-07 A | 100% | 2006-09-28 | 2006-12-07 | 51d? | finish no earlier than 2006-12-07 | S5 | 408h | 408h | FBI2-TISP2-CH | Amdocs | yishai.brown@amdocs.com | Rel-8 | Mirko | FBI2-TISP2-CH | 32.297 |  |  |  |  |  |
| 4107 | 1087.2.4 | Deleted - Protocol impact of FBI for TISPAN R2 |  | 152d? | 2006-08-16 A | 2007-03-15 A | 100% | 2006-08-16 | 2007-03-15 | 152d? | finish no earlier than 2007-03-15 | C1 | 1216h | 1216h | FBI2-TISP2-c1 | Ericsson |  | Rel-8 | Frederic | FBI2-TISP2-c1 |  | SP-38 |  |  |  |  |
| 4108 | 1087.2.5 | Deleted (never approved) - Stage 2 of FBI for TISPAN R2 - Rel 8 | milestone | 0d? | 2007-11-30 A | 2007-11-30 A | 100% | 2007-11-30 | 2007-11-30 | 0d? | finish no earlier than 2007-11-30 | S2 |  |  | FBI2-TISP2-s2 | Nokia Siemens Networks |  | Rel-8 | Maurice | FBI2-TISP2-s2 |  | SP-36 |  |  |  |  |
| 4109 | 1088 | **Support of (G)MSC-S – (G)MSC-S Nc Interface based on the SIP-I protocol** |  | 386d? | 2007-09-14 A | 2009-03-06 A | 100% | 2007-09-14 | 2009-03-06 | 386d? |  | C4; C3 | 14960h | 14960h | SIP_Nc | Vodafone | David.Hutton@vodafone.com | Rel-8 | Kimmo | SIP_Nc |  |  |  |  |  |  |
| 4110 | 1088.1 | Stage 1 for SIP_Nc (covered by Feature IPinterc) |  | 70d? | 2007-12-06 A | 2008-03-12 A | 100% | 2007-12-06 | 2008-03-12 | 70d? | start no earlier than 2007-12-06 | S1 | 560h | 560h | SIP_Nc | Telefónica O2 | chris.friel@O2.com | Rel-8 | Alain |  | 22.101, 22.228 |  |  | 41 | 21 |  |
| 4111 | 1088.2 | SIP-I based circuit-switched core network; Stage 2 |  | 321d? | 2007-09-14 A | 2008-12-05 A | 100% | 2007-09-14 | 2008-12-05 | 321d? | finish no earlier than 2008-12-11 | C4 | 2568h | 2568h | SIP_Nc-St2 | Vodafone | David.Hutton@vodafone.com | Rel-8 | Kimmo | SIP_Nc-St2 | 23.231, 23.153, 23.205 |  |  |  |  |  |
| 4112 | 1088.3 | Application of SIP-I Protocols to Circuit Switched (CS) core network architecture; Stage 3 |  | 321d? | 2007-09-14 A | 2008-12-05 A | 100% | 2007-09-14 | 2008-12-05 | 321d? | finish no earlier than 2008-12-11 | C4 | 2568h | 2568h | SIP_Nc-St3C4 | Vodafone | David.Hutton@vodafone.com | Rel-8 | Kimmo | SIP_Nc-St3 | 29.231, 29.232, 29.332 |  |  |  |  |  |
| 4113 | 1088.4 | Interworking between the 3GPP CS domain with SIP-I as signalling protocol and other networks |  | 386d? | 2007-09-14 A | 2009-03-06 A | 100% | 2007-09-14 | 2009-03-06 | 386d? | finish no earlier than 2009-03-06 | C3 | 3088h | 3088h | SIP_Nc-St3C3 | Nokia Siemens Networks | Thomas.Belling@nsn.com | Rel-8 | Adrian |  | 29.235, 23.172, 23.202, 29.007, 29.163, 29.414 |  |  |  |  |  |

Notes:
- 4087: CP#43 completed
- 4088: SP#31 completed
- 4089: CP#42 completed
- 4090: CP#43 completed
- 4091: CP#43 completed
- 4092: CP#42 no impact on CT4 specs
- 4093: SP#37 completed
- 4094: SP#37 stopped
- 4095: SP#39 completed. Linked to SA4 Feature UID_34042 (eCall_Phase2)
- 4096: SP#39 completed
- 4097: CP#43 completed
- 4098: SP#45 completed. Triggered by Study UID_360015 (eCALLIBMS). Linked to SA1 Feature UID_330005 (EData)
- 4099: GP#47 completed. GP#43 WID approved. Testing for Rel-8 eCall_Phase2 (UID_34042) and EData (UID_330005)
- 4100: RP#48 completed. Testing for Rel-8 eCall_Phase2 (UID_34042) and Edata (UID_330005)
- 4101: SP#43 completed
- 4102: SP#39 completed.
- 4103: CP#43 completed
- 4104: SP#38 completed
- 4105: CP#43 completed
- 4106: SP#34 completed
- 4107: SP#38 stopped
- 4108: SP#36 stopped
- 4109: CP#43 completed. Stage 1 in Feature UID_380060 (IPinterc). CP#40 updated WID CP-070517=>CP-080282
- 4110: 22/07/08 Created. Stage 1 for SIP_Nc (covered by SA1 Feature UID_380060 Ipinterc)
- 4111: CP#42 completed
- 4112: CP#42 completed
- 4113: CP#43 completed. CP#42 target 12/08=>03/09

| ID | WBS | Task | Type | Duration | Start | Finish | Complete | Baseline start | Baseline finish | Baseline duration | Constraint | Resources | Work | Actual work | Acronym | WI rapporteur name | WI rapporteur e-mail | Release | TSG approved | MCC resp | Special Focus Doc | Acronym_3GU_Export | Impacted TSs and TRs | PCG approved | Status Report |
| --- | --- | --- | --- | --- | --- | --- | --- | --- | --- | --- | --- | --- | --- | --- | --- | --- | --- | --- | --- | --- | --- | --- | --- | --- | --- |
| 4114 | 1089 | **Earthquake and Tsunami Warning System** |  | 440d? | 2007-09-10 A | 2009-05-15 A | 100% | 2007-09-10 | 2009-05-15 | 440d? |  | S1; S2; C1; C4; G2 | 21280h | 21280h | ETWS | NTT DoCoMo | kitaharar@nttdocomo.co.jp | Rel-8 | 37 | Alain | Public Safety (I-A) | ETWS |  |  |  |
| 4115 | 1089.1 | Stage 1 for ETWS |  | 133d? | 2007-09-10 A | 2008-03-12 A | 100% | 2007-09-10 | 2008-03-12 | 133d? | finish no earlier than 2008-03-12 | S1 | 1064h | 1064h | ETWS | NTT DoCoMo | kitaharar@nttdocomo.co.jp | Rel-8 | 37 | Alain | Public Safety (I-A) |  | 22.168 |  |  |
| 4116 | 1089.2 | SA2 aspects of ETWS |  | 179d? | 2008-01-14 A | 2008-09-18 A | 100% | 2008-01-14 | 2008-09-18 | 179d? | finish no earlier than 2008-09-08 | S2 | 1432h | 1432h | ETWS | NTT DoCoMo | tanakai@nttdocomo.co.jp | Rel-8 | 38 | Maurice | Public Safety (I-A) |  | 23.828, 23.401 | 21 |  |
| 4117 | 1089.3 | CT1 aspects of ETWS |  | 50.5d? | 2008-05-30 A | 2008-12-05 A | 100% | 2008-05-30 | 2008-12-05 | 50.5d? | finish no earlier than 2008-12-05 | C1 | 404h | 404h | ETWS | NTT DoCoMo | yamashitahi@s1.nttdocomo.co.jp | Rel-8 | 40 | Frederic | Public Safety (I-A) |  | 23.041 | 21 |  |
| 4118 | 1089.4 | CT4 aspects of ETWS |  | 50.5d? | 2008-09-26 A | 2008-12-05 A | 100% | 2008-09-26 | 2008-12-05 | 50.5d? | finish no earlier than 2008-12-05 | C4 | 404h | 404h | ETWS | NTT DoCoMo | yamashitahi@s1.nttdocomo.co.jp | Rel-8 | 40 | Kimmo | Public Safety (I-A) |  | 29.168 | 21 |  |
| 4119 | 1089.5 | ETWS primary notification message definition in GERAN |  | 47d? | 2009-03-12 A | 2009-05-15 A | 100% | 2009-03-12 | 2009-05-15 | 47d? | finish no earlier than 2009-05-15 | G2 | 376h | 376h | ETWS | Ericsson | claes-goran.persson@ericsson.com | Rel-8 | 43 | Gert | Public Safety (I-A) |  | 44.018, 44.060 | 22 |  |
| 4120 | 1090 | Conformance Test Aspects – UMTS Earthquake and Tsunami Warning System (ETWS) FDD |  | 207d? | 2009-05-29 A | 2010-03-12 A | 100% | 2009-05-29 | 2010-03-12 | 207d? | finish no earlier than 2010-03-12 | R5 | 1656h | 1656h | ETWS_UMTS_UEConTestFDD | NTT DoCoMo | Makoto Ito (itohm@nttdocomo.co.jp) | Rel-8 | 44 | Ingbert | Public Safety (I-A) | ETWS_UMTS_UEConTestFDD | 34.108, 34.123-1, 34.123-2 | 23 | RP-100068 |
| 4121 | 1091 | **In Case of Emergency numbers storage and easy access on UICC** |  | 519d? | 2007-03-13 A | 2009-03-06 A | 100% | 2007-03-13 | 2009-03-06 | 519d? |  | S1; C6 | 14552h | 14552h | ICE | Vodafone | armin.toepfer@vodafone.com | Rel-8 | 38 | Alain |  | ICE |  | 21 |  |
| 4122 | 1091.1 | Stage 1 for ICE |  | 262d? | 2007-03-13 A | 2008-03-12 A | 100% | 2007-03-13 | 2008-03-12 | 262d? | finish no earlier than 2008-03-12 | S1 | 2096h | 2096h | ICE | Vodafone | armin.toepfer@vodafone.com | Rel-8 | 38 | Alain |  |  | 22.030, 22.101 | 21 |  |
| 4123 | 1091.2 | CT6 aspects of ICE |  | 519d? | 2007-03-13 A | 2009-03-06 A | 100% | 2007-03-13 | 2009-03-06 | 519d? | finish no earlier than 2009-03-06 | C6 | 4152h | 4152h | ICE | Vodafone | armin.toepfer@vodafone.com | Rel-8 | 38 | Xavier |  |  | 31.102 | 21 |  |
| 4124 | 1092 | Local Charging Zone Requirements |  | 380d? | 2006-09-28 A | 2008-03-12 A | 100% | 2006-09-28 | 2008-03-12 | 380d? | finish no earlier than 2006-12-07 | S1 | 3040h | 3040h | LCZR | China Mobile | liuhongyfw@chinamobile.com | Rel-8 |  | Alain |  | LCZR | 22.115 |  |  |
| 4125 | 1093 | **Customized Alerting Tone (CAT) service** |  | 729d? | 2006-12-06 A | 2009-09-18 A | 100% | 2006-12-06 | 2009-09-18 | 729d? |  | S1; C1; C3; C4 | 39854h | 39854h | CAT | China Mobile | fenglingjuan@chinamobile.com | Rel-8 | 34 | Alain |  | CAT |  |  |  |
| 4126 | 1093.1 | Stage 1 for CAT |  | 207d? | 2006-12-06 A | 2007-09-20 A | 100% | 2006-12-06 | 2007-09-20 | 207d? | start no earlier than 2006-12-06 | S1 | 1656h | 1656h | CAT | China Mobile | fenglingjuan@chinamobile.com | Rel-8 | 37 | Alain |  |  | 22.182 |  |  |
| 4127 | 1093.2 | TISPAN requirements for customized multimedia information services |  | 71d? | 2007-09-03 A | 2007-12-10 A | 100% | 2007-09-03 | 2007-12-10 | 71d? | finish no earlier than 2007-12-10 | S1 | 568h | 568h | TISCMI | China Mobile | fenglingjuan@chinamobile.com | Rel-8 | 37 | Alain |  | TISCMI | 22.182 |  |  |
| 4128 | 1093.3 | **IMS CAT Supplementary Service** |  | 399d? | 2008-03-12 A | 2009-09-18 A | 100% | 2008-03-12 | 2009-09-18 | 399d? |  | C1; C3 | 10814.4h | 10814.4h | CAT-SS | Nortel | milanpa@nortel.com | Rel-8 | 39 | Frederic |  | CAT-SS |  | 21 |  |
| 4129 | 1093.3.1 | IMS CAT SS |  | 164d? | 2008-04-21 A | 2008-12-04 A | 100% | 2008-04-21 | 2008-12-04 | 164d? | finish no earlier than 2008-12-05 | C1 | 1312h | 1312h | CAT-SS | Nortel | milanpa@nortel.com | Rel-8 | 39 | Frederic |  |  | 24.182 | 21 |  |
| 4130 | 1093.3.2 | CAT solution for voice and video call in CS domain |  | 389.8d? | 2008-03-12 A | 2009-09-18 A | 100% | 2008-03-12 | 2009-09-18 | 389.8d? | finish no earlier than 2009-09-11 | C3 | 3118.4h | 3118.4h | CAT-SS | Nortel | milanpa@nortel.com | Rel-8 | 39 | Adrian |  |  | 29.163 | 21 |  |
| 4131 | 1093.4 | **CAT Service in 3GPP CS domain** |  | 126d? | 2008-09-12 A | 2009-03-06 A | 100% | 2008-09-12 | 2009-03-06 | 126d? |  | C4; C1 | 3487.6h | 3487.6h | CAT-3G_CS | China Mobile | zhaoyuyi@chinamobile.com | Rel-8 | 41 | Kimmo |  | CAT-3G_CS | 23.205, 23.231, 29.002 | 21 |  |
| 4132 | 1093.4.1 | CT4 part of CAT Service in 3GPP CS domain |  | 126d? | 2008-09-12 A | 2009-03-06 A | 100% | 2008-09-12 | 2009-03-06 | 126d? | finish no earlier than 2009-03-06 | C4 | 1008h | 1008h | CAT-3G_CS | China Mobile | zhaoyuyi@chinamobile.com | Rel-8 | 41 | Kimmo |  |  | 23.205, 23.231, 29.002 | 21 |  |
| 4133 | 1093.4.2 | CT1 part of CAT Service in 3GPP CS domain |  | 57.95d? | 2008-09-12 A | 2008-12-05 A | 100% | 2008-09-12 | 2008-12-05 | 57.95d? | start no earlier than 2008-09-12 | C1 | 463.6h | 463.6h | CAT-3G_CS | China Mobile | zhaoyuyi@chinamobile.com | Rel-8 | 41 | Frederic |  |  | 24.008, 23.014 | 21 |  |
| 4134 | 1094 | **Service-Level Interworking for Messaging Services** |  | 509d? | 2007-03-26 A | 2009-03-06 A | 100% | 2007-03-26 | 2009-03-06 | 509d? |  | S1; S2; C3; C1 | 20800h | 20800h | MESSIW | Huawei | ling.liu@huawei.com; duanxiaoqin@huawei.com | Rel-8 | 34 | Alain |  | MESSIW |  |  |  |
| 4135 | 1094.1 | Stage 1 for MESSIW | milestone | 0d? | 2007-03-26 A | 2007-03-26 A | 100% | 2007-03-26 | 2007-03-26 | 0d? | finish no earlier than 2007-12-01 | S1 |  |  | MESSIW | Huawei | ling.liu@huawei.com | Rel-8 |  | Alain |  |  | 22.105, 22.340 |  |  |
| 4136 | 1094.2 | Stage 2 for MESSIW |  | 227d? | 2007-04-26 A | 2008-03-07 A | 100% | 2007-04-26 | 2008-03-07 | 227d? | finish no earlier than 2008-03-07 | S2 | 1816h | 1816h | MESSIW | Huawei | patrice.hede@huawei.com | Rel-8 |  | Maurice |  |  | 23.811, 23.204 |  |  |
| 4137 | 1094.3 | CT3 part of Stage 3 for MESSIW |  | 201d? | 2008-05-30 A | 2009-03-06 A | 100% | 2008-05-30 | 2009-03-06 | 201d? | finish no earlier than 2008-12-05 | C3 | 1608h | 1608h | MESSIW | Huawei | xupeili@huawei.com | Rel-8 | 40 | Adrian |  |  | 29.311 | 21 |  |
| 4138 | 1094.4 | CT1 part of Stage 3 for MESSIW |  | 136d? | 2008-05-30 A | 2008-12-05 A | 100% | 2008-05-30 | 2008-12-05 | 136d? | finish no earlier than 2008-12-12 | C1 | 1088h | 1088h | MESSIW | Huawei | xupeili@huawei.com | Rel-8 | 40 | Frederic |  |  | 24.229 | 21 |  |

Notes:
- 4114: SP#43 Larger scope Feature UID_380057 (PWS) moved to Rel-9
- 4115: SP#39 completed
- 4116: SP#41 completed
- 4117: CP#42 completed
- 4118: CP#42 completed
- 4119: SP#44 completed with CT1 help (GERAN2 LS_in SP-090154)
- 4120: RP#47 completed. Testing for Rel-8 ETWS UID_370051
- 4121: CP#43 completed (ICE Graphics not included in Rel-8)
- 4122: SP#39 Stage 1 completed
- 4123: CP#43 completed (ICE Graphics not in Rel-8 / not explicitly in SA1 WID either)
- 4124: SP#39 Stage 1 completed
- 4125: CP#45 completed
- 4126: -
- 4127: SP#38 completed
- 4128: -
- 4129: CP#42 completed
- 4130: CP#45 completed. Triggered by Study UID_360031 (TR 29.882)
- 4131: -
- 4132: CP#43 completed. Triggered by Study UID_360031 (TR 29.882)
- 4133: CP#42 completed. Triggered by Study UID_360031 (TR 29.882)
- 4134: CP#43 completed
- 4135: SP#35 completed
- 4136: SP#39 completed
- 4137: CP#43 completed
- 4138: CP#42 completed

| ID | WBS | Task | Duration | Start | Finish | Complete | Baseline start | Baseline finish | Baseline duration | Constraint | Resources | Work | Actual work | Acronym | WI rapporteur name | WI rapporteur e-mail | Release | TSG approved | MCC resp | Special Focus Doc | Acronym_3GU_Export | Impacted TSs and TRs | PCG stopped | TSG stopped | PCG approved |
| --- | --- | --- | --- | --- | --- | --- | --- | --- | --- | --- | --- | --- | --- | --- | --- | --- | --- | --- | --- | --- | --- | --- | --- | --- | --- |
| 4139 | 1095 | **Multimedia Priority Service** | 858d? | 2006-06-08 A | 2009-09-18 A | 100% | 2006-06-08 | 2009-09-18 | 858d? |  | S1; C1; C3; C4 | 43016h | 43016h | PRIOR_EMR | Telcordia | jgarraha@telcordia.com | Rel-8 | 34 | Alain | Public Safety (I-A) | PRIOR |  |  |  |  |
| 4140 | 1095.1 | Service Requirements for PRIOR | 391d? | 2006-06-08 A | 2007-12-06 A | 100% | 2006-06-08 | 2007-12-06 | 391d? | finish no earlier than 2007-11-30 | S1 | 3128h | 3128h | PRIOR_EMR | Telcordia | jgarraha@telcordia.com | Rel-8 | 32 | Alain | Public Safety (I-A) | PRIOR-EMR | New 22.153 |  |  |  |
| 4141 | 1095.2 | CT1 part of Stage 3 for PRIOR | 732d? | 2006-12-01 A | 2009-09-18 A | 100% | 2006-12-01 | 2009-09-18 | 732d? | finish no earlier than 2009-09-18 | C1 | 5856h | 5856h | PRIOR_EMR | Alcatel-Lucent | Keith Drage (drage@alcatel-lucent.com) | Rel-8 | 34 | Frederic | Public Safety (I-A) |  | 24.229 |  |  |  |
| 4142 | 1095.3 | CT4 part of Stage 3 for PRIOR | 381d? | 2007-09-21 A | 2009-03-06 A | 100% | 2007-09-21 | 2009-03-06 | 381d? | finish no earlier than 2009-03-06 | C4 | 3048h | 3048h | PRIOR_EMR | Alcatel-Lucent | Keith Drage (drage@alcatel-lucent.com) | Rel-8 | 37 | Kimmo | Public Safety (I-A) |  | 23.008, 29.228, 29.229 |  |  |  |
| 4143 | 1095.4 | Deleted - Stage 3 for PRIOR | 441d? | 2007-09-21 A | 2009-05-29 A | 100% | 2007-09-21 | 2009-05-29 | 441d? | finish no earlier than 2009-05-29 | C3 | 3528h | 3528h | PRIOR-EMR | Alcatel-Lucent | Keith Drage (drage@alcatel-lucent.com) | Rel-8 | 37 | Adrian | Public Safety (I-A) |  | 29.212, 29.213, 29.214, 29.163 | PCG-23 | CP-44 |  |
| 4144 | 1096 | **Open Service Access (OSA) Rel-8** | 202d? | 2007-08-23 A | 2008-05-30 A | 100% | 2007-08-23 | 2008-05-30 | 202d? |  | S1; C5 | 25528h | 25528h | OSA8 | Orange | Song Dong | Rel-8 |  | Alain |  | OSA8 |  |  |  |  |
| 4145 | 1096.1 | OSA Stage 1 - Service Requirements | 145d? | 2007-08-23 A | 2008-03-12 A | 100% | 2007-08-23 | 2008-03-12 | 145d? | finish no earlier than 2007-12-04 | S1 | 1160h | 1160h | OSA8 | Orange, AePONA | Song Dong | Rel-8 |  | Alain |  |  | 22.127 |  |  |  |
| 4146 | 1096.2 | OSA Stage 1 - NGN Service Requirement | 140d? | 2007-09-03 A | 2008-03-14 A | 100% | 2007-09-03 | 2008-03-14 | 140d? | finish no earlier than 2008-03-14 | S1 | 1120h | 1120h | OSA8-IMSReq | Orange | Song Dong | Rel-8 | 37 | Alain |  | OSA8-IMS | 22.127 |  |  |  |
| 4147 | 1096.3 | **Rel-8 OSA Stage 2/3 enhancements** | 157d? | 2007-10-25 A | 2008-05-30 A | 100% | 2007-10-25 | 2008-05-30 | 157d? |  | C5 | 20016h | 20016h | OSA8-IMS | Alcatel-Lucent | unmehopa@alcatel-lucent.com | Rel-8 |  | Kimmo |  |  | 23.198, 29.198, 29.199 |  |  |  |
| 4148 | 1096.3.1 | Deleted - Ensure Parlay-X composable with identity management frameworks, in particular Liberty Alliance | 157d? | 2007-10-25 A | 2008-05-30 A | 100% | 2007-10-25 | 2008-05-30 | 157d? | finish no earlier than 2008-12-25 | C5 | 1256h | 1256h |  | Ericsson | catherine.mulligan@ericsson.com | Rel-8 | 37 | Kimmo |  |  | existing 29.199-xy | PCG-21 | CP-40 | 21 |
| 4149 | 1096.3.2 | Parlay-X Content Management web service (store/manage meta-data) | 157d? | 2007-10-25 A | 2008-05-30 A | 100% | 2007-10-25 | 2008-05-30 | 157d? | finish no earlier than 2008-12-04 | C5 | 1256h | 1256h | OSA8-IMS | Alcatel-Lucent | unmehopa@alcatel-lucent.com | Rel-8 | 37 | Kimmo |  |  | 29.199-21 |  |  |  |
| 4150 | 1096.3.3 | Parlay-X Policy web service | 157d? | 2007-10-25 A | 2008-05-30 A | 100% | 2007-10-25 | 2008-05-30 | 157d? | finish no earlier than 2008-12-04 | C5 | 1256h | 1256h | OSA8-IMS | Alcatel-Lucent | unmehopa@alcatel-lucent.com | Rel-8 | 37 | Kimmo |  |  | 29.199-22 |  |  |  |
| 4151 | 1096.3.4 | Parlay-X Terminal status web service | 157d? | 2007-10-25 A | 2008-05-30 A | 100% | 2007-10-25 | 2008-05-30 | 157d? | finish no earlier than 2008-05-30 | C5 | 1256h | 1256h | OSA8-IMS | Alcatel-Lucent | unmehopa@alcatel-lucent.com | Rel-8 | 37 | Kimmo |  |  | 29.199-08 |  |  |  |
| 4152 | 1096.3.5 | Deleted - Identify communication format used by a particular application | 157d? | 2007-10-25 A | 2008-05-30 A | 100% | 2007-10-25 | 2008-05-30 | 157d? | finish no earlier than 2008-05-30 | C5 | 1256h | 1256h |  | Ericsson | catherine.mulligan@ericsson.com | Rel-8 | 37 | Kimmo |  |  | existing 29.199-xy | PCG-21 | CP-40 | 21 |
| 4153 | 1096.3.6 | Deleted - Security on User Profile Management - reuse GUP API (22.127 CR 0084 S1-071794) | 128d? | 2007-12-05 A | 2008-05-30 A | 100% | 2007-12-05 | 2008-05-30 | 128d? | finish no earlier than 2008-12-25 | C5 | 1024h | 1024h |  | Telecom Italia | vincenzo.amorino@telecomitalia.it | Rel-8 | 38 | Kimmo |  |  | PXWS Framework | PCG-21 | CP-40 | 21 |
| 4154 | 1096.3.7 | Deleted - Privacy on Subscriber Identity (Liberty Alliance, OASIS) (22.127 CR 0085 S1-071835) | 128d? | 2007-12-05 A | 2008-05-30 A | 100% | 2007-12-05 | 2008-05-30 | 128d? | finish no earlier than 2008-12-25 | C5 | 1024h | 1024h |  | Telecom Italia | vincenzo.amorino@telecomitalia.it | Rel-8 | 38 | Kimmo |  |  | PXWS Framework | PCG-21 | CP-40 | 21 |
| 4155 | 1096.3.8 | Deleted - Topology Hiding (22.127 CR 0086 S1-071838) | 128d? | 2007-12-05 A | 2008-05-30 A | 100% | 2007-12-05 | 2008-05-30 | 128d? | finish no earlier than 2008-12-25 | C5 | 1024h | 1024h |  | Telecom Italia | vincenzo.amorino@telecomitalia.it | Rel-8 | 38 | Kimmo |  |  | PXWS Framework | PCG-21 | CP-40 | 21 |
| 4156 | 1096.3.9 | Deleted - Subscriber event notification (22.127 CR 0087 S1-071836) | 128d? | 2007-12-05 A | 2008-05-30 A | 100% | 2007-12-05 | 2008-05-30 | 128d? | finish no earlier than 2008-12-25 | C5 | 1024h | 1024h |  | Telecom Italia | vincenzo.amorino@telecomitalia.it | Rel-8 | 38 | Kimmo |  |  | PXWS Framework | PCG-21 | CP-40 | 21 |
| 4157 | 1096.3.10 | Deleted - Event notification (22.127 CR 0088 S1-071762) | 128d? | 2007-12-05 A | 2008-05-30 A | 100% | 2007-12-05 | 2008-05-30 | 128d? | finish no earlier than 2008-12-25 | C5 | 1024h | 1024h |  | Telecom Italia | vincenzo.amorino@telecomitalia.it | Rel-8 | 38 | Kimmo |  |  | PXWS Framework | PCG-21 | CP-40 | 21 |
| 4158 | 1096.3.11 | Deleted - Access policy (22.127 CR 0089 S1-071763) | 128d? | 2007-12-05 A | 2008-05-30 A | 100% | 2007-12-05 | 2008-05-30 | 128d? | finish no earlier than 2008-12-25 | C5 | 1024h | 1024h |  | Telecom Italia | vincenzo.amorino@telecomitalia.it | Rel-8 | 38 | Kimmo |  |  | PXWS Framework | PCG-21 | CP-40 | 21 |
| 4159 | 1096.3.12 | Deleted - API usage accounting (22.127 CR 0090 S1-071792) | 128d? | 2007-12-05 A | 2008-05-30 A | 100% | 2007-12-05 | 2008-05-30 | 128d? | finish no earlier than 2008-12-25 | C5 | 1024h | 1024h |  | Telecom Italia | vincenzo.amorino@telecomitalia.it | Rel-8 | 38 | Kimmo |  |  | PXWS Framework | PCG-21 | CP-40 | 21 |
| 4160 | 1096.3.13 | Presence alignment with OMA and IETF (22.127 CR 0092 S1-071764) | 128d? | 2007-12-05 A | 2008-05-30 A | 100% | 2007-12-05 | 2008-05-30 | 128d? | finish no earlier than 2008-05-30 | C5 | 1024h | 1024h | OSA8-IMS | Alcatel-Lucent | unmehopa@alcatel-lucent.com | Rel-8 | 38 | Kimmo |  |  | 29.199-14/13 |  |  | 21 |
| 4161 | 1096.3.14 | Deleted - Service identification (22.127 CR 0095 S1-071837) | 128d? | 2007-12-05 A | 2008-05-30 A | 100% | 2007-12-05 | 2008-05-30 | 128d? | finish no earlier than 2008-05-30 | C5 | 1024h | 1024h |  | Ericsson | catherine.mulligan@ericsson.com | Rel-8 | 38 | Kimmo |  |  | existing 29.199-xy | PCG-21 | CP-40 | 21 |
| 4162 | 1096.3.15 | Framework Enterprise Operator (Service Subscription function) | 102d? | 2008-01-10 A | 2008-05-30 A | 100% | 2008-01-10 | 2008-05-30 | 102d? | finish no earlier than 2008-05-30 | C5 | 816h | 816h | OSA8-IMS | Alcatel-Lucent | unmehopa@alcatel-lucent.com | Rel-8 | 39 | Kimmo |  |  | 29.198-03 |  |  | 21 |
| 4163 | 1096.3.16 | Mobility Emergency Location | 102d? | 2008-01-10 A | 2008-05-30 A | 100% | 2008-01-10 | 2008-05-30 | 102d? | finish no earlier than 2008-05-30 | C5 | 816h | 816h | OSA8-IMS | Alcatel-Lucent | unmehopa@alcatel-lucent.com | Rel-8 | 39 | Kimmo |  |  | 29.198-06 |  |  | 21 |
| 4164 | 1096.3.17 | Connectivity Manager SCF | 102d? | 2008-01-10 A | 2008-05-30 A | 100% | 2008-01-10 | 2008-05-30 | 102d? |  | C5 | 816h | 816h | OSA8-IMS | Alcatel-Lucent | unmehopa@alcatel-lucent.com | Rel-8 | 39 | Kimmo |  |  | 29.198-10 |  |  | 21 |
| 4165 | 1096.3.18 | PAM Presence Agent | 102d? | 2008-01-10 A | 2008-05-30 A | 100% | 2008-01-10 | 2008-05-30 | 102d? | finish no earlier than 2008-05-30 | C5 | 816h | 816h | OSA8-IMS | Alcatel-Lucent | unmehopa@alcatel-lucent.com | Rel-8 | 39 | Kimmo |  |  | 29.198-14 |  |  | 21 |

Notes:
- 4139: CP#45 completed
- 4140: SP#38 completed
- 4141: CP#45 completed
- 4142: CP#43 completed
- 4143: CP#44 stopped (Reason: No Rel-8 solution expected (LS sent to SA2, but not prioritized in SA2)
- 4144: SP#40 maintenance & new OSA work moved to OMA. Rel-9 onwards 3GPP references to 22.127 changed to OMA Parlay Service Access Requirements (OMA-RD-Parlay_Service_Access-V1_0-20100427-A).
- 4145: SP#40 maintenance & new OSA work moved to OMA. Rel-9 onwards 3GPP references to 22.127 changed to OMA Parlay Service Access Requirements (OMA-RD-Parlay_Service_Access-V1_0-20100427-A).
- 4146: SP#40 maintenance & new OSA work moved to OMA
- 4147: SP#40 maintenance & new OSA work moved to OMA
- 4148: CP#40: Work moved to OMA
- 4149: CP#40 completed
- 4150: CP#40 completed
- 4151: CP#40 completed
- 4152: CP#40: Work moved to OMA
- 4153: SP#38 SP-070853 R8 CRs 22.127 OSA Stage 1. CP#40: Work moved to OMA
- 4154: SP#38 SP-070853 R8 CRs 22.127 OSA Stage 1. CP#40: Work moved to OMA
- 4155: SP#38 SP-070853 R8 CRs 22.127 OSA Stage 1. CP#40: Work moved to OMA
- 4156: SP#38 SP-070853 R8 CRs 22.127 OSA Stage 1. CP#40: Work moved to OMA
- 4157: SP#38 SP-070853 R8 CRs 22.127 OSA Stage 1. CP#40: Work moved to OMA
- 4158: SP#38 SP-070853 R8 CRs 22.127 OSA Stage 1. CP#40: Work moved to OMA
- 4159: SP#38 SP-070853 R8 CRs 22.127 OSA Stage 1. CP#40: Work moved to OMA
- 4160: CP#40 completed
- 4161: SP#38 SP-070853 R8 CRs 22.127 OSA Stage 1. CP#40: Work moved to OMA
- 4162: CP#40 completed
- 4163: CP#40 completed
- 4164: CP#40 completed
- 4165: CP#40 completed

| ID | WBS | Task | Duration | Start | Finish | Complete | Remaining | Baseline start | Baseline finish | Baseline duration | Total slack | Constraint | Resources | Work | Actual work | Acronym | WI rapporteur name | Release | MCC resp | Acronym_3GU_Export | TSG approved | PCG approved | Status Report | Special Focus Doc |
| --- | --- | --- | --- | --- | --- | --- | --- | --- | --- | --- | --- | --- | --- | --- | --- | --- | --- | --- | --- | --- | --- | --- | --- | --- |
| 4166 | 1097 | **Paging Permission with Access Control (PPACR)** | 389d? | 2007-06-12 A | 2008-12-05 A | 100% |  | 2007-06-12 | 2008-12-05 | 389d? |  |  | S1; C1 | 9000h | 9000h | PPACR | NTT DoCoMo | Rel-8 | Alain | PPACR |  |  |  |  |
| 4167 | 1097.1 | Stage 1 for PPACR | 69d? | 2007-06-12 A | 2007-09-14 A | 100% |  | 2007-06-12 | 2007-09-14 | 69d? |  | finish no earlier than 2007-09-14 | S1 | 552h | 552h | PPACR-S1 | NTT DoCoMo | Rel-8 | Alain | PPACR-S1 | 37 |  |  |  |
| 4168 | 1097.2 | Stage 3 for PPACR (CT1) | 278d? | 2007-11-14 A | 2008-12-05 A | 100% |  | 2007-11-14 | 2008-12-05 | 278d? |  | finish no earlier than 2008-12-05 | C1 | 2224h | 2224h | PPACR-CT1 | NTT DoCoMo | Rel-8 | Frederic | PPACR-CT1 | 38 | 21 |  |  |
| 4169 | 1098 | Conformance Test Aspects – Paging Permission with Access Control (PPAC) | 61d? | 2010-09-17 A | 2010-12-10 A | 100% |  | 2010-09-17 | 2010-12-10 | 61d? |  | finish no earlier than 2010-12-10 | R5 | 488h | 488h | PPAC_UEConTest | NTT DoCoMo | Rel-8 | Ingbert | PPAC_UEConTest | 49 | 25 | RP-101074 |  |
| 4170 | 1099 | **Charging for multi-phases services** | 70d? | 2007-12-06 A | 2008-03-12 | 99% | 0d? | 2007-12-06 | 2008-03-12 | 70d? | 0d |  | S1 | 560h | 560h | CHRGMPH | Telecom Italia | Rel-8 | Alain | CHRGMPH | 38 | 21 |  |  |
| 4171 | 1099.1 | Stage 1 for CHRGMPH | 70d? | 2007-12-06 A | 2008-03-12 A | 100% |  | 2007-12-06 | 2008-03-12 | 70d? |  | start no earlier than 2007-12-06 | S1 | 560h | 560h | CHRGMPH-s1 | Telecom Italia | Rel-8 | Alain | CHRGMPH-s1 | 38 | 21 |  |  |
| 4172 | 1100 | **Home NodeB / eNodeB** | 327d? | 2007-12-06 A | 2009-03-06 A | 100% |  | 2007-12-06 | 2009-03-06 | 327d? |  |  | S1; C1; C4 | 10952h | 10952h | HomeNB | Vodafone | Rel-8 | Alain | HomeNB | 38 | 21 |  | HNB |
| 4173 | 1100.1 | Stage 1 for Home NodeB / eNodeB | 70d? | 2007-12-06 A | 2008-03-12 A | 100% |  | 2007-12-06 | 2008-03-12 | 70d? |  | start no earlier than 2007-12-06 | S1 | 560h | 560h | HomeNB-S1 | Vodafone | Rel-8 | Alain | HomeNB-S1 | 38 | 21 |  | HNB |
| 4174 | 1100.2 | Support of Closed Subscriber Group (CSG) | 66d? | 2008-12-05 A | 2009-03-06 A | 100% |  | 2008-12-05 | 2009-03-06 | 66d? |  | finish no earlier than 2009-03-06 | C4 | 528h | 528h |  | CT#42 | Rel-8 | Kimmo |  | 42 | 22 |  | HNB |
| 4175 | 1100.3 | CSG and Idle Mode Mobility for LTE Home eNodeB | 126d? | 2008-09-12 A | 2009-03-06 A | 100% |  | 2008-09-12 | 2009-03-06 | 126d? |  | finish no earlier than 2009-03-06 | C1 | 1008h | 1008h | HomeNB-LTE | Huawei | Rel-8 | Frederic | HomeNB-LTE | 41 | 21 |  | HNB |
| 4176 | 1100.4 | CSG and Idle Mode Mobility for 3G Home NodeB | 126d? | 2008-09-12 A | 2009-03-06 A | 100% |  | 2008-09-12 | 2009-03-06 | 126d? |  | finish no earlier than 2009-03-06 | C1 | 1008h | 1008h | HomeNB-3G | Qualcomm | Rel-8 | Frederic | HomeNB-3G | 41 | 21 |  | HNB |
| 4177 | 1101 | **UTRA HNB** | 326d? | 2008-03-07 A | 2009-06-04 A | 100% |  | 2008-03-07 | 2009-06-04 | 326d? |  |  | RP; S5 | 11008h | 11008h | HNB |  | Rel-8 | Issam | HNB | 39 | 21 |  | HNB |
| 4178 | 1101.1 | Support of UTRA HNB | 201d? | 2008-05-30 A | 2009-03-06 A | 100% |  | 2008-05-30 | 2009-03-06 | 201d? |  | finish no earlier than 2009-03-06 | R2 | 1608h | 1608h | HNB-supp | Huawei | Rel-8 | Yong-Jun | HNB-supp | 40 | 21 | RP-090040 | HNB |
| 4179 | 1101.2 | UTRAN Architecture for 3G HNB | 136d? | 2008-05-30 A | 2008-12-05 A | 100% |  | 2008-05-30 | 2008-12-05 | 136d? |  | finish no earlier than 2008-12-05 | R3 | 1088h | 1088h | HNB-arch | Alcatel-Lucent | Rel-8 | Juha | HNB-arch | 40 | 21 | RP-090042 | HNB |
| 4180 | 1101.3 | FDD Home NodeB RF requirements | 261d? | 2008-03-07 A | 2009-03-06 A | 100% |  | 2008-03-07 | 2009-03-06 | 261d? |  | finish no earlier than 2009-03-06 | R4 | 2088h | 2088h | HNB-RF | Motorola | Rel-8 | Issam | HNB-RF | 39 | 21 | RP-090041 | HNB |
| 4181 | 1101.4 | 3G Home NodeB OAM&P Type 1 Management Interface | 127d? | 2008-12-11 A | 2009-06-04 A | 100% |  | 2008-12-11 | 2009-06-04 | 127d? |  | finish no earlier than 2009-06-04 | S5 | 1008h | 1008h | HNB-3G_OAM | Huawei | Rel-8 | Mirko | HNB-3G_OAM | 42 | 22 |  | HNB |
| 4182 | 1102 | **UTRA HNB – UE Conformance Testing** | 327d? | 2009-03-06 A | 2010-06-04 A | 100% |  | 2009-03-06 | 2010-06-04 | 327d? |  |  | R5 | 5224h | 5224h | HNB-UEConTest |  | Rel-8 | Ingbert | HNB-UEConTest | 43 | 22 |  | HNB |
| 4183 | 1102.1 | Conformance Test Aspects – UTRA HNB (FDD) | 326d? | 2009-03-06 A | 2010-06-04 A | 100% |  | 2009-03-06 | 2010-06-04 | 326d? |  | finish no earlier than 2010-06-04 | R5 | 2608h | 2608h | HNB-UEConTestFDD | Huawei | Rel-8 | Ingbert | HNB-UEConTestFDD | 43 | 22 | RP-100482 | HNB |
| 4184 | 1103 | Lawful Interception in the 3GPP Rel-8 | 524d? | 2007-03-12 A | 2009-03-12 A | 100% |  | 2007-03-12 | 2009-03-12 | 524d? |  | finish no earlier than 2009-03-12 | S3 | 4192h | 4192h | LI8 | BMWI, Verizon | Rel-8 | Mirko | LI8 |  |  |  |  |
| 4185 | 1104 | **Generic Bootstrapping Architecture Push Function** | 258d? | 2008-03-12 A | 2009-03-06 A | 100% |  | 2008-03-12 | 2009-03-06 | 258d? |  |  | S3; C1; C4 | 10596.8h | 10596.8h | GBAPush | Ericsson | Rel-8 | Mirko | GBAPush | 39 | 21 |  |  |
| 4186 | 1104.1 | SA3 part of GBAPush (33.223) | 193d? | 2008-03-12 A | 2008-12-05 A | 100% |  | 2008-03-12 | 2008-12-05 | 193d? |  | finish no earlier than 2008-12-05 | S3 | 1544h | 1544h | GBAPush | Ericsson | Rel-8 | Mirko |  | 39 | 21 |  |  |
| 4187 | 1104.2 | CT1 part of GBAPush | 178.8d? | 2008-03-12 A | 2009-03-06 A | 100% |  | 2008-03-12 | 2009-03-06 | 178.8d? |  | finish no earlier than 2009-03-06 | C1 | 1430.4h | 1430.4h | GBAPush | Ericsson | Rel-8 | Frederic |  | 39 | 21 |  |  |
| 4188 | 1104.3 | CT4 part of GBAPush | 178.8d? | 2008-03-12 A | 2009-03-06 A | 100% |  | 2008-03-12 | 2009-03-06 | 178.8d? |  | finish no earlier than 2009-03-06 | C4 | 1430.4h | 1430.4h | GBAPush | Ericsson | Rel-8 | Kimmo |  | 39 | 21 |  |  |
| 4189 | 1105 | Requirements and Test methods for Wideband Terminals | 197d? | 2008-03-12 A | 2008-12-11 A | 100% |  | 2008-03-12 | 2008-12-11 | 197d? |  | start no earlier than 2008-03-12 | S4 | 1576h | 1576h | RETEM_WB_T | FT, Ericsson | Rel-8 | Paolo | RETEM_WB_T |  |  |  |  |
| 4190 | 1106 | Extending PSS and MBMS User Services for optimized Mobile TV | 266d? | 2007-12-06 A | 2008-12-11 A | 100% |  | 2007-12-06 | 2008-12-11 | 266d? |  | finish no earlier than 2008-12-11 | S4 | 2128h | 2128h | PSS_MBMS_OMTV | Ericsson | Rel-8 | Paolo | PSS_MBMS_OMTV |  |  |  |  |

Notes:
- 4166: CP#42 completed. Triggered by Study UID_330016 (PPAC). / WI rapporteur e-mail: Morita Takashi
- 4167: SP#37 completed / Impacted TSs and TRs: 22.011 / WI rapporteur e-mail: Morita Takashi
- 4168: CP#42 completed / Impacted TSs and TRs: 24.008, 23.122, 24.301
- 4169: RP#50 completed / Impacted TSs and TRs: UTRA 34.108, 34.123-1, 34.123-2, 34.123-3 / WI rapporteur e-mail: Takao.Shimizu.rp@nttdocomo.com
- 4170: SP#39 Stage 1 completed / Impacted TSs and TRs: 22.115 / WI rapporteur e-mail: Marco.DeLuca1@telecomitalia.it
- 4171: SP#39 completed / Impacted TSs and TRs: 22.115 / WI rapporteur e-mail: Marco.DeLuca1@telecomitalia.it
- 4172: CP#43 completed / WI rapporteur e-mail: John Watson
- 4173: SP#39 completed / Impacted TSs and TRs: 22.011, 22.115 / WI rapporteur e-mail: John Watson
- 4174: CP#43 completed. SP#42 SP-080874 22.011CR0141 confirmed Requirement to support roaming subscribers with CSG home network subscription but did NOT confirmed requirement for home network independent support of roamers in CSG / Impacted TSs and TRs: 29.002, 29.272, 23.008, 23.003 / WI rapporteur e-mail: Hannu Hietalahti
- 4175: CP#43 completed / Impacted TSs and TRs: 23.122, new (24.285, 24.301, 24.801) / WI rapporteur e-mail: zhang.peng@huawei.com
- 4176: CP#43 completed / Impacted TSs and TRs: 23.122, 24.008, new 24.285 / WI rapporteur e-mail: Osok Song
- 4177: SP#44 completed
- 4178: RP#43 completed / Impacted TSs and TRs: 25.304, 25.306, 25.331, new 25.367 / WI rapporteur e-mail: Yang Xudong (yangxudong@huawei.com)
- 4179: RP#42 completed / Impacted TSs and TRs: 25.401, 25.410, 25.412, 25.413, 25.414, 25.415, new (25.467, 25.468, 25.469) / WI rapporteur e-mail: Martin Warner (mw15@alcatel-lucent.com)
- 4180: RP#43 completed / Impacted TSs and TRs: 25.104, 25.141, new 25.967 / WI rapporteur e-mail: Ying Cai (yingcai@motorola.com)
- 4181: SP#44 completed. Complements work in BroadBand Forum / Impacted TSs and TRs: new (32.581, 32.582, 32.583, 32.584) / WI rapporteur e-mail: Zou Lan (zlan@huawei.com)
- 4182: RP#48 FDD completed. Testing for Feature UID_390033 UTRA HNB
- 4183: RP#48 completed / Impacted TSs and TRs: 34.108, 34.123-1, 34.123-2, 34.123-3 / WI rapporteur e-mail: Trica Li (trica_li@huawei.com)
- 4184: SP#43 completed / Impacted TSs and TRs: 33.106, 33.107, 33.108 / WI rapporteur e-mail: berthold.wilhelm@bnetza.de, ron_ryan@verizon.net
- 4185: CP#43 completed / WI rapporteur e-mail: Rolf Blom
- 4186: SP#42 completed 33.223 as Rel-8. TS 33.224 moved to Rel-9 under new UID_420039 / Impacted TSs and TRs: 33.223 / WI rapporteur e-mail: Rolf Blom
- 4187: CP#43 completed / Impacted TSs and TRs: 24.109 / WI rapporteur e-mail: Rolf Blom
- 4188: CP#43 completed / Impacted TSs and TRs: 29.109 / WI rapporteur e-mail: Rolf Blom
- 4189: SP#42 completed. SP#39 WID approved. / Impacted TSs and TRs: 26.131, 26.132 / WI rapporteur e-mail: stephane.ragot@orange-ftgroup.com, wanqing.shi@sonyericsson.com
- 4190: SP#42 completed. SP#38 WID approved. / Impacted TSs and TRs: 26.234, 26.346, 26.946 / WI rapporteur e-mail: thorsten.lohmar@ericsson.com

| ID | WBS | Task | Duration | Start | Finish | Complete | Baseline start | Baseline finish | Baseline duration | Constraint | Resources | Work | Actual work | Acronym | PCG approved | WI rapporteur name | Release | TSG approved | MCC resp | Acronym_3GU_Export | TSG stopped | PCG stopped |
| --- | --- | --- | --- | --- | --- | --- | --- | --- | --- | --- | --- | --- | --- | --- | --- | --- | --- | --- | --- | --- | --- | --- |
| 4191 | 1107 | **Encoding formats, transport formats and media description signalling for interworking, QoE, and other enhancements to MTSI-MHI** | 331d? | 2007-12-06 A | 2009-03-12 A | 100% | 2007-12-06 | 2009-03-12 | 331d? |  | S4; C3; C4 | 14936h | 14936h | MTSI_eMHI | 21 | Ericsson, Qualcomm | Rel-8 | 40 | Paolo | MTSI_eMHI |  |  |
| 4192 | 1107.1 | MTSI Video - Dynamic Rate Adaptation/Signalling of Image Size | 331d? | 2007-12-06 A | 2009-03-12 A | 100% | 2007-12-06 | 2009-03-12 | 331d? | finish no earlier than 2009-03-12 | S4 | 2648h | 2648h | MTSI_eMHI-DRASIS |  | Qualcomm, Samsung | Rel-8 |  | Paolo | MTSI_eMHI-DRASIS |  |  |
| 4193 | 1107.2 | CT3 part of Enhancement of interworking between MTSI and CS networks | 201d? | 2008-05-30 A | 2009-03-06 A | 100% | 2008-05-30 | 2009-03-06 | 201d? | finish no earlier than 2009-03-06 | C3 | 1608h | 1608h | MTSI_eMHI | 21 | Huawei | Rel-8 | 40 | Adrian |  |  |  |
| 4194 | 1107.3 | CT4 part of Enhancement of interworking between MTSI and CS networks | 201d? | 2008-05-30 A | 2009-03-06 A | 100% | 2008-05-30 | 2009-03-06 | 201d? | finish no earlier than 2009-03-06 | C4 | 1608h | 1608h | MTSI_eMHI | 21 | Huawei | Rel-8 | 40 | Kimmo |  |  |  |
| 4195 | 1107.4 | Deleted - CT1 part of Enhancement of interworking between MTSI and CS networks | 141d? | 2008-05-30 A | 2008-12-12 A | 100% | 2008-05-30 | 2008-12-12 | 141d? | start no earlier than 2008-05-30 | C1 | 1128h | 1128h | MTSI_eMHI | 21 | Huawei | Rel-8 | 40 | Frederic |  | CP-42 |  |
| 4196 | 1108 | **Rel-8 Operations, Administration, Maintenance and Provisioning (OAM&P)** | 1445d? | 2007-06-07 A | 2012-12-07 A | 100% | 2007-06-07 | 2012-12-07 | 1445d? |  | S5; C1; C4; IETF | 120270h | 120270h | OAM8 |  |  | Rel-8 | 34 | Mirko | OAM8 |  |  |
| 4197 | 1108.1 | **Rel-8 Network Infrastructure Management** | 653d? | 2007-06-07 A | 2009-12-04 A | 100% | 2007-06-07 | 2009-12-04 | 653d? |  | S5 | 19464h | 19464h | OAM8-NIM |  |  | Rel-8 | 34 | Mirko | OAM8-NIM |  |  |
| 4198 | 1108.1.1 | Telecom Management Methodology | 461d? | 2007-06-07 A | 2009-03-12 A | 100% | 2007-06-07 | 2009-03-12 | 461d? | finish no earlier than 2009-03-12 | S5 | 3688h | 3688h | OAM8-NIM |  | Ericsson | Rel-8 |  | Mirko |  |  |  |
| 4199 | 1108.1.2 | Advanced Alarming on Itf-N | 266d? | 2007-06-07 A | 2008-06-12 A | 100% | 2007-06-07 | 2008-06-12 | 266d? | finish no earlier than 2008-12-11 | S5 | 2128h | 2128h | OAM8-NIM |  | Nokia Siemens Networks | Rel-8 |  | Mirko |  |  |  |
| 4200 | 1108.1.3 | CN CS Bearer Transport Network (BTN) relative NRM | 266d? | 2007-06-07 A | 2008-06-12 A | 100% | 2007-06-07 | 2008-06-12 | 266d? | finish no earlier than 2008-12-11 | S5 | 2128h | 2128h | OAM8-NIM |  | China Mobile | Rel-8 |  | Mirko |  |  |  |
| 4201 | 1108.1.4 | Alignment with eTOM and M.3060 architectural concepts | 210d? | 2008-02-22 A | 2008-12-11 A | 100% | 2008-02-22 | 2008-12-11 | 210d? | start no earlier than 2008-02-22 | S5 | 1680h | 1680h | OAM8-NIM | 21 | TeliaSonera | Rel-8 | 39 | Mirko |  |  |  |
| 4202 | 1108.1.5 | IRP SOAP Solution Sets | 201d? | 2008-06-05 A | 2009-03-12 A | 100% | 2008-06-05 | 2009-03-12 | 201d? | finish no earlier than 2009-03-12 | S5 | 1608h | 1608h | OAM8-NIM | 21 | Ericsson | Rel-8 | 40 | Mirko |  |  |  |
| 4203 | 1108.1.6 | Create missing specifications for IRP XML definitions | 52d? | 2009-09-24 A | 2009-12-04 A | 100% | 2009-09-24 | 2009-12-04 | 52d? | finish no earlier than 2010-03-12 | S5 | 416h | 416h | OAM8-NIM | 23 | ZTE | Rel-8 | 45 | Mirko |  |  |  |
| 4204 | 1108.1.7 | Deleted - End point modelling for reference point | 324d? | 2007-09-17 A | 2008-12-11 A | 100% | 2007-09-17 | 2008-12-11 | 324d? | finish no earlier than 2008-12-11 | S5 | 2592h | 2592h | OAM8-NIM |  | Motorola | Rel-8 | 37 | Mirko |  | SP-41 | PCG-21 |
| 4205 | 1108.2 | **Rel-8 Performance Management** | 461d? | 2007-06-07 A | 2009-03-12 A | 100% | 2007-06-07 | 2009-03-12 | 461d? |  | S5 | 13712h | 13712h | OAM8-PM |  |  | Rel-8 | 34 | Mirko | OAM8-PM |  |  |
| 4206 | 1108.2.1 | IP bearer network Performance measurement definitions | 396d? | 2007-06-07 A | 2008-12-11 A | 100% | 2007-06-07 | 2008-12-11 | 396d? | finish no earlier than 2008-12-11 | S5 | 3168h | 3168h | OAM8-PM |  | China Mobile | Rel-8 |  | Mirko |  |  |  |
| 4207 | 1108.2.2 | HSUPA performance measurements | 396d? | 2007-06-07 A | 2008-12-11 A | 100% | 2007-06-07 | 2008-12-11 | 396d? | finish no earlier than 2008-12-11 | S5 | 3168h | 3168h | OAM8-PM |  | China Mobile | Rel-8 |  | Mirko |  |  |  |
| 4208 | 1108.2.3 | Key Performance Indicators (KPIs) for UMTS and GSM | 461d? | 2007-06-07 A | 2009-03-12 A | 100% | 2007-06-07 | 2009-03-12 | 461d? | finish no earlier than 2009-03-12 | S5 | 3688h | 3688h | OAM8-PM |  | China Mobile | Rel-8 |  | Mirko |  |  |  |
| 4209 | 1108.3 | **Rel-8 Trace Management** | 1249d? | 2008-03-07 A | 2012-12-07 A | 100% | 2008-03-07 | 2012-12-07 | 1249d? |  | C1; C4; IETF | 40854.4h | 40854.4h | OAM8-Trace |  |  | Rel-8 | 34 | Mirko | OAM8-Trace |  |  |
| 4210 | 1108.3.1 | CT1 part of Service Level Tracing in IMS | 196d? | 2008-03-07 A | 2008-12-05 A | 100% | 2008-03-07 | 2008-12-05 | 196d? | finish no earlier than 2008-12-05 | C1 | 1568h | 1568h | OAM8-Trace |  | Vodafone | Rel-8 |  | Frederic |  |  |  |
| 4211 | 1108.3.2 | (IETF) Service Level Tracing in IMS (draft-dawes-sipping-debug) | 717d? | 2008-03-07 A | 2012-12-07 A | 100% | 2008-03-07 | 2012-12-07 | 717d? | finish no earlier than 2012-12-07 | C1-IETF | 5736h | 5736h | OAM8-Trace | 27 | Peter Dawes | Rel-8 | 52 | Frederic |  |  |  |
| 4212 | 1108.3.3 | (IETF) Service Level Tracing in IMS (draft-dawes-sipping-debug-event) | 98d? | 2008-03-07 A | 2011-12-09 A | 100% | 2008-03-07 | 2011-12-09 | 98d? | finish no earlier than 2011-12-09 | C1-IETF | 768.04h | 768.04h | OAM8-Trace | 27 | Peter Dawes | Rel-8 | 53 | Frederic |  |  |  |
| 4213 | 1108.3.4 | CT4 part of Service Level Tracing in IMS | 175.4d? | 2008-03-07 A | 2008-12-05 A | 100% | 2008-03-07 | 2008-12-05 | 175.4d? | finish no earlier than 2008-12-05 | C4 | 1403.2h | 1403.2h | OAM8-Trace | 21 | Vodafone | Rel-8 | 40 | Frederic |  |  |  |
| 4214 | 1108.3.5 | Deleted - CT3 part of Service Level Tracing in IMS | 175.4d? | 2008-03-07 A | 2008-12-05 A | 100% | 2008-03-07 | 2008-12-05 | 175.4d? | finish no earlier than 2008-12-05 | C3 | 1403.2h | 1403.2h | OAM8-Trace | 21 | Vodafone | Rel-8 | 40 | Adrian |  | CP-42 | PCG-22 |

Notes:
- 4191: TSG#43 completed / WI rapporteur e-mail: olle.franceschi@ericsson.com, nleung@qualcomm.com
- 4192: SP#43 completed / Impacted TSs and TRs: 26.114 / WI rapporteur e-mail: nleung@qualcomm.com & kyunghun.jung@samsung.com
- 4193: CP#43 completed / Impacted TSs and TRs: 29.163 / WI rapporteur e-mail: Tingfang Tang (tagna_online@huawei.com)
- 4194: CP#43 completed / Impacted TSs and TRs: 29.332 / WI rapporteur e-mail: Tingfang Tang (tagna_online@huawei.com)
- 4195: CP#42 stopped (No CT1-impact). WID updated CP-080422=>CP-080774 / WI rapporteur e-mail: Tingfang Tang (tagna_online@huawei.com)
- 4196: OAM8 is an umbrella Feature also for OAM&P related TEI8 type of changes that are not part of any other dedicated feature/WI / Impacted TSs and TRs: TR 30.818
- 4197: -
- 4198: SP#43 completed / Impacted TSs and TRs: 32.155, 32.153 / WI rapporteur e-mail: thomas.tovinger@ericsson.com
- 4199: SP#40 completed / Impacted TSs and TRs: 32.121, 32.122, 32.123 / WI rapporteur e-mail: SUERBAUM, Clemens
- 4200: SP#40 completed / Impacted TSs and TRs: 32.632, 32.633, 32.635 / WI rapporteur e-mail: Li Jian (lijian@chinamobile.com)
- 4201: SP#42 completed / Impacted TSs and TRs: 32.101/2, 32-series / WI rapporteur e-mail: tommy.berggren@teliasonera.com
- 4202: SP#43 completed / Impacted TSs and TRs: 32.111-7, 32.617, 32.417, 32.367, 32.347, 32.111-1, 32.111-2, 32.111-3, 32.111-5, 32.307, 32.317, 32.341, 32.342, 32.343, 32.345, 32.361, 32.362, 32.363, 32.365, 32.411, 32.412, 32.413, 32.415, 32.611, 32.612, 32.613, 32.615, 32.625 / WI rapporteur e-mail: edwin.tse@ericsson.com
- 4203: SP#46 completed. Create missing XML definitions specs for IRPs (Advanced Alarm Management, Communication Surveillance, Self-Configuration of Network Elements, Software Management) needed for implementation of Rel-8 Notification Log IRP (TS 32.33x) / Impacted TSs and TRs: new (32.125, 32.355, 32.505, 32.535), 32.150, 32.153, 32.335 / WI rapporteur e-mail: Shuqiang Huang (huangsq@zte.com.cn)
- 4204: SP#41 Work stopped. Contributions related to E-UTRAN/EPC to be submitted to UID_380036 E-UTRAN NRM IRP/ UID_380037 EPC NRM IRP / Impacted TSs and TRs: 32.152, 32.62/3/4x, 32.73x / WI rapporteur e-mail: Yizhi Yao (yzyao@motorola.com)
- 4205: - / WI rapporteur e-mail: Li Jian (lijian@chinamobile.com)
- 4206: SP#42 completed / Impacted TSs and TRs: 32.321, 32.322, 32.323, 32.325 / WI rapporteur e-mail: lilianyuan@chinamobile.com
- 4207: SP#42 completed / Impacted TSs and TRs: 32.405 / WI rapporteur e-mail: Li Jian (lijian@chinamobile.com)
- 4208: SP#43 completed / Impacted TSs and TRs: 32.410 / WI rapporteur e-mail: Li Jian (lijian@chinamobile.com), Liang Shuangchun (liangshuangchun@cmdi.chinamobile.com)
- 4209: -
- 4210: CP#42 completed / Impacted TSs and TRs: 24.323, 24.229 / WI rapporteur e-mail: peter.dawes@vodafone.com
- 4211: CP#58 Removed from Rel-8, Rel-9 and Rel-10 (Not completed internet-draft) / Impacted TSs and TRs: Rel-11 remains draft-dawes-dispatch-debug / WI rapporteur e-mail: peter.dawes@vodafone.com
- 4212: CP#54 Draft removed from 3GPP documentation, covered by draft-dawes-sipping-debug / Impacted TSs and TRs: draft-dawes-sipping-debug-event / WI rapporteur e-mail: peter.dawes@vodafone.com
- 4213: CP#42 completed / Impacted TSs and TRs: 29.228, 29.229 / WI rapporteur e-mail: peter.dawes@vodafone.com
- 4214: CP#42 stopped (No CT3-impact) / WI rapporteur e-mail: peter.dawes@vodafone.com

| ID | WBS | Task | Type | Duration | Start | Finish | Complete | Baseline start | Baseline finish | Baseline duration | Constraint | Resources | Work | Actual work | Acronym | Release | MCC resp | Acronym_3GU_Export | WI rapporteur name | WI rapporteur e-mail | PCG approved | TSG approved | PCG stopped | TSG stopped | Status Report |
| --- | --- | --- | --- | --- | --- | --- | --- | --- | --- | --- | --- | --- | --- | --- | --- | --- | --- | --- | --- | --- | --- | --- | --- | --- | --- |
| 4215 | 1109 | **Rel-8 Charging Management small Enhancements** |  | 716d? | 2006-03-16 A | 2008-12-11 A | 100% | 2006-03-16 | 2008-12-11 | 716d? |  | S5 | 12544h | 12544h | CH8 | Rel-8 | Mirko | CH8 |  |  |  |  |  |  |  |
| 4216 | 1109.1 | Online charging correlation |  | 457d? | 2006-03-16 A | 2007-12-14 A | 100% | 2006-03-16 | 2007-12-14 | 457d? | start no earlier than 2006-03-16 | S5 | 3656h | 3656h | CH8 | Rel-8 | Mirko |  | Orange | Chahine, Rony |  |  |  |  |  |
| 4217 | 1109.2 | SMS online charging |  | 137d? | 2007-06-07 A | 2007-12-14 A | 100% | 2007-06-07 | 2007-12-14 | 137d? | finish no earlier than 2007-12-14 | S5 | 1096h | 1096h | CH8 | Rel-8 | Mirko |  | Vodafone | Gavin.Wong@vodafone.com |  |  |  |  |  |
| 4218 | 1109.3 | Introduce Online Charging from SMS-SC into the SMS Charging Specifications |  | 61d? | 2008-09-18 A | 2008-12-11 A | 100% | 2008-09-18 | 2008-12-11 | 61d? | finish no earlier than 2008-12-11 | S5 | 488h | 488h | CH8 | Rel-8 | Mirko |  | Acision | erik.gebler@acision.com | 21 | 41 |  |  |  |
| 4219 | 1109.4 | Deleted - WLAN Offline Charging |  | 244d? | 2008-01-07 A | 2008-12-11 A | 100% | 2008-01-07 | 2008-12-11 | 244d? | finish no earlier than 2008-12-11 | S5 | 1952h | 1952h | CH8 | Rel-8 | Mirko |  | Alcatel-Lucent | maryse.gardella@alcatel-lucent.com | 21 | 38 | PCG-22 | SP-42 |  |
| 4220 | 1110 | **Conferencing enhancements for Mp interface** |  | 266d? | 2007-11-30 A | 2008-12-05 A | 100% | 2007-11-30 | 2008-12-05 | 266d? |  | C4 | 6384h | 6384h | eMp | Rel-8 | Kimmo | eMp | Huawei | Chencheng@huawei.com | 21 |  |  |  |  |
| 4221 | 1110.1 | Stage 2 for eMp |  | 266d? | 2007-11-30 A | 2008-12-05 A | 100% | 2007-11-30 | 2008-12-05 | 266d? | finish no earlier than 2008-12-11 | C4 | 2128h | 2128h | eMp | Rel-8 | Kimmo |  | Huawei | Chencheng@huawei.com | 21 | 38 |  |  |  |
| 4222 | 1110.2 | Stage 3 for eMp |  | 266d? | 2007-11-30 A | 2008-12-05 A | 100% | 2007-11-30 | 2008-12-05 | 266d? | finish no earlier than 2008-12-05 | C4 | 2128h | 2128h | eMp | Rel-8 | Kimmo |  | Huawei | Chencheng@huawei.com | 21 | 38 |  |  |  |
| 4223 | 1111 | **Contact Manager for 3GPP UICC applications** |  | 642d? | 2006-06-22 A | 2008-12-05 A | 100% | 2006-06-22 | 2008-12-05 | 642d? |  | C6 | 13352h | 13352h | eUPHBOOK | Rel-8 | Xavier | eUPHBOOK | Gemalto | Jacques.seif@gemalto.com |  |  |  |  |  |
| 4224 | 1111.1 | Requirements for Contact Manager |  | 392d? | 2006-06-22 A | 2007-12-21 A | 100% | 2006-06-22 | 2007-12-21 | 392d? | finish no earlier than 2007-12-21 | C6 | 3136h | 3136h | eUPHBOOK-St1 | Rel-8 | Xavier | eUPHBOOK-St1 | Gemalto | Jacques.seif@gemalto.com |  |  |  |  |  |
| 4225 | 1111.2 | External interface for eUPHBOOK |  | 220d? | 2007-05-07 A | 2008-03-07 A | 100% | 2007-05-07 | 2008-03-07 | 220d? | finish no earlier than 2008-03-07 | C6 | 1760h | 1760h | eUPHBOOK-Ext_Spec | Rel-8 | Xavier | eUPHBOOK-Ext_Spec | Gemalto | Jacques.seif@gemalto.com |  |  |  |  |  |
| 4226 | 1111.3 | Internal interface for eUPHBOOK |  | 415d? | 2007-05-07 A | 2008-12-05 A | 100% | 2007-05-07 | 2008-12-05 | 415d? | finish no earlier than 2008-12-05 | C6 | 3320h | 3320h | eUPHBOOK-Int_Spec | Rel-8 | Xavier | eUPHBOOK-Int_Spec | Gemalto | Jacques.seif@gemalto.com |  | 37 |  |  |  |
| 4227 | 1111.4 | Deleted - Implementation of eUPHBOOK | milestone | 0d? | 2007-06-21 A | 2007-06-21 A | 100% | 2007-06-21 | 2007-06-21 | 0d? | start no earlier than 2007-06-21 | C6 |  |  | eUPHBOOK-St23 | Rel-8 | Xavier | eUPHBOOK-St23 | Giesecke & Devrient | Claus Dietze |  |  |  | SP-33 |  |
| 4228 | 1112 | **Rel-8 LTE – 3G Long Term Evolution - Evolved Packet System RAN part** |  | 644d? | 2006-09-25 A | 2009-03-12 A | 100% | 2006-09-25 | 2009-03-12 | 644d? |  | RP; S5 | 50048h | 50048h | LTE | Rel-8 |  | LTE | NTT DoCoMo | Takehiro Nakamura (nakamurata@nttdocomo.co.jp) |  |  |  |  | RP-080741 |
| 4229 | 1112.1 | LTE – Physical Layer |  | 380d? | 2006-09-25 A | 2008-03-07 A | 100% | 2006-09-25 | 2008-03-07 | 380d? | finish no earlier than 2007-09-14 | R1 | 3040h | 3040h | LTE-Phys | Rel-8 | Patrick | LTE-Phys | NTT DoCoMo | Sadayuki Abeta |  |  |  |  | RP-080741 |
| 4230 | 1112.2 | LTE – Radio Interface Layer 2 and 3 Protocol Aspect |  | 575d? | 2006-09-25 A | 2008-12-05 A | 100% | 2006-09-25 | 2008-12-05 | 575d? | finish no earlier than 2008-12-11 | R2 | 4600h | 4600h | LTE-L23 | Rel-8 | Yong-Jun | LTE-L23 | Nokia Siemens Networks | benoist.sebire@nokia.com |  |  |  |  | RP-080741 |
| 4231 | 1112.3 | LTE – eUTRAN Interfaces |  | 575d? | 2006-09-25 A | 2008-12-05 A | 100% | 2006-09-25 | 2008-12-05 | 575d? | finish no earlier than 2008-12-11 | R3 | 4600h | 4600h | LTE-interfaces | Rel-8 | Juha | LTE-interfaces | Ericsson | Martin Israelsson |  |  |  |  | RP-080741 |
| 4232 | 1112.4 | LTE – Evolved UTRA and UTRAN RF Radio Transmission/Reception, System Performance Requirements and Conformance Testing |  | 575d? | 2006-09-25 A | 2008-12-05 A | 100% | 2006-09-25 | 2008-12-05 | 575d? | finish no earlier than 2008-12-11 | R4 | 4600h | 4600h | LTE-RF | Rel-8 | Issam | LTE-RF | Nokia Siemens Networks | Tuomo Saynajakangas |  |  |  |  | RP-080741 |
| 4233 | 1112.5 | LTE – FDD repeaters |  | 386d? | 2007-09-14 A | 2009-03-06 A | 100% | 2007-09-14 | 2009-03-06 | 386d? | finish no earlier than 2009-03-06 | R4 | 3088h | 3088h | LTE-Repeaters | Rel-8 | Issam | LTE-Repeaters | Powerwave Technologies, Andrew Wireless | ralf.michanikl@andrew.com, Alf.Ahlstrom@pwav.com |  | 37 |  |  | RP-090037 |
| 4234 | 1112.6 | **E-UTRAN Data Definitions** |  | 389d? | 2007-09-17 A | 2009-03-12 A | 100% | 2007-09-17 | 2009-03-12 | 389d? |  | S5 | 13096h | 13096h | E-UTRAN-OAM | Rel-8 | Mirko | E-UTRAN-OAM |  |  | 21 | 39 |  |  |  |
| 4235 | 1112.6.1 | Subscriber and Equipment Trace for E-UTRAN and EPC |  | 389d? | 2007-09-17 A | 2009-03-12 A | 100% | 2007-09-17 | 2009-03-12 | 389d? | finish no earlier than 2009-03-12 | S5 | 3112h | 3112h | E-UTRAN-OAM | Rel-8 | Mirko |  | Ericsson | robert.petersen@ericsson.com |  | 37 |  |  |  |
| 4236 | 1112.6.2 | E-UTRAN Network Resource Model (NRM) Integration Reference Point (IRP) |  | 309d? | 2008-01-07 A | 2009-03-12 A | 100% | 2008-01-07 | 2009-03-12 | 309d? | finish no earlier than 2009-03-12 | S5 | 2472h | 2472h | E-UTRAN-OAM | Rel-8 | Mirko |  | Ericsson | ELMDAHL, Per | 21 | 38 |  |  |  |
| 4237 | 1112.6.3 | Performance measurements for E-UTRAN |  | 275d? | 2008-02-22 A | 2009-03-12 A | 100% | 2008-02-22 | 2009-03-12 | 275d? | finish no earlier than 2009-03-12 | S5 | 2200h | 2200h | E-UTRAN-OAM | Rel-8 | Mirko |  | Motorola, Huawei | Yizhi Yao (yzyao@motorola.com) | 21 | 39 |  |  |  |
| 4238 | 1112.6.4 | Key Performance Indicators (KPIs) for E-UTRAN |  | 275d? | 2008-02-22 A | 2009-03-12 A | 100% | 2008-02-22 | 2009-03-12 | 275d? | finish no earlier than 2009-03-12 | S5 | 2200h | 2200h | E-UTRAN-OAM | Rel-8 | Mirko |  | Ericsson | ulf.hubinette@ericsson.com | 21 | 39 |  |  |  |

Notes:
- 4215: CH8 is an umbrella Feature also for OAM&P related TEI8 type of changes that are not part of any other dedicated feature/WI / Impacted TSs and TRs: TR 30.818
- 4216: SP#38 completed / Impacted TSs and TRs: 32.296
- 4217: SP#38 completed / Impacted TSs and TRs: 32.240, 32.299, new 32.274
- 4218: SP#42 completed. Linked to SA2 UID 32081 (Support of SMS over IP networks) and CT4 UID 340016 (Routeing of MT-SMS via the HPLMN). / Impacted TSs and TRs: 32.274, 32.299
- 4219: SP#42 stopped / Impacted TSs and TRs: 32.252, 32.298, 32.299
- 4220: CP#42 completed
- 4221: CP#42 completed / Impacted TSs and TRs: 23.333
- 4222: CP#42 completed / Impacted TSs and TRs: 29.333
- 4223: CP#42 completed. CP#40: WID updated CP-070622=>CP-080382. aka Enhanced USIM phonebook
- 4224: CP#38 completed / Impacted TSs and TRs: 21.111
- 4225: CP#39 completed / Impacted TSs and TRs: new 31.220
- 4226: CP#42 completed / Impacted TSs and TRs: new 31.221
- 4227: SP#33 stopped / Impacted TSs and TRs: 31.102
- 4228: RP#43 completed. Role model for SAE/LTE system wide project management by SA2 in SP-060166 / Impacted TSs and TRs: LTE 36.300, 36.938
- 4229: RP#39 completed / Impacted TSs and TRs: 36.201, 36.211, 36.212, 36.213, 36.214, 25.215, 25.225
- 4230: RP#42 completed / Impacted TSs and TRs: 36.302, 36.304, 36.306, 36.314, 36.321, 36.322, 36.323, 36.331, 25.302, 25.304, 25.331
- 4231: RP#42 completed / Impacted TSs and TRs: 36.401, 36.410, 36.411, 36.412, 36.413, 36.414, 36.420, 36.421, 36.422, 36.423, 36.424, 25.413
- 4232: RP#42 completed. RP#47 abandoned draft 36.801, 36.803, 36.804 / Impacted TSs and TRs: 36.101, 36.104, 36.113, 36.124, 36.133, 36.141, 36.942, 25.123, 25.133
- 4233: RP#43 completed. RP#47 create Rel-9 TR 36.956 (see R4-100386, RP-100320_RAN4 Report) / Impacted TSs and TRs: 36.106, 36.143, 25.113
- 4234: SP#43 completed
- 4235: SP#43 completed / Impacted TSs and TRs: 32.421, 2.422, 32.423, 2.441, 32.442, 32.443, 32.445
- 4236: SP#43 completed / Impacted TSs and TRs: new (32.761, 32.762, 32.763, 32.765)
- 4237: SP#43 completed / Impacted TSs and TRs: new 32.425
- 4238: SP#43 completed / Impacted TSs and TRs: new (32.450, 32.451)

| ID | WBS | Task | Duration | Start | Finish | Complete | Baseline start | Baseline finish | Baseline duration | Constraint | Resources | Work | Actual work | Acronym | PCG approved | WI rapporteur name | WI rapporteur e-mail | Release | TSG approved | MCC resp | Special Focus Doc | Acronym_3GU_Export | Status Report | PCG stopped | TSG stopped |
| --- | --- | --- | --- | --- | --- | --- | --- | --- | --- | --- | --- | --- | --- | --- | --- | --- | --- | --- | --- | --- | --- | --- | --- | --- | --- |
| 4239 | 1112.7 | **Self-Organizing Networks (SON)** | 210d? | 2008-02-22 A | 2008-12-11 A | 100% | 2008-02-22 | 2008-12-11 | 210d? |  | S5 | 6720h | 6720h | LTE_SON-OAM | 21 | Vodafone | GOMPAKIS, Panagiotis | Rel-8 | 39 | Mirko | SON | LTE_SON-OAM |  |  |  |
| 4240 | 1112.7.1 | SON Concepts and requirements | 210d? | 2008-02-22 A | 2008-12-11 A | 100% | 2008-02-22 | 2008-12-11 | 210d? |  | S5 | 1680h | 1680h | LTE_SON-OAM | 21 | Vodafone | GOMPAKIS, Panagiotis | Rel-8 | 39 | Mirko |  |  |  |  |  |
| 4241 | 1112.7.2 | Self-Establishment of eNBs, including automated Software Management | 210d? | 2008-02-22 A | 2008-12-11 A | 100% | 2008-02-22 | 2008-12-11 | 210d? | start no earlier than 2008-02-22 | S5 | 1680h | 1680h | LTE_SON-OAM | 21 | Nokia Siemens Networks | SUERBAUM, Clemens | Rel-8 | 39 | Mirko |  |  |  |  |  |
| 4242 | 1112.7.3 | SON Automatic Neighbour Relations (ANR) List Management | 210d? | 2008-02-22 A | 2008-12-11 A | 100% | 2008-02-22 | 2008-12-11 | 210d? | finish no earlier than 2008-12-11 | S5 | 1680h | 1680h | LTE_SON-OAM | 21 | Ericsson | edwin.tse@ericsson.com | Rel-8 | 39 | Mirko |  |  |  |  |  |
| 4243 | 1113 | **Rel-8 LTE – Terminal Conformance Test Specification** | 657d? | 2007-06-01 A | 2009-12-04 A | 100% | 2007-06-01 | 2009-12-04 | 657d? |  | R5 | 14336h | 14336h | LTE-UEConTest |  |  |  | Rel-8 |  | Ingbert |  | LTE-UEConTest |  |  |  |
| 4244 | 1113.1 | 3G LTE – Terminal Protocol Conformance Test Specifications | 657d? | 2007-06-01 A | 2009-12-04 A | 100% | 2007-06-01 | 2009-12-04 | 657d? | finish no earlier than 2009-12-04 | R5 | 5256h | 5256h | LTE-UEConTest_SIG |  | NEC, Motorola | david.lecompte@nectech.fr, Jacob.John@motorola.com | Rel-8 |  | Ingbert |  | LTE-UEConTest_SIG | RP-091060 |  |  |
| 4245 | 1113.2 | LTE – Terminal Radio Transmission and Reception Conformance Test Specifications | 657d? | 2007-06-01 A | 2009-12-04 A | 100% | 2007-06-01 | 2009-12-04 | 657d? |  | R5 | 5256h | 5256h | LTE-UEConTest_RF |  | Agilent | andrea_leonardi@agilent.com | Rel-8 |  | Ingbert |  | LTE-UEConTest_RF | RP-091059 |  |  |
| 4246 | 1114 | **Rel-8 Improvements of the Radio Interface** | 525d? | 2007-03-05 A | 2009-03-06 A | 100% | 2007-03-05 | 2009-03-06 | 525d? |  | RP | 18152h | 18152h | RInImp8 |  |  |  | Rel-8 |  | Issam |  | RInImp8 |  |  |  |
| 4247 | 1114.1 | UMTS 1500 MHz | 140d? | 2007-03-05 A | 2007-09-14 A | 100% | 2007-03-05 | 2007-09-14 | 140d? | finish no earlier than 2007-09-14 | R4 | 1120h | 1120h | RInImp8-UMTS1500 |  | NTT DoCoMo | Takehiro Nakamura (nakamurata@nttdocomo.co.jp) | Rel-8 |  | Issam |  | RInImp8-UMTS1500 | RP-070526 |  |  |
| 4248 | 1114.2 | UMTS 700 MHz FDD | 325d? | 2007-03-05 A | 2008-05-30 A | 100% | 2007-03-05 | 2008-05-30 | 325d? | finish no earlier than 2008-06-12 | R4 | 2600h | 2600h | RInImp8-UMTS700 |  | Nokia | Tuomo Saynajakangas | Rel-8 |  | Issam |  | RInImp8-UMTS700 | RP-080260 |  |  |
| 4249 | 1114.3 | UMTS 1880 MHz TDD | 126d? | 2008-09-12 A | 2009-03-06 A | 100% | 2008-09-12 | 2009-03-06 | 126d? | finish no earlier than 2009-03-09 | R4 | 1008h | 1008h | RInImp9-UMTS1880TDD | 21 | CATT | Yuexia Song (songyuexia@catt.cn) | Rel-8 | 41 | Issam |  | RInImp9-UMTS1880TDD | RP-090044 |  |  |
| 4250 | 1114.4 | UMTS 2300 MHz TDD LCR | 195d? | 2007-12-17 A | 2008-09-12 A | 100% | 2007-12-17 | 2008-09-12 | 195d? | finish no earlier than 2008-09-12 | R4 | 1560h | 1560h | RInImp8-UMTS2300TDD | 21 | CATT | Yuexia Song (songyuexia@catt.cn) | Rel-8 | 38 | Issam |  | RInImp8-UMTS2300TDD | RP-080517 |  |  |
| 4251 | 1114.5 | Further Improved Minimum Performance Requirements for HSDPA UE (FDD) - Two-Branch Interference Cancellation | 265d? | 2007-03-05 A | 2008-03-07 A | 100% | 2007-03-05 | 2008-03-07 | 265d? | finish no earlier than 2008-03-12 | R4 | 2120h | 2120h | RInImp8-2BIC |  | AT&T | Marc Grant | Rel-8 |  | Issam |  | RInImp8-2BIC | RP-080041 |  |  |
| 4252 | 1114.6 | CS Voice Service over HSPA | 167d? | 2007-07-19 A | 2008-03-07 A | 100% | 2007-07-19 | 2008-03-07 | 167d? |  | R2 | 1336h | 1336h | RInImp8-CsHspa |  | Nokia Siemens Networks | woonhee.hwang@nsn.com | Rel-8 | 37 | Yong-Jun |  | RInImp8-CsHspa | RP-080042 |  |  |
| 4253 | 1114.7 | Performance requirements for 15 code reception with 16QAM/QPSK (FDD) | 126d? | 2007-06-11 A | 2008-03-07 A | 100% | 2007-06-11 | 2008-03-07 | 126d? | finish no earlier than 2008-06-12 | R4 | 1008h | 1008h | RInImp8-Hsdpa15codes |  | Vodafone | tim.frost@vodafone.com | Rel-8 | 37 | Issam |  | RInImp8-Hsdpa15codes | RP-080043 |  |  |
| 4254 | 1114.8 | Deleted - UMTS 2300 MHz FDD/TDD | 400d? | 2007-03-05 A | 2008-09-12 A | 100% | 2007-03-05 | 2008-09-12 | 400d? | finish no earlier than 2008-12-11 | R4 | 3200h | 3200h | RInImp8-UMTS2300 |  | AT&T | Marc Grant | Rel-8 |  | Issam |  | RInImp8-UMTS2300 | RP-080515 | PCG-21 | RP-41 |
| 4255 | 1115 | **Rel-8 Improvements of the Radio Interface - UE Conformance Testing** | 396d? | 2007-06-01 A | 2008-12-05 A | 100% | 2007-06-01 | 2008-12-05 | 396d? |  | R5 | 6256h | 6256h |  |  |  |  | Rel-8 |  | Ingbert |  |  |  |  |  |
| 4256 | 1115.1 | Conformance Test Aspects – CS Voice Service over HSPA | 336d? | 2007-06-01 A | 2008-09-12 A | 100% | 2007-06-01 | 2008-09-12 | 336d? | finish no earlier than 2008-09-12 | R5 | 2688h | 2688h | RInImp8-CsHspa_UEConTest |  | Huawei | baoyi@huawei.com | Rel-8 |  | Ingbert |  | RInImp8-CsHspa_UEConTest | RP-080542 |  |  |
| 4257 | 1115.2 | Conformance Test Aspects – Performance requirements for 15 code reception with 16QAM/QPSK (FDD) | 195d? | 2008-03-07 A | 2008-12-05 A | 100% | 2008-03-07 | 2008-12-05 | 195d? | finish no earlier than 2008-12-05 | R5 | 1560h | 1560h | RInImp8-UEConTest_Hsdpa15codes | 21 | Ericsson | Mikael.Ziren@Ericsson.com | Rel-8 | 40 | Ingbert |  | RInImp8-UEConTest_ Hsdpa15codes | RP-080818 |  |  |
| 4258 | 1116 | **Rel-8 RAN improvements** | 520d? | 2007-06-04 A | 2009-05-29 A | 100% | 2007-06-04 | 2009-05-29 | 520d? |  | RP | 37481.6h | 37481.6h |  |  |  |  | Rel-8 |  |  |  |  |  |  |  |
| 4259 | 1116.1 | Combination of 64QAM and MIMO for HSDPA (FDD) | 205d? | 2007-06-04 A | 2008-09-12 A | 100% | 2007-06-04 | 2008-09-12 | 205d? | finish no earlier than 2008-09-12 | R1 | 1640h | 1640h | RANimp-64QamMimoHsdpa |  | Ericsson | Johan.Bergman@ericsson.com | Rel-8 |  | Patrick |  | RANimp-64QamMimoHsdpa | RP-080518 |  |  |
| 4260 | 1116.2 | Improved L2 for uplink | 186d? | 2007-09-14 A | 2008-05-30 A | 100% | 2007-09-14 | 2008-05-30 | 186d? | finish no earlier than 2008-05-30 | R2 | 1488h | 1488h | RANimp-UplinkL2dataRates |  | Ericsson | Janne.Peisa@ericsson.com | Rel-8 | 37 | Yong-Jun |  | RANimp-UplinkL2dataRates | RP-080265 |  |  |
| 4261 | 1116.3 | Enhanced Uplink for CELL_FACH State in FDD | 321d? | 2007-09-14 A | 2008-12-05 A | 100% | 2007-09-14 | 2008-12-05 | 321d? | finish no earlier than 2008-12-12 | R2 | 2568h | 2568h | RANimp-UplinkEnhState |  | Nokia Siemens Networks | markus.wimmer@nsn.com | Rel-8 | 37 | Yong-Jun |  | RANimp-UplinkEnhState | RP-080804 |  |  |
| 4262 | 1116.4 | Enhanced UE Discontinuous Reception (DRX) for FDD | 261d? | 2007-09-14 A | 2008-09-12 A | 100% | 2007-09-14 | 2008-09-12 | 261d? | finish no earlier than 2008-09-12 | R2 | 2088h | 2088h | RANimp-DRX |  | Nokia | luis.barreto@nokia.com | Rel-8 | 37 | Yong-Jun |  | RANimp-DRX | RP-080520 |  |  |
| 4263 | 1116.5 | Enhancements for Serving Radio Network Subsystem (SRNS) Relocation Procedure | 261d? | 2007-09-14 A | 2008-09-12 A | 100% | 2007-09-14 | 2008-09-12 | 261d? | finish no earlier than 2008-09-12 | R3 | 2088h | 2088h | RANimp-SrnsReloc |  | Nokia Siemens Networks | masatoshi.nakamata@nsn.com | Rel-8 | 37 | Juha |  | RANimp-SrnsReloc | RP-080521 |  |  |
| 4264 | 1116.6 | Enhancements for FDD HSPA Evolution | 321d? | 2007-09-14 A | 2008-12-05 A | 100% | 2007-09-14 | 2008-12-05 | 321d? | finish no earlier than 2008-12-05 | R3; R2 | 5136h | 5136h | RANimp-HSPAEvo |  | Nokia Siemens Networks | masatoshi.nakamata@nsn.com | Rel-8 | 37 | Juha |  | RANimp-HSPAEvo | RP-080805 |  |  |
| 4265 | 1116.7 | 64QAM for 1.28 Mcps TDD HSDPA | 264d? | 2007-12-04 A | 2008-12-05 A | 100% | 2007-12-04 | 2008-12-05 | 264d? | finish no earlier than 2008-12-05 | R1 | 2112h | 2112h | RANimp-64Qam1.28TDD | 21 | ZTE | zfmail@zte.com.cn | Rel-8 | 38 | Patrick |  | RANimp-64Qam1.28TDD | RP-080806 |  |  |
| 4266 | 1116.8 | Enhanced CELL_FACH state in 1.28 Mcps TDD | 264d? | 2007-12-04 A | 2008-12-05 A | 100% | 2007-12-04 | 2008-12-05 | 264d? | finish no earlier than 2008-12-12 | R2 | 2112h | 2112h | RANimp-EnhState1.28TDD | 21 | ZTE | zhang.yincheng@zte.com.cn | Rel-8 | 38 | Yong-Jun |  | RANimp-EnhState1.28TDD | RP-080807 |  |  |
| 4267 | 1116.9 | Continuous Connectivity for packet data users for 1.28 Mcps TDD | 321d? | 2008-03-07 A | 2009-05-29 A | 100% | 2008-03-07 | 2009-05-29 | 321d? | finish no earlier than 2009-05-29 | R1 | 2568h | 2568h | RANimp-LCRCPC | 21 | TD Tech | chenying@td-tech.com | Rel-8 | 39 | Patrick |  | RANimp-LCRCPC | RP-090394 |  |  |
| 4268 | 1116.10 | HSPA VoIP to WCDMA/GSM CS continuity | 261d? | 2008-03-07 A | 2009-03-06 A | 100% | 2008-03-07 | 2009-03-06 | 261d? | finish no earlier than 2009-03-06 | R2 | 2088h | 2088h | RANimp-HSPAVoIP | 21 | Nokia | Simone.Provvedi@nokia.com | Rel-8 | 39 | Yong-Jun |  | RANimp-HSPAVoIP | RP-090050 |  |  |
| 4269 | 1116.11 | HS-DSCH Serving Cell Change Enhancements | 196d? | 2008-03-07 A | 2008-12-05 A | 100% | 2008-03-07 | 2008-12-05 | 196d? | finish no earlier than 2008-12-12 | R2 | 1568h | 1568h | RANimp-HSDSCH | 21 | Ericsson | henrik.enbuske@ericsson.com | Rel-8 | 39 | Yong-Jun |  | RANimp-HSDSCH | RP-080811 |  |  |
| 4270 | 1116.12 | MIMO for 1.28 Mcps TDD. Linked to Rel-8 Study on Scope of future HSPA Evolution for 1.28 Mcps TDD (UID_370041) TR 25.824 | 351.6d? | 2008-01-24 A | 2009-05-29 A | 100% | 2008-01-24 | 2009-05-29 | 351.6d? | finish no earlier than 2009-05-29 | R1; R4 | 5625.6h | 5625.6h | RANimp-MIMOLCR | 21 | CATT | wangke@datangmobile.cn | Rel-8 | 40 | Patrick |  | RANimp-MIMOLCR | RP-090313 |  |  |
| 4271 | 1116.13 | Dual-Cell HSDPA operation on adjacent carriers | 140d? | 2008-11-17 A | 2009-05-29 A | 100% | 2008-11-17 | 2009-05-29 | 140d? | finish no earlier than 2009-05-29 | R1; R4 | 2240h | 2240h | RANimp-DCHSDPA | 21 | Ericsson | johan.bergman@ericsson.com | Rel-8 | 40 | Patrick |  | RANimp-DCHSDPA | RP-080814 |  |  |

Notes:
- 4239: SP#42 completed (WT UID_390007 moved to Rel-9)
- 4240: SP#42 completed / Impacted TSs and TRs: new 32.500
- 4241: SP#42 completed / Impacted TSs and TRs: new (32.501, 32.502, 32.503, 32.531, 32.532, 32.533)
- 4242: SP#42 completed / Impacted TSs and TRs: 32.761, 32.762, 32.763, 32.765, new 32.511
- 4243: Testing for Feature UID_20068 (LTE)
- 4244: RP#46 completed / Impacted TSs and TRs: 36.521-1, 36.521-2, 36.508, 36.509, 36.523-1, 36.523-2, 36.523-3
- 4245: RP#46 completed. RP#50 TR 36.903 v100 for Approval / Impacted TSs and TRs: 36.521-1, 36.521-2, 36.521-3, new TR 36.903
- 4246: -
- 4247: RP#37 completed / Impacted TSs and TRs: 25.101, 25.104, 25.133, 25.141, 25.331, 25.942, 25.306, 25.307, 34.121
- 4248: RP#40 completed / Impacted TSs and TRs: 25.101, 25.104, 25.133, 25.141, 25.331, 25.942, 25.306, 25.307, 34.121
- 4249: RP#43 completed / Impacted TSs and TRs: 25.102, 25.105, 25.113, 25.123, 25.142, 34.124, 25.307
- 4250: RP#41 completed. RP#47 abandoned draft 25.828 / Impacted TSs and TRs: 25.102, 25.105, 25.113, 25.123, 25.142, 34.124, 25.306, 25.331, 34.122
- 4251: RP#39 completed / Impacted TSs and TRs: 25.101
- 4252: RP#39 completed / Impacted TSs and TRs: 25.323, 25.331, 25.322
- 4253: RP#39 completed / Impacted TSs and TRs: 25.101
- 4254: RP#41 stopped / Impacted TSs and TRs: 25.101, 25.104, 25.133, 25.141, 25.331, 25.942, 25.306, 25.307, 34.121
- 4255: 05/08: Linked to Feature UID_20028 (RInImp)
- 4256: RP#41 completed / Impacted TSs and TRs: 34.108, 34.123-1, 34.123-2, 34.123-3
- 4257: RP#42 completed / Impacted TSs and TRs: 34.121-1, 34.121-2
- 4258: -
- 4259: RP#41 completed / Impacted TSs and TRs: 25.308, 25.211, 25.212, 25.213, 25.306, 25.331, 25.433, 25.435, 25.423, 25.425, 25.101, 25.104, 25.141
- 4260: RP#40 completed. Linked to UID_370037 Enhanced Uplink for CELL_FACH State in FDD / Impacted TSs and TRs: 25.319, 25.301, 25.306, 25.321, 25.331, 25.433, 25.435, 25.423, 25.425, 25.427
- 4261: RP#42 completed. Linked to UID_370036 Improved L2 for uplink / Impacted TSs and TRs: 25.309, 25.211, 25.214, 25.321, 25.331, 25.423, 25.433
- 4262: RP#41 completed. Continuation of Rel-7 work item "Continuous connectivity for packet data users" UID_20046. / Impacted TSs and TRs: 25.306, 25.308, 25.321, 25.331, 25.423
- 4263: RP#41 completed. Linked to UID_370040 Enhancements for FDD HSPA Evolution / Impacted TSs and TRs: 25.306, 25.308, 25.321, 25.331, 25.423, 25.433, 25.214, 25.133
- 4264: RP#42 completed. Triggered by Rel-7 Study on Scope of future FDD HSPA Evolution (UID_20065) TR 25.999 / Impacted TSs and TRs: 25.401, 25.413, 25.420, 25.423, 25.427, 25.433, 25.446, 25.301, 25.346
- 4265: RP#42 completed. Linked to Rel-8 Study on Scope of future HSPA Evolution for 1.28 Mcps TDD (UID_370041) TR 25.824 / Impacted TSs and TRs: 25.102, 25.105, 25.123, 25.142, 25.201, 25.221, 25.222, 25.223, 25.224, 25.306, 25.308, 25.321, 25.331, 25.423, 25.433
- 4266: RP#42 completed. Linked to Rel-8 Study on Scope of future HSPA Evolution for 1.28 Mcps TDD (UID_370041) TR 25.824 / Impacted TSs and TRs: 25.123, 25.221, 25.222, 25.224, 25.301, 25.302, 25.304, 25.306, 25.308, 25.319, 25.321, 25.331, 25.401, 25.423, 25.425, 25.433, 25.435
- 4267: RP#44 completed. Linked to Rel-8 Study on Scope of future HSPA Evolution for 1.28 Mcps TDD (UID_370041) TR 25.824 / Impacted TSs and TRs: 25.929, 25.308, 25.319
- 4268: RP#43 completed / Impacted TSs and TRs: 25.331, 25.413
- 4269: RP#42 completed / Impacted TSs and TRs: 25.101, 25.104, 25.133, 25.212, 25.214, 25.308, 25.321, 25.331, 25.423, 25.433
- 4270: RP#43 completed / Impacted TSs and TRs: 25.201, 25.221, 25.222, 25.223, 25.224, 25.306, 25.308, 25.321, 25.331, 25.423, 25.433, 25.102, 25.105, 25.142
- 4271: RP#42 completed. Triggered by UID_390032 Study on Dual-Cell HSDPA (withdrawn TR 25.825 v100). / Impacted TSs and TRs: 25.101, 25.104, 25.133, 25.141, 25.211, 25.212, 25.213, 25.214, 25.215, 25.306, 25.308, 25.321, 25.331, 25.423, 25.433

| ID | WBS | Task | Duration | Start | Finish | Complete | Baseline start | Baseline finish | Baseline duration | Constraint | Resources | Work | Actual work | Release | MCC resp | Acronym | PCG approved | WI rapporteur name | TSG approved | Status Report | Acronym_3GU_Export |
| --- | --- | --- | --- | --- | --- | --- | --- | --- | --- | --- | --- | --- | --- | --- | --- | --- | --- | --- | --- | --- | --- |
| 4272 | 1117 | **Rel-8 RAN improvements - UE Conformance Testing** | 602d? | 2008-05-30 A | 2010-09-17 A | 100% | 2008-05-30 | 2010-09-17 | 602d? |  | R5 | 29391.2h | 29391.2h | Rel-8 | Ingbert |  |  |  |  |  |  |
| 4273 | 1117.1 | Conformance Test Aspects – Combination of 64QAM and MIMO for HSDPA (FDD) | 322d? | 2008-09-12 A | 2009-12-04 A | 100% | 2008-09-12 | 2009-12-04 | 322d? | finish no earlier than 2009-12-04 | R5 | 2576h | 2576h | Rel-8 | Ingbert | RANimp-UEConTest_64QamMimoHsdpa | 21 | Ericsson | 41 | RP-091058 | RANimp-UEConTest_64QamMimoHsdpa |
| 4274 | 1117.2 | Conformance Test Aspects – Improved L2 for uplink | 341d? | 2008-05-30 A | 2009-09-18 A | 100% | 2008-05-30 | 2009-09-18 | 341d? | finish no earlier than 2009-09-18 | R5 | 2728h | 2728h | Rel-8 | Ingbert | RANimp-UEConTest_UplinkL2dataRates | 21 | Ericsson | 40 | RP-090712 | RANimp-UEConTest_UplinkL2dataRates |
| 4275 | 1117.3 | Conformance Test Aspects – 1.28 Mcps TDD Improved L2 support for high data rates | 342d? | 2009-05-29 A | 2010-09-17 A | 100% | 2009-05-29 | 2010-09-17 | 342d? | finish no earlier than 2010-09-17 | R5 | 2736h | 2736h | Rel-8 | Ingbert | RANimp-UEConTest_ImprovedL2LCRTDD | 23 | CATT | 44 | RP-100737 | RANimp-UEConTest_ImprovedL2LCRTDD |
| 4276 | 1117.4 | Conformance Test Aspects – 64QAM for 1.28 Mcps TDD HSDPA | 261d? | 2008-05-30 A | 2009-05-29 A | 100% | 2008-05-30 | 2009-05-29 | 261d? | finish no earlier than 2009-05-29 | R5 | 2088h | 2088h | Rel-8 | Ingbert | RANimp-UEConTest_64Qam1.28TDD | 21 | ZTE | 40 | RP-090415 | RANimp-UEConTest_64Qam1.28TDD |
| 4277 | 1117.5 | Conformance Test Aspects – Dual-Cell HSDPA operation on adjacent carriers | 391d? | 2008-12-05 A | 2010-06-04 A | 100% | 2008-12-05 | 2010-06-04 | 391d? | finish no earlier than 2010-06-04 | R5 | 3128h | 3128h | Rel-8 | Ingbert | RANimp-UEConTest_DCHSDPA | 22 | Qualcomm | 42 | RP-100479 | RANimp-UEConTest_DCHSDPA |
| 4278 | 1117.6 | Conformance Test Aspects – Enhanced Uplink for CELL_FACH State in FDD | 326d? | 2009-03-06 A | 2010-06-04 A | 100% | 2009-03-06 | 2010-06-04 | 326d? | finish no earlier than 2010-06-04 | R5 | 2608h | 2608h | Rel-8 | Ingbert | RANimp-UEConTest_EnhancedRACHCellFACHState | 22 | Nokia | 43 | RP-100483 | RANimp-UEConTest_EnhancedRACHCellFACHState |
| 4279 | 1117.7 | Conformance Test Aspects – Receiver Type3i | 196d? | 2009-03-06 A | 2009-12-04 A | 100% | 2009-03-06 | 2009-12-04 | 196d? | finish no earlier than 2009-12-04 | R5 | 1568h | 1568h | Rel-8 | Ingbert | RANimp-UEConTest_ReceiverType3i | 22 | Qualcomm | 43 | RP-091066 | RANimp-UEConTest_ReceiverType3i |
| 4280 | 1117.8 | Conformance Test Aspects – Enhanced CELL_FACH State in LCR TDD | 341d? | 2009-05-30 A | 2010-09-17 A | 100% | 2009-05-30 | 2010-09-17 | 341d? | finish no earlier than 2010-09-17 | R5 | 2728h | 2728h | Rel-8 | Ingbert | RANimp-UEConTest_EnhancedCellFACHStateLCRTDD | 23 | CATT | 44 | RP-100735 | RANimp-UEConTest_EnhancedCellFACHStateLCRTDD |
| 4281 | 1117.9 | Conformance Test Aspects – Continuous Connectivity for packet data users for 1.28 Mcps TDD | 261d? | 2009-09-18 A | 2010-09-17 A | 100% | 2009-09-18 | 2010-09-17 | 261d? | finish no earlier than 2010-09-17 | R5 | 2088h | 2088h | Rel-8 | Ingbert | RANimp-UEConTest_CPCLCRTDD | 23 | ZTE | 45 | RP-100739 | RANimp-UEConTest_CPCLCRTDD |
| 4282 | 1117.10 | Conformance Test Aspects – MIMO for 1.28 Mcps TDD | 186d? | 2009-09-18 A | 2010-06-04 A | 100% | 2009-09-18 | 2010-06-04 | 186d? | finish no earlier than 2010-06-04 | R5 | 1488h | 1488h | Rel-8 | Ingbert | RANimp-UEConTest_MIMOLCRTDD | 23 | ZTE | 45 | RP-100660 | RANimp-UEConTest_MIMOLCRTDD |
| 4283 | 1117.11 | Conformance Test Aspects – HS-DSCH Serving Cell Change Enhancements | 131d? | 2009-09-18 A | 2010-03-19 A | 100% | 2009-09-18 | 2010-03-19 | 131d? | finish no earlier than 2010-03-12 | R5 | 1048h | 1048h | Rel-8 | Ingbert | HSDSCH_UEConTest | 23 | Qualcomm | 45 | RP-100077 | HSDSCH_UEConTest |
| 4284 | 1118 | 3.84 Mcps TDD MBMS over a Single Frequency Network (MBSFN) Integrated Mobile Broadcast | 395d? | 2007-06-04 A | 2008-12-05 A | 100% | 2007-06-04 | 2008-12-05 | 395d? |  | R1 | 3160h | 3160h | Rel-8 | Patrick | MBSFN-DOB |  | Ericsson |  | RP-080218 | MBSFN-DOB |
| 4285 | 1119 | Conformance Test Aspects – 3.84 Mcps TDD MBMS over a Single Frequency Network (MBSFN) Integrated Mobile Broadcast | 211d? | 2009-05-30 A | 2010-03-19 A | 100% | 2009-05-30 | 2010-03-19 | 211d? | finish no earlier than 2010-03-19 | R5 | 1688h | 1688h | Rel-8 | Ingbert | MBSFN_IMB_UEConTest | 23 | IPwireless | 44 | RP-100070 | MBSFN_IMB_UEConTest |
| 4286 | 1120 | **GERAN support for GERAN - 3G Long Term Evolution interworking** | 1365d? | 2006-09-08 A | 2011-11-25 A | 100% | 2006-09-08 | 2011-11-25 | 1365d? |  | GP; G1; C1; G3new | 69960h | 69960h | Rel-8 | Paolo | GELTE |  | Nokia, Nokia Siemens Networks |  |  | GELTE |
| 4287 | 1120.1 | G1 part of GERAN support for GERAN - 3G Long Term Evolution interworking | 641d? | 2006-09-08 A | 2009-02-20 A | 100% | 2006-09-08 | 2009-02-20 | 641d? | finish no earlier than 2009-02-20 | G1 | 5128h | 5128h | Rel-8 | Paolo | GELTE |  | Nokia, Nokia Siemens Networks |  |  |  |
| 4288 | 1120.2 | G2 part of GERAN support for GERAN - 3G Long Term Evolution interworking | 641d? | 2006-09-08 A | 2009-02-20 A | 100% | 2006-09-08 | 2009-02-20 | 641d? | finish no earlier than 2009-02-20 | G2 | 5128h | 5128h | Rel-8 | Paolo | GELTE |  | Nokia, Nokia Siemens Networks |  |  |  |
| 4289 | 1120.3 | CT1 part of GERAN support for GERAN - 3G Long Term Evolution interworking | 641d? | 2006-09-08 A | 2009-02-20 A | 100% | 2006-09-08 | 2009-02-20 | 641d? | finish no earlier than 2009-02-20 | C1 | 5128h | 5128h | Rel-8 | Paolo | GELTE |  | Nokia, Nokia Siemens Networks |  |  |  |
| 4290 | 1120.4 | Testing for GERAN support for GERAN - 3G Long Term Evolution interworking | 1363d? | 2006-09-08 A | 2011-11-25 A | 100% | 2006-09-08 | 2011-11-25 | 1363d? | finish no earlier than 2011-11-25 | G3new | 10896h | 10896h | Rel-8 | Ingbert | GELTE |  | Renesas Mobile |  |  |  |
| 4291 | 1121 | U-TDOA Enhancement | 131d? | 2007-05-18 A | 2007-11-16 A | 100% | 2007-05-18 | 2007-11-16 | 131d? | finish no earlier than 2007-05-18 | GP | 1048h | 1048h | Rel-8 | Paolo | GUTEN |  | TruePosition |  |  | GUTEN |
| 4292 | 1122 | **GAN Enhancements** | 604.2d? | 2007-05-15 A | 2009-09-04 A | 100% | 2007-05-15 | 2009-09-04 | 604.2d? |  | GP | 9432h | 9432h | Rel-8 | Paolo | GANENH |  | T-Mobile |  |  | GANENH |
| 4293 | 1122.1 | Update to GAN specifications | 126d? | 2007-08-31 A | 2008-02-22 A | 100% | 2007-08-31 | 2008-02-22 | 126d? | finish no earlier than 2008-02-22 | GP | 1008h | 1008h | Rel-8 | Paolo | GANENH-SPEC |  | T-Mobile |  |  | GANENH-SPEC |
| 4294 | 1122.2 | Update TS 51.010 Mobile Station (MS) Conformance Specification for GAN Enhancements | 526d? | 2007-05-15 A | 2009-09-04 A | 100% | 2007-05-15 | 2009-09-04 | 526d? | finish no earlier than 2009-09-04 | G3new | 4208h | 4208h | Rel-8 | Ingbert | GANENH-MStest |  | T-Mobile |  |  | GANENH-MStest |
| 4295 | 1123 | **AoIP (A-interface over IP)** | 2335d? | 2000-01-03 A | 2008-12-11 A | 100% | 2000-01-03 | 2008-12-11 | 2335d? |  | GP; S4; C4; C1; C3 | 119396h | 119396h | Rel-8 | Paolo | AoIP | 21 | China Mobile, Ericsson |  |  | AoIP |
| 4296 | 1123.1 | GERAN aspects of AoIP | 2321d? | 2000-01-03 A | 2008-11-21 A | 100% | 2000-01-03 | 2008-11-21 | 2321d? | finish no earlier than 2008-11-21 | GP | 18560h | 18560h | Rel-8 | Paolo | AoIP | 21 | China Mobile, Ericsson | 40 |  |  |
| 4297 | 1123.2 | Media Requirements for CS over IP based User Plane | 267d? | 2007-12-05 A | 2008-12-11 A | 100% | 2007-12-05 | 2008-12-11 | 267d? | finish no earlier than 2008-12-11 | S4 | 1996.09h | 1996.09h | Rel-8 | Paolo | AoIP-CSoIP | 21 | China Mobile, Ericsson | 40 |  | AoIP-CSoIP |

Notes:
- 4272: Linked to Feature UID_20029 (RANimp)
- 4273: RP#46 completed. Testing for UID_360013 / Impacted TSs and TRs: 34.108, 34.121-1, 34.121-2, 34.123-1, 34.123-2 / WI rapporteur e-mail: leif.mattisson@ericsson.com
- 4274: RP#45 completed. Testing for UID_370036 / Impacted TSs and TRs: 34.108, 34.123-1, 34.123-2, 34.123-3 / WI rapporteur e-mail: leif.mattisson@ericsson.com
- 4275: RP#49 completed. Testing for Rel-7 UID_340039 Improved L2 support for high data rates and Rel-8 UID_370036 Improved L2 for uplink / Impacted TSs and TRs: 34.108, 34.123-1, 34.123-2, 34.123-3 / WI rapporteur e-mail: Xiaozhong Chen (chenxiaozhong@datangmobile.cn)
- 4276: RP#44 completed. Testing for UID_380075 / Impacted TSs and TRs: 34.108, 34.122, 34.123-1, 34.123-2, 34.123-3 / WI rapporteur e-mail: ma.zijiang@zte.com.cn
- 4277: RP#48 completed. Testing for UID_400052 / Impacted TSs and TRs: 34.108, 34.121-1, 34.121-2, 34.123-1, 34.123-2, 34.123-3 / WI rapporteur e-mail: Shubhang Vora (svora@qualcomm.com)
- 4278: RP#48 completed. Testing for UID_370037 / Impacted TSs and TRs: 34.108, 34.121-1, 34.121-2, 34.123-1, 34.123-2, 34.123-3 / WI rapporteur e-mail: jarkko.hellsten@nokia.com
- 4279: RP#46 completed. Testing for Receiver Type3i in 25.101 UE radio Tx and Rx FDD / Impacted TSs and TRs: 34.108, 34.121-1, 34.121-2 / WI rapporteur e-mail: Ashok Kumar Narayanaswamy (anarayan@qualcomm.com)
- 4280: RP#49 completed. Testing for UID_380076 / Impacted TSs and TRs: 34.108, 34.123-1, 34.123-2, 34.123-3 / WI rapporteur e-mail: Xiaozhong Chen (chenxiaozhong@datangmobile.cn)
- 4281: RP#49 completed. Testing for UID_390028 / Impacted TSs and TRs: 34.108, 34.123-1, 34.123-2, 34.123-3 / WI rapporteur e-mail: huang.he4@zte.com.cn
- 4282: PR#48 completed. Testing for UID_400050 / Impacted TSs and TRs: 34.108, 34.122, 34.123-1, 34.123-2, 34.123-3 / WI rapporteur e-mail: huang.chun2@zte.com.cn
- 4283: RP#47 completed. Testing for UID_390030 / Impacted TSs and TRs: 34.108, 34.121-1, 34.121-2, 34.123-1, 34.123-2, 34.123-3 / WI rapporteur e-mail: Shubhang Vora (svora@qualcomm.com)
- 4284: RP#42 completed. WID updated RP-070493=>RP-081124 (changed WI title "MBSFN Downlink Optimized Broadcast (DOB) 3.84 Mcps TDD" => "3.84Mcps TDD MBSFN Integrated Mobile Broadcast"). / Impacted TSs and TRs: 25.102, 25.105, 25.123, 25.201, 25.221, 25.222, 25.223, 25.224, 25.304, 25.306, 25.331, 25.346, 25.402, 25.433 / WI rapporteur e-mail: Lars.Lindbom@ericsson.com
- 4285: RP#47 completed. Testing for Rel-8 MBSFN-DOB UID_360008 / Impacted TSs and TRs: 34.108, 34.122, 34.123-1, 34.123-2, 34.123-3 / WI rapporteur e-mail: Phil Young (pyoung@ipwireless.com)
- 4286: GP#41 completed. GP#52 completed MS conformance testing / Impacted TSs and TRs: 44.018, 44.060, 45.002, 45.008, 45.010, 48.008, 48.018, 51.010 / WI rapporteur e-mail: sergio.parolari@nsn.com, vlora.rexhepi@nokia.com
- 4287: GP#41 completed / Impacted TSs and TRs: 43.055, 43.129, 43.246, 45.002, 45.008, 45.010 / WI rapporteur e-mail: sergio.parolari@nsn.com, vlora.rexhepi@nokia.com
- 4288: GP#41 completed / Impacted TSs and TRs: 44.018, 44.060, 48.008, 48.018 / WI rapporteur e-mail: sergio.parolari@nsn.com, vlora.rexhepi@nokia.com
- 4289: - / Impacted TSs and TRs: 24.008 / WI rapporteur e-mail: sergio.parolari@nsn.com, vlora.rexhepi@nokia.com
- 4290: GP#52 completed / Impacted TSs and TRs: 51.010 / WI rapporteur e-mail: deepa.kamath@renesasmobile.com
- 4291: GP#36 completed U-TDOA (Uplink Time Difference of Arrival) / Impacted TSs and TRs: 43.059, 45.008, 48.071 / WI rapporteur e-mail: Terry Brooks (terri.brooks@trueposition.com)
- 4292: GP#37 completed. GP#43 completed Testing / WI rapporteur e-mail: mohammed.versi@t-mobile.com
- 4293: GP#37 completed / Impacted TSs and TRs: 43.318, 44.318 / WI rapporteur e-mail: mohammed.versi@t-mobile.com
- 4294: GP#43 completed / Impacted TSs and TRs: 51.010 / WI rapporteur e-mail: mohammed.versi@t-mobile.com
- 4295: GP#40/TSG#42 completed . Triggered by TR 43.903 Study on A-interface over IP (AINTIP) UID_50589. / WI rapporteur e-mail: wangshuaiyu@chinamobile.com, paul.schliwa-bertling@ericsson.com
- 4296: GP#40 completed. GP#39 updated WID GP-080901=>GP-081362. / Impacted TSs and TRs: 48.001, 48.002, 48.008, 48.020, 49.008, 48.103 / WI rapporteur e-mail: wangshuaiyu@chinamobile.com, paul.schliwa-bertling@ericsson.com
- 4297: SP#42 completed / Impacted TSs and TRs: 26.102, 26.103, 26.202 / WI rapporteur e-mail: Karl.Hellwig@Ericsson.com

| ID | WBS | Task | Type | Duration | Start | Finish | Complete | Baseline start | Baseline finish | Baseline duration | Constraint | Resources | Work | Actual work | Acronym | PCG approved | WI rapporteur name | Release | TSG approved | MCC resp | Acronym_3GU_Export | Impacted TSs and TRs | Status Report | TSG stopped | Special Focus Doc | PCG stopped |
| --- | --- | --- | --- | --- | --- | --- | --- | --- | --- | --- | --- | --- | --- | --- | --- | --- | --- | --- | --- | --- | --- | --- | --- | --- | --- | --- |
| 4298 | 1123.3 | **Core Network Impacts for A-Interface User Plane over IP** |  | 136d? | 2008-05-30 A | 2008-12-05 A | 100% | 2008-05-30 | 2008-12-05 | 136d? |  | C4; C1; C3 | 5440h | 5440h | AoIP-CN | 21 | Ericsson | Rel-8 | 40 | Kimmo | AoIP-CN |  |  |  |  |  |
| 4299 | 1123.3.1 | CT4 part of Core Network Impacts for A-Interface User Plane over IP |  | 136d? | 2008-05-30 A | 2008-12-05 A | 100% | 2008-05-30 | 2008-12-05 | 136d? | start no earlier than 2008-05-30 | C4 | 1088h | 1088h | AoIP-CN | 21 | Ericsson | Rel-8 | 40 | Kimmo |  | 23.205, 23.153, 23.231, 29.232 |  |  |  |  |
| 4300 | 1123.3.2 | CT1 part of Core Network Impacts for A-Interface User Plane over IP |  | 68d? | 2008-05-30 A | 2008-12-05 A | 100% | 2008-05-30 | 2008-12-05 | 68d? | finish no earlier than 2008-12-05 | C1 | 544h | 544h | AoIP-CN | 21 | Ericsson | Rel-8 | 40 | Frederic |  | 23.009 |  |  |  |  |
| 4301 | 1123.3.3 | CT3 part of Core Network Impacts for A-Interface User Plane over IP |  | 68d? | 2008-05-30 A | 2008-12-05 A | 100% | 2008-05-30 | 2008-12-05 | 68d? | finish no earlier than 2008-12-05 | C3 | 544h | 544h | AoIP-CN | 21 | Ericsson | Rel-8 | 40 | Adrian |  | 29.007 |  |  |  |  |
| 4302 | 1124 | New multicarrier BTS class |  | 261d? | 2007-08-31 A | 2008-08-29 A | 100% | 2007-08-31 | 2008-08-29 | 261d? | finish no earlier than 2008-08-29 | G1 | 2088h | 2088h | MCBTS |  | Alcatel-Lucent | Rel-8 |  | Paolo | MCBTS | 45.005, 45.050, 51.021 |  |  |  |  |
| 4303 | 1125 | **Support for Additional Navigation Satellite Systems (ANSS) for LCS** |  | 150d? | 2008-05-16 A | 2008-12-11 A | 100% | 2008-05-16 | 2008-12-11 | 150d? |  | S1; G2; R2 | 5784h | 5784h | ANSS |  | Qualcomm | Rel-8 |  | Paolo | ANSS |  |  |  |  |  |
| 4304 | 1125.1 | Stage 1 for ANSS for LCS |  | 1d? | 2008-12-11 A | 2008-12-11 A | 100% | 2008-12-11 | 2008-12-11 | 1d? | start no earlier than 2008-12-11 | S1 | 8h | 8h | ANSS | 22 |  | Rel-8 | 42 | Alain |  | 22.071 |  |  |  |  |
| 4305 | 1125.2 | GERAN2 part of Support for Additional Navigation Satellite Systems (ANSS) for LCS |  | 136d? | 2008-05-16 A | 2008-11-21 A | 100% | 2008-05-16 | 2008-11-21 | 136d? | start no earlier than 2008-05-16 | G2 | 1088h | 1088h | ANSS |  | Qualcomm | Rel-8 |  | Paolo |  | 43.059, 44.031, 49.031, 44.071, 48.031, 51.010 |  |  |  |  |
| 4306 | 1125.3 | RAN2 part of Support for Additional Navigation Satellite Systems (ANSS) for LCS |  | 136d? | 2008-05-30 A | 2008-12-05 A | 100% | 2008-05-30 | 2008-12-05 | 136d? | finish no earlier than 2008-12-08 | R2 | 1088h | 1088h | RANimp-ANSS | 21 | Qualcomm | Rel-8 | 40 | Yong-Jun | RANimp-ANSS | 25.305, 25.306, 25.331, 25.413, 25.423, 25.433, 25.453 | RP-080813 |  |  |  |
| 4307 | 1126 | **Conformance testing for the Latency Reductions feature** |  | 532d? | 2008-02-22 A | 2010-03-05 A | 100% | 2008-02-22 | 2010-03-05 | 532d? |  | G1; G3new | 14848h | 14848h | CTLATRED | 21 | Ericsson | Rel-8 |  | Paolo | CTLATRED |  |  |  |  |  |
| 4308 | 1126.1 | MS conformance testing for the Latency Reductions feature |  | 532d? | 2008-02-22 A | 2010-03-05 A | 100% | 2008-02-22 | 2010-03-05 | 532d? | finish no earlier than 2010-03-05 | G3new | 4248h | 4248h | CTLATRED-MStest | 21 | Ericsson | Rel-8 |  | Ingbert | CTLATRED-MStest | 51.010 |  |  |  |  |
| 4309 | 1126.2 | BTS conformance testing for the Latency Reductions feature |  | 261d? | 2008-02-22 A | 2009-02-20 A | 100% | 2008-02-22 | 2009-02-20 | 261d? | finish no earlier than 2009-02-20 | G1 | 2088h | 2088h | CTLATRED-BTStest | 21 | Ericsson | Rel-8 |  | Paolo | CTLATRED-BTStest | 51.021 |  |  |  |  |
| 4310 | 1127 | MS conformance testing of changes introduced by WI "Support of Packet-switched Handover for GERAN A/Gb mode" |  | 196d? | 2008-02-22 A | 2008-11-21 A | 100% | 2008-02-22 | 2008-11-21 | 196d? | finish no earlier than 2008-11-21 | G3new | 1568h | 1568h | PSHCT-MStest | 21 | Rohde & Schwarz | Rel-8 |  | Ingbert | PSHCT-MStest | 51.010 |  |  |  |  |
| 4311 | 1128 | (Small) Technical Enhancements and Improvements for Rel-8 |  | 509d? | 2007-01-01 A | 2008-12-11 A | 100% | 2007-01-01 | 2008-12-11 | 509d? | finish no earlier than 2008-12-11 | SP; CP; RP; GP | 16288h | 16288h | TEI8 |  |  | Rel-8 |  | All | TEI8 |  |  |  |  |  |
| 4312 | 1129 | (IETF) (Small) Technical Enhancements and Improvements for Rel-8 |  | 650d? | 2007-01-01 A | 2012-09-07 A | 100% | 2007-01-01 | 2012-09-07 | 650d? | finish no earlier than 2012-09-07 | C1-IETF | 5200h | 5200h | TEI8_IETF | 27 | christer.holmberg@ericsson.com | Rel-8 | 52 | Frederic | TEI8_IETF | RFC 6714 (was draft-ietf-simple-msrp-cema) |  |  |  |  |
| 4313 | 1130 | Test - (Small) Technical Enhancements and Improvements for Rel-8 |  | 993.6d? | 2007-03-07 A | 2010-12-24 A | 100% | 2007-03-07 | 2010-12-24 | 993.6d? | finish no earlier than 2010-12-24 | R5; G3new | 15897.6h | 15897.6h | TEI8_Test | 21 |  | Rel-8 | 40 | Ingbert | TEI8_Test |  |  |  |  |  |
| 4314 | 1131 | **Deleted - All-IP Network** |  | 448d? | 2004-06-28 A | 2006-03-15 A | 100% | 2004-06-28 | 2006-03-15 | 448d? |  | S1 | 7168h | 7168h | AIPN |  | NTT DoCoMo | Rel-8 |  | Alain | AIPN |  |  | SP-38 |  |  |
| 4315 | 1131.1 | Deleted - Stage 1 |  | 448d? | 2004-06-28 A | 2006-03-15 A | 100% | 2004-06-28 | 2006-03-15 | 448d? | finish no earlier than 2006-03-15 | S1 | 3584h | 3584h | AIPN |  | NTT DoCoMo | Rel-8 |  | Alain |  | 22.258 |  | SP-38 |  |  |
| 4316 | 1132 | Deleted - was Rel-7 - LCS for 3GPP Interworking WLAN | milestone | 0d? | 2007-09-28 A | 2007-09-28 A | 100% | 2007-09-28 | 2007-09-28 | 0d? | start no earlier than 2007-09-28 | S2 |  |  | LCS4_IWLAN |  | LG Electronics | Rel-8 | 34 | Maurice | LCS4_IWLAN | 23.234, 23.271, 23.167 |  | SP-35 | WLAN |  |
| 4317 | 1133 | Deleted - never approved- FBI Phase 2 | milestone | 0d | 2007-09-28 A | 2007-09-28 A | 100% | 2007-09-28 | 2007-09-28 | 0d | start no earlier than 2007-09-28 | S2 |  |  | FBI2 |  | Nokia Siemens Networks | Rel-8 |  | Maurice | FBI2 |  |  | SP-38 |  |  |
| 4318 | 1134 | Deleted -Enhancements to BS30 Bearer service for Videotelephony | milestone | 0d? | 2007-03-15 A | 2007-03-15 A | 100% | 2007-03-15 | 2007-03-15 | 0d? | finish no earlier than 2007-03-15 | S1 |  |  | BS30 |  |  | Rel-8 |  | Alain | BS30 | 22.002, 22.004, 22.101, 22.105, 24.008 |  | SP-38 |  |  |
| 4319 | 1135 | Deleted - IMS Enhancements Rel-8 |  | 75d? | 2007-09-03 A | 2007-12-14 A | 100% | 2007-09-03 | 2007-12-14 | 75d? |  | S1 | 600h | 600h | IMS8 |  | Telecom Italia | Rel-8 | 37 | Alain | IMS8 |  |  | SP-38 |  |  |
| 4320 | 1136 | **Deleted - Contact Manager Conformance Test specifications** |  | 471d? | 2008-06-02 A | 2010-03-19 A | 100% | 2008-06-02 | 2010-03-19 | 471d? |  | C6 | 11304h | 11304h | eUPHBOOK-Test | 21 | Comprion, Gemalto | Rel-8 | 40 | Xavier | eUPHBOOK-Test |  |  | CP-47 |  | PCG-24 |
| 4321 | 1136.1 | Deleted - Contact Manager for 3GPP UICC applications test specifications |  | 471d? | 2008-06-02 A | 2010-03-19 A | 100% | 2008-06-02 | 2010-03-19 | 471d? | finish no earlier than 2010-03-19 | C6 | 3768h | 3768h | eUPHBOOK-Test | 21 | Comprion | Rel-8 | 40 | Xavier |  | 31.320 (external interface for communication with the ME) |  | CP-47 |  | PCG-24 |
| 4322 | 1136.2 | Deleted - Contact Manager API for Java™ Card test specification |  | 471d? | 2008-06-02 A | 2010-03-19 A | 100% | 2008-06-02 | 2010-03-19 | 471d? | finish no earlier than 2010-03-19 | C6 | 3768h | 3768h | eUPHBOOK-Test | 21 | Gemalto | Rel-8 | 40 | Xavier |  | 31.321 (internal interface (API)) |  | CP-47 |  | PCG-24 |
| 4323 | 1137 | Deleted - MS conformance testing of Support of Conversational Services in A/Gb mode via the PS domain |  | 401d? | 2008-02-25 A | 2009-09-04 A | 100% | 2008-02-25 | 2009-09-04 | 401d? | finish no earlier than 2009-09-04 | G3new | 3208h | 3208h | SCSAGBCT-MStest | 21 | Nokia | Rel-8 |  | Ingbert | SCSAGBCT-MStest | 51.010 |  | GP-43 |  | PCG-23 |
| 4324 | 1138 | Release 8 Studies | milestone | 0d? | 2005-10-07 A | 2005-10-07 A | 100% | 2005-10-07 | 2010-11-12 | 1332d? | start no earlier than 2000-01-03 | CP; GP; RP; SP |  |  |  |  |  | Rel-8 |  | All |  |  |  |  |  |  |
| 4325 | 1139 | Study on Customised Alerting Tone (CAT) Requirements |  | 245d? | 2005-10-07 A | 2006-09-14 A | 100% | 2005-10-07 | 2006-09-14 | 245d? | start no earlier than 2005-10-07 | S1 | 1960h | 1960h | FS_CAT |  | China Mobile | Rel-8 |  | Alain | FS_CAT | 22.982 |  |  |  |  |
| 4326 | 1140 | Study on Facilitating Machine to Machine Communication in GSM and UMTS (M2M) |  | 350d? | 2005-11-04 A | 2007-03-08 A | 100% | 2005-11-04 | 2007-03-08 | 350d? | finish no earlier than 2006-06-16 | S1 | 2800h | 2800h | FS_M2M |  | Siemens | Rel-8 |  | Alain | FS_M2M | 22.868 |  |  | MTC, M2M |  |
| 4327 | 1141 | Study on Network Composition |  | 526d? | 2005-12-07 A | 2007-12-12 A | 100% | 2005-12-07 | 2007-12-12 | 526d? | finish no earlier than 2006-09-27 | S1 | 4208h | 4208h | FS_NetComp |  | Nokia Siemens Networks | Rel-8 |  | Alain | FS_NetComp | 22.980 |  |  |  |  |
| 4328 | 1142 | Study on Requirements of IMS Multimedia Conferencing |  | 330d? | 2006-06-08 A | 2007-09-12 A | 100% | 2006-06-08 | 2007-09-12 | 330d? | finish no earlier than 2007-03-21 | S1 | 2640h | 2640h | FS_IMSconf |  | China Mobile | Rel-8 |  | Alain | FS_IMSconf | 22.948 |  |  |  |  |
| 4329 | 1143 | Study on support of a Public Warning System |  | 140d? | 2007-09-03 A | 2008-03-14 A | 100% | 2007-09-03 | 2008-03-14 | 140d? |  | S1 | 1120h | 1120h | FS_PWS |  | T-Mobile | Rel-8 |  | Alain | FS_PWS | 22.968 |  |  | Public Safety (I-A) |  |
| 4330 | 1144 | Study on Paging Permission with Access Control |  | 256d? | 2006-09-28 A | 2007-09-20 A | 100% | 2006-09-28 | 2007-09-20 | 256d? | finish no earlier than 2007-09-20 | S1 | 2048h | 2048h | FS_PPAC |  | NTT DoCoMo | Rel-8 |  | Alain | FS_PPAC | 22.908 |  |  |  |  |
| 4331 | 1145 | Study on Non-3GPP access Network Selection Principles (NSP) |  | 392d? | 2006-12-06 A | 2008-06-05 A | 100% | 2006-12-06 | 2008-06-05 | 392d? | finish no earlier than 2007-11-19 | S1 | 3136h | 3136h | FS_N3GtoNSP |  | Telefónica O2 | Rel-8 | 34 | Alain | FS_N3GtoNSP | 22.912 |  |  |  |  |
| 4332 | 1146 | Study on Value Added Services for Short Message Service |  | 263d? | 2006-12-06 A | 2007-12-07 A | 100% | 2006-12-06 | 2007-12-07 | 263d? | finish no earlier than 2007-12-07 | S1 | 2104h | 2104h | FS_VAS4SMS |  | China Mobile | Rel-8 | 34 | Alain | FS_VAS4SMS | 22.942 |  |  |  |  |
| 4333 | 1147 | Study on Service continuity between mobile and WLAN networks |  | 262d? | 2006-12-06 A | 2007-12-06 A | 100% | 2006-12-06 | 2007-12-06 | 262d? | finish no earlier than 2008-12-25 | S1 | 2096h | 2096h | FS_SMLSWLAN |  | NEC | Rel-8 | 34 | Alain | FS_SMLSWLAN | 22.937 |  |  | WLAN |  |
| 4334 | 1148 | Study on Services Alignment and Migration |  | 331d? | 2006-12-06 A | 2008-03-12 A | 100% | 2006-12-06 | 2008-03-12 | 331d? | finish no earlier than 2007-09-20 | S1 | 2648h | 2648h | FS_ServAl |  | Telefónica O2 | Rel-8 | 37 | Alain | FS_ServAl | 22.983 |  |  |  |  |

Notes:
- 4298: CP#42 completed. Updated WID CP-080278=>CP-080722 / WI rapporteur e-mail: philip.hodges@ericsson.com
- 4299: CP#42 completed. Updated WID CP-080278=>CP-080722 / WI rapporteur e-mail: philip.hodges@ericsson.com
- 4300: CP#42 completed. Updated WID CP-080278=>CP-080722 / WI rapporteur e-mail: philip.hodges@ericsson.com
- 4301: CP#42 completed. Updated WID CP-080278=>CP-080722 / WI rapporteur e-mail: philip.hodges@ericsson.com
- 4302: GP#39 completed / WI rapporteur e-mail: thomas.bitzer@alcatel-lucent.de
- 4303: GP#40 completed / WI rapporteur e-mail: Mungal Dhanda
- 4304: SP#42 completed by 22.071 CR0077
- 4305: GP#40 completed / WI rapporteur e-mail: Mungal Dhanda
- 4306: RP#42 WI closed at 95%. Considers Rel-9 performance requirements / WI rapporteur e-mail: Etienne Chaponniere (echaponn@qualcomm.com)
- 4307: GP#45 completed / WI rapporteur e-mail: mats.y.samuelsson@ericsson.com, hakan.e.grunditz@ericsson.com
- 4308: GP#45 completed / WI rapporteur e-mail: hakan.e.grunditz@ericsson.com
- 4309: GP#41 completed / WI rapporteur e-mail: mats.y.samuelsson@ericsson.com
- 4310: GP#40 completed / WI rapporteur e-mail: Franz.Segerer@ROHDE-SCHWARZ.COM
- 4311: SP#42 completed
- 4312: CP#57 completed / WI rapporteur e-mail: christer.holmberg@ericsson.com
- 4313: -
- 4314: SP#38 stopped. 25/07/08 Moved UID_31059 Study on All-IP Network (FS_AIPN/was AIPFS) to Rel-7 out of the stopped Rel-8 Feature UID_31067 Deleted - All-IP Network (AIPN) / WI rapporteur e-mail: c.masyu@nttdocomo.co.jp
- 4315: 22.258 withdrawn, superseded by 22.278 (UID 320022). SP#38 stopped / WI rapporteur e-mail: c.masyu@nttdocomo.co.jp
- 4316: SP#35 stopped / WI rapporteur e-mail: dhshim@lge.com
- 4317: SP#38 stopped
- 4318: SP#38 stopped (no support) / WI rapporteur e-mail: andre.jarvis@three.co.uk
- 4319: SP#38 stopped
- 4320: CP#47 work stopped/abandoned / WI rapporteur e-mail: Udo Willenbrink, Jacques Seif
- 4321: CP#47 work stopped/abandoned / WI rapporteur e-mail: Udo Willenbrink (uwillenbrink@comprion.com )
- 4322: CP#47 work stopped/abandoned / WI rapporteur e-mail: jacques.seif@gemalto.com
- 4323: GP#43 work stopped/abandoned (completion 0%) / WI rapporteur e-mail: arsi.heino@nokia.com
- 4324: -
- 4325: Spin-off Rel-8 Feature Customized Alerting Tone (CAT) Service UID_340029 / WI rapporteur e-mail: Qing Huang (huangqing@chinamobile.com)
- 4326: SP#35 completed. Spin-off SA3 Study on Security Aspects of Remote Provisioning and Change of Subscription for M2M (UID_370053). SP#40 Spin-off new Feature UID_410030 (NIMTC) / WI rapporteur e-mail: Juergen Merkel
- 4327: SP#38 completed / WI rapporteur e-mail: joerg.swetina@neclab.eu
- 4328: SP#37 completed. Spin-off New Feature UID_370026 Value-Added Services for Short Message Service (VAS4SMS) / WI rapporteur e-mail: Qing Huang (huangqing@chinamobile.com)
- 4329: SP#39 completed. Spin-off Rel-9 Feature UID_380057 (PWS) / WI rapporteur e-mail: mark.younge@t-mobile.com
- 4330: SP#37 completed. Spin-off new Feature UID_370084 (PPACR) / WI rapporteur e-mail: Katsuhiro NOGUCHI (noguchi@nttdocomo.co.jp)
- 4331: SP#38 completed. Spin-off New Feature UID_380062 (N3GTONSP). SP#40 WID updated SP-060930=>SP-080318. TR re-approved with new # 22.812=>22.912 / WI rapporteur e-mail: chris.friel@O2.com
- 4332: SP#38 completed. Spin-off New Feature UID_370026 (VAS4SM) / WI rapporteur e-mail: Qing Huang (huangqing@chinamobile.com)
- 4333: SP#38 completed / WI rapporteur e-mail: joerg.swetina@neclab.eu
- 4334: SP#39 completed. Spin-off Rel-9 Feature UID_330017 Services Alignment and Migration (ServAl) / WI rapporteur e-mail: chris.friel@O2.com

| ID | WBS | Task | Duration | Start | Finish | Complete | Baseline start | Baseline finish | Baseline duration | Constraint | Resources | Work | Actual work | Acronym | WI rapporteur name | WI rapporteur e-mail | Release | MCC resp | Acronym_3GU_Export | Impacted TSs and TRs | PCG approved | TSG approved | Special Focus Doc | Status Report | PCG stopped | TSG stopped |
| --- | --- | --- | --- | --- | --- | --- | --- | --- | --- | --- | --- | --- | --- | --- | --- | --- | --- | --- | --- | --- | --- | --- | --- | --- | --- | --- |
| 4335 | 1149 | **Study on 3GPP System Architecture Evolution** | 1115d? | 2004-12-03 A | 2009-03-12 A | 100% | 2004-12-03 | 2009-03-12 | 1115d? |  | S2; S3 | 34064h | 34064h | FS_SAE | Vodafone | chris.pudney@vodafone.com | Rel-8 | Maurice | FS_SAE |  |  |  |  |  |  |  |
| 4336 | 1149.1 | Stage 2 Interim conclusion for RAN Work to start | 990d? | 2004-12-03 A | 2008-09-18 A | 100% | 2004-12-03 | 2008-09-18 | 990d? | finish no earlier than 2005-09-23 | S2 | 7920h | 7920h | FS_SAE | Vodafone | chris.pudney@vodafone.com | Rel-8 | Maurice |  | 23.882 |  |  |  |  |  |  |
| 4337 | 1149.2 | Stage 2 study on 3GPP architectural development | 704d? | 2006-01-09 A | 2008-09-18 A | 100% | 2006-01-09 | 2008-09-18 | 704d? | finish no earlier than 2007-09-28 | S2 | 5632h | 5632h | FS_SAE | Vodafone | chris.pudney@vodafone.com | Rel-8 | Maurice |  | 23.882 |  |  |  |  |  |  |
| 4338 | 1149.3 | Security study for Inter-access mobility between non-3GPP and 3GPP system | 334d? | 2007-09-03 A | 2009-03-12 A | 100% | 2007-09-03 | 2009-03-12 | 334d? | finish no earlier than 2009-03-12 | S3 | 2672h | 2672h | FS_SAE | Nokia | dajiang.zhang@nokia.com | Rel-8 | Mirko |  | 33.821, 33.822 |  |  |  |  |  |  |
| 4339 | 1150 | Study on Stage 2 aspects of IMS Service Brokering | 589d? | 2006-06-19 A | 2008-09-18 A | 100% | 2006-06-19 | 2008-09-18 | 589d? | finish no earlier than 2008-09-18 | S2 | 4712h | 4712h | FS_ISB_ST2 | Telcordia | raquel@research.telcordia.com | Rel-8 | Maurice | FS_ISB_ST2 | 23.810 |  |  |  |  |  |  |
| 4340 | 1151 | Study on IMS utilizing multicast bearer services | 447d? | 2006-03-22 A | 2007-12-06 A | 100% | 2006-03-22 | 2007-12-06 | 447d? | finish no earlier than 2007-12-03 | S2 | 3576h | 3576h | FS_MLTICAST-IMS | Nokia Siemens Networks |  | Rel-8 | Maurice | FS_MLTICAST-IMS | 23.847 |  |  |  |  |  |  |
| 4341 | 1152 | Study on Multimedia Session Continuity | 291d? | 2007-04-26 A | 2008-06-05 A | 100% | 2007-04-26 | 2008-06-05 | 291d? | finish no earlier than 2008-06-05 | S2 | 2328h | 2328h | FS_MMSC | LG Electronics |  | Rel-8 | Maurice | FS_MMSC | 23.893 |  |  |  |  |  |  |
| 4342 | 1153 | **Study on centralized IMS service control** | 363d? | 2006-10-23 A | 2008-03-12 A | 100% | 2006-10-23 | 2008-03-12 | 363d? |  | S2; S1 | 10856h | 10856h | FS_ICS | Ericsson | peter.bleckert@ericsson.com | Rel-8 | Alain | FS_ICS |  | 21 | 38 |  |  |  |  |
| 4343 | 1153.1 | Study on centralized IMS services requirements | 268d? | 2007-03-05 A | 2008-03-12 A | 100% | 2007-03-05 | 2008-03-12 | 268d? | start no earlier than 2007-03-05 | S1 | 2144h | 2144h | FS_ICS-S1 | NEC | joerg.swetina@neclab.eu | Rel-8 | Alain | FS_ICS-S1 | 22.892 |  | 37 |  |  |  |  |
| 4344 | 1153.2 | Study on centralized IMS services control | 363d? | 2006-10-23 A | 2008-03-12 A | 100% | 2006-10-23 | 2008-03-12 | 363d? | finish no earlier than 2008-02-21 | S2 | 2904h | 2904h | FS_IMS_CSC | Alcatel-Lucent | andy.bennett@alcatel-lucent.com | Rel-8 | Maurice | FS_IMS_CSC | 23.892 |  |  |  |  |  |  |
| 4345 | 1154 | Study on Architecture of IMS based Customized Alerting Tone (CAT) | 208d? | 2007-12-04 A | 2008-09-18 A | 100% | 2007-12-04 | 2008-09-18 | 208d? | finish no earlier than 2008-09-08 | S2 | 1664h | 1664h | FS_CAT-St2 | China Mobile | WANG, Jing (wangjing@chinamobilecom) | Rel-8 | Maurice | FS_CAT-St2 | 23.872 | 21 | 38 |  |  |  |  |
| 4346 | 1155 | Study on Home (e)NodeB Security | 321d? | 2007-12-20 A | 2009-03-12 A | 100% | 2007-12-20 | 2009-03-12 | 321d? | finish no earlier than 2009-03-10 | S3 | 2568h | 2568h | FS_HNB_Sec | Huawei | yangyanmei@huawei.com | Rel-8 | Mirko | FS_HNB_Sec | 33.820 | 21 | 38 | HNB |  |  |  |
| 4347 | 1156 | Study on Transferring of emergency call data – in-band modem solution | 265d? | 2006-12-07 A | 2007-12-12 A | 100% | 2006-12-07 | 2007-12-12 | 265d? | finish no earlier than 2008-09-18 | S4 | 2120h | 2120h | eCALLIBMS | Airbiquity | lhong@airbiquity.com | Rel-8 | Paolo | eCALLIBMS | 26.967 |  |  | Public Safety (I-A) |  |  |  |
| 4348 | 1157 | Study on Element Operations Systems Function (EOSF) definition | 266d? | 2007-06-07 A | 2008-06-12 A | 100% | 2007-06-07 | 2008-06-12 | 266d? | finish no earlier than 2008-12-11 | S5 | 2128h | 2128h | OAM7-NIM-EOSF | China Mobile | Li Jian (lijian@chinamobile.com) | Rel-8 | Mirko | OAM7-NIM-EOSF | 32.819 |  |  |  |  |  |  |
| 4349 | 1158 | Study on SA5 MTOSI XML Harmonization | 351d? | 2006-05-10 A | 2007-09-12 A | 100% | 2006-05-10 | 2007-09-12 | 351d? | finish no earlier than 2007-12-14 | S5 | 2808h | 2808h | OAM8-NIM-XML | Nortel | jduguay@nortel.com | Rel-8 | Mirko | OAM8-NIM-XML | 32.818 |  |  |  |  |  |  |
| 4350 | 1159 | Study on Common Profile Storage (CPS) Framework of User Data for network services and management | 244d? | 2006-07-03 A | 2007-06-07 A | 100% | 2006-07-03 | 2007-06-07 | 244d? | finish no earlier than 2007-06-07 | S5 | 1952h | 1952h | OAM7-CPS | T-Mobile | istvan.aba@t-mobile.at | Rel-8 | Mirko | OAM7-CPS | 32.808 |  |  |  |  |  |  |
| 4351 | 1160 | Study on Management for LTE and SAE | 526d? | 2006-12-07 A | 2008-12-11 A | 100% | 2006-12-07 | 2008-12-11 | 526d? | finish no earlier than 2008-12-11 | S5 | 4208h | 4208h | FS_OAM_LTE_SAE | Ericsson | robert.petersen@ericsson.com | Rel-8 | Mirko | FS_OAM_LTE_SAE | 32.816 |  | 34 |  |  |  |  |
| 4352 | 1161 | Study on Charging Aspects of 3GPP System Evolution | 179d? | 2007-04-02 A | 2007-12-06 A | 100% | 2007-04-02 | 2007-12-06 | 179d? | finish no earlier than 2007-12-06 | S5 | 1432h | 1432h | FS_SAEcharg | Nokia Siemens Networks | Gerald.Goermer@nsn.com | Rel-8 | Mirko | FS_SAEcharg | 32.820 |  |  |  |  |  |  |
| 4353 | 1162 | Study on AS-MRFC media server control protocol | 583d? | 2006-03-22 A | 2008-06-13 A | 100% | 2006-03-22 | 2008-06-13 | 583d? | finish no earlier than 2008-06-13 | C1 | 4664h | 4664h | MRFC | Hewlett-Packard | mark.syrett@hp.com | Rel-8 | Frederic | MRFC | 24.880 |  |  |  |  |  |  |
| 4354 | 1163 | Study on IMS Restoration Procedures | 310d? | 2007-03-26 A | 2008-05-30 A | 100% | 2007-03-26 | 2008-05-30 | 310d? | finish no earlier than 2008-05-30 | C4 | 2480h | 2480h | FS_IMS_RP | Ericsson | german.blanco@ericsson.com | Rel-8 | Kimmo | FS_IMS_RP | 23.820 |  |  |  |  |  |  |
| 4355 | 1164 | Study on IMS Application Server Service Data Descriptions for AS interoperability | 261d? | 2007-09-14 A | 2008-09-12 A | 100% | 2007-09-14 | 2008-09-12 | 261d? | finish no earlier than 2008-09-12 | C4 | 2088h | 2088h | FS_IMS_ASIO | Alcatel-Lucent | Jean-Jacques Trottin | Rel-8 | Kimmo | FS_IMS_ASIO | 29.864 |  |  |  |  |  |  |
| 4356 | 1165 | Study on Customized Alerting Tone (CAT) solution for voice and video call in CS domain | 261d? | 2007-09-14 A | 2008-09-12 A | 100% | 2007-09-14 | 2008-09-12 | 261d? |  | C4 | 626.4h | 626.4h | FS_CAT_VVC_CS | China Mobile | zhanghao@chinamobile.com | Rel-8 | Kimmo | FS_CAT_VVC_CS | 29.882 |  |  |  |  |  |  |
| 4357 | 1166 | Study on InterWorking Function between MAP based and Diameter based interfaces | 266d? | 2007-11-30 A | 2008-12-05 A | 100% | 2007-11-30 | 2008-12-05 | 266d? | finish no earlier than 2008-12-05 | C4 | 2128h | 2128h | FS_MAP2Diam | Huawei | liming49985@huawei.com | Rel-8 | Kimmo | FS_MAP2Diam | 29.805 | 21 | 38 |  |  |  |  |
| 4358 | 1167 | Study on Scope of future HSPA Evolution for 1.28 Mcps TDD | 186d? | 2007-09-14 A | 2008-05-30 A | 100% | 2007-09-14 | 2008-05-30 | 186d? | finish no earlier than 2008-05-30 | R1 | 1488h | 1488h | FS_RAN-LCRTDDHSPAEvo | RITT | Xu Fei | Rel-8 | Patrick | FS_RAN-LCRTDDHSPAEvo | 25.824 |  | 37 |  | RP-080290 |  |  |
| 4359 | 1168 | Study on Synchronized E-DCH for UTRA FDD | 126d? | 2007-09-14 A | 2008-03-07 A | 100% | 2007-09-14 | 2008-03-07 | 126d? | finish no earlier than 2008-03-14 | R1 | 1008h | 1008h | FS_RAN-UplinkSync | Nokia Siemens Networks | Karri.Ranta-aho@nsn.com | Rel-8 | Patrick | FS_RAN-UplinkSync | 25.823 |  | 37 |  | RP-080068 |  |  |
| 4360 | 1169 | Study on Improved network controlled mobility between LTE and 3GPP2/mobile WiMAX radio technologies | 131d? | 2007-06-04 A | 2007-12-03 A | 100% | 2007-06-04 | 2007-12-03 | 131d? | finish no earlier than 2007-12-03 | R4 | 1048h | 1048h | FS_RAN-LTEmob | Motorola | hao.bi@Motorola.com | Rel-8 | Issam | FS_RAN-LTEmob | 36.938 |  |  |  | RP-070827 |  |  |
| 4361 | 1170 | Study on 3G Home NodeB/eNodeB | 325d? | 2007-03-05 A | 2008-05-30 A | 100% | 2007-03-05 | 2008-05-30 | 325d? | finish no earlier than 2008-05-30 | R4 | 2600h | 2600h | FS_RAN-HNBeNB | Motorola | howard.thomas@motorola.com | Rel-8 | Issam | FS_RAN-HNBeNB | 25.820 |  |  | HNB | RP-080289 |  |  |
| 4362 | 1171 | Study on A-interface over IP | 126d? | 2007-08-31 A | 2008-02-22 A | 100% | 2007-08-31 | 2008-02-22 | 126d? | finish no earlier than 2008-02-22 | GP | 1008h | 1008h | AINTIP | China Mobile, Ericsson | paul.schliwa-bertling@ericsson.com | Rel-8 | Paolo | AINTIP | 43.903 |  |  |  |  |  |  |
| 4363 | 1172 | Study on Multi-User Reusing-One-Slot | 782d? | 2007-11-16 A | 2010-11-12 A | 100% | 2007-11-16 | 2010-11-12 | 782d? | finish no earlier than 2010-11-12 | GP | 6248h | 6248h | MUROS | Nokia Siemens Networks | juergen.hofmann@nsn.com | Rel-8 | Paolo | MUROS | 45.914 |  |  |  |  |  |  |
| 4364 | 1173 | Study on Optimized Transmit Pulse Shape for Downlink EGPRS2-B | 657d? | 2007-11-16 A | 2010-05-21 A | 100% | 2007-11-16 | 2010-05-21 | 657d? | finish no earlier than 2010-05-27 | G1 | 5248.44h | 5248.44h | WIDER | Research In Motion, Nokia Siemens Networks | jdwyer@RIM.COM and eddie.riddington@nsn.com | Rel-8 | Paolo | WIDER | 45.913 |  |  |  |  |  |  |
| 4365 | 1174 | Deleted - Study on Mobility between 3GPP-WLAN Interworking and 3GPP Systems | 393d? | 2007-03-20 A | 2008-09-18 A | 100% | 2007-03-20 | 2008-09-18 | 393d? | finish no earlier than 2008-09-18 | S2 | 3144h | 3144h | FS_SM3GWLAN | Orange |  | Rel-8 | Maurice | FS_SM3GWLAN | withdrawn 23.827 |  |  | WLAN |  | PCG-21 | SP-41 |
| 4366 | 1175 | Deleted - equals 340035 -FS on Service continuity between mobile and WLAN networks | 75d? | 2007-09-03 A | 2007-12-14 A | 100% | 2007-09-03 | 2007-12-14 | 75d? | finish no earlier than 2007-12-14 | S1 | 600h | 600h | FSSCMobToW | BT | mike.meyerstein@bt.com | Rel-8 | Alain | FSSCMobToW | 22.937 |  | 37 |  |  | PCG-21 | SP-39 |
| 4367 | 1176 | Deleted - Study on Evaluation of LCS Control Plane Solution for EPS | 100d? | 2008-01-14 A | 2008-05-30 A | 100% | 2008-01-14 | 2008-05-30 | 100d? | finish no earlier than 2009-03-20 | S2 | 800h | 800h | FS_LCS_EPS | SiRF |  | Rel-8 | Maurice | FS_LCS_EPS | 23.891 |  | 38 |  |  | PCG-21 | SP-40 |
| 4368 | 1177 | Deleted - Study on HS-PDSCH serving cell change enhancements | 60d? | 2007-12-17 A | 2008-03-07 A | 100% | 2007-12-17 | 2008-03-07 | 60d? | finish no earlier than 2008-06-12 | R4 | 480h | 480h | FS_RAN-HSPDSCH | Qualcomm |  | Rel-8 | Issam | FS_RAN-HSPDSCH | none | 21 | 38 |  | RP-080070 | PCG-21 | RP-39 |
| 4369 | 1178 | Deleted - Study on Dual-Cell HSDPA operation | 261d? | 2007-08-15 A | 2009-03-06 A | 100% | 2007-08-15 | 2009-03-06 | 261d? | finish no earlier than 2009-03-06 | R1 | 2088h | 2088h | FS_RAN-DCHS | Qualcomm | Josef Blanz | Rel-8 | Patrick | FS_RAN-DCHS | withdrawn 25.825 v100 | 21 | 39 |  | RP-090066 | PCG-22 | RP-43 |
| 4370 | 1179 | Release 7 Features | 679d? | 2005-05-02 A | 2007-12-06 A | 100% | 2005-05-02 | 2007-12-06 | 679d? | start no earlier than 2000-01-01 | CP; GP; RP; SP | 21728h | 21728h |  |  |  | Rel-7 | All |  |  |  |  |  |  |  |  |

Notes:
- 4335: SP#43 completed
- 4336: SP#41 completed
- 4337: SP#41 completed
- 4338: SP#43 completed
- 4339: SP#41 completed. No spin-off activity proposed. [Note: IMS Service Brokering enhancements UID_31088 moved back from R8 to R7 to give a home to 22228CR0036_(Rel-7)_S1-051232. Hence, Rel-7 ISB has Stage 1 only (and is misaligned with Rel-7 Stages 2/3.]
- 4340: SP#38 completed
- 4341: SP#40 completed
- 4342: SP#39 completed
- 4343: SP#39 completed
- 4344: SP#39 completed
- 4345: SP#41 completed as Rel-8
- 4346: SP#43 completed. Linked to RAN4 Study on 3G Home NodeB/eNodeB (UID_350039) and to SA5 Study on Self-Organizing Networks (SON) related OAM interfaces for Home NodeB (UID_360007)
- 4347: SP#38 completed. Spin-off WID UID_34042 (eCall_Phase2)
- 4348: SP#40 completed. WID updated SP-050608=>SP-070307
- 4349: SP#37 completed. WID updated SP-050295=>SP-070305
- 4350: SP#36 completed. Spin-off New Feature UID_400034 User Data Convergence (UDC)
- 4351: SP#42 completed
- 4352: SP#38 completed
- 4353: CP#40 completed. Spin-off New Feature UID_380035 (MRFC_TS)
- 4354: CP#40 completed. Spin-off WID UID_400012 (IMS_RP)
- 4355: CP#41 completed. Linked to SA5 Study on Common Profile Storage framework UID_320006. Spin-off WID UID_410003 (IMS_ASIO)
- 4356: CP#41 completed. Spin-off WID under Feature CAT UID_340029
- 4357: CP#42 completed. Spin-off implementation Building Block UID_410007 (MAP2Diam) under the SAES Feature UID_320005
- 4358: RP#40 completed
- 4359: RP#39 completed
- 4360: RP#38 completed
- 4361: RP#40 completed
- 4362: GP#37 completed. Spin-off implementation Feature AoIP (A-interface over IP) UID_50591
- 4363: GP#48 completed as Rel-8. Spin-off implementation WI UID_420002 VAMOS (Voice services over Adaptive Multi-user channels on One Slot)
- 4364: GP#46 completed
- 4365: SP#41 stopped. Draft TR 23.827 content implemented in TS 23.327.
- 4366: SP#39 stopped
- 4367: SP#40 spin-off Feature UID_400038 (LCS_CPS_EPS). SP#40 FS stopped
- 4368: RP#39 stopped (no TR produced). Spin-off HS-DSCH Serving Cell Change Enhancements (UID_39003)
- 4369: RP#43 stopped (draft TR 25.825 v100 withdrawn). Conclusions in RP-090318 (RAN1 findings of the UTRA Multi-Carrier Evolution study). RP#42 New WI approved on Dual-Cell HSDPA operation on adjacent carriers (UID_400052)
- 4370: -

| ID | WBS | Task | Type | Duration | Start | Finish | Complete | Baseline start | Baseline finish | Baseline duration | Constraint | Resources | Work | Actual work | Acronym | WI rapporteur name | WI rapporteur e-mail | Release | MCC resp | Acronym_3GU_Export | TSG stopped | PCG approved | TSG approved | Status Report | Special Focus Doc |
| --- | --- | --- | --- | --- | --- | --- | --- | --- | --- | --- | --- | --- | --- | --- | --- | --- | --- | --- | --- | --- | --- | --- | --- | --- | --- |
| 4371 | 1180 | **Identification of Communication Services in IMS** |  | 620d? | 2005-05-02 A | 2007-09-14 A | 100% | 2005-05-02 | 2007-09-14 | 620d? |  | S2; S1; C1; S5 | 29048h | 29048h | ServID | Ericsson | stephen.terrill@ericsson.com | Rel-7 | Maurice | ServID |  |  |  |  |  |
| 4372 | 1180.1 | TR on ServID |  | 232d? | 2005-05-02 A | 2006-03-21 A | 100% | 2005-05-02 | 2006-03-21 | 232d? | finish no earlier than 2006-03-20 | S2 | 1856h | 1856h | ServID | Ericsson | stephen.terrill@ericsson.com | Rel-7 | Maurice |  |  |  |  |  |  |
| 4373 | 1180.2 | Stage 1,2 of ServID |  | 144d? | 2005-11-11 A | 2006-05-31 A | 100% | 2005-11-11 | 2006-05-31 | 144d? | start no earlier than 2005-11-11 | S1; S2 | 2304h | 2304h | ServID | Ericsson | stephen.terrill@ericsson.com | Rel-7 | Maurice |  |  |  |  |  |  |
| 4374 | 1180.3 | Stage 3 of ServID |  | 250d? | 2006-03-31 A | 2007-03-15 A | 100% | 2006-03-31 | 2007-03-15 | 250d? | finish no earlier than 2007-03-15 | C1 | 2000h | 2000h | ServID | Ericsson | christer.holmberg@ericsson.com | Rel-7 | Frederic |  |  |  |  |  |  |
| 4375 | 1180.4 | Charging of ServID |  | 381d? | 2006-03-31 A | 2007-09-14 A | 100% | 2006-03-31 | 2007-09-14 | 381d? | finish no earlier than 2007-09-14 | S5 | 3048h | 3048h | ServID | Orange | alain.bibas@orange-ft.com | Rel-7 | Mirko |  |  |  |  |  |  |
| 4376 | 1181 | **Supporting Globally Routable User Agent URIs in IMS** |  | 415d? | 2005-11-14 A | 2007-06-15 A | 100% | 2005-11-14 | 2007-06-15 | 415d? |  | S2; S1; C1 | 14920h | 14920h | GRUU | Research In Motion | Adrian Buckley (abuckley@rim.com) | Rel-7 | Maurice | GRUU |  |  |  |  |  |
| 4377 | 1181.1 | Deleted - TR on GRUU |  | 219d? | 2005-11-14 A | 2006-09-14 A | 100% | 2005-11-14 | 2006-09-14 | 219d? | finish no earlier than 2006-09-14 | S2 | 1752h | 1752h | GRUU | Research In Motion | Adrian Buckley (abuckley@rim.com) | Rel-7 | Maurice |  | SP-32 |  |  |  |  |
| 4378 | 1181.2 | Stage 1,2 of GRUU |  | 65d? | 2006-07-03 A | 2006-09-29 A | 100% | 2006-07-03 | 2006-09-29 | 65d? | start no earlier than 2006-07-03 | S1; S2 | 1040h | 1040h | GRUU | Research In Motion | Adrian Buckley (abuckley@rim.com) | Rel-7 | Maurice |  |  |  |  |  |  |
| 4379 | 1181.3 | Stage 3 of GRUU |  | 271d? | 2006-06-02 A | 2007-06-15 A | 100% | 2006-06-02 | 2007-06-15 | 271d? | finish no earlier than 2007-06-15 | C1 | 2168h | 2168h | GRUU | CableLabs | Bernie McKibben (b.mckibben@cablelabs.com) | Rel-7 | Frederic |  |  |  |  |  |  |
| 4380 | 1182 | **Multimedia Telephony Service for IMS** |  | 2919d? | 2006-02-01 A | 2017-03-15 A | 100% | 2006-02-01 | 2007-06-15 | 357d? |  | S1; C1; S4 | 81952h | 81952h | MTSI | Ericsson | peter.bleckert@ericsson.com | Rel-7 | Alain | MTSI |  | 35 | 69 |  |  |
| 4381 | 1182.1 | Stage 1 of MTSI |  | 173d? | 2006-02-01 A | 2006-09-29 A | 100% | 2006-02-01 | 2006-09-29 | 173d? | start no earlier than 2006-02-01 | S1 | 1384h | 1384h | MTSI-REQ | Ericsson | peter.bleckert@ericsson.com | Rel-7 | Alain | MTSI-REQ |  |  |  |  |  |
| 4382 | 1182.2 | Stage 3 of MTSI |  | 330d? | 2006-03-10 A | 2007-06-14 A | 100% | 2006-03-10 | 2007-06-14 | 330d? | finish no earlier than 2007-06-15 | C1 | 2640h | 2640h | MTSI | Ericsson | christer.holmberg@ericsson.com | Rel-7 | Frederic | MTSI |  |  |  |  |  |
| 4383 | 1182.3 | Media handling and interaction in MTSI |  | 262d? | 2006-03-15 A | 2007-03-15 A | 100% | 2006-03-15 | 2007-03-15 | 262d? | finish no earlier than 2007-03-15 | S4 | 2096h | 2096h | MTSI-MHI | Ericsson | olle.franceschi@ericsson.com | Rel-7 | Paolo | MTSI-MHI |  |  |  |  |  |
| 4384 | 1182.4 | UE Conformance Test Aspects - Multimedia Telephony Services for IMS (MTSI) over fixed access |  | 393d? | 2015-09-15 A | 2017-03-15 A | 100% |  |  |  | finish no earlier than 2017-03-15 | R5 | 3144h | 3144h | MTSI_FIXED_ACCESS-UEConTest | Telecom Italia |  | Rel-7 |  |  |  | 35 | 69 |  |  |
| 4385 | 1182.5 | UE Conformance Test Aspects – Multimedia Telephony Services for IMS (MTSI) over WLAN |  | 329d? | 2015-09-15 A | 2016-12-15 A | 100% |  |  |  | finish no earlier than 2016-12-15 | R5 | 2632h | 2632h | MTSI_WLAN-UEConTest | Ericsson |  | Rel-7 |  |  |  | 35 | 69 |  |  |
| 4386 | 1182.6 | Deleted - duplicates UID7039 - IMS Multimedia Telephony Service | milestone | 0d? | 2007-06-15 A | 2007-06-15 A | 100% | 2007-06-15 | 2007-06-15 | 0d? | start no earlier than 2007-06-15 | S1 |  |  | MMTEL | Ericsson | peter.bleckert@ericsson.com | Rel-7 | Alain | MMTEL | SP-32 |  |  |  |  |
| 4387 | 1183 | Multimedia Telephony Service for IMS (MTSI) - UE Conformance Testing |  | 387d | 2007-09-19 A | 2009-03-12 A | 100% | 2007-09-19 | 2009-03-12 | 387d | finish no earlier than 2009-03-13 | R5 | 1664h | 1664h | MTSI-UEConTest | Ericsson, Motorola | Leif.Mattisson@ericsson.com, Jacob.John@motorola.com | Rel-7 | Ingbert | MTSI-UEConTest |  |  |  | RP-090056 |  |
| 4388 | 1184 | TISPAN requirements for Multimedia Telephony with PSTN/ISDN simulation services |  | 58d? | 2007-09-18 A | 2007-12-06 A | 100% | 2007-09-18 | 2007-12-06 | 58d? | start no earlier than 2007-09-18 | S1 | 464h | 464h | TMMTEL7 |  |  | Rel-7 | Alain | TMMTEL7 |  |  | 37 |  |  |
| 4389 | 1185 | **Maintenance of TISPAN release 1 common IMS** |  | 180d? | 2007-07-02 A | 2008-03-07 A | 100% | 2007-07-02 | 2008-03-07 | 180d? |  | S2 | 5808h | 5808h | MCIMSTR1 | Ericsson | Raymond Forbes | Rel-7 | Maurice | MCIMSTR1 |  | 21 | 38 |  |  |
| 4390 | 1185.1 | SA1 aspects of MCIMSTR1 |  | 58d? | 2007-09-18 A | 2007-12-06 A | 100% | 2007-09-18 | 2007-12-06 | 58d? | finish no earlier than 2007-12-06 | S1 | 464h | 464h | MCIMSTR1-S1 | Telecom Italia | Marco.DeLuca1@telecomitalia.it | Rel-7 | Alain | MCIMSTR1-S1 |  | 21 | 38 |  |  |
| 4391 | 1185.2 | SA2 aspects of MCIMSTR1 |  | 58d? | 2007-09-18 A | 2007-12-06 A | 100% | 2007-09-18 | 2007-12-06 | 58d? | finish no earlier than 2007-12-06 | S2 | 464h | 464h | MCIMSTR1-S2 | Ericsson | Raymond Forbes | Rel-7 | Maurice | MCIMSTR1-S2 |  | 21 | 38 |  |  |
| 4392 | 1185.3 | SA1,SA2 part of Maintenance of TISPAN release 1 common IMS |  | 114d? | 2007-07-02 A | 2007-12-06 A | 100% | 2007-07-02 | 2007-12-06 | 114d? | finish no earlier than 2007-12-06 | S2; S1 | 1824h | 1824h | IMS_Comm_Mtce7 | BT, Ericsson | Dick Knight, Raymond Forbes | Rel-7 | Maurice | IMS_Comm_Mtce7 |  | 21 | 38 |  |  |
| 4393 | 1185.4 | Maintenance of TISPAN R1 |  | 86d? | 2007-11-09 A | 2008-03-07 A | 100% | 2007-11-09 | 2008-03-07 | 86d? | start no earlier than 2007-11-09 | C1; C3; C4 | 2064h | 2064h | MAINT_R1 | Alcatel-Lucent | Keith Drage (drage@alcatel-lucent.com) | Rel-7 | Frederic | MAINT_R1 |  | 21 | 38 |  |  |
| 4394 | 1186 | **PS domain and IMS impacts for supporting IMS Emergency calls (EMC1)** |  | 2934d? | 2000-09-18 A | 2011-12-09 A | 100% | 2000-09-18 | 2011-12-09 | 2934d? |  | S2; S1; C1; C4; IETF | 185422h | 185422h | EMC1 | Siemens | Rainer Liebhart | Rel-7 | Maurice | EMC1 |  |  |  |  | Public Safety (I-A) |
| 4395 | 10.1.1 | Service Requirements for IP-based emergency calls |  | 985d | 2000-09-18 A | 2004-06-25 A | 100% | 2000-09-18 | 2004-06-25 | 985d | finish no earlier than 2004-06-25 | S1 | 7880h | 7880h | EMC1 | Siemens | Rainer Liebhart | Rel-7 | Alain |  |  |  |  |  | Public Safety (I-A) |
| 4396 | 1186.2 | Study on Stage 2 for IMS-level solution |  | 668d? | 2003-02-26 A | 2005-09-16 A | 100% | 2003-02-26 | 2005-09-16 | 668d? | finish no earlier than 2005-09-16 | S2 | 5344h | 5344h | EMC1 | Siemens | Rainer Liebhart | Rel-7 | Maurice |  |  |  |  |  | Public Safety (I-A) |
| 4397 | 1186.3 | Study on Stage 2 for GPRS-level solution |  | 301d? | 2004-10-14 A | 2005-12-08 A | 100% | 2004-10-14 | 2005-12-08 | 301d? | finish no earlier than 2005-12-08 | S2 | 2408h | 2408h | EMC1 | Siemens | Rainer Liebhart | Rel-7 | Maurice |  |  |  |  |  | Public Safety (I-A) |
| 4398 | 1186.4 | Stage 2 Specification Phase - IMS-level |  | 200d? | 2005-09-05 A | 2006-06-09 A | 100% | 2005-09-05 | 2006-06-09 | 200d? | finish no earlier than 2006-06-09 | S2 | 1600h | 1600h | EMC1 | Siemens | Rainer Liebhart | Rel-7 | Maurice |  |  |  |  |  | Public Safety (I-A) |
| 4399 | 1186.5 | Deleted - Stage 2 Specification Phase - GPRS-level | milestone | 0d? | 2007-03-02 A | 2007-03-02 A | 100% | 2007-03-02 | 2007-03-02 | 0d? | start no earlier than 2007-03-02 | S2 |  |  | EMC1 | Siemens | Rainer Liebhart | Rel-7 | Maurice |  | SP-32 |  |  |  | Public Safety (I-A) |

Notes:
- 4371: WID approved SP#28. WID updated SP#32
- 4372: - / Impacted TSs and TRs: 23.816
- 4373: - / Impacted TSs and TRs: 22.228, 23.228, 23.203
- 4374: CP#32 approved WID / Impacted TSs and TRs: 23.218, 24.229
- 4375: - / Impacted TSs and TRs: 32.260, 32.298, 32.299
- 4376: SP#29 approved WID
- 4377: Abandoned
- 4378: SP#29 approved WID / Impacted TSs and TRs: 22.228, 23.228, 23.218, 24.229
- 4379: CP#32 approved WID / Impacted TSs and TRs: 24.229
- 4380: -
- 4381: - / Impacted TSs and TRs: 22.173
- 4382: - / Impacted TSs and TRs: 24.173
- 4383: - / Impacted TSs and TRs: 26.114
- 4384: tested: REL-7 SA/CT WI MTSI;1/1/16: Compl:0%->5%; 22/3/16: Compl:5%->15%1/7/16: Compl:15%->30% ; 21/...
- 4385: tested: REL-7 WI MTSI; 1/1/16: Compl:0%->5%1/1/16: WID: RP-151334->RP-15177022/3/16: Compl:5%->10%
- 4386: - / Impacted TSs and TRs: 22.173
- 4387: RP#43 completed. Linked UID_7038 (MTSI) / Impacted TSs and TRs: 34.123-1, 34.123-2, 34.123-3, 34.229-1, 34.229-2
- 4388: - / Impacted TSs and TRs: 22.273 (EI 181 002 maintenance)
- 4389: - / Impacted TSs and TRs: http://www.3gpp.org/specs/TISPAN-IMS-ansfer.htm
- 4390: - / Impacted TSs and TRs: 22.173, 22.273
- 4391: - / Impacted TSs and TRs: 23.406, 23.417, 23.508,23.509, 23.511
- 4392: SP#38 completed / Impacted TSs and TRs: 22.173, 22.273, 22.401, 23.406, 23.417, 23.508, 23.509, 23.511
- 4393: CP#39 completed / Impacted TSs and TRs: 24.404, 24.405, 24.406, 24.407, 24.408, 24.410, 24.411, 24.416, 29.421, 24.423, 24.428, 24.429, 29.433, 24.441, 24.403, 29.427, 24.430, 29.412
- 4394: - / Impacted TSs and TRs: EMC1
- 4395: - / Impacted TSs and TRs: 22.101
- 4396: - / Impacted TSs and TRs: 23.867
- 4397: - / Impacted TSs and TRs: 23.867
- 4398: - / Impacted TSs and TRs: 23.060, 23.167, 23.203, 23.221, 23.228, 23.234, 23.271, 23.406
- 4399: -

| ID | WBS | Task | Type | Duration | Start | Finish | Complete | Baseline start | Baseline finish | Baseline duration | Constraint | Resources | Work | Actual work | Acronym | WI rapporteur name | WI rapporteur e-mail | Release | MCC resp | Special Focus Doc | Impacted TSs and TRs | PCG approved | TSG approved | TSG stopped | Acronym_3GU_Export | Created at | Status Report |
| --- | --- | --- | --- | --- | --- | --- | --- | --- | --- | --- | --- | --- | --- | --- | --- | --- | --- | --- | --- | --- | --- | --- | --- | --- | --- | --- | --- |
| 4400 | 10.1 | **Emergency Call Enhancements for IP& PS Based Calls – stage 3** |  | 1549d? | 2006-01-09 A | 2011-12-09 A | 100% | 2006-01-09 | 2011-12-09 | 1549d? |  | C1; C4; IETF | 50829.8h | 50829.8h | EMC1 | Ericsson | alf.heidermark@ericsson.com | Rel-7 | Frederic | Public Safety (I-A) |  |  |  |  |  |  |  |
| 4401 | 10.1.2 | CT1 IMS aspects to support IMS Emergency sessions |  | 350.82d | 2006-01-09 A | 2007-06-15 A | 100% | 2006-01-09 | 2007-06-15 | 350.82d | finish no earlier than 2007-06-15 | C1 | 2806.57h | 2806.57h | EMC1 | Ericsson | alf.heidermark@ericsson.com | Rel-7 | Frederic | Public Safety (I-A) | 24.229 |  |  |  |  |  |  |
| 4402 | 1186.6.2 | (IETF) CT1 IMS aspects to support IMS Emergency sessions |  | 452d? | 2006-01-09 A | 2011-12-09 A | 100% | 2006-01-09 | 2011-12-09 | 452d? | finish no earlier than 2011-12-09 | C1-IETF | 3608h | 3608h | EMC1 | Keith Drage |  | Rel-7 | Frederic | Public Safety (I-A) | RFC 6442 (was draft-ietf-sipcore-location-conveyance) | 27 | 52 |  |  |  |  |
| 4403 | 10.1.2 | Deleted - CT3 IMS aspects to support IMS Emergency sessions |  | 95d | 2006-05-08 A | 2006-09-15 A | 100% | 2006-05-08 | 2006-09-15 | 95d | finish no earlier than 2006-09-15 | C3 | 760h | 760h | EMC1 | Ericsson | alf.heidermark@ericsson.com | Rel-7 | Adrian | Public Safety (I-A) | 29.163 |  |  | CP-33 |  |  |  |
| 4404 | 10.1.5 | Deleted - CT3 PS domain aspects to support IMS Emergency sessions |  | 95d | 2006-05-08 A | 2006-09-15 A | 100% | 2006-05-08 | 2006-09-15 | 95d | start no earlier than 2006-05-08 | C3 | 760h | 760h | EMC1 | Ericsson | alf.heidermark@ericsson.com | Rel-7 | Adrian | Public Safety (I-A) | 29.061 |  |  | CP-33 |  |  |  |
| 4405 | 10.1.5 | CT1 PS domain aspects to support IMS Emergency sessions |  | 349.9d | 2006-01-09 A | 2007-06-15 A | 100% | 2006-01-09 | 2007-06-15 | 349.9d | finish no earlier than 2007-06-15 | C1 | 2799.2h | 2799.2h | EMC1 | Ericsson | alf.heidermark@ericsson.com | Rel-7 | Frederic | Public Safety (I-A) | 24.008, 24.234 |  |  |  |  |  |  |
| 4406 | 10.1.5 | CT4 PS domain aspects to support IMS Emergency sessions |  | 365d | 2006-01-09 A | 2007-06-01 A | 100% | 2006-01-09 | 2007-06-01 | 365d | finish no earlier than 2007-06-01 | C4 | 2920h | 2920h | EMC1-GPRSc4 | Ericsson | alf.heidermark@ericsson.com | Rel-7 | Kimmo | Public Safety (I-A) | 29.060 |  |  |  | EMC1-GPRSc4 |  |  |
| 4407 | 1187 | IMS Support of Conferencing |  | 355d? | 2005-11-04 A | 2007-03-15 A | 100% | 2005-11-04 | 2007-03-15 | 355d? | finish no earlier than 2007-03-15 | C1 | 2840h | 2840h | IMSconf | Alcatel-Lucent | Keith Drage (drage@alcatel-lucent.com) | Rel-7 | Frederic |  | 24.147, 24.229 |  |  |  | IMSconf |  |  |
| 4408 | 1188 | Performance Characterization of VoIMS over HSDPA\EUL channels |  | 713d? | 2005-03-15 A | 2007-12-06 A | 100% | 2005-03-15 | 2007-12-06 | 713d? | finish no earlier than 2007-12-06 | S4 | 5704h | 5704h | VoIMS-PCVoIMS | Alcatel-Lucent | mcgowan@alcatel-lucent.com | Rel-7 | Paolo |  | 26.935 |  |  |  | VoIMS-PCVoIMS |  |  |
| 4409 | 1189 | **WLAN-UMTS Interworking Phase 2** |  | 371d? | 2004-01-05 A | 2005-06-07 A | 100% | 2004-01-05 | 2005-06-07 | 371d? |  | S1; S2 | 6856h | 6856h | WLAN2 | Telenor | frederic.paint@telenor.com | Rel-7 | Alain | WLAN | 33.234 (SP-36 SA3 CRs approved) |  |  |  | WLAN2, WLAN-SC |  |  |
| 4410 | 1189.1 | Stage 1 on Session Continuity |  | 115d? | 2004-01-05 A | 2004-06-11 A | 100% | 2004-01-05 | 2004-06-11 | 115d? | start no earlier than 2004-01-05 | S1 | 920h | 920h | WLAN2 |  |  | Rel-7 | Alain | WLAN | 22.234 |  |  |  |  | SP-24 |  |
| 4411 | 1189.2 | Stage 2 on Session Continuity: covered by SAE | milestone | 0d? | 2005-06-07 A | 2005-06-07 A | 100% | 2005-06-07 | 2005-06-07 | 0d? | finish no earlier than 2005-06-07 | S2 |  |  | WLAN2 |  |  | Rel-7 | Maurice | WLAN |  |  |  |  |  |  |  |
| 4412 | 1190 | **WLAN Interworking – Private Network access from WLAN 3GPP IP Access** |  | 252d? | 2005-10-10 A | 2006-09-26 A | 100% | 2005-10-10 | 2006-09-26 | 252d? |  | S2; C1; C3; C4 | 17704h | 17704h | WLANPNA | NEC | Toshiyuki Tamura (tamurato@aj.jp.nec.com) | Rel-7 | Maurice | WLAN |  |  |  |  | WLANPNA |  |  |
| 4413 | 1190.1 | WLAN-PNA - Stage 2 |  | 185d? | 2005-10-10 A | 2006-06-23 A | 100% | 2005-10-10 | 2006-06-23 | 185d? | start no earlier than 2005-10-10 | S2 | 1480h | 1480h | WLANPNA-st2 | NEC | Toshiyuki Tamura (tamurato@aj.jp.nec.com) | Rel-7 | Maurice | WLAN | 23.234, 33.234 |  |  |  | WLANPNA-st2 |  |  |
| 4414 | 1190.2 | **WLAN-PNA - Stage 3** |  | 170d? | 2006-02-01 A | 2006-09-26 A | 100% | 2006-02-01 | 2006-09-26 | 170d? |  | C1; C3; C4 | 8160h | 8160h | WLANPNA-st3 | NEC |  | Rel-7 | Frederic | WLAN |  |  |  |  | WLANPNA-st3 |  |  |
| 4415 | 1190.2.1 | CT1 aspets for WLAN-PNA |  | 170d? | 2006-02-01 A | 2006-09-26 A | 100% | 2006-02-01 | 2006-09-26 | 170d? | start no earlier than 2006-02-01 | C1 | 1360h | 1360h | WLANPNA-st3 | NEC |  | Rel-7 | Frederic | WLAN | 24.234 |  |  |  |  |  |  |
| 4416 | 1190.2.2 | CT3 aspets for WLAN-PNA |  | 170d? | 2006-02-01 A | 2006-09-26 A | 100% | 2006-02-01 | 2006-09-26 | 170d? | start no earlier than 2006-02-01 | C3 | 1360h | 1360h | WLANPNA-st3 | NEC |  | Rel-7 | Adrian | WLAN | 29.161 |  |  |  |  |  |  |
| 4417 | 1190.2.3 | Deleted - CT4 aspets for WLAN-PNA |  | 170d? | 2006-02-01 A | 2006-09-26 A | 100% | 2006-02-01 | 2006-09-26 | 170d? | start no earlier than 2006-02-01 | C4 | 1360h | 1360h | WLANPNA-st3 | NEC |  | Rel-7 | Kimmo | WLAN | 29.234 |  |  | CP-32 |  |  |  |
| 4418 | 1191 | **Enhancements to support QoS provisioning over 3GPP/WLAN Interworking** |  | 520d? | 2005-03-14 A | 2007-03-09 A | 100% | 2005-03-14 | 2007-03-09 | 520d? |  | S2; C4; C1 | 16680h | 16680h | WLANQOS | Samsung |  | Rel-7 | Maurice | WLAN |  |  |  |  | WLANQOS |  |  |
| 4419 | 1191.1 | Deleted - TR on support of QoS on WLAN |  | 232d? | 2005-03-14 A | 2006-01-31 A | 100% | 2005-03-14 | 2006-01-31 | 232d? | start no earlier than 2005-03-14 | S2 | 1856h | 1856h | WLANQOS | Samsung |  | Rel-7 | Maurice | WLAN | 23.836 |  |  | SP-32 |  |  |  |
| 4420 | 1191.2 | Stage 2 on support of QoS over 3GPP/WLAN interworking |  | 108d? | 2006-02-01 A | 2006-06-30 A | 100% | 2006-02-01 | 2006-06-30 | 108d? | start no earlier than 2006-02-01 | S2 | 864h | 864h | WLANQOS | Samsung |  | Rel-7 | Maurice | WLAN | 23.234 |  |  |  |  |  |  |
| 4421 | 1191.3 | Stage 3 CT4 on support of QoS over 3GPP/WLAN Interworking |  | 121d? | 2006-09-22 A | 2007-03-09 A | 100% | 2006-09-22 | 2007-03-09 | 121d? | finish no earlier than 2007-03-09 | C4 | 968h | 968h | WLANQOS | Huawei | zhang.peng@huawei.com | Rel-7 | Kimmo | WLAN | 29.234, 23.008 |  |  |  |  |  |  |
| 4422 | 1191.4 | Stage 3 CT1 on support of QoS over 3GPP/WLAN Interworking |  | 64d? | 2006-09-04 A | 2006-11-30 A | 100% | 2006-09-04 | 2006-11-30 | 64d? | finish no earlier than 2006-11-30 | C1 | 512h | 512h | WLANQOS | Huawei | zhang.peng@huawei.com | Rel-7 | Frederic | WLAN | 24.234 |  | 34 |  |  |  |  |
| 4423 | 1192 | **Location Services enhancements** |  | 906d? | 2004-06-28 A | 2007-12-17 A | 100% | 2004-06-28 | 2007-12-17 | 906d? |  | S1; S2; GP; C4; R2 | 81525.6h | 81525.6h | LCS3 |  |  | Rel-7 | Alain |  |  |  |  |  | LCS3 |  |  |
| 4424 | 1192.1 | Stage 2 for LCS3 (including IMS emergency location aspects) |  | 446d? | 2004-12-31 A | 2006-09-15 A | 100% | 2004-12-31 | 2006-09-15 | 446d? | finish no earlier than 2006-09-15 | S2 | 3568h | 3568h | LCS3 | SiRF | brodilitz@sirf.com | Rel-7 | Maurice |  | 23.271 |  |  |  |  |  |  |
| 4425 | 1192.2 | LCS Enhancements related to Location-Based Services |  | 695d? | 2005-01-03 A | 2007-08-31 A | 100% | 2005-01-03 | 2007-08-31 | 695d? | finish no earlier than 2007-08-31 | GP | 5560h | 5560h | LCS3-LBS | SiRF | kjudge@sirf.com | Rel-7 | Paolo |  | 43.059, 44.031, 48.008, 49.031 |  |  |  | LCS3-LBS |  |  |
| 4426 | 1192.3 | CT4 aspects for LCS UEPos-LBS |  | 240d? | 2006-01-02 A | 2006-12-01 A | 100% | 2006-01-02 | 2006-12-01 | 240d? | finish no earlier than 2006-12-01 | C4 | 1920h | 1920h | LCS3-UEPos-LBS | SiRF | brodilitz@sirf.com | Rel-7 | Kimmo |  | 24.030, 24.080, 29.002 |  |  |  | LCS3-UEPos-LBS |  |  |
| 4427 | 1192.4 | UE positioning - Velocity |  | 394d? | 2005-03-15 A | 2006-09-15 A | 100% | 2005-03-15 | 2006-09-15 | 394d? | finish no earlier than 2006-09-15 | R2 | 3152h | 3152h | LCS3-UEPos-Velocity | SiRF | BRodilitz@SiRF.com | Rel-7 | Yong-Jun |  | 25.305, 25.331, 25.410, 25.413, 25.453 |  |  |  | LCS3-UEPos-Velocity |  | RP-060459 |
| 4428 | 1192.5 | Inclusion of Uplink TDOA UE positioning method in the UTRAN specifications |  | 849d? | 2004-09-15 A | 2007-12-17 A | 100% | 2004-09-15 | 2007-12-17 | 849d? | finish no earlier than 2007-12-17 | R2 | 6792h | 6792h | LCS3-UEPos-UTDOA | TruePosition | Robert Gross (rgross@polariswireless.com) | Rel-7 | Yong-Jun |  | 25.305, 25.453, new TS 25.111 |  |  |  | LCS3-UEPos-UTDOA |  | RP-070797 |

Notes:
- 4400: -
- 4401: -
- 4402: CP#54 completed
- 4403: Cancelled for Rel-7 and there is no corresponding Rel-8 WI
- 4404: Cancelled for Rel-7 and there is no corresponding Rel-8 WI
- 4405: -
- 4406: -
- 4407: CP#35 revised WID
- 4408: -
- 4409: Created at SP#27 because of WLAN items belonging to Rel-7. Acronym changed from "WLAN2, WLAN-SC"
- 4410: Acronym changed from "WLAN2, WLAN-SC"
- 4411: Acronym changed from "WLAN2, WLAN-SC"
- 4412: -
- 4413: Approved at SP#29
- 4414: Approved at CP#29
- 4415: Approved at CP#29
- 4416: Approved at CP#29
- 4417: CT4#31; no impacts identified, therefore completed. CP-32 stopped
- 4418: Moved from FS section Feb 06. SP-30 updated WID
- 4419: SP#32 stopped
- 4420: SP#30 updated WID
- 4421: CP#33 approved WID
- 4422: CP#33 approved WID
- 4423: -
- 4424: SP#27 approved WID
- 4425: -
- 4426: -
- 4427: -
- 4428: -

| ID | WBS | Task | Duration | Start | Finish | Complete | Baseline start | Baseline finish | Baseline duration | Constraint | Resources | Work | Actual work | Acronym | WI rapporteur name | WI rapporteur e-mail | Release | MCC resp | Special Focus Doc | Acronym_3GU_Export | TSG stopped | TSG approved | Status Report | PCG approved |
| --- | --- | --- | --- | --- | --- | --- | --- | --- | --- | --- | --- | --- | --- | --- | --- | --- | --- | --- | --- | --- | --- | --- | --- | --- |
| 4429 | 1192.6 | **LCS for 3GPP Interworking WLAN** | 700d? | 2004-06-28 A | 2007-03-02 A | 100% | 2004-06-28 | 2007-03-02 | 700d? |  | S1; S2 | 17501.6h | 17501.6h | LCS3-IWLAN | Telcordia | Mike Loushine | Rel-7 | Alain | WLAN | LCS3-IWLAN |  |  |  |  |
| 4430 | 1192.6.1 | FS on 3GPP system to WLAN Interworking with LCS | 512.7d? | 2004-06-28 A | 2006-06-30 A | 100% | 2004-06-28 | 2006-06-30 | 512.7d? | finish no earlier than 2005-09-29 | S1 | 4101.6h | 4101.6h | LCS3-IWLAN-FSs1 | Telcordia | Mike Loushine | Rel-7 | Alain |  | LCS3-IWLAN-FSs1 |  |  |  |  |
| 4431 | 1192.6.2 | Deleted - Study of work on an LCS architecture for I-WLAN. | 180d? | 2006-06-26 A | 2007-03-02 A | 100% | 2006-06-26 | 2007-03-02 | 180d? | finish no earlier than 2007-03-02 | S2 | 1440h | 1440h | LCS3-IWLAN-FSs2 | LG Electronics | dhshim@lge.com ; phede@lge.com | Rel-7 | Maurice |  | LCS3-IWLAN-FSs2 | SP-35 |  |  |  |
| 4432 | 1192.6.3 | Stage 2 for LCS architecture for I-WLAN | 95d? | 2006-10-23 A | 2007-03-02 A | 100% | 2006-10-23 | 2007-03-02 | 95d? | finish no earlier than 2007-03-02 | S2 | 760h | 760h | LCS3-IWLAN | LG Electronics | dhshim@lge.com ; phede@lge.com | Rel-7 | Maurice |  | LCS3-IWLAN |  | 34 |  |  |
| 4433 | 1192.7 | Deleted - UE positioning Rel-7 | 849d? | 2004-09-15 A | 2007-12-17 A | 100% | 2004-09-15 | 2007-12-17 | 849d? |  | RP | 6792h | 6792h | LCS3-UEpos |  |  | Rel-7 | Yong-Jun |  | LCS3-UEpos | RP-38 |  |  |  |
| 4434 | 1193 | **MBMS Enhancements** | 625d? | 2005-07-11 A | 2007-11-30 A | 100% | 2005-07-11 | 2007-11-30 | 625d? |  | S1; R1; C3 | 20844.6h | 20844.6h | MBMSE | China Mobile | liuhongyfw@chinamobile.com | Rel-7 | Alain |  | MBMSE |  |  |  |  |
| 4435 | 1193.1 | Stage 1 of MBMSE | 109d? | 2005-07-11 A | 2005-12-08 A | 100% | 2005-07-11 | 2005-12-08 | 109d? | finish no earlier than 2005-12-08 | S1 | 872h | 872h | MBMSE | China Mobile | liuhongyfw@chinamobile.com | Rel-7 | Alain |  |  |  | 34 |  |  |
| 4436 | 1193.2 | MBMS FDD Physical layer Enhancements | 117.29d? | 2006-12-15 A | 2007-06-04 A | 100% | 2006-12-15 | 2007-06-04 | 117.29d? | finish no earlier than 2007-06-04 | R1 | 938.32h | 938.32h | MBMSE-RANPhysFDD | Ericsson | Lars.Lindbom@ericsson.com | Rel-7 | Patrick |  | MBMSE-RANPhysFDD |  | 34 | RP-070290 |  |
| 4437 | 1193.3 | MBMS TDD Physical layer Enhancements | 117.29d? | 2006-12-15 A | 2007-06-04 A | 100% | 2006-12-15 | 2007-06-04 | 117.29d? | finish no earlier than 2007-06-04 | R1 | 938.32h | 938.32h | MBMSE-RANPhysTDD | IPWireless | Nicholas Anderson | Rel-7 | Patrick |  | MBMSE-RANPhysTDD |  | 34 | RP-070291 |  |
| 4438 | 1193.4 | MBMS Low Chip Rate TDD Physical Layer Enhancement | 127d? | 2007-03-16 A | 2007-09-10 A | 100% | 2007-03-16 | 2007-09-10 | 127d? | finish no earlier than 2007-09-10 | R1 | 1016h | 1016h | MBMSE-RANPhysLCRTDD | RITT | Lin Hui | Rel-7 | Patrick |  | MBMSE-RANPhysLCRTDD |  |  | RP-070292 |  |
| 4439 | 1193.5 | MBMS Mz interface | 260d? | 2006-12-04 A | 2007-11-30 A | 100% | 2006-12-04 | 2007-11-30 | 260d? | finish no earlier than 2007-05-11 | C3 | 2080h | 2080h | MBMSMz | Huawei | Deng Tingting (ttdeng@huawei.com) | Rel-7 | Adrian |  | MBMSMz |  | 34 |  |  |
| 4440 | 1194 | **MBMS - UE Conformance Testing** | 657d? | 2007-06-01 A | 2009-12-04 A | 100% | 2007-06-01 | 2009-12-04 | 657d? |  | R5 | 13848h | 13848h | MBMSE_UEConTest |  |  | Rel-7 | Ingbert |  | MBMSE_UEConTest |  | 40 |  | 21 |
| 4441 | 1194.1 | Conformance Test Aspects – MBMS TDD Physical layer Enhancements – MBSFN for HCR and VHCR TDD | 336d? | 2007-06-01 A | 2008-09-12 A | 100% | 2007-06-01 | 2008-09-12 | 336d? | start no earlier than 2007-06-01 | R5 | 2688h | 2688h | MBMSE-RANPhysTDD_UEConTest | IPWireless | tspeight@ipwireless.com | Rel-7 | Ingbert |  | MBMSE-RANPhysTDD_UEConTest |  |  | RP-080541 |  |
| 4442 | 1194.2 | Conformance Test Aspects – MBMS LCR TDD Physical Layer Enhancement | 342d? | 2008-05-30 A | 2009-09-18 A | 100% | 2008-05-30 | 2009-09-18 | 342d? | finish no earlier than 2009-09-18 | R5 | 2728h | 2728h | MBMSE-RANPhysLCRTDD_UEConTest | CATT | chenxiaozhong@datangmobile.cn | Rel-7 | Ingbert |  | MBMSE-RANPhysLCRTDD_UEConTest |  | 40 | RP-090715 | 21 |
| 4443 | 1194.3 | Conformance Test Aspects – MBSFN for FDD | 397d? | 2008-05-30 A | 2009-12-04 A | 100% | 2008-05-30 | 2009-12-04 | 397d? | finish no earlier than 2009-12-04 | R5 | 3176h | 3176h | MBMSE-UEConTest_RANPhysFDD | Huawei | Xiang Li (trica_li@huawei.com) | Rel-7 | Ingbert |  | MBMSE-UEConTest_RANPhysFDD |  | 40 | RP-091214 | 21 |
| 4444 | 1195 | MBMS User Service Extensions | 392d? | 2005-12-07 A | 2007-06-07 A | 100% | 2005-12-07 | 2007-06-07 | 392d? | finish no earlier than 2007-06-07 | S4 | 3136h | 3136h | MBMSUSE | Ericsson | Thorsten.Lohmar@ericsson.com | Rel-7 | Paolo |  | MBMSUSE |  |  |  |  |
| 4445 | 1196 | **Advanced Global Navigation Satellite System (AGNSS) concept** | 830d? | 2004-06-28 A | 2007-08-31 A | 100% | 2004-06-28 | 2007-08-31 | 830d? |  | S1; S2; GP; R2 | 36129.6h | 36129.6h | LCS3-AGNSS | Alcatel | Michel.monnerat@thalesaleniaspace.com | Rel-7 | Alain |  | LCS3-AGNSS |  |  |  |  |
| 4446 | 1196.1 | Stage 1/2 for Towards AGNSS Concept | 1d? | 2007-02-16 A | 2007-02-16 A | 100% | 2007-02-16 | 2007-02-16 | 1d? | start no earlier than 2007-02-16 | S1; S2 | 16h | 16h | AGNSS | Alcatel | richard.couty@space.alcatel.fr | Rel-7 | Alain |  | AGNSS |  |  |  |  |
| 4447 | 1196.2 | Towards AGNSS Concept | 811.2d? | 2004-06-28 A | 2007-08-31 A | 100% | 2004-06-28 | 2007-08-31 | 811.2d? | finish no earlier than 2007-08-31 | GP | 6489.6h | 6489.6h | AGNSS-GP | Alcatel | richard.couty@space.alcatel.fr | Rel-7 | Paolo |  | AGNSS-GP |  |  |  |  |
| 4448 | 1196.3 | Global Navigation Satellite System (GNSS) in UTRAN | 383d? | 2005-12-15 A | 2007-06-04 A | 100% | 2005-12-15 | 2007-06-04 | 383d? | finish no earlier than 2007-06-04 | R2 | 3064h | 3064h | LCS3-GNSS-UTRAN | France Telecom | alain.abinakhoul@francetelecom.com | Rel-7 | Yong-Jun |  | LCS3-GNSS-UTRAN |  |  | RP-070482 |  |
| 4449 | 1197 | A-GPS Minimum Performance | 351d? | 2006-04-28 A | 2007-08-31 A | 100% | 2006-04-28 | 2007-08-31 | 351d? | finish no earlier than 2007-08-31 | G1; G3 | 5616h | 5616h | GAGR | Spirent | richard.catmur@spirentcom.com | Rel-7 | Paolo |  | GAGR |  |  |  |  |
| 4450 | 1198 | **Unstructured Supplementary Service Data (USSD) message delivery and transfer to USIM** | 376d? | 2004-03-05 A | 2005-08-12 A | 100% | 2004-03-05 | 2005-08-12 | 376d? |  | S1; C6 | 8778.4h | 8778.4h | USSD-USIM | Axalto | Christophe Dubois (cdubois@axalto.com) | Rel-7 | Alain |  | USSD-USIM |  |  |  |  |
| 4451 | 1198.1 | Stage 1 for USSD message delivery and transfer to USIM | 152d? | 2004-03-18 A | 2004-10-15 A | 100% | 2004-03-18 | 2004-10-15 | 152d? | start no earlier than 2004-03-18 | S1 | 1216h | 1216h | USSD-USIM | Axalto | Christophe Dubois (cdubois@axalto.com) | Rel-7 | Alain |  |  |  |  |  |  |
| 4452 | 1198.2 | Alignment with requirements regarding USSD usage | 193.3d? | 2004-03-05 A | 2005-08-12 A | 100% | 2004-03-05 | 2005-08-12 | 193.3d? | finish no earlier than 2005-08-12 | C6 | 1546.4h | 1546.4h | USSD-USIM | Axalto | Christophe Dubois (cdubois@axalto.com) | Rel-7 | Xavier |  |  |  |  |  |  |

Notes:
- 4429: -
- 4430: - / Impacted TSs and TRs: new TR 22.935
- 4431: SP#41 TR withdrawn. All work transferred to specs / Impacted TSs and TRs: 23.837
- 4432: - / Impacted TSs and TRs: 23.234, 23.271, 23.167
- 4433: -
- 4434: -
- 4435: - / Impacted TSs and TRs: 22.146, 22.246, 22.228
- 4436: - / Impacted TSs and TRs: 25.211, 25.212, 25.213, 25.101, 25.104, 25.331, 25.433, 25.346, 25.306
- 4437: - / Impacted TSs and TRs: 25.346, 25.221, 25.222, 25.223, 25.224, 25.306, 25.331, 25.402, 25.433, 25.102, 25.105, 25.123
- 4438: - / Impacted TSs and TRs: 25.346, 25.221, 25.222, 25.223, 25.224, 25.306, 25.331, 25.402, 25.433, 25.102, 25.105, 25.123
- 4439: - / Impacted TSs and TRs: 29.061
- 4440: Linked to Rel-7 Feature UID_31084 (MBMSE)
- 4441: RP#41 completed / Impacted TSs and TRs: 34.108, 34.122, 34.123-1/2/3
- 4442: RP#45 completed / Impacted TSs and TRs: 34.108, 34.123-1
- 4443: RP#46 completed / Impacted TSs and TRs: 34.108, 34.109, 34.121-1, 34.121-2, 34.123-1, 34.123-2, 34.123-3
- 4444: - / Impacted TSs and TRs: 26.346, 26.946
- 4445: -
- 4446: - / Impacted TSs and TRs: 22.071, 23.271
- 4447: GP#36 completed / Impacted TSs and TRs: 43.030, 43.059, 44.031, 44.035, 44.071, 48.008, 48.018, 48.031, 49.031
- 4448: - / Impacted TSs and TRs: 25.305, 25.331, 25.306, 25.413, 25.423, 25.433, 25.453, 25.302, 25.215, 25.401, 25.402, 25.450, 25.452
- 4449: - / Impacted TSs and TRs: 45.005, 51.010
- 4450: -
- 4451: - / Impacted TSs and TRs: 22.090
- 4452: - / Impacted TSs and TRs: 31.111, 31.115, 31.130

| ID | WBS | Task | Type | Duration | Start | Finish | Complete | Baseline start | Baseline finish | Baseline duration | Constraint | Resources | Work | Actual work | Acronym | WI rapporteur name | WI rapporteur e-mail | Release | MCC resp | Acronym_3GU_Export | Impacted TSs and TRs | PCG approved | TSG approved | TSG stopped |
| --- | --- | --- | --- | --- | --- | --- | --- | --- | --- | --- | --- | --- | --- | --- | --- | --- | --- | --- | --- | --- | --- | --- | --- | --- |
| 4453 | 1199 | **Combinational Services** |  | 296d? | 2005-01-17 A | 2006-03-06 A | 100% | 2005-01-17 | 2006-03-06 | 296d? |  | S1; S2; C1; S4 | 14648h | 14648h | CSICS | TeliaSonera | Robert.Frank@teliasonera.com | Rel-7 | Alain | CSICS |  |  |  |  |
| 4454 | 1199.1 | Stage 1 for CSICS |  | 104d? | 2005-01-17 A | 2005-06-09 A | 100% | 2005-01-17 | 2005-06-09 | 104d? | start no earlier than 2005-01-17 | S1 | 832h | 832h | CSICS | TeliaSonera | Robert.Frank@teliasonera.com | Rel-7 | Alain |  | 22.279 |  |  |  |
| 4455 | 1199.2 | Stage 2 for CSICS |  | 130d? | 2005-01-17 A | 2005-07-15 A | 100% | 2005-01-17 | 2005-07-15 | 130d? | start no earlier than 2005-01-17 | S2 | 1040h | 1040h | CSICS | TeliaSonera | Robert.Frank@teliasonera.com | Rel-7 | Maurice |  | 23.279 |  |  |  |
| 4456 | 1199.3 | Stage 3 for CSICS CN aspects |  | 221d? | 2005-05-02 A | 2006-03-06 A | 100% | 2005-05-02 | 2006-03-06 | 221d? | finish no earlier than 2006-03-06 | C1 | 1768h | 1768h | CSICS | Vodafone | peter.dawes@vodafone.com | Rel-7 | Frederic |  | 24.879, 24.279, 24.229, 24.008 |  |  |  |
| 4457 | 1199.4 | Stage 3 for codec aspects |  | 192d? | 2005-03-15 A | 2005-12-07 A | 100% | 2005-03-15 | 2005-12-07 | 192d? | finish no earlier than 2005-12-07 | S4 | 1536h | 1536h | CSICS-Codec | Ericsson | Per.Frojdh@ericsson.com | Rel-7 | Paolo | CSICS-Codec | 26.141, 26.235 |  |  |  |
| 4458 | 1200 | **CAMEL Trunk Triggers** |  | 251d? | 2004-12-17 A | 2005-12-05 A | 100% | 2004-12-17 | 2005-12-05 | 251d? |  | S1; C4 | 8032h | 8032h | TTCAMEL | Nortel | Amar Deol (deola@nortelnetworks.com) | Rel-7 | Alain | TTCAMEL |  |  |  |  |
| 4459 | 1200.1 | Stage 1 for CAMEL Trunk Triggers |  | 251d? | 2004-12-17 A | 2005-12-05 A | 100% | 2004-12-17 | 2005-12-05 | 251d? |  | S1 | 2008h | 2008h | TTCAMEL | Nortel | Amar Deol (deola@nortelnetworks.com) | Rel-7 | Alain |  | 22.078 |  |  |  |
| 4460 | 1200.2 | CAMEL Trunk Originated Trigger Detection Points |  | 251d? | 2004-12-17 A | 2005-12-05 A | 100% | 2004-12-17 | 2005-12-05 | 251d? | start no earlier than 2004-12-17 | C4 | 2008h | 2008h | CamelR7 | Nortel | David Hutton (dhutton@nortel.com) | Rel-7 | Kimmo | CamelR7 |  |  |  |  |
| 4461 | 1201 | **IMS Service Brokering enhancements** |  | 69d? | 2005-12-07 A | 2006-03-13 A | 100% | 2005-12-07 | 2006-03-13 | 69d? |  | S1 | 1104h | 1104h | ISB | Telcordia | jbakker@telcordia.com | Rel-7 | Alain | ISB | 22.228 |  |  |  |
| 4462 | 1201.1 | Stage 1 for ISB |  | 69d? | 2005-12-07 A | 2006-03-13 A | 100% | 2005-12-07 | 2006-03-13 | 69d? | finish no earlier than 2006-03-13 | S1 | 552h | 552h | ISB-s1 | Telcordia | jbakker@telcordia.com | Rel-7 | Alain | ISB-s1 | 22.228 |  |  |  |
| 4463 | 1202 | **Enhancements of VGCS for public authority officials** |  | 731d? | 2004-08-27 A | 2007-06-15 A | 100% | 2004-08-27 | 2007-06-15 | 731d? |  | S1; C1; C4; G2 | 49312h | 49312h | EVGCS |  |  | Rel-7 | Alain | EVGCS | 43.068, 44.068, 24.008, 29.002 | 38 | 75 |  |
| 4464 | 1202.1 | Stage 1 for Enhancements of VGCS for public authority officials | milestone | 0d? | 2004-08-27 A | 2004-08-27 A | 100% | 2004-08-27 | 2004-08-27 | 0d? | finish no earlier than 2004-08-27 | S1 |  |  | EVGCS | Siemens | joerg.swetina@neclab.eu | Rel-7 | Alain |  | 42.068, 43.068 |  |  |  |
| 4465 | 1202.2 | **Architecture and protocol aspects** |  | 731d? | 2004-08-27 A | 2007-06-15 A | 100% | 2004-08-27 | 2007-06-15 | 731d? |  | C1; C4 | 20752h | 20752h | EVGCS | Siemens | robert.zaus@nsn.com | Rel-7 | Frederic |  | 43.068, 44.068 |  |  |  |
| 4466 | 1202.2.1 | CT1 aspects of EVGCS |  | 731d? | 2004-08-27 A | 2007-06-15 A | 100% | 2004-08-27 | 2007-06-15 | 731d? | finish no earlier than 2006-09-15 | C1 | 5848h | 5848h | EVGCS | Siemens | robert.zaus@nsn.com | Rel-7 | Frederic |  | 43.068, 44.068, 24.008 |  |  |  |
| 4467 | 1202.2.2 | CT4 aspects of EVGCS |  | 401d? | 2004-08-27 A | 2006-03-10 A | 100% | 2004-08-27 | 2006-03-10 | 401d? | finish no earlier than 2006-03-10 | C4 | 3208h | 3208h | EVGCS | Siemens | robert.zaus@nsn.com | Rel-7 | Kimmo |  | 29.002 |  |  |  |
| 4468 | 1202.3 | GERAN2 aspects of EVGCS |  | 646d? | 2004-08-27 A | 2007-02-16 A | 100% | 2004-08-27 | 2007-02-16 | 646d? | finish no earlier than 2007-02-16 | G2 | 5168h | 5168h | EVGCS | Siemens | kenneth.isaacs@roke.co.uk | Rel-7 | Gert |  |  | 38 | 75 |  |
| 4469 | 1203 | **Improvements of VGCS for parallel use of services** |  | 523d? | 2005-03-15 A | 2007-03-15 A | 100% | 2005-03-15 | 2007-03-15 | 523d? |  | S1 | 12230.2h | 12230.2h | IVGCS |  |  | Rel-7 | Alain | IVGCS |  |  |  |  |
| 4470 | 1203.1 | Service Requirements for VGCS improvements |  | 62d? | 2005-03-15 A | 2005-06-08 A | 100% | 2005-03-15 | 2005-06-08 | 62d? | finish no earlier than 2005-06-08 | S1 | 496h | 496h | IVGCS | T-Mobile | kurt.bischinger@t-mobile.at | Rel-7 | Alain |  | 42.068 |  |  |  |
| 4471 | 1203.2 | Stage 2 modifications for VGCS improvements |  | 335d? | 2005-12-01 A | 2007-03-14 A | 100% | 2005-12-01 | 2007-03-14 | 335d? | start no earlier than 2005-12-01 | C1 | 2680h | 2680h | IVGCS | T-Mobile | kurt.bischinger@t-mobile.at | Rel-7 | Frederic |  | 43.068 |  |  |  |
| 4472 | 1203.3 | **Protocol aspects** |  | 336d? | 2005-12-01 A | 2007-03-15 A | 100% | 2005-12-01 | 2007-03-15 | 336d? |  | C1 | 5376h | 5376h | IVGCS | T-Mobile | Dieter Jacobsohn | Rel-7 | Frederic |  | 44.068 |  |  |  |
| 4473 | 1203.3.1 | CT1 aspects of IVGCS |  | 336d? | 2005-12-01 A | 2007-03-15 A | 100% | 2005-12-01 | 2007-03-15 | 336d? | finish no earlier than 2007-03-15 | C1 | 2688h | 2688h | IVGCS | T-Mobile |  | Rel-7 | Frederic |  | 43.068, 44.068 |  |  |  |
| 4474 | 1203.3.2 | Deleted - CT4 aspects of IVGCS | milestone | 0d? | 2007-03-09 A | 2007-03-09 A | 100% | 2007-03-09 | 2007-03-09 | 0d? | finish no earlier than 2007-03-09 | C4 |  |  | IVGCS-St3-c4 | T-mobile |  | Rel-7 | Kimmo | IVGCS-St3-c4 | 29.002 |  |  | CP-35 |
| 4475 | 1204 | **Open Service Access (OSA) Rel-7** |  | 584d? | 2005-03-15 A | 2007-06-08 A | 100% | 2005-03-15 | 2007-06-08 | 584d? |  | S1; C5 | 29776h | 29776h | OSA7 | AePONA | eamonn.murray@aepona.com | Rel-7 | Alain | OSA7 |  |  |  |  |
| 4476 | 1204.1 | **OSA Service Broker** |  | 449d? | 2005-03-15 A | 2006-12-01 A | 100% | 2005-03-15 | 2006-12-01 | 449d? |  | S1; C5 | 10176h | 10176h | OSA7-SB | AePONA | eamonn.murray@aepona.com | Rel-7 | Alain | OSA7-SB |  |  |  |  |
| 4477 | 1204.1.1 | Service Requirements for OSA Service Broker |  | 62d? | 2005-03-15 A | 2005-06-08 A | 100% | 2005-03-15 | 2005-06-08 | 62d? | finish no earlier than 2005-06-08 | S1 | 496h | 496h | OSA7 | AePONA | eamonn.murray@aepona.com | Rel-7 | Alain |  | 22.127 |  |  |  |
| 4478 | 1204.1.2 | Stage 2 OSA API Service Brokering |  | 156d? | 2006-04-28 A | 2006-12-01 A | 100% | 2006-04-28 | 2006-12-01 | 156d? |  | C5 | 1248h | 1248h | OSA7 | AePONA | damian.oneill@aepona.com | Rel-7 | Kimmo |  | 23.198 |  |  |  |
| 4479 | 1204.1.3 | Stage 3 OSA API Service Brokering |  | 156d? | 2006-04-28 A | 2006-12-01 A | 100% | 2006-04-28 | 2006-12-01 | 156d? | finish no earlier than 2006-12-01 | C5 | 1248h | 1248h | OSA7 | AePONA | damian.oneill@aepona.com | Rel-7 | Kimmo |  | 29.198-16 |  |  |  |

Notes:
- 4453: -
- 4454: -
- 4455: -
- 4456: -
- 4457: -
- 4458: -
- 4459: -
- 4460: -
- 4461: No CR submitted in rel-8 (according to CR database).
- 4462: No Rel-8 changes
- 4463: Moved from Rel-6 UID_50563 Enhancements of VGCS in public networks for communication of public authority officials
- 4464: Voice Group Call Service
- 4465: -
- 4466: -
- 4467: -
- 4468: -
- 4469: Voice Group Call Service
- 4470: -
- 4471: -
- 4472: Previous name (before CT32) was Architecture and protocol aspects
- 4473: -
- 4474: CT4#33 stage 2 solution is still open.
- 4475: -
- 4476: -
- 4477: -
- 4478: -
- 4479: -

| ID | WBS | Task | Type | Duration | Start | Finish | Complete | Baseline start | Baseline finish | Baseline duration | Constraint | Resources | Work | Actual work | Acronym | Impacted TSs and TRs | WI rapporteur name | WI rapporteur e-mail | Release | MCC resp | TSG approved | Acronym_3GU_Export | TSG stopped | Status Report |
| --- | --- | --- | --- | --- | --- | --- | --- | --- | --- | --- | --- | --- | --- | --- | --- | --- | --- | --- | --- | --- | --- | --- | --- | --- |
| 4480 | 1204.2 | **Rel-7 OSA Stage 2/3 enhancements** |  | 291d? | 2006-04-28 A | 2007-06-08 A | 100% | 2006-04-28 | 2007-06-08 | 291d? |  | C5 | 10256h | 10256h | OSA7 | 29.198/9, 23.198 | AePONA | damian.oneill@aepona.com | Rel-7 | Kimmo |  |  |  |  |
| 4481 | 1204.2.1 | Parlay X Message Broadcast Web Service |  | 156d? | 2006-04-28 A | 2006-12-01 A | 100% | 2006-04-28 | 2006-12-01 | 156d? | finish no earlier than 2006-12-01 | C5 | 1248h | 1248h | OSA7 | 29.199-15, 23.198 | ETRI |  | Rel-7 | Kimmo |  |  |  |  |
| 4482 | 1204.2.2 | Parlay X Geocoding Web Service |  | 156d? | 2006-04-28 A | 2006-12-01 A | 100% | 2006-04-28 | 2006-12-01 | 156d? | finish no earlier than 2006-12-01 | C5 | 1248h | 1248h | OSA7 | 29.199-16, 23.198 | ETRI |  | Rel-7 | Kimmo |  |  |  |  |
| 4483 | 1204.2.3 | Parlay X Application driven QoS Web Service |  | 226d? | 2006-04-28 A | 2007-03-09 A | 100% | 2006-04-28 | 2007-03-09 | 226d? | finish no earlier than 2007-03-09 | C5 | 1808h | 1808h | OSA7 | 29.199-17, 23.198 | BT |  | Rel-7 | Kimmo |  |  |  |  |
| 4484 | 1204.2.4 | Parlay-X Device Capabilities and Configuration |  | 162d? | 2006-10-26 A | 2007-06-08 A | 100% | 2006-10-26 | 2007-06-08 | 162d? | finish no earlier than 2007-06-09 | C5 | 1296h | 1296h | OSA7 | 29.199-18, 23.198 | Telenor |  | Rel-7 | Kimmo | 34 |  |  |  |
| 4485 | 1204.2.5 | Parlay-X Multimedia Streaming Session Management Web Service |  | 97d? | 2006-10-26 A | 2007-03-09 A | 100% | 2006-10-26 | 2007-03-09 | 97d? | start no earlier than 2006-10-26 | C5 | 776h | 776h | OSA7 | 29.199-19, 23.198 | Telenor |  | Rel-7 | Kimmo | 34 |  |  |  |
| 4486 | 1204.2.6 | Parlay-X Multimedia Multicast Control Web Service |  | 97d? | 2006-10-26 A | 2007-03-09 A | 100% | 2006-10-26 | 2007-03-09 | 97d? | start no earlier than 2006-10-26 | C5 | 776h | 776h | OSA7 | 29.199-20, 23.198 | ETRI |  | Rel-7 | Kimmo | 34 |  |  |  |
| 4487 | 1204.2.7 | OSA API Conference Call Control SCF |  | 97d? | 2006-10-26 A | 2007-03-09 A | 100% | 2006-10-26 | 2007-03-09 | 97d? | start no earlier than 2006-10-26 | C5 | 776h | 776h | OSA7 | 29.198-04-5, 23.198 | Ericsson |  | Rel-7 | Kimmo | 34 |  |  |  |
| 4488 | 1205 | **Selective Disabling of UE Capabilities** |  | 624.36d? | 2005-01-24 A | 2007-06-15 A | 100% | 2005-01-24 | 2007-06-15 | 624.36d? |  | S1; S2; C1 | 22341.5h | 22341.5h | SDoUE |  | Motorola |  | Rel-7 | Alain |  | SDoUE |  |  |
| 4489 | 1205.1 | Stage 1 of SDoUE |  | 393.6d? | 2005-01-24 A | 2006-12-08 A | 100% | 2005-01-24 | 2006-12-08 | 393.6d? | finish no earlier than 2006-12-08 | S1 | 3148.8h | 3148.8h | SDoUE-CR | 22.011 | Motorola |  | Rel-7 | Alain |  | SDoUE-CR |  |  |
| 4490 | 1205.2 | Deleted - TR on different possible architectures |  | 195d? | 2005-03-21 A | 2005-12-16 A | 100% | 2005-03-21 | 2005-12-16 | 195d? | finish no earlier than 2005-12-16 | S2 | 1560h | 1560h | SDoUE-FS | 23.805 abandonned at SP-30; descendant C1 24.305 | Vodafone | Gavin.Wong@vodafone.com | Rel-7 | Maurice |  | SDoUE-FS | SP-30 |  |
| 4491 | 1205.3 | Stage 3 of SDoUE |  | 331d? | 2006-03-10 A | 2007-06-15 A | 100% | 2006-03-10 | 2007-06-15 | 331d? | finish no earlier than 2007-06-15 | C1 | 2648h | 2648h | SDoUE | 24.305 | Ericsson | christian.herrero@ericsson.com | Rel-7 | Frederic |  |  |  |  |
| 4492 | 1206 | **Network selection enhancements (NSP)** |  | 328d? | 2006-03-15 A | 2007-06-15 A | 100% | 2006-03-15 | 2007-06-15 | 328d? |  | S1 | 6320h | 6320h | NSP |  | O2 | chris.friel@O2.com | Rel-7 | Alain |  | NSP |  |  |
| 4493 | 1206.1 | Stage 1 of NSP |  | 191d? | 2006-03-15 A | 2006-12-06 A | 100% | 2006-03-15 | 2006-12-06 | 191d? | start no earlier than 2006-03-15 | S1 | 1528h | 1528h | NSP-TS | 22.101, 22.011, 23.122, 24.008, 25.304, 31.102, 45.008 | O2 | chris.friel@O2.com | Rel-7 | Alain |  | NSP-TS |  |  |
| 4494 | 1206.2 | Procedural aspects of NSP |  | 271d? | 2006-06-02 A | 2007-06-15 A | 100% | 2006-06-02 | 2007-06-15 | 271d? | finish no earlier than 2007-06-15 | C1 | 2168h | 2168h | NSP-CR | 23.122, 24.008, 31.102 | Motorola | Andrew Howell | Rel-7 | Frederic |  | NSP-CR |  |  |
| 4495 | 1207 | Network selection enhancements (NSP) - UE Conformance Testing |  | 396d? | 2007-06-01 A | 2008-12-05 A | 100% | 2007-06-01 | 2008-12-05 | 396d? | finish no earlier than 2008-12-05 | R5 | 3168h | 3168h | NSP-CR_UEConTest | 34.108, 34.123-1, 34.123-2, 34.123-3 | Nokia | jarkko.hellsten@nokia.com | Rel-7 | Ingbert |  | NSP-CR_UEConTest |  | RP-080819 |
| 4496 | 1208 | **Access Class Barring and Overload Protection** |  | 650d? | 2004-03-15 A | 2006-09-08 A | 100% | 2004-03-15 | 2006-09-08 | 650d? |  | S2; C1 | 13968h | 13968h | ACBOP | 23.898 | Vodafone | chris.pudney@vodafone.com | Rel-7 | Maurice |  | ACBOP |  |  |
| 4497 | 1208.1 | TR on Stage 2 |  | 274d? | 2004-03-15 A | 2005-03-31 A | 100% | 2004-03-15 | 2005-03-31 | 274d? | finish no earlier than 2005-03-31 | S2 | 2192h | 2192h | ACBOP | 23.898 | NTT DoCoMo | Jean-Jacques Davidian (davidian@docomo.fr) | Rel-7 | Maurice |  |  |  |  |
| 4498 | 1208.2 | Stage 3 CN aspects of ACBOP |  | 172d? | 2005-06-06 A | 2006-01-31 A | 100% | 2005-06-06 | 2006-01-31 | 172d? | start no earlier than 2005-06-06 | C1 | 1376h | 1376h | ACBOP | 24.008 |  |  | Rel-7 | Frederic |  |  |  |  |
| 4499 | 1208.3 | Deleted - Potential impact on Iu interface Overload functionality | milestone | 0d? | 2004-03-15 A | 2004-03-15 A | 100% | 2004-03-15 | 2004-03-15 | 0d? | finish no earlier than 2004-03-15 | RP |  |  | ACBOP | 25.413 |  |  | Rel-7 | Issam |  |  | RP-25 |  |
| 4500 | 1208.4 | Deleted - Extra ACBOP information in RAN | milestone | 0d? | 2004-03-15 A | 2004-03-15 A | 100% | 2004-03-15 | 2004-03-15 | 0d? | finish no earlier than 2004-03-15 | RP |  |  | ACBOP | 25.331 |  |  | Rel-7 | Issam |  |  | RP-25 |  |
| 4501 | 1208.5 | Deleted - Extra ACBOP information in GERAN | milestone | 0d? | 2006-09-08 A | 2006-09-08 A | 100% | 2006-09-08 | 2006-09-08 | 0d? | start no earlier than 2006-09-08 | GP |  |  | ACBOP | 44.018 |  |  | Rel-7 | Paolo |  |  | RP-33 |  |
| 4502 | 1209 | **System enhancements for Fixed Broadband access to IMS** |  | 2117d? | 2003-11-05 A | 2011-12-09 A | 100% | 2003-11-05 | 2011-12-09 | 2117d? |  | S2; S3; S5; C1; C3; C4; IETF | 369944h | 369944h | FBI |  |  |  | Rel-7 | Maurice |  | FBI |  |  |
| 4503 | 1209.1 | **TISPAN Rel 1 related aspects** |  | 2117d? | 2003-11-05 A | 2011-12-09 A | 100% | 2003-11-05 | 2011-12-09 | 2117d? |  | S2; S3; C1; C3; C4; IETF | 239320h | 239320h | FBI-TIS1 |  |  |  | Rel-7 | Maurice |  | FBI-TIS1 |  |  |
| 4504 | 1209.1.1 | Stage 2 of FBI for TISPAN R1 |  | 365d? | 2004-10-14 A | 2006-03-08 A | 100% | 2004-10-14 | 2006-03-08 | 365d? | start no earlier than 2004-10-14 | S2 | 2920h | 2920h |  |  |  |  | Rel-7 | Maurice |  |  |  |  |

Notes:
- 4480: CP#34 updated WID CP-060607=>CP-070200
- 4481: -
- 4482: -
- 4483: -
- 4484: -
- 4485: -
- 4486: -
- 4487: -
- 4488: Moved from FS section Feb 06
- 4489: Moved from FS section Feb 06
- 4490: Moved from FS section Feb 06. Abandoned at SP-30
- 4491: -
- 4492: -
- 4493: -
- 4494: -
- 4495: RP#42 completed. Testing for Feature UID_7041 (NSP-CR)
- 4496: -
- 4497: -
- 4498: -
- 4499: -
- 4500: -
- 4501: -
- 4502: -
- 4503: -
- 4504: -

| ID | WBS | Task | Duration | Start | Finish | Complete | Baseline start | Baseline finish | Baseline duration | Constraint | Resources | Work | Actual work | WI rapporteur name | WI rapporteur e-mail | Release | MCC resp | PCG approved | TSG approved | Acronym | Acronym_3GU_Export | Special Focus Doc | TSG stopped |
| --- | --- | --- | --- | --- | --- | --- | --- | --- | --- | --- | --- | --- | --- | --- | --- | --- | --- | --- | --- | --- | --- | --- | --- |
| 4505 | 1209.1.2 | **Protocol impact of FBI for TISPAN R1** | 2117d? | 2003-11-05 A | 2011-12-09 A | 100% | 2003-11-05 | 2011-12-09 | 2117d? |  | S3; C1; C3; C4; IETF | 133840h | 133840h | Siemens | peter.leis@nsn.com | Rel-7 | Frederic |  |  |  |  |  |  |
| 4506 | 1209.1.2.1 | (IETF) CT aspects of FBI for TISPAN R1 | 2117d? | 2003-11-05 A | 2011-12-09 A | 100% | 2003-11-05 | 2011-12-09 | 2117d? | start no earlier than 2003-11-05 | C1-IETF; C3-IETF | 33872h | 33872h | Roland Jesske |  | Rel-7 | Frederic | 27 | 52 |  |  |  |  |
| 4507 | 1209.1.2.2 | CT1 aspects of FBI for TISPAN R1 | 802d? | 2003-11-05 A | 2006-11-30 A | 100% | 2003-11-05 | 2006-11-30 | 802d? | finish no earlier than 2006-11-30 | C1 | 6416h | 6416h | Siemens | peter.leis@nsn.com | Rel-7 | Frederic |  |  |  |  |  |  |
| 4508 | 1209.1.2.3 | CT3 aspects of FBI for TISPAN R1 | 808d? | 2003-11-05 A | 2006-12-08 A | 100% | 2003-11-05 | 2006-12-08 | 808d? | finish no earlier than 2006-12-08 | C3 | 6464h | 6464h | Siemens | peter.leis@nsn.com | Rel-7 | Adrian |  |  |  |  |  |  |
| 4509 | 1209.1.2.4 | CT4 aspects of FBI for TISPAN R1 | 301d? | 2006-01-13 A | 2007-03-09 A | 100% | 2006-01-13 | 2007-03-09 | 301d? | finish no earlier than 2007-03-09 | C4 | 2408h | 2408h | Siemens | peter.leis@nsn.com | Rel-7 | Kimmo |  |  | FBI-TIS1-st3-c4 | FBI-TIS1-st3-c4 |  |  |
| 4510 | 1209.1.3 | Security Enhancements for FBI | 118d? | 2005-06-28 A | 2005-12-08 A | 100% | 2005-06-28 | 2005-12-08 | 118d? | start no earlier than 2005-06-28 | S3 | 944h | 944h | Ericsson | Bengt.Sahlin@ericsson.com | Rel-7 | Mirko |  |  | FBI-ISE | FBI-ISE |  |  |
| 4511 | 1209.2 | **PacketCable Related aspects** | 291d? | 2006-02-01 A | 2007-03-14 A | 100% | 2006-02-01 | 2007-03-14 | 291d? |  | S2; S5; C1 | 12072h | 12072h | CableLabs | Bernie McKibben (b.mckibben@cablelabs.com) | Rel-7 | Maurice |  |  | FBI-PCBL | FBI-PCBL |  |  |
| 4512 | 1209.2.1 | Stage 1,2 of FBI for PacketCable | 228d? | 2006-02-01 A | 2006-12-15 A | 100% | 2006-02-01 | 2006-12-15 | 228d? | finish no earlier than 2006-12-15 | S2 | 1824h | 1824h | CableLabs | Bernie McKibben (b.mckibben@cablelabs.com) | Rel-7 | Maurice |  |  |  |  |  |  |
| 4513 | 1209.2.2 | Protocol impact of FBI for PacketCable | 228d? | 2006-05-01 A | 2007-03-14 A | 100% | 2006-05-01 | 2007-03-14 | 228d? | finish no earlier than 2007-03-15 | C1 | 1824h | 1824h |  |  | Rel-7 | Frederic |  |  |  |  |  |  |
| 4514 | 1209.2.3 | SA5 Charging aspects of FBI for PacketCable | 180d? | 2006-03-31 A | 2006-12-07 A | 100% | 2006-03-31 | 2006-12-07 | 180d? | finish no earlier than 2006-12-07 | S5 | 1440h | 1440h | CableLabs | Bernie McKibben (b.mckibben@cablelabs.com) | Rel-7 | Mirko |  |  | FBI-PCBL-CH | FBI-PCBL-CH |  |  |
| 4515 | 1210 | **Support of SMS over generic 3GPP IP access** | 696d? | 2004-10-14 A | 2007-06-14 A | 100% | 2004-10-14 | 2007-06-14 | 696d? |  | S2; C4; C1 | 37544h | 37544h | Huawei | zhangwenlin@huawei.com | Rel-7 | Maurice |  |  | SMSIP | SMSIP | WLAN |  |
| 4516 | 1210.1 | FS on SMSIP | 173d? | 2004-10-14 A | 2005-06-13 A | 100% | 2004-10-14 | 2005-06-13 | 173d? | start no earlier than 2004-10-14 | S2 | 1384h | 1384h | Huawei | zhangwenlin@huawei.com | Rel-7 | Maurice |  |  |  |  | WLAN |  |
| 4517 | 1210.2 | Stage 2 for SMSIP | 333d? | 2005-06-08 A | 2006-09-15 A | 100% | 2005-06-08 | 2006-09-15 | 333d? | finish no earlier than 2006-09-15 | S2 | 2664h | 2664h | Huawei | zhangwenlin@huawei.com | Rel-7 | Maurice |  |  |  |  | WLAN |  |
| 4518 | 1210.3 | **Stage 3 for SMSIP** | 527d? | 2005-06-08 A | 2007-06-14 A | 100% | 2005-06-08 | 2007-06-14 | 527d? |  | C4; C1 | 16792h | 16792h | Nokia | jari.jansson@nokia.com | Rel-7 | Kimmo |  |  | SMSIP-St3 | SMSIP-St3 | WLAN |  |
| 4519 | 1210.3.1 | CT1 aspects for SMSIP | 527d? | 2005-06-08 A | 2007-06-14 A | 100% | 2005-06-08 | 2007-06-14 | 527d? | finish no earlier than 2007-06-15 | C1 | 4216h | 4216h | Nokia | jari.jansson@nokia.com | Rel-7 | Frederic |  |  |  |  | WLAN |  |
| 4520 | 1210.3.2 | CT4 aspects for SMSIP | 518d? | 2005-06-08 A | 2007-06-01 A | 100% | 2005-06-08 | 2007-06-01 | 518d? | finish no earlier than 2007-06-01 | C4 | 4144h | 4144h | Nokia | jari.jansson@nokia.com | Rel-7 | Kimmo |  |  | SMSIP-St3-c4 | SMSIP-St3-c4 | WLAN |  |
| 4521 | 1211 | **Evolution of Policy Control and Charging** | 817d? | 2004-10-14 A | 2007-11-30 A | 100% | 2004-10-14 | 2007-11-30 | 817d? |  | S2; S5; C3; C1 | 54112h | 54112h | Nokia | balazs.bertenyi@nsn.com | Rel-7 | Maurice |  |  | PCC | PCC |  |  |
| 4522 | 1211.1 | Deleted - TR for PCC | 315d? | 2004-10-14 A | 2005-12-29 A | 100% | 2004-10-14 | 2005-12-29 | 315d? | finish no earlier than 2005-12-28 | S2 | 2520h | 2520h | Nokia | balazs.bertenyi@nsn.com | Rel-7 | Maurice |  |  |  |  |  | SP-33 |
| 4523 | 1211.2 | Stage 2 for PCC | 315d? | 2005-07-04 A | 2006-09-15 A | 100% | 2005-07-04 | 2006-09-15 | 315d? | finish no earlier than 2006-09-15 | S2 | 2520h | 2520h | Nokia | balazs.bertenyi@nsn.com | Rel-7 | Maurice |  |  |  |  |  |  |
| 4524 | 1211.3 | Evolution of policy control and flow based bearer level charging | 109d? | 2006-08-01 A | 2006-12-29 A | 100% | 2006-08-01 | 2006-12-29 | 109d? | start no earlier than 2006-08-01 | S2 | 872h | 872h | Nokia | balazs.bertenyi@nsn.com | Rel-7 | Maurice |  |  |  |  |  |  |
| 4525 | 1211.4 | SA5 Charging aspects of PCC | 316d? | 2006-03-31 A | 2007-06-15 A | 100% | 2006-03-31 | 2007-06-15 | 316d? | finish no earlier than 2007-06-15 | S5 | 2528h | 2528h | Orange | alain.bibas@orange-ft.com | Rel-7 | Mirko |  |  | PCC-CH | PCC-CH |  |  |
| 4526 | 1211.5 | Gx reference point for Policy and Charging Control | 521d? | 2005-12-02 A | 2007-11-30 A | 100% | 2005-12-02 | 2007-11-30 | 521d? | finish no earlier than 2007-09-14 | C3 | 4168h | 4168h | Siemens | Thomas.Belling@nsn.com | Rel-7 | Adrian |  |  | PCC-Gx | PCC-Gx |  |  |
| 4527 | 1211.6 | **Rx reference point for PCC CT3 aspects** | 521d? | 2005-12-02 A | 2007-11-30 A | 100% | 2005-12-02 | 2007-11-30 | 521d? |  | C3; C1 | 15360h | 15360h | Ericsson | j.javier.pastor@ericsson.com | Rel-7 | Adrian |  |  | PCC-Rx | PCC-Rx |  |  |
| 4528 | 1211.6.1 | PCC-Rx CT3 aspects | 521d? | 2005-12-02 A | 2007-11-30 A | 100% | 2005-12-02 | 2007-11-30 | 521d? | finish no earlier than 2007-09-14 | C3 | 4168h | 4168h | Ericsson | j.javier.pastor@ericsson.com | Rel-7 | Adrian |  |  | PCC-Rx-c3 | PCC-Rx-c3 |  |  |
| 4529 | 1211.6.2 | PCC-Rx CT1 aspects | 357d? | 2005-12-02 A | 2007-06-15 A | 100% | 2005-12-02 | 2007-06-15 | 357d? | finish no earlier than 2007-06-15 | C1 | 2856h | 2856h | Ericsson | j.javier.pastor@ericsson.com | Rel-7 | Frederic |  |  | PCC-Rx-Gx-c1 | PCC-Rx-Gx-c1 |  |  |

Notes:
- 4505: -
- 4506: CP#54 completed / Impacted TSs and TRs: RFC 6432 (was draft-jesske-dispatch-update3326-reason-responses)
- 4507: - / Impacted TSs and TRs: 24.819, 24.229
- 4508: - / Impacted TSs and TRs: 29.163, 29.209
- 4509: CT4#32: a set of CRs on FBI for cable labs / Impacted TSs and TRs: 29.229
- 4510: Duplicated entry ("ACCSEC2", "Access Security Enhancements", SP-040865) deleted by A.Sultan / Impacted TSs and TRs: 33.203
- 4511: -
- 4512: - / Impacted TSs and TRs: 22.228, 23.228
- 4513: -
- 4514: 03/2006 SP#31 WID approved / Impacted TSs and TRs: 32.240, 32.260, 32.298, 32.299
- 4515: SP#33 updated WID (removed MMS)
- 4516: SP#33 updated WID / Impacted TSs and TRs: 23.804
- 4517: SP#33 updated WID / Impacted TSs and TRs: 23.204
- 4518: CP#34 updated WID
- 4519: CP#34 updated WID / Impacted TSs and TRs: 23.040, 24.229
- 4520: CP#34 updated WID / Impacted TSs and TRs: 23.008, 29.002
- 4521: SP-29 approved WID. SP-31 updated WID adding SA5 charging. 23.125 will be discontinued from Rel-7.
- 4522: SP-30: S2 has no intention for TR completion / Impacted TSs and TRs: 23.803
- 4523: SP-29 approved WID. SP-31 updated WID. 23.125 will be discontinued from Rel-7. / Impacted TSs and TRs: 23.203
- 4524: SP-29 approved WID. SP-31 updated WID. 23.125 will be discontinued from Rel-7. / Impacted TSs and TRs: 23.207, 23.002, 23.228
- 4525: SP-31 updated WID with SA5 charging. / Impacted TSs and TRs: 32.250, 32.251, 32.298, 32.299
- 4526: - / Impacted TSs and TRs: 29.212 (not progressed to Rel-7: 29.210, 29.207, 29.208)
- 4527: WID approved at CP#30, Revised at CP#31, Revised at CP#33
- 4528: - / Impacted TSs and TRs: 29.213, 29.214 (not progressed to Rel-7: 29.209, 29.211)
- 4529: - / Impacted TSs and TRs: 24.229

| ID | WBS | Task | Type | Duration | Start | Finish | Complete | Baseline start | Baseline finish | Baseline duration | Constraint | Resources | Work | Actual work | Acronym | WI rapporteur name | WI rapporteur e-mail | Release | MCC resp | Special Focus Doc | Acronym_3GU_Export | Impacted TSs and TRs | TSG stopped | TSG approved |
| --- | --- | --- | --- | --- | --- | --- | --- | --- | --- | --- | --- | --- | --- | --- | --- | --- | --- | --- | --- | --- | --- | --- | --- | --- |
| 4530 | 1212 | **Voice Call Continuity between CS and IMS (incl. I-WLAN)** |  | 641d? | 2004-12-31 A | 2007-06-15 A | 100% | 2004-12-31 | 2007-06-15 | 641d? |  | S2; S1; S5; C1; C4 | 43592h | 43592h | VCC | Alcatel-Lucent | Keith Drage (drage@alcatel-lucent.com) | Rel-7 | Maurice | WLAN | VCC |  |  |  |
| 4531 | 1212.1 | TR for Voice Call Continuity between CS and IMS (incl. I-WLAN) |  | 245d? | 2004-12-31 A | 2005-12-08 A | 100% | 2004-12-31 | 2005-12-08 | 245d? | finish no earlier than 2005-12-08 | S2 | 1960h | 1960h |  | Alcatel-Lucent | andy.bennett@alcatel-lucent.com | Rel-7 | Maurice | WLAN |  | 23.806 |  |  |
| 4532 | 1212.2 | Stage 1 for Voice Call Continuity between CS and IMS (incl. I-WLAN) |  | 140d? | 2005-03-17 A | 2005-09-28 A | 100% | 2005-03-17 | 2005-09-28 | 140d? | finish no earlier than 2005-09-28 | S1 | 1120h | 1120h |  | Alcatel-Lucent | andy.bennett@alcatel-lucent.com | Rel-7 | Alain | WLAN |  | 22.101 |  |  |
| 4533 | 1212.3 | Stage 2 for Voice Call Continuity between CS and IMS (incl. I-WLAN) |  | 264d? | 2005-09-06 A | 2006-09-08 A | 100% | 2005-09-06 | 2006-09-08 | 264d? | finish no earlier than 2006-09-08 | S2 | 2112h | 2112h |  | Alcatel-Lucent | andy.bennett@alcatel-lucent.com | Rel-7 | Maurice | WLAN |  | 23.206 |  |  |
| 4534 | 1212.4 | SA5 Charging for Voice Call Continuity between CS and IMS (incl. I-WLAN) |  | 325d? | 2006-03-17 A | 2007-06-14 A | 100% | 2006-03-17 | 2007-06-14 | 325d? | finish no earlier than 2007-06-14 | S5 | 2600h | 2600h | VCC-CH | Orange | alain.bibas@orange-ft.com | Rel-7 | Mirko | WLAN | VCC-CH | 32.250, 32.260 |  |  |
| 4535 | 1212.5 | **Stage 3 for Voice Call Continuity between CS and IMS (incl. I-WLAN)** |  | 358d? | 2006-02-01 A | 2007-06-15 A | 100% | 2006-02-01 | 2007-06-15 | 358d? |  | C1; C4 | 10160h | 10160h |  | Alcatel-Lucent | Keith Drage (drage@alcatel-lucent.com) | Rel-7 | Frederic | WLAN |  |  |  |  |
| 4536 | 1212.5.1 | CT1 aspects of Stage 3 for Voice Call Continuity between CS and IMS (incl. I-WLAN) |  | 358d? | 2006-02-01 A | 2007-06-15 A | 100% | 2006-02-01 | 2007-06-15 | 358d? | finish no earlier than 2007-06-15 | C1 | 2864h | 2864h |  | Alcatel-Lucent | Keith Drage (drage@alcatel-lucent.com) | Rel-7 | Frederic | WLAN |  | 24.206, 24.216 |  |  |
| 4537 | 1212.5.2 | CT4 aspects of Stage 3 for Voice Call Continuity between CS and IMS (incl. I-WLAN) |  | 196d? | 2006-06-09 A | 2007-03-09 A | 100% | 2006-06-09 | 2007-03-09 | 196d? | start no earlier than 2006-06-09 | C4 | 1568h | 1568h | VCC-St3-c4 | Alcatel-Lucent | Keith Drage (drage@alcatel-lucent.com) | Rel-7 | Kimmo | WLAN | VCC-St3-c4 | 23.003 |  |  |
| 4538 | 1212.5.3 | Deleted - CT3 aspects of Stage 3 for Voice Call Continuity between CS and IMS (incl. I-WLAN) | milestone | 0d? | 2006-11-02 A | 2006-11-02 A | 100% | 2006-11-02 | 2006-11-02 | 0d? | finish no earlier than 2006-11-02 | C3 |  |  |  | Alcatel-Lucent | Keith Drage (drage@alcatel-lucent.com) | Rel-7 | Adrian | WLAN |  | 29.163 | CP-33 |  |
| 4539 | 1213 | **One Tunnel solution for optimization of Packet Data Traffic** |  | 418d? | 2006-03-27 A | 2007-10-31 A | 100% | 2006-03-27 | 2007-10-31 | 418d? |  | S2 | 7048h | 7048h | OPTUNEL | Nokia | antti.j.pasanen@nokia.com | Rel-7 | Maurice |  | OPTUNEL |  |  |  |
| 4540 | 1213.1 | Deleted - Study on Stage 2 for One Tunnel solution |  | 125d? | 2006-03-27 A | 2006-09-15 A | 100% | 2006-03-27 | 2006-09-15 | 125d? | finish no earlier than 2005-09-12 | S2 | 1000h | 1000h | OPTUNEL-Study | Nokia | antti.j.pasanen@nokia.com | Rel-7 | Maurice |  | OPTUNEL-Study | 23.809 | SP-34 |  |
| 4541 | 1213.2 | One Tunnel Deployment Guideline |  | 268d? | 2006-10-23 A | 2007-10-31 A | 100% | 2006-10-23 | 2007-10-31 | 268d? | finish no earlier than 2007-10-31 | S2 | 2144h | 2144h | OPTUNEL-Guide | Huawei | lan.liu@huawei.com | Rel-7 | Maurice |  | OPTUNEL-Guide | 23.919 |  | 34 |
| 4542 | 1213.3 | Stage 2 specification for One Tunnel solution |  | 70d? | 2006-09-11 A | 2006-12-15 A | 100% | 2006-09-11 | 2006-12-15 | 70d? | finish no earlier than 2006-12-15 | S2 | 560h | 560h | OPTUNEL-Stage2 | Nokia | antti.j.pasanen@nokia.com | Rel-7 | Maurice |  | OPTUNEL-Stage2 | 23.060 |  |  |
| 4543 | 1214 | **CSI Terminating Session handling** |  | 267d? | 2006-06-08 A | 2007-06-15 A | 100% | 2006-06-08 | 2007-06-15 | 267d? |  | S2; C1 | 6864h | 6864h | CSItermS | Samsung | Osok Song | Rel-7 | Maurice |  | CSItermS |  |  |  |
| 4544 | 1214.1 | Stage 2 of CStermS |  | 192d? | 2006-06-08 A | 2007-03-02 A | 100% | 2006-06-08 | 2007-03-02 | 192d? | start no earlier than 2006-06-08 | S2 | 1536h | 1536h |  | Samsung | Osok Song | Rel-7 | Maurice |  |  | 23.279 |  | 34 |
| 4545 | 1214.2 | Stage 3 of CStermS |  | 132d? | 2006-12-14 A | 2007-06-15 A | 100% | 2006-12-14 | 2007-06-15 | 132d? | finish no earlier than 2007-06-15 | C1 | 1056h | 1056h |  | Samsung | chenho.chin@samsung.com | Rel-7 | Frederic |  |  | 24.229, 24.279 |  | 34 |
| 4546 | 1214.3 | Deleted - duplicated with UID 340015 -Stage 3 CSI Terminating Session handling | milestone | 0d? | 2007-03-09 A | 2007-03-09 A | 100% | 2007-03-09 | 2007-03-09 | 0d? | start no earlier than 2007-03-09 | C1 |  |  |  | Samsung | chenho.chin@samsung.com | Rel-7 | Frederic |  |  | 24.229, 24.179, 24.279 | CP-34 | 34 |
| 4547 | 1215 | Liberty Alliance and 3GPP Security Interworking |  | 451d? | 2005-03-10 A | 2006-11-30 A | 100% | 2005-03-10 | 2006-11-30 | 451d? | finish no earlier than 2006-11-30 | S3 | 3608h | 3608h | LibSec | Nokia | Silke.Holtmanns@nokia.com | Rel-7 | Mirko |  | LibSec | 33.980 |  |  |
| 4548 | 1216 | Trust Requirements for Open Platforms in 3GPP |  | 499d? | 2005-01-03 A | 2006-11-30 A | 100% | 2005-01-03 | 2006-11-30 | 499d? | finish no earlier than 2006-11-30 | S3 | 3992h | 3992h | TrustOP | Nokia | Silke.Holtmanns@nokia.com | Rel-7 | Mirko |  | TrustOP | 33.905 |  |  |
| 4549 | 1217 | Development of UEA2 and UIA2 |  | 268d? | 2004-12-01 A | 2005-12-09 A | 100% | 2004-12-01 | 2005-12-09 | 268d? | finish no earlier than 2005-12-09 | S3 | 2144h | 2144h | AlgUEA2 | TeliaSonera | per.christoffersson@teliasonera.com | Rel-7 | Mirko |  | AlgUEA2 | 35.919, 35.215, 35.216, 35.217, 35.218 |  |  |
| 4550 | 1218 | Lawful Interception in the 3GPP Rel-7 architecture |  | 118d? | 2005-06-28 A | 2005-12-08 A | 100% | 2005-06-28 | 2005-12-08 | 118d? | start no earlier than 2005-06-28 | S3 | 944h | 944h | LI-7A | BMWI | berthold.wilhelm@regtp.de | Rel-7 | Mirko |  | LI-7A | 33.106, 33.107, 33.108 |  |  |
| 4551 | 1219 | Key establishment between a UICC and a terminal |  | 201.45d? | 2005-12-07 A | 2006-09-28 A | 100% | 2005-12-07 | 2006-09-28 | 201.45d? | finish no earlier than 2006-09-28 | S3 | 1611.6h | 1611.6h | KeyEstUTerm | Gemalto | mireille.pauliac@gemplus.com | Rel-7 | Mirko |  | KeyEstUTerm | 33.110 |  |  |
| 4552 | 1220 | NDS Authentication Framework Extension for Transport Layer Security |  | 50d? | 2006-09-28 A | 2006-12-06 A | 100% | 2006-09-28 | 2006-12-06 | 50d? | finish no earlier than 2006-09-28 | S3 | 400h | 400h | NDSAFTLS | Nokia | tiina.s.koskinen@nokia.com | Rel-7 | Mirko |  | NDSAFTLS | 33.310 |  |  |
| 4553 | 1221 | **Security enhancements** |  | 319d? | 2005-09-12 A | 2006-11-30 A | 100% | 2005-09-12 | 2006-11-30 | 319d? |  | S3; C1; C4 | 16376h | 16376h | SEC7 |  |  | Rel-7 | Mirko |  | SEC7 |  |  |  |
| 4554 | 1221.1 | HTTPS connection between a UICC and a NAF |  | 1d? | 2005-09-12 A | 2005-09-12 A | 100% | 2005-09-12 | 2005-09-12 | 1d? | start no earlier than 2005-09-12 | S3; C1 | 16h | 16h | SEC7-HSUN | Gemalto | JSeif@axalto.com, mireille.pauliac@gemplus.com | Rel-7 | Mirko |  | SEC7-HSUN | 33.918, 33.222, 24.109 |  |  |
| 4555 | 1221.2 | 2G GBA: 2G SIM usage in 3GPP GAA framework |  | 61d? | 2005-09-12 A | 2005-12-05 A | 100% | 2005-09-12 | 2005-12-05 | 61d? | finish no earlier than 2005-12-05 | S3 | 488h | 488h | SEC7-2GGBA | Nokia | Silke.Holtmanns@nokia.com | Rel-7 | Mirko |  | SEC7-2GGBA | 33.920, 33.220 |  |  |
| 4556 | 1221.3 | Generic Authentication Architecture usage extensions and optimizations |  | 319d? | 2005-09-12 A | 2006-11-30 A | 100% | 2005-09-12 | 2006-11-30 | 319d? | finish no earlier than 2006-11-30 | S3 | 2552h | 2552h | SEC7-GAA2 | Nokia | Silke.Holtmanns@nokia.com | Rel-7 | Mirko |  | SEC7-GAA2 | 33.220, 29.109, 24.109, (33.223 goes to R8) |  |  |

Notes:
- 4530: WID approved SP#27; updated SP#28; updated SP#32
- 4531: -
- 4532: -
- 4533: -
- 4534: 03/2006 SP#31 WID approved
- 4535: -
- 4536: -
- 4537: -
- 4538: -
- 4539: -
- 4540: TR for Info SP-33. SP-34: S2 Report intention to discontinue TR
- 4541: -
- 4542: -
- 4543: Triggered by the abandoned Study UID_32117
- 4544: -
- 4545: CP-34 approved WID. CP-35 updated WID
- 4546: CP-34 approved WID
- 4547: WID approved SP#27.
- 4548: WID approved SP#26.
- 4549: WID approved SP#26, Dependant on Funding Availability.
- 4550: -
- 4551: -
- 4552: TLS profile is moved to Rel-8
- 4553: -
- 4554: -
- 4555: -
- 4556: 33.223 goes to R8

| ID | WBS | Task | Duration | Start | Finish | Complete | Baseline start | Baseline finish | Baseline duration | Constraint | Resources | Work | Actual work | Acronym | WI rapporteur name | WI rapporteur e-mail | Release | MCC resp | Acronym_3GU_Export | Impacted TSs and TRs | PCG approved | TSG approved | TSG stopped |
| --- | --- | --- | --- | --- | --- | --- | --- | --- | --- | --- | --- | --- | --- | --- | --- | --- | --- | --- | --- | --- | --- | --- | --- |
| 4557 | 1221.4 | **SS7 TCAP security Gateway** | 241d? | 2005-09-12 A | 2006-08-14 A | 100% | 2005-09-12 | 2006-08-14 | 241d? |  | S3; C4 | 5664h | 5664h | SEC7-NDS-TCAPsec | Siemens | marc.blommaert.ext@nsn.com | Rel-7 | Mirko | SEC7-NDS-TCAPsec |  |  |  |  |
| 4558 | 1221.4.1 | SA3 aspects of SEC7-NDS-TCAPsec | 130d? | 2005-09-12 A | 2006-03-10 A | 100% | 2005-09-12 | 2006-03-10 | 130d? | finish no earlier than 2006-03-10 | S3 | 1040h | 1040h | SEC7-NDS-TCAPsec-SA3 | Siemens | marc.blommaert.ext@nsn.com | Rel-7 | Mirko | SEC7-NDS-TCAPsec-SA3 | 33.204 |  |  |  |
| 4559 | 1221.4.2 | TCAPsec Gateway | 96d? | 2006-04-03 A | 2006-08-14 A | 100% | 2006-04-03 | 2006-08-14 | 96d? | start no earlier than 2006-04-01 | C4 | 768h | 768h | SEC7-TCAP | Siemens | Ulrich.wiehe@gksag.de | Rel-7 | Kimmo | SEC7-TCAP | 29.204, 29.002 |  |  |  |
| 4560 | 1222 | IMS Stage 3 IETF Protocol Alignment | 589d? | 2004-12-10 A | 2007-03-14 A | 100% | 2004-12-10 | 2007-03-14 | 589d? | finish no earlier than 2007-03-15 | C1 | 4712h | 4712h | IMSProtoc |  |  | Rel-7 | Frederic | IMSProtoc | 24.930 | 36 | 71 |  |
| 4561 | 1223 | **Interoperability between VGCS/VBS and A/Gb flexibility** | 253d? | 2006-03-22 A | 2007-03-09 A | 100% | 2006-03-22 | 2007-03-09 | 253d? |  | C1; C4 | 7344h | 7344h | VGCSFlex | Siemens | robert.zaus@nsn.com | Rel-7 | Frederic | VGCSFlex |  |  |  |  |
| 4562 | 1223.1 | CT1 aspects of VGCSFlex | 159d? | 2006-03-22 A | 2006-10-30 A | 100% | 2006-03-22 | 2006-10-30 | 159d? | finish no earlier than 2006-10-30 | C1 | 1272h | 1272h |  | Siemens | robert.zaus@nsn.com | Rel-7 | Frederic |  | 43.068, 43.069 |  |  |  |
| 4563 | 1223.2 | CT4 aspects of VGCSFlex | 253d? | 2006-03-22 A | 2007-03-09 A | 100% | 2006-03-22 | 2007-03-09 | 253d? | finish no earlier than 2007-03-09 | C4 | 2024h | 2024h | VGCSFlex-c4 | Siemens | robert.zaus@nsn.com | Rel-7 | Kimmo | VGCSFlex-c4 | 29.002 |  |  |  |
| 4564 | 1224 | DIAMETER on the GGSN Gi interface | 586d? | 2004-09-10 A | 2006-12-08 A | 100% | 2004-09-10 | 2006-12-08 | 586d? | finish no earlier than 2006-12-08 | C3 | 4688h | 4688h | DIAMGi | Vodafone | Nico.Gabriele@vodafone.com | Rel-7 | Adrian | DIAMGi | 29.061 |  |  |  |
| 4565 | 1225 | DIAMETER on the PDG Wi interface | 586d? | 2004-09-10 A | 2006-12-08 A | 100% | 2004-09-10 | 2006-12-08 | 586d? | finish no earlier than 2006-12-08 | C3 | 4688h | 4688h | DIAMWi | Vodafone | Nico.Gabriele@vodafone.com | Rel-7 | Adrian | DIAMWi | 29.161 |  |  |  |
| 4566 | 1226 | Interworking between the 3GPP CS domain with BICC or ISUP as signalling protocol and external SIP-I networks | 478d? | 2006-09-22 A | 2008-07-22 A | 100% | 2006-09-22 | 2008-07-22 | 478d? | finish no earlier than 2007-09-14 | C3 | 3824h | 3824h | ExtSIPI | Siemens | Thomas.Belling@nsn.com | Rel-7 | Adrian | ExtSIPI | 29.164 |  |  |  |
| 4567 | 1227 | PDU multiplexing at Nb Interface with IP transport | 427d? | 2006-12-04 A | 2008-07-22 A | 100% | 2006-12-04 | 2008-07-22 | 427d? | start no earlier than 2006-12-04 | C3 | 3416h | 3416h | NbIPMux | Alcatel-Lucent | Jean.Rzeznik@alcatel-lucent.fr | Rel-7 | Adrian | NbIPMux | 29.414 |  | 34 |  |
| 4568 | 1228 | **Mp (MRFC - MRFP) interface** | 345d? | 2006-02-13 A | 2007-06-08 A | 100% | 2006-02-13 | 2007-06-08 | 345d? |  | C4; C1 | 9904h | 9904h | Mp | Ericsson | philip.hodges@ericsson.com | Rel-7 | Kimmo | Mp |  |  |  |  |
| 4569 | 1228.1 | CT1 aspects of Mp | 1d | 2006-02-13 A | 2006-02-13 A | 100% | 2006-02-13 | 2006-02-13 | 1d | finish no earlier than 2006-02-13 | C1 | 8h | 8h |  | Ericsson | philip.hodges@ericsson.com | Rel-7 | Frederic |  | 24.229 |  |  |  |
| 4570 | 1228.2 | Deleted - CT3 aspects of Mp | 1d | 2006-09-22 A | 2006-09-22 A | 100% | 2006-09-22 | 2006-09-22 | 1d | start no earlier than 2006-09-22 | C3 | 8h | 8h |  | Ericsson | philip.hodges@ericsson.com | Rel-7 | Adrian |  | 29.162 |  |  | CP-33 |
| 4571 | 1228.3 | Procedures description | 201d? | 2006-06-02 A | 2007-03-09 A | 100% | 2006-06-02 | 2007-03-09 | 201d? | finish no earlier than 2007-03-09 | C4 | 1608h | 1608h | Mp-PROCc4 | Huawei | Chencheng@huawei.com | Rel-7 | Kimmo | Mp-PROCc4 | 23.333 |  |  |  |
| 4572 | 1228.4 | Stage 3 for Mp (MRFC - MRFP) interface | 345d | 2006-02-13 A | 2007-06-08 A | 100% | 2006-02-13 | 2007-06-08 | 345d | finish no earlier than 2007-06-08 | C4 | 2760h | 2760h | Mp-St3c4 | Ericsson | philip.hodges@ericsson.com | Rel-7 | Kimmo | Mp-St3c4 | 29.333 |  |  |  |
| 4573 | 1229 | Routeing of MT-SMS via the HPLMN | 71d? | 2006-12-01 A | 2007-03-09 A | 100% | 2006-12-01 | 2007-03-09 | 71d? | finish no earlier than 2007-03-09 | C4; C1 | 1136h | 1136h | SMSviaH | Vodafone | Nick.Russell@vodafone.com | Rel-7 | Kimmo | SMSviaH | 23.040, 29.002 |  | 34 |  |
| 4574 | 1230 | Mobile Termination whilst the MS is moving to another MSC | 60d? | 2007-03-09 A | 2007-05-31 A | 100% | 2007-03-09 | 2007-05-31 | 60d? | start no earlier than 2007-03-09 | C4 | 480h | 480h | MTmovMS | Alcatel-Lucent | bruno.landais@alcatel-lucent.fr | Rel-7 | Kimmo | MTmovMS | 23.008, 23.012, 23.018, 23.078, 23.079, 29.002 |  |  |  |
| 4575 | 1231 | ISIM API for Java Card | 620d? | 2005-03-14 A | 2007-07-27 A | 100% | 2005-03-14 | 2007-07-27 | 620d? | finish no earlier than 2007-07-27 | C6 | 4960h | 4960h | APIJAVA | Sun | Sebastian Hans | Rel-7 | Xavier | APIJAVA | 31.103, 102 241 | 38 | 74 |  |
| 4576 | 1232 | Rel-7 (U)SIM API Testing (TS 31.213) | 211d? | 2009-05-30 A | 2010-03-19 A | 100% | 2009-05-30 | 2010-03-19 | 211d? | finish no earlier than 2010-03-12 | C6 | 1688h | 1688h | USIM_API_Test | Sagem Orga | gerrit.hartbrod@sagem-orga.com | Rel-7 | Xavier | USIM_API_Test | 31.213 | 23 | 44 |  |
| 4577 | 1233 | High speed interface between the UICC and the ME | 311d? | 2006-09-22 A | 2007-11-30 A | 100% | 2006-09-22 | 2007-11-30 | 311d? | finish no earlier than 2007-11-30 | C6 | 2488h | 2488h | HSI | Gemalto | jacques.seif@GEMALTO.COM | Rel-7 | Xavier | HSI | 31.101 |  |  |  |
| 4578 | 1234 | Video Codec Performance Requirements | 634d? | 2005-01-03 A | 2007-06-07 A | 100% | 2005-01-03 | 2007-06-07 | 634d? | finish no earlier than 2007-06-07 | S4 | 5072h | 5072h | VICPer | Siemens | juergen.pandel@siemens.com | Rel-7 | Paolo | VICPer | 26.234, 26.235, 26.346, 26.140, 26.902 |  |  |  |
| 4579 | 1235 | Dynamic and Interactive Multimedia Scenes | 583d? | 2005-03-15 A | 2007-06-07 A | 100% | 2005-03-15 | 2007-06-07 | 583d? | finish no earlier than 2007-06-07 | S4 | 4664h | 4664h | DIMS | Streamezzo | gaelle.martin-cocher@streamezzo.com | Rel-7 | Paolo | DIMS | 26.140, 26.142, 26.234, 26.244, 23.346 |  |  |  |
| 4580 | 1236 | 3G-324M Video Telephony Call Setup Times Improvements | 341d? | 2005-06-08 A | 2006-09-27 A | 100% | 2005-06-08 | 2006-09-27 | 341d? | finish no earlier than 2006-09-27 | S4 | 2728h | 2728h | VTCSTI | Vodafone | edward.hall@vodafone.co.uk | Rel-7 | Paolo | VTCSTI | 26.911 |  |  |  |

Notes:
- 4557: -
- 4558: -
- 4559: -
- 4560: TR 24.930: Signalling flows for the session setup in the IM CN subsystem based on Session Initiation Protocol (SIP)
- 4561: Voice Group Call Service
- 4562: -
- 4563: -
- 4564: -
- 4565: -
- 4566: -
- 4567: -
- 4568: -
- 4569: -
- 4570: CP#34: CT3 not involved in Mp interface definition
- 4571: -
- 4572: -
- 4573: WID approved in CP#34
- 4574: -
- 4575: -
- 4576: CP#47 completed. Update of Rel-6 (U)SIM API for Java Card Testing UID_43007 under Rel-6 UICC/USIM enhancements and interworking UID_1800
- 4577: Following ETSI publication of TS 102 600, expected to be completed at CT6 meeting 45
- 4578: -
- 4579: -
- 4580: -

| ID | WBS | Task | Duration | Start | Finish | Complete | Baseline start | Baseline finish | Baseline duration | Constraint | Resources | Work | Actual work | Acronym | WI rapporteur name | WI rapporteur e-mail | Release | MCC resp | Acronym_3GU_Export | TSG stopped |
| --- | --- | --- | --- | --- | --- | --- | --- | --- | --- | --- | --- | --- | --- | --- | --- | --- | --- | --- | --- | --- |
| 4581 | 1237 | **Optimizations for Multimedia Telephony over IMS** | 2d? | 2005-09-28 A | 2005-09-29 A | 100% | 2005-09-28 | 2005-09-28 | 0d? |  | S4 | 32h | 32h | OMTIMS | Ericsson | olle.franceschi@ericsson.com | Rel-7 | Paolo | OMTIMS |  |
| 4582 | 1237.1 | Deleted - Characterisation of Adaptive Jitter Management Performance for VoIP Services | 2d? | 2005-09-28 A | 2005-09-29 A | 100% | 2005-09-28 | 2005-09-28 | 0d? | finish no earlier than 2005-09-29 | S4 | 16h | 16h | OMTIMS-CAJMP | Lucent | dhuo@lucent.com | Rel-7 | Paolo | OMTIMS-CAJMP | SP-35 |
| 4583 | 1238 | End-to-End Multimedia Services Performance Metrics | 382d? | 2005-09-28 A | 2007-03-15 A | 100% | 2005-09-28 | 2007-03-15 | 382d? | finish no earlier than 2007-03-15 | S4 | 3056h | 3056h | E2EMSPM | China Mobile | zhangyanyf@chinamobile.com | Rel-7 | Paolo | E2EMSPM |  |
| 4584 | 1239 | Packet Switched Streaming Enhancements | 261d? | 2006-06-08 A | 2007-06-07 A | 100% | 2006-06-08 | 2007-06-07 | 261d? | finish no earlier than 2007-06-07 | S4 | 2088h | 2088h | PSSe | Ericsson | olle.franceschi@ericsson.com | Rel-7 | Paolo | PSSe |  |
| 4585 | 1240 | **Rel-7 Operations, Administration, Maintenance and Provisioning (OAM&P)** | 472.86d? | 2005-09-02 A | 2007-06-26 A | 100% | 2005-09-02 | 2007-06-26 | 472.86d? |  | S5 | 82725.8h | 82725.8h | OAM7 | Huawei | Christian.Toche@huawei.com | Rel-7 | Mirko | OAM7 |  |
| 4586 | 1240.1 | **Rel-7 Network Infrastructure Management** | 465d? | 2005-09-02 A | 2007-06-14 A | 100% | 2005-09-02 | 2007-06-14 | 465d? |  | S5 | 41800h | 41800h | OAM7-NIM |  |  | Rel-7 | Mirko | OAM7-NIM |  |
| 4587 | 1240.1.1 | Enhance NRM to accommodate NGN (IMS as basis of the Next Generation Network) | 465d? | 2005-09-02 A | 2007-06-14 A | 100% | 2005-09-02 | 2007-06-14 | 465d? | finish no earlier than 2007-06-14 | S5 | 3720h | 3720h |  | Motorola |  | Rel-7 | Mirko |  |  |
| 4588 | 1240.1.2 | Co-operative Element Management interface (CO-OP) (Study + Implementation) | 400d? | 2005-09-02 A | 2007-03-15 A | 100% | 2005-09-02 | 2007-03-15 | 400d? | finish no earlier than 2007-03-15 | S5 | 3200h | 3200h |  | Motorola |  | Rel-7 | Mirko |  |  |
| 4589 | 1240.1.3 | Network Management (NM) Itf-N performance criteria | 465d? | 2005-09-02 A | 2007-06-14 A | 100% | 2005-09-02 | 2007-06-14 | 465d? | finish no earlier than 2007-06-14 | S5 | 3720h | 3720h |  | China Mobile |  | Rel-7 | Mirko |  |  |
| 4590 | 1240.1.4 | Delta synchronization between IRP Manager and IRP Agent (Study + Implementation) | 465d? | 2005-09-02 A | 2007-06-14 A | 100% | 2005-09-02 | 2007-06-14 | 465d? | finish no earlier than 2007-06-14 | S5 | 3720h | 3720h |  | Siemens |  | Rel-7 | Mirko |  |  |
| 4591 | 1240.1.5 | Subscription Management (SuM) IRP Solution Sets | 330d? | 2005-09-02 A | 2006-12-07 A | 100% | 2005-09-02 | 2006-12-07 | 330d? | finish no earlier than 2006-12-07 | S5 | 2640h | 2640h |  | Ericsson |  | Rel-7 | Mirko |  |  |
| 4592 | 1240.1.6 | Integration Reference Point (IRP) Security Management | 400d? | 2005-09-02 A | 2007-03-15 A | 100% | 2005-09-02 | 2007-03-15 | 400d? | finish no earlier than 2007-03-15 | S5 | 3200h | 3200h |  | Huawei | Christian.Toche@huawei.com | Rel-7 | Mirko |  |  |
| 4593 | 1240.1.7 | Partial suspension of Itf-N during maintenance/testing (Study + Implementation) | 465d? | 2005-09-02 A | 2007-06-14 A | 100% | 2005-09-02 | 2007-06-14 | 465d? | finish no earlier than 2007-06-14 | S5 | 3720h | 3720h |  | Siemens |  | Rel-7 | Mirko |  |  |
| 4594 | 1240.1.8 | Deleted - Management of Legacy Equipment | 336d? | 2005-09-02 A | 2006-12-15 A | 100% | 2005-09-02 | 2006-12-15 | 336d? | finish no earlier than 2006-12-15 | S5 | 2688h | 2688h |  | Siemens |  | Rel-7 | Mirko |  | SP-35 |
| 4595 | 1240.1.9 | Deleted - Rules for Vendor Specific Extensions | 400d? | 2005-09-02 A | 2007-03-15 A | 100% | 2005-09-02 | 2007-03-15 | 400d? | finish no earlier than 2007-03-15 | S5 | 3200h | 3200h |  | Siemens |  | Rel-7 | Mirko |  | SP-35 |
| 4596 | 1240.1.10 | Backward and Forward Compatibility of IRP systems | 465d? | 2005-09-02 A | 2007-06-14 A | 100% | 2005-09-02 | 2007-06-14 | 465d? | finish no earlier than 2007-06-14 | S5 | 3720h | 3720h |  | Ericsson |  | Rel-7 | Mirko |  |  |
| 4597 | 1240.1.11 | Repeater Network Resource Model (NRM) definition | 214d? | 2006-02-13 A | 2006-12-07 A | 100% | 2006-02-13 | 2006-12-07 | 214d? | finish no earlier than 2006-12-07 | S5 | 1712h | 1712h |  | China Mobile |  | Rel-7 | Mirko |  |  |
| 4598 | 1240.1.12 | UTRAN radio channel power monitoring | 284d? | 2006-02-13 A | 2007-03-15 A | 100% | 2006-02-13 | 2007-03-15 | 284d? | finish no earlier than 2007-03-15 | S5 | 2272h | 2272h |  | China Mobile |  | Rel-7 | Mirko |  |  |
| 4599 | 1240.1.13 | Notification XML Schema | 71d? | 2006-12-07 A | 2007-03-15 A | 100% | 2006-12-07 | 2007-03-15 | 71d? | finish no earlier than 2007-03-15 | S5 | 568h | 568h |  | Huawei | Christian.Toche@huawei.com | Rel-7 | Mirko |  |  |
| 4600 | 1240.2 | **Rel-7 Performance Management** | 465d? | 2005-09-02 A | 2007-06-14 A | 100% | 2005-09-02 | 2007-06-14 | 465d? |  | S5 | 22992h | 22992h | OAM7-PM |  |  | Rel-7 | Mirko | OAM7-PM |  |
| 4601 | 1240.2.1 | Performance measurements definition for CN CS | 400d? | 2005-09-02 A | 2007-03-15 A | 100% | 2005-09-02 | 2007-03-15 | 400d? | finish no earlier than 2007-03-15 | S5 | 3200h | 3200h |  | China Mobile |  | Rel-7 | Mirko |  |  |
| 4602 | 1240.2.2 | Enhancement UTRAN performance measurements definition | 465d? | 2005-09-02 A | 2007-06-14 A | 100% | 2005-09-02 | 2007-06-14 | 465d? | finish no earlier than 2007-06-14 | S5 | 3720h | 3720h |  | China Mobile |  | Rel-7 | Mirko |  |  |
| 4603 | 1240.2.3 | Add TDD specific counters in Performance measurement | 330d? | 2005-09-02 A | 2006-12-07 A | 100% | 2005-09-02 | 2006-12-07 | 330d? | finish no earlier than 2006-12-15 | S5 | 2640h | 2640h |  | CATT |  | Rel-7 | Mirko |  |  |
| 4604 | 1240.2.4 | ATM bearer network Performance measurements | 400d? | 2005-09-02 A | 2007-03-15 A | 100% | 2005-09-02 | 2007-03-15 | 400d? | finish no earlier than 2007-03-15 | S5 | 3200h | 3200h |  | ZTE |  | Rel-7 | Mirko |  |  |
| 4605 | 1240.2.5 | Performance measurements definition for IMS | 465d? | 2005-09-02 A | 2007-06-14 A | 100% | 2005-09-02 | 2007-06-14 | 465d? | finish no earlier than 2007-06-14 | S5 | 3720h | 3720h |  | China Mobile |  | Rel-7 | Mirko |  |  |
| 4606 | 1240.2.6 | HSDPA performance measurements | 349d? | 2006-02-13 A | 2007-06-14 A | 100% | 2006-02-13 | 2007-06-14 | 349d? | finish no earlier than 2007-06-14 | S5 | 2792h | 2792h |  | China Mobile |  | Rel-7 | Mirko |  |  |

Notes:
- 4581: Aug2015: 99%->100 / Impacted TSs and TRs: 26.235, 26.236
- 4582: SP-35 stopped
- 4583: - / Impacted TSs and TRs: 26.944
- 4584: - / Impacted TSs and TRs: 26.234, 26.244
- 4585: OAM7 is an umbrella Feature also for OAM&P related TEI7 type of changes that are not part of any other dedicated feature/WI / Impacted TSs and TRs: TR 30.817
- 4586: -
- 4587: - / Impacted TSs and TRs: 32.731/2/3/5, 32.631/2/3/5
- 4588: - / Impacted TSs and TRs: 32.806, 32.814, 32.101
- 4589: - / Impacted TSs and TRs: 32.811
- 4590: - / Impacted TSs and TRs: 32.391/2/3/5
- 4591: - / Impacted TSs and TRs: 32.307/317/607/667/665, 32.101, 32.175
- 4592: - / Impacted TSs and TRs: 32.372/3/5, 32.111,32.30x,32.32x,32.33x,32.34x,32.35x,32.36x,32.41x,32.60x,32.61x,32.66x
- 4593: - / Impacted TSs and TRs: 32.381/2/3/5
- 4594: Request to TSG#35 to STOP the WI / Impacted TSs and TRs: new 32.xxx
- 4595: Request to TSG#35 to STOP the WI / Impacted TSs and TRs: 32.62n; For n = 1 to 5
- 4596: - / Impacted TSs and TRs: 32.154
- 4597: - / Impacted TSs and TRs: 32.721/2/3/5
- 4598: - / Impacted TSs and TRs: 32.405, 32.64n; For n = 1 to 5
- 4599: 12/2006 SP#34 WID approved / Impacted TSs and TRs: New 32.325/345/365/415, CR to 32.335/615/665
- 4600: -
- 4601: - / Impacted TSs and TRs: 32.407, 32.408
- 4602: - / Impacted TSs and TRs: 32.405
- 4603: - / Impacted TSs and TRs: 32.405
- 4604: - / Impacted TSs and TRs: No impact on 32.404, 32.405, 32.406, 32.407
- 4605: - / Impacted TSs and TRs: 32.404,32.409,32.437, 32.632/3/4/5
- 4606: - / Impacted TSs and TRs: 32.405

| ID | WBS | Task | Type | Duration | Start | Finish | Complete | Baseline start | Baseline finish | Baseline duration | Constraint | Resources | Work | Actual work | Acronym | WI rapporteur name | Release | MCC resp | Acronym_3GU_Export | TSG stopped | WI rapporteur e-mail | Status Report |
| --- | --- | --- | --- | --- | --- | --- | --- | --- | --- | --- | --- | --- | --- | --- | --- | --- | --- | --- | --- | --- | --- | --- |
| 4607 | 44.5 | **Rel-7 Trace Management** |  | 472.86d? | 2005-09-02 A | 2007-06-26 A | 100% | 2005-09-02 | 2007-06-26 | 472.86d? |  | S5 | 14150.9h | 14150.9h | OAM7-Trace | Vodafone | Rel-7 | Mirko | OAM7-Trace |  |  |  |
| 4608 | 1240.3.1 | End-to-end Service Level tracing for IMS |  | 350d? | 2005-11-11 A | 2007-03-15 A | 100% | 2005-11-11 | 2007-03-15 | 350d? | finish no earlier than 2007-03-15 | S5 | 2800h | 2800h |  | Vodafone | Rel-7 | Mirko |  | SP-31 |  |  |
| 4609 | 1240.3.2 | Trace record content for UTRAN TDD |  | 330d? | 2005-09-02 A | 2006-12-07 A | 100% | 2005-09-02 | 2006-12-07 | 330d? | finish no earlier than 2006-12-07 | S5 | 2640h | 2640h |  | Nokia | Rel-7 | Mirko |  |  |  |  |
| 4610 | 1240.3.3 | IRP for Subscriber and Equipment Trace Management |  | 465d? | 2005-09-02 A | 2007-06-14 A | 100% | 2005-09-02 | 2007-06-14 | 465d? | finish no earlier than 2007-06-14 | S5 | 3720h | 3720h |  | Nokia | Rel-7 | Mirko |  |  |  |  |
| 4611 | 1240.3.4 | Deleted - SIP enhancements for trace | milestone | 0d? | 2007-06-15 A | 2007-06-26 A | 100% | 2007-06-15 | 2007-06-26 | 0d? | start no earlier than 2007-06-15 | C1 |  |  |  |  | Rel-7 | Frederic |  | CP-32 |  |  |
| 4612 | 1240.3.5 | Deleted - duplicated with UID 35063 - IRP for Subscriber and Equipment Trace Management |  | 336d? | 2005-09-02 A | 2006-12-15 A | 100% | 2005-09-02 | 2006-12-15 | 336d? | finish no earlier than 2006-12-15 | S5 | 2688h | 2688h |  | Nokia | Rel-7 | Mirko |  | SP-33 |  |  |
| 4613 | 1241 | **Rel-7 Charging Management small Enhancements** |  | 279d? | 2006-05-22 A | 2007-06-14 A | 100% | 2006-05-22 | 2007-06-14 | 279d? |  | S5 | 5952h | 5952h | CH7 | Orange | Rel-7 | Mirko | CH7 |  | alain.bibas@orange-ft.com |  |
| 4614 | 1241.1 | Alternate Charged Party (ACP) for IMS |  | 279d? | 2006-05-22 A | 2007-06-14 A | 100% | 2006-05-22 | 2007-06-14 | 279d? | finish no earlier than 2007-06-14 | S5 | 2232h | 2232h | CH7-IMS-ACP | Lucent | Rel-7 | Mirko | CH7-IMS-ACP |  | njmazzarella@alcatel-lucent.com |  |
| 4615 | 1241.2 | Align 3GPP Charging with OMA PoC Enabler Release 2.0 |  | 186d? | 2006-09-28 A | 2007-06-14 A | 100% | 2006-09-28 | 2007-06-14 | 186d? | finish no earlier than 2007-06-14 | S5 | 1488h | 1488h | CH7-PoC | Siemens | Rel-7 | Mirko | CH7-PoC |  | Gerald.Goermer@nsn.com |  |
| 4616 | 8.5 | **Multiple-Input Multiple-Output (MIMO) antennas** |  | 1301d? | 2003-03-14 A | 2008-03-07 A | 100% | 2003-03-14 | 2008-03-07 | 1301d? |  | R1; R5 | 55848h | 55848h | MIMO | Alcatel-Lucent | Rel-7 | Patrick | MIMO |  | hchuang@Alcatel-Lucent.com |  |
| 4617 | 1242.1 | MIMO - Physical layer |  | 915d? | 2003-09-12 A | 2007-03-15 A | 100% | 2003-09-12 | 2007-03-15 | 915d? | finish no earlier than 2007-03-15 | R1 | 7320h | 7320h | MIMO-Phys | Alcatel-Lucent | Rel-7 | Patrick | MIMO-Phys |  | hchuang@Alcatel-Lucent.com | RP-070037 |
| 4618 | 1242.2 | MIMO - Layer 2,3 aspects |  | 915d? | 2003-09-12 A | 2007-03-15 A | 100% | 2003-09-12 | 2007-03-15 | 915d? | finish no earlier than 2007-03-15 | R2 | 7320h | 7320h | MIMO-L23 | Alcatel-Lucent | Rel-7 | Yong-Jun | MIMO-L23 |  | hchuang@Alcatel-Lucent.com | RP-070037 |
| 4619 | 1242.3 | MIMO - Iub/Iur Protocol Aspects |  | 1045d? | 2003-03-14 A | 2007-03-15 A | 100% | 2003-03-14 | 2007-03-15 | 1045d? | finish no earlier than 2007-03-15 | R3 | 8360h | 8360h | MIMO-IurIub | Alcatel-Lucent | Rel-7 | Juha | MIMO-IurIub |  | hchuang@Alcatel-Lucent.com | RP-070037 |
| 4620 | 1242.4 | MIMO - RF Radio Transmission/Reception, System Performance Requirements and Conformance Testing |  | 982d? | 2003-12-12 A | 2007-09-17 A | 100% | 2003-12-12 | 2007-09-17 | 982d? | finish no earlier than 2007-09-17 | R4 | 7856h | 7856h | MIMO-RF | Alcatel-Lucent | Rel-7 | Issam | MIMO-RF |  | ngm@Alcatel-Lucent.com | RP-070531 |
| 4621 | 1242.5 | **UE Conformance Testing for Multiple Input Multiple Output antennas (MIMO)** |  | 261d? | 2007-03-09 A | 2008-03-07 A | 100% | 2007-03-09 | 2008-03-07 | 261d? |  | R5 | 4176h | 4176h | MIMO-UEConTest | Qualcomm | Rel-7 | Ingbert | MIMO-UEConTest |  | svora@qualcomm.com |  |
| 4622 | 1242.5.1 | Conformance Test Aspects – Multiple Input Multiple Output Antennas (MIMO) for FDD |  | 261d? | 2007-03-09 A | 2008-03-07 A | 100% | 2007-03-09 | 2008-03-07 | 261d? | finish no earlier than 2008-03-07 | R5 | 2088h | 2088h | MIMO-UEConTest_FDD | Qualcomm | Rel-7 | Ingbert | MIMO-UEConTest_FDD |  | svora@qualcomm.com |  |
| 4623 | 1243 | **Rel-7 Improvements of the Radio Interface** |  | 709d? | 2004-09-15 A | 2007-06-04 A | 100% | 2004-09-15 | 2007-06-04 | 709d? |  | RP; GP | 40520h | 40520h |  |  | Rel-7 | Issam |  |  |  |  |
| 4624 | 1243.1 | Extended UMTS 1.7/2.1 GHz |  | 198d? | 2006-03-15 A | 2006-12-15 A | 100% | 2006-03-15 | 2006-12-15 | 198d? | finish no earlier than 2006-12-15 | R4 | 1584h | 1584h | RInImp-UMTS1721Ext | Ericsson | Rel-7 | Issam | RInImp-UMTS1721Ext |  | johan.skold@ericsson.com | RP-060681 |
| 4625 | 1243.2 | UMTS 2.6 GHz 7.68 Mcps TDD |  | 67d? | 2006-06-15 A | 2006-09-15 A | 100% | 2006-06-15 | 2006-09-15 | 67d? | finish no earlier than 2006-09-15 | R4 | 536h | 536h | RInImp-UMTS26VHCRTDD | IPWireless | Rel-7 | Issam | RInImp-UMTS26VHCRTDD |  | Shin Horng Wong (shwong@ipwireless.com) | RP-060451 |
| 4626 | 1243.3 | UMTS 2.6 GHz |  | 195d? | 2004-09-15 A | 2005-06-14 A | 100% | 2004-09-15 | 2005-06-14 | 195d? | finish no earlier than 2005-06-14 | R4 | 1560h | 1560h | RInImp-UMTS2600 | Nokia | Rel-7 | Issam | RInImp-UMTS2600 |  | jussi.numminen@nokia.com | RP-050184 |
| 4627 | 1243.4 | UMTS 2.6 GHz TDD |  | 261d? | 2004-12-15 A | 2005-12-14 A | 100% | 2004-12-15 | 2005-12-14 | 261d? | finish no earlier than 2005-12-15 | R4 | 2088h | 2088h | RInImp-UMTS2600TDD | IPWireless | Rel-7 | Issam | RInImp-UMTS2600TDD |  | Shin Horng Wong (shwong@ipwireless.com) | RP-050661 |
| 4628 | 1243.5 | UMTS 900 MHz |  | 261d? | 2004-12-15 A | 2005-12-14 A | 100% | 2004-12-15 | 2005-12-14 | 261d? | finish no earlier than 2005-12-15 | R4 | 2088h | 2088h | RInImp-UMTS900 | Nortel | Rel-7 | Issam | RInImp-UMTS900 |  | Yannick Li (yli@nortelnetworks.com) | RP-050662 |
| 4629 | 1243.6 | UMTS 1700 MHz |  | 197d? | 2005-03-15 A | 2005-12-14 A | 100% | 2005-03-15 | 2005-12-14 | 197d? | finish no earlier than 2005-12-15 | R4 | 1576h | 1576h | RInImp-UMTS1700 | NTT DoCoMo | Rel-7 | Issam | RInImp-UMTS1700 |  | Takehiro Nakamura (nakamurata@nttdocomo.co.jp) | RP-050824 |
| 4630 | 1243.7 | UE Antenna Performance Evaluation Method and Requirements |  | 644d? | 2004-12-15 A | 2007-06-04 A | 100% | 2004-12-15 | 2007-06-04 | 644d? | finish no earlier than 2007-06-04 | R4; GP | 10304h | 10304h | RInImp-UEAnt | TeliaSonera | Rel-7 | Issam | RInImp-UEAnt |  | Christian.Bergljung@TeliaSonera.com | RP-070281 |
| 4631 | 1243.8 | Improved Performance Requirements for HSDPA UE based on Rx Diversity (type 1) & LMMSE equalizer (type 2) | milestone | 0d? | 2005-03-15 A | 2005-03-15 A | 100% | 2005-03-15 | 2005-03-15 | 0d? | finish no earlier than 2005-03-15 | R4 |  |  | RInImp-HSPerf-Type3 | Cingular | Rel-7 | Issam | RInImp-HSPerf-Type3 |  | Marc Grant | RP-060015 |

Notes:
- 4607: -
- 4608: 07/2005: OMA (Stage 1), Stage 2/3 SA5, CT1/3/4 / Impacted TSs and TRs: 32.101, 32.421, 32.422, 32.423
- 4609: - / Impacted TSs and TRs: 32.421, 32.422, 32.423
- 4610: - / Impacted TSs and TRs: 32.441, 32.442, 32.443, 32.445, 32.632, 32.633, 32.635
- 4611: combined with UID 11067
- 4612: - / Impacted TSs and TRs: 32.421,32.422,32.423. 3 new 32.4x1,2,3
- 4613: CH7 is an umbrella Feature also for OAM&P related TEI7 type of changes that are not part of any other dedicated feature/WI / Impacted TSs and TRs: TR 30.817
- 4614: - / Impacted TSs and TRs: 32.240, 32.260, 32.298, 32.299
- 4615: 09/2006 SP#33 WID approved / Impacted TSs and TRs: 32.240, 32.272, 32.299, 32.298
- 4616: Completed Sep 2007; SR in RP-070037and RP-070531 / Impacted TSs and TRs: 25.876, 25.996
- 4617: Completed Sep 2007; SR in RP-070037 / Impacted TSs and TRs: 25.211, 25.212, 25.213, 25.214, 25.215, 25.221
- 4618: Completed Sep 2007; SR in RP-070037 / Impacted TSs and TRs: 25.876
- 4619: Completed Sep 2007; SR in RP-070037
- 4620: Completed Sep 2007; SR in RP-070531
- 4621: BB place holder for a number of RAN5 Tasks
- 4622: - / Impacted TSs and TRs: TS 34.108, TS 34.109, TS 34.121-1, TS 34.121-2, TS 34.123-1, TS 34.123-2, TS 34.123-3
- 4623: Generic feature
- 4624: RP#34 completed. Introduction of Band X (Extended UMTS 1.7/2.1 GHz) in 25.307 / Impacted TSs and TRs: 25.806, 25.101, 25.104, 25.133, 24.141, 25.331, 25.306, 25.307, 25.423, 25.461, 25.463, 34.121
- 4625: RP#33 completed / Impacted TSs and TRs: 25.102, 25.105, 25.123, 25.113, 25.142, 34.124
- 4626: RP#28 completed / Impacted TSs and TRs: 25.101, 25.104, 25.133, 25.141, 25.331, 25.942, 25.306, 25.307, 34.121
- 4627: RP#30 completed / Impacted TSs and TRs: 25.102, 25.105, 25.113, 25.123, 25.142, 25.331, 25.942, 25.306, 25.307, 34.122, 34.124
- 4628: RP#30 completed / Impacted TSs and TRs: 25.101, 25.104, 25.113, 25.133, 25.141, 25.331, 25.942, 25.306, 25.307, 34.121
- 4629: RP#30 completed / Impacted TSs and TRs: 25.101, 25.104, 25.113, 25.133, 25.141, 25.306, 25.307, 25.331, 34.121
- 4630: RP#36 completed / Impacted TSs and TRs: 25.101, new TR (25.914, 25.963)
- 4631: RP#27 completed / Impacted TSs and TRs: 25.101

| ID | WBS | Task | Type | Duration | Start | Finish | Complete | Baseline start | Baseline finish | Baseline duration | Constraint | Deadline | Resources | Work | Actual work | Acronym | WI rapporteur name | WI rapporteur e-mail | Release | MCC resp | Acronym_3GU_Export | Status Report | TSG stopped | PCG stopped | Created at |
| --- | --- | --- | --- | --- | --- | --- | --- | --- | --- | --- | --- | --- | --- | --- | --- | --- | --- | --- | --- | --- | --- | --- | --- | --- | --- |
| 4632 | 1243.9 | **Additional minimum UE performance requirement for non-HSDPA channels based on type 1 enhanced receiver (Rx Diversity)** |  | 327d? | 2005-09-15 A | 2006-12-15 A | 100% | 2005-09-15 | 2006-12-15 | 327d? |  |  | R4 | 7344h | 7344h | RInImp-RxDiv | Qualcomm | Serge Willenegger (sergew@qualcomm.com) | Rel-7 | Issam | RInImp-RxDiv |  |  |  |  |
| 4633 | 1243.9.1 | Additional minimum UE performance requirement for DL physical channels in support of DCH/HS-DSCH operation based on type 1 enhanced receiver (RX-Diversity) |  | 195d? | 2005-09-15 A | 2006-06-14 A | 100% | 2005-09-15 | 2006-06-14 | 195d? | finish no earlier than 2006-06-15 |  | R4 | 1560h | 1560h | RInImp-RxDiv-DCH | Cingular | Marc Grant | Rel-7 | Issam | RInImp-RxDiv-DCH | RP-060235 |  |  |  |
| 4634 | 1243.9.2 | Additional minimum UE performance requirement for downlink physical channels in support of MTCH and MCCH operation based on type 1 enhanced receiver (Rx-Diversity) |  | 198d? | 2006-03-15 A | 2006-12-15 A | 100% | 2006-03-15 | 2006-12-15 | 198d? | finish no earlier than 2006-12-15 |  | R4 | 1584h | 1584h | RInImp-RxDiv-MBMS | Qualcomm | Serge Willenegger (sergew@qualcomm.com) | Rel-7 | Issam | RInImp-RxDiv-MBMS | RP-060678 |  |  |  |
| 4635 | 1243.9.3 | Additional minimum UE performance requirement for downlink physical channels in support of E-DCH operation based on type 1 enhanced receiver (Rx-Diversity) |  | 198d? | 2006-03-15 A | 2006-12-15 A | 100% | 2006-03-15 | 2006-12-15 | 198d? | finish no earlier than 2006-12-15 |  | R4 | 1584h | 1584h | RInImp-RxDiv-EDCH | Qualcomm | Serge Willenegger (sergew@qualcomm.com) | Rel-7 | Issam | RInImp-RxDiv-EDCH | RP-060679 |  |  |  |
| 4636 | 1243.10 | Deleted Improved support of gaming over HSDPA/EDCH |  | 262d? | 2005-12-15 A | 2006-12-15 A | 100% | 2005-12-15 | 2006-12-15 | 262d? | finish no earlier than 2006-12-15 |  | R2 | 2096h | 2096h | RInImp-Gaming | Cingular | Don Zelmer (dz1069@att.com) | Rel-7 | Yong-Jun | RInImp-Gaming | RP-060680 | RP-34 |  |  |
| 4637 | 1243.11 | Deleted (not approved at PCG) - UMTS 2.6 GHz FDD DL External | milestone | 0d? | 2005-09-15 A | 2005-09-15 A | 100% | 2005-09-15 | 2005-09-15 | 0d? | finish no earlier than 2005-09-15 |  | R4 |  |  | RInImp-UMTS2600Ext | T-mobile | han.van.bussel@t-mobile.de | Rel-7 | Issam | RInImp-UMTS2600Ext |  | RP-31 | PCG-16 |  |
| 4638 | 1244 | **Rel-7 Improvements of the Radio Interface - UE Conformance Testing** |  | 741d? | 2005-11-11 A | 2008-09-12 A | 100% | 2005-11-11 | 2008-09-12 | 741d? |  |  | R5 | 17568h | 17568h |  |  |  | Rel-7 | Ingbert |  |  |  |  |  |
| 4639 | 16.5.1 | UE Conformance Test for UMTS 2600 MHz |  | 146d | 2005-11-11 A | 2006-06-02 A | 100% | 2005-11-11 | 2006-06-02 | 146d | finish no earlier than 2006-06-02 | 2006-06-02 | R5 | 1168h | 1168h | RInImp-UMTS2600_Test | Nokia | Aleksi.Heino@nokia.com | Rel-7 | Ingbert | RInImp-UMTS2600_Test |  |  |  | Fri 7/11/05 |
| 4640 | 16.5.1 | UE Conformance Test for UMTS 900 MHz (band VIII) |  | 146d | 2005-11-11 A | 2006-06-02 A | 100% | 2005-11-11 | 2006-06-02 | 146d | finish no earlier than 2006-06-02 | 2006-06-02 | R5 | 1168h | 1168h | RInImp-UMTS900_Test | Qualcomm | hanye@qualcomm.com | Rel-7 | Ingbert | RInImp-UMTS900_Test |  |  |  | Fri 11/03/05 |
| 4641 | 1244.3 | Conformance Test Aspects – Improved Performance of HSDPA Receiver type 3 |  | 191d? | 2006-03-10 A | 2006-12-01 A | 100% | 2006-03-10 | 2006-12-01 | 191d? | finish no earlier than 2006-12-01 |  | R5 | 1528h | 1528h | RInImp-HSPerf-Type3_Test | Motorola | carolyn.taylor@motorola.com | Rel-7 | Ingbert | RInImp-HSPerf-Type3_Test |  |  |  |  |
| 4642 | 1244.4 | UE antenna Over The Air (OTA) conformance testing |  | 518d? | 2006-09-20 A | 2008-09-12 A | 100% | 2006-09-20 | 2008-09-12 | 518d? | finish no earlier than 2008-09-12 |  | R5 | 4144h | 4144h | RInImp-UEAnt_Test | Nokia | Aleksi.Heino@nokia.com | Rel-7 | Ingbert | RInImp-UEAnt_Test | RP-080535 |  |  |  |
| 4643 | 1244.5 | UE conformance testing for FDD Inter-Band Operation |  | 131d? | 2006-06-02 A | 2006-12-01 A | 100% | 2006-06-02 | 2006-12-01 | 131d? | finish no earlier than 2006-12-01 |  | R5 | 1048h | 1048h | RInImp-InterBand_Test | NEC, Motorola | Jacob.John@motorola.com | Rel-7 | Ingbert | RInImp-InterBand_Test |  |  |  |  |
| 4644 | 1244.6 | Conformance Test Aspects – Extended UMTS 1.7/2.1 GHz |  | 131d? | 2006-12-01 A | 2007-06-01 A | 100% | 2006-12-01 | 2007-06-01 | 131d? | finish no earlier than 2007-06-01 |  | R5 | 1048h | 1048h | RInImp-UEConTest_UMTS1721Ext | Motorola | carolyn.taylor@motorola.com | Rel-7 | Ingbert | RInImp-UEConTest_UMTS1721Ext | RP-070312 |  |  |  |
| 4645 | 1244.7 | Conformance Test Aspects – Minimum UE performance requirement for downlink physical channels in support of E-DCH operation based on type 1 enhanced receiver (Rx-Diversity) |  | 136d? | 2007-06-01 A | 2007-12-07 A | 100% | 2007-06-01 | 2007-12-07 | 136d? | finish no earlier than 2007-12-07 |  | R5 | 1088h | 1088h | RInImp-UEConTest_RxDivEDCH | Motorola | carolyn.taylor@motorola.com | Rel-7 | Ingbert | RInImp-UEConTest_RxDivEDCH | RP-070810 |  |  |  |
| 4646 | 1244.8 | Conformance Test Aspects – Minimum UE performance requirement for downlink physical channels in support of MTCGH and MCCH operation based on type 1 enhanced receiver (Rx-Diversity) |  | 201d? | 2007-06-01 A | 2008-03-07 A | 100% | 2007-06-01 | 2008-03-07 | 201d? | finish no earlier than 2008-03-07 |  | R5 | 1608h | 1608h | RInImp-UEConTest_RxDivMBMS | Ericsson | leif.mattisson@ericsson.com | Rel-7 | Ingbert | RInImp-UEConTest_RxDivMBMS | RP-080056 |  |  |  |
| 4647 | 1245 | **Rel-7 RAN improvements** |  | 653d? | 2004-12-15 A | 2007-06-15 A | 100% | 2004-12-15 | 2007-06-15 | 653d? |  |  | RP; S5 | 39512h | 39512h |  |  |  | Rel-7 |  |  |  |  |  |  |
| 4648 | 1245.1 | Optimization of channelisation code utilisation for 1.28 Mcps TDD |  | 523d? | 2004-12-15 A | 2006-12-15 A | 100% | 2004-12-15 | 2006-12-15 | 523d? | finish no earlier than 2006-12-15 |  | R1 | 4184h | 4184h | RANimp-RABSE-CodOptLCRTDD | UTStarcom | Ka Leong Lo (kaleong.lo@UTSTAR.COM) | Rel-7 | Patrick | RANimp-RABSE-CodOptLCRTDD | RP-060682 |  |  |  |
| 4649 | 1245.2 | Delay optimization for procedures applicable to CS and PS Connections |  | 394d? | 2005-03-15 A | 2006-09-15 A | 100% | 2005-03-15 | 2006-09-15 | 394d? | finish no earlier than 2006-09-15 |  | R2 | 3152h | 3152h | RANimp-DelayOpt | Nokia | juho.pirskanen@nokia.com | Rel-7 | Yong-Jun | RANimp-DelayOpt | RP-060453 |  |  |  |
| 4650 | 1245.3 | Improved support of IMS Realtime Services using HSDPA/HSUPA |  | 197d? | 2005-03-15 A | 2005-12-14 A | 100% | 2005-03-15 | 2005-12-14 | 197d? | start no earlier than 2005-03-15 |  | R2 | 1576h | 1576h | RANimp-IMSRealTime | Cingular | Don Zelmer (dz1069@att.com) | Rel-7 | Yong-Jun | RANimp-IMSRealTime | RP-050667 |  |  |  |
| 4651 | 1245.4 | UE Performance Requirements for MBMS (TDD) |  | 328d? | 2005-03-15 A | 2006-06-15 A | 100% | 2005-03-15 | 2006-06-15 | 328d? | finish no earlier than 2006-06-15 |  | R4 | 2624h | 2624h | MBMS-RAN-RF-TDD | IPwireless | shwong@ipwireless.com | Rel-7 | Issam | MBMS-RAN-RF-TDD | RP-060477 |  |  |  |
| 4652 | 1245.5 | Continuous connectivity for packet data users |  | 524d? | 2005-03-14 A | 2007-03-15 A | 100% | 2005-03-14 | 2007-03-15 | 524d? | finish no earlier than 2007-03-15 |  | R1 | 4192h | 4192h | RANimp-CPC | Siemens | Joern.Krause@siemens.com | Rel-7 | Patrick | RANimp-CPC | RP-070033 |  |  |  |
| 4653 | 1245.6 | Extended WCDMA Cell Range |  | 198d? | 2006-03-15 A | 2006-12-15 A | 100% | 2006-03-15 | 2006-12-15 | 198d? | finish no earlier than 2006-12-15 |  | R3 | 1584h | 1584h | RANimp-ExtCell | Ericsson | Muhammad Kazmi | Rel-7 | Juha | RANimp-ExtCell | RP-060685 |  |  |  |
| 4654 | 1245.7 | 7.68 Mcps TDD Enhanced Uplink |  | 198d? | 2006-03-15 A | 2006-12-15 A | 100% | 2006-03-15 | 2006-12-15 | 198d? | finish no earlier than 2006-12-15 |  | R1 | 1584h | 1584h | RANimp-VHCRTDD-EDCH | IPwireless | nanderson@ipwireless.com | Rel-7 | Patrick | RANimp-VHCRTDD-EDCH | RP-060684 |  |  |  |
| 4655 | 1245.8 | Enhanced CELL_FACH State in FDD |  | 181d? | 2006-09-25 A | 2007-06-04 A | 100% | 2006-09-25 | 2007-06-04 | 181d? | finish no earlier than 2007-06-04 |  | R2 | 1448h | 1448h | RANimp-EnhState | Nokia | juho.pirskanen@nokia.com | Rel-7 | Yong-Jun | RANimp-EnhState | RP-070286 |  |  |  |
| 4656 | 1245.9 | 64QAM for HSDPA (FDD) |  | 110d? | 2006-12-15 A | 2007-06-04 A | 100% | 2006-12-15 | 2007-06-04 | 110d? | finish no earlier than 2007-06-04 |  | R1 | 880h | 880h | RANimp-64QamDownlink | Ericsson | Johan.Bergman@ericsson.com | Rel-7 | Patrick | RANimp-64QamDownlink | RP-070287 |  |  |  |
| 4657 | 1245.10 | Improved L2 support for high data rates |  | 122d? | 2006-12-15 A | 2007-06-04 A | 100% | 2006-12-15 | 2007-06-04 | 122d? | finish no earlier than 2007-06-04 |  | R2 | 976h | 976h | RANimp-L2DataRates | Ericsson | Janne.Peisa@ericsson.com | Rel-7 | Yong-Jun | RANimp-L2DataRates | RP-070289 |  |  |  |
| 4658 | 1245.11 | Introduction of 16QAM in HSUPA (FDD) |  | 110d? | 2006-12-15 A | 2007-06-04 A | 100% | 2006-12-15 | 2007-06-04 | 110d? | finish no earlier than 2007-06-04 |  | R1 | 880h | 880h | RANimp-16QamUplink | Nokia | Karri.Ranta-aho@nsn.com | Rel-7 | Patrick | RANimp-16QamUplink | RP-070288 |  |  |  |

Notes:
- 4632: - / Impacted TSs and TRs: 25.101
- 4633: RP#32 completed / Impacted TSs and TRs: 25.101
- 4634: RP#34 completed / Impacted TSs and TRs: 25.101
- 4635: RP#34 completed / Impacted TSs and TRs: 25.101
- 4636: RP#34 stopped. SR in RP-060680
- 4637: This item was conditionnaly approved pending decision of PCG#16 who decided not to approve it / Impacted TSs and TRs: 25.101, 25.104, 25.133, 25.141, 25.331, 25.942, 25.306, 25.307, 34.121
- 4638: Linked to Feature UID_20028 (RInImp)
- 4639: RP#32 completed / Impacted TSs and TRs: 34.108, 34.121
- 4640: RP#32 completed / Impacted TSs and TRs: 34.108, 34.121
- 4641: RP#34 completed / Impacted TSs and TRs: 34.121, 34.108
- 4642: RP#41 completed (GERAN aspects might need to be included later) / Impacted TSs and TRs: 34.114
- 4643: RP#34 completed / Impacted TSs and TRs: 34.108, 34.123-1, 34.123-2, 34.123-3
- 4644: RP#36 completed / Impacted TSs and TRs: 34.108, 34.121-1, 34.121-2
- 4645: RP#38 completed
- 4646: RP#39 completed / Impacted TSs and TRs: 34.121-1, 34.121-2
- 4647: Generic feature
- 4648: RP#34 completed
- 4649: RP#33 completed / Impacted TSs and TRs: 25.815, 25.321, 25.322, 25.331
- 4650: RP#30 completed
- 4651: RP#32 completed / Impacted TSs and TRs: 25.102, 25.123
- 4652: RP#35 completed / Impacted TSs and TRs: 25.903, 25.201, 25.211, 25.212, 25.214, 25.308, 25.321, 25.331, 25.423, 25.433, 25.101, 25.133
- 4653: RP#34 completed / Impacted TSs and TRs: 25.133, 25.423, 25.425, 25.433, 25.435, 25.453, 25.331
- 4654: RP#34 completed / Impacted TSs and TRs: 25.201, 25.202, 25.221, 25.222, 25.223, 25.224, 25.225, 25.331, 23.321, 25.306, 25.302, 25.401, 25.420, 25.423, 25.427, 25.433, 25.102, 25.105, 25.142
- 4655: RP#36 completed / Impacted TSs and TRs: 25.308, 25.304, 25.306, 25.321, 25.331, 25.433, 25.435, 25.423, 25.425,
- 4656: RP#36 completed / Impacted TSs and TRs: 25.308, 25.211, 25.212, 25.213, 25.306, 25.331, 25.433, 25.435, 25.423, 25.425, 25.101, 25.104, 25.141
- 4657: RP#36 completed / Impacted TSs and TRs: 25.301, 25.308,25.306, 25.321, 25.322, 25.331, 25.433, 25.435, 25.423, 25.425, 25.999
- 4658: RP#36 completed / Impacted TSs and TRs: 25.319, 25.101, 25.104, 25.133, 25.141, 25.211, 25.212, 25.213, 25.214, 25.306, 25.321, 25.331, 25.423, 25.433

| ID | WBS | Task | Duration | Start | Finish | Complete | Baseline start | Baseline finish | Baseline duration | Constraint | Resources | Work | Actual work | Acronym | WI rapporteur name | WI rapporteur e-mail | Release | MCC resp | Status Report | Acronym_3GU_Export | PCG approved | TSG approved |
| --- | --- | --- | --- | --- | --- | --- | --- | --- | --- | --- | --- | --- | --- | --- | --- | --- | --- | --- | --- | --- | --- | --- |
| 4659 | 1245.12 | **Interface to control Tower Mounted Amplifiers (TMAs)** | 271d? | 2006-06-02 A | 2007-06-15 A | 100% | 2006-06-02 | 2007-06-15 | 271d? |  | R3; S5 | 5984h | 5984h | RANImp-TMA | Vodafone | alexej.kulakov@vodafone.com | Rel-7 | Juha | RP-070140 | RANImp-TMA |  |  |
| 4660 | 1245.12.1 | RAN3 part of Interface to control Tower Mounted Amplifiers (TMAs) | 206d? | 2006-06-02 A | 2007-03-16 A | 100% | 2006-06-02 | 2007-03-16 | 206d? |  | R3 | 840h | 840h |  | Vodafone | alexej.kulakov@vodafone.com | Rel-7 | Juha | RP-070140 |  |  |  |
| 4661 | 1245.12.2 | OAM aspects to Interface to control TMAs | 101d? | 2007-01-26 A | 2007-06-15 A | 100% | 2007-01-26 | 2007-06-15 | 101d? | finish no earlier than 2007-06-15 | S5 | 808h | 808h | RANImp-TMA-OAM | Vodafone | Adrian.Neal@vodafone.com | Rel-7 | Mirko |  | RANImp-TMA-OAM |  |  |
| 4662 | 1246 | **Rel-7 RAN improvements - UE Conformance Testing** | 784d? | 2006-09-20 A | 2009-09-18 A | 100% | 2006-09-20 | 2009-09-18 | 784d? |  | R5 | 25472h | 25472h |  |  |  | Rel-7 | Ingbert |  |  |  |  |
| 4663 | 1246.1 | Conformance Test Aspects - 3.84 Mcps and 7.68 Mcps TDD Enhanced Uplink | 518d? | 2006-09-20 A | 2008-09-12 A | 100% | 2006-09-20 | 2008-09-12 | 518d? | finish no earlier than 2008-09-12 | R5 | 4144h | 4144h | RANimp-UEConTest_EDCHTDH | IPWireless | tspeight@ipwireless.com | Rel-7 | Ingbert | RP-080536 | RANimp-UEConTest_EDCHTDH |  |  |
| 4664 | 1246.2 | Conformance Test Aspects – 64QAM for HSDPA (FDD) | 257d? | 2007-03-09 A | 2008-03-03 A | 100% | 2007-03-09 | 2008-03-03 | 257d? | finish no earlier than 2008-03-03 | R5 | 2056h | 2056h | RANimp-UEConTest_64QamDownlink | Ericsson | leif.mattisson@ericsson.com | Rel-7 | Ingbert | RP-080059 | RANimp-UEConTest_64QamDownlink |  |  |
| 4665 | 1246.3 | Conformance Test Aspects – 16QAM for HSUPA (FDD) | 321d? | 2007-03-09 A | 2008-05-30 A | 100% | 2007-03-09 | 2008-05-30 | 321d? | finish no earlier than 2008-05-30 | R5 | 2568h | 2568h | RANimp-UEConTest_16QamUplink | Motorola | carolyn.taylor@motorola.com | Rel-7 | Ingbert | RP-080281 | RANimp-UEConTest_16QamUplink |  |  |
| 4666 | 1246.4 | Conformance Test Aspects – Improved L2 support for high data rates | 321d? | 2007-03-09 A | 2008-05-30 A | 100% | 2007-03-09 | 2008-05-30 | 321d? | finish no earlier than 2008-05-30 | R5 | 2568h | 2568h | RANimp-UEConTest_L2DataRates | Ericsson | leif.mattisson@ericsson.com | Rel-7 | Ingbert | RP-080256 | RANimp-UEConTest_L2DataRates |  |  |
| 4667 | 1246.5 | Conformance Test Aspects – Continuous connectivity for packet data users | 321d? | 2007-03-09 A | 2008-05-30 A | 100% | 2007-03-09 | 2008-05-30 | 321d? | finish no earlier than 2008-05-30 | R5 | 2568h | 2568h | RANimp-UEConTest_CPC | Nokia | jarkko.hellsten@nokia.com | Rel-7 | Ingbert | RP-080282 | RANimp-UEConTest_CPC |  |  |
| 4668 | 1246.6 | Conformance Test Aspects – Enhanced CELL_FACH state in FDD | 662d? | 2007-03-09 A | 2009-09-18 A | 100% | 2007-03-09 | 2009-09-18 | 662d? | finish no earlier than 2009-09-18 | R5 | 5296h | 5296h | RANimp-UEConTest_EnhancedCellFACHState | Nokia | jarkko.hellsten@nokia.com | Rel-7 | Ingbert | RP-090711 | RANimp-UEConTest_EnhancedCellFACHState |  |  |
| 4669 | 1247 | **7.68 Mcps TDD option** | 783d? | 2004-09-15 A | 2007-09-14 A | 100% | 2004-09-15 | 2007-09-14 | 783d? |  | R1; R2; R3; R4; R5 | 49552h | 49552h | VHCRTDD | IPwireless | Martin Beale (mbeale@ipwireless.com) | Rel-7 | Patrick | RP-060684 | VHCRTDD |  |  |
| 4670 | 1247.1 | VHCRTDD: Stage 2 | 391d? | 2004-09-15 A | 2006-03-15 A | 100% | 2004-09-15 | 2006-03-15 | 391d? | finish no earlier than 2006-03-15 | R1 | 3128h | 3128h | VHCRTDD-Stage2 | IPwireless | Martin Beale (mbeale@ipwireless.com) | Rel-7 | Patrick | RP-060684 | VHCRTDD-Stage2 |  |  |
| 4671 | 1247.2 | VHCRTDD: Physical Layer | 391d? | 2004-09-15 A | 2006-03-15 A | 100% | 2004-09-15 | 2006-03-15 | 391d? | finish no earlier than 2006-03-15 | R1 | 3128h | 3128h | VHCRTDD-Phys | IPwireless | Martin Beale (mbeale@ipwireless.com) | Rel-7 | Patrick | RP-060684 | VHCRTDD-Phys |  |  |
| 4672 | 1247.3 | VHCRTDD: Layer 2 and layer 3 protocol aspects | 391d? | 2004-09-15 A | 2006-03-15 A | 100% | 2004-09-15 | 2006-03-15 | 391d? | finish no earlier than 2006-03-15 | R2 | 3128h | 3128h | VHCRTDD-L23 | IPwireless | drichards@ipwireless.com | Rel-7 | Yong-Jun | RP-060684 | VHCRTDD-L23 |  |  |
| 4673 | 1247.4 | VHCRTDD: UTRAN Iub/Iur Protocol Aspects | 391d? | 2004-09-15 A | 2006-03-15 A | 100% | 2004-09-15 | 2006-03-15 | 391d? | finish no earlier than 2006-03-15 | R3 | 3128h | 3128h | VHCRTDD-IurIub | IPwireless | Peter Legg (plegg@ipwireless.com) | Rel-7 | Juha | RP-060684 | VHCRTDD-IurIub |  |  |
| 4674 | 1247.5 | VHCRTDD: RF Radio Transmission/ Reception, System Performance Requirements and Conformance Testing | 457d? | 2004-09-15 A | 2006-06-15 A | 100% | 2004-09-15 | 2006-06-15 | 457d? | finish no earlier than 2006-06-15 | R4 | 3656h | 3656h | VHCRTDD-RF | IPwireless | Shin Horng Wong (shwong@ipwireless.com) | Rel-7 | Issam | RP-060684 | VHCRTDD-RF |  |  |
| 4675 | 1247.6 | Conformance Test Aspects - 7.68 Mcps TDD | 258d? | 2006-09-20 A | 2007-09-14 A | 100% | 2006-09-20 | 2007-09-14 | 258d? | finish no earlier than 2007-09-10 | R5 | 2064h | 2064h | VHCRTDD-UEConTest | IPWireless | tspeight@ipwireless.com | Rel-7 | Ingbert | RP-070307 | VHCRTDD-UEConTest |  |  |
| 4676 | 1248 | **3.84 Mcps TDD Enhanced Uplink** | 394d? | 2005-03-15 A | 2006-09-15 A | 100% | 2005-03-15 | 2006-09-15 | 394d? |  | RP | 18384h | 18384h | EDCHTDD | IPwireless | nanderson@ipwireless.com | Rel-7 |  | RP-060462 | EDCHTDD |  |  |
| 4677 | 1248.1 | EDCHTDD: Stage 2 | 328d? | 2005-03-15 A | 2006-06-15 A | 100% | 2005-03-15 | 2006-06-15 | 328d? | finish no earlier than 2006-06-15 | R2 | 2624h | 2624h | EDCHTDD-Stage2 | IPwireless | nanderson@ipwireless.com | Rel-7 | Yong-Jun | RP-060462 | EDCHTDD-Stage2 |  |  |
| 4678 | 1248.2 | EDCHTDD: Physical Layer | 394d? | 2005-03-15 A | 2006-09-15 A | 100% | 2005-03-15 | 2006-09-15 | 394d? | finish no earlier than 2006-09-15 | R1 | 3152h | 3152h | EDCHTDD-Phys | IPwireless | nanderson@ipwireless.com | Rel-7 | Patrick | RP-060462 | EDCHTDD-Phys |  |  |
| 4679 | 1248.3 | EDCHTDD: Layer 2 and 3 Protocol Aspects | 394d? | 2005-03-15 A | 2006-09-15 A | 100% | 2005-03-15 | 2006-09-15 | 394d? | finish no earlier than 2006-09-15 | R2 | 3152h | 3152h | EDCHTDD-L23 | IPwireless | drichards@ipwireless.com | Rel-7 | Yong-Jun | RP-060462 | EDCHTDD-L23 |  |  |
| 4680 | 1248.4 | EDCHTDD: UTRAN Iub/Iur Protocol Aspects | 394d? | 2005-03-15 A | 2006-09-15 A | 100% | 2005-03-15 | 2006-09-15 | 394d? | finish no earlier than 2006-09-15 | R3 | 3152h | 3152h | EDCHTDD-IurIub | Interdigital | jim.miller@interdigital.com | Rel-7 | Juha | RP-060462 | EDCHTDD-IurIub |  |  |
| 4681 | 1248.5 | EDCHTDD: RF Radio Transmission/ Reception, System Performance Requirements and Conformance Testing | 394d? | 2005-03-15 A | 2006-09-15 A | 100% | 2005-03-15 | 2006-09-15 | 394d? | finish no earlier than 2006-09-15 | R4 | 3152h | 3152h | EDCHTDD-RF | IPwireless | Shin Horng Wong (shwong@ipwireless.com) | Rel-7 | Issam | RP-060462 | EDCHTDD-RF |  |  |
| 4682 | 1249 | **1.28 Mcps TDD Enhanced Uplink** | 653d? | 2006-03-15 A | 2008-09-12 A | 100% | 2006-03-15 | 2008-09-12 | 653d? |  | R1; R2; R3; R4; R5 | 35656h | 35656h | LCRTDD-EDCH | CATT | Haijing Hu | Rel-7 | Patrick | RP-070296 | LCRTDD-EDCH |  |  |
| 4683 | 1249.1 | 1.28 Mcps TDD Enhanced Uplink: Physical Layer | 262d? | 2006-03-15 A | 2007-03-15 A | 100% | 2006-03-15 | 2007-03-15 | 262d? | finish no earlier than 2007-03-15 | R1 | 2096h | 2096h | LCRTDD-EDCH-Phys | CATT | Ke Wang | Rel-7 | Patrick | RP-070038 | LCRTDD-EDCH-Phys |  |  |
| 4684 | 1249.2 | 1.28 Mcps TDD Enhanced Uplink: Layer 2 and 3 Protocol Aspects | 262d? | 2006-03-15 A | 2007-03-15 A | 100% | 2006-03-15 | 2007-03-15 | 262d? | finish no earlier than 2007-03-15 | R2 | 2096h | 2096h | LCRTDD-EDCH-L23 | CATT | Haiyang Quan | Rel-7 | Yong-Jun | RP-070038 | LCRTDD-EDCH-L23 |  |  |
| 4685 | 1249.3 | 1.28 Mcps TDD Enhanced Uplink: UTRAN Iub/Iur Protocol Aspects | 262d? | 2006-03-15 A | 2007-03-15 A | 100% | 2006-03-15 | 2007-03-15 | 262d? | finish no earlier than 2007-03-15 | R3 | 2096h | 2096h | LCRTDD-EDCH-IubIur | CATT | Yincheng Zhang | Rel-7 | Juha | RP-070038 | LCRTDD-EDCH-IubIur |  |  |
| 4686 | 1249.4 | 1.28 Mcps TDD Enhanced Uplink: RF Radio Transmission/ Reception, System Performance Requirements and Conformance Testing | 328d? | 2006-03-15 A | 2007-06-15 A | 100% | 2006-03-15 | 2007-06-15 | 328d? | finish no earlier than 2007-06-15 | R4 | 2624h | 2624h | LCRTDD-EDCH-RF | CATT | Yuexia Song (songyuexia@catt.cn) | Rel-7 | Issam | RP-070296 | LCRTDD-EDCH-RF |  |  |
| 4687 | 1249.5 | 1.28 Mcps TDD Enhanced Uplink - UE Conformance Testing | 257d? | 2007-09-20 A | 2008-09-12 A | 100% | 2007-09-20 | 2008-09-12 | 257d? | finish no earlier than 2008-09-11 | R5 | 624h | 624h | LCRTDD-EDCH-UEConTest | CATT | chenxiaozhong@datangmobile.cn | Rel-7 | Ingbert | RP-080539 | LCRTDD-EDCH-UEConTest |  |  |
| 4688 | 1250 | Conformance Test Aspects – Multiple Band and Multiple Frequency operation for LCR TDD | 263d? | 2010-09-17 A | 2011-09-16 A | 100% | 2010-09-17 | 2011-09-16 | 263d? | finish no earlier than 2011-12-09 | R5 | 2091.37h | 2091.37h | LCRTDD_MB_MF_UEConTest | CATR | Ms Jun Chen (chenjun@catr.cn) | Rel-7 | Ingbert | RP-110968 | LCRTDD_MB_MF_UEConTest | 25 | 49 |
| 4689 | 1251 | MS Antenna Performance Evaluation Method and Requirements | 731d? | 2005-01-28 A | 2007-11-16 A | 100% | 2005-01-28 | 2007-11-16 | 731d? | finish no earlier than 2007-11-16 | GP | 5848h | 5848h | APEMR | TeliaSonera | Ulf.Tegth@teliasonera.com | Rel-7 | Paolo |  | APEMR |  |  |

Notes:
- 4659: RP#35 completed
- 4660: RP#35 completed
- 4661: SP#36 completed / Impacted TSs and TRs: 32.642, 32.643, 32.645 – Align with RAN 25.466
- 4662: Linked to Feature UID_20029 (RANimp)
- 4663: RP#41 completed / Impacted TSs and TRs: 34.108, 34.122, 34.123-1, 34.123-2, 34.123-3
- 4664: RP#39 completed / Impacted TSs and TRs: 34.108, 34.121-1, 34.121-2, 34.123-1, 34.123-2, 34.123-3
- 4665: RP#40 completed / Impacted TSs and TRs: 34.108, 34.121-1, 34.121-2, 34.123-1, 34.123-2, 34.123-3
- 4666: RP#40 completed / Impacted TSs and TRs: 34.108, 34.123-1, 34.123-2, 34.123-3
- 4667: RP#40 completed / Impacted TSs and TRs: 34.108, 34.121-1, 34.121-2, 34.123-1, 34.123-2, 34.123-3
- 4668: RP#45 completed / Impacted TSs and TRs: 34.108, 34.123-1, 34.123-2, 34.123-3
- 4669: RP#31 completed
- 4670: RP#31 completed / Impacted TSs and TRs: 25.202
- 4671: RP#31 completed / Impacted TSs and TRs: 25.221, 25.222, 25.223, 25.224,25.225
- 4672: RP#31 completed / Impacted TSs and TRs: 25.301, 25.302, 25.305, 25.306, 25.321, 25.331
- 4673: RP#31 completed / Impacted TSs and TRs: 25.401, 25.420, 25.423, 25.425, 25.427, 25.430, 25.433, 25.435
- 4674: RP#32 completed / Impacted TSs and TRs: 25.102, 25.105, 25.123, 25.133, 25.142
- 4675: RP#37 completed / Impacted TSs and TRs: 34.108, 34.122, 34.123-1, 34.123-2, 34.123-3
- 4676: RP#33 completed
- 4677: RP#33 completed
- 4678: RP#33 completed / Impacted TSs and TRs: 25.201, 25.221,25.222, 25.223, 25.224, 25.225
- 4679: RP#33 completed / Impacted TSs and TRs: 25.301, 25.302, 25.306, 25.321, 25.331
- 4680: RP#33 completed / Impacted TSs and TRs: 25.401, 25.420, 25.423, 25.427, 25.430, 25.433, 25.435
- 4681: RP#33 completed / Impacted TSs and TRs: 25.102, 25.105, 25.123, 25.142
- 4682: RP#35 completed
- 4683: RP#35 completed / Impacted TSs and TRs: 25.201, 25.221, 25.222, 25.223, 25.224, 25.225
- 4684: RP#35 completed / Impacted TSs and TRs: 25.301, 25.302, 25.306, 25.321, 25.331
- 4685: RP#35 completed / Impacted TSs and TRs: 25.401, 25.420, 25.423, 25.425, 25.427, 25.430, 25.433, 25.435
- 4686: RP#36 completed / Impacted TSs and TRs: 25.102, 25.105, 25.123, 25.142
- 4687: RP#41 completed / Impacted TSs and TRs: 34.108, 34.122, 34.123-1/2/3
- 4688: RP#53 completed. Core specification was introduced via Rel-7 CR under TEI7 (RP#37 RP-070650) and via 2 Rel-8 work items: RInImp9-UMTS1880TDD and RInImp8-UMTS2300TDD. / Impacted TSs and TRs: UTRA 34.108, 34.123-1, 34.123-2, 34.123-3
- 4689: GP#36 completed for R7 / Impacted TSs and TRs: 25.914, 25.144, 45.005

| ID | WBS | Task | Type | Duration | Start | Finish | Complete | Remaining | Baseline start | Baseline finish | Baseline duration | Total slack | Constraint | Resources | Work | Actual work | Acronym | WI rapporteur name | WI rapporteur e-mail | Release | MCC resp | Acronym_3GU_Export | TSG stopped |
| --- | --- | --- | --- | --- | --- | --- | --- | --- | --- | --- | --- | --- | --- | --- | --- | --- | --- | --- | --- | --- | --- | --- | --- |
| 4690 | 1252 | **Lower 700 MHz Inclusion in the GERAN Specifications** |  | 390d? | 2005-01-03 A | 2006-06-30 | 99% | 0d? | 2005-01-03 | 2006-06-30 | 390d? | 0d |  | GP | 11112h | 9372h | GSM710 | UTC | dcotton@mtview.union-tel.com | Rel-7 | Paolo | GSM710 |  |
| 4691 | 1252.1 | Inclusion of the 698 – 746 MHz band into GERAN core specifications |  | 129d? | 2005-01-03 A | 2005-06-30 A | 100% |  | 2005-01-03 | 2005-06-30 | 129d? |  | finish no earlier than 2005-06-30 | G1 | 1032h | 1032h | GSM710-core |  |  | Rel-7 | Paolo | GSM710-core |  |
| 4692 | 1252.2 | **Aspects of GSM710** |  | 217.5d? | 2005-08-31 A | 2006-06-30 | 100% | 0d? | 2005-08-31 | 2006-06-30 | 217.5d? | 0d |  | G1; G3new | 6960h | 5220h | GSM-710-test |  |  | Rel-7 | Paolo | GSM-710-test |  |
| 4693 | 1252.2.1 | G1 aspects of GSM710 |  | 217.5d? | 2005-08-31 A | 2006-06-30 A | 100% |  | 2005-08-31 | 2006-06-30 | 217.5d? |  | finish no earlier than 2006-06-30 | G1 | 1740h | 1740h |  |  |  | Rel-7 | Paolo |  |  |
| 4694 | 1252.2.2 | G3 aspects of GSM710 |  | 217.5d? | 2005-08-31 A | 2006-06-30 A | 100% |  | 2005-08-31 | 2006-06-30 | 217.5d? |  | finish no earlier than 2006-06-30 | G3new | 1740h | 1740h |  |  |  | Rel-7 | Ingbert |  |  |
| 4695 | 1253 | **Support of Conversational Services in A/Gb mode via the PS domain** |  | 626d? | 2005-04-08 A | 2007-08-31 A | 100% |  | 2005-04-08 | 2007-08-31 | 626d? |  |  | GP | 15442.8h | 15442.8h | SCSAGB | Ericsson | gunnar.hedby@ericsson.com | Rel-7 | Paolo | SCSAGB |  |
| 4696 | 1253.1 | Minimise the transfer delay between the SGSN and the MS |  | 604.95d? | 2005-04-08 A | 2007-08-31 A | 100% |  | 2005-04-08 | 2007-08-31 | 604.95d? |  | finish no earlier than 2007-08-31 | GP | 4839.6h | 4839.6h | SCSAGB-MTD | Ericsson | gunnar.hedby@ericsson.com | Rel-7 | Paolo | SCSAGB-MTD |  |
| 4697 | 1253.2 | Definition of radio resource management functionality for Support of Conversational Services in A/Gb mode via the PS domain |  | 626d? | 2005-04-08 A | 2007-08-31 A | 100% |  | 2005-04-08 | 2007-08-31 | 626d? |  | finish no earlier than 2007-08-31 | G1 | 5008h | 5008h | SCSAGB-RRM | Ericsson | gunnar.hedby@ericsson.com | Rel-7 | Paolo | SCSAGB-RRM |  |
| 4698 | 1253.3 | Support of Conversational Services in A/Gb mode via the PS domain – RLC Non-Persistent mode |  | 101d? | 2006-06-30 A | 2006-11-17 A | 100% |  | 2006-06-30 | 2006-11-17 | 101d? |  | finish no earlier than 2006-11-17 | G2 | 808h | 808h | SCSAGB-RLCNP | Ericsson | gunnar.hedby@ericsson.com | Rel-7 | Gert | SCSAGB-RLCNP |  |
| 4699 | 1253.4 | Deleted- Radio Channel Support | milestone | 0d? | 2006-07-17 A | 2006-07-17 A | 100% |  | 2006-07-17 | 2006-07-17 | 0d? |  | start no earlier than 2006-07-17 | G2 |  |  | SCSAGB-RCHS | Ericsson | gunnar.hedby@ericsson.com | Rel-7 | Gert | SCSAGB-RCHS | SP-32 |
| 4700 | 1253.5 | Deleted- Modifications to FLO | milestone | 0d? | 2006-07-17 A | 2006-07-17 A | 100% |  | 2006-07-17 | 2006-07-17 | 0d? |  | start no earlier than 2006-07-17 | G2 |  |  | SCSAGB-FLO | Ericsson | gunnar.hedby@ericsson.com | Rel-7 | Gert | SCSAGB-FLO | SP-32 |
| 4701 | 1254 | **Addition of new frequency band to GSM (T-GSM810)** |  | 626d? | 2005-04-08 A | 2007-08-31 A | 100% |  | 2005-04-08 | 2007-08-31 | 626d? |  |  | GP | 12112h | 12112h | TGSM810 | Huawei | chende@huawei.com | Rel-7 | Paolo | TGSM810 |  |
| 4702 | 1254.1 | Changes to core specification |  | 106d? | 2005-04-08 A | 2005-09-02 A | 100% |  | 2005-04-08 | 2005-09-02 | 106d? |  | finish no earlier than 2005-09-02 | GP | 848h | 848h | TGSM810-Core | Huawei | chende@huawei.com | Rel-7 | Paolo | TGSM810-Core |  |
| 4703 | 1254.2 | Changes to MS testing specification |  | 626d? | 2005-04-08 A | 2007-08-31 A | 100% |  | 2005-04-08 | 2007-08-31 | 626d? |  | finish no earlier than 2007-08-31 | G3new | 5008h | 5008h | TGSM810-MStest | Huawei | chende@huawei.com | Rel-7 | Ingbert | TGSM810-MStest |  |
| 4704 | 1254.3 | Changes to BTS testing specification |  | 156d? | 2005-04-08 A | 2005-11-11 A | 100% |  | 2005-04-08 | 2005-11-11 | 156d? |  | finish no earlier than 2005-11-11 | G1 | 1248h | 1248h | TGSM810-BTStest | Huawei | chende@huawei.com | Rel-7 | Paolo | TGSM810-BTStest |  |
| 4705 | 1255 | **Handover of dedicated and shared resources while in Dual Transfer Mode** |  | 421d? | 2005-04-08 A | 2006-11-17 A | 100% |  | 2005-04-08 | 2006-11-17 | 421d? |  |  | GP | 12672h | 12672h | HODSRDTM | Nokia | rami.vaittinen@nokia.com | Rel-7 | Paolo | HODSRDTM |  |
| 4706 | 1255.1 | GERAN2 part of Handover of dedicated and shared resources while in Dual Transfer Mode |  | 321d? | 2005-04-08 A | 2006-06-30 A | 100% |  | 2005-04-08 | 2006-06-30 | 321d? |  | finish no earlier than 2006-06-30 | G2 | 2568h | 2568h | HODSRDTM-G2 | Nokia | rami.vaittinen@nokia.com | Rel-7 | Gert | HODSRDTM-G2 |  |
| 4707 | 1255.2 | Deleted - MS Conformance Testing |  | 421d? | 2005-04-08 A | 2006-11-17 A | 100% |  | 2005-04-08 | 2006-11-17 | 421d? |  | finish no earlier than 2006-11-17 | G3new | 3368h | 3368h | HODSRDTM-MStest | Nokia | rami.vaittinen@nokia.com | Rel-7 | Ingbert | HODSRDTM-MStest | GP-32 |
| 4708 | 1255.3 | Deleted - BTS conformance testing |  | 421d? | 2005-04-08 A | 2006-11-17 A | 100% |  | 2005-04-08 | 2006-11-17 | 421d? |  | finish no earlier than 2006-11-17 | G1 | 3368h | 3368h | HODSRDTM-BTStest | Nokia | rami.vaittinen@nokia.com | Rel-7 | Paolo | HODSRDTM-BTStest | GP-32 |
| 4709 | 1256 | **Mobile Station Receive Diversity (DARP Phase II)** |  | 526d? | 2005-11-11 A | 2007-11-16 A | 100% |  | 2005-11-11 | 2007-11-16 | 526d? |  |  | GP | 16360h | 16360h | MSRD2 | Nokia | kent.pedersen@nokia.com | Rel-7 | Paolo | MSRD2 |  |
| 4710 | 1256.1 | Performance Requirements for Mobile Station Receive Diversity, DARP Phase II |  | 331d? | 2005-11-11 A | 2007-02-16 A | 100% |  | 2005-11-11 | 2007-02-16 | 331d? |  | finish no earlier than 2007-02-16 | GP | 2648h | 2648h | MSRD2-PerfReq | Nokia | kent.pedersen@nokia.com | Rel-7 | Paolo | MSRD2-PerfReq |  |
| 4711 | 1256.2 | Capability signalling of Mobile Station Receive Diversity, DARP Phase II |  | 331d? | 2005-11-11 A | 2007-02-16 A | 100% |  | 2005-11-11 | 2007-02-16 | 331d? |  | finish no earlier than 2007-02-16 | GP | 2648h | 2648h | MSRD2-CapSig | Nokia | kent.pedersen@nokia.com | Rel-7 | Paolo | MSRD2-CapSig |  |
| 4712 | 1256.3 | Test Scenarios for Mobile Station Receive Diversity, DARP Phase II |  | 331d? | 2005-11-11 A | 2007-02-16 A | 100% |  | 2005-11-11 | 2007-02-16 | 331d? |  | finish no earlier than 2007-02-16 | GP | 2648h | 2648h | MSRD2-TestSc | Nokia | kent.pedersen@nokia.com | Rel-7 | Paolo | MSRD2-TestSc |  |
| 4713 | 1256.4 | MS conformance test of DARP Phase II (MSRD) |  | 526d? | 2005-11-11 A | 2007-11-16 A | 100% |  | 2005-11-11 | 2007-11-16 | 526d? |  | finish no earlier than 2007-11-16 | GP | 4208h | 4208h | MSRD2-Msconf | Nokia | kent.pedersen@nokia.com | Rel-7 | Ingbert | MSRD2-Msconf |  |

Notes:
- 4690: -
- 4691: Completed / Impacted TSs and TRs: 24.008, 43.022, 44.018, 44.118, 45, 001, 45.005,
- 4692: -
- 4693: - / Impacted TSs and TRs: 51.021
- 4694: - / Impacted TSs and TRs: 51.010
- 4695: Originally started Nov. 2003 as GP-030443
- 4696: -
- 4697: -
- 4698: - / Impacted TSs and TRs: 43.955, 43.064, 44.060, 45.001, 45.002, 45.003, 45.005, 45.010, 51.010, 51.021
- 4699: -
- 4700: -
- 4701: - / Impacted TSs and TRs: 45.005, 45.050, 24.008, 45.008, 45.001, 43.022, 43.030, 44.018, 44.060, 51.010-1, 51.021
- 4702: - / Impacted TSs and TRs: 45.005, 45.050, 24.008, 45.008, 45.001, 43.022, 43.030, 44.018, 44.060
- 4703: - / Impacted TSs and TRs: 51010-1
- 4704: - / Impacted TSs and TRs: 51021
- 4705: GP#30 completed. Started at GP#24
- 4706: GP#30 completed / Impacted TSs and TRs: 43.055, 44.018, 44.060
- 4707: Stopped, no work done. 12/2008 Marked as stopped ("deleted") / Impacted TSs and TRs: 51-010
- 4708: Stopped, no work done. 12/2008 Marked as stopped ("deleted") / Impacted TSs and TRs: 51.026
- 4709: GP#36 completed
- 4710: GP#33 completed / Impacted TSs and TRs: 45.005
- 4711: GP#33 completed / Impacted TSs and TRs: 24.008
- 4712: GP#33 completed / Impacted TSs and TRs: 45.005
- 4713: GP#36 completed / Impacted TSs and TRs: 51.010

| ID | WBS | Task | Type | Duration | Start | Finish | Complete | Remaining | Baseline start | Baseline finish | Baseline duration | Total slack | Constraint | Resources | Work | Actual work | Acronym | WI rapporteur name | WI rapporteur e-mail | Release | MCC resp | Acronym_3GU_Export | TSG stopped |
| --- | --- | --- | --- | --- | --- | --- | --- | --- | --- | --- | --- | --- | --- | --- | --- | --- | --- | --- | --- | --- | --- | --- | --- |
| 4714 | 1257 | **Downlink Dual Carrier** |  | 947d? | 2006-01-20 A | 2009-09-04 A | 100% |  | 2006-01-20 | 2009-09-04 | 947d? |  |  | GP | 15446.6h | 15446.6h | GDCDL | Nokia Siemens Networks | leonardo.provvedi@roke.co.uk | Rel-7 | Paolo | GDCDL |  |
| 4715 | 1257.1 | Downlink Dual Carrier Stage 2 |  | 116d? | 2006-01-20 A | 2006-06-30 A | 100% |  | 2006-01-20 | 2006-06-30 | 116d? |  | finish no earlier than 2006-06-30 | G1 | 928h | 928h | GDCDL-Stage2 | Nokia Siemens Networks | leonardo.provvedi@roke.co.uk | Rel-7 | Paolo | GDCDL-Stage2 |  |
| 4716 | 1257.2 | Downlink Dual Carrier Stage 3 |  | 421d? | 2006-01-20 A | 2007-08-31 A | 100% |  | 2006-01-20 | 2007-08-31 | 421d? |  | finish no earlier than 2007-08-31 | G1 | 3368h | 3368h | GDCDL-Stage3 | Nokia Siemens Networks | leonardo.provvedi@roke.co.uk | Rel-7 | Paolo | GDCDL-Stage3 |  |
| 4717 | 1257.3 | Downlink Dual Carrier – MS Conformance Test |  | 446.82d? | 2006-01-20 A | 2009-09-04 A | 100% |  | 2006-01-20 | 2009-09-04 | 446.82d? |  | finish no earlier than 2009-09-04 | G3new | 3574.6h | 3574.6h | GDCDL-MStest | Nokia Siemens Networks | leonardo.provvedi@roke.co.uk | Rel-7 | Ingbert | GDCDL-MStest |  |
| 4718 | 1258 | Support of SIGTRAN in GERAN |  | 116d? | 2006-01-20 A | 2006-06-30 A | 100% |  | 2006-01-20 | 2006-06-30 | 116d? |  | finish no earlier than 2006-06-30 | GP | 928h | 928h | GSIGT | Ericsson | peter.ostrup@ericsson.com | Rel-7 | Ingbert | GSIGT |  |
| 4719 | 1259 | **Latency Reductions** |  | 306d? | 2006-06-30 A | 2007-08-31 A | 100% |  | 2006-06-30 | 2007-08-31 | 306d? |  |  | GP | 7344h | 7344h | LATRED | Ericsson | Hakan.Persson@Ericsson.com | Rel-7 | Paolo | LATRED |  |
| 4720 | 1259.1 | Improved Ack/Nack reporting |  | 306d? | 2006-06-30 A | 2007-08-31 A | 100% |  | 2006-06-30 | 2007-08-31 | 306d? |  | finish no earlier than 2007-08-31 | G2 | 2448h | 2448h | LATRED-ACKNAR | Ericsson | Hakan.Persson@Ericsson.com | Rel-7 | Gert | LATRED-ACKNAR |  |
| 4721 | 1259.2 | Reduced TTI |  | 306d? | 2006-06-30 A | 2007-08-31 A | 100% |  | 2006-06-30 | 2007-08-31 | 306d? |  | finish no earlier than 2007-08-31 | G2 | 2448h | 2448h | LATRED-REDTTI | Ericsson | Hakan.Persson@Ericsson.com | Rel-7 | Gert | LATRED-REDTTI |  |
| 4722 | 1260 | PS Handover between GERAN/UTRAN mode and GAN Mode |  | 166d? | 2006-06-30 A | 2007-02-16 A | 100% |  | 2006-06-30 | 2007-02-16 | 166d? |  | finish no earlier than 2007-02-16 | G2 | 1328h | 1328h | GUGAN | Ericsson | John.Diachina@Ericsson.com | Rel-7 | Gert | GUGAN |  |
| 4723 | 1261 | **Higher Uplink performance for GERAN Evolution** |  | 1227d? | 2006-09-08 A | 2011-05-20 A | 100% |  | 2006-09-08 | 2011-05-20 | 1227d? |  |  | GP | 37184h | 37184h | HUGE | Nokia Siemens Networks, Ericsson | eddie.riddington@nokia.com, stefan.g.eriksson@ericsson.com | Rel-7 | Paolo | HUGE |  |
| 4724 | 1261.1 | Stage 2 for HUGE |  | 261d? | 2006-09-08 A | 2007-09-07 A | 100% |  | 2006-09-08 | 2007-09-07 | 261d? |  | finish no earlier than 2007-09-07 | G1 | 2088h | 2088h | HUGE-Stage2 | Nokia Siemens Networks, Ericsson | eddie.riddington@nokia.com, stefan.g.eriksson@ericsson.com | Rel-7 | Paolo | HUGE-Stage2 |  |
| 4725 | 1261.2 | Layer 1 Support for HUGE |  | 381d? | 2006-09-08 A | 2008-02-22 A | 100% |  | 2006-09-08 | 2008-02-22 | 381d? |  | finish no earlier than 2008-02-22 | G1 | 3048h | 3048h | HUGE-Layer1 | Nokia Siemens Networks, Ericsson | eddie.riddington@nokia.com, stefan.g.eriksson@ericsson.com | Rel-7 | Paolo | HUGE-Layer1 |  |
| 4726 | 1261.3 | Layer 2/3 Support for HUGE |  | 256d? | 2006-09-08 A | 2007-08-31 A | 100% |  | 2006-09-08 | 2007-08-31 | 256d? |  | finish no earlier than 2007-08-31 | G2 | 2048h | 2048h | HUGE-Layer23 | Nokia Siemens Networks, Ericsson | eddie.riddington@nokia.com, stefan.g.eriksson@ericsson.com | Rel-7 | Gert | HUGE-Layer23 |  |
| 4727 | 1261.4 | Performance requirements for HUGE |  | 516d? | 2006-09-08 A | 2008-08-29 A | 100% |  | 2006-09-08 | 2008-08-29 | 516d? |  | finish no earlier than 2008-08-29 | G1 | 4128h | 4128h | HUGE-Perfreq | Nokia Siemens Networks, Ericsson | eddie.riddington@nokia.com, stefan.g.eriksson@ericsson.com | Rel-7 | Paolo | HUGE-Perfreq |  |
| 4728 | 1261.5 | BTS Conformance Test for HUGE |  | 782d? | 2006-09-08 A | 2009-09-04 A | 100% |  | 2006-09-08 | 2009-09-04 | 782d? |  | finish no earlier than 2009-09-04 | G1 | 6248h | 6248h | HUGE-BTStest | Nokia Siemens Networks, Ericsson | eddie.riddington@nokia.com, stefan.g.eriksson@ericsson.com | Rel-7 | Paolo | HUGE-BTStest |  |
| 4729 | 1261.6 | MS Conformance Test for HUGE |  | 1226d? | 2006-09-08 A | 2011-05-20 A | 100% |  | 2006-09-08 | 2011-05-20 | 1226d? |  | finish no earlier than 2011-05-20 | G3new | 9808h | 9808h | HUGE-Mstest | Nokia Siemens Networks, Ericsson | eddie.riddington@nokia.com, stefan.g.eriksson@ericsson.com | Rel-7 | Ingbert | HUGE-Mstest |  |
| 4730 | 1262 | **REduced symbol Duration, Higher Order modulation and Turbo coding (RED HOT) for downlink** |  | 1177d? | 2006-11-17 A | 2011-05-20 A | 100% |  | 2006-11-17 | 2011-05-20 | 1177d? |  |  | GP | 28808h | 28808h | REDHOT | Ericsson, Nokia Siemens Networks, Marvell | stefan.g.eriksson@ericsson.com | Rel-7 | Paolo | REDHOT |  |
| 4731 | 1262.1 | Stage 2 for REDHOT |  | 206d? | 2006-11-17 A | 2007-08-31 A | 100% |  | 2006-11-17 | 2007-08-31 | 206d? |  | finish no earlier than 2007-08-31 | G1 | 1648h | 1648h | REDHOT-Stage2 | Ericsson, Nokia Siemens Networks, Marvell | stefan.g.eriksson@ericsson.com | Rel-7 | Paolo | REDHOT-Stage2 |  |
| 4732 | 1262.2 | Stage 3 for REDHOT |  | 391d? | 2006-11-17 A | 2008-05-16 A | 100% |  | 2006-11-17 | 2008-05-16 | 391d? |  | finish no earlier than 2008-05-16 | G1 | 3128h | 3128h | REDHOT-Stage3 | Ericsson, Nokia Siemens Networks, Marvell | stefan.g.eriksson@ericsson.com | Rel-7 | Paolo | REDHOT-Stage3 |  |
| 4733 | 1262.3 | BTS Conformance Tests for REDHOT |  | 651d? | 2006-11-17 A | 2009-05-15 A | 100% |  | 2006-11-17 | 2009-05-15 | 651d? |  | finish no earlier than 2009-05-15 | G1 | 5208h | 5208h | REDHOT-BTStest | Ericsson, Nokia Siemens Networks, Marvell | stefan.g.eriksson@ericsson.com | Rel-7 | Paolo | REDHOT-BTStest |  |
| 4734 | 1262.4 | MS Conformance Tests for REDHOT |  | 1176d? | 2006-11-17 A | 2011-05-20 A | 100% |  | 2006-11-17 | 2011-05-20 | 1176d? |  | finish no earlier than 2011-05-20 | G3new | 9408h | 9408h | REDHOT-Mstest | Ericsson, Nokia Siemens Networks, Marvell | stefan.g.eriksson@ericsson.com | Rel-7 | Ingbert | REDHOT-Mstest |  |
| 4735 | 1263 | (Small) Technical Enhancements and Improvements for Rel-7 | milestone | 0d? | 2007-03-26 A | 2007-03-26 A | 100% |  | 2007-03-26 | 2007-03-26 | 0d? |  | start no earlier than 2007-03-26 | SP; CP; RP; GP |  |  | TEI7 |  |  | Rel-7 | All | TEI7 |  |
| 4736 | 1264 | Test - (Small) Technical Enhancements and Improvements for Rel-7 |  | 389d? | 2006-06-02 A | 2007-11-28 A | 100% |  | 2006-06-02 | 2007-11-28 | 389d? |  | finish no earlier than 2010-06-04 | R5 | 3112h | 3112h | TEI7_Test |  |  | Rel-7 | Ingbert | TEI7_Test |  |
| 4737 | 1265 | **Deleted - PS domain and IMS support for IMS Emergency sessions** |  | 63.69d? | 2006-06-23 A | 2006-09-21 | 99% | 0d? | 2006-06-23 | 2006-09-21 | 63.69d? | 0d |  | S2 |  |  | IMS-EMER | Nokia | curt.c.wong@nokia.com | Rel-7 | Maurice | IMS-EMER | SP-30 |
| 4738 | 1265.1 | Deleted - IMS aspects to support IMS Emergency sessions | milestone | 0d? | 2006-06-23 A | 2006-09-21 A | 100% |  | 2006-06-23 | 2006-09-21 | 0d? |  | start no earlier than 2006-06-23 | S2 |  |  |  | Nokia | curt.c.wong@nokia.com | Rel-7 | Maurice |  | SP-30 |
| 4739 | 1265.2 | Deleted - PS domain aspects to support IMS Emergency sessions | milestone | 0d? | 2006-06-23 A | 2006-09-21 A | 100% |  | 2006-06-23 | 2006-09-21 | 0d? |  | start no earlier than 2006-06-23 | S2 |  |  |  | Nokia | curt.c.wong@nokia.com | Rel-7 | Maurice |  | SP-30 |

Notes:
- 4714: GP#35 completed
- 4715: GP#30 completed / Impacted TSs and TRs: 43.055, 43.064
- 4716: GP#35 completed / Impacted TSs and TRs: 24.008, 44.018, 44.060, 45.001, 45.002, 45.005, 45.008
- 4717: GP#43 completed / Impacted TSs and TRs: 51.010
- 4718: GP#30 completed / Impacted TSs and TRs: 48.001, 48.006, 43.059, 49.031
- 4719: GP#35 completed / Impacted TSs and TRs: 45.001, 45.002, 45.003, 45.005, 45.010, 43.055, 43.064, 44.060, 51.010-1, 51.021
- 4720: GP#35 completed / Impacted TSs and TRs: 45.001, 45.002, 45.003, 45.005, 45.010, 43.055, 43.064, 44.060, 51.010-1, 51.021
- 4721: GP#35 completed / Impacted TSs and TRs: 45.001, 45.002, 45.003, 45.005, 45.010, 43.055, 43.064, 44.060, 51.010-1, 51.021
- 4722: GP#33 completed / Impacted TSs and TRs: 43.318, 44.318, 43.129, 25.306, 24.008, 44.060, 25.331, 51.010
- 4723: GP#39 completed
- 4724: GP#35 completed / Impacted TSs and TRs: 43.055, 43.064
- 4725: GP#37 completed / Impacted TSs and TRs: 45.001, 45.002, 45.003, 45.004, 45.008
- 4726: GP#35 completed / Impacted TSs and TRs: 24.008, 44.018, 44.060
- 4727: GP#39 completed / Impacted TSs and TRs: 45.005
- 4728: GP#43 completed / Impacted TSs and TRs: 51.021
- 4729: GP#50 completed / Impacted TSs and TRs: 51.010
- 4730: GP#38 completed
- 4731: GP#35 completed / Impacted TSs and TRs: 43.055, 43.064
- 4732: GP#38 completed / Impacted TSs and TRs: 24.008, 44.018, 44.060, 45.001, 45.002, 45.003, 45.004, 45.005, 45.008
- 4733: GP#42 completed / Impacted TSs and TRs: 51.021
- 4734: GP#50 completed / Impacted TSs and TRs: 51.010
- 4735: -
- 4736: -
- 4737: Approved at SP#29 / Impacted TSs and TRs: 23.867, 23.abc, 23.060, 23.002, 23.271
- 4738: Approved at SP#29 / Impacted TSs and TRs: 23.867, 23.abc, 23.060, 23.002, 23.271
- 4739: Approved at SP#29 / Impacted TSs and TRs: 23.867, 23.abc, 23.060, 23.002, 23.271
